# 3GPP_Release-2000

Schedule from MS Project, 1999-01-01 to 2017-06-14, A marks actual dates.

## Calendars

- Standard: Mon-Fri 08:00-12:00, 13:00-17:00; Sat-Sun off. Exceptions (off unless hours are given): 2000-01-15 08:00-12:00, 13:00-17:00, 2009-05-30 08:00-12:00, 13:00-17:00, 2011-08-27 to 2011-08-28 08:00-12:00, 13:00-17:00, 2011-09-24 08:00-12:00, 13:00-17:00, 2012-06-02 08:00-12:00, 13:00-17:00, 2012-09-01 08:00-12:00, 13:00-17:00, 2012-11-18 08:00-12:00, 13:00-17:00, 2012-11-24 08:00-12:00, 13:00-17:00, 2013-02-16 08:00-12:00, 13:00-17:00, 2013-06-02 08:00-12:00, 13:00-17:00, 2013-08-10 to 2013-08-11 08:00-12:00, 13:00-17:00, 2013-09-14 08:00-12:00, 13:00-17:00, 2014-03-01 08:00-12:00, 13:00-17:00, 2014-08-24 08:00-12:00, 13:00-17:00, 2014-09-21 08:00-12:00, 13:00-17:00, 2014-10-05 08:00-12:00, 13:00-17:00, 2016-06-18 08:00-12:00, 13:00-17:00.

## Resources

| Resource |
| --- |
| NP |
| N1 |
| N2 |
| N3 |
| N4 |
| N5 |
| TP |
| T1 |
| T2 |
| T3 |
| RP |
| R1 |
| R2 |
| R3 |
| R4 |
| SP |
| S1 |
| S2 |
| S3 |
| S4 |
| S5 |
| PCG |
| GP |
| No |
| CN4 |
| ? |
| WG G2 |
| G2 |
| G1 |
| G4 |
| G3 |
| All |
| Generic |
| MLST |
| G5 |
| S3, G2 |
| WG T2 |
| GP,G1 |
| G4,G5 |
| OMA |
| GP-G2 |
| Yes |
| GP, |
| N4, |
| GP, N1 |
| CT5 |
| C5 |
| C1 |
| C4 |
| C3 |
| C6 |
| G1, |
| 4 |
| ct |
| c,s,r |
| CT,RAN,SA |
| G2, |
| G1, G3 |
| CT6 |
| CT1 |
| CT1, CT3, CT4 |
| C1, C3, C4 |
| CP |
| R5 |
| C |
| Rel-8 |
| GP, G2 |
| R1,R4 |
| S5,C1 |
| CT,RAN,SA,GERAN |
| S3,C1,C4 |
| 5 |
| S1,C1,C3,C4,S5 |
| S1,C1,C3,C5 |
| S1,C1,C3,C4 |
| S1,S5 |
| S2,S3 |
| RAN,SA |
| RP,S5 |
| S2,CT |
| S1,CT |
| S1,CT,GERAN |
| S1,C5 |
| S3,CT |
| S4,CT |
| C1,SA |
| S1,S2 |
| S1,S4 |
| S2,S2,S3,CT |
| S2,S3,CT |
| S1,CT,GX |
| S1,S4,CT |
| S2,S2,S3,S5,CT |
| S1,S2,CT |
| S1,S2,S3,CT |
| S1,S2,S3,S5CT |
| S1,S2,S3,S5,CT |
| S2,S5,CT |
| S4,S3 |
| S1,C1 |
| CP,C1 |
| C1,C3 |
| C1,C3,C4 |
| S1,S5,CT |
| C4,C3 |
| CP,RAN,SA,GERAN |
| S1,S2,S3,S5,CP |
| S2,S3,CP |
| S2,CP |
| S1,CP,GX |
| S1,CP |
| S1,S4,CP |
| S1,S2,CP |
| S1,S2,S3,CP |
| S2,S5,CP |
| S3,CP |
| S1,S5,CP |
| RAN,SA,GERAN |
| S1,S2,S3,S5,C1,C3,C4,C6 |
| S2,S3,C1,C3,C4 |
| S2,C4 |
| S2,C1,C3,C4 |
| S2,C1,C4 |
| S2,S3,C1,C4 |
| S1,C1,C4,G2 |
| C1,C4 |
| S1,C1,C3 |
| S1,S4,C1,C3,C4 |
| S1,S2,S3,C1,C3,C4 |
| S2,S5,C3 |
| S1,S2,C1,C4 |
| S2,C1 |
| S2,C1,C3 |
| S3,C1,C3,C4 |
| S1,S5,C1,C3,C4 |
| S2,C3,C4 |
| C3,C1 |
| R2,R4 |
| R2,R5 |
| RP,R5 |
| RP,S5,R5 |
| R1,R5 |
| S1,C1,R5 |
| S1,C1,S4,R5 |
| GERAN |
| G3new |
| G1, G3new |
| C4,C1,C3 |
| R1.R4 |
| R1, R4 |
| R2,R3 |
| C3,C4 |
| S4,C3 |
| S4,C3,C1,C4 |
| S1,S2,C1 |
| S1,S2<C1,C3,C4 |
| S1,S2,C1,C3,C4 |
| S5,C1,C3,C4 |
| GP,C4 |
| C4,C1 |
| S2,S1 |
| RP,SP,GP |
| RP,SP,CP,GP |
| CP,GP,RP,SP |
| GP,C4,S4 |
| S1,C1,C4 |
| S1,S2,C3,C1 |
| R2,R4,R3 |
| CP,GP, RP,SP |
| S2,S1,C1,S5 |
| S2,S1,C1 |
| S1,C1,S4 |
| S1,S2,GP,C4,R2 |
| S1,GP,R2 |
| S1,C6 |
| S1,S2,C1,S4 |
| S2,S3,S5,C1,C3,C4 |
| S2,S5,C1 |
| S2,S3,S5 |
| CP,GP, RP,SP,TP |
| S2,C4,C1 |
| S1,C1,C4,S3 |
| S2,S5 |
| S3,C1 |
| S3,C4 |
| S1,C4 |
| S2,S5,C3,C1 |
| S2,S1,S5,C1,C4 |
| S1,R1,C3 |
| S1,C1,R2 |
| S2,S1,C1,C4 |
| S1,C1,C6 |
| GP,S4,C4,C1,C3 |
| C3,C1,C4 |
| S1,C4,C1 |
| S1,S3 |
| S1,S2,S5,C3,C4 |
| R4,G1 |
| G1,R4 |
| RP,GP |
| R4,GP |
| R3,R2 |
| C6,RP,SP |
| R5,C6 |
| CP,RP,SP |
| RP,SP,CP |
| R3,S5 |
| S1,S2,RP |
| S1,S2,S5,RP |
| S2,S1,RP |
| Rel-9 |
| S3,C6 |
| S1,S2,S3,S5,RP |
| S2,S1,S3 |
| S1,S2,S3 |
| S1,S2,S3,S5 |
| C6,R5 |
| S1,S2,RP,GP |
| S1,S2,S4,S5,RP,GP |
| GP,G2 |
| GP,GP, N1 |
| GP,S2,G1,G2 |
| GP,R2,R3,S2,G1,G2 |
| GP,S2,S5,R2,R3,G2,G1 |
| GP,R3 |
| N4,S2 |
| GP,RP |
| GP,S2,RP |
| G5,G4 |
| G4,R3 |
| S2,R2,R4 |
| S1,S2,R2,R4 |
| GP,S5 |
| S1,S2,S5 |
| R4,R5 |
| R4,R2,R3,R5 |
| S2,S5,N4,RP |
| S1,S2,S3,S5,NP |
| S2,S4,S5 |
| T2,S1,S4,S5 |
| SP,RP |
| S2,RP |
| S1,S2,CP,G2 |
| CP,SP |
| S1,G2 |
| SP,CP |
| S1,S2,S5,C3 |
| S1,C1,S3 |
| G1,G3new |
| C4, C3, C1C4 |
| C4,C3,C1 |
| S1,S2,S3,S5,R2,R3,R4 |
| S1,S2,S3,R2 |
| S2,S3,S5,C4,R2 |
| S1,S5,C1 |
| S1,S2,S3,C1,C3,C4,R2 |
| Ggp |
| S3,S2,C1,C4,G2 G3new |
| R1,R2,R3,R4 |
| R4,R1,R2,R3 |
| R4,R2,R3 |
| S1,C1,C4,R2 |
| R4,R2 |
| S2,C4,R2,R4 |
| S2,C4,R2 |
| S2,S3,S5,C3,C4,R2 |
| S1,S2,S4,T2 |
| S1,S2,S4 |
| S1,S2,S4,R5 |
| S3,S2,C1,C4,G2,G3new |
| GP,C1 |
| S1,S5,C4 |
| S1,S2,S3,S5,R2,R3,R4,GP |
| GP,C4,C3,C1 |
| SMG9 |
| SMG1 |
| SMG2 |
| N3,R5 |
| N1, N2, N4, G1, G2, R3, S1, SMG2 |
| S1,SMG1 |
| SMG1,N4 |
| N1,C1,N4,S1,T2,G2,SMG1,SMG2,SMG3,SMG7,SMG9 |
| SMG1,N2 |
| S1,S2,N2,N4 |
| N4,N2 |
| G1,G2 |
| G1,G2,C1 |
| G1,G2,N1 |
| SMG2, SMG1, SMG3, SMG4, SMG7, SMG9, SMG10, G1, G2, G3, N1, N3, T2 |
| SMG2,G1 |
| S1,G1,G2 |
| SMG1,N1,G1,G2 |
| G2,G1 |
| G1,G2,G3,S1,S2,SMG1,SMG2,SMG7,N1,N2,N3,N4,T2 |
| 23.003, 23.008, 29.060 |
| S1, S2, SMG1, SMG2, SMG12, G2, N1, N2, N4 |
| S1,S2,SMG1,SMG2,SMG12,G2,N1,N2,N4 |
| S1,SMG2,N1,N2,N4 |
| SMG1,T2 |
| S1,N1,N2,N4 |
| S1,S2,N5 |
| SMG2,SMG7,G2,T2 |
| S3,N1,N2,N3 |
| S3,N1,N2,N4 |
| SMG9,T3 |
| SMG2,SMG3,SMG7,G2,N2 |
| SMG2,N1,G1,G2 |
| S1,N2 |
| N1,N3 |
| S2,N1 |
| N1,N2,N4 |
| N2,N1,N4 |
| N2,N4 |
| S1,T3 |
| T2,N3 |
| S3,N2 |
| T2,S1 |
| S1,N4 |
| SMG1,SMG2,SMG7 |
| N1,S1,T1 |
| SMG1,SMG3 |
| N4,S2,N1 |
| S1,S2,SMG1,SMG2,SMG7,G1,G2,G3,N1,N2,N3,N4,T2 |
| SMG1,N3 |
| S1,N3 |
| CP,SP,SMG |
| CP,SP,TP,GP,SMG |
| NP,SP,TP,GP,SMG |
| NP,GP, RP,SP,TP |
| SMG2,SMG1,SMG3,SMG4,SMG7,SMG9,SMG10,G1,G2,G3,N1,N3,T2 |
| S1,N2,N4 |
| S1,S2,S3,C1,C3,C4,R2,R3 |
| R2,R3,R1,R4 |
| R2,R3,R4 |
| R2,R1,R3,R4 |
| S2,C4,R2,R3,R4 |
| S2,C4,R2,R1,R3,R4 |
| S2,S3,S5,C3,C4,R2,R3,R4 |
| R1,R2,R4 |
| R3,R1,R4 |
| S2, |
| S2,G2, |
| S1,S2,G2, |
| S1,S2,G2,R2,R3, |
| S1,S2,C4,G2,R2,R3 |
| S1,S2,N4,G2,R2,R3 |
| S1,S2,SMG1,SMG2,SMG12,G2,N1,N2,N4,R2,R3 |
| S1,SMG1,T2 |
| S1,SMG1,S2 |
| S1,N4,N2 |
| T2,N1,N3 |
| S3,N2,N4 |
| SMG1,SMG2,SMG3,SMG7,SMG9,N1,C1,N4,S1,T2,G2 |
| SMG1,N2,N4 |
| S2,T2,N1,N2,N4 |
| S1,T2 |
| S1,S2,C4 |
| S1,S2,N4,RP |
| S2,N4 |
| S1,S2,N3,N4,RP |
| S1,S2,SMG1,SMG2,SMG12,T2,G2,N1,N2,N4,R2,R3 |
| S1,T2,N1,N3 |
| S1,S2,SMG1,SMG2,SMG12,T2,G2,N1,N2,N3,N4,R2,R3 |
| S1,S2,S3,SMG1,SMG2,SMG12,G2,N1,N2,N4,R2,R3 |
| S1,S2,SMG,G1,G2,G3,N1,N2,N3,N4,T2 |
| S1,S2,SMG,T2,G2,N1,N2,N3,N4,R2,R3 |
| S1,S3,SMG,G1,G2,G3,N1,N2,N3,N4,T2 |
| S1,S3,T2,N2,N4 |
| S1,S2,SMG,T2,G1,G2,G3,N1,N2,N3,N4 |
| G2,S2 |
| T1,R5 |
| R5,T1 |
| S1,S2,S4,T1,R5 |
| S1,S2,S4,S5,T1,RP,GP |
| S1,S2,S3,S5,R2,R3,R4,GP,C1 |
| S1,S2,S3,SMG1,SMG2,SMG12,N1,N2,N4,R2,R3 |
| S1,S2,SMG,T2,N1,N2,N3,N4,R2,R3 |
| NP,SP,TP,SMG |
| S1,S2,SMG,T2,N1,N2,N3,N4 |
| SMG,N1 |
| SMG |
| S1,S2,SMG1,SMG2,SMG7,N1,N2,N3,N4,T2 |
| SMG2,SMG1,SMG3,SMG4,SMG7,SMG9,SMG10,N1,N3,T2 |
| S1,SMG |
| SMG2,SMG7,T2 |
| SMG2,S2 |
| N1,N2,N4,R3,S1,SMG |
| SMG2,SMG3,SMG7,N2 |
| SMG1,SMG2,SMG3,SMG7,SMG9,N1,C1,N4,S1,T2 |
| S1,S2,SMG,N3,N4,RP |
| S1,S2,S4,SMG,N3,N4,RP |
| S2,C1,C4,R2,R1,R3,R4 |
| R2,S2,S4 |
| G3new,R5 |
| GP,R4 |
| S2,S4,R2 |
| SP,GP |
| RP,SP |
| S2,S1,S3,S5 |
| S3,S1 |
| N4,N1,N2,S2 |
| S2,G1,G2,R2,R3 |
| S2,G1,G2 |
| G1,G2,R2,R3 |
| N4,T3 |
| S3,S2,N1,N4,T3,OMA |
| T2,S1,S4,S5,OMA |
| S2,N3 |
| S4,S1 |
| N4,N3,S1 |
| R5,G3new |
| R4,R2,R1 |
| S2,R2 |
| C3, C4,C1 |
| S3,C1,C4,C3 |
| C1,C4,C3 |
| S2,C1,C4,C3 |
| R3,R5 |
| S1,S2,C3 |
| R1,R2 |
| S3,C1,C4,G2,G3new |
| R1,R3 |
| GP,N1 |
| R1,R2,R3 |
| R3,R2,R4 |
| R4,R3 |
| S1,S2,R2,R3 |
| S1,S2,S3,C1,C3,C4,R2,R3,R5 |
| S2,S1,S5 |
| C4, C1 |
| C3, C1, C4 |
| S2,S1,S3,S5,C4,C1 |
| S2,C3,C1,C4 |
| S2,S1,S5,C3 |
| GP,S2,C1 |
| GP,S2,C1,G2 |
| G2,S2,C1 |
| v |
| G3new,G1,G2 |
| G1,G2,C1,G3new |
| S2,S1,S5,C1,C3 |
| C1,C3,C4,R5 |
| R2,R1 |
| S1<S2,N1,R2,R5 |
| S1,S2,N1,R2,R5 |
| S2,R5 |
| S1,S2,S5,R5 |
| S2,C1,C4,R2,R1,R3,R4,R5 |
| S1,S2,S3,S5,NP,R5 |
| S1,S2,S4,S5,RP,R5,GP |
| S1,S2,S3,S5,C1,C6,R2,R3,R4 |
| S1,S2,S3,S5,C1,C6,R2,R3,R4,GP |
| S4,R2 |
| S1,S2,C1,C4,G2 |
| S4,C3,C4 |
| S5,C1,C4 |
| S2,C4,C3,C1 |
| C4, C3, C1 |
| S2,S4,R2,C4,C3,C1 |
| GP1,GP2 |
| GP,GP1,GP2 |
| GP,G1,G2 |
| G2,R3 |
| S1,S2,S3,C1,C3,C4,G2 |
| GP,G1,C1 |
| S1,S2,C4,C3,C1 |
| - |
| GP,G1,G2,G3new |
| S1,S2,S3,C1,C3,C4,G2,R2,R3 |
| S1,S2,C1,C3,C4,G2,R2,R3 |
| C1,C6 |
| GP,G2,C4 |
| S2,C3 |
| R5,R4 |
| C4,GP,G2 |
| S1,S2,C1,C4,G2,R2,R3 |
| R1,R2,R4,S3 |
| S2,S5,C3,C1,C4 |
| S2,S4,C4,C3,C1 |
| S2,S4 |
| S3,S1,S2 |
| S1,S2,S3,C1,R2 |
| S3,S1,S2,C1,R2 |
| S2,C3,S5 |
| S1,S2,C1,C4,C3,G2,R2,R3 |
| S5,C4 |
| S2,S1,C3 |
| C1,C4,C3,C6 |
| S1,S2,C1,C4,C3,C6,G2,R2,R3 |
| R1,R2,R4,S3,C4,C6 |
| R4,R1,R4,R1,R2,R3,R3 |
| S2,R3,R2 |
| S1,S2,S5,CP |
| S1,S3,CP |
| C6,C1 |
| R4,R2,R1,R3 |
| R3,R1,R2 |
| R1,R4,R2,R3 |
| S2,C4,C1,C3 |
| R3,R1,R2,R4 |
| C4,S1 |
| S2,S5,R3,GP, |
| S2,S5,R3,GP |
| S1,S2,S3,S5,C1,C3,C4 |
| S2,S3,S5,C1,C3,C4,C6 |
| S5,S1 |
| 03.06.2011 |
| CT1 CT3, CT4 |
| CT3, |
| CT4 |
| CT3 |
| GP,G2,G1 |
| S5,S1,C1 |
| SP,RP,CP |
| SP,CP,GP,RP |
| R1,R2,R4,R3 |
| R4,R2,R5 |
| R2,R4,R5 |
| R1,R2,R4,S2,S3,C4,C6 |
| C1-IETF |
| S4-IETF |
| C1-IETF, C3-IETF, C4-IETF |
| S3-IETF |
| C4-IETF |
| C1-IETF, C3-IETF |
| S2,S4,C1,R2 |
| S2,S4,C3,C4 |
| S2,S4,C1,C3,R2 |
| S1,S2,C1,IETF |
| S4,IETF |
| C1,C4,IETF |
| S2,S4,C1,C3,R2,IETF |
| S3,C1,C4,C3,IETF |
| S3,C4,IETF |
| C1,IETF |
| S1,S2,S3,S5,C1,C3,C4,C6,IETF |
| S2,S3,C1,C4,IETF |
| S1,S2,C1,C3,C4,IETF |
| C1,C3,C4,IETF |
| S1,S5,C1,C3,C4,IETF |
| C1,C3,IETF |
| S2,C1,C3,C4,IETF |
| S2,S4,C3,C4,IETF |
| S5,C1,C4,IETF |
| S5,C1,C3,C4,IETF |
| S2,S3,S5,C1,C3,C4,IETF |
| S2,IETF |
| S3,C1,C3,C4,IETF |
| S2,S3,C1,C3,C4,IETF |
| S3,S2 |
| S3,S2,C1 |
| S3,S1,S2,C1 |
| S2,S5,N3 |
| S1,S2,S3,S5,N1,N3,N4,T3 |
| S5,N4,R3 |
| S1,S2,S5,C1,C4,C3,C6,G2,R2,R3 |
| S2,N1,N4,R3,GP |
| T2,S3 |
| S3,N4,N1 |
| S2,N3,N4 |
| S3,T2 |
| S2,S1,S3,S5,RP,GP |
| S1,S2,S3,S5,R5 |
| S1,S2,S3,S5,NP,T3,T1,R5 |
| S3,T3 |
| GP,S3 |
| S1,S2,S3,S4,S5,RP,R5,GP |
| N1,N4 |
| S1,S2,S3,S4,N1,N3,N4,OMA |
| S2,C1,C3,C4,G2,R2,R3 |
| S1,C4,C3 |
| S2,S1,C1,C4,IETF |
| C1,C3,C4,C6 |
| C4,C1,C6 |
| S1,S2,S3,C1,C3,C4,C6 |
| S2,S1,C1,C3,C4 |
| S1,S2,C1,C3 |
| C1.IETF |
| C1-IETF,C4-IETF |
| G1,C1 |
| G1,S2,C4 |
| G2,S2,C4 |
| R1,R2,R3,R4,R5 |
| R2,R4,R3,R5 |
| R3,R2,R5 |
| R2,R3,C1,C6 |
| S1,S2,S3,C1,C3,C4,C6,R2,R3 |
| R4,R1 |
| S2,S4,C4,C3,C1,IETF |
| S2,C4,C3 |
| S3.C4,C1 |
| G2,C4 |
| R4,G1,G3new |
| C4,G2 |
| S3,C4,C1 |
| R2,R3,R5 |
| R1,R2,R4,R5 |
| S1,S2,S3,S5,C1,C6,R2,R3,R4,R5,GP |
| S1,C1,C4,R2,R5 |
| S2,S3,S5,C3,C4,R2,R3,R4,R5 |
| R2,R1,R3,R4,R5 |
| S3-IETF, C1-IETF |
| S3-IETF,C1-IETF |
| C1-IETF,C3-IETF |
| S2-IETF |
| S2,S1,C1,C3,C4,IETF |
| 25.101, 25.104, 25.141, 25.317 |
| S1,G2,S2,C1 |
| S1,C1,C4,R2,R3,R5 |
| S5,S2 |
| S4,C3,C4,IETF |
| S4,S3,C3,C4,IETF |
| S4,S3,C3,C4 |
| S4,S3,IETF |
| S1,S2,S3,S5,C1,C3,C4,C6,R2,R3 |
| C1,C4,C6 |
| S1,S2,S5,C1,C4,C6,G2,R2,R3 |
| GP,G1,C1,G3new |
| S2,S5,C1,C3 |
| C4,C3,G2 |
| S2,S1,S5,C3,C1,C4 |
| C3,C4,C1 |
| S2,S1,S5,C3,C4,C1 |
| RAN1 |
| RAN2 |
| RAN3 |
| RAN4 |
| R4,R2,R3, |
| Feasibility Study on LTE Device to Device Communications – Radio Aspects |
| SMG1,SMG2,SMG3,SMG7,SMG9,N1,N4,S1,T2 |
| C3-IETF, C4-IETF |
| S3-IETF,C1-IETF,C3-IETF |
| C3-IETF |
| C3,IETF |
| S2,C1,C4,C3,IETF |
| S1,S2,S3,C1,C3,C4,R2,R3,R5,IETF |
| C1-IETF,C3-IETF,C4-IETF |
| C4,C1,C3,IETF |
| S2,C4,C1,C3,IETF |
| C1,C4,C3,IETF |
| S2,S1,T2,N1,N4,R3,R2 |
| S2,S1,S2,S1,N1,N4 |
| S2,S1,N1,N4 |
| S2,R2,G1 |
| S2,S1,S3,S5,N4,R2,R3,GP |
| S1,S2,N4 |
| S2,OMA |
| S2,N4,OMA |
| S2,S5,N4,R2,R4 |
| S2,S5,N4,R2,R4,OMA |
| GP,R2 |
| S1,S2,GP,R2 |
| G1,G3 |
| S1,G2,R2 |
| S2,S5,N4,R2,R4,R5,OMA |
| SR5 |
| S3,C4,C1,R5 |
| S3,S1,C1 |
| S2,C4,C3,G2 |
| SP,CP,RP |
| S3,R5 |
| GP,G2,G3new |
| S1,S2,S3,S4,S5,N1,N3,RP,R5,GP |
| S1,S2,S3,S4,S5,N1,N3,RP,R5,T1,GP |
| S1,S2,S3,S4,S5,N1,N3,RP,R5,T1,GP,G2,G3new |
| S1,S2,S3,S4,S5,N1,N3,R2,R4,R5,T1,GP,G2,G3new |
| S1,S2,S5,C1,C4,C6,G2,R2,R3,G3new |
| SP,CP,RP,GP |
| G2,G1,G3new |
| G2,G1,C1,G3new |
| RAN |
| R |
| S2,S1,S3,S5,R2 |
| S2,S1,S3,S5,R2,R3 |
| S1,S2,S5,C1,C4,C6,G2,R2,R3,R5,G3new |
| C1,C4,R5,IETF |
| C1,R5 |
| R3,R1 |
| R3,GP |
| S3,IETF |
| S1,S2,S5,C1,C3,C4,C6,R2,R3 |
| S3,C4,C1,C3 |
| C1,C4,S1 |
| C1,C4,R3 |
| R2,R1,R3 |
| R1,R4,R2,R3,R5 |
| RAN5 |
| S2,C4,C1,R3 |
| G1,G2,G3new |
| S4,C1 |
| S4,C4,C1,C3 |
| 14/06/2013 08:00 |
| S2,C1,C3,IETF |
| C3, C1 |
| R3,C4 |
| S2,S1,C1,C3 |
| R3,S2,C4 |
| R% |
| G1,C1,G3new |
| R3,S2,C4,G2 |
| S1,S3,N4 |
| S1,OMA |
| S1,S2,S4,OMA |
| S5,S2,N3 |
| S3,C4,C1,C3,IETF |
| S1,S2,S5,C1,C3,C4,C6,R2,R3,R5 |
| S2,S1,S5<c3 |
| S2,C1,C4,C6 |
| S2,S1,S3,C1,C4,C6 |
| S2,S1,S3,C1 |
| R2,R3,R4,G2,G1,G3new |
| C1,C3,R5 |
| ,C4,C6 |
| S2,S1,S3,C1,C4,C6,R2 |
| S2,S1,S3,C1,C4,C6,R2,R3 |
| S2,S1,S3,C1,C3,C4,C6,R2,R3 |
| S1,S2,S3,IETF |
| S1,S2,S3,C1,C3 |
| S1,S2,S3,C4,C1,C3 |
| C1,S1 |
| C34 |
| S1,S2,S3,C1,C4,IETF |
| IETF |
| SMG12 |
| SMG7 |
| SMG3 |
| SMG4 |
| SMG10 |
| C3-IETF,C4-IETF |
| NP,GP,RP,SP,TP |
| S3,G2 |
| R2,S2 |
| R2,S2,C1 |
| R2,C1 |
| S1` |
| R2,S1,C1 |
| C1-IET |
| 18/06/2014 08:00 |
| C4-IET |
| RAN1 (primary) |
| C3.S2 |
| C3-IET |
| S6 |
| ` |

## Schedule

| ID | WBS | Task | Duration | Start | Finish | Complete | Remaining | Baseline start | Baseline finish | Baseline duration | Total slack | Constraint | Resources | Work | Actual work | Release | Acronym | PCG approved | Impacted TSs and TRs | WI rapporteur name | TSG approved | WI rapporteur e-mail | MCC resp | Status Report | Acronym_3GU_Export | Special Focus Doc |
| --- | --- | --- | --- | --- | --- | --- | --- | --- | --- | --- | --- | --- | --- | --- | --- | --- | --- | --- | --- | --- | --- | --- | --- | --- | --- | --- |
| 1 | 1 | Work Plan 3GPP version May 5th 2015 | 1d? | 2000-01-03 | 2000-01-03 |  |  |  |  |  | 4571d |  |  |  |  |  |  |  |  |  |  |  |  |  |  |  |
| 2 | 2 | (includes several off-line enhancements and corrections) | 1d? | 2000-01-03 | 2000-01-03 |  |  |  |  |  | 4571d |  |  |  |  |  |  |  |  |  |  |  |  |  |  |  |
| 4 | 3 | Release 14 Features | 655d? | 2014-12-12 | 2017-06-14 |  |  |  |  |  | 0d | start no earlier than 2014-12-12 | SP; RP; CP; GP | 20960h |  | Rel-14 |  |  |  |  |  |  |  |  |  |  |
| 5 | 4 | Password based service activation for IMS Multimedia Telephony service | 3d? | 2015-03-11 | 2015-03-13 |  |  |  |  |  | 589d | finish no earlier than 2015-03-13 | S1 | 24h |  | Rel-14 | PWDIMS | PCG-34 | 22.173 | Peter Bleckert (Ericsson) | SP-67 |  |  |  |  |  |
| 6 | 5 | Multimedia Priority Service Modifications | 331d? | 2015-03-11 | 2016-06-15 |  |  |  |  |  | 261d | finish no earlier than 2016-06-15 | S1 | 2648h |  | Rel-14 | MPS_Mods | PCG-34 | 22.153 | Ray P. Singh (Applied Communications Science) | SP-67 | rsingh@appcomsci.com |  |  |  |  |
| 7 | 6 | Enhancing Location Capabilities for Indoor and Outdoor Emergency Communications | 200d? | 2015-03-11 | 2015-12-15 |  |  |  |  |  | 392d | finish no earlier than 2015-12-15 | S1 | 1600h |  | Rel-14 | ELIOT | PCG-34 | 22.101, 22.071 | Greg Schumacher | SP-67 | Gregory.schumacher@sprint.com |  |  |  |  |
| 8 | 7 | Enhancements to Domain Selection between VoLTE and CDMA CS | 69d? | 2015-03-11 | 2015-06-15 |  |  |  |  |  | 523d | finish no earlier than 2015-06-15 | S1 | 552h |  | Rel-14 | eDSVCC | PCG-34 | 22.101 | China Telecom, Hongmei Zhu | SP-67 | zhuhongmei@gsta.com |  |  |  |  |
| 9 | 8 | Release 14 Studies | 323d? | 2014-09-17 A | 2015-12-11 | 10% | 290.7d? |  |  |  | 394d | finish no earlier than 2015-12-11 | SP; RP; CP; GP | 10336h | 1033.6h | Rel-14 |  |  |  |  |  |  |  |  |  |  |
| 10 | 9 | Study on New Services and Markets Technology Enablers | 241d? | 2015-04-14 | 2016-03-15 |  |  |  |  |  | 327d | finish no earlier than 2016-03-15 | S1 | 1928h |  | Rel-14 | FS_SMARTER | PCG-34 | New TR 22.891 | Adrian Neal (Vodafone) | SP-67 | adrian.neal@vodafone.com |  |  |  |  |
| 11 | 10 | Study on need for Multiple Access Point Names | 464d? | 2013-09-12 A | 2015-06-19 | 90% | 46.4d? | 2013-09-12 | 2014-12-10 | 327d? | 519d | finish no earlier than 2015-06-19 | S1 | 3704h | 3332.8h | Rel-14 | FS_MAPN | PCG-31 | 22.802 | Giesecke & Devrient | SP-61 | Ilario.macchi@gi-de.com | Alain | S1-143308 | FS_MAPN |  |
| 12 | 11 | Study on Multimedia Broadcast Supplement for Public Warning System | 264d? | 2013-12-11 A | 2014-12-12 A | 100% |  | 2013-12-11 | 2014-09-17 | 202d? |  | finish no earlier than 2014-12-12 | S1 | 2104h | 2104h | Rel-14 | FS_MBSP | PCG-32 | 22.815 | Qualcomm | SP-62 | Eddy Hall (edhall@qti.qualcomm.com) | Alain | S1-143312 | FS_MBSP | Public Safety (I-A) |
| 13 | 12 | Study on service aspects for dealing with User Control over spoofed calls | 271d? | 2014-03-07 A | 2015-03-20 A | 100% |  | 2014-03-07 | 2014-12-10 | 199d? |  | finish no earlier than 2015-03-20 | S1 | 2168h | 2168h | Rel-14 | FS_UC_SPOOF | PCG-32 | 22.898 | Sprint | SP-63 | Gregory.schumacher@sprint.com | Alain | S1-143314 | FS_UC_SPOOF |  |
| 14 | 13 | Study on User Location Reporting Support enhancements | 261d? | 2014-06-19 A | 2015-06-17 | 90% | 26.1d? | 2014-06-18 | 2015-06-17 | 261d? | 521d | finish no earlier than 2015-06-17 | S1 | 2088h | 1879.2h | Rel-14 | FS_eULRS | PCG-33 | 22.899 | China Unicom | SP-64 | Zhuoyun Zhang ( zhangzy910@chinaunicom.cn) |  | S1-143315 | FS_eULRS |  |
| 15 | 14 | Study on Control of Applications when Third party Servers encounter difficulties | 259d? | 2014-06-19 A | 2015-06-15 | 90% | 25.9d? | 2014-06-18 | 2014-12-10 | 126d? | 523d | finish no earlier than 2015-06-15 | S1 | 2072h | 1864.8h | Rel-14 | FS_CATS | PCG-33 | 22.818 | KDDI | SP-64 | Eriko Yoshida (er-yoshida@kddi.com) |  | S1-143316 | FS_CATS |  |
| 16 | 15 | Study on Mission Critical Video over LTE | 176d? | 2015-04-14 | 2015-12-15 |  |  |  |  |  | 392d | finish no earlier than 2015-12-15 | S1 | 1408h |  | Rel-14 | FS_MCVideo | PCG-34 | New TR 22.879 | Villebrun, Emmanuelle (French MoI) | SP-67 | emmanuelle.villebrun@gendarmerie.interieur.gouv.fr |  |  |  |  |
| 17 | 16 | Study on Mission Critical Data Communications | 176d? | 2015-04-14 | 2015-12-15 |  |  |  |  |  | 392d | finish no earlier than 2015-12-15 | S1 | 1408h |  | Rel-14 | FS_MCDATA | PCG-34 | New TR 22.880 | Villebrun, Emmanuelle (French MoI) | SP-67 | emmanuelle.villebrun@gendarmerie.interieur.gouv.fr |  |  |  |  |
| 18 | 17 | Study on LTE support for V2X services | 176d? | 2015-04-14 A | 2015-12-15 | 25% | 132d? |  |  |  | 392d | finish no earlier than 2015-12-15 | S1 | 1408h | 352h | Rel-14 | FS_V2XLTE | PCG-34 | New TR 22.885 | Ki-Dong Lee (LG electronics) | SP-67 | kidong.lee@lge.com |  |  |  |  |
| 19 | 18 | Study on 3GPP Enhancement for TV Video service | 176d? | 2015-04-14 | 2015-12-15 |  |  |  |  |  | 392d | finish no earlier than 2015-12-15 | S1 | 1408h |  | Rel-14 | FS_EnTV | PCG-34 | TR 22.816 | Zhiming Li (Huawei) | SP-67 | lizhiming@huawei.com |  |  |  |  |
| 20 | 19 | Study on Paging Policy Enhancements and Procedure Optimizations in LTE | 176d? | 2015-04-14 | 2015-12-15 |  |  |  |  |  | 392d | finish no earlier than 2015-12-15 | S1 | 1408h |  | Rel-14 | FS_PPEPO_LTE | PCG-34 | New TR 22.838 | Zhuoyun Zhang (China Unicom) | SP-67 | zhangzy910@chinaunicom.cn |  |  |  |  |
| 21 | 20 | Release 13 Features | 183.25d? | 2013-09-12 A | 2015-12-25 | 25% | 137.44d? | 2015-04-14 | 2015-12-25 | 183.25d? | 384d | finish no earlier than 2015-12-25 | SP; RP; CP; GP | 5864h | 1466h | Rel-13 |  |  |  |  |  |  |  |  |  |  |
| 22 | 21 | **Mission Critical Push To Talk over LTE** | 527d? | 2013-12-11 A | 2015-12-11 | 19% | 429.03d? | 2013-12-11 | 2015-06-17 | 397d? | 394d |  | S1; S2; S3; S6; S4 | 29726.8h | 4409.62h | Rel-13 | MCPTT | PCG-32 | Stage 1/2 | NIST | SP-62 | david.cypher@nist.gov | Alain |  | MCPTT | Public Safety (A-A) |
| 23 | 21.1 | Stage 1 for Mission Critical Push To Talk over LTE | 263d? | 2013-12-11 A | 2014-12-12 A | 100% |  | 2013-12-11 | 2014-12-10 | 261d? |  | finish no earlier than 2014-12-12 | S1 | 2104h | 2104h | Rel-13 | MCPTT | PCG-32 | New TS 22.179 | NIST | SP-62 | david.cypher@nist.gov | Alain | SP-140502 |  | Public Safety (A-A) |
| 24 | 21.2 | SA6 Study on Application Architecture to support Mission Critical Push To Talk over LTE (MCPTT) services | 261d? | 2014-06-23 A | 2015-06-17 | 30% | 182.7d? | 2014-06-18 | 2014-12-10 | 126d? | 521d | finish no earlier than 2015-06-17 | S6 | 2088h | 626.4h | Rel-13 | MCPTT | PCG-33 | New TR 23.779 | U.S. Department of Commerce | SP-64 | Randy Bloomfield (randy@its.bldrdoc.gov) |  |  |  | Public Safety (A-A) |
| 25 | 21.3 | (to be confirmed:) SA2 Study on Architecture Enhancements at the EPS and IMS Level to Support Mission Critical Push To Talk over LTE (MCPTT) Services | 69d? | 2015-03-13 | 2015-06-17 |  |  |  |  |  | 521d | finish no earlier than 2015-06-17 | S2 | 552h |  | Rel-13 | MCPTT | PCG-34 |  | Randy Bloomfield (randy@its.bldrdoc.gov) | SP-67 | Randy Bloomfield (randy@its.bldrdoc.gov) |  |  |  |  |
| 26 | 21.4 | Application Architecture to support Mission Critical Push To Talk over LTE (MCPTT) Services | 131d? | 2015-03-13 | 2015-09-11 |  |  |  |  |  | 459d | finish no earlier than 2015-09-11 | S6 | 1048h |  | Rel-13 | MCPTT | PCG-34 |  | U.S. Department of Commerce | SP-67 | Randy Bloomfield (randy@its.bldrdoc.gov) |  |  |  |  |
| 27 | 21.5 | deleted: SA2 aspects for Mission Critical Push To Talk over LTE | 1d? | 2015-03-13 | 2015-03-13 |  |  | 2014-06-18 | 2015-06-17 | 261d? | 589d | finish no earlier than 2015-03-13 | S2 | 8h |  | Rel-13 | MCPTT-del | PCG-33 | New TS 23.179 | Randy Bloomfield (randy@its.bldrdoc.gov) | SP-64 | Randy Bloomfield (randy@its.bldrdoc.gov) |  |  |  | Public Safety (A-A) |
| 28 | 21.6 | SA6 aspects for Mission Critical Push To Talk over LTE | 261d? | 2014-12-12 | 2015-12-11 |  |  |  |  |  | 394d | finish no earlier than 2015-12-11 | S6 | 2088h |  | Rel-13 | MCPTT | PCG-34 |  | David Cypher (david.cypher at nist.gov) | SP-66 | David Cypher (david.cypher at nist.gov) |  |  |  |  |
| 29 | 21.7 | Security of Mission Critical Push To Talk over LTE | 261d? | 2014-12-12 A | 2015-12-11 | 5% | 247.95d? |  |  |  | 394d | finish no earlier than 2015-12-11 | S3 | 2088h | 104.4h | Rel-13 | MCPTT | PCG-34 | TR 33.xxx, TS 33.xxx, | Peter Haigh (peter.haigh at cesg.gsi.gov.uk) | SP-66 | Peter Haigh (peter.haigh at cesg.gsi.gov.uk) |  |  |  |  |
| 30 | 21.8 | Study on Security Enhancements for Mission Critical Push To Talk over LTE | 196d? | 2015-03-13 | 2015-12-11 |  |  |  |  |  | 394d | finish no earlier than 2015-12-11 | S3 | 1568h |  | Rel-13 | MCPTT | PCG-34 |  | Peter Haigh (peter.haigh at cesg.gsi.gov.uk) | SP-67 | Peter Haigh (peter.haigh at cesg.gsi.gov.uk) |  |  |  |  |
| 31 | 21.9 | Study on media, codecs and MBMS enhancements for Mission Critical Push to Talk over LTE | 261d? | 2014-12-12 | 2015-12-11 |  |  |  |  |  | 394d | start no earlier than 2014-12-12 | S4 | 2088h |  | Rel-13 | MCPTT | PCG-34 | New TR 26.879 | Zhiming Li (lizhiming@huawei.com) | SP-67 | Zhiming Li (lizhiming@huawei.com) |  |  |  |  |
| 32 | 21.10 | MCPTT Codecs and media handling | 202d? | 2015-03-05 | 2015-12-11 |  |  |  |  |  | 394d | finish no earlier than 2015-12-11 | S4 | 1616h |  | Rel-13 | MCPTT | PCG-34 | 26.346, new TS 26.179 | Zhiming Li (lizhiming@huawei.com) | SP-67 | Zhiming Li (lizhiming@huawei.com) |  |  |  |  |
| 33 | 22 | Isolated E-UTRAN Operation for Public Safety | 140d? | 2014-03-07 A | 2014-09-17 A | 100% |  | 2014-03-07 | 2014-09-17 | 139d? |  | finish no earlier than 2014-09-17 | S1 | 1120h | 1120h | Rel-13 | IOPS | PCG-32 | New TS 22.346 | General Dynamics | SP-63 | paul.piggin@gd-broadband.com | Alain | S1-143304 | IOPS | Public Safety (A-A) |

Notes:
- 4: -
- 5: 1/4/15: rapporteur added, Impacted TS added
- 6: 1/4/15: rapporteur added, Impacted TS added
- 7: 1/4/15: rapporteur added, Impacted TS added
- 8: 1/4/15: rapporteur added, Impacted TS added
- 9: -
- 10: 11/3: WID: SP-150050->150142
- 11: SP#65 moved to Rel-14. Completion 12/14=>03/15. Triggered by S1-133134 LS on GSMA Connected Living Programme Request for APN Storage in the SIM. Dec.14: 50->70%, CD: 03/15->06/15. Mar.15: 90%
- 12: SP#65 completion 09/14=>12/14. Moved to Rel-14. TR 22.815v100 for Information. Linked to Rel-9 Feature PWS. Dec.14:70->100%
- 13: SP#65 moved to Rel-14. Linked to SA3 Rel-11 TR 33.838 PUCI and Rel-12 ongoing study TR 33.831 (FS_SPOOF). Dec.14: 70->90, CD: 12/14->03/15. Mar.15: 100%
- 14: SP#65 moved to Rel-14. Linked to Rel-12 SA2 TR 23.843 Study on Core Network Overload solutions (FS_CNO) and Rel-13 Feature Service Exposure and Enablement Support (SEES). Dec.14: 30->70%. Mar.15: 90%
- 15: SP#65 completion 12/14=>03/15. Moved to Rel-14. Linked to Rel-13 Feature SEES and Rel-13 TR 22.806 (FS_ACDC). Dec.14: 30->60%, WID SP-140246->SP-140758, CD: 12/14->03/15. Mar.15: CD: 03/13->06/15. 60->90%
- 16: 1/4/15:TR number added
- 17: 1/4/15:TR number added
- 18: 1/4/15:TR number added
- 19: 1/4/15:TR number added
- 20: 1/4/15:TR number added
- 21: -
- 22: SP#65 updated WID SP-140276=>SP-140435. Mar 15: WID: SP-140879->SP-150164. 84/15: S4 added
- 23: SP#65 completion 09/14=>12/14. Exception in SP-140502. TS 22.179v100 for Information. Completed. Mar 15: WID: SP-140879->SP-150164.
- 24: SP#65 completion 12/14=>06/15. Updated WID SP-140276=>SP-140435. Dec.14: 2->20%. Mar 15: WID: SP-140879->SP-150095. Mar15: 30%. Transferred to SA6.
- 25: Mar 2015: WID: SP-140879->SP-150164.
- 26: Mar 2015: WID: SP-140879->SP-150164. Name clarified.
- 27: Mar 2015: transferred to SA6. Was 06/14 to 06/15
- 28: Mar 2015: WID: SP-140879->SP-150164. Name clarified.
- 29: Mar 2015: WID: SP-140879->SP-150164. Name clarified. FCD: 03/2016->12/2015
- 30: Mar 2015: WID: SP-140879->SP-150164. Name clarified.
- 31: Mar 2015: WID: SP-140879->SP-150164. Name clarified. 5/5/15: TR number added
- 32: Mar 2015: WID: SP-140879->SP-150164. Name clarified. FCD: 03/2016->12/2015
- 33: SP#65 completed. TS 22.346v100 for 1-step Approval. Triggered by Rel-13 TR 22.897 (FS_IOPS)

| ID | WBS | Task | Duration | Start | Finish | Complete | Remaining | Baseline start | Baseline finish | Baseline duration | Total slack | Constraint | Resources | Work | Actual work | Acronym | PCG approved | WI rapporteur name | Release | TSG approved | Impacted TSs and TRs | WI rapporteur e-mail | MCC resp | Status Report | Special Focus Doc | Acronym_3GU_Export | PCG stopped | TSG stopped |
| --- | --- | --- | --- | --- | --- | --- | --- | --- | --- | --- | --- | --- | --- | --- | --- | --- | --- | --- | --- | --- | --- | --- | --- | --- | --- | --- | --- | --- |
| 34 | 23 | **MBMS Enhancements** | 204d? | 2014-12-03 A | 2015-09-14 | 10% | 182.71d? |  |  |  | 458d |  | S2 | 3272h | 341.55h | MBMS_enh | PCG-34 | Rainer Liebhart | Rel-13 | SP-66 |  |  |  |  |  |  |  |  |
| 35 | 23.1 | MBMS Enhancements TR Phase | 204d? | 2014-12-03 A | 2015-09-14 | 10% | 183.6d? |  |  |  | 458d | finish no earlier than 2015-09-14 | S2 | 1632h | 163.2h | MBMS_enh | PCG-34 | Rainer Liebhart | Rel-13 | SP-66 | TR 23.8xy |  |  |  |  |  |  |  |
| 36 | 23.2 | deleted - MBMS Enhancements - Stage 2 | 1d? | 2015-03-13 A | 2015-03-13 A | 100% |  |  |  |  |  | finish no earlier than 2015-03-13 | S2 | 8h | 8h | MBMS_enh-del | PCG-34 | Rainer Liebhart | Rel-13 | SP-66 | TS 23.246, TS 23.468 |  |  |  |  |  |  |  |
| 37 | 24 | **MBMS Extensions and Profiling** | 202d? | 2015-03-05 | 2015-12-11 |  |  |  |  |  | 394d |  | S4 | 4848h |  | MEPRO | PCG-34 | Zhiming Li (lizhiming@huawei.com) | Rel-13 | SP-67 | 26.346, new TR 26.852 | i.bouazizi@samsung.com |  |  |  |  |  |  |
| 38 | 24.1 | TR on Profiling and Extensions of MBMS | 202d? | 2015-03-05 | 2015-12-11 |  |  |  |  |  | 394d | finish no earlier than 2015-12-11 | S4 | 1616h |  | MEPRO | PCG-34 | Zhiming Li (lizhiming@huawei.com) | Rel-13 | SP-67 | new TR 26.852 | i.bouazizi@samsung.com |  |  |  |  |  |  |
| 39 | 24.2 | Specification of MBMS Extensions and Profiling | 202d? | 2015-03-05 | 2015-12-11 |  |  |  |  |  | 394d | start no earlier than 2015-03-05 | S4 | 1616h |  | MEPRO | PCG-34 | Zhiming Li (lizhiming@huawei.com) | Rel-13 | SP-67 | 26.346 | i.bouazizi@samsung.com |  |  |  |  |  |  |
| 40 | 25 | **Service Exposure and Enablement Support** | 268d? | 2013-09-12 A | 2014-09-17 A | 100% |  | 2013-09-12 | 2014-09-17 | 267d? |  |  | S1 | 5880h | 5880h | SEES | PCG-31 | KPN | Rel-13 | SP-61 | Stage 1 | toon.norp@tno.nl | Alain | S1-143301 | MTC, M2M | SEES |  |  |
| 41 | 25.1 | TR on Stage 1 for Service Exposure and Enablement Support | 202d? | 2013-09-12 A | 2014-06-18 A | 100% |  | 2013-09-12 | 2014-06-18 | 202d? |  | finish no earlier than 2014-06-18 | S1 | 1608h | 1608h | SEES | PCG-31 | KPN | Rel-13 | SP-61 | New TR 22.853 | toon.norp@tno.nl | Alain | S1-143301 | MTC, M2M |  |  |  |
| 42 | 25.2 | Stage 1 for Service Exposure and Enablement Support | 266d? | 2013-09-12 A | 2014-09-17 A | 100% |  | 2013-09-12 | 2014-09-17 | 266d? |  | finish no earlier than 2014-09-17 | S1 | 2128h | 2128h | SEES | PCG-31 | KPN | Rel-13 | SP-61 | 22.101, 22.115, 22.368, TBD | toon.norp@tno.nl | Alain | S1-143301 | MTC, M2M |  |  |  |
| 43 | 26 | Service Requirements Maintenance for Machine-Type Communications (MTC) | 201d? | 2013-12-13 A | 2014-09-17 A | 100% |  | 2013-12-12 | 2014-12-10 | 261d? |  | finish no earlier than 2014-09-17 | S1 | 1608h | 1608h | SRMMTC | PCG-32 | KPN | Rel-13 | SP-62 | 22.368 | toon.norp@tno.nl | Alain |  | MTC, M2M | SRMMTC |  |  |
| 44 | 27 | Service Requirements Maintenance for Group Communication System Enablers for LTE | 67d? | 2014-06-18 A | 2014-09-17 A | 100% |  | 2014-06-18 | 2014-09-17 | 66d? |  | finish no earlier than 2014-09-17 | S1 | 536h | 536h | SRM_GCSE_LTE | PCG-33 | Nokia Networks | Rel-13 | SP-64 | 22.468 | Juergen.Merkel@nsn.com |  | S1-143307 | Public Safety (A-A) | SRM_GCSE_LTE |  |  |
| 45 | 28 | **Application specific Congestion control for Data Communication** | 261d? | 2014-06-18 A | 2015-06-12 | 20% | 209.72d? | 2014-06-18 | 2014-09-17 | 66d? | 524d |  | S1; C1 | 7464h | 1064.12h | ACDC | PCG-33 | NTT DOCOMO | Rel-13 | SP-64 | 22.011 | Atsushi Minokuchi (minokuchi@nttdocomo.co.jp) |  | S1-143305 |  | ACDC |  |  |
| 46 | 28.1 | Stage 1 for Application specific Congestion control for Data Communication | 67d? | 2014-06-18 A | 2014-09-17 A | 100% |  | 2014-06-18 | 2014-09-17 | 66d? |  | finish no earlier than 2014-09-17 | S1 | 536h | 536h | ACDC-ST1 | PCG-33 | NTT DOCOMO | Rel-13 | SP-64 | 22.011 | Atsushi Minokuchi (minokuchi@nttdocomo.co.jp) |  | S1-143305 |  | ACDC |  |  |
| 47 | 28.2 | **Stage 3 for Application specific Congestion control for Data Communication** | 137d? | 2014-12-04 | 2015-06-12 |  |  |  |  |  | 524d |  | C1 | 3288h |  | ACDC-CT | PCG-34 | LGE | Rel-13 | CT-66 | TS 24.105, 24.301, 24.008, 27.007, 31.102 |  |  |  |  |  |  |  |
| 48 | 28.2.1 | CT1 part of Stage 3 for Application specific Congestion control for Data Communication | 137d? | 2014-12-04 | 2015-06-12 |  |  |  |  |  | 524d | start no earlier than 2014-12-04 | C1 | 1096h |  | ACDC-CT | PCG-34 | LGE | Rel-13 | CT-66 | 24.105, 24.301, 24.008, 27.007 |  |  |  |  |  |  |  |
| 49 | 28.2.2 | CT6 part of Stage 3 for Application specific Congestion control for Data Communication | 137d? | 2014-12-04 | 2015-06-12 |  |  |  |  |  | 524d | start no earlier than 2014-12-04 | C6 | 1096h |  | ACDC-CT | PCG-34 | LGE | Rel-13 | CT-66 | 31.102 |  |  |  |  |  |  |  |
| 50 | 29 | Enhanced Calling Information Presentation | 2d? | 2014-09-15 A | 2014-09-16 A | 100% |  | 2013-12-11 | 2014-09-17 | 201d? |  | finish no earlier than 2015-06-16 | S1 | 16h | 16h | ECIP | PCG-32 | China Mobile | Rel-13 | SP-62 | 22.182 (CAT), 22.183 (CRS) | LI Xiaofan (lixiaofan@chinamobile.com | Alain | S1-143311 |  | ECIP |  |  |
| 51 | 30 | **Flexible Mobile Service Steering** | 200d? | 2014-09-15 A | 2015-06-17 | 11% | 178.01d? | 2013-12-11 | 2014-09-17 | 202d? | 521d |  | S1; S2 | 5343.76h | 414.07h | FMSS | PCG-33 | China Mobile | Rel-13 | SP-65 | 22.101 | Lu Lu (lulu@chinamobile.com) | Alain | S1-143310 |  | FMSS |  |  |
| 52 | 30.1 | Stage 1 for Flexible Mobile Service Steering | 3d? | 2014-09-15 A | 2014-09-17 A | 100% |  | 2013-12-11 | 2014-09-17 | 202d? |  | start no earlier than 2014-09-15 | S1 | 23.85h | 23.85h | FMSS-ST1 | PCG-33 | China Mobile | Rel-13 | SP-65 | 22.101 | Lu Lu (lulu@chinamobile.com) | Alain | S1-143310 |  | FMSS |  |  |
| 53 | 30.2 | Flexible Mobile Service Steering TR Phase | 134d? | 2014-12-12 A | 2015-06-17 | 20% | 107.2d? |  |  |  | 521d | finish no earlier than 2015-06-17 | S2 | 1072h | 214.4h | FMSS-SA2TR | PCG-34 | Lu Lu, China Mobile | Rel-13 | SP-66 | 23.718 | lulu@chinamobile.com |  |  |  |  |  |  |
| 54 | 30.3 | Flexible Mobile Service Steering - Stage 2 | 134d? | 2014-12-12 | 2015-06-17 |  |  |  |  |  | 521d | start no earlier than 2014-12-12 | S2 | 1072h |  | FMSS-SA2 | PCG-34 | Lu Lu, China Mobile | Rel-13 | SP-66 |  | lulu@chinamobile.com |  |  |  |  |  |  |
| 55 | 31 | GERAN UTRAN Sharing Enhancements | 63d? | 2014-09-19 A | 2014-12-12 A | 100% |  |  |  |  |  | finish no earlier than 2014-12-12 | S1 | 504h | 504h | GUSH | PCG-33 | Telefónica | Rel-13 | SP-65 | 22.101 | chris.friel@telefonica.com |  | SP-140515 |  | GUSH |  |  |
| 56 | 32 | **User Plane Congestion management** | 667d? | 2012-09-12 A | 2015-03-18 | 93% | 48.29d? | 2012-02-02 | 2015-06-17 | 890d? | 586d |  | S1; S2; C3; C4 | 39368h | 26190.9h | UPCON | PCG-29 | KDDI | Rel-13 | SP-57 | Stage 1/2/3 | Eriko Yoshida (er-yoshida@kddi.com) | Alain |  |  | UPCON |  |  |
| 57 | 32.1 | Stage 1 for User Plane Congestion management | 129d? | 2012-09-12 A | 2013-03-06 A | 100% |  | 2012-02-02 | 2013-03-06 | 289d? |  | start no earlier than 2012-09-12 | S1 | 1032h | 1032h | UPCON-ST1 | PCG-29 | KDDI | Rel-13 | SP-57 | 22.101 | Eriko Yoshida (er-yoshida@kddi.com) | Alain |  |  |  |  |  |
| 58 | 32.2 | TR on Stage 2 for User Plane Congestion management | 595d? | 2012-12-12 A | 2015-03-18 A | 100% |  | 2012-12-12 | 2014-12-10 | 525d? |  | finish no earlier than 2015-03-18 | S2 | 4760h | 4760h | UPCON-SA2TR | PCG-30 | Allot | Rel-13 | SP-58 | new TR 23.705 | Alla Goldner (agoldner@allot.com) | Maurice |  |  |  |  |  |
| 59 | 32.3 | Deleted - Stage 2 for User Plane Congestion management | 261d? | 2012-12-19 A | 2013-12-11 A | 100% |  | 2012-12-19 | 2013-12-11 | 261d? |  | finish no earlier than 2013-12-11 | S2 | 2088h | 2088h | UPCON-SA2Del | PCG-30 | NEC | Rel-13 | SP-58 | TBD | andreas.maeder@neclab.eu | Maurice |  |  |  | PCG-32 | SP-62 |

Notes:
- 34: . 3/3: WID tdoc number updated
- 35: Acronym changed from "MBMS_enh-SA2TR". Mar15: 0->10%
- 36: Commented during RAN#67 that it should have never beeen here (was 3/12/14 to 14/9/15, 0%)
- 37: 1/4/15: TS number added
- 38: 8/4/15: line added
- 39: 8/4/15: line added
- 40: SP#62 completion 06/14=>09/14. Linked to Rel-12 Study TR 22.888 (FS_MTCe) and to Features Rel-11 SIMTC & Rel-12 MTCe and MOSAP
- 41: SP#64 completed. TR 22.853v200 for Approval. External requirements from oneM2M TR0001(oneM2M Use Case collection), TS0002 (M2M Requirements)
- 42: SP#65 completed
- 43: SP#65 completed. Linked to Rel-13 SEES, Rel-12 Support for Interworking with M2M Service Enablement (MTCe-SIMSE), Service Requirement Maintenance (MTCe-SRM). Decide which MTC reqs with no Stage 2 should be removed/maintained in Rel-13.
- 44: SP#65 completed. Some Rel-12 service reqs have no Stage 2/3 implementation
- 45: SP#65 completed. Triggered by Rel-13 Study TR 22.806
- 46: Results from MCC Split of the SA1 feature into F+BB for stage 1
- 47: Presented at CT#66
- 48: Presented at CT#66
- 49: Presented at CT#66
- 50: SP#65 approved WID & completed. Triggered by Rel-13 TR 22.810. Linked to Multimedia Telephony Service for IMS (UID_7038), Customized Alerting Tone (CAT) UID_370028, Customized Ringing Signal (CRS) UID_380067
- 51: SP#65 WID approved & completed. Triggered by Rel-13 TR 22.808 (FS_FMSS)
- 52: SP#65 WID approved & completed. Triggered by Rel-13 TR 22.808 (FS_FMSS). Dec.14: moved from Feature to S1 BB
- 53: 3/3: TR number added.Mar15: 15->20%
- 55: SP#65 exception in SP-140515. Triggered by TR 22.852 (FS_RSE and FS_GUSH). Completed.
- 56: SP#65 updated WID SP-140153=>SP-140631 (BBII & BBIII stopped). Triggered by Rel-12 TR 22.805 Study on User Plane Congestion management (FS_UPCON)
- 57: SP#63 moved to Rel-13 updated WID SP-120890=>SP-140153. SP#59 completed. Convert TR 22.805 clause 6 consolidated requirements to normative requirements in 22.101. 3/3/15: start date corrected (was Mar 12)
- 58: SP#65 updated WID SP-140153=>SP-140631. TR 23.705v100 for Information. Dec.14: 87->98%. Mar15: 100%
- 59: SP#62 stopped at 0% completion

| ID | WBS | Task | Duration | Start | Finish | Complete | Remaining | Baseline start | Baseline finish | Baseline duration | Total slack | Constraint | Resources | Work | Actual work | Acronym | PCG approved | WI rapporteur name | WI rapporteur e-mail | Release | TSG approved | MCC resp | Acronym_3GU_Export | PCG stopped | TSG stopped | Status Report | Special Focus Doc |
| --- | --- | --- | --- | --- | --- | --- | --- | --- | --- | --- | --- | --- | --- | --- | --- | --- | --- | --- | --- | --- | --- | --- | --- | --- | --- | --- | --- |
| 60 | 32.4 | **BB1: RAN Downlink Traffic Differentiation, Congestion Detection and Reporting** | 269d? | 2014-03-07 A | 2015-03-13 | 80% | 53.46d? | 2014-03-07 | 2015-06-17 | 334d? | 589d |  | S2 | 10048h | 6790.94h | UPCON-DOTCON | PCG-32 | Allot | Alla Goldner (agoldner@allot.com) | Rel-13 | SP-63 | Maurice | UPCON-DOTCON |  |  |  |  |
| 61 | 32.4.1 | Stage 2 for RAN Downlink Traffic Differentiation, Congestion Detection and Reporting | 201d? | 2014-03-07 A | 2014-12-12 A | 100% |  | 2014-03-07 | 2015-06-17 | 334d? |  | finish no earlier than 2014-12-12 | S2 | 1608h | 1608h | UPCON-DOTCON-SA2 | PCG-32 | Allot | Alla Goldner (agoldner@allot.com) | Rel-13 | SP-63 | Maurice |  |  |  |  |  |
| 62 | 32.4.2 | **CT aspects of User Plane Congestion Management for BB1** | 262d? | 2014-03-18 A | 2015-03-13 | 73% | 72.04d? |  |  |  | 589d |  | C3 | 6288h | 4558.84h | UPCON-DOTCON-CT | PCG-33 | Huawei | Xia Haitao (xiahaitao@huawei.com) | Rel-13 | CP-65 |  | UPCON-DOTCON-CT |  |  |  |  |
| 63 | 32.4.2.1 | CT3 part of CT aspects of User Plane Congestion Management for BB1 | 262d? | 2014-03-18 A | 2015-03-13 | 95% | 13.1d? |  |  |  | 589d | finish no earlier than 2015-03-13 | C3 | 2096h | 1991.2h | UPCON-DOTCON-CT | PCG-33 | Huawei | Xia Haitao (xiahaitao@huawei.com) | Rel-13 | CP-65 |  |  |  |  |  |  |
| 64 | 32.4.2.2 | CT4 part of CT aspects of User Plane Congestion Management for BB1 | 262d? | 2014-03-18 A | 2015-03-13 | 50% | 131d? |  |  |  | 589d | finish no earlier than 2015-03-13 | C4 | 2096h | 1048h | UPCON-DOTCON-CT | PCG-33 | Huawei | Xia Haitao (xiahaitao@huawei.com) | Rel-13 | CP-65 |  |  |  |  |  |  |
| 65 | 32.5 | Deleted - BB2: Application and Content Prioritization | 140d? | 2014-03-07 A | 2014-09-17 A | 100% |  | 2014-03-07 | 2015-06-17 | 334d? |  | finish no earlier than 2014-09-17 | S2 | 1120h | 1120h | UPCON-CONDEL | PCG-32 | Allot | Alla Goldner (agoldner@allot.com) | Rel-13 | SP-63 | Maurice | UPCON-CON | PCG-33 | SP-65 |  |  |
| 66 | 32.6 | Deleted - BB3: Uplink traffic and attended/unattended traffic | 140d? | 2014-03-07 A | 2014-09-17 A | 100% |  | 2014-03-07 | 2015-06-17 | 334d? |  | finish no earlier than 2014-09-17 | S2 | 1120h | 1120h | UPCON-TRAFDEL | PCG-32 | Allot | Alla Goldner (agoldner@allot.com) | Rel-13 | SP-63 | Maurice | UPCON-TRAF | PCG-33 | SP-65 |  |  |
| 67 | 33 | **Media Handling Aspects of IMS-based Telepresence** | 334d? | 2014-09-09 A | 2015-12-16 | 20% | 267.2d? |  |  |  | 391d |  | S4 | 7496h | 1499.16h | IMS_TELEP_S4 | PCG-33 | Intel | ozgur.oyman@intel.com | Rel-13 | SP-65 |  | IMS_TELEP_S4 |  |  |  |  |
| 68 | 33.1 | TR on Media Handling Aspects of IMS-based Telepresence | 269d? | 2014-09-09 A | 2015-09-16 | 20% | 215.2d? |  |  |  | 456d | finish no earlier than 2015-09-16 | S4 | 2152h | 430.4h | IMS_TELEP_S4-SA4TR | PCG-33 | Intel | ozgur.oyman@intel.com | Rel-13 | SP-65 |  |  |  |  |  |  |
| 69 | 33.2 | Specification on Media Handling Aspects of IMS-based Telepresence | 334d? | 2014-09-09 A | 2015-12-16 | 20% | 267.2d? |  |  |  | 391d | finish no earlier than 2015-12-16 | S4 | 2672h | 534.4h | IMS_TELEP_S4-SA4 | PCG-33 | Intel | ozgur.oyman@intel.com | Rel-13 | SP-65 |  |  |  |  |  |  |
| 70 | 34 | **RAN Sharing Enhancements** | 592d? | 2013-06-19 A | 2015-09-15 | 46% | 318.54d? | 2013-06-19 | 2013-12-11 | 129d? | 457d |  | S1; R3 | 14744h | 3944h | RSE | PCG-31 | NEC | joerg.swetina@neclab.eu | Rel-13 | SP-60 | Alain | RSE |  |  |  |  |
| 71 | 34.1 | Stage 1 for RAN Sharing Enhancements | 129d? | 2013-06-19 A | 2013-12-11 A | 100% |  | 2013-06-19 | 2013-12-11 | 129d? |  |  | S1 | 1032h | 1032h | RSE-SA1 | PCG-31 | NEC | joerg.swetina@neclab.eu | Rel-13 | SP-60 | Alain |  |  |  |  |  |
| 72 | 34.2 | **RAN aspects of RAN Sharing Enhancements for LTE** | 265d? | 2014-09-12 A | 2015-09-15 | 20% | 212d? | 2014-06-13 | 2015-06-12 | 261d? | 457d |  | R3 | 4240h | 848h | RSE-RAN_LTE | PCG-33 | NEC | Siva.Vakeesar@emea.nec.com | Rel-13 | RP-65 |  | RSE-RAN_LTE |  |  |  |  |
| 73 | 34.2.1 | Core part: RAN aspects of RAN Sharing Enhancements for LTE | 265d? | 2014-09-12 A | 2015-09-15 | 20% | 212d? | 2014-06-13 | 2015-06-12 | 261d? | 457d | finish no earlier than 2015-09-15 | R3 | 2120h | 424h | RSE-RAN_LTE-Core | PCG-33 | NEC | Siva.Vakeesar@emea.nec.com | Rel-13 | RP-65 |  | RSE-RAN_LTE-Core |  |  | RP-150289 |  |
| 74 | 35 | **Enhancements to WEBRTC interoperability** | 337d? | 2014-03-07 A | 2015-06-17 | 35% | 219.52d? | 2014-03-07 | 2015-06-17 | 334d? | 521d |  | S1; S2; S3 | 15424h | 4334.62h | eWebRTCi | PCG-32 | Alcatel-Lucent | betsy.covell@alcatel-lucent.com | Rel-13 | SP-63 | Alain | eWebRTCi |  |  |  |  |
| 75 | 35.1 | Stage 1 for Enhancements to WEBRTC interoperability | 139d? | 2014-03-07 A | 2014-09-17 A | 100% |  | 2014-03-07 | 2014-09-17 | 139d? |  | finish no earlier than 2014-09-17 | S1 | 1112h | 1112h | eWebRTCi | PCG-32 | Alcatel-Lucent | betsy.covell@alcatel-lucent.com | Rel-13 | SP-63 | Alain |  |  |  | S1-143303 |  |
| 76 | 35.2 | TR on Stage 2 for Enhancements to WEBRTC interoperability | 196d? | 2014-06-19 A | 2015-03-18 | 55% | 88.2d? | 2014-06-18 | 2015-03-18 | 196d? | 586d | finish no earlier than 2015-03-18 | S2 | 1568h | 862.4h | eWebRTCi | PCG-33 | China Mobile | Yu Qing (yuqing@chinamobile.com) | Rel-13 | SP-64 |  |  |  |  |  |  |
| 77 | 35.3 | Stage 2 for Enhancements to WEBRTC interoperability | 261d? | 2014-06-23 | 2015-06-17 |  |  | 2014-06-18 | 2015-06-17 | 261d? | 521d | finish no earlier than 2015-06-17 | S2 | 2088h |  | eWebRTCi | PCG-33 | China Mobile | Yu Qing (yuqing@chinamobile.com) | Rel-13 | SP-64 |  |  |  |  |  |  |
| 78 | 35.4 | TR on Security for Enhancements to WEBRTC interoperability | 197d? | 2014-09-17 A | 2015-06-16 | 30% | 137.9d? |  |  |  | 522d | start no earlier than 2014-09-17 | S3 | 1576h | 472.8h | eWebRTCi | PCG-33 | Ericsson | vesa.lehtovirta@ericsson.com | Rel-13 | SP-65 |  |  |  |  |  |  |
| 79 | 35.5 | Security for Enhancements to WEBRTC interoperability | 198d? | 2014-09-17 A | 2015-06-17 | 20% | 158.4d? |  |  |  | 521d | start no earlier than 2014-09-17 | S3 | 1584h | 316.8h | eWebRTCi | PCG-33 | Ericsson | vesa.lehtovirta@ericsson.com | Rel-13 | SP-65 |  |  |  |  |  |  |
| 80 | 36 | **Improvements to CS/PS coordination in UTRAN/GERAN Shared Networks** | 204d? | 2014-03-07 A | 2014-12-12 A | 100% |  | 2014-03-07 | 2014-12-10 | 199d? |  |  | S2 | 4360h | 4360h | CSPS_Coord | PCG-32 | Ericsson | roland.gustafsson@ericsson.com | Rel-13 | SP-63 | Maurice | CSPS_Coord |  |  |  |  |
| 81 | 36.1 | TR on Stage 2 for Improvements to CS/PS coordination in UTRAN/GERAN Shared Networks | 140d? | 2014-03-07 A | 2014-09-17 A | 100% |  | 2014-03-07 | 2014-12-10 | 199d? |  | finish no earlier than 2014-09-17 | S2 | 1120h | 1120h | CSPS_Coord-SA2TR | PCG-32 | Ericsson | roland.gustafsson@ericsson.com | Rel-13 |  | Maurice |  |  |  |  |  |
| 82 | 36.2 | Stage 2 for Improvements to CS/PS coordination in UTRAN/GERAN Shared Networks | 201d? | 2014-03-12 A | 2014-12-12 A | 100% |  | 2014-03-07 | 2014-12-10 | 199d? |  | finish no earlier than 2014-12-12 | S2 | 1608h | 1608h | CSPS_Coord-SA2 | PCG-32 | Ericsson | roland.gustafsson@ericsson.com | Rel-13 |  | Maurice |  |  |  |  |  |
| 83 | 37 | **Enhancements to Proximity-based Services** | 329d? | 2014-06-18 A | 2015-09-16 | 23% | 252.42d? | 2014-06-18 | 2015-06-12 | 258d? | 456d |  | S1; S2; S3 | 14136h | 1953.78h | eProSe | PCG-33 | Qualcomm | Eddy Hall (edhall@qti.qualcomm.com) | Rel-13 | SP-64 |  | eProSe |  |  |  | Public Safety (A-A) |
| 84 | 37.1 | Stage 1 for Enhancements to Proximity-based Services | 66d? | 2014-06-19 A | 2014-09-17 A | 100% |  | 2014-06-18 | 2014-09-17 | 66d? |  | finish no earlier than 2014-09-17 | S1 | 528h | 528h | eProSe-SA1 | PCG-33 | Qualcomm | Eddy Hall (edhall@qti.qualcomm.com) | Rel-13 | SP-64 |  |  |  |  |  | Public Safety (A-A) |
| 85 | 37.2 | Stage 2 for Enhancements to Proximity-based Services - Extensions | 261d? | 2014-06-23 | 2015-06-17 |  |  | 2014-06-18 | 2015-06-12 | 258d? | 521d | finish no earlier than 2015-06-17 | S2 | 2088h |  | eProSe-Ext-SA2 | PCG-33 | Qualcomm | Haris Zisimopoulos (harisz@qti.qualcomm.com) | Rel-13 | SP-64 |  | eProSe-Ext |  |  |  | Public Safety (A-A) |
| 86 | 37.3 | TR on Stage 2 for Enhancements to Proximity-based Services - Extensions | 193d? | 2014-06-18 A | 2015-03-13 | 60% | 77.2d? | 2014-06-18 | 2015-03-13 | 193d? | 589d | finish no earlier than 2015-03-13 | S2 | 1544h | 926.4h | eProSe-Ext-SA2TR | PCG-33 | Qualcomm | Haris Zisimopoulos (harisz@qti.qualcomm.com) | Rel-13 | SP-64 |  |  |  |  |  | Public Safety (A-A) |
| 87 | 37.4 | Security for Enhancements to Proximity-based Services - Extensions | 261d? | 2014-09-19 | 2015-09-16 |  |  |  |  |  | 456d | finish no earlier than 2015-09-16 | S3 | 2088h |  | eProSe-Ext-SA3 | PCG-33 | Qualcomm | Adrian Escott (aescott@qti.qualcomm.com) | Rel-13 | SP-65 |  |  |  |  |  | Public Safety (A-A) |

Notes:
- 60: SP#65 updated WID SP-140153=>SP-140631. Includes: RAN Congestion Detection: , RAN Traffic Differentiation, RAN Congestion Reporting, CN Congestion Mitigation mechanisms, Dynamic Policy Control
- 61: SP#65 updated WID SP-140153=>S2-142850 (added impacted specs). Dec.14: 70->100% only if RAN agrees to standardize the FPI / Impacted TSs and TRs: 23.060, 23.203, 23.401
- 62: Stage 3; WID: CP-140734->CP-140929 / Impacted TSs and TRs: Stage 3
- 63: Dec.14: 0->60; WID: CP-140734->CP-140929. Mar.15: 60->95% / Impacted TSs and TRs: 29.201, 29.212, 29.213, 29.214, 29.215, 29.219, New TS 29.217 (PCC over Np)
- 64: Dec.14: 0->20; WID: CP-140734->CP-140929. Mar. 15: 50% / Impacted TSs and TRs: 23.003, 29.303, New TS 29.405 (UPCON over Nq)
- 65: SP#65 updated WID SP-140153=>SP-140631 (BBII & BBIII stopped). Includes: Content specific UP prioritization (Video), Application specific UP prioritization / Impacted TSs and TRs: TBD
- 66: SP#65 updated WID SP-140153=>SP-140631 (BBII & BBIII stopped). Includes: Uplink Congestion Management, Un/Attended UE Information / Impacted TSs and TRs: TBD
- 67: Can be seen as an "enhancement" of Rel-12 IMS-based Telepresence (IMS_TELEP) UID_530042. Mar. 15: 20%
- 68: Dec.14: 0->10%. 8/4/15: 20% / Impacted TSs and TRs: New TR 26.9xy
- 69: Dec.14: 0->10%. 8/4/15: 20% / Impacted TSs and TRs: New TS 26.1xy
- 70: Triggered by Rel-12 TR 22.852 Study on RAN Sharing Enhancements (FS_RSE)
- 71: SP#62 completed / Impacted TSs and TRs: 22.101
- 72: Triggered by TR 36.856 Study on RAN aspects of RAN Sharing Enhancements for LTE (FS_RSE-RAN_LTE) & SA1 22.101 Stage 1 / Impacted TSs and TRs: LTE
- 73: ; CD:Mon 15/06/15->Tue 15/09/15; Stat Rep: -->RP-141891 1st Apr 15: Compl:15%->20% 1st Apr 15: Stat Rep: RP-141891->RP-150289 / Impacted TSs and TRs: 36.300, 36.413, 36.423
- 74: SP#65 updated WID SP-14028=>SP-140630 (added SA3 part, SA1 change). Add enhanced interoperability support for WebRTC to Rel-12 Web Real Time Communication (WebRTC) Access to IMS. / Impacted TSs and TRs: Stage 1/2
- 75: SP#65 completed. Updated WID SP-140286=>SP-140630 / Impacted TSs and TRs: 22.228
- 76: SP#65 updated WID SP-14028=>SP-140630 (added SA3 part). Dec.14: 9->55% / Impacted TSs and TRs: New TR 23.706
- 77: SP#65 updated WID SP-14028=>SP-140630 (added SA3 part) / Impacted TSs and TRs: 23.228
- 78: SP#65 updated WID SP-14028=>SP-140630 (added SA3 part). Dec.14: 0->20%, TR number added. 3/3/15: 30%. / Impacted TSs and TRs: New TR 33.872
- 79: SP#65 updated WID SP-14028=>SP-140630 (added SA3 part). Dec.14: 0->20% / Impacted TSs and TRs: 33.203, 33.328
- 80: Provide improvements to the solutions for CS/PS coordination in TS 23.251 to ensure that CS/PS coordination can be achieved for all mobility scenarios / Impacted TSs and TRs: Stage 2
- 81: SP#65 completed. TR 23.704v200 for Approval / Impacted TSs and TRs: New TR 23.704
- 82: Dec.14: 0->100% / Impacted TSs and TRs: 23.216, 23.251, 23.272
- 83: - / Impacted TSs and TRs: Stage 1/2
- 84: SP#65 completed. Some Rel-12 ProSe service requirements have not been implemented at Stage 2/3 level. These are taken up in Rel-13 Stage 2/3 and need Stage 1 appropriate service requirements. No new service requirements are introduced. / Impacted TSs and TRs: 22.115, 22.278
- 85: SP#65 updated WID SP-140385=>SP-140573 (added SA3 part). Mar15: WID: SP-140573 ->SP-150028 / Impacted TSs and TRs: 23.303, TBD
- 86: SP#65 updated WID SP-140385=>SP-140573 (added SA3 part). Acronym corrected: eProSe-Ex-SA2TRt->eProSe-Ext-SA2TR. Mar15: 60% Mar15: WID: SP-140573 ->SP-150028 / Impacted TSs and TRs: New TR 23.713
- 87: SP#65 updated WID SP-140385=>SP-140573 (added SA3 part). Specify selected security solutions based on the outcome of SA3 study TR 33.833. Acronym corrected: eProSe-Ex-SA3t->eProSe-Ext-SA3. Mar15: WID: SP-140573 ->SP-150028 / Impacted TSs and TRs: 33.303

| ID | WBS | Task | Duration | Start | Finish | Complete | Remaining | Baseline start | Baseline finish | Baseline duration | Total slack | Constraint | Resources | Work | Actual work | Acronym | PCG approved | Impacted TSs and TRs | WI rapporteur name | WI rapporteur e-mail | Release | TSG approved | Acronym_3GU_Export |
| --- | --- | --- | --- | --- | --- | --- | --- | --- | --- | --- | --- | --- | --- | --- | --- | --- | --- | --- | --- | --- | --- | --- | --- |
| 88 | 38 | **voice over E-UTRAN Paging Policy Differentiation** | 133d? | 2014-06-16 A | 2014-12-12 | 90% | 13.09d? | 2014-06-16 | 2014-12-10 | 128d? | 654d |  | S1; S2; C4; C1; C3 | 9244.75h | 8231.56h | voE_UTRAN_PPD | PCG-33 | Stage 1/2 | Alcatel-Lucent | (betsy.covell@alcatel-lucent.com) | Rel-13 | SP-64 | voE_UTRAN_PPD |
| 89 | 38.1 | Stage 1 for voice over E-UTRAN Paging Policy Differentiation | 3d? | 2014-06-16 A | 2014-06-18 A | 100% |  | 2014-06-16 | 2014-06-18 | 3d? |  | finish no earlier than 2014-06-18 | S1 | 24h | 24h | voE_UTRA-N_PPD-SA1 | PCG-33 | 22.228, 22.278 | Alcatel-Lucent | betsy.covell@alcatel-lucent.com | Rel-13 | SP-64 |  |
| 90 | 38.2 | Stage 2 for voice over E-UTRAN Paging Policy Differentiation | 128d? | 2014-06-18 A | 2014-12-12 A | 100% |  | 2014-06-18 | 2014-12-10 | 126d? |  | finish no earlier than 2014-12-12 | S2 | 1024h | 1024h | voE_UTRAN_PPD-SA2 | PCG-33 | 23.228, 23.401 | Alcatel-Lucent | laurent.thiebaut@alcatel-lucent.com | Rel-13 | SP-64 |  |
| 91 | 38.3 | **CT aspects of voice over E-UTRAN Paging Policy Differentiation** | 63d? | 2014-09-16 A | 2014-12-09 | 83% | 10.5d? |  |  |  | 657d |  | C4; C1; C3 | 3024h | 2520h | voE_UTRAN_PPD-CT | PCG-33 | Stage 3 | Alcatel-Lucent | bruno.landais@alcatel-lucent.com | Rel-13 | CP-65 |  |
| 92 | 38.3.1 | CT4 part of CT aspects of voice over E-UTRAN Paging Policy Differentiation | 63d? | 2014-09-16 A | 2014-12-09 A | 100% |  |  |  |  |  | finish no earlier than 2014-12-09 | C4 | 504h | 504h | voE_UTRAN_PPD-CT | PCG-33 | 29.274, 29.281 | Alcatel-Lucent | bruno.landais@alcatel-lucent.com | Rel-13 | CP-65 |  |
| 93 | 38.3.2 | CT1 part of CT aspects of voice over E-UTRAN Paging Policy Differentiation | 63d? | 2014-09-16 A | 2014-12-09 | 50% | 31.5d? |  |  |  | 657d | finish no earlier than 2014-12-09 | C1 | 504h | 252h | voE_UTRAN_PPD-CT | PCG-33 | 24.229 | Alcatel-Lucent | bruno.landais@alcatel-lucent.com | Rel-13 | CP-65 |  |
| 94 | 38.3.3 | CT3 part of CT aspects of voice over E-UTRAN Paging Policy Differentiation | 63d? | 2014-09-16 A | 2014-12-09 A | 100% |  |  |  |  |  | finish no earlier than 2014-12-09 | C3 | 504h | 504h | voE_UTRAN_PPD-CT | PCG-33 | 29.061 | Alcatel-Lucent | bruno.landais@alcatel-lucent.com | Rel-13 | CP-65 |  |
| 95 | 39 | **Dedicated Core Networks** | 199d? | 2014-06-18 A | 2015-03-18 | 82% | 36.11d? | 2014-06-18 | 2015-03-18 | 196d? | 586d |  | S2 | 4184h | 3424.7h | DECOR | PCG-33 | Stage 2 | NTT DOCOMO | Daisuke Fujishima (fujishimad@nttdocomo.co.jp) | Rel-13 | SP-64 | DECOR |
| 96 | 39.1 | TR for Dedicated Core Networks | 128d? | 2014-06-18 A | 2014-12-12 A | 100% |  | 2014-06-18 | 2014-12-10 | 126d? |  | finish no earlier than 2014-12-12 | S2 | 1024h | 1024h | DECOR | PCG-33 | New TR 23.707 | NTT DOCOMO | Daisuke Fujishima (fujishimad@nttdocomo.co.jp) | Rel-13 | SP-64 |  |
| 97 | 39.2 | Stage 2 for Dedicated Core Networks | 196d? | 2014-06-23 A | 2015-03-18 | 70% | 58.8d? | 2014-06-18 | 2015-03-18 | 196d? | 586d | finish no earlier than 2015-03-18 | S2 | 1568h | 1097.6h | DECOR | PCG-33 | 23.060, 23.401, 23.236 | NTT DOCOMO | Daisuke Fujishima (fujishimad@nttdocomo.co.jp) | Rel-13 | SP-64 |  |
| 98 | 40 | **IP Flow Mobility support for S2a and S2b Interfaces** | 264d? | 2014-06-18 A | 2015-06-17 | 26% | 196.66d? | 2014-06-18 | 2015-06-17 | 261d? | 521d |  | S2 | 5744h | 1465.09h | NBIFOM | PCG-33 | Stage 2 | ZTE | Tricci So (tso@zteusa.com) | Rel-13 | SP-64 | NBIFOM |
| 99 | 40.1 | TR for IP Flow Mobility support for S2a and S2b Interfaces | 193d? | 2014-06-18 A | 2015-03-13 | 60% | 77.2d? | 2014-06-18 | 2015-03-13 | 193d? | 589d | finish no earlier than 2015-03-13 | S2 | 1544h | 926.4h | NBIFOM-SA2TR | PCG-33 | New TR 23.861 | ZTE | Tricci So (tso@zteusa.com) | Rel-13 | SP-64 |  |
| 100 | 40.2 | Stage 2 for IP Flow Mobility support for S2a and S2b Interfaces | 261d? | 2014-06-23 | 2015-06-17 |  |  | 2014-06-18 | 2015-06-17 | 261d? | 521d | finish no earlier than 2015-06-17 | S2 | 2088h |  | NBIFOM-SA2 | PCG-33 | 23.402, TBD | ZTE | Tricci So (tso@zteusa.com) | Rel-13 | SP-64 |  |
| 101 | 41 | **Architecture Enhancements for Service capability Exposure** | 329d? | 2014-06-18 A | 2015-09-16 | 25% | 246.9d? | 2014-06-18 | 2015-09-16 | 326d? | 456d |  | S2; S3 | 13459.2h | 2701.84h | AESE | PCG-33 | Stage 2 | Intel | puneet.jain@intel.com | Rel-13 | SP-64 | AESE |
| 102 | 41.1 | TR for Architecture Enhancements for Service capability Exposure | 196d? | 2014-06-18 A | 2015-03-18 | 75% | 49d? | 2014-06-18 | 2015-03-18 | 196d? | 586d | finish no earlier than 2015-03-18 | S2 | 1568h | 1176h | AESE | PCG-33 | New TR 23.708 | Intel, Puneet Jain | puneet.jain@intel.com | Rel-13 | SP-64 |  |
| 103 | 41.2 | Stage 2 for Architecture Enhancements for Service capability Exposure | 261d? | 2014-06-23 | 2015-06-17 |  |  | 2014-06-18 | 2015-06-17 | 261d? | 521d | finish no earlier than 2015-06-17 | S2 | 2088h |  | AESE | PCG-33 | TS 23.682, TS 33.187 | Intel, Puneet Jain | puneet.jain@intel.com | Rel-13 | SP-64 |  |
| 104 | 41.3 | TR on Security for Architecture Enhancements for Service capability Exposure | 241.4d? | 2014-06-23 A | 2015-06-17 | 45% | 132.77d? | 2014-06-18 | 2015-06-17 | 241.4d? | 521d | finish no earlier than 2015-06-17 | S3 | 1931.2h | 869.04h | AESE | PCG-33 | New TR 33.889 | Samsung | Rajavelsamy R (rajvel@samsung.com) | Rel-13 | SP-64 |  |
| 105 | 41.4 | Security for Architecture Enhancements for Service capability Exposure | 326d? | 2014-06-23 | 2015-09-16 |  |  | 2014-06-18 | 2015-09-16 | 326d? | 456d | finish no earlier than 2015-09-16 | S3 | 2608h |  | AESE | PCG-33 | 33.187 | Samsung | Rajavelsamy R (rajvel@samsung.com) | Rel-13 | SP-64 |  |
| 106 | 42 | **Monitoring Enhancements** | 329d? | 2014-06-18 A | 2015-09-16 | 22% | 257.94d? | 2014-06-18 | 2015-09-16 | 326d? | 456d |  | S2; S3 | 13380.8h | 2890.28h | MONTE | PCG-33 | Stage 2 | Intel | puneet.jain@intel.com | Rel-13 | SP-64 | MONTE |
| 107 | 42.1 | TR for Monitoring Enhancements | 196d? | 2014-09-17 A | 2015-06-17 A | 100% |  | 2014-09-17 | 2015-06-17 | 196d? |  | finish no earlier than 2015-06-17 | S2 | 1568h | 1568h | MONTE | PCG-33 | New TR 23.789 | Intel, Puneet Jain | puneet.jain@intel.com | Rel-13 | SP-64 |  |
| 108 | 42.2 | Stage 2 for Monitoring Enhancements | 261d? | 2014-06-23 | 2015-06-17 |  |  | 2014-06-18 | 2015-06-17 | 261d? | 521d | finish no earlier than 2015-06-17 | S2 | 2088h |  | MONTE | PCG-33 | 23.682, TBD | Intel, Puneet Jain | puneet.jain@intel.com | Rel-13 | SP-64 |  |
| 109 | 42.3 | TR on Security for Monitoring Enhancements | 231.6d? | 2014-06-18 A | 2015-06-12 | 10% | 208.44d? | 2014-06-18 | 2015-06-17 | 231.6d? | 524d | start no earlier than 2014-06-18 | S3 | 1852.8h | 185.28h | MONTE | PCG-33 | New TR 33.889 | Samsung | Rajavelsamy R (rajvel@samsung.com) | Rel-13 | SP-64 |  |
| 110 | 42.4 | Security for Monitoring Enhancements | 326d? | 2014-06-23 | 2015-09-16 |  |  | 2014-06-18 | 2015-09-16 | 326d? | 456d | finish no earlier than 2015-09-16 | S3 | 2608h |  | MONTE | PCG-33 | 33.187 | Samsung | Rajavelsamy R (rajvel@samsung.com) | Rel-13 | SP-64 |  |
| 111 | 43 | **Group based Enhancements** | 329d? | 2014-06-18 A | 2015-09-16 | 25% | 247.37d? | 2014-06-18 | 2015-09-16 | 326d? | 456d |  | S2; S3 | 13380.8h | 2667.14h | GROUPE | PCG-33 | Stage 2 | Huawei | ZhangWanqiang@huawei.com | Rel-13 | SP-64 | GROUPE |
| 112 | 43.1 | TR for Group based Enhancements | 196d? | 2014-06-18 A | 2015-03-18 | 90% | 19.6d? | 2014-06-18 | 2015-03-18 | 196d? | 586d | finish no earlier than 2015-03-18 | S2 | 1568h | 1411.2h | GROUPE | PCG-33 | New TR 23.769 | Huawei, Wanqiang Zhang | ZhangWanqiang@huawei.com | Rel-13 | SP-64 |  |
| 113 | 43.2 | Stage 2 for Group based Enhancements | 261d? | 2014-06-23 A | 2015-06-17 | 20% | 208.8d? | 2014-06-18 | 2015-06-17 | 261d? | 521d | finish no earlier than 2015-06-17 | S2 | 2088h | 417.6h | GROUPE | PCG-33 | 23.682, TBD | Huawei | ZhangWanqiang@huawei.com | Rel-13 | SP-64 |  |
| 114 | 43.3 | TR on Security for Group based Enhancements | 231.6d? | 2014-06-18 A | 2015-06-12 | 10% | 208.44d? | 2014-06-18 | 2015-06-17 | 231.6d? | 524d | start no earlier than 2014-06-18 | S3 | 1852.8h | 185.28h | GROUPE | PCG-33 | New TR 33.889 | Samsung | Rajavelsamy R (rajvel@samsung.com) | Rel-13 | SP-64 |  |
| 115 | 43.4 | Security for Group based Enhancements | 326d? | 2014-06-23 | 2015-09-16 |  |  | 2014-06-18 | 2015-09-16 | 326d? | 456d | finish no earlier than 2015-09-16 | S3 | 2608h |  | GROUPE | PCG-33 | 33.187 | Samsung | Rajavelsamy R (rajvel@samsung.com) | Rel-13 | SP-64 |  |

Notes:
- 88: -
- 89: SP#64 approved WID & completed
- 90: Architectural enhancements allowing a differentiated paging policy for IMS voice calls over E-UTRAN. Dec.14: 25->100%
- 91: Stage 3
- 92: Mar.15: 0->100%
- 93: Dec.14: 0->50%
- 94: Mar.15: 0->100%
- 95: Enable deployment of dedicated CNs to UEs sharing the same characteristics. The specific dedicated CN that serves a UE is selected based on subscription info and operator config, without requiring UEs to be modified.
- 96: Dec.14: 30->100%
- 97: Mar15: 0->70%
- 98: -
- 99: Revived the Rel-12 DRAFT TR 23.861 stopped at SP#59 (at 40% completion). Dec.14: 20->60%
- 100: -
- 101: -
- 102: Dec.14: 30->65%. Mar15: 75%
- 103: -
- 104: TR 33.8xy will capture requirements, solution alternatives, evaluations and conclusions for the AESE, MONTE and GROUPE WIDs. Dec.14: 0->40%. 3/3/15: 45%.
- 105: -
- 106: Linked to Rel-13 Feature Architecture Enhancements for Service Exposure (AESE). Although service requirements (TS 22.368 clause 7.2.8) are motivated by MTC, the solution may apply to normal UEs
- 107: Dec.14: 25->85%. Mar15: 100%
- 108: -
- 109: TR 33.8xy will capture requirements, solution alternatives, evaluations and conclusions for the AESE, MONTE and GROUPE WIDs.3/3/15: 5->10%.
- 110: -
- 111: -
- 112: Dec.14: 20->70%. Mar15: 90%
- 113: Mar15: 0->20%
- 114: TR 33.8xy will capture requirements, solution alternatives, evaluations and conclusions for the AESE, MONTE and GROUPE WIDs. 3/3/15: 5->10%.
- 115: -

| ID | WBS | Task | Duration | Start | Finish | Complete | Remaining | Baseline start | Baseline finish | Baseline duration | Total slack | Constraint | Resources | Work | Actual work | Acronym | PCG approved | WI rapporteur name | Release | TSG approved | Acronym_3GU_Export | MCC resp | Status Report |
| --- | --- | --- | --- | --- | --- | --- | --- | --- | --- | --- | --- | --- | --- | --- | --- | --- | --- | --- | --- | --- | --- | --- | --- |
| 116 | 44 | **Double Resource Reuse for Multiple Media Sessions** | 264d? | 2014-03-14 A | 2015-03-13 | 93% | 18.8d? | 2014-03-14 | 2015-03-13 | 261d? | 589d |  | S2 | 5952h | 5451.25h | DRuMS | PCG-33 | Ericsson | Rel-13 | SP-64 | DRuMS |  |  |
| 117 | 44.1 | Stage 2 for Double Resource Reuse for Multiple Media Sessions | 264d? | 2014-03-14 A | 2015-03-13 A | 100% |  | 2014-03-14 | 2015-03-13 | 261d? |  | finish no earlier than 2015-03-13 | S2 | 2088h | 2088h | DRuMS-SA2 | PCG-33 | Ericsson | Rel-13 | SP-64 |  |  |  |
| 118 | 44.2 | **CT aspects of Double Resource Reuse for Multiple Media Sessions** | 73d? | 2014-12-03 A | 2015-03-13 | 80% | 14.6d? |  |  |  | 589d |  | C3 | 1752h | 1401.62h | DRuMS-CT | PCG-34 | Ericsson | Rel-13 | CT-66 |  |  |  |
| 119 | 44.2.1 | CT1 aspects of Double Resource Reuse for Multiple Media Sessions | 73d? | 2014-12-03 A | 2015-03-13 | 65% | 25.55d? |  |  |  | 589d | start no earlier than 2014-12-03 | C1 | 584h | 379.6h | DRuMS-CT | PCG-34 | Ericsson | Rel-13 | CT-66 |  |  |  |
| 120 | 44.2.2 | CT3 aspects of Double Resource Reuse for Multiple Media Sessions | 73d? | 2014-12-03 A | 2015-03-13 | 95% | 3.65d? |  |  |  | 589d | start no earlier than 2014-12-03 | C3 | 584h | 554.8h | DRuMS-CT | PCG-34 | Ericsson | Rel-13 | CT-66 |  |  |  |
| 121 | 45 | **Security Assurance Specification for 3GPP network products** | 337d? | 2013-12-09 A | 2015-03-18 | 49% | 171.19d? | 2013-12-09 | 2015-03-18 | 334d? | 586d |  | S3 | 9600h | 4041.31h | SCAS | PCG-32 | NTT DOCOMO | Rel-13 | SP-62 | SCAS | Mirko |  |
| 122 | 45.1 | TR on Pilot development of Security Assurance Specification for MME network product class | 266d? | 2013-12-09 A | 2014-12-12 | 75% | 66.5d? | 2013-12-09 | 2014-12-10 | 264d? | 654d | finish no earlier than 2014-12-12 | S3 | 2120h | 1588h | SCAS-SA3Pil_TR | PCG-32 | NTT DOCOMO | Rel-13 | SP-62 |  | Mirko |  |
| 123 | 45.2 | Security Assurance Specification for 3GPP network product classes | 333d? | 2013-12-13 | 2015-03-18 |  |  | 2013-12-10 | 2015-03-18 | 333d? | 586d | finish no earlier than 2015-03-18 | S3 | 2664h |  | SCAS-SA3 | PCG-32 | China Mobile | Rel-13 | SP-62 |  | Mirko |  |
| 124 | 45.3 | TR on Security Assurance scheme for 3GPP network products | 266d? | 2013-12-09 A | 2014-12-12 | 85% | 39.9d? | 2013-12-09 | 2014-12-10 | 264d? | 654d | finish no earlier than 2014-12-12 | S3 | 2120h | 1800.8h | SCAS-SA3TR | PCG-32 | NTT DOCOMO | Rel-13 | SP-62 |  | Mirko |  |
| 125 | 46 | Lawful Interception in the 3GPP Rel-13 | 386d? | 2014-06-18 | 2015-12-04 |  |  | 2014-06-18 | 2015-12-09 | 386d? | 399d | start no earlier than 2014-06-18 | S3 | 3088h |  | LI13 | PCG-33 | PIDS, Alcatel-Lucent | Rel-13 | SP-64 | LI13 |  |  |
| 126 | 47 | Video enhancements by Region-Of-Interest information signalling | 263d? | 2014-06-18 A | 2015-06-19 | 40% | 157.8d? | 2014-06-18 | 2015-06-17 | 261d? | 519d | finish no earlier than 2015-06-19 | S4 | 2104h | 841.6h | ROI | PCG-33 | Intel | Rel-13 | SP-64 | ROI |  |  |
| 127 | 48 | **TV video profile** | 334d? | 2014-09-09 A | 2015-12-16 | 15% | 283.91d? |  |  |  | 391d |  | S4 | 8016h | 1202.29h | TVProf | PCG-33 | Orange | Rel-13 | SP-65 | TVProf |  |  |
| 128 | 48.1 | TR on TV video profile | 334d? | 2014-09-09 A | 2015-12-16 | 15% | 283.9d? |  |  |  | 391d | finish no earlier than 2015-12-16 | S4 | 2672h | 400.8h | TVProf-SA4TR | PCG-33 | Orange | Rel-13 | SP-65 |  |  |  |
| 129 | 48.2 | Specification on TV video profile | 334d? | 2014-09-09 A | 2015-12-16 | 15% | 283.9d? |  |  |  | 391d | finish no earlier than 2015-12-16 | S4 | 2672h | 400.8h | TVProf-SA4 | PCG-33 | Orange | Rel-13 | SP-65 |  |  |  |
| 130 | 49 | Enhanced LTE UE Delay test methods and requirements | 334d? | 2014-09-09 A | 2015-12-16 | 5% | 317.3d? |  |  |  | 391d | finish no earlier than 2015-12-16 | S4 | 2672h | 133.6h | E_LTE_UED | PCG-33 | Orange | Rel-13 | SP-65 | E_LTE_UED |  |  |
| 131 | 50 | HTML5 Presentation Layer | 334d? | 2014-09-09 A | 2015-12-16 | 10% | 300.6d? |  |  |  | 391d | finish no earlier than 2015-12-16 | S4 | 2672h | 267.2h | HTML5 | PCG-33 | Samsung | Rel-13 | SP-65 | HTML5 |  |  |
| 132 | 51 | **Support of EVS in 3G Circuit-Switched networks** | 334d? | 2014-09-09 A | 2015-12-16 | 4% | 320.77d? |  |  |  | 391d |  | S4; C4; C1; C3; R1; R2; R3 | 33069.6h | 688.21h | EVSoCS | PCG-33 | Qualcomm | Rel-13 | SP-65 | EVSoCS |  |  |
| 133 | 51.1 | SA4 aspects of EVS in 3G Circuit-Switched networks | 334d? | 2014-09-09 A | 2015-12-16 | 10% | 300.6d? |  |  |  | 391d | finish no earlier than 2015-12-16 | S4 | 2672h | 267.2h | EVSoCS-S4 | PCG-33 | Qualcomm | Rel-13 | SP-65 | EVSoCS |  |  |
| 134 | 51.2 | **CT aspects of EVS in 3G Circuit-Switched Networks** | 203d? | 2015-03-04 | 2015-12-11 |  |  |  |  |  | 394d |  | C4; C1; C3 | 9744h |  | EVSoCS-CT | PCG-34 | Qualcomm, Lena Chaponniere | Rel-13 | CP-67 |  |  |  |
| 135 | 51.2.1 | CT1 aspects of EVS in 3G Circuit-Switched Networks | 203d? | 2015-03-04 | 2015-12-11 |  |  |  |  |  | 394d | finish no earlier than 2015-12-11 | C1 | 1624h |  | EVSoCS-CT | PCG-34 | Qualcomm, Lena Chaponniere | Rel-13 | CP-67 |  |  |  |
| 136 | 51.2.2 | CT3 aspects of EVS in 3G Circuit-Switched Networks | 203d? | 2015-03-04 | 2015-12-11 |  |  |  |  |  | 394d | finish no earlier than 2015-12-11 | C3 | 1624h |  | EVSoCS-CT | PCG-34 | Qualcomm, Lena Chaponniere | Rel-13 | CP-67 |  |  |  |
| 137 | 51.2.3 | CT4 aspects of EVS in 3G Circuit-Switched Networks | 203d? | 2015-03-04 | 2015-12-11 |  |  |  |  |  | 394d | finish no earlier than 2015-12-11 | C4 | 1624h |  | EVSoCS-CT | PCG-34 | Qualcomm, Lena Chaponniere | Rel-13 | CP-67 |  |  |  |
| 138 | 51.3 | **Support of EVS over UTRAN CS** | 65.67d? | 2015-06-16 A | 2015-09-15 | 10% | 59.1d? |  |  |  | 457d |  | R2; R1; R3 | 3152h | 315.15h | EVSoCS_UTRAN | PCG-34 | Qualcomm | Rel-13 | RP-66 |  |  |  |
| 139 | 51.3.1 | Core part: Support of EVS over UTRAN CS | 65.67d? | 2015-06-16 A | 2015-09-15 | 10% | 59.1d? |  |  |  | 457d | finish no earlier than 2015-09-15 | R2; R1; R3 | 1576h | 157.6h | EVSoCS_UTRAN-Core | PCG-34 | Francesco Pica - Qualcomm Incorporated | Rel-13 | RP-66 |  |  | RP-150128 |
| 140 | 52 | Enhanced DASH (Dynamic Adaptive Streaming over HTTP in 3GPP) | 334d? | 2014-09-09 A | 2015-12-16 | 15% | 283.9d? |  |  |  | 391d | finish no earlier than 2015-12-16 | S4 | 2672h | 400.8h | eDASH | PCG-33 | Qualcomm, Huawei | Rel-13 | SP-65 | eDASH |  |  |

Notes:
- 116: - / Impacted TSs and TRs: Stage 2 / WI rapporteur e-mail: George.Foti@ericsson.com
- 117: Dec.14: 49->95%. Mar15: 100% / Impacted TSs and TRs: 23.203, 23.228 / WI rapporteur e-mail: George.Foti@ericsson.com
- 118: Impacted TSs and TRs: 24.229, 24.615, 24.610, 24.605, 29.212, 29.213, 29.214, 29.215
- 119: 5/5/15: C3 corrected in C1 / Impacted TSs and TRs: 24.229, 24.615, 24.610, 24.605
- 120: Mar.15: 65->95% / Impacted TSs and TRs: 29.212, 29.213, 29.214, 29.215 / WI rapporteur e-mail: Jan Holm
- 121: Triggered by Rel-12 TR 33.805 Study on Security Assurance Methodology for 3GPP Network Elements (FS_SECAM) / WI rapporteur e-mail: Alf Zugenmaier (alf.zugenmaier@hm.edu)
- 122: This TR collects input for the new TS 33.116. Dec.14: 55->70%. 3/3/15: 70->55%. 10/03/15: 55->75% / Impacted TSs and TRs: New TR 33.806 / WI rapporteur e-mail: Alf Zugenmaier (alf.zugenmaier@hm.edu)
- 123: This TS contains results of the first WID objective / Impacted TSs and TRs: New TS 33.116 / WI rapporteur e-mail: Judy Zhu (zhuhongru@chinamobile.com)
- 124: This TR contains results of the second WID objective. Dec.14: 75->85% / Impacted TSs and TRs: New TR 33.916 / WI rapporteur e-mail: Alf Zugenmaier (alf.zugenmaier@hm.edu)
- 125: SP#65 updated WID SP-140400=>SP-140578. 2/4/15: WID SP-140815->SP-150111 / Impacted TSs and TRs: 33.106, 33.107, 33.108 / WI rapporteur e-mail: Koen Jaspers (k.b.jaspers@minjus.nl), terry.jacobson@alcatel-lucent.com
- 126: Dec.14: 5->20%. Mar.15: 40% / Impacted TSs and TRs: 26.114 / WI rapporteur e-mail: ozgur.oyman@intel.com
- 127: Mar. 15: 5->15% / WI rapporteur e-mail: gilles.teniou@orange.com
- 128: Dec.14: 0->5% / Impacted TSs and TRs: New TR 26.9xy / WI rapporteur e-mail: gilles.teniou@orange.com
- 129: Dec.14: 0->5% / Impacted TSs and TRs: 26.234, 26.244, 26.346, 26.247, New TS 26.xyz / WI rapporteur e-mail: gilles.teniou@orange.com
- 130: Mar. 15: 0->5% / Impacted TSs and TRs: 26.131, 26.132 / WI rapporteur e-mail: stephane.ragot@orange.com
- 131: Triggered by Rel-12 TR 26.907 (Study of HTML5 and 3GPP User Services). Dec.14: 0->5%. Mar. 15: 10% / Impacted TSs and TRs: 26.140, 26.234, 26.247, 26.346, New TS 26.xyz / WI rapporteur e-mail: Imed Bouazizi (i.bouazizi@samsung.com)
- 132: Provide CS support of EVS to enhance voice quality in CS services over UTRAN (3G WCDMA). Dec.14: 0->5% / Impacted TSs and TRs: 26.103, 28.062, New TS 26.xyz (EVS; Speech Codec Frame Structure), New TS 26.xyw (EVS; Interface to Iu, Uu and Nb) / WI rapporteur e-mail: Imre Varga (ivarga@qti.qualcomm.com)
- 133: Created by MCC (duplicated from previously single-line Feature) due to the introduction of the CT BB. Mar. 15: 10% / Impacted TSs and TRs: 26.103, 28.062, New TS 26.xyz (EVS; Speech Codec Frame Structure), New TS 26.xyw (EVS; Interface to Iu, Uu and Nb) / WI rapporteur e-mail: Imre Varga (ivarga@qti.qualcomm.com)
- 134: WI rapporteur e-mail: lguellec@qti.qualcomm.com
- 135: Impacted TSs and TRs: 24.008 / WI rapporteur e-mail: lguellec@qti.qualcomm.com
- 136: Impacted TSs and TRs: 29.163, 29.414, 29.415 / WI rapporteur e-mail: lguellec@qti.qualcomm.com
- 137: Impacted TSs and TRs: 23.153, 23.334, 29.002, 29.231, 29.232, 29.332, 29.334 / WI rapporteur e-mail: lguellec@qti.qualcomm.com
- 138: WI rapporteur e-mail: Qualcomm
- 139: Rapporteur details and involved WGs updated 1st Apr 15: Compl:0%->10% 1st Apr 15: Stat Rep: ->RP-150128. 5/5/15: 0->10% / WI rapporteur e-mail: fpica@qti.qualcomm.com
- 140: Triggered by Rel-12 Dec.14: 0->10%. Mar. 15: 15% / Impacted TSs and TRs: 26.233, 26.234, 26.244, 26.247, 26.938 / WI rapporteur e-mail: Thomas Stockhammer (tsto@qti.qualcomm.com), Li Zhiming (lizhiming@huawei.com)

| ID | WBS | Task | Duration | Start | Finish | Complete | Remaining | Baseline start | Baseline finish | Baseline duration | Total slack | Constraint | Resources | Work | Actual work | Acronym | PCG approved | Release | TSG approved | MCC resp | Acronym_3GU_Export | Special Focus Doc |
| --- | --- | --- | --- | --- | --- | --- | --- | --- | --- | --- | --- | --- | --- | --- | --- | --- | --- | --- | --- | --- | --- | --- |
| 141 | 53 | **QoS End-to-end Multimedia Telephony Service for IMS (MTSI) extensions (Stage 3)** | 671d? | 2013-03-06 A | 2015-09-18 | 31% | 464.87d? | 2013-03-06 | 2015-03-13 | 533d? | 454d |  | S4; C3; C1; C4 | 40696h | 15324.2h | QOSE2EMTSI | PCG-30 | Rel-13 | SP-59 | Paolo | QOSE2EMTSI |  |
| 142 | 53.1 | TR on improved end-to-end QoS handling for MTSI | 399d? | 2013-12-11 A | 2015-06-19 | 50% | 199.5d? | 2013-12-11 | 2015-03-13 | 329d? | 519d | finish no earlier than 2015-06-19 | S4 | 3184h | 1590.29h | QOSE2EMTSI | PCG-32 | Rel-13 | SP-62 | Paolo |  |  |
| 143 | 53.2 | SA4 part of QoS End-to-end Multimedia Telephony Service for IMS (MTSI) extensions (Stage 3) | 667d? | 2013-03-06 A | 2015-09-18 | 50% | 333.5d? | 2013-03-06 | 2015-03-13 | 532d? | 454d | finish no earlier than 2015-09-18 | S4 | 5336h | 2668h | QOSE2EMTSI | PCG-30 | Rel-13 | SP-59 | Paolo |  |  |
| 144 | 53.3 | **CT Aspects of QoS End-to-End MTSI Extensions** | 223d? | 2014-11-05 | 2015-09-11 |  |  |  |  |  | 459d |  | C3; C1; C4 | 10704h |  | QOSE2EMTSI-CT | PCG-34 | Rel-13 | CP-66 |  |  |  |
| 145 | 53.3.1 | CT3 Aspects of QoS End-to-End MTSI Extensions | 223d? | 2014-11-05 | 2015-09-11 |  |  |  |  |  | 459d | finish no earlier than 2015-09-11 | C3 | 1784h |  | QOSE2EMTSI-CT | PCG-34 | Rel-13 | CP-66 |  |  |  |
| 146 | 53.3.2 | CT1 Aspects of QoS End-to-End MTSI Extensions | 223d? | 2014-11-05 | 2015-09-11 |  |  |  |  |  | 459d | start no earlier than 2014-11-05 | C1 | 1784h |  | QOSE2EMTSI-CT | PCG-34 | Rel-13 | CP-66 |  |  |  |
| 147 | 53.3.3 | CT4 Aspects of QoS End-to-End MTSI Extensions | 223d? | 2014-11-05 | 2015-09-11 |  |  |  |  |  | 459d | start no earlier than 2014-11-05 | C4 | 1784h |  | QOSE2EMTSI-CT | PCG-34 | Rel-13 | CP-66 |  |  |  |
| 148 | 54 | MTSI Extension on Multi-stream Multiparty | 196d? | 2014-12-12 A | 2015-09-11 | 10% | 176.4d? |  |  |  | 459d | finish no earlier than 2015-09-11 | S4 | 1568h | 156.8h | MMCMH | PCG-34 | Rel-13 | SP-66 |  |  |  |
| 149 | 55 | **Video Telephony Robustness Improvements Extensions** | 196d? | 2014-12-12 A | 2015-09-11 | 10% | 176.41d? |  |  |  | 459d |  | S4 | 4704h | 470.29h | VTRI_EXT | PCG-34 | Rel-13 | SP-66 |  |  |  |
| 150 | 55.1 | TR on Video Telephony Robustness Improvements | 196d? | 2014-12-12 A | 2015-09-11 | 10% | 176.4d? |  |  |  | 459d | finish no earlier than 2015-09-11 | S4 | 1568h | 156.8h | VTRI_EXT | PCG-34 | Rel-13 | SP-66 |  |  |  |
| 151 | 55.2 | Specification on Video Telephony Robustness Improvements | 196d? | 2014-12-12 A | 2015-09-11 | 10% | 176.4d? |  |  |  | 459d | finish no earlier than 2015-09-11 | S4 | 1568h | 156.8h | VTRI_EXT | PCG-34 | Rel-13 | SP-66 |  |  |  |
| 152 | 56 | Acoustic Test methods and Performance Objectives for Speakerphone Performance in Noisy Environments | 131d? | 2014-12-12 | 2015-06-12 |  |  |  |  |  | 524d | finish no earlier than 2015-06-12 | S4 | 1048h |  | ATeMPO_SPINE | PCG-34 | Rel-13 | SP-66 |  |  |  |
| 153 | 57 | **Rel-13 Operations, Administration, Maintenance and Provisioning (OAM&P)** | 920d? | 2012-06-20 A | 2015-12-11 | 34% | 604.42d? | 2014-09-17 | 2015-12-11 | 323d? | 394d |  | S5 | 55448h | 18221.8h | OAM13 | PCG-32 | Rel-13 | SP-63 | Mirko | OAM13 | SON |
| 154 | 57.1 | Enhanced Network Management (NM) centralized Coverage and Capacity Optimization | 319d? | 2014-09-19 A | 2015-12-11 | 30% | 223.3d? | 2014-09-17 | 2015-12-11 | 319d? | 394d | finish no earlier than 2015-12-11 | S5 | 2552h | 765.6h | SON-NM-CCO | PCG-29 | Rel-13 | SP-56 | Mirko | SON-NM-CCO | SON |
| 155 | 57.2 | **Compliance of 3GPP SA5 specifications to the NGMN Top Operational Efficiency (OPE) Recommendations** | 728d? | 2012-06-20 A | 2015-03-18 | 65% | 254.57d? | 2012-06-20 | 2014-09-17 | 595d? | 586d |  | S5 | 17368h | 10369.2h | OAM-NGMN_OPE | PCG-29 | Rel-13 | SP-56 | Mirko | OAM-NGMN_OPE |  |
| 156 | 57.2.1 | TR on Compliance of 3GPP SA5 specifications to the NGMN Top Operational Efficiency (OPE) Recommendations | 723d? | 2012-06-20 A | 2015-03-18 | 80% | 144.6d? | 2012-06-20 | 2014-09-17 | 593d? | 586d | finish no earlier than 2015-03-18 | S5 | 5784h | 4627.2h | OAM-NGMN_OPE | PCG-29 | Rel-13 | SP-56 | Mirko |  |  |
| 157 | 57.2.2 | TS work on Compliance of 3GPP SA5 specifications to the NGMN Top Operational Efficiency (OPE) Recommendations | 720d? | 2012-06-25 A | 2015-03-18 | 50% | 360d? | 2012-06-25 | 2014-09-17 | 590d? | 586d | finish no earlier than 2015-03-18 | S5 | 5760h | 2880h | OAM-NGMN_OPE | PCG-29 | Rel-13 | SP-56 | Mirko |  |  |
| 158 | 57.3 | Converged management Performance Management Interface Definitions | 910d? | 2012-06-20 A | 2015-12-11 | 30% | 637d? | 2012-06-20 | 2014-09-17 | 588d? | 394d | finish no earlier than 2015-12-11 | S5 | 7280h | 2184h | OAM-PMID | PCG-29 | Rel-13 | SP-56 | Mirko | OAM-PMID |  |
| 159 | 57.4 | **WLAN Management** | 788d? | 2012-06-27 A | 2015-06-17 | 12% | 689.51d? | 2012-06-20 | 2014-09-17 | 595d? | 521d |  | S5 | 18848h | 3053.48h | WLAN-OAM | PCG-29 | Rel-13 | SP-56 | Mirko | WLAN-OAM | WLAN |
| 160 | 57.4.1 | WLAN Network Resource Model for Type-2 interface | 784d? | 2012-06-27 A | 2015-06-17 | 20% | 627.2d? | 2012-06-27 | 2014-09-17 | 589d? | 521d | finish no earlier than 2015-06-17 | S5 | 6272h | 1254.4h | WLAN-OAM-SA5 | PCG-29 | Rel-13 | SP-56 | Mirko |  | WLAN |
| 161 | 57.4.2 | WLAN measurements defined in IEEE and IETF WLAN performance measurements for use on Type-2 interface | 784d? | 2012-06-27 A | 2015-06-17 | 5% | 744.8d? | 2012-06-27 | 2014-09-17 | 589d? | 521d | finish no earlier than 2015-06-17 | S5 | 6272h | 313.6h | WLAN-OAM-SA5ietf | PCG-29 | Rel-13 | SP-56 | Mirko |  | WLAN |
| 162 | 57.5 | Energy Efficiency related Performance Measurements | 521d? | 2013-06-21 A | 2015-06-17 | 25% | 390.75d? | 2013-06-21 | 2014-09-17 | 326d? | 521d | finish no earlier than 2015-06-17 | S5 | 4168h | 1042h | OAM-PM_EE | PCG-31 | Rel-13 | SP-60 | Mirko | OAM-PM_EE |  |
| 163 | 57.6 | Multi-Broadcast Single Frequency Network (MBSFN) Minimization of Drive Tests (MDT) enhancement | 1d? | 2014-12-12 A | 2014-12-12 | 15% | 0.85d? |  |  |  | 654d | start no earlier than 2014-12-12 | S5 | 8h | 1.2h | MBSFN_MDT | PCG-34 | Rel-13 | SP-66 |  |  |  |
| 164 | 58 | **Rel-13 Charging** | 393d? | 2014-06-19 A | 2015-12-16 | 16% | 330.73d? | 2014-06-18 | 2015-12-09 | 386d? | 391d |  | S5 | 14688h | 2584.47h | CH13 | PCG-33 | Rel-13 | SP-64 |  | CH13 |  |
| 165 | 58.1 | **Inter-PLMN PS domain online charging** | 393d? | 2014-06-19 A | 2015-12-16 | 24% | 298.61d? | 2014-06-18 | 2015-12-09 | 386d? | 391d |  | S5 | 8360h | 2007.88h | iPLMN-PS-OCH | PCG-33 | Rel-13 | SP-64 |  | iPLMN-PS-OCH |  |
| 166 | 58.1.1 | TR on Inter-PLMN PS domain online charging | 261d? | 2014-06-19 A | 2015-06-17 | 60% | 104.4d? | 2014-06-18 | 2015-06-17 | 261d? | 521d | finish no earlier than 2015-06-17 | S5 | 2088h | 1252.8h | iPLMN-PS-OCH | PCG-33 | Rel-13 | SP-64 |  |  |  |
| 167 | 58.1.2 | Specification of Inter-PLMN PS domain online charging | 391d? | 2014-06-23 | 2015-12-16 |  |  | 2014-06-18 | 2015-12-09 | 386d? | 391d | finish no earlier than 2015-12-16 | S5 | 3128h |  | iPLMN-PS-OCH | PCG-33 | Rel-13 | SP-64 |  |  |  |
| 168 | 58.2 | ULI and release causes for charging enhancement for VoLTE | 196d? | 2014-12-12 A | 2015-09-11 | 5% | 186.2d? |  |  |  | 459d | finish no earlier than 2015-09-11 | S5 | 1568h | 78.4h | ULRELC-CH | PCG-34 | Rel-13 | SP-66 |  |  |  |
| 169 | 58.3 | Charging on enhancements for IMS Service Continuity | 202d? | 2015-03-05 | 2015-12-11 |  |  |  |  |  | 394d | finish no earlier than 2015-12-11 | S5 | 1616h |  | CHeISC | PCG-34 | Rel-13 | SP-67 |  |  |  |

Notes:
- 141: SP#65 updated WID SP-130670=>SP-140601 (moved work from Rel-12 incl. new TR to Rel-13). Co-ordinate with SA2, CT1/3/4, IETF MMUSIC. Linked to SA4 Rel-7 Media handling and interaction in MTSI (MTSI-MHI) UID_7040 / WI rapporteur name: Ericsson / WI rapporteur e-mail: tomas.frankkila@ericsson.com
- 142: SP#65 updated WID SP-130670=>SP-140601 (moved work from Rel12 incl. new TR to Rel-13). Completion 03/15=>06/15. Mar15: 26.924 for info. 8/4/15: 50% / Impacted TSs and TRs: new TR 26.924 / WI rapporteur name: Ericsson / WI rapporteur e-mail: tomas.frankkila@ericsson.com
- 143: SP#65 updated WID SP-130670=>SP-140601 (moved work from Rel12 incl. new TR to Rel-13). Completion 03/15=>06/15. Stage 1 in TS 22.173. Dec.14: 70->40%, CD: 06/15->09/15. Mar. 15: 50% / Impacted TSs and TRs: 26.114 / WI rapporteur name: Ericsson / WI rapporteur e-mail: tomas.frankkila@ericsson.com
- 144: WI rapporteur name: Ericsson
- 145: Impacted TSs and TRs: 29.162, 29.163, 29.213, 29.214 / WI rapporteur name: Ericsson
- 146: Impacted TSs and TRs: 24.229 / WI rapporteur name: Ericsson
- 147: Impacted TSs and TRs: 23.333, 23.334, 29.238, 29.332, 29.333, 29.334 / WI rapporteur name: Ericsson
- 148: Mar. 15: 0->10%. WID: SP-140738->SP-150097 / Impacted TSs and TRs: 26.114 / WI rapporteur name: Tomas Frankkila, Ericsson LM / WI rapporteur e-mail: tomas.frankkila@ericsson.com
- 149: New TR added. 3/3/15: "extensions" added in the title. Mar. 15: 0->10% / Impacted TSs and TRs: 26.922 (new), 26.114 / WI rapporteur name: Muhammed Coban, Qualcomm Incorporated / WI rapporteur e-mail: mcoban@qti.qualcomm.com
- 150: 3/3/15: created to distinguish TR and TS tasks / Impacted TSs and TRs: 26.922 (new), 26.114 / WI rapporteur name: Muhammed Coban, Qualcomm Incorporated / WI rapporteur e-mail: mcoban@qti.qualcomm.com
- 151: 3/3/15: created to distinguish TR and TS tasks / Impacted TSs and TRs: 26.922 (new), 26.114 / WI rapporteur name: Muhammed Coban, Qualcomm Incorporated / WI rapporteur e-mail: mcoban@qti.qualcomm.com
- 152: Impacted TSs and TRs: 26.131, 26.132 / WI rapporteur name: Andre Schevciw, Qualcomm Incorporated; Scott Isabelle, Audience Inc. / WI rapporteur e-mail: aschevci@qti.qualcomm.com; sisabelle@audience.com
- 153: OAM13 is an umbrella Feature for changes that are not part of any other dedicated feature/WI
- 154: SP#64 work not started. Dec.14: 0->20, cd: 06/15->12/15. Mar 15: 20->30% / Impacted TSs and TRs: 28.627, 28.628, 32.103, 32.422, 32.425, 32.442 / WI rapporteur name: Ericsson / WI rapporteur e-mail: robert.petersen@ericsson.com
- 155: SP#65 updated WID SP-120349=>SP-140538. Completion 12/14=>03/15. Moved to Rel-13. Source of external requirements: NGMN Top OPE Recommendations 1.0 / WI rapporteur name: Huawei / WI rapporteur e-mail: christian.toche@huawei.com
- 156: SP#65 updated WID SP-120349=>SP-140538. Completion 12/14=>03/15. Moved to Rel-13.. Dec.14: 72->78. Mar 15: 80% / Impacted TSs and TRs: New TR 32.838 / WI rapporteur name: Huawei / WI rapporteur e-mail: christian.toche@huawei.com
- 157: SP#65 updated WID SP-120349=>SP-140538. Completion 12/14=>03/15. Moved to Rel-13 / Impacted TSs and TRs: 32.101/2/3,32.111-1,32.111-2,32.111-6,32.15x,32.401,32.411,32.412,32.421,32.422,32.423,32.431,32.432,32.436,32.441,32.442,32.446,32.500,32.501,32.502,32.506,32.521,32.522,32.526,32.531,32.532,32.536,32.551,32.691,32.692,32.696,32.762 / WI rapporteur name: Huawei / WI rapporteur e-mail: christian.toche@huawei.com
- 158: SP#65 updated WID SP-130641=>SP-140613. Completion 09/14=>12/15. Moved to Rel-13. Completion 09/14=>12/15. Dec.14: 20->30 / Impacted TSs and TRs: new TSs (32.PM1, 32.PM6, 32.PM7) / WI rapporteur name: Huawei / WI rapporteur e-mail: christian.toche@huawei.com
- 159: SP#65 moved to Rel-13. Updated WID SP-130042=>SP-140535 (split into Rel-12 Study & Rel-13 normative WI). TR 32.841 was completed as a Rel-12 Study and has triggered this normative work / WI rapporteur name: Intel / WI rapporteur e-mail: joey.chou@intel.com
- 160: SP#65 updated WID SP-130042=>SP-140535. Completion 09/14=>06/15. Moved to Rel-13. Dec.14: 10->20 / Impacted TSs and TRs: new TS (28.680, 28.682) / WI rapporteur name: Intel / WI rapporteur e-mail: joey.chou@intel.com
- 161: SP#65 updated WID SP-130042=>SP-140535. Completion 09/14=>06/15. Moved to Rel-13. 22/01:Acronym modified / Impacted TSs and TRs: new TS 28.403 / WI rapporteur name: Intel / WI rapporteur e-mail: joey.chou@intel.com
- 162: SP#65 updated WID SP-130263=>SP-140612. Completion 09/14=>06/15. Moved to Rel-13 / Impacted TSs and TRs: 32.425 / WI rapporteur name: Nokia Networks / WI rapporteur e-mail: Yizhi.yao@nsn.com
- 163: Mar 15: 0->15% / Impacted TSs and TRs: 32.421, 32.422, 32.423, 32.441, 32.442, 32.446 / WI rapporteur name: Padma Sudarsan (Alcatel-Lucent) / WI rapporteur e-mail: padma.sudarsan<AT>alcatel-lucent<DOT>com
- 164: CH13 is an umbrella Feature for changes that are not part of any other dedicated feature/WI
- 165: Study and specify Gy Reference Point service data flows based online charging for inter-PLMN situations / Impacted TSs and TRs: Stage 2/3 / WI rapporteur name: Alcatel-Lucent / WI rapporteur e-mail: maryse.gardella@alcatel-lucent.com
- 166: Dec.14: 10->25%. Mar15: 20->60% / Impacted TSs and TRs: New TR 32.843 / WI rapporteur name: Alcatel-Lucent / WI rapporteur e-mail: maryse.gardella@alcatel-lucent.com
- 167: - / Impacted TSs and TRs: 32.251, 32.299 / WI rapporteur name: Alcatel-Lucent / WI rapporteur e-mail: maryse.gardella@alcatel-lucent.com
- 168: Acronym changed to ULRELC-CH. Mar15: 0->5%. CD: 12/14->09/15 / Impacted TSs and TRs: 32.251, 32.260, 32.299, 32.298, / WI rapporteur name: Alcatel-Lucent, Maryse Gardella / WI rapporteur e-mail: Alcatel-Lucent, Maryse <dot> Gardella <at> Alcatel-Lucent <dot> com
- 169: Impacted TSs and TRs: 32.260, 32.299, 32.298 / WI rapporteur name: Gerald Goermer / WI rapporteur e-mail: Gerald <dot> Goermer <at> nsn <dot> com

| ID | WBS | Task | Duration | Start | Finish | Complete | Remaining | Baseline start | Baseline finish | Baseline duration | Total slack | Constraint | Resources | Work | Actual work | Acronym | PCG approved | WI rapporteur name | WI rapporteur e-mail | Release | TSG approved | MCC resp | Acronym_3GU_Export | Status Report |
| --- | --- | --- | --- | --- | --- | --- | --- | --- | --- | --- | --- | --- | --- | --- | --- | --- | --- | --- | --- | --- | --- | --- | --- | --- |
| 170 | 59 | **Support of Real-time Transport Protocol (RTP) / Real-time Transport Control Protocol (RTCP) multiplexing (signalling) in IMS** | 595d? | 2013-09-09 A | 2015-12-11 | 33% | 396.67d? | 2013-09-09 | 2014-09-12 | 267d? | 394d |  | C4; C1; C3 | 28464h | 9488h | RTCP_MUX | PCG-31 | Alcatel-Lucent | Albrecht.Schwarz@alcatel-lucent.com | Rel-13 | CP-61 | Kimmo | RTCP_MUX |  |
| 171 | 59.1 | CT4 part of Support of RTP / RTCP multiplexing (signalling) in IMS | 591d? | 2013-09-09 A | 2015-12-11 A | 100% |  | 2013-09-09 | 2014-09-12 | 266d? |  | finish no earlier than 2015-12-11 | C4 | 4728h | 4728h | RTCP_MUX | PCG-31 | Alcatel-Lucent | Albrecht.Schwarz@alcatel-lucent.com | Rel-13 | CP-61 | Kimmo |  |  |
| 172 | 59.2 | CT1 part of Support of RTP / RTCP multiplexing (signalling) in IMS | 591d? | 2013-09-13 | 2015-12-11 |  |  | 2013-09-10 | 2014-09-12 | 266d? | 394d | finish no earlier than 2015-12-11 | C1 | 4728h |  | RTCP_MUX | PCG-31 | Alcatel-Lucent | Albrecht.Schwarz@alcatel-lucent.com | Rel-13 | CP-61 | Frederic |  |  |
| 173 | 59.3 | CT3 part of Support of RTP / RTCP multiplexing (signalling) in IMS | 591d? | 2013-09-13 | 2015-12-11 |  |  | 2013-09-10 | 2014-06-13 | 201d? | 394d | finish no earlier than 2015-12-11 | C3 | 4728h |  | RTCP_MUX | PCG-31 | Alcatel-Lucent | Albrecht.Schwarz@alcatel-lucent.com | Rel-13 | CP-61 | Adrian |  |  |
| 174 | 60 | **LTE in the 1670-1675 MHz Band for US (on hold till 12/2014)** | 868d? | 2012-03-05 A | 2015-06-12 | 8% | 801.54d? | 2012-03-05 | 2015-06-12 | 865d? | 524d |  | R4; R2; R3 | 35264h | 2347.6h | LTE_FDD_1670_US | PCG-28 | LightSquared | masoud.olfat@lightsquared.com | Rel-13 | RP-55 | Issam | LTE_FDD_1670_US |  |
| 175 | 60.1 | Core part: LTE in the 1670-1675 MHz Band for US (on hold till 12/2014) | 313d? | 2013-08-06 A | 2015-03-13 | 15% | 266.05d? | 2013-08-06 | 2015-03-13 | 313d? | 589d | finish no earlier than 2015-03-13 | R4; R2; R3 | 7512h | 1126.8h | LTE_FDD_1670_US-Core | PCG-28 | LightSquared | masoud.olfat@lightsquared.com | Rel-13 | RP-55 | Issam | LTE_FDD_1670_US-Core | RP-141452 |
| 176 | 60.2 | Perf. Part: LTE in the 1670-1675 MHz Band for US (on hold till 12/2014) | 865d? | 2012-03-05 A | 2015-06-12 | 5% | 821.75d? | 2012-03-05 | 2015-06-12 | 865d? | 524d | finish no earlier than 2015-06-12 | R4 | 6920h | 346h | LTE_FDD_1670_US-Perf | PCG-28 | LightSquared | masoud.olfat@lightsquared.com | Rel-13 | RP-55 | Issam | LTE_FDD_1670_US-Perf | RP-141452 |
| 177 | 61 | **Enhanced Signalling for Inter-eNB Coordinated Multi-Point (CoMP) for LTE** | 262d? | 2014-06-18 A | 2015-06-15 | 30% | 183.41d? | 2014-06-13 | 2014-12-05 | 126d? | 523d |  | R3 | 4192h | 1257.52h | COMP_LTE_IeNB_sig | PCG-33 | Samsung | sunghwan.won@samsung.com | Rel-13 | RP-64 |  | COMP_LTE_IeNB_sig |  |
| 178 | 61.1 | Core part: Enhanced Signalling for Inter-eNB Coordinated Multi-Point (CoMP) for LTE | 262d? | 2014-06-18 A | 2015-06-15 | 30% | 183.4d? | 2014-06-13 | 2014-12-05 | 126d? | 523d | finish no earlier than 2015-06-15 | R3 | 2096h | 628.8h | COMP_LTE_IeNB_sig-Core | PCG-33 | Samsung | sunghwan.won@samsung.com | Rel-13 | RP-64 |  | COMP_LTE_IeNB_sig-Core | RP-150162 |
| 179 | 62 | **2GHz FDD LTE in Region 1 (1980-2010MHz and 2170-2200MHz Bands)** | 263d? | 2014-06-17 A | 2015-06-15 | 17% | 216.98d? | 2014-06-13 | 2015-06-12 | 261d? | 523d |  | R4 | 6296h | 1101.77h | LTE_1980_2170_REG1 | PCG-33 | DISH Network | johny.kim@dish.com, mariam.sorond@dish.com | Rel-13 | RP-64 |  | LTE_1980_2170_REG1 |  |
| 180 | 62.1 | Core part: 2GHz FDD LTE in Region 1 (1980-2010MHz and 2170-2200MHz Bands) | 262d? | 2014-06-17 A | 2015-06-15 | 35% | 170.3d? | 2014-06-13 | 2015-06-12 | 261d? | 523d | finish no earlier than 2015-06-15 | R4 | 2096h | 733.6h | LTE_1980_2170_REG1-Core | PCG-33 | DISH Network | johny.kim@dish.com, mariam.sorond@dish.com | Rel-13 | RP-64 |  | LTE_1980_2170_REG1-Core | RP-150106 |
| 181 | 62.2 | Perf. Part: 2GHz FDD LTE in Region 1 (1980-2010MHz and 2170-2200MHz Bands) | 262d? | 2014-06-18 | 2015-06-15 |  |  | 2014-06-13 | 2015-06-12 | 261d? | 523d | finish no earlier than 2015-06-15 | R4 | 2096h |  | LTE_1980_2170_REG1-Perf | PCG-33 | DISH Network | johny.kim@dish.com, mariam.sorond@dish.com | Rel-13 | RP-64 |  | LTE_1980_2170_REG1-Perf | RP-150106 |
| 182 | 63 | **Further LTE Physical Layer Enhancements for MTC** | 461d? | 2014-09-12 A | 2016-06-15 | 10% | 412.92d? | 2014-06-13 | 2015-06-12 | 261d? | 261d |  | R1; R4; R2 | 22672h | 3133.95h | LTE_MTCe2_L1 | PCG-33 | Ericsson | johan.bergman@ericsson.com | Rel-13 | RP-65 |  | LTE_MTCe2_L1 |  |
| 183 | 63.1 | Core part: Further LTE Physical Layer Enhancements for MTC | 330d? | 2014-09-12 A | 2015-12-15 | 25% | 247.5d? | 2014-06-13 | 2015-06-12 | 261d? | 392d | finish no earlier than 2015-12-15 | R1; R2; R4 | 7920h | 1980h | LTE_MTCe2_L1-Core | PCG-33 | Ericsson | johan.bergman@ericsson.com | Rel-13 | RP-65 |  | LTE_MTCe2_L1-Core | RP-150495 |
| 184 | 63.2 | Perf. Part: Further LTE Physical Layer Enhancements for MTC | 461d? | 2014-09-12 | 2016-06-15 |  |  | 2014-06-13 | 2015-06-12 | 261d? | 261d | finish no earlier than 2016-06-15 | R4 | 3688h |  | LTE_MTCe2_L1-Perf | PCG-33 | Ericsson | johan.bergman@ericsson.com | Rel-13 | RP-65 |  | LTE_MTCe2_L1-Perf | RP-150495 |
| 185 | 64 | **Self Organizing Networks (SON) for Active Antenna System (AAS) based deployments** | 199d? | 2014-09-12 A | 2015-06-15 | 25% | 149.25d? | 2014-06-13 | 2015-06-12 | 261d? | 523d |  | R3; G2 | 4776h | 1194h | UTRA_LTE_SON_AAS | PCG-33 | Nokia Networks | krzysztof.kordybach@nsn.com | Rel-13 | RP-65 |  | UTRA_LTE_SON_AAS |  |
| 186 | 64.1 | Core part: Self Organizing Networks (SON) for Active Antenna System (AAS) based deployments | 199d? | 2014-09-12 A | 2015-06-15 | 25% | 149.25d? | 2014-06-13 | 2015-06-12 | 261d? | 523d | finish no earlier than 2015-06-15 | R3 | 1592h | 398h | UTRA_LTE_SON_AAS-Core | PCG-33 | Nokia Networks | krzysztof.kordybach@nsn.com | Rel-13 | RP-65 |  | UTRA_LTE_SON_AAS-Core | RP-150110 |
| 187 | 65 | **Usage Monitoring Control PCC Extension** | 140d? | 2014-12-03 A | 2015-06-16 | 38% | 86.76d? |  |  |  | 522d |  | S2 | 2824h | 712h | eUMONC | PCG-34 | CTBRI |  | Rel-13 | SP-66 |  |  |  |
| 188 | 65.1 | Stage 2 of Usage Monitoring Control PCC Extension | 140d? | 2014-12-03 A | 2015-06-16 | 6% | 132d? |  |  |  | 522d | finish no earlier than 2015-06-16 | S2 | 1120h | 64h | eUMONC-SA2 | PCG-34 | China Telecom, Jinyan Li | lijy@ctbri.com.cn | Rel-13 | SP-66 |  |  |  |
| 189 | 65.2 | CT3 Aspect of Usage Monitoring Control extension | 73d? | 2014-12-03 A | 2015-03-13 A | 100% |  |  |  |  |  | finish no earlier than 2015-03-13 | C3 | 584h | 584h | eUMONC-CT3 | PCG-34 | ZTE |  | Rel-13 | CT-66 |  |  |  |
| 190 | 66 | **Enhanced P-CSCF discovery using signalling for access to EPC via WLAN** | 115d? | 2014-10-06 A | 2015-03-13 | 99% | 0d? |  |  |  | 0d |  | C1 | 2424h | 1812.46h | ePCSCF_WLAN | PCG-34 | Ericsson |  | Rel-13 | CT-66 |  |  |  |
| 191 | 66.1 | CT1 aspects of Enhanced P-CSCF discovery using signalling for access to EPC via WLAN | 73d? | 2014-12-03 A | 2015-03-13 A | 100% |  |  |  |  |  | finish no earlier than 2015-03-13 | C1 | 584h | 584h | ePCSCF_WLAN | PCG-34 | Ericsson |  | Rel-13 | CT-66 |  |  |  |
| 192 | 66.2 | CT4 aspects of Enhanced P-CSCF discovery using signalling for access to EPC via WLAN | 115d? | 2014-10-06 A | 2015-03-13 A | 100% |  |  |  |  |  | finish no earlier than 2015-03-13 | C4 | 920h | 920h | ePCSCF_WLAN | PCG-34 | Ericsson |  | Rel-13 | CT-66 |  |  |  |
| 193 | 67 | **Stage-3 SAE Protocol Development - Phase 4** | 268d? | 2014-12-03 | 2015-12-11 |  |  |  |  |  | 394d |  | C1 | 8576h |  | SAES4 | PCG-34 | interdigital |  | Rel-13 | CT-66 |  |  |  |
| 194 | 67.1 | SAE Protocol Development (Stage 3) - Phase 4 | 268d? | 2014-12-03 | 2015-12-11 |  |  |  |  |  | 394d | start no earlier than 2014-12-03 | C1 | 2144h |  | SAES4 | PCG-34 | interdigital |  | Rel-13 | CT-66 |  |  |  |
| 195 | 67.2 | CS Fallback in EPS - Phase 4 | 268d? | 2014-12-03 | 2015-12-11 |  |  |  |  |  | 394d | start no earlier than 2014-12-03 | C1 | 2144h |  | SAES4-CSFB | PCG-34 | interdigital |  | Rel-13 | CT-66 |  |  |  |
| 196 | 67.3 | SAE for support for non-3GPP accesses - Phase 4 | 268d? | 2014-12-03 | 2015-12-11 |  |  |  |  |  | 394d | start no earlier than 2014-12-03 | C1 | 2144h |  | SAES4-non3GPP | PCG-34 | interdigital |  | Rel-13 | CT-66 |  |  |  |

Notes:
- 170: CP#65 moved to Rel-13. Stage 2/3 / Impacted TSs and TRs: Stage 2/3
- 171: CP#65 moved to Rel-13. Completion 09/14=>12/15. Dec.14: 10->100 / Impacted TSs and TRs: 23.334, 29.334
- 172: CP#65 moved to Rel-13. Completion 09/14=>12/15 / Impacted TSs and TRs: 24.229
- 173: CP#65 moved to Rel-13. Completion 09/14=>12/15 / Impacted TSs and TRs: 29.213, 29.214
- 174: RP#65 FS_LTE_FDD_1670_US is extended to 12/14 and this WI (LTE_FDD_1670_US) is on hold till 12/14 / Impacted TSs and TRs: LTE
- 175: RP#65 completion 03/15=>06/15. On hold till 12/2014 / Impacted TSs and TRs: 25.101, 25.104, 25.113, 25.133, 25.306, 25.307, 25.331, 25.461, 25.466, 34.124, 36.101, 36.104, 36.113, 36.124, 36.133, 36.307, new TR 36.832
- 176: RP#65 completion 06/15=>09/15. . On hold till 12/2014 / Impacted TSs and TRs: 25.133, 25.306, 25.307, 25.331, 25.461, 25.466, 34.124, 36.113, 36.124, 36.133, 36.141, 36.307
- 177: Triggered by TR 36.874 Study on Coordinated Multi-Point (CoMP) operation for LTE with Non-Ideal Backhaul (UID_600015) / Impacted TSs and TRs: LTE
- 178: CD:Thu 11/12/14->Mon 15/06/15; Compl:0%->15%; Stat Rep: -->RP-141805 1st Apr 15: Compl:15%->30% 1st Apr 15: Stat Rep: RP-141805->RP-150162 / Impacted TSs and TRs: 36.300, 36.423
- 179: Triggered by TR 37.846 Study on 2GHz FDD for UTRA and LTE in Region 1 (1980-2010MHz and 2170-2200MHz Bands) FS_UTRA_LTE_1980_2170_REG1 / Impacted TSs and TRs: LTE
- 180: CD:Fri 12/06/15->Mon 15/06/15; Compl:5%->15%; Stat Rep: RP-141627->RP-141795 1st Apr 15: Compl:15%->35% 1st Apr 15: WID: RP-141710->RP-150424 1st Apr 15: Stat Rep: RP-141795->RP-150106 / Impacted TSs and TRs: 36.101, 36.104, 36.133, 36.141, 36.307, generic TR 36.853 (3 Band CA with 1UL), New TR 36.862 (Technical Report for 2 GHz Band in Region 1)
- 181: CD:Fri 12/06/15->Mon 15/06/15; Compl:0%->0%; Stat Rep: RP-141627->RP-141795 1st Apr 15: WID: RP-141710->RP-150424 1st Apr 15: Stat Rep: RP-141795->RP-150106 / Impacted TSs and TRs: 36.101, 36.104, 36.133, 36.141, 36.307, 36.862
- 182: Triggered by Rel-12 TR 36.888 Study on Provision of low-cost MTC UEs based on LTE (FS_LC_MTC_LTE) and Low cost & enhanced coverage MTC UE for LTE (LC_MTC_UE) / Impacted TSs and TRs: LTE
- 183: 3/3/15: WID: RP-141865; Stat Rep: -->RP-141785 1st Apr 15: Compl:10%->25% 1st Apr 15: WID: RP-141865->RP-150492 1st Apr 15: Stat Rep: RP-141785->RP-150495 / Impacted TSs and TRs: 36.101, 36.104, 36.133, 36.201, 36.211, 36.212, 36.213, 36.214, 36.300, 36.302, 36.306, 36.321, 36.331
- 184: ; WID: RP-142043->RP-141865; Stat Rep: -->RP-141785 1st Apr 15: WID: RP-141865->RP-150492 1st Apr 15: Stat Rep: RP-141785->RP-150495 / Impacted TSs and TRs: 36.101, 36.104, 36.133
- 185: Triggered by TR 37.822 Study on Next-Generation SON for UTRA and LTE (FS_UTRA_LTE_NG_SON) / Impacted TSs and TRs: LTE
- 186: CD:Tue 16/06/15->Mon 15/06/15; Compl:0%->15%; Stat Rep: -->RP-141854 1st Apr 15: Compl:15%->25% 1st Apr 15: Stat Rep: RP-141854->RP-150110 / Impacted TSs and TRs: 36.300, 36.423, 36.413, 25.413
- 188: Impacted TSs and TRs: 23.203
- 189: Mar.15: 10->100% / Impacted TSs and TRs: 29.212, 29.215
- 191: . 12/12:0->100%. 5/5/15: acronym changed from ePCSCF_WLAN-CT1 to ePCSCF_WLAN / Impacted TSs and TRs: 24.229, 24.302
- 192: Mar.15: 0->100%. 5/5/15: acronym changed from ePCSCF_WLAN-CT1 to ePCSCF_WLAN / Impacted TSs and TRs: 29.274, 29.275
- 193: WP Structure created 24/03/15 to avoid confusion in Acronyms / Impacted TSs and TRs: 23.12, 24.008, 24.167, 24.229, 24.301, 24.302, 24.303, 24.304, 24.305, 24.312, 29.018, 29.118
- 194: WP Structure created 24/03/15 to avoid confusion in Acronyms. 5/5/15: acronym changed from "SAES4-CT1"
- 195: WP Structure created 24/03/15 to avoid confusion in Acronyms
- 196: WP Structure created 24/03/15 to avoid confusion in Acronyms

| ID | WBS | Task | Duration | Start | Finish | Complete | Remaining | Baseline start | Baseline finish | Baseline duration | Total slack | Constraint | Resources | Work | Actual work | Acronym | PCG approved | Impacted TSs and TRs | WI rapporteur name | WI rapporteur e-mail | Release | TSG approved | MCC resp | Acronym_3GU_Export | Status Report |
| --- | --- | --- | --- | --- | --- | --- | --- | --- | --- | --- | --- | --- | --- | --- | --- | --- | --- | --- | --- | --- | --- | --- | --- | --- | --- |
| 197 | 68 | **IMS Stage-3 IETF Protocol Alignment** | 268d? | 2014-12-03 A | 2015-12-11 | 5% | 254.6d? |  |  |  | 394d |  | C1 | 6432h | 321.57h | IMSProtoc7 | PCG-34 | 23.218, 24.998, 24.930 | Alcatel-Lucent | Keith Drage | Rel-13 | CT-66 |  |  |  |
| 198 | 68.1 | CT1 aspects of IMS Stage-3 IETF Protocol Alignment | 268d? | 2014-12-03 A | 2015-12-11 | 10% | 241.2d? |  |  |  | 394d | finish no earlier than 2015-12-11 | C1 | 2144h | 214.4h | IMSProtoc7 | PCG-34 |  | Alcatel-Lucent | Keith Drage | Rel-13 | CT-66 |  |  |  |
| 199 | 68.2 | CT3 aspects of IMS Stage-3 IETF Protocol Alignment | 268d? | 2014-12-03 | 2015-12-11 |  |  |  |  |  | 394d | start no earlier than 2014-12-03 | C3 | 2144h |  | IMSProtoc7 | PCG-34 |  | Alcatel-Lucent | Keith Drage | Rel-13 | CT-67 |  |  |  |
| 200 | 69 | **Interworking solution for Called IN number and original called IN number ISUP parameters** | 73d? | 2014-12-03 | 2015-03-13 |  |  |  |  |  | 589d |  | C1; C3 | 2354.5h |  | INNB_IW | PCG-34 |  | Orange |  | Rel-13 | CT-66 |  |  |  |
| 201 | 69.1 | Interworking solution for Called IN number and original called IN number ISUP parameters | 73d? | 2014-12-03 | 2015-03-13 |  |  |  |  |  | 589d | start no earlier than 2014-12-03 | C1 | 584h |  | INNB_IW | PCG-34 | 24.229 | Orange |  | Rel-13 | CT-66 |  |  |  |
| 202 | 69.2 | (IETF) CT1 part of Interworking solution for Called IN number and original called IN number ISUP parameters | 51.75d? | 2014-12-03 | 2015-03-10 |  |  |  |  |  | 592d | finish no earlier than 2015-03-10 | C1-IETF | 414h |  | INNB_IW | PCG-34 | draft-mohali-dispatch-cause-for-service-number | Orange |  | Rel-13 | CT-66 |  |  |  |
| 203 | 69.3 | CT3 aspects of Interworking solution for Called IN number and original called IN number ISUP parameters | 73d? | 2014-12-03 | 2015-03-13 |  |  |  |  |  | 589d | finish no earlier than 2015-03-13 | C3 | 584h |  | INNB_IW | PCG-34 |  | Orange |  | Rel-13 | CT-66 |  |  |  |
| 204 | 70 | **Warning Status Report in EPS** | 204d? | 2014-12-03 | 2015-09-14 |  |  |  |  |  | 458d |  | C4 | 4896h |  | WSR_EPS | PCG-34 |  | one2many |  | Rel-13 | CT-66 |  |  |  |
| 205 | 70.1 | CT1 aspects of Warning Status Report in EPS | 204d? | 2014-12-03 | 2015-09-14 |  |  |  |  |  | 458d | start no earlier than 2014-12-03 | C1 | 1632h |  | WSR_EPS | PCG-34 | New TR 23.712 | one2many |  | Rel-13 | CT-66 |  |  |  |
| 206 | 70.2 | CT4 aspects of Warning Status Report in EPS | 204d? | 2014-12-03 | 2015-09-14 |  |  |  |  |  | 458d | finish no earlier than 2015-09-14 | C4 | 1632h |  | WSR_EPS | PCG-34 |  | one2many |  | Rel-13 | CT-66 |  |  |  |
| 207 | 71 | Shared Data Update for Multiple Subscriber | 1d? | 2014-12-03 A | 2014-12-03 | 50% | 0.5d? |  |  |  | 661d | start no earlier than 2014-12-03 | C4 | 8h | 4h | SHARED_SubData_UPD | PCG-34 | 29.328, 29.364 | Huawei, Susan Shi | susan.shishufeng@huawei.com | Rel-13 | CT-66 |  |  |  |
| 208 | 72 | **P-CSCF Restoration Enhancements with WLAN** | 268.05d? | 2014-12-03 A | 2015-12-14 | 50% | 134.03d? |  |  |  | 393.95d |  | C4 | 6432.4h | 3216.2h | PCSCF_RES_WLAN | PCG-34 |  | Alcatel-Lucent |  | Rel-13 | CT-66 |  |  |  |
| 209 | 72.1 | CT4 aspects of P-CSCF Restoration Enhancements with WLAN | 268d? | 2014-12-03 A | 2015-12-11 A | 100% |  |  |  |  |  | finish no earlier than 2015-12-11 | C4 | 2144h | 2144h | PCSCF_RES_WLAN | PCG-34 | New 29.8xy, 23.380, 29.273, 29.274, 29.275 | Alcatel-Lucent |  | Rel-13 | CT-66 |  |  |  |
| 210 | 72.2 | CT1 aspects of P-CSCF Restoration Enhancements with WLAN | 268d? | 2014-12-03 A | 2015-12-14 |  | 268d? |  |  |  | 393.95d | finish no earlier than 2015-12-11 | C1 | 2144h |  | PCSCF_RES_WLAN | PCG-34 | 24.302, 24.229, 24.244, 24.008 | Alcatel-Lucent |  | Rel-13 | CT-66 |  |  |  |
| 211 | 73 | **IMS Signalling Activated Trace** | 466d? | 2014-03-05 A | 2015-12-11 | 28% | 335.83d? | 2014-03-05 | 2014-09-12 | 138d? | 394d |  | C1; C3; C4; IETF | 33848h | 6700.85h | ISAT | PCG-32 |  | Vodafone | peter.dawes @vodafone.com | Rel-13 | CP-63 | Frederic | ISAT |  |
| 212 | 73.1 | CT1 part of IMS Signalling Activated Trace | 463d? | 2014-03-10 | 2015-12-11 |  |  | 2014-03-05 | 2014-09-12 | 138d? | 394d | finish no earlier than 2015-12-11 | C1 | 3704h |  | ISAT | PCG-32 | 24.229, 24.323 | Vodafone | peter.dawes @vodafone.com | Rel-13 | CP-63 | Frederic |  | CP-140606 |
| 213 | 73.2 | (IETF) IMS Signalling Activated Trace (draft-dawes-sipping-debug) | 326d? | 2014-09-12 A | 2015-12-11 | 25% | 244.5d? |  |  |  | 394d | finish no earlier than 2015-12-11 | C1-IETF | 2608h | 652h | ISAT | PCG-33 | draft-dawes-sipping-debug | Vodafone | peter.dawes @vodafone.com | Rel-13 | CP-65 |  |  |  |
| 214 | 73.3 | (IETF) IMS Signalling Activated Trace (draft-dawes-sipping-debug) | 326d? | 2014-09-12 A | 2015-12-11 | 25% | 244.5d? |  |  |  | 394d | finish no earlier than 2015-12-11 | C3-IETF | 2608h | 652h | ISAT | PCG-33 | draft-dawes-sipping-debug | Vodafone | peter.dawes @vodafone.com | Rel-13 | CP-65 |  |  |  |
| 215 | 73.4 | (IETF) IMS Signalling Activated Trace (draft-dawes-sipping-debug) | 326d? | 2014-09-12 A | 2015-12-11 | 25% | 244.5d? |  |  |  | 394d | finish no earlier than 2015-12-11 | C4-IETF | 2608h | 652h | ISAT | PCG-33 | draft-dawes-sipping-debug | Vodafone | peter.dawes @vodafone.com | Rel-13 | CP-65 |  |  |  |
| 216 | 73.5 | CT3 part of IMS Signalling Activated Trace | 463d? | 2014-03-10 | 2015-12-11 |  |  | 2014-03-05 | 2014-06-13 | 73d? | 394d | finish no earlier than 2015-12-11 | C3 | 3704h |  | ISAT | PCG-32 | 29.165 | Vodafone | peter.dawes @vodafone.com | Rel-13 | CP-63 | Adrian |  | CP-140564 |
| 217 | 73.6 | CT4 part of IMS Signalling Activated Trace | 463d? | 2014-03-05 A | 2015-12-11 | 90% | 46.3d? | 2014-03-05 | 2014-09-12 | 138d? | 394d | finish no earlier than 2015-12-11 | C4 | 3704h | 3333.6h | ISAT | PCG-32 | 23.008, 29.228, 29.229, 29.328, 29.329 | Vodafone | peter.dawes @vodafone.com | Rel-13 | CP-63 | Kimmo |  | CP-140480 |
| 218 | 74 | Retry restriction for Improving System Efficiency | 205d? | 2015-03-04 | 2015-12-15 |  |  |  |  |  | 392d | finish no earlier than 2015-12-15 | C1 | 1640h |  | RISE | PCG-34 |  | Huawei, Lin Shu | shulin@huawei.com | Rel-13 | CP-67 |  |  |  |
| 219 | 75 | **H.248 Aspects of WebRTC Data Channel on IMS Access Gateway** | 203d? | 2015-03-04 | 2015-12-11 |  |  |  |  |  | 394d |  | C4 | 3248h |  | WebRTCH248DC | PCG-34 | 23.334 | China Mobile, Xiaoning Du | duxiaoning@chinamobile.com | Rel-13 | CP-67 |  |  |  |
| 220 | 75.1 | CT4 Aspect of H.248 Aspects of WebRTC Data Channel on IMS Access Gateway | 203d? | 2015-03-04 | 2015-12-11 |  |  |  |  |  | 394d | finish no earlier than 2015-12-11 | C4 | 1624h |  | WebRTCH248DC | PCG-34 | 23.334 | China Mobile, Xiaoning Du | duxiaoning@chinamobile.com | Rel-13 | CT-67 |  |  |  |
| 221 | 76 | Continuation of the Overload Control for PCC based Diameter applications | 203d? | 2015-03-04 | 2015-12-11 |  |  |  |  |  | 394d | finish no earlier than 2015-12-11 | C3 | 1624h |  | cDOCME_PCC | PCG-34 | 29.212, 29.215, 29.219, 29.217 | ZTE, Zhou Xiaoyun | zhou.xiaoyun@zte.com.cn | Rel-13 | CP-67 |  |  |  |
| 222 | 77 | Review of dedicated 3GPP UICC features | 200d? | 2015-03-09 | 2015-12-11 |  |  |  |  |  | 394d | finish no earlier than 2015-12-11 | C6 | 1600h |  | Red_UCe | PCG-34 | 31.102, 31.111, 31.121, 31.124 | Blackberry, Adrian Buckley | abuckley@blackberry.com | Rel-13 | CP-67 |  |  |  |
| 223 | 78 | Optimizations to Support High Latency Communications | 73d? | 2015-03-05 | 2015-06-15 |  |  |  |  |  | 523d | finish no earlier than 2015-06-15 | S2 | 584h |  | HLcom | PCG-34 | 23.401, 23.060, 23.682 | Ericsson, Hans Rönneke | hans.ronneke(at)ericsson.com | Rel-13 | RP-67 |  |  |  |

Notes:
- 197: Mar.15: 0->10%
- 198: Mar.15: 0->10%
- 199: 2/4/15: added, following CT3 chair's info that the WID also has a CT3 part
- 201: 5/5/15: created
- 202: Mar15: resp WG:C1->C1-IETF. WID changed from INNB_IW-CT1
- 203: Mar.15: 80->90%. WID changed from INNB_IW-CT3
- 204: 5/5/15: acronym changed from "WSR_EP"
- 205: 2/4/15: acronym changed to WSR_EP. 5/5/15: acronym changed from "WSR_EP"
- 206: 2/4/15: acronym changed to WSR_EP. 5/5/15: acronym changed from "WSR_EP"
- 207: Mar.15: 0->50%, WID: CP-140804->CP-150013
- 208: WID added, acronym
- 209: Dec.14: 0->5%. Mar.15: 5->100%. 2/4/15: acronym changed to PCSCF_RES_WLAN
- 210: CT4->CT1. 2/4/15: acronym changed to PCSCF_RES_WLAN
- 211: Mar 15: WID: CP-140195->CP-150091
- 212: CP66: moved to Rel-13. Mar 15: WID: CP-140195->CP-150091
- 213: CP66: moved to Rel-13. Mar 15: WID: CP-140195->CP-150091
- 214: CP66: moved to Rel-13. Mar 15: WID: CP-140195->CP-150091
- 215: CP66: moved to Rel-13. Mar 15: WID: CP-140195->CP-150091
- 216: CP66: moved to Rel-13. Mar 15: WID: CP-140195->CP-150091
- 217: CP66: moved to Rel-13. Mar.15: 90%
- 218: Continuation of Rel-12 SINE UID 620006. 5/5/15: acronym changed from "RISE"
- 221: Relates to UID 580026 (Study on Diameter overload control mechanism)
- 222: Results from the homonymous Study

| ID | WBS | Task | Duration | Start | Finish | Complete | Remaining | Baseline start | Baseline finish | Baseline duration | Total slack | Constraint | Resources | Work | Actual work | Acronym | PCG approved | Impacted TSs and TRs | WI rapporteur name | WI rapporteur e-mail | Release | TSG approved | Status Report | Acronym_3GU_Export | MCC resp |
| --- | --- | --- | --- | --- | --- | --- | --- | --- | --- | --- | --- | --- | --- | --- | --- | --- | --- | --- | --- | --- | --- | --- | --- | --- | --- |
| 224 | 79 | **(SA66: on hold) Co-ordinated packet data network gateway (P-GW) change for SIPTO** | 66d? | 2014-06-18 A | 2014-09-16 A | 100% |  | 2014-06-18 | 2014-09-17 | 66d? |  |  | S1 | 1056h | 1056h | CSIPTO | PCG-33 | 22.101 | Intel | Eric.siow@intel.com | Rel-13 | SP-64 | S1-143306 | CSIPTO |  |
| 225 | 79.1 | Stage 1 for Co-ordinated packet data network gateway (P-GW) change for SIPTO | 66d? | 2014-06-18 A | 2014-09-16 A | 100% |  | 2014-06-18 | 2014-09-17 | 66d? |  | finish no earlier than 2014-09-17 | S1 | 528h | 528h | CSIPTO-ST1 | PCG-33 | 22.101 | Intel | Eric.siow@intel.com | Rel-13 | SP-64 | S1-143306 | CSIPTO |  |
| 226 | 80 | **(SA66: on hold) Enhanced CS Fallback (CSFB)** | 196d? | 2014-06-18 A | 2015-03-13 | 34% | 129.77d? | 2014-06-18 | 2015-03-18 | 196d? | 589d |  | S2; S3 | 5712h | 1400.2h | eCSFB | PCG-33 | Stage 2 | China Unicom | Yang Xu (xuyang49@chinaunicom.cn) | Rel-13 | SP-64 |  | eCSFB |  |
| 227 | 80.1 | TR for Enhanced CS Fallback (CSFB) | 128d? | 2014-06-18 A | 2014-12-12 | 85% | 19.2d? | 2014-06-18 | 2014-12-10 | 126d? | 654d | finish no earlier than 2014-12-12 | S2 | 1024h | 870.4h | eCSFB | PCG-33 | New TR 23.772 | China Unicom | Yang Xu (xuyang49@chinaunicom.cn) | Rel-13 | SP-64 |  |  |  |
| 228 | 80.2 | Stage 2 for Enhanced CS Fallback (CSFB) | 193d? | 2014-06-23 | 2015-03-13 |  |  | 2014-06-18 | 2015-03-18 | 196d? | 589d | finish no earlier than 2015-03-13 | S2 | 1544h |  | eCSFB | PCG-33 | 23.272 | China Unicom | Yang Xu (xuyang49@chinaunicom.cn) | Rel-13 | SP-64 |  |  |  |
| 229 | 80.3 | Security for Enhanced CS Fallback (CSFB) | 1d? | 2014-09-17 | 2014-09-17 |  |  |  |  |  | 718d | start no earlier than 2014-09-17 | S3 | 8h |  | eCSFB | PCG-33 |  | China Unicom | Feng Gao (gaofeng149@chinaunicom.cn) | Rel-13 | SP-65 |  |  |  |
| 230 | 81 | **(SA66: on hold) SRVCC Enhancements for Transcoding Avoidance** | 196d? | 2014-09-19 A | 2015-06-17 | 28% | 141.8d? |  |  |  | 521d |  | S2 | 4160h | 1150.37h | SETA | PCG-33 | Stage 2 | Ericsson | George.Foti@ericsson.com | Rel-13 | SP-65 |  | SETA |  |
| 231 | 81.1 | TR for SRVCC Enhancements for Transcoding Avoidance | 128d? | 2014-09-19 A | 2015-03-13 | 70% | 38.4d? |  |  |  | 589d | finish no earlier than 2015-03-13 | S2 | 1024h | 716.8h | SETA-SA2TR | PCG-33 | New TR 23.7xy | Ericsson | George.Foti@ericsson.com | Rel-13 | SP-65 |  |  |  |
| 232 | 81.2 | Stage 2 for SRVCC Enhancements for Transcoding Avoidance | 196d? | 2014-09-19 | 2015-06-17 |  |  |  |  |  | 521d | finish no earlier than 2015-06-17 | S2 | 1568h |  | SETA-SA2 | PCG-33 | 23.216, 23.237 | Ericsson | George.Foti@ericsson.com | Rel-13 | SP-65 |  |  |  |
| 233 | 82 | **Base Station (BS) RF requirements for Active Antenna System (AAS)** | 866d? | 2013-03-04 A | 2016-06-15 | 45% | 473.76d? | 2013-03-04 | 2014-12-05 | 465d? | 261d |  | R4 | 19592h | 7518.76h | AAS_BS_LTE_UTRA | PCG-30 | UTRA, LTE, GERAN | Huawei | ronnie.zhang@huawei.com | Rel-13 | RP-59 |  | AAS_BS_LTE_UTRA | Issam |
| 234 | 82.1 | Core part: Base Station (BS) RF requirements for Active Antenna System (AAS) | 728d? | 2013-03-04 A | 2015-12-15 | 75% | 182d? | 2013-03-04 | 2014-09-12 | 401d? | 392d | finish no earlier than 2015-12-15 | R4 | 5824h | 4368h | AAS_BS_LTE_UTRA-Core | PCG-30 | New TS 37.142 (AAS BS Tx & Rx), New TR 37.842 | Huawei | ronnie.zhang@huawei.com | Rel-13 | RP-59 | RP-141908 | AAS_BS_LTE_UTRA-Core | Issam |
| 235 | 82.2 | Perf. part: Base Station (BS) RF requirements for Active Antenna System (AAS) | 855d? | 2013-03-15 A | 2016-06-15 | 20% | 684d? | 2013-03-07 | 2014-12-05 | 461d? | 261d | finish no earlier than 2016-06-15 | R4 | 6840h | 1368h | AAS_BS_LTE_UTRA-Perf | PCG-30 | New TS 37.1xy (AAS BS conformance testing) | Huawei | ronnie.zhang@huawei.com | Rel-13 | RP-59 | RP-141908 | AAS_BS_LTE_UTRA-Perf | Issam |
| 236 | 83 | **LTE UE Total Radiated Power (TRP) and Total Radiated Sensitivity (TRS) and UTRA Hand Phantom related UE TRP and TRS Requirements** | 922d? | 2012-12-15 A | 2016-06-15 | 31% | 636.25d? | 2013-03-15 | 2015-06-12 | 591d? | 261d |  | R4; R5 | 19764h | 6085.75h | LTE_UTRA_TRP_TRS | PCG-30 | UTRA, LTE | Nokia | petri.j.vasenkari@nokia.com | Rel-13 | RP-58 |  | LTE_UTRA_TRP_TRS | Issam |
| 237 | 83.1 | Core part: LTE UE TRP and TRS and UTRA Hand Phantom related UE TRP and TRS Requirements | 720d? | 2012-12-15 A | 2015-12-15 | 40% | 432d? | 2013-03-15 | 2014-09-12 | 393d? | 392d | finish no earlier than 2015-12-15 | R4 | 5760h | 2304h | LTE_UTRA_TRP_TRS-Core | PCG-30 | 25.144, New (TS 37.144, TR 37.844) | Nokia | petri.j.vasenkari@nokia.com | Rel-13 | RP-58 | RP-150104 | LTE_UTRA_TRP_TRS-Core | Issam |
| 238 | 83.2 | Test part: LTE UE TRP and TRS and UTRA Hand Phantom | 590d? | 2014-03-15 A | 2016-06-15 | 20% | 472d? | 2014-03-06 | 2015-06-12 | 332d? | 261d | finish no earlier than 2016-06-15 | R5 | 4720h | 944h | LTE_UTRA_TRP_TRS-UEConTest | PCG-32 | New TS 37.544 | ZTE | TAYLOR Carolyn (carolyn.tayl@zte.com.cn) | Rel-13 | RP-63 | RP-150069 | LTE_UTRA_TRP_TRS-UEConTest | Ingbert |
| 239 | 84 | **Enhanced LTE Device to Device Proximity Services** | 393d? | 2014-12-15 | 2016-06-15 |  |  |  |  |  | 261d |  | R2 | 8384h |  | LTE_eD2D_Prox | PCG-34 |  | Qualcomm | Qualcomm | Rel-13 | RP-66 |  |  |  |
| 240 | 84.1 | Core part: Enhanced LTE Device to Device Proximity Services | 87.33d? | 2015-08-14 | 2015-12-15 |  |  |  |  |  | 392d | finish no earlier than 2015-12-15 | R2; R1; R3 | 2096h |  | LTE_eD2D_Prox-Core | PCG-34 |  | Qualcomm Incorporated, Shailesh Patil | patil@qti.qualcomm.com | Rel-13 | RP-66 | RP-150095 |  |  |
| 241 | 84.2 | Perf. part: Enhanced LTE Device to Device Proximity Services | 393d? | 2014-12-15 | 2016-06-15 |  |  |  |  |  | 261d | finish no earlier than 2016-06-15 | R4 | 3144h |  | LTE_eD2D_Prox-Perf | PCG-34 |  | Qualcomm | Qualcomm | Rel-13 | RP-66 | RP-150095 |  |  |
| 242 | 85 | **Radiated requirements for the verification of multi-antenna reception performance of UEs** | 262d? | 2014-12-15 A | 2015-12-15 | 5% | 248.92d? |  |  |  | 392d |  | R4 | 4192h | 209.47h | UTRA_LTE_MIMO_OTA | PCG-34 |  | Intel | Intel | Rel-13 | RP-66 |  |  |  |
| 243 | 85.1 | Core part: Radiated requirements for the verification of multi-antenna reception performance of UEs | 262d? | 2014-12-15 A | 2015-12-15 | 5% | 248.9d? |  |  |  | 392d | finish no earlier than 2015-12-15 | R4 | 2096h | 104.8h | UTRA_LTE_MIMO_OTA-Core | PCG-34 |  | Intel | Intel | Rel-13 | RP-66 | RP-150260 |  |  |
| 244 | 86 | **UE core requirements for uplink 64 QAM** | 197d? | 2014-12-15 A | 2015-09-15 | 10% | 177.31d? |  |  |  | 457d |  | R4 | 3152h | 315.12h | LTE_UL64QAM | PCG-34 |  | Huawei | Huawei | Rel-13 | RP-66 |  |  |  |
| 245 | 86.1 | Core part: UE core requirements for uplink 64 QAM | 197d? | 2014-12-15 A | 2015-09-15 | 10% | 177.3d? |  |  |  | 457d | finish no earlier than 2015-09-15 | R4 | 1576h | 157.6h | LTE_UL64QAM-Core | PCG-34 |  | Huawei | Huawei | Rel-13 | RP-66 | RP-150232 |  |  |
| 246 | 87 | **Performance requirements of MMSE-IRC receiver for LTE BS** | 393d? | 2014-12-15 A | 2016-06-15 | 10% | 353.71d? |  |  |  | 261d |  | R4 | 6288h | 628.75h | LTE_MMSE_IRC_BS | PCG-34 |  | China Telecom | China Telecom | Rel-13 | RP-66 |  |  |  |
| 247 | 87.1 | Perf. part: Performance requirements of MMSE-IRC receiver for LTE BS | 393d? | 2014-12-15 A | 2016-06-15 | 10% | 353.7d? |  |  |  | 261d | finish no earlier than 2016-06-15 | R4 | 3144h | 314.4h | LTE_MMSE_IRC_BS-Perf | PCG-34 |  | China Telecom | China Telecom | Rel-13 | RP-66 | RP-150204 |  |  |

Notes:
- 224: SP#65 completed. Updated WID SP-140235=>SP-140509. Triggered by Rel-13 Study TR 22.828 (FS_CSIPTO)
- 225: SP#65 completed. Updated WID SP-140235=>SP-140509. Triggered by Rel-13 Study TR 22.828 (FS_CSIPTO). Dec.14: former S1-only feature split
- 226: SP#65 updated ID SP-140285=>SP-140579 (added SA3 part). Linked to Rel-8 WIs Single Radio Voice Call Continuity for 3GPP (SAES-SRVCC) and CS Fallback in EPS (SAES-CSFB)
- 227: SP#65 updated ID SP-140285=>SP-140579 (added SA3 part). Dec.14: 35->85%
- 228: SP#65 updated ID SP-140285=>SP-140579 (added SA3 part)
- 229: SP#65 updated ID SP-140285=>SP-140579
- 230: Enhance chances for end-to-end transcoder free operation (TrFo) where possible/ ensure proper CS radio resources are reserved for optimal RAN codec. Address TrFo of EVS codecs during SRVCC that are not covered by Rel-12
- 231: Dec.14: 0->70%
- 232: -
- 233: Triggered by Rel-12 TR 37.840 Study of RF and EMC Requirements for Active Antenna Array System BS (FS_AAS_BS_LTE_UTRA)
- 234: ; CD:Thu 11/12/14->Tue 15/12/15; WID: RP-141966->RP-142235; Stat Rep: RP-141249->RP-141908; Release: Rel-12->Rel-13
- 235: ; CD:Sat 18/06/16->Wed 15/06/16; WID: RP-141966->RP-142235; Stat Rep: RP-141249->RP-141908; Release: Rel-12->Rel-13
- 236: Triggered by Rel-11 TR 37.902 Study on Measurements of radio performances for LTE terminals - TRP and TRS test methodology (FS_LTE_OTA) UID_550022
- 237: ; CD:Wed 18/03/15->Sun 15/03/15; Rel-12->Rel-13; Stat Rep: RP-141158->RP-141973 1st Apr 15: Compl:35%->40% 1st Apr 15: Stat Rep: RP-141973->RP-150104
- 238: Stat Rep: RP-141132->RP-141848; Rel 12->Rel13 1st Apr 15: Compl:15%->20% 1st Apr 15: CD:Mon 15/06/15->Wed 15/06/16 1st Apr 15: WID: RP-140090->RP-150070 1st Apr 15: Stat Rep: RP-141848->RP-150069
- 240: Rapporteur details and involved WGs updated 1st Apr 15: WID: RP-142311->RP-150441 1st Apr 15: Stat Rep: ->RP-150095
- 241: 1st Apr 15: WID: RP-142311->RP-150441 1st Apr 15: Stat Rep: ->RP-150095
- 243: 1st Apr 15: Compl:0%->5% 1st Apr 15: WID: RP-142221->RP-150261 1st Apr 15: Stat Rep: ->RP-150260
- 245: 1st Apr 15: Compl:0%->10% 1st Apr 15: Stat Rep: ->RP-150232
- 247: 1st Apr 15: Compl:0%->10% 1st Apr 15: WID: RP-142223->RP-150206 1st Apr 15: Stat Rep: ->RP-150204

| ID | WBS | Task | Duration | Start | Finish | Complete | Remaining | Total slack | Constraint | Resources | Work | Actual work | Acronym | PCG approved | WI rapporteur name | WI rapporteur e-mail | Release | TSG approved | Status Report |
| --- | --- | --- | --- | --- | --- | --- | --- | --- | --- | --- | --- | --- | --- | --- | --- | --- | --- | --- | --- |
| 248 | 88 | **CRS Interference Mitigation for LTE Homogenous Deployments** | 327d? | 2014-12-15 A | 2016-03-15 | 10% | 294.31d? | 327d |  | R4 | 5232h | 523.12h | LTE_CRSIM | PCG-34 | Ericsson | Ericsson | Rel-13 | RP-66 |  |
| 249 | 88.1 | Perf. part: CRS Interference Mitigation for LTE Homogenous Deployments | 327d? | 2014-12-15 A | 2016-03-15 | 10% | 294.3d? | 327d | finish no earlier than 2016-03-15 | R4 | 2616h | 261.6h | LTE_CRSIM-Perf | PCG-34 | Ericsson | Ericsson | Rel-13 | RP-66 | RP-150061 |
| 250 | 89 | **Dual Connectivity enhancements for LTE** | 328d? | 2015-03-16 | 2016-06-15 |  |  | 261d |  | R2 | 6824h |  | LTE_dualC_enh | PCG-34 | NTT DOCOMO |  | Rel-13 | RP-67 |  |
| 251 | 89.1 | Core part: Dual Connectivity enhancements for LTE | 197d? | 2015-03-16 | 2015-12-15 |  |  | 392d | finish no earlier than 2015-12-15 | R2 | 1576h |  | LTE_dualC_enh-Core | PCG-34 | NTT DOCOMO |  | Rel-13 | RP-67 |  |
| 252 | 89.2 | Perf. part: Dual Connectivity enhancements for LTE | 328d? | 2015-03-16 | 2016-06-15 |  |  | 261d | finish no earlier than 2016-06-15 | R4 | 2624h |  | LTE_dualC_enh-Perf | PCG-34 | NTT DOCOMO |  | Rel-13 | RP-67 |  |
| 253 | 90 | **Multicarrier Load Distribution of UEs in LTE** | 197d? | 2015-03-16 | 2015-12-15 |  |  | 392d |  | R2 | 4728h |  | LTE_MC_load | PCG-34 | ZTE |  | Rel-13 | RP-67 |  |
| 254 | 90.1 | Core part: Multicarrier Load Distribution of UEs in LTE | 197d? | 2015-03-16 | 2015-12-15 |  |  | 392d | finish no earlier than 2015-12-15 | R2 | 1576h |  | LTE_MC_load-Core | PCG-34 | ZTE |  | Rel-13 | RP-67 |  |
| 255 | 90.2 | Perf. part: Multicarrier Load Distribution of UEs in LTE | 197d? | 2015-03-16 | 2015-12-15 |  |  | 392d | finish no earlier than 2015-12-15 | R4 | 1576h |  | LTE_MC_load-Perf | PCG-34 | ZTE |  | Rel-13 | RP-67 |  |
| 256 | 91 | **RAN enhancements for extended DRX in LTE** | 197d? | 2015-03-16 | 2015-12-15 |  |  | 392d |  | R2 | 3152h |  | LTE_extDRX | PCG-34 | Qualcomm |  | Rel-13 | RP-67 |  |
| 257 | 91.1 | Core part: RAN enhancements for extended DRX in LTE | 197d? | 2015-03-16 | 2015-12-15 |  |  | 392d | finish no earlier than 2015-12-15 | R2 | 1576h |  | LTE_extDRX-Core | PCG-34 | Qualcomm |  | Rel-13 | RP-67 |  |
| 258 | 92 | **LTE-WLAN Radio Level Integration and Interworking Enhancement** | 197d? | 2015-03-16 | 2015-12-15 |  |  | 392d |  | R2 | 4728h |  | LTE_WLAN_radio | PCG-34 | Intel |  | Rel-13 | RP-67 |  |
| 259 | 92.1 | Core part: LTE-WLAN Radio Level Integration and Interworking Enhancement | 197d? | 2015-03-16 | 2015-12-15 |  |  | 392d | finish no earlier than 2015-12-15 | R2 | 1576h |  | LTE_WLAN_radio-Core | PCG-34 | Intel |  | Rel-13 | RP-67 |  |
| 260 | 92.2 | Perf. part: LTE-WLAN Radio Level Integration and Interworking Enhancement | 197d? | 2015-03-16 | 2015-12-15 |  |  | 392d | finish no earlier than 2015-12-15 | R4 | 1576h |  | LTE_WLAN_radio-Perf | PCG-34 | Intel |  | Rel-13 | RP-67 |  |
| 261 | 93 | **RAN aspects of Application specific Congestion control for Data Communication** | 197d? | 2015-03-16 | 2015-12-15 |  |  | 392d |  | R2 | 3152h |  | ACDC-RAN | PCG-34 | LG Electronics |  | Rel-13 | RP-67 |  |
| 262 | 93.1 | Core part: RAN aspects of Application specific Congestion control for Data Communication | 197d? | 2015-03-16 | 2015-12-15 |  |  | 392d | finish no earlier than 2015-12-15 | R2 | 1576h |  | ACDC-RAN-Core | PCG-34 | LG Electronics |  | Rel-13 | RP-67 |  |
| 263 | 94 | **RAN aspects for improvements to CS/PS coordination in UTRAN Shared Network** | 132d? | 2015-03-16 | 2015-09-15 |  |  | 457d |  | R3 | 2112h |  | CSPS_Coord-UTRA | PCG-34 | Ericsson |  | Rel-13 | RP-67 |  |
| 264 | 94.1 | Core part: RAN aspects for improvements to CS/PS coordination in UTRAN Shared Network | 132d? | 2015-03-16 | 2015-09-15 |  |  | 457d | finish no earlier than 2015-09-15 | R3 | 1056h |  | CSPS_Coord-UTRA-Core | PCG-34 | Ericsson |  | Rel-13 | RP-67 |  |
| 265 | 95 | **LTE DL 4 Rx antenna ports** | 4180d? | 2000-01-03 | 2015-12-15 |  |  | 392d |  | R4 | 36592h |  | LTE_4Rx_AP_DL | PCG-34 | Ericsson |  | Rel-13 | RP-67 |  |
| 266 | 95.1 | Core part: LTE DL 4 Rx antenna ports | 197d? | 2015-03-16 | 2015-12-15 |  |  | 392d | finish no earlier than 2015-12-15 | R4 | 1576h |  | LTE_4Rx_AP_DL-Core | PCG-34 | Ericsson |  | Rel-13 | RP-67 |  |
| 267 | 95.2 | Perf. part: LTE DL 4 Rx antenna ports | 197d? | 2000-01-03 | 2000-10-02 |  |  | 4375d |  | R4 | 1576h |  | LTE_4Rx_AP_DL-Perf | PCG-34 | Ericsson |  | Rel-13 | RP-67 |  |
| 268 | 96 | **AWS-Extension Band for LTE** | 197d? | 2015-03-16 | 2015-12-15 |  |  | 392d |  | R4 | 4728h |  | LTE_AWS_EXT | PCG-34 | Ericsson |  | Rel-13 | RP-67 |  |
| 269 | 96.1 | Core part: AWS-Extension Band for LTE | 197d? | 2015-03-16 | 2015-12-15 |  |  | 392d | finish no earlier than 2015-12-15 | R4 | 1576h |  | LTE_AWS_EXT-Core | PCG-34 | Ericsson |  | Rel-13 | RP-67 |  |
| 270 | 96.2 | Perf. part: AWS-Extension Band for LTE | 197d? | 2015-03-16 | 2015-12-15 |  |  | 392d | finish no earlier than 2015-12-15 | R4 | 1576h |  | LTE_AWS_EXT-Perf | PCG-34 | Ericsson |  | Rel-13 | RP-67 |  |
| 271 | 97 | **Additional bandwidth combination set for LTE Advanced inter-band Carrier Aggregation of Band 5 and Band 7** | 66d? | 2015-03-16 | 2015-06-15 |  |  | 523d |  | R4 | 1584h |  | LTE_CA_B5_B7_BWset | PCG-34 | Nokia Networks |  | Rel-13 | RP-67 |  |
| 272 | 97.1 | Core part: Additional bandwidth combination set for LTE Advanced inter-band Carrier Aggregation of Band 5 and Band 7 | 66d? | 2015-03-16 | 2015-06-15 |  |  | 523d | finish no earlier than 2015-06-15 | R4 | 528h |  | LTE_CA_B5_B7_BWset-Core | PCG-34 | Nokia Networks |  | Rel-13 | RP-67 |  |
| 273 | 97.2 | Perf. part: Additional bandwidth combination set for LTE Advanced inter-band Carrier Aggregation of Band 5 and Band 7 | 66d? | 2015-03-16 | 2015-06-15 |  |  | 523d | finish no earlier than 2015-06-15 | R4 | 528h |  | LTE_CA_B5_B7_BWset-Perf | PCG-34 | Nokia Networks |  | Rel-13 | RP-67 |  |

Notes:
- 249: 1st Apr 15: Compl:0%->10% 1st Apr 15: CD:Mon 15/06/15->Tue 15/03/16 1st Apr 15: Stat Rep: ->RP-150061

| ID | WBS | Task | Duration | Start | Finish | Complete | Remaining | Baseline start | Baseline finish | Baseline duration | Total slack | Constraint | Resources | Work | Actual work | Acronym | PCG approved | WI rapporteur name | Release | TSG approved | WI rapporteur e-mail | MCC resp | Special Focus Doc | Acronym_3GU_Export | Status Report |
| --- | --- | --- | --- | --- | --- | --- | --- | --- | --- | --- | --- | --- | --- | --- | --- | --- | --- | --- | --- | --- | --- | --- | --- | --- | --- |
| 274 | 98 | **Additional bandwidth combination set for LTE Advanced inter-band Carrier Aggregation of Band 3 and Band 5** | 66d? | 2015-03-16 | 2015-06-15 |  |  |  |  |  | 523d |  | R4 | 1584h |  | LTE_CA_B3_B5_BWset | PCG-34 | Samsung | Rel-13 | RP-67 |  |  |  |  |  |
| 275 | 98.1 | Core part: Additional bandwidth combination set for LTE Advanced inter-band Carrier Aggregation of Band 3 and Band 5 | 66d? | 2015-03-16 | 2015-06-15 |  |  |  |  |  | 523d | finish no earlier than 2015-06-15 | R4 | 528h |  | LTE_CA_B3_B5_BWset-Core | PCG-34 | Samsung | Rel-13 | RP-67 |  |  |  |  |  |
| 276 | 98.2 | Perf. part: Additional bandwidth combination set for LTE Advanced inter-band Carrier Aggregation of Band 3 and Band 5 | 66d? | 2015-03-16 | 2015-06-15 |  |  |  |  |  | 523d | finish no earlier than 2015-06-15 | R4 | 528h |  | LTE_CA_B3_B5_BWset-Perf | PCG-34 | Samsung | Rel-13 | RP-67 |  |  |  |  |  |
| 277 | 99 | **Multiflow Enhancements for UTRA** | 132d? | 2015-03-16 | 2015-09-15 |  |  |  |  |  | 457d |  | R2 | 2112h |  | HSDPA_MFTX_enh | PCG-34 | Nokia | Rel-13 | RP-67 | alexander.sayenko@nokia.com |  |  |  |  |
| 278 | 99.1 | Core part: Multiflow Enhancements for UTRA | 132d? | 2015-03-16 | 2015-09-15 |  |  |  |  |  | 457d | finish no earlier than 2015-09-15 | R2 | 1056h |  | HSDPA_MFTX_enh-Core | PCG-34 | Nokia | Rel-13 | RP-67 | alexander.sayenko@nokia.com |  |  |  |  |
| 279 | 100 | **Rel-13 LTE Carrier Aggregation** | 662d? | 2013-12-09 A | 2016-06-15 | 36% | 421.07d? | 2014-03-06 | 2015-06-12 | 332d? | 261d |  | R4 | 366176h | 122734h | LTE_CA_Rel13 | PCG-30 |  | Rel-13 | RP-58 |  | Issam | CA | LTE_CA_Rel-13 |  |
| 280 | 100.1 | **LTE Advanced inter-band Carrier Aggregation of Band 8 and Band 27** | 400d? | 2013-12-09 A | 2015-06-15 | 15% | 340.01d? | 2013-12-09 | 2014-12-11 | 265d? | 523d |  | R4 | 9552h | 1061.48h | LTE_CA_B8_B27 | PCG-32 | KT | Rel-13 | RP-62 | ilwhan.kim@kt.com | Issam | CA | LTE_CA_B8_B27 |  |
| 281 | 100.1.1 | Core part: LTE Advanced inter-band Carrier Aggregation of Band 8 and Band 27 | 397d? | 2013-12-09 A | 2015-06-15 | 15% | 337.45d? | 2013-12-09 | 2014-12-11 | 265d? | 523d | finish no earlier than 2015-06-15 | R4 | 3176h | 476.4h | LTE_CA_B8_B27-Core | PCG-32 | KT | Rel-13 | RP-62 | ilwhan.kim@kt.com | Issam | CA | LTE_CA_B8_B27-Core | RP-150013 |
| 282 | 100.1.2 | Perf. part: LTE Advanced inter-band Carrier Aggregation of Band 8 and Band 27 | 397d? | 2013-12-09 A | 2015-06-15 | 15% | 337.45d? | 2013-12-09 | 2014-12-11 | 265d? | 523d | finish no earlier than 2015-06-15 | R4 | 3176h | 476.4h | LTE_CA_B8_B27-Perf | PCG-32 | KT | Rel-13 | RP-62 | ilwhan.kim@kt.com | Issam | CA | LTE_CA_B8_B27-Perf | RP-150013 |
| 283 | 100.2 | **LTE Advanced 3 band Carrier Aggregation (3DL/1UL) for Band 3, Band 8 and Band 27** | 400d? | 2013-12-09 A | 2015-06-15 | 30% | 280.01d? | 2013-12-09 | 2014-12-05 | 261d? | 523d |  | R4 | 9552h | 2177.6h | LTE_CA_B3_B8_B27 | PCG-32 | KT | Rel-13 | RP-62 | Chungwoo HWANG (cwhwang@kt.com) | Issam | CA | LTE_CA_B3_B8_B27 |  |
| 284 | 100.2.1 | Core part: LTE Advanced 3 band Carrier Aggregation (3DL/1UL) for Band 3, Band 8 and Band 27 | 397d? | 2013-12-09 A | 2015-06-15 | 30% | 277.9d? | 2013-12-09 | 2014-12-05 | 261d? | 523d | finish no earlier than 2015-06-15 | R4 | 3176h | 952.8h | LTE_CA_B3_B8_B27-Core | PCG-32 | KT | Rel-13 | RP-62 | Chungwoo HWANG (cwhwang@kt.com) | Issam | CA | LTE_CA_B3_B8_B27-Core | RP-150013 |
| 285 | 100.2.2 | Perf. part: LTE Advanced 3 band Carrier Aggregation (3DL/1UL) for Band 3, Band 8 and Band 27 | 397d? | 2013-12-09 A | 2015-06-15 | 30% | 277.9d? | 2013-12-09 | 2014-12-05 | 261d? | 523d | finish no earlier than 2015-06-15 | R4 | 3176h | 952.8h | LTE_CA_B3_B8_B27-Perf | PCG-32 | KT | Rel-13 | RP-62 | Chungwoo HWANG (cwhwang@kt.com) | Issam | CA | LTE_CA_B3_B8_B27-Perf | RP-150013 |
| 286 | 100.3 | **LTE Advanced inter-band Carrier Aggregation of Band 7 and Band 22** | 336d? | 2014-03-06 A | 2015-06-15 | 5% | 319.2d? | 2014-03-06 | 2014-12-05 | 197d? | 523d |  | R4 | 8016h | 346.33h | LTE_CA_B7_B22 | PCG-32 | Orange, Ericsson | Rel-13 | RP-63 | erika.tejedor@ericsson.com | Issam | CA | LTE_CA_B7_B22 |  |
| 287 | 100.3.1 | Core part: LTE Advanced inter-band Carrier Aggregation of Band 7 and Band 22 | 333d? | 2014-03-06 A | 2015-06-15 | 10% | 299.7d? | 2014-03-06 | 2014-12-05 | 197d? | 523d | finish no earlier than 2015-06-15 | R4 | 2664h | 266.4h | LTE_CA_B7_B22-Core | PCG-32 | Orange, Ericsson | Rel-13 | RP-63 | erika.tejedor@ericsson.com | Issam | CA | LTE_CA_B7_B22-Core | RP-141732 |
| 288 | 100.3.2 | Perf. part: LTE Advanced inter-band Carrier Aggregation of Band 7 and Band 22 | 333d? | 2014-03-11 | 2015-06-15 |  |  | 2014-03-06 | 2014-12-05 | 197d? | 523d | finish no earlier than 2015-06-15 | R4 | 2664h |  | LTE_CA_B7_B22-Perf | PCG-32 | Orange, Ericsson | Rel-13 | RP-63 | erika.tejedor@ericsson.com | Issam | CA | LTE_CA_B7_B22-Perf | RP-141732 |
| 289 | 100.4 | **LTE Advanced 3 Band Carrier Aggregation (3DL/1UL) for Band 2, Band 2 and Band 12** | 262d? | 2014-06-18 A | 2015-06-15 | 99% | 2.6d? | 2014-06-13 | 2015-03-13 | 196d? | 523d |  | R4 | 6288h | 6225.24h | LTE_CA_B2_B2_B12 | PCG-33 | U.S. Cellular | Rel-13 | RP-64 | sebastian.thalanany@uscellular.com |  | CA | LTE_CA_B2_B2_B12 |  |
| 290 | 100.4.1 | Core part: LTE Advanced 3 Band Carrier Aggregation (3DL/1UL) for Band 2, Band 2 and Band 12 | 262d? | 2014-06-18 A | 2015-06-15 | 99% | 2.62d? | 2014-06-13 | 2014-12-05 | 126d? | 523d | finish no earlier than 2015-06-15 | R4 | 2096h | 2075.04h | LTE_CA_B2_B2_B12-Core | PCG-33 | U.S. Cellular | Rel-13 | RP-64 | sebastian.thalanany@uscellular.com |  | CA | LTE_CA_B2_B2_B12-Core | RP-150013 |
| 291 | 100.4.2 | Perf. Part: LTE Advanced 3 Band Carrier Aggregation (3DL/1UL) for Band 2, Band 2 and Band 12 | 262d? | 2014-06-18 A | 2015-06-15 | 99% | 2.62d? | 2014-06-13 | 2015-03-13 | 196d? | 523d | finish no earlier than 2015-06-15 | R4 | 2096h | 2075.04h | LTE_CA_B2_B2_B12-Perf | PCG-33 | U.S. Cellular | Rel-13 | RP-64 | sebastian.thalanany@uscellular.com |  | CA | LTE_CA_B2_B2_B12-Perf | RP-150013 |
| 292 | 100.5 | **LTE Advanced 3 Band Carrier Aggregation (3DL/1UL) of Band 3, Band 3 and Band 8** | 264d? | 2014-06-16 A | 2015-06-15 | 99% | 2.62d? | 2014-06-13 | 2015-06-12 | 261d? | 523d |  | R4 | 6304h | 6241.09h | LTE_CA_B3_B3_B8 | PCG-33 | CHTTL | Rel-13 | RP-64 | Po-Han Hsieh (pohanhsieh@cht.com.tw) |  | CA | LTE_CA_B3_B3_B8 |  |
| 293 | 100.5.1 | Core part: LTE Advanced 3 Band Carrier Aggregation (3DL/1UL) of Band 3, Band 3 and Band 8 | 262d? | 2014-06-16 A | 2015-06-15 | 99% | 2.62d? | 2014-06-13 | 2015-06-12 | 261d? | 523d | finish no earlier than 2015-06-15 | R4 | 2096h | 2075.04h | LTE_CA_B3_B3_B8-Core | PCG-33 | CHTTL | Rel-13 | RP-64 | Po-Han Hsieh (pohanhsieh@cht.com.tw) |  | CA | LTE_CA_B3_B3_B8-Core | RP-150013 |
| 294 | 100.5.2 | Perf. Part: LTE Advanced 3 Band Carrier Aggregation (3DL/1UL) of Band 3, Band 3 and Band 8 | 262d? | 2014-06-18 A | 2015-06-15 | 99% | 2.62d? | 2014-06-13 | 2015-06-12 | 261d? | 523d | finish no earlier than 2015-06-15 | R4 | 2096h | 2075.04h | LTE_CA_B3_B3_B8-Perf | PCG-33 | CHTTL | Rel-13 | RP-64 | Po-Han Hsieh (pohanhsieh@cht.com.tw) |  | CA | LTE_CA_B3_B3_B8-Perf | RP-150013 |
| 295 | 100.6 | **LTE Advanced 3 Band Carrier Aggregation (3DL/1UL) of Band 41, Band 42 and Band 42** | 264d? | 2014-06-16 A | 2015-06-15 | 60% | 105.6d? | 2014-06-13 | 2014-12-05 | 126d? | 523d |  | R4 | 6304h | 2673.6h | LTE_CA_B41_B42_B42 | PCG-33 | Huawei | Rel-13 | RP-64 | leo.liuye@huawei.com |  | CA | LTE_CA_B41_B42_B42 |  |
| 296 | 100.6.1 | Core part: LTE Advanced 3 Band Carrier Aggregation (3DL/1UL) of Band 41, Band 42 and Band 42 | 262d? | 2014-06-16 A | 2015-06-15 | 60% | 104.8d? | 2014-06-13 | 2014-12-05 | 126d? | 523d | finish no earlier than 2015-06-15 | R4 | 2096h | 1257.6h | LTE_CA_B41_B42_B42-Core | PCG-33 | Huawei | Rel-13 | RP-64 | leo.liuye@huawei.com |  | CA | LTE_CA_B41_B42_B42-Core | RP-150013 |
| 297 | 100.6.2 | Perf. Part: LTE Advanced 3 Band Carrier Aggregation (3DL/1UL) of Band 41, Band 42 and Band 42 | 262d? | 2014-06-18 A | 2015-06-15 | 60% | 104.8d? | 2014-06-13 | 2014-12-05 | 126d? | 523d | finish no earlier than 2015-06-15 | R4 | 2096h | 1257.6h | LTE_CA_B41_B42_B42-Perf | PCG-33 | Huawei | Rel-13 | RP-64 | leo.liuye@huawei.com |  | CA | LTE_CA_B41_B42_B42-Perf | RP-150013 |

Notes:
- 279: Acronym changed from "LTE_CA_Rel-13" to "LTE_CA_Rel13"
- 280: Inter-band CA 2DL/1UL / Impacted TSs and TRs: LTE
- 281: CD:Thu 18/06/15->Mon 15/06/15; Compl:10%->10%; Stat Rep: RP-141084->RP-141732 1st Apr 15: Compl:10%->15% 1st Apr 15: Stat Rep: RP-141732->RP-150013 / Impacted TSs and TRs: 36.101, 36.104, 36.133, generic TR 36.851
- 282: CD:Thu 18/06/15->Mon 15/06/15; Compl:10%->10%; Stat Rep: RP-141084->RP-141732 1st Apr 15: Compl:10%->15% 1st Apr 15: Stat Rep: RP-141732->RP-150013 / Impacted TSs and TRs: 36.141, 36.307
- 283: Inter-band CA 3DL / Impacted TSs and TRs: LTE
- 284: CD:Thu 18/06/15->Mon 15/06/15; Compl:25%->25%; Stat Rep: RP-141084->RP-141732 1st Apr 15: Compl:25%->30% 1st Apr 15: Stat Rep: RP-141732->RP-150013 / Impacted TSs and TRs: 36.101, 36.104, 36.133, 36.141, 36.307, new generic TR 36.853 (3 Band CA with 1UL)
- 285: CD:Thu 18/06/15->Mon 15/06/15; Compl:25%->25%; Stat Rep: RP-141084->RP-141732 1st Apr 15: Compl:25%->30% 1st Apr 15: Stat Rep: RP-141732->RP-150013 / Impacted TSs and TRs: 36.101, 36.104, 36.133, 36.141, 36.307
- 286: Inter-band CA 2DL / Impacted TSs and TRs: LTE
- 287: CD:Thu 11/12/14->Mon 15/06/15; Compl:10%->10%; Stat Rep: RP-141084->RP-141732 / Impacted TSs and TRs: 36.101, 36.104, 36.133, generic TR 36.851 (2 Band CA with 1UL),
- 288: CD:Thu 11/12/14->Mon 15/06/15; Compl:0%->0%; Stat Rep: RP-141084->RP-141732 / Impacted TSs and TRs: 36.141, 36.307
- 289: Inter-band CA 3DL/1UL / Impacted TSs and TRs: LTE
- 290: CD:Thu 12/03/15->Sun 15/03/15; Compl:0%->40%; Stat Rep: RP-141084->RP-141732 1st Apr 15: Compl:40%->99% 1st Apr 15: CD:Sun 15/03/15->Mon 15/06/15 1st Apr 15: Stat Rep: RP-141732->RP-150013 / Impacted TSs and TRs: 36.101, 36.104, 36.133, 36.141, 36.307, generic new Rel-13 TR36.8xy [similar to Rel-12 TR 36.853 (3 Band CA with 1UL)]
- 291: CD:Thu 18/06/15->Mon 15/06/15; Compl:0%->10%; Stat Rep: RP-141084->RP-141732 1st Apr 15: Compl:10%->99% 1st Apr 15: Stat Rep: RP-141732->RP-150013 / Impacted TSs and TRs: 36.101, 36.104, 36.133, 36.141, 36.307
- 292: Inter-band CA 3DL/1UL / Impacted TSs and TRs: LTE
- 293: ; WID: RP-142043->RP-141832; Stat Rep: RP-141084->RP-141732 1st Apr 15: Compl:60%->99% 1st Apr 15: Stat Rep: RP-141732->RP-150013 / Impacted TSs and TRs: 36.101, 36.133, generic TR 36.853 (3 Band CA with 1UL)
- 294: ; WID: RP-142043->RP-141832; Stat Rep: RP-141084->RP-141732 1st Apr 15: Compl:0%->99% 1st Apr 15: Stat Rep: RP-141732->RP-150013 / Impacted TSs and TRs: 36.307
- 295: Inter-band CA 3DL/1UL / Impacted TSs and TRs: LTE
- 296: CD:Thu 11/12/14->Sun 15/03/15; Compl:30%->50%; Stat Rep: RP-141084->RP-141732 1st Apr 15: Compl:50%->60% 1st Apr 15: CD:Sun 15/03/15->Mon 15/06/15 1st Apr 15: Stat Rep: RP-141732->RP-150013 / Impacted TSs and TRs: 36.101, 36.104, 36.133, generic TR 36.853 (3 Band CA with 1UL)
- 297: CD:Thu 11/12/14->Sun 15/03/15; Compl:0%->0%; Stat Rep: RP-141084->RP-141732 1st Apr 15: Compl:0%->60% 1st Apr 15: CD:Sun 15/03/15->Mon 15/06/15 1st Apr 15: Stat Rep: RP-141732->RP-150013 / Impacted TSs and TRs: 36.141, 36.307

| ID | WBS | Task | Duration | Start | Finish | Complete | Remaining | Baseline start | Baseline finish | Baseline duration | Total slack | Constraint | Resources | Work | Actual work | Acronym | PCG approved | Impacted TSs and TRs | WI rapporteur name | WI rapporteur e-mail | Release | TSG approved | Special Focus Doc | Acronym_3GU_Export | Status Report |
| --- | --- | --- | --- | --- | --- | --- | --- | --- | --- | --- | --- | --- | --- | --- | --- | --- | --- | --- | --- | --- | --- | --- | --- | --- | --- |
| 298 | 100.7 | **LTE Advanced inter-band Carrier Aggregation of Band 3 and Band 38** | 198d? | 2014-09-15 A | 2015-06-15 | 90% | 19.79d? | 2014-06-13 | 2015-03-13 | 196d? | 523d |  | R4 | 4752h | 3801.68h | LTE_CA_B3_B38 | PCG-33 | LTE | Nokia Networks | iwajlo.angelow@nsn.com | Rel-13 | RP-65 | CA | LTE_CA_B3_B38 |  |
| 299 | 100.7.1 | Core part: LTE Advanced inter-band Carrier Aggregation of Band 3 and Band 38 | 198d? | 2014-09-15 A | 2015-06-15 | 90% | 19.8d? | 2014-06-13 | 2015-03-13 | 196d? | 523d | finish no earlier than 2015-06-15 | R4 | 1584h | 1425.6h | LTE_CA_B3_B38-Core | PCG-33 | 36.101, 36.104, New TR 36.8xx | Nokia Networks | iwajlo.angelow@nsn.com | Rel-13 | RP-65 | CA | LTE_CA_B3_B38-Core | RP-150013 |
| 300 | 100.7.2 | Perf. Part: LTE Advanced inter-band Carrier Aggregation of Band 3 and Band 38 | 198d? | 2014-09-15 A | 2015-06-15 | 90% | 19.8d? | 2014-06-13 | 2015-03-13 | 196d? | 523d | finish no earlier than 2015-06-15 | R4 | 1584h | 1425.6h | LTE_CA_B3_B38-Perf | PCG-33 | 36.141, 36.307 | Nokia Networks | iwajlo.angelow@nsn.com | Rel-13 | RP-65 | CA | LTE_CA_B3_B38-Perf | RP-150013 |
| 301 | 100.8 | **LTE Advanced inter-band Carrier Aggregation of Band 2 and Band 28** | 198d? | 2014-09-15 A | 2015-06-15 | 99% | 1.98d? | 2014-06-13 | 2015-03-13 | 196d? | 523d |  | R4 | 4752h | 3659.03h | LTE_CA_B2_B28 | PCG-33 | LTE | Huawei | alf.ahlstrom@huawei.com | Rel-13 | RP-65 | CA | LTE_CA_B2_B28 |  |
| 302 | 100.8.1 | Core part: LTE Advanced inter-band Carrier Aggregation of Band 2 and Band 28 | 198d? | 2014-09-15 A | 2015-06-15 | 99% | 1.98d? | 2014-06-13 | 2015-03-13 | 196d? | 523d | finish no earlier than 2015-06-15 | R4 | 1584h | 1568.16h | LTE_CA_B2_B28-Core | PCG-33 | 36.101, 36.104, New TR 36.8xx | Huawei | alf.ahlstrom@huawei.com | Rel-13 | RP-65 | CA | LTE_CA_B2_B28-Core | RP-150013 |
| 303 | 100.8.2 | Perf. Part: LTE Advanced inter-band Carrier Aggregation of Band 2 and Band 28 | 198d? | 2014-09-15 A | 2015-06-15 | 99% | 1.98d? | 2014-06-13 | 2015-03-13 | 196d? | 523d | finish no earlier than 2015-06-15 | R4 | 1584h | 1568.16h | LTE_CA_B2_B28-Perf | PCG-33 | 36.141, 36.307 | Huawei | alf.ahlstrom@huawei.com | Rel-13 | RP-65 | CA | LTE_CA_B2_B28-Perf | RP-150013 |
| 304 | 100.9 | **LTE Advanced inter-band Carrier Aggregation of Band 4 and Band 28** | 198d? | 2014-09-15 A | 2015-06-15 | 99% | 1.98d? | 2014-06-13 | 2015-03-13 | 196d? | 523d |  | R4 | 4752h | 3659.03h | LTE_CA_B4_B28 | PCG-33 | LTE | Huawei | alf.ahlstrom@huawei.com | Rel-13 | RP-65 | CA | LTE_CA_B4_B28 |  |
| 305 | 100.9.1 | Core part: LTE Advanced inter-band Carrier Aggregation of Band 4 and Band 28 | 198d? | 2014-09-15 A | 2015-06-15 | 99% | 1.98d? | 2014-06-13 | 2015-03-13 | 196d? | 523d | finish no earlier than 2015-06-15 | R4 | 1584h | 1568.16h | LTE_CA_B4_B28-Core | PCG-33 | 36.101, 36.104, New TR 36.8xx | Huawei | alf.ahlstrom@huawei.com | Rel-13 | RP-65 | CA | LTE_CA_B4_B28-Core | RP-150013 |
| 306 | 100.9.2 | Perf. Part: LTE Advanced inter-band Carrier Aggregation of Band 4 and Band 28 | 198d? | 2014-09-15 A | 2015-06-15 | 99% | 1.98d? | 2014-06-13 | 2015-03-13 | 196d? | 523d | finish no earlier than 2015-06-15 | R4 | 1584h | 1568.16h | LTE_CA_B4_B28-Perf | PCG-33 | 36.141, 36.307 | Huawei | alf.ahlstrom@huawei.com | Rel-13 | RP-65 | CA | LTE_CA_B4_B28-Perf | RP-150013 |
| 307 | 100.10 | **LTE Advanced inter-band Carrier Aggregation of Band 20 and Band 40** | 199d? | 2014-09-12 A | 2015-06-15 | 35% | 129.18d? | 2014-06-13 | 2015-03-13 | 196d? | 523d |  | R4 | 4768h | 1488.17h | LTE_CA_B20_B40 | PCG-33 | LTE | Ericsson | imadur.rahman@ericsson.com | Rel-13 | RP-65 | CA | LTE_CA_B20_B40 |  |
| 308 | 100.10.1 | Core part: LTE Advanced inter-band Carrier Aggregation of Band 20 and Band 40 | 199d? | 2014-09-12 A | 2015-06-15 | 70% | 59.7d? | 2014-06-13 | 2015-03-13 | 196d? | 523d | finish no earlier than 2015-06-15 | R4 | 1592h | 1114.4h | LTE_CA_B20_B40-Core | PCG-33 | 36.101, 36.104, 36.133, New TR 36.8xx | Ericsson | imadur.rahman@ericsson.com | Rel-13 | RP-65 | CA | LTE_CA_B20_B40-Core | RP-150013 |
| 309 | 100.10.2 | Perf. Part: LTE Advanced inter-band Carrier Aggregation of Band 20 and Band 40 | 198d? | 2014-09-15 | 2015-06-15 |  |  | 2014-06-13 | 2015-03-13 | 196d? | 523d | finish no earlier than 2015-06-15 | R4 | 1584h |  | LTE_CA_B20_B40-Perf | PCG-33 | 36.141, 36.307 | Ericsson | imadur.rahman@ericsson.com | Rel-13 | RP-65 | CA | LTE_CA_B20_B40-Perf | RP-150013 |
| 310 | 100.11 | **LTE Advanced inter-band Carrier Aggregation of Band 1 and Band 40** | 198d? | 2014-09-15 A | 2015-06-15 | 80% | 39.59d? | 2014-06-13 | 2015-03-13 | 196d? | 523d |  | R4 | 4752h | 3224.97h | LTE_CA_B1_B40 | PCG-33 | LTE | KT | ilwhan.kim@kt.com | Rel-13 | RP-65 | CA | LTE_CA_B1_B40 |  |
| 311 | 100.11.1 | Core part: LTE Advanced inter-band Carrier Aggregation of Band 1 and Band 40 | 198d? | 2014-09-15 A | 2015-06-15 | 80% | 39.6d? | 2014-06-13 | 2015-03-13 | 196d? | 523d | finish no earlier than 2015-06-15 | R4 | 1584h | 1267.2h | LTE_CA_B1_B40-Core | PCG-33 | 36.101, 36.104, 36.133, New TR 36.8xx | KT | ilwhan.kim@kt.com | Rel-13 | RP-65 | CA | LTE_CA_B1_B40-Core | RP-150013 |
| 312 | 100.11.2 | Perf. Part: LTE Advanced inter-band Carrier Aggregation of Band 1 and Band 40 | 198d? | 2014-09-15 A | 2015-06-15 | 80% | 39.6d? | 2014-06-13 | 2015-03-13 | 196d? | 523d | finish no earlier than 2015-06-15 | R4 | 1584h | 1267.2h | LTE_CA_B1_B40-Perf | PCG-33 | 36.141, 36.307 | KT | ilwhan.kim@kt.com | Rel-13 | RP-65 | CA | LTE_CA_B1_B40-Perf | RP-150013 |
| 313 | 100.12 | **LTE Advanced inter-band Carrier Aggregation of Band 3 and Band 40** | 198d? | 2014-09-15 A | 2015-06-15 | 80% | 39.59d? | 2014-06-13 | 2015-03-13 | 196d? | 523d |  | R4 | 4752h | 3801.7h | LTE_CA_B3_B40 | PCG-33 | LTE | KT | Chungwoo HWANG (cwhwang@kt.com) | Rel-13 | RP-65 | CA | LTE_CA_B3_B40 |  |
| 314 | 100.12.1 | Core part: LTE Advanced inter-band Carrier Aggregation of Band 3 and Band 40 | 198d? | 2014-09-15 A | 2015-06-15 | 80% | 39.6d? | 2014-06-13 | 2015-03-13 | 196d? | 523d | finish no earlier than 2015-06-15 | R4 | 1584h | 1267.2h | LTE_CA_B3_B40-Core | PCG-33 | 36.101, 36.104, 36.133, New TR 36.8xx | KT | Chungwoo HWANG (cwhwang@kt.com) | Rel-13 | RP-65 | CA | LTE_CA_B3_B40-Core | RP-150013 |
| 315 | 100.12.2 | Perf. Part: LTE Advanced inter-band Carrier Aggregation of Band 3 and Band 40 | 198d? | 2014-09-15 A | 2015-06-15 | 80% | 39.6d? | 2014-06-13 | 2015-03-13 | 196d? | 523d | finish no earlier than 2015-06-15 | R4 | 1584h | 1267.2h | LTE_CA_B3_B40-Perf | PCG-33 | 36.141, 36.307 | KT | Chungwoo HWANG (cwhwang@kt.com) | Rel-13 | RP-65 | CA | LTE_CA_B3_B40-Perf | RP-150013 |
| 316 | 100.13 | **LTE Advanced inter-band Carrier Aggregation of Band 20 and Band 31** | 198d? | 2014-09-15 A | 2015-06-15 | 99% | 1.98d? | 2014-06-13 | 2015-03-13 | 196d? | 523d |  | R4 | 4752h | 3659.03h | LTE_CA_B20_B31 | PCG-33 | LTE | Huawei | Liu Liehai (liuliehai@huawei.com) | Rel-13 | RP-65 | CA | LTE_CA_B20_B31 |  |
| 317 | 100.13.1 | Core part: LTE Advanced inter-band Carrier Aggregation of Band 20 and Band 31 | 198d? | 2014-09-15 A | 2015-06-15 | 99% | 1.98d? | 2014-06-13 | 2015-03-13 | 196d? | 523d | finish no earlier than 2015-06-15 | R4 | 1584h | 1568.16h | LTE_CA_B20_B31-Core | PCG-33 | 36.101, 36.104, New TR 36.8xx | Huawei | Liu Liehai (liuliehai@huawei.com) | Rel-13 | RP-65 | CA | LTE_CA_B20_B31-Core | RP-150013 |
| 318 | 100.13.2 | Perf. Part: LTE Advanced inter-band Carrier Aggregation of Band 20 and Band 31 | 198d? | 2014-09-15 A | 2015-06-15 | 99% | 1.98d? | 2014-06-13 | 2015-03-13 | 196d? | 523d | finish no earlier than 2015-06-15 | R4 | 1584h | 1568.16h | LTE_CA_B20_B31-Perf | PCG-33 | 36.141, 36.307 | Huawei | Liu Liehai (liuliehai@huawei.com) | Rel-13 | RP-65 | CA | LTE_CA_B20_B31-Perf | RP-150013 |
| 319 | 100.14 | **LTE Advanced inter-band Carrier Aggregation of Band 3 and Band 31** | 198d? | 2014-09-15 A | 2015-06-15 | 38% | 123.75d? | 2014-06-13 | 2015-03-13 | 196d? | 523d |  | R4 | 4752h | 1584h | LTE_CA_B3_B31 | PCG-33 | LTE | Huawei | Liu Liehai (liuliehai@huawei.com) | Rel-13 | RP-65 | CA | LTE_CA_B3_B31 |  |
| 320 | 100.14.1 | Core part: LTE Advanced inter-band Carrier Aggregation of Band 3 and Band 31 | 198d? | 2014-09-15 A | 2015-06-15 | 75% | 49.5d? | 2014-06-13 | 2015-03-13 | 196d? | 523d | finish no earlier than 2015-06-15 | R4 | 1584h | 1188h | LTE_CA_B3_B31-Core | PCG-33 | 36.101, 36.104, New TR 36.8xx | Huawei | Liu Liehai (liuliehai@huawei.com) | Rel-13 | RP-65 | CA | LTE_CA_B3_B31-Core | RP-150013 |
| 321 | 100.14.2 | Perf. Part: LTE Advanced inter-band Carrier Aggregation of Band 3 and Band 31 | 198d? | 2014-09-15 | 2015-06-15 |  |  | 2014-06-13 | 2015-03-13 | 196d? | 523d | finish no earlier than 2015-06-15 | R4 | 1584h |  | LTE_CA_B3_B31-Perf | PCG-33 | 36.141, 36.307 | Huawei | Liu Liehai (liuliehai@huawei.com) | Rel-13 | RP-65 | CA | LTE_CA_B3_B31-Perf | RP-150013 |

Notes:
- 298: Inter-band CA 2DL/1UL
- 299: CD:Thu 11/12/14->Sun 15/03/15; Compl:0%->90%; Stat Rep: -->RP-141732 1st Apr 15: CD:Sun 15/03/15->Mon 15/06/15 1st Apr 15: Stat Rep: RP-141732->RP-150013
- 300: CD:Thu 11/12/14->Sun 15/03/15; Compl:0%->90%; Stat Rep: -->RP-141732 1st Apr 15: CD:Sun 15/03/15->Mon 15/06/15 1st Apr 15: Stat Rep: RP-141732->RP-150013
- 301: Inter-band CA 2DL/1UL
- 302: CD:Fri 11/12/15->Sun 15/03/15; Compl:0%->50%; Stat Rep: -->RP-141732 1st Apr 15: Compl:50%->99% 1st Apr 15: CD:Sun 15/03/15->Mon 15/06/15 1st Apr 15: Stat Rep: RP-141732->RP-150013
- 303: CD:Thu 12/03/15->Sun 15/03/15; Compl:0%->0%; Stat Rep: -->RP-141732 1st Apr 15: Compl:0%->99% 1st Apr 15: CD:Sun 15/03/15->Mon 15/06/15 1st Apr 15: Stat Rep: RP-141732->RP-150013
- 304: Inter-band CA 2DL/1UL
- 305: CD:Fri 11/12/15->Sun 15/03/15; Compl:0%->35%; Stat Rep: -->RP-141732 1st Apr 15: Compl:35%->99% 1st Apr 15: CD:Sun 15/03/15->Mon 15/06/15 1st Apr 15: Stat Rep: RP-141732->RP-150013
- 306: CD:Thu 12/03/15->Sun 15/03/15; Compl:0%->0%; Stat Rep: -->RP-141732 1st Apr 15: Compl:0%->99% 1st Apr 15: CD:Sun 15/03/15->Mon 15/06/15 1st Apr 15: Stat Rep: RP-141732->RP-150013
- 307: Inter-band CA 2DL/1UL
- 308: CD:Wed 11/03/15->Sun 15/03/15; Compl:0%->30%; Stat Rep: -->RP-141732 1st Apr 15: Compl:30%->70% 1st Apr 15: CD:Sun 15/03/15->Mon 15/06/15 1st Apr 15: Stat Rep: RP-141732->RP-150013
- 309: CD:Thu 12/03/15->Sun 15/03/15; Compl:0%->0%; Stat Rep: -->RP-141732 1st Apr 15: CD:Sun 15/03/15->Mon 15/06/15 1st Apr 15: Stat Rep: RP-141732->RP-150013
- 310: Inter-band CA 2DL/1UL
- 311: CD:Fri 12/06/15->Mon 15/06/15; Compl:0%->70%; Stat Rep: -->RP-141732 1st Apr 15: Compl:70%->80% 1st Apr 15: Stat Rep: RP-141732->RP-150013
- 312: CD:Fri 11/12/15->Mon 15/06/15; Compl:0%->70%; Stat Rep: -->RP-141732 1st Apr 15: Compl:70%->80% 1st Apr 15: Stat Rep: RP-141732->RP-150013
- 313: Inter-band CA 2DL/1UL
- 314: CD:Fri 11/12/15->Mon 15/06/15; Compl:0%->70%; Stat Rep: -->RP-141732 1st Apr 15: Compl:70%->80% 1st Apr 15: Stat Rep: RP-141732->RP-150013
- 315: CD:Fri 12/06/15->Mon 15/06/15; Compl:0%->70%; Stat Rep: -->RP-141732 1st Apr 15: Compl:70%->80% 1st Apr 15: Stat Rep: RP-141732->RP-150013
- 316: Inter-band CA 2DL/1UL
- 317: ; WID: RP-142043->RP-142007; Stat Rep: -->RP-141732 1st Apr 15: Compl:75%->99% 1st Apr 15: CD:Sun 15/03/15->Mon 15/06/15 1st Apr 15: Stat Rep: RP-141732->RP-150013
- 318: ; WID: RP-142043->RP-142007; Stat Rep: -->RP-141732 1st Apr 15: Compl:0%->99% 1st Apr 15: CD:Sun 15/03/15->Mon 15/06/15 1st Apr 15: Stat Rep: RP-141732->RP-150013
- 319: Inter-band CA 2DL/1UL
- 320: CD:Fri 11/12/15->Sun 15/03/15; Compl:0%->50%; Stat Rep: -->RP-141732 1st Apr 15: Compl:50%->75% 1st Apr 15: CD:Sun 15/03/15->Mon 15/06/15 1st Apr 15: WID: RP-141337->RP-150318 1st Apr 15: Stat Rep: RP-141732->RP-150013
- 321: CD:Thu 12/03/15->Sun 15/03/15; Compl:0%->0%; Stat Rep: -->RP-141732 1st Apr 15: CD:Sun 15/03/15->Mon 15/06/15 1st Apr 15: WID: RP-141337->RP-150318 1st Apr 15: Stat Rep: RP-141732->RP-150013

| ID | WBS | Task | Duration | Start | Finish | Complete | Remaining | Baseline start | Baseline finish | Baseline duration | Total slack | Constraint | Resources | Work | Actual work | Acronym | PCG approved | WI rapporteur name | WI rapporteur e-mail | Release | TSG approved | Special Focus Doc | Acronym_3GU_Export | Status Report |
| --- | --- | --- | --- | --- | --- | --- | --- | --- | --- | --- | --- | --- | --- | --- | --- | --- | --- | --- | --- | --- | --- | --- | --- | --- |
| 322 | 100.15 | **LTE Advanced inter-band Carrier Aggregation of Band 5 and Band 40** | 199d? | 2014-09-12 A | 2015-06-15 | 80% | 39.79d? | 2014-06-13 | 2015-03-13 | 196d? | 523d |  | R4 | 4768h | 3814.47h | LTE_CA_B5_B40 | PCG-33 | SK Telecom | haesung.park@sk.com | Rel-13 | RP-65 | CA | LTE_CA_B5_B40 |  |
| 323 | 100.15.1 | Core part: LTE Advanced inter-band Carrier Aggregation of Band 5 and Band 40 | 199d? | 2014-09-12 A | 2015-06-15 | 80% | 39.8d? | 2014-06-13 | 2015-03-13 | 196d? | 523d | finish no earlier than 2015-06-15 | R4 | 1592h | 1273.6h | LTE_CA_B5_B40-Core | PCG-33 | SK Telecom | haesung.park@sk.com | Rel-13 | RP-65 | CA | LTE_CA_B5_B40-Core | RP-150013 |
| 324 | 100.15.2 | Perf. Part: LTE Advanced inter-band Carrier Aggregation of Band 5 and Band 40 | 198d? | 2014-09-15 A | 2015-06-15 | 80% | 39.6d? | 2014-06-13 | 2015-03-13 | 196d? | 523d | finish no earlier than 2015-06-15 | R4 | 1584h | 1267.2h | LTE_CA_B5_B40-Perf | PCG-33 | SK Telecom | haesung.park@sk.com | Rel-13 | RP-65 | CA | LTE_CA_B5_B40-Perf | RP-150013 |
| 325 | 100.16 | **LTE Advanced intra-band contiguous Carrier Aggregation in Band 42 for 3DL** | 198d? | 2014-09-15 A | 2015-06-15 | 99% | 1.98d? | 2014-06-13 | 2015-03-13 | 196d? | 523d |  | R4 | 4752h | 4704.48h | LTE_CA_C_B42_3DL | PCG-33 | CATT | Yuexia Song (songyuexia@catt.cn) | Rel-13 | RP-65 | CA | LTE_CA_C_B42_3DL |  |
| 326 | 100.16.1 | Core part: LTE Advanced intra-band contiguous Carrier Aggregation in Band 42 for 3DL | 198d? | 2014-09-15 A | 2015-06-15 | 99% | 1.98d? | 2014-06-13 | 2015-03-13 | 196d? | 523d | finish no earlier than 2015-06-15 | R4 | 1584h | 1568.16h | LTE_CA_C_B42_3DL-Core | PCG-33 | CATT | Yuexia Song (songyuexia@catt.cn) | Rel-13 | RP-65 | CA | LTE_CA_C_B42_3DL-Core | RP-150013 |
| 327 | 100.16.2 | Perf. Part: LTE Advanced intra-band contiguous Carrier Aggregation in Band 42 for 3DL | 198d? | 2014-09-15 A | 2015-06-15 | 99% | 1.98d? | 2014-06-13 | 2015-03-13 | 196d? | 523d | finish no earlier than 2015-06-15 | R4 | 1584h | 1568.16h | LTE_CA_C_B42_3DL-Perf | PCG-33 | CATT | Yuexia Song (songyuexia@catt.cn) | Rel-13 | RP-65 | CA | LTE_CA_C_B42_3DL-Perf | RP-150013 |
| 328 | 100.17 | **LTE Advanced 3 Band Carrier Aggregation (3DL/1UL) of Band 8, Band 41 and Band 41** | 199d? | 2014-09-12 A | 2015-06-15 | 99% | 1.98d? | 2014-06-13 | 2015-03-13 | 196d? | 523d |  | R4 | 4768h | 3668.92h | LTE_CA_B8_B41_B41 | PCG-33 | China Mobile | PAN, Qun (panqun@chinamobile.com) | Rel-13 | RP-65 | CA | LTE_CA_B8_B41_B41 |  |
| 329 | 100.17.1 | Core part: LTE Advanced 3 Band Carrier Aggregation (3DL/1UL) of Band 8, Band 41 and Band 41 | 198d? | 2014-09-15 A | 2015-06-15 | 99% | 1.98d? | 2014-06-13 | 2015-03-13 | 196d? | 523d | finish no earlier than 2015-06-15 | R4 | 1584h | 1568.16h | LTE_CA_B8_B41_B41-Core | PCG-33 | China Mobile | PAN, Qun (panqun@chinamobile.com) | Rel-13 | RP-65 | CA | LTE_CA_B8_B41_B41-Core | RP-150013 |
| 330 | 100.17.2 | Perf. Part: LTE Advanced 3 Band Carrier Aggregation (3DL/1UL) of Band 8, Band 41 and Band 41 | 199d? | 2014-09-12 A | 2015-06-15 | 99% | 1.99d? | 2014-06-13 | 2015-03-13 | 196d? | 523d | finish no earlier than 2015-06-15 | R4 | 1592h | 1576.08h | LTE_CA_B8_B41_B41-Perf | PCG-33 | China Mobile | PAN, Qun (panqun@chinamobile.com) | Rel-13 | RP-65 | CA | LTE_CA_B8_B41_B41-Perf | RP-150013 |
| 331 | 100.18 | **LTE Advanced 3 Band Carrier Aggregation (3DL/1UL) of Band 38, Band 40 and Band 40** | 198d? | 2014-09-15 A | 2015-06-15 | 70% | 59.4d? | 2014-06-13 | 2015-03-13 | 196d? | 523d |  | R4 | 4752h | 3326.38h | LTE_CA_B38_B40_B40 | PCG-33 | Samsung | xutao.zhou@samsung.com | Rel-13 | RP-65 | CA | LTE_CA_B38_B40_B40 |  |
| 332 | 100.18.1 | Core part: LTE Advanced 3 Band Carrier Aggregation (3DL/1UL) of Band 38, Band 40 and Band 40 | 198d? | 2014-09-15 A | 2015-06-15 | 70% | 59.4d? | 2014-06-13 | 2015-03-13 | 196d? | 523d | finish no earlier than 2015-06-15 | R4 | 1584h | 1108.8h | LTE_CA_B38_B40_B40-Core | PCG-33 | Samsung | xutao.zhou@samsung.com | Rel-13 | RP-65 | CA | LTE_CA_B38_B40_B40-Core | RP-150013 |
| 333 | 100.18.2 | Perf. Part: LTE Advanced 3 Band Carrier Aggregation (3DL/1UL) of Band 38, Band 40 and Band 40 | 198d? | 2014-09-15 A | 2015-06-15 | 70% | 59.4d? | 2014-06-13 | 2015-03-13 | 196d? | 523d | finish no earlier than 2015-06-15 | R4 | 1584h | 1108.8h | LTE_CA_B38_B40_B40-Perf | PCG-33 | Samsung | xutao.zhou@samsung.com | Rel-13 | RP-65 | CA | LTE_CA_B38_B40_B40-Perf | RP-150013 |
| 334 | 100.19 | **LTE Advanced 3 Band Carrier Aggregation (3DL/1UL) of Band 2, Band 5 and Band 29** | 198d? | 2014-09-15 A | 2015-06-15 | 99% | 1.98d? | 2014-06-13 | 2015-03-13 | 196d? | 523d |  | R4 | 4752h | 4704.48h | LTE_CA_B2_B5_B29 | PCG-33 | Huawei | SHAN Huiping (shanhuiping@huawei.com) | Rel-13 | RP-65 | CA | LTE_CA_B2_B5_B29 |  |
| 335 | 100.19.1 | Core part: LTE Advanced 3 Band Carrier Aggregation (3DL/1UL) of Band 2, Band 5 and Band 29 | 198d? | 2014-09-15 A | 2015-06-15 | 99% | 1.98d? | 2014-06-13 | 2015-03-13 | 196d? | 523d | finish no earlier than 2015-06-15 | R4 | 1584h | 1568.16h | LTE_CA_B2_B5_B29-Core | PCG-33 | Huawei | SHAN Huiping (shanhuiping@huawei.com) | Rel-13 | RP-65 | CA | LTE_CA_B2_B5_B29-Core | RP-150013 |
| 336 | 100.19.2 | Perf. Part: LTE Advanced 3 Band Carrier Aggregation (3DL/1UL) of Band 2, Band 5 and Band 29 | 198d? | 2014-09-15 A | 2015-06-15 | 99% | 1.98d? | 2014-06-13 | 2015-03-13 | 196d? | 523d | finish no earlier than 2015-06-15 | R4 | 1584h | 1568.16h | LTE_CA_B2_B5_B29-Perf | PCG-33 | Huawei | SHAN Huiping (shanhuiping@huawei.com) | Rel-13 | RP-65 | CA | LTE_CA_B2_B5_B29-Perf | RP-150013 |
| 337 | 100.20 | **LTE Carrier Aggregation Enhancement Beyond 5 Carriers** | 393d? | 2014-12-15 A | 2016-06-15 | 4% | 377.29d? |  |  |  | 261d |  | R1 | 8384h | 335.3h | LTE_CA_enh_b5C | PCG-34 | Nokia | Nokia | Rel-13 | RP-66 |  |  |  |
| 338 | 100.20.1 | Core part: LTE Carrier Aggregation Enhancement Beyond 5 Carriers | 262d? | 2014-12-15 A | 2015-12-15 | 10% | 235.8d? |  |  |  | 392d | finish no earlier than 2015-12-15 | R1 | 2096h | 209.6h | LTE_CA_enh_b5C-Core | PCG-34 | Nokia | Nokia | Rel-13 | RP-66 |  |  | RP-150272 |
| 339 | 100.20.2 | Perf. part: LTE Carrier Aggregation Enhancement Beyond 5 Carriers | 393d? | 2014-12-15 | 2016-06-15 |  |  |  |  |  | 261d | finish no earlier than 2016-06-15 | R4 | 3144h |  | LTE_CA_enh_b5C-Perf | PCG-34 | Nokia | Nokia | Rel-13 | RP-66 |  |  | RP-150272 |
| 340 | 100.21 | **HSPA Dual-Band UL carrier aggregation** | 327d? | 2014-12-15 A | 2016-03-15 | 4% | 312.46d? |  |  |  | 327d |  | R4 | 7328h | 325.91h | HSUPA_DB_MC | PCG-34 | Qualcomm | Qualcomm | Rel-13 | RP-66 |  |  |  |
| 341 | 100.21.1 | Core part: HSPA Dual-Band UL carrier aggregation | 262d? | 2014-12-15 A | 2015-12-15 | 10% | 235.8d? |  |  |  | 392d | finish no earlier than 2015-12-15 | R4 | 2096h | 209.6h | HSUPA_DB_MC-Core | PCG-34 | Qualcomm | Qualcomm | Rel-13 | RP-66 |  |  | RP-150127 |
| 342 | 100.21.2 | Perf. part: HSPA Dual-Band UL carrier aggregation | 327d? | 2014-12-15 | 2016-03-15 |  |  |  |  |  | 327d | finish no earlier than 2016-03-15 | R4 | 2616h |  | HSUPA_DB_MC-Perf | PCG-34 | Qualcomm | Qualcomm | Rel-13 | RP-66 |  |  | RP-150127 |
| 343 | 100.22 | **LTE Advanced inter-band Carrier Aggregation of Band 25 and Band 26** | 131d? | 2014-12-15 A | 2015-06-15 | 95% | 6.54d? |  |  |  | 523d |  | R4 | 3144h | 3039.2h | LTE_CA_B25_B26 | PCG-34 | Sprint | Sprint | Rel-13 | RP-66 |  |  |  |
| 344 | 100.22.1 | Core part: LTE Advanced inter-band Carrier Aggregation of Band 25 and Band 26 | 131d? | 2014-12-15 A | 2015-06-15 | 95% | 6.55d? |  |  |  | 523d | finish no earlier than 2015-06-15 | R4 | 1048h | 995.6h | LTE_CA_B25_B26-Core | PCG-34 | Sprint | Sprint | Rel-13 | RP-66 |  |  | RP-150013 |
| 345 | 100.22.2 | Perf. part: LTE Advanced inter-band Carrier Aggregation of Band 25 and Band 26 | 131d? | 2014-12-15 A | 2015-06-15 | 95% | 6.55d? |  |  |  | 523d | finish no earlier than 2015-06-15 | R4 | 1048h | 995.6h | LTE_CA_B25_B26-Perf | PCG-34 | Sprint | Sprint | Rel-13 | RP-66 |  |  | RP-150013 |

Notes:
- 322: Inter-band CA 2DL/1UL / Impacted TSs and TRs: LTE
- 323: ; WID: RP-142043->RP-141888; Stat Rep: -->RP-141732 1st Apr 15: Compl:0%->80% 1st Apr 15: WID: RP-141888->RP-150285 1st Apr 15: Stat Rep: RP-141732->RP-150013 / Impacted TSs and TRs: 36.101, 36.104, New TR 36.8xx
- 324: ; WID: RP-142043->RP-141888; Stat Rep: -->RP-141732 1st Apr 15: Compl:0%->80% 1st Apr 15: WID: RP-141888->RP-150285 1st Apr 15: Stat Rep: RP-141732->RP-150013 / Impacted TSs and TRs: 36.141, 36.307
- 325: Intra-band contig. CA 3DL / Impacted TSs and TRs: LTE
- 326: CD:Fri 12/06/15->Mon 15/06/15; Compl:0%->70%; Stat Rep: -->RP-141732 1st Apr 15: Compl:70%->99% 1st Apr 15: WID: RP-141677->RP-150319 1st Apr 15: Stat Rep: RP-141732->RP-150013 / Impacted TSs and TRs: 36.101, 36.104, 36.133, New TR 36.833-5-42
- 327: CD:Fri 12/06/15->Mon 15/06/15; Compl:0%->0%; Stat Rep: -->RP-141732 1st Apr 15: Compl:0%->99% 1st Apr 15: WID: RP-141677->RP-150319 1st Apr 15: Stat Rep: RP-141732->RP-150013 / Impacted TSs and TRs: 36.141, 36.307
- 328: Inter-band CA 3DL/1UL / Impacted TSs and TRs: LTE
- 329: ; WID: RP-142043->RP-141845; Stat Rep: -->RP-141732 1st Apr 15: Compl:80%->99% 1st Apr 15: CD:Sun 15/03/15->Mon 15/06/15 1st Apr 15: Stat Rep: RP-141732->RP-150013 / Impacted TSs and TRs: 36.101, 36.104, 36.133, New TR 36.8xx
- 330: ; WID: RP-142043->RP-141845; Stat Rep: -->RP-141732 1st Apr 15: Compl:0%->99% 1st Apr 15: CD:Sun 15/03/15->Mon 15/06/15 1st Apr 15: Stat Rep: RP-141732->RP-150013 / Impacted TSs and TRs: 36.141, 36.307
- 331: Inter-band CA 3DL/1UL / Impacted TSs and TRs: LTE
- 332: CD:Fri 12/06/15->Mon 15/06/15; Compl:0%->0%; Stat Rep: -->RP-141732 1st Apr 15: Compl:0%->70% 1st Apr 15: Stat Rep: RP-141732->RP-150013 / Impacted TSs and TRs: 36.101, 36.104, 36.133, New TR 36.8xx
- 333: CD:Fri 12/06/15->Mon 15/06/15; Compl:0%->0%; Stat Rep: -->RP-141732 1st Apr 15: Compl:0%->70% 1st Apr 15: Stat Rep: RP-141732->RP-150013 / Impacted TSs and TRs: 36.141, 36.307
- 334: Inter-band CA 3DL/1UL / Impacted TSs and TRs: LTE
- 335: CD:Fri 11/12/15->Mon 15/06/15; Compl:0%->50%; Stat Rep: -->RP-141732 1st Apr 15: Compl:50%->99% 1st Apr 15: Stat Rep: RP-141732->RP-150013 / Impacted TSs and TRs: 36.101, 36.104, 36.133, New TR 36.8xy (inter-band CA 2DL/1UL (introduce CA_B5-B29), New TR 36.8xz (inter-band CA 3DL/1UL)
- 336: CD:Fri 12/06/15->Mon 15/06/15; Compl:0%->0%; Stat Rep: -->RP-141732 1st Apr 15: Compl:0%->99% 1st Apr 15: Stat Rep: RP-141732->RP-150013 / Impacted TSs and TRs: 36.141, 36.307
- 337: FCD: 06/16->12/15, Rel-14?->Rel-13
- 338: FCD: 06/16->12/15, Rel-14?->Rel-13 1st Apr 15: Compl:0%->10% 1st Apr 15: WID: RP-142286->RP-150277 1st Apr 15: Stat Rep: ->RP-150272
- 339: 1st Apr 15: WID: RP-142286->RP-150277 1st Apr 15: Stat Rep: ->RP-150272
- 341: 1st Apr 15: Compl:0%->10% 1st Apr 15: WID: RP-142237->RP-150129 1st Apr 15: Stat Rep: ->RP-150127
- 342: 1st Apr 15: WID: RP-142237->RP-150129 1st Apr 15: Stat Rep: ->RP-150127
- 344: 1st Apr 15: Compl:0%->95% 1st Apr 15: CD:Tue 15/12/15->Mon 15/06/15 1st Apr 15: WID: RP-142020->RP-150115 1st Apr 15: Stat Rep: ->RP-150013
- 345: 1st Apr 15: Compl:0%->95% 1st Apr 15: CD:Tue 15/12/15->Mon 15/06/15 1st Apr 15: WID: RP-142020->RP-150115 1st Apr 15: Stat Rep: ->RP-150013

| ID | WBS | Task | Duration | Start | Finish | Complete | Remaining | Total slack | Constraint | Resources | Work | Actual work | Acronym | PCG approved | WI rapporteur name | WI rapporteur e-mail | Release | TSG approved | Status Report |
| --- | --- | --- | --- | --- | --- | --- | --- | --- | --- | --- | --- | --- | --- | --- | --- | --- | --- | --- | --- |
| 346 | 100.23 | **LTE Advanced inter-band Carrier Aggregation of Band 3 and Band 41** | 197d? | 2014-12-15 A | 2015-09-15 | 20% | 157.6d? | 457d |  | R4 | 4728h | 945.6h | LTE_CA_B3_B41 | PCG-34 | China Telecom | China Telecom | Rel-13 | RP-66 |  |
| 347 | 100.23.1 | Core part: LTE Advanced inter-band Carrier Aggregation of Band 3 and Band 41 | 197d? | 2014-12-15 A | 2015-09-15 | 20% | 157.6d? | 457d | finish no earlier than 2015-09-15 | R4 | 1576h | 315.2h | LTE_CA_B3_B41-Core | PCG-34 | China Telecom | China Telecom | Rel-13 | RP-66 | RP-150013 |
| 348 | 100.23.2 | Perf. part: LTE Advanced inter-band Carrier Aggregation of Band 3 and Band 41 | 197d? | 2014-12-15 A | 2015-09-15 | 20% | 157.6d? | 457d | finish no earlier than 2015-09-15 | R4 | 1576h | 315.2h | LTE_CA_B3_B41-Perf | PCG-34 | China Telecom | China Telecom | Rel-13 | RP-66 | RP-150013 |
| 349 | 100.24 | **LTE Advanced 3 band Carrier Aggregation (3DL/1UL) of Band 1, Band 3 and Band 3** | 131d? | 2014-12-15 A | 2015-06-15 | 25% | 98.25d? | 523d |  | R4 | 3144h | 786h | LTE_CA_B1_B3_B3 | PCG-34 | China Unicom | China Unicom | Rel-13 | RP-66 |  |
| 350 | 100.24.1 | Core part: LTE Advanced 3 band Carrier Aggregation (3DL/1UL) of Band 1, Band 3 and Band 3 | 131d? | 2014-12-15 A | 2015-06-15 | 50% | 65.5d? | 523d | finish no earlier than 2015-06-15 | R4 | 1048h | 524h | LTE_CA_B1_B3_B3-Core | PCG-34 | China Unicom | China Unicom | Rel-13 | RP-66 | RP-150013 |
| 351 | 100.24.2 | Perf. part: LTE Advanced 3 band Carrier Aggregation (3DL/1UL) of Band 1, Band 3 and Band 3 | 131d? | 2014-12-15 | 2015-06-15 |  |  | 523d | finish no earlier than 2015-06-15 | R4 | 1048h |  | LTE_CA_B1_B3_B3-Perf | PCG-34 | China Unicom | China Unicom | Rel-13 | RP-66 |  |
| 352 | 100.25 | **LTE Advanced 3 Band Carrier Aggregation (3DL/1UL) of Band 1, Band 19 and Band 28** | 131d? | 2014-12-15 A | 2015-06-15 | 25% | 98.25d? | 523d |  | R4 | 3144h | 786h | LTE_CA_B1_B19_B28 | PCG-34 | NTT DOCOMO | NTT DOCOMO | Rel-13 | RP-66 |  |
| 353 | 100.25.1 | Core part: LTE Advanced 3 Band Carrier Aggregation (3DL/1UL) of Band 1, Band 19 and Band 28 | 131d? | 2014-12-15 A | 2015-06-15 | 50% | 65.5d? | 523d | finish no earlier than 2015-06-15 | R4 | 1048h | 524h | LTE_CA_B1_B19_B28-Core | PCG-34 | NTT DOCOMO | NTT DOCOMO | Rel-13 | RP-66 | RP-150013 |
| 354 | 100.25.2 | Perf. part: LTE Advanced 3 Band Carrier Aggregation (3DL/1UL) of Band 1, Band 19 and Band 28 | 131d? | 2014-12-15 | 2015-06-15 |  |  | 523d | finish no earlier than 2015-06-15 | R4 | 1048h |  | LTE_CA_B1_B19_B28-Perf | PCG-34 | NTT DOCOMO | NTT DOCOMO | Rel-13 | RP-66 |  |
| 355 | 100.26 | **LTE Advanced 3 Band Carrier Aggregation (3DL/1UL) of Band 21, Band 42 and Band 42** | 131d? | 2014-12-15 A | 2015-06-15 | 45% | 72.05d? | 523d |  | R4 | 3144h | 1414.82h | LTE_CA_B21_B42_B42 | PCG-34 | NTT DOCOMO | NTT DOCOMO | Rel-13 | RP-66 |  |
| 356 | 100.26.1 | Core part: LTE Advanced 3 Band Carrier Aggregation (3DL/1UL) of Band 21, Band 42 and Band 42 | 131d? | 2014-12-15 A | 2015-06-15 | 90% | 13.1d? | 523d | finish no earlier than 2015-06-15 | R4 | 1048h | 943.2h | LTE_CA_B21_B42_B42-Core | PCG-34 | NTT DOCOMO | NTT DOCOMO | Rel-13 | RP-66 | RP-150013 |
| 357 | 100.26.2 | Perf. part: LTE Advanced 3 Band Carrier Aggregation (3DL/1UL) of Band 21, Band 42 and Band 42 | 131d? | 2014-12-15 | 2015-06-15 |  |  | 523d | finish no earlier than 2015-06-15 | R4 | 1048h |  | LTE_CA_B21_B42_B42-Perf | PCG-34 | NTT DOCOMO | NTT DOCOMO | Rel-13 | RP-66 |  |
| 358 | 100.27 | **LTE Advanced 3 Band Carrier Aggregation (3DL/1UL) of Band 7, Band 40 and Band 40** | 131d? | 2014-12-15 A | 2015-06-15 | 40% | 78.6d? | 523d |  | R4 | 3144h | 1257.63h | LTE_CA_B7_B40_B40 | PCG-34 | ZTE | ZTE | Rel-13 | RP-66 |  |
| 359 | 100.27.1 | Core part: LTE Advanced 3 Band Carrier Aggregation (3DL/1UL) of Band 7, Band 40 and Band 40 | 131d? | 2014-12-15 A | 2015-06-15 | 40% | 78.6d? | 523d | finish no earlier than 2015-06-15 | R4 | 1048h | 419.2h | LTE_CA_B7_B40_B40-Core | PCG-34 | ZTE | ZTE | Rel-13 | RP-66 | RP-150013 |
| 360 | 100.27.2 | Perf. part: LTE Advanced 3 Band Carrier Aggregation (3DL/1UL) of Band 7, Band 40 and Band 40 | 131d? | 2014-12-15 A | 2015-06-15 | 40% | 78.6d? | 523d | finish no earlier than 2015-06-15 | R4 | 1048h | 419.2h | LTE_CA_B7_B40_B40-Perf | PCG-34 | ZTE | ZTE | Rel-13 | RP-66 | RP-150013 |
| 361 | 100.28 | **LTE Advanced 3 band Carrier Aggregation (3DL/1UL) of Band 1, Band 8 and Band 28** | 197d? | 2014-12-15 A | 2015-09-15 | 20% | 157.6d? | 457d |  | R4 | 4728h | 945.6h | LTE_CA_B1_B8_B28 | PCG-34 | Softbank Mobile | Softbank Mobile | Rel-13 | RP-66 |  |
| 362 | 100.28.1 | Core part: LTE Advanced 3 band Carrier Aggregation (3DL/1UL) of Band 1, Band 8 and Band 28 | 197d? | 2014-12-15 A | 2015-09-15 | 20% | 157.6d? | 457d | finish no earlier than 2015-09-15 | R4 | 1576h | 315.2h | LTE_CA_B1_B8_B28-Core | PCG-34 | Softbank Mobile | Softbank Mobile | Rel-13 | RP-66 | RP-150013 |
| 363 | 100.28.2 | Perf. part: LTE Advanced 3 band Carrier Aggregation (3DL/1UL) of Band 1, Band 8 and Band 28 | 197d? | 2014-12-15 A | 2015-09-15 | 20% | 157.6d? | 457d | finish no earlier than 2015-09-15 | R4 | 1576h | 315.2h | LTE_CA_B1_B8_B28-Perf | PCG-34 | Softbank Mobile | Softbank Mobile | Rel-13 | RP-66 | RP-150013 |
| 364 | 100.29 | **LTE Advanced 3 Band Carrier Aggregation (3DL/1UL) of Band 3, Band 7 and Band 7** | 131d? | 2014-12-15 A | 2015-06-15 | 99% | 1.29d? | 523d |  | R4 | 3144h | 2332.41h | LTE_CA_B3_B7_B7_Bwset | PCG-34 | Ericsson | Ericsson | Rel-13 | RP-66 |  |
| 365 | 100.29.1 | Core part: Additional bandwidth combination set for LTE Advanced 3 Band Carrier Aggregation (3DL/1UL) of Band 3, Band 7 and Band 7 | 131d? | 2014-12-15 A | 2015-06-15 | 99% | 1.31d? | 523d | finish no earlier than 2015-06-15 | R4 | 1048h | 1037.52h | LTE_CA_B3_B7_B7_Bwset-Core | PCG-34 | Ericsson | Ericsson | Rel-13 | RP-66 | RP-150013 |
| 366 | 100.29.2 | Perf. Part: Additional bandwidth combination set for LTE Advanced 3 Band Carrier Aggregation (3DL/1UL) of Band 3, Band 7 and Band 7 | 131d? | 2014-12-15 A | 2015-06-15 | 99% | 1.31d? | 523d | finish no earlier than 2015-06-15 | R4 | 1048h | 1037.52h | LTE_CA_B3_B7_B7_BWset-Perf | PCG-34 | Ericsson | Ericsson | Rel-13 | RP-66 | RP-150013 |
| 367 | 100.30 | **LTE Advanced 3 Band Carrier Aggregation (3DL/1UL) of Band 7, Band 7 and Band 28** | 131d? | 2014-12-15 A | 2015-06-15 | 99% | 1.29d? | 523d |  | R4 | 3144h | 2332.41h | LTE_CA_B7_B7_B28 | PCG-34 | Ericsson | Ericsson | Rel-13 | RP-66 |  |
| 368 | 100.30.1 | Core part: LTE Advanced 3 Band Carrier Aggregation (3DL/1UL) of Band 7, Band 7 and Band 28 | 131d? | 2014-12-15 A | 2015-06-15 | 99% | 1.31d? | 523d | finish no earlier than 2015-06-15 | R4 | 1048h | 1037.52h | LTE_CA_B7_B7_B28-Core | PCG-34 | Ericsson | Ericsson | Rel-13 | RP-66 | RP-150013 |
| 369 | 100.30.2 | Perf. part: LTE Advanced 3 Band Carrier Aggregation (3DL/1UL) of Band 7, Band 7 and Band 28 | 131d? | 2014-12-15 A | 2015-06-15 | 99% | 1.31d? | 523d | finish no earlier than 2015-06-15 | R4 | 1048h | 1037.52h | LTE_CA_B7_B7_B28-Perf | PCG-34 | Ericsson | Ericsson | Rel-13 | RP-66 | RP-150013 |

Notes:
- 347: 1st Apr 15: Compl:0%->20% 1st Apr 15: Stat Rep: ->RP-150013
- 348: 1st Apr 15: Compl:0%->20% 1st Apr 15: Stat Rep: ->RP-150013
- 350: 1st Apr 15: Compl:0%->50% 1st Apr 15: Stat Rep: ->RP-150013
- 353: 1st Apr 15: Compl:0%->50% 1st Apr 15: Stat Rep: ->RP-150013
- 356: 1st Apr 15: Compl:0%->90% 1st Apr 15: Stat Rep: ->RP-150013
- 359: 1st Apr 15: Compl:0%->40% 1st Apr 15: Stat Rep: ->RP-150013
- 360: 1st Apr 15: Compl:0%->40% 1st Apr 15: Stat Rep: ->RP-150013
- 362: 1st Apr 15: Compl:0%->20% 1st Apr 15: WID: RP-141826->RP-150447 1st Apr 15: Stat Rep: ->RP-150013
- 363: 1st Apr 15: Compl:0%->20% 1st Apr 15: WID: RP-141826->RP-150447 1st Apr 15: Stat Rep: ->RP-150013
- 364: Acronym changed from LTE_CA_B3_B7_B7
- 365: Acronym changed from LTE_CA_B3_B7_B7-Core 1st Apr 15: Compl:0%->99% 1st Apr 15: CD:Sun 15/03/15->Mon 15/06/15 1st Apr 15: Stat Rep: ->RP-150013
- 366: Acronym changed from LTE_CA_B3_B7_B7-Perf 1st Apr 15: Compl:0%->99% 1st Apr 15: CD:Sun 15/03/15->Mon 15/06/15 1st Apr 15: Stat Rep: ->RP-150013
- 368: 1st Apr 15: Compl:0%->99% 1st Apr 15: CD:Sun 15/03/15->Mon 15/06/15 1st Apr 15: Stat Rep: ->RP-150013
- 369: 1st Apr 15: Compl:0%->99% 1st Apr 15: CD:Sun 15/03/15->Mon 15/06/15 1st Apr 15: Stat Rep: ->RP-150013

| ID | WBS | Task | Duration | Start | Finish | Complete | Remaining | Total slack | Constraint | Resources | Work | Actual work | Acronym | PCG approved | WI rapporteur name | WI rapporteur e-mail | Release | TSG approved | Status Report |
| --- | --- | --- | --- | --- | --- | --- | --- | --- | --- | --- | --- | --- | --- | --- | --- | --- | --- | --- | --- |
| 370 | 100.31 | **LTE Advanced 3 band Carrier Aggregation (3DL/1UL) of Band 1, Band 3 and Band 40** | 197d? | 2014-12-15 A | 2015-09-15 | 10% | 177.31d? | 457d |  | R4 | 4728h | 472.72h | LTE_CA_B1_B3_B40 | PCG-34 | KT | KT | Rel-13 | RP-66 |  |
| 371 | 100.31.1 | Core part: LTE Advanced 3 band Carrier Aggregation (3DL/1UL) of Band 1, Band 3 and Band 40 | 197d? | 2014-12-15 A | 2015-09-15 | 10% | 177.3d? | 457d | finish no earlier than 2015-09-15 | R4 | 1576h | 157.6h | LTE_CA_B1_B3_B40-Core | PCG-34 | KT | KT | Rel-13 | RP-66 | RP-150013 |
| 372 | 100.31.2 | Perf. part: LTE Advanced 3 band Carrier Aggregation (3DL/1UL) of Band 1, Band 3 and Band 40 | 197d? | 2014-12-15 A | 2015-09-15 | 10% | 177.3d? | 457d | finish no earlier than 2015-09-15 | R4 | 1576h | 157.6h | LTE_CA_B1_B3_B40-Perf | PCG-34 | KT | KT | Rel-13 | RP-66 | RP-150013 |
| 373 | 100.32 | **LTE Advanced 3 band Carrier Aggregation (3DL/1UL) of Band 1, Band 8 and Band 40** | 197d? | 2014-12-15 A | 2015-09-15 | 10% | 177.31d? | 457d |  | R4 | 4728h | 472.72h | LTE_CA_B1_B8_B40 | PCG-34 | KT | KT | Rel-13 | RP-66 |  |
| 374 | 100.32.1 | Core part: LTE Advanced 3 band Carrier Aggregation (3DL/1UL) of Band 1, Band 8 and Band 40 | 197d? | 2014-12-15 A | 2015-09-15 | 10% | 177.3d? | 457d | finish no earlier than 2015-09-15 | R4 | 1576h | 157.6h | LTE_CA_B1_B8_B40-Core | PCG-34 | KT | KT | Rel-13 | RP-66 | RP-150013 |
| 375 | 100.32.2 | Perf. part: LTE Advanced 3 band Carrier Aggregation (3DL/1UL) of Band 1, Band 8 and Band 40 | 197d? | 2014-12-15 A | 2015-09-15 | 10% | 177.3d? | 457d | finish no earlier than 2015-09-15 | R4 | 1576h | 157.6h | LTE_CA_B1_B8_B40-Perf | PCG-34 | KT | KT | Rel-13 | RP-66 | RP-150013 |
| 376 | 100.33 | **LTE Advanced 3 band Carrier Aggregation (3DL/1UL) of Band 3, Band 8 and Band 40** | 197d? | 2014-12-15 A | 2015-09-15 | 10% | 177.31d? | 457d |  | R4 | 4728h | 472.72h | LTE_CA_B3_B8_B40 | PCG-34 | KT | KT | Rel-13 | RP-66 |  |
| 377 | 100.33.1 | Core part: LTE Advanced 3 band Carrier Aggregation (3DL/1UL) of Band 3, Band 8 and Band 40 | 197d? | 2014-12-15 A | 2015-09-15 | 10% | 177.3d? | 457d | finish no earlier than 2015-09-15 | R4 | 1576h | 157.6h | LTE_CA_B3_B8_B40-Core | PCG-34 | KT | KT | Rel-13 | RP-66 | RP-150013 |
| 378 | 100.33.2 | Perf. part: LTE Advanced 3 band Carrier Aggregation (3DL/1UL) of Band 3, Band 8 and Band 40 | 197d? | 2014-12-15 A | 2015-09-15 | 10% | 177.3d? | 457d | finish no earlier than 2015-09-15 | R4 | 1576h | 157.6h | LTE_CA_B3_B8_B40-Perf | PCG-34 | KT | KT | Rel-13 | RP-66 | RP-150013 |
| 379 | 100.34 | **LTE Advanced 3 Band Carrier Aggregation (3DL) of Band 3, Band 7 and Band 8** | 131d? | 2014-12-15 A | 2015-06-15 | 97% | 3.92d? | 523d |  | R4 | 3144h | 3049.78h | LTE_CA_B3_B7_B8 | PCG-34 | Ericsson | Ericsson | Rel-13 | RP-66 |  |
| 380 | 100.34.1 | Core part: LTE Advanced 3 Band Carrier Aggregation (3DL) of Band 3, Band 7 and Band 8 | 131d? | 2014-12-15 A | 2015-06-15 | 95% | 6.55d? | 523d | finish no earlier than 2015-06-15 | R4 | 1048h | 995.6h | LTE_CA_B3_B7_B8-Core | PCG-34 | Ericsson | Ericsson | Rel-13 | RP-66 | RP-150013 |
| 381 | 100.34.2 | Perf. part: LTE Advanced 3 Band Carrier Aggregation (3DL) of Band 3, Band 7 and Band 8 | 131d? | 2014-12-15 A | 2015-06-15 | 99% | 1.31d? | 523d | finish no earlier than 2015-06-15 | R4 | 1048h | 1037.52h | LTE_CA_B3_B7_B8-Perf | PCG-34 | Ericsson | Ericsson | Rel-13 | RP-66 | RP-150013 |
| 382 | 100.35 | **LTE Advanced 3 Band Carrier Aggregation (3DL/1UL) of Band 1, Band 3 and Band 28** | 131d? | 2014-12-15 A | 2015-06-15 | 99% | 1.29d? | 523d |  | R4 | 3144h | 2332.41h | LTE_CA_B1_B3_B28 | PCG-34 | Nokia Networks | Nokia Networks | Rel-13 | RP-66 |  |
| 383 | 100.35.1 | Core part: LTE Advanced 3 Band Carrier Aggregation (3DL/1UL) of Band 1, Band 3 and Band 28 | 131d? | 2014-12-15 A | 2015-06-15 | 99% | 1.31d? | 523d | finish no earlier than 2015-06-15 | R4 | 1048h | 1037.52h | LTE_CA_B1_B3_B28-Core | PCG-34 | Nokia Networks | Nokia Networks | Rel-13 | RP-66 | RP-150013 |
| 384 | 100.35.2 | Perf. part: LTE Advanced 3 Band Carrier Aggregation (3DL/1UL) of Band 1, Band 3 and Band 28 | 131d? | 2014-12-15 A | 2015-06-15 | 99% | 1.31d? | 523d | finish no earlier than 2015-06-15 | R4 | 1048h | 1037.52h | LTE_CA_B1_B3_B28-Perf | PCG-34 | Nokia Networks | Nokia Networks | Rel-13 | RP-66 | RP-150013 |
| 385 | 100.36 | **LTE Advanced 3 band Carrier Aggregation (3DL/1UL) of Band 3, Band 8 and Band 28** | 197d? | 2014-12-15 A | 2015-09-15 | 20% | 157.6d? | 457d |  | R4 | 4728h | 869.67h | LTE_CA_B3_B8_B28 | PCG-34 | Softbank Mobile | Softbank Mobile | Rel-13 | RP-66 |  |
| 386 | 100.36.1 | Core part: LTE Advanced 3 band Carrier Aggregation (3DL/1UL) of Band 3, Band 8 and Band 28 | 197d? | 2014-12-15 A | 2015-09-15 | 20% | 157.6d? | 457d | finish no earlier than 2015-09-15 | R4 | 1576h | 315.2h | LTE_CA_B3_B8_B28-Core | PCG-34 | Softbank Mobile | Softbank Mobile | Rel-13 | RP-66 | RP-150013 |
| 387 | 100.36.2 | Perf. part: LTE Advanced 3 band Carrier Aggregation (3DL/1UL) of Band 3, Band 8 and Band 28 | 197d? | 2014-12-15 A | 2015-09-15 | 20% | 157.6d? | 457d | finish no earlier than 2015-09-15 | R4 | 1576h | 315.2h | LTE_CA_B3_B8_B28-Perf | PCG-34 | Softbank Mobile | Softbank Mobile | Rel-13 | RP-66 | RP-150013 |
| 388 | 100.37 | **LTE Advanced 3 Band Carrier Aggregation (3DL/1UL) of Band 8, Band 42 and Band 42** | 131d? | 2014-12-15 A | 2015-06-15 | 20% | 104.81d? | 523d |  | R4 | 3144h | 698.66h | LTE_CA_B8_B42_B42 | PCG-34 | Softbank Mobile | Softbank Mobile | Rel-13 | RP-66 |  |
| 389 | 100.37.1 | Core part: LTE Advanced 3 Band Carrier Aggregation (3DL/1UL) of Band 8, Band 42 and Band 42 | 131d? | 2014-12-15 A | 2015-06-15 | 20% | 104.8d? | 523d | finish no earlier than 2015-06-15 | R4 | 1048h | 209.6h | LTE_CA_B8_B42_B42-Core | PCG-34 | Softbank Mobile | Softbank Mobile | Rel-13 | RP-66 | RP-150013 |
| 390 | 100.37.2 | Perf. part: LTE Advanced 3 Band Carrier Aggregation (3DL/1UL) of Band 8, Band 42 and Band 42 | 131d? | 2014-12-15 A | 2015-06-15 | 20% | 104.8d? | 523d | finish no earlier than 2015-06-15 | R4 | 1048h | 209.6h | LTE_CA_B8_B42_B42-Perf | PCG-34 | Softbank Mobile | Softbank Mobile | Rel-13 | RP-66 | RP-150013 |
| 391 | 100.38 | **LTE Advanced 3 Band Carrier Aggregation (3DL/1UL) of Band 28, Band 40 and Band 40** | 131d? | 2014-12-15 A | 2015-06-15 | 15% | 111.35d? | 523d |  | R4 | 3144h | 733.53h | LTE_CA_B28_B40_B40 | PCG-34 | Huawei | Huawei | Rel-13 | RP-66 |  |
| 392 | 100.38.1 | Core part: LTE Advanced 3 Band Carrier Aggregation (3DL/1UL) of Band 28, Band 40 and Band 40 | 131d? | 2014-12-15 A | 2015-06-15 | 30% | 91.7d? | 523d | finish no earlier than 2015-06-15 | R4 | 1048h | 314.4h | LTE_CA_B28_B40_B40-Core | PCG-34 | Huawei | Huawei | Rel-13 | RP-66 | RP-150013 |
| 393 | 100.38.2 | Perf. part: LTE Advanced 3 Band Carrier Aggregation (3DL/1UL) of Band 28, Band 40 and Band 40 | 131d? | 2014-12-15 | 2015-06-15 |  |  | 523d | finish no earlier than 2015-06-15 | R4 | 1048h |  | LTE_CA_B28_B40_B40-Perf | PCG-34 | Huawei | Huawei | Rel-13 | RP-66 | RP-150013 |

Notes:
- 371: 1st Apr 15: Compl:0%->10% 1st Apr 15: Stat Rep: ->RP-150013
- 372: 1st Apr 15: Compl:0%->10% 1st Apr 15: Stat Rep: ->RP-150013
- 374: 1st Apr 15: Compl:0%->10% 1st Apr 15: Stat Rep: ->RP-150013
- 375: 1st Apr 15: Compl:0%->10% 1st Apr 15: Stat Rep: ->RP-150013
- 377: 1st Apr 15: Compl:0%->10% 1st Apr 15: Stat Rep: ->RP-150013
- 378: 1st Apr 15: Compl:0%->10% 1st Apr 15: Stat Rep: ->RP-150013
- 380: 1st Apr 15: Compl:0%->95% 1st Apr 15: Stat Rep: ->RP-150013
- 381: 1st Apr 15: Compl:0%->99% 1st Apr 15: Stat Rep: ->RP-150013
- 383: 1st Apr 15: Compl:0%->99% 1st Apr 15: CD:Sun 15/03/15->Mon 15/06/15 1st Apr 15: Stat Rep: ->RP-150013
- 384: 1st Apr 15: Compl:0%->99% 1st Apr 15: CD:Sun 15/03/15->Mon 15/06/15 1st Apr 15: Stat Rep: ->RP-150013
- 386: 1st Apr 15: Compl:0%->20% 1st Apr 15: CD:Tue 15/12/15->Tue 15/09/15 1st Apr 15: Stat Rep: ->RP-150013
- 387: 1st Apr 15: Compl:0%->20% 1st Apr 15: Stat Rep: ->RP-150013
- 389: 1st Apr 15: Compl:0%->20% 1st Apr 15: CD:Tue 15/12/15->Mon 15/06/15 1st Apr 15: Stat Rep: ->RP-150013
- 390: 1st Apr 15: Compl:0%->20% 1st Apr 15: Stat Rep: ->RP-150013
- 392: 1st Apr 15: Compl:0%->30% 1st Apr 15: CD:Tue 15/12/15->Mon 15/06/15 1st Apr 15: WID: RP-142206->RP-150233 1st Apr 15: Stat Rep: ->RP-150013
- 393: 1st Apr 15: WID: RP-142206->RP-150233 1st Apr 15: Stat Rep: ->RP-150013

| ID | WBS | Task | Duration | Start | Finish | Complete | Remaining | Total slack | Constraint | Resources | Work | Actual work | Acronym | PCG approved | WI rapporteur name | WI rapporteur e-mail | Release | TSG approved | Status Report |
| --- | --- | --- | --- | --- | --- | --- | --- | --- | --- | --- | --- | --- | --- | --- | --- | --- | --- | --- | --- |
| 394 | 100.39 | **LTE Advanced 3 Band Carrier Aggregation (3DL/1UL) of Band 3, Band 40 and Band 40** | 131d? | 2014-12-15 A | 2015-06-15 | 25% | 98.25d? | 523d |  | R4 | 3144h | 1222.67h | LTE_CA_B3_B40_B40 | PCG-34 | Huawei | Huawei | Rel-13 | RP-66 |  |
| 395 | 100.39.1 | Core part: LTE Advanced 3 Band Carrier Aggregation (3DL/1UL) of Band 3, Band 40 and Band 40 | 131d? | 2014-12-15 A | 2015-06-15 | 50% | 65.5d? | 523d | finish no earlier than 2015-06-15 | R4 | 1048h | 524h | LTE_CA_B3_B40_B40-Core | PCG-34 | Huawei | Huawei | Rel-13 | RP-66 | RP-150013 |
| 396 | 100.39.2 | Perf. part: LTE Advanced 3 Band Carrier Aggregation (3DL/1UL) of Band 3, Band 40 and Band 40 | 131d? | 2014-12-15 | 2015-06-15 |  |  | 523d | finish no earlier than 2015-06-15 | R4 | 1048h |  | LTE_CA_B3_B40_B40-Perf | PCG-34 | Huawei | Huawei | Rel-13 | RP-66 |  |
| 397 | 100.40 | **LTE Advanced 3 Band Carrier Aggregation (3DL/1UL) of Band 1, Band 7 and Band 28** | 131d? | 2014-12-15 A | 2015-06-15 | 25% | 98.25d? | 523d |  | R4 | 3144h | 1222.67h | LTE_CA_B1_B7_B28 | PCG-34 | Huawei | Huawei | Rel-13 | RP-66 |  |
| 398 | 100.40.1 | Core part: LTE Advanced 3 Band Carrier Aggregation (3DL/1UL) of Band 1, Band 7 and Band 28 | 131d? | 2014-12-15 A | 2015-06-15 | 50% | 65.5d? | 523d | finish no earlier than 2015-06-15 | R4 | 1048h | 524h | LTE_CA_B1_B7_B28-Core | PCG-34 | Huawei | Huawei | Rel-13 | RP-66 | RP-150013 |
| 399 | 100.40.2 | Perf. part: LTE Advanced 3 Band Carrier Aggregation (3DL/1UL) of Band 1, Band 7 and Band 28 | 131d? | 2014-12-15 | 2015-06-15 |  |  | 523d | finish no earlier than 2015-06-15 | R4 | 1048h |  | LTE_CA_B1_B7_B28-Perf | PCG-34 | Huawei | Huawei | Rel-13 | RP-66 | RP-150013 |
| 400 | 100.41 | **LTE Advanced 3 Band Carrier Aggregation (3DL/1UL) of Band 1, Band 3 and Band 7** | 131d? | 2014-12-15 A | 2015-06-15 | 15% | 111.35d? | 523d |  | R4 | 3144h | 733.53h | LTE_CA_B1_B3_B7 | PCG-34 | Huawei | Huawei | Rel-13 | RP-66 |  |
| 401 | 100.41.1 | Core part: LTE Advanced 3 Band Carrier Aggregation (3DL/1UL) of Band 1, Band 3 and Band 7 | 131d? | 2014-12-15 A | 2015-06-15 | 30% | 91.7d? | 523d | finish no earlier than 2015-06-15 | R4 | 1048h | 314.4h | LTE_CA_B1_B3_B7-Core | PCG-34 | Huawei | Huawei | Rel-13 | RP-66 | RP-150013 |
| 402 | 100.41.2 | Perf. part: LTE Advanced 3 Band Carrier Aggregation (3DL/1UL) of Band 1, Band 3 and Band 7 | 131d? | 2014-12-15 | 2015-06-15 |  |  | 523d | finish no earlier than 2015-06-15 | R4 | 1048h |  | LTE_CA_B1_B3_B7-Perf | PCG-34 | Huawei | Huawei | Rel-13 | RP-66 |  |
| 403 | 100.42 | **LTE Advanced 3 Band Carrier Aggregation (3DL/1UL) of Band 3, Band 3 and Band 5** | 197d? | 2014-12-15 A | 2015-09-15 | 5% | 187.16d? | 457d |  | R4 | 4728h | 236.35h | LTE_CA_B3_B3_B5 | PCG-34 | Intel | Intel | Rel-13 | RP-66 |  |
| 404 | 100.42.1 | Core part: LTE Advanced 3 Band Carrier Aggregation (3DL/1UL) of Band 3, Band 3 and Band 5 | 197d? | 2014-12-15 A | 2015-09-15 | 10% | 177.3d? | 457d | finish no earlier than 2015-09-15 | R4 | 1576h | 157.6h | LTE_CA_B3_B3_B5-Core | PCG-34 | Intel | Intel | Rel-13 | RP-66 | RP-150013 |
| 405 | 100.42.2 | Perf. part: LTE Advanced 3 Band Carrier Aggregation (3DL/1UL) of Band 3, Band 3 and Band 5 | 197d? | 2014-12-15 | 2015-09-15 |  |  | 457d | finish no earlier than 2015-09-15 | R4 | 1576h |  | LTE_CA_B3_B3_B5-Perf | PCG-34 | Intel | Intel | Rel-13 | RP-66 |  |
| 406 | 100.43 | **LTE Advanced 3 Band Carrier Aggregation (3DL/1UL) of Band 3, Band 7 and Band 28** | 131d? | 2014-12-15 A | 2015-06-15 | 99% | 1.29d? | 523d |  | R4 | 3144h | 2332.41h | LTE_CA_B3_B7_B28 | PCG-34 | Ericsson | Ericsson | Rel-13 | RP-66 |  |
| 407 | 100.43.1 | Core part: LTE Advanced 3 Band Carrier Aggregation (3DL/1UL) of Band 3, Band 7 and Band 28 | 131d? | 2014-12-15 A | 2015-06-15 | 99% | 1.31d? | 523d | finish no earlier than 2015-06-15 | R4 | 1048h | 1037.52h | LTE_CA_B3_B7_B28-Core | PCG-34 | Ericsson | Ericsson | Rel-13 | RP-66 | RP-150013 |
| 408 | 100.43.2 | Perf. part: LTE Advanced 3 Band Carrier Aggregation (3DL/1UL) of Band 3, Band 7 and Band 28 | 131d? | 2014-12-15 A | 2015-06-15 | 99% | 1.31d? | 523d | finish no earlier than 2015-06-15 | R4 | 1048h | 1037.52h | LTE_CA_B3_B7_B28-Perf | PCG-34 | Ericsson | Ericsson | Rel-13 | RP-66 | RP-150013 |
| 409 | 100.44 | **LTE Advanced 4 Band Carrier Aggregation (4DL/1UL) of Band 2, Band 2, Band 12 and Band 30** | 262d? | 2014-12-15 A | 2015-12-15 | 50% | 131d? | 392d |  | R4 | 6288h | 3144h | LTE_CA_B2_B2_B12_B30 | PCG-34 | AT&T | AT&T | Rel-13 | RP-66 |  |
| 410 | 100.44.1 | Core part: LTE Advanced 4 Band Carrier Aggregation (4DL/1UL) of Band 2, Band 2, Band 12 and Band 30 | 262d? | 2014-12-15 A | 2015-12-15 | 50% | 131d? | 392d | finish no earlier than 2015-12-15 | R4 | 2096h | 1048h | LTE_CA_B2_B2_B12_B30-Core | PCG-34 | AT&T | AT&T | Rel-13 | RP-66 | RP-150013 |
| 411 | 100.44.2 | Perf. part: LTE Advanced 4 Band Carrier Aggregation (4DL/1UL) of Band 2, Band 2, Band 12 and Band 30 | 262d? | 2014-12-15 A | 2015-12-15 | 50% | 131d? | 392d | finish no earlier than 2015-12-15 | R4 | 2096h | 1048h | LTE_CA_B2_B2_B12_B30-Perf | PCG-34 | AT&T | AT&T | Rel-13 | RP-66 | RP-150013 |
| 412 | 100.45 | **LTE Advanced 4 Band Carrier Aggregation (4DL/1UL) of Band 2, Band 2, Band 5 and Band 30** | 262d? | 2014-12-15 A | 2015-12-15 | 50% | 131d? | 392d |  | R4 | 5768h | 2884h | LTE_CA_B2_B2_B5_B30 | PCG-34 | AT&T | AT&T | Rel-13 | RP-66 |  |
| 413 | 100.45.1 | Core part: LTE Advanced 4 Band Carrier Aggregation (4DL/1UL) of Band 2, Band 2, Band 5 and Band 30 | 197d? | 2014-12-15 A | 2015-09-15 | 50% | 98.5d? | 457d | finish no earlier than 2015-09-15 | R4 | 1576h | 788h | LTE_CA_B2_B2_B5_B30-Core | PCG-34 | AT&T | AT&T | Rel-13 | RP-66 | RP-150013 |
| 414 | 100.45.2 | Perf. part: LTE Advanced 4 Band Carrier Aggregation (4DL/1UL) of Band 2, Band 2, Band 5 and Band 30 | 262d? | 2014-12-15 A | 2015-12-15 | 50% | 131d? | 392d | finish no earlier than 2015-12-15 | R4 | 2096h | 1048h | LTE_CA_B2_B2_B5_B30-Perf | PCG-34 | AT&T | AT&T | Rel-13 | RP-66 | RP-150013 |
| 415 | 100.46 | **LTE Advanced 4 Band Carrier Aggregation (4DL/1UL) of Band 2, Band 2 Band 29 and Band 30** | 262d? | 2014-12-15 A | 2015-12-15 | 50% | 131d? | 392d |  | R4 | 6288h | 3144h | LTE_CA_B2_B2_B29_B30 | PCG-34 | AT&T | AT&T | Rel-13 | RP-66 |  |
| 416 | 100.46.1 | Core part: LTE Advanced 4 Band Carrier Aggregation (4DL/1UL) of Band 2, Band 2 Band 29 and Band 30 | 262d? | 2014-12-15 A | 2015-12-15 | 50% | 131d? | 392d | finish no earlier than 2015-12-15 | R4 | 2096h | 1048h | LTE_CA_B2_B2_B29_B30-Core | PCG-34 | AT&T | AT&T | Rel-13 | RP-66 | RP-150013 |
| 417 | 100.46.2 | Perf. part: LTE Advanced 4 Band Carrier Aggregation (4DL/1UL) of Band 2, Band 2 Band 29 and Band 30 | 262d? | 2014-12-15 A | 2015-12-15 | 50% | 131d? | 392d | finish no earlier than 2015-12-15 | R4 | 2096h | 1048h | LTE_CA_B2_B2_B29_B30-Perf | PCG-34 | AT&T | AT&T | Rel-13 | RP-66 | RP-150013 |

Notes:
- 395: 1st Apr 15: Compl:0%->50% 1st Apr 15: CD:Tue 15/12/15->Mon 15/06/15 1st Apr 15: Stat Rep: ->RP-150013
- 398: 1st Apr 15: Compl:0%->50% 1st Apr 15: CD:Tue 15/12/15->Mon 15/06/15 1st Apr 15: WID: RP-142208->RP-150234 1st Apr 15: Stat Rep: ->RP-150013
- 399: 1st Apr 15: WID: RP-142208->RP-150234 1st Apr 15: Stat Rep: ->RP-150013
- 401: 1st Apr 15: Compl:0%->30% 1st Apr 15: CD:Tue 15/12/15->Mon 15/06/15 1st Apr 15: Stat Rep: ->RP-150013
- 404: 1st Apr 15: Compl:0%->10% 1st Apr 15: Stat Rep: ->RP-150013
- 407: 1st Apr 15: Compl:0%->99% 1st Apr 15: CD:Sun 15/03/15->Mon 15/06/15 1st Apr 15: Stat Rep: ->RP-150013
- 408: 1st Apr 15: Compl:0%->99% 1st Apr 15: CD:Sun 15/03/15->Mon 15/06/15 1st Apr 15: Stat Rep: ->RP-150013
- 410: 1st Apr 15: Compl:0%->50% 1st Apr 15: WID: RP-142198->RP-150449 1st Apr 15: Stat Rep: ->RP-150013
- 411: 1st Apr 15: Compl:0%->50% 1st Apr 15: WID: RP-142198->RP-150449 1st Apr 15: Stat Rep: ->RP-150013
- 413: 1st Apr 15: Compl:0%->50% 1st Apr 15: CD:Tue 15/12/15->Tue 15/09/15 1st Apr 15: WID: RP-142199->RP-150448 1st Apr 15: Stat Rep: ->RP-150013
- 414: 1st Apr 15: Compl:0%->50% 1st Apr 15: WID: RP-142199->RP-150448 1st Apr 15: Stat Rep: ->RP-150013
- 416: 1st Apr 15: Compl:0%->50% 1st Apr 15: WID: RP-142200->RP-150450 1st Apr 15: Stat Rep: ->RP-150013
- 417: 1st Apr 15: Compl:0%->50% 1st Apr 15: WID: RP-142200->RP-150450 1st Apr 15: Stat Rep: ->RP-150013

| ID | WBS | Task | Duration | Start | Finish | Complete | Remaining | Baseline start | Baseline finish | Baseline duration | Total slack | Constraint | Resources | Work | Actual work | Acronym | PCG approved | WI rapporteur name | WI rapporteur e-mail | Release | TSG approved | Status Report | Acronym_3GU_Export |
| --- | --- | --- | --- | --- | --- | --- | --- | --- | --- | --- | --- | --- | --- | --- | --- | --- | --- | --- | --- | --- | --- | --- | --- |
| 418 | 100.47 | **LTE Advanced 4 Band Carrier Aggregation (4DL/1UL) of Band 2, Band 4, Band 12 and Band 30** | 262d? | 2014-12-15 A | 2015-12-15 | 50% | 131d? |  |  |  | 392d |  | R4 | 6288h | 3144h | LTE_CA_B2_B4_B12_B30 | PCG-34 | AT&T | AT&T | Rel-13 | RP-66 |  |  |
| 419 | 100.47.1 | Core part: LTE Advanced 4 Band Carrier Aggregation (4DL/1UL) of Band 2, Band 4, Band 12 and Band 30 | 262d? | 2014-12-15 A | 2015-12-15 | 50% | 131d? |  |  |  | 392d | finish no earlier than 2015-12-15 | R4 | 2096h | 1048h | LTE_CA_B2_B4_B12_B30-Core | PCG-34 | AT&T | AT&T | Rel-13 | RP-66 | RP-150013 |  |
| 420 | 100.47.2 | Perf. part: LTE Advanced 4 Band Carrier Aggregation (4DL/1UL) of Band 2, Band 4, Band 12 and Band 30 | 262d? | 2014-12-15 A | 2015-12-15 | 50% | 131d? |  |  |  | 392d | finish no earlier than 2015-12-15 | R4 | 2096h | 1048h | LTE_CA_B2_B4_B12_B30-Perf | PCG-34 | AT&T | AT&T | Rel-13 | RP-66 | RP-150013 |  |
| 421 | 100.48 | **LTE Advanced 4 Band Carrier Aggregation (4DL/1UL) of Band 2, Band 4, Band 5 and Band 30** | 262d? | 2014-12-15 A | 2015-12-15 | 50% | 131d? |  |  |  | 392d |  | R4 | 6288h | 3144h | LTE_CA_B2_B4_B5_B30 | PCG-34 | AT&T | AT&T | Rel-13 | RP-66 |  |  |
| 422 | 100.48.1 | Core part: LTE Advanced 4 Band Carrier Aggregation (4DL/1UL) of Band 2, Band 4, Band 5 and Band 30 | 262d? | 2014-12-15 A | 2015-12-15 | 50% | 131d? |  |  |  | 392d | finish no earlier than 2015-12-15 | R4 | 2096h | 1048h | LTE_CA_B2_B4_B5_B30-Core | PCG-34 | AT&T | AT&T | Rel-13 | RP-66 | RP-150013 |  |
| 423 | 100.48.2 | Perf. part: LTE Advanced 4 Band Carrier Aggregation (4DL/1UL) of Band 2, Band 4, Band 5 and Band 30 | 262d? | 2014-12-15 A | 2015-12-15 | 50% | 131d? |  |  |  | 392d | finish no earlier than 2015-12-15 | R4 | 2096h | 1048h | LTE_CA_B2_B4_B5_B30-Perf | PCG-34 | AT&T | AT&T | Rel-13 | RP-66 | RP-150013 |  |
| 424 | 100.49 | **LTE Advanced 4 Band Carrier Aggregation (4DL/1UL) of Band 2, Band 4, Band 29 and Band 30** | 262d? | 2014-12-15 A | 2015-12-15 | 50% | 131d? |  |  |  | 392d |  | R4 | 6288h | 3144h | LTE_CA_B2_B4_B29_B30 | PCG-34 | AT&T | AT&T | Rel-13 | RP-66 |  |  |
| 425 | 100.49.1 | Core part: LTE Advanced 4 Band Carrier Aggregation (4DL/1UL) of Band 2, Band 4, Band 29 and Band 30 | 262d? | 2014-12-15 A | 2015-12-15 | 50% | 131d? |  |  |  | 392d | finish no earlier than 2015-12-15 | R4 | 2096h | 1048h | LTE_CA_B2_B4_B29_B30-Core | PCG-34 | AT&T | AT&T | Rel-13 | RP-66 | RP-150013 |  |
| 426 | 100.49.2 | Perf. part: LTE Advanced 4 Band Carrier Aggregation (4DL/1UL) of Band 2, Band 4, Band 29 and Band 30 | 262d? | 2014-12-15 A | 2015-12-15 | 50% | 131d? |  |  |  | 392d | finish no earlier than 2015-12-15 | R4 | 2096h | 1048h | LTE_CA_B2_B4_B29_B30-Perf | PCG-34 | AT&T | AT&T | Rel-13 | RP-66 | RP-150013 |  |
| 427 | 100.50 | **LTE Advanced 4 Band Carrier Aggregation (4DL/1UL) of Band 25, Band 41, Band 41 and Band 41** | 262d? | 2014-12-15 A | 2015-12-15 | 36% | 168.39d? |  |  |  | 392d |  | R4 | 5768h | 2060.9h | LTE_CA_B25_B41_B41_B41 | PCG-34 | Alcatel-Lucent | Alcatel-Lucent | Rel-13 | RP-66 |  |  |
| 428 | 100.50.1 | Core part: LTE Advanced 4 Band Carrier Aggregation (4DL/1UL) of Band 25, Band 41, Band 41 and Band 41 | 197d? | 2014-12-15 A | 2015-09-15 | 50% | 98.5d? |  |  |  | 457d | finish no earlier than 2015-09-15 | R4 | 1576h | 788h | LTE_CA_B25_B41_B41_B41-Core | PCG-34 | Alcatel-Lucent | Alcatel-Lucent | Rel-13 | RP-66 | RP-150013 |  |
| 429 | 100.50.2 | Perf. part: LTE Advanced 4 Band Carrier Aggregation (4DL/1UL) of Band 25, Band 41, Band 41 and Band 41 | 262d? | 2014-12-15 A | 2015-12-15 | 25% | 196.5d? |  |  |  | 392d | finish no earlier than 2015-12-15 | R4 | 2096h | 524h | LTE_CA_B25_B41_B41_B41-Perf | PCG-34 | Alcatel-Lucent | Alcatel-Lucent | Rel-13 | RP-66 | RP-150013 |  |
| 430 | 100.51 | **LTE Advanced dual uplink inter-band Carrier Aggregation Class A1 in REL-13** | 262d? | 2014-12-15 A | 2015-12-15 | 40% | 157.2d? |  |  |  | 392d |  | R4 | 6288h | 2515.2h | LTE_CA_2UL_R13-A1 | PCG-34 | Huawei | Huawei | Rel-13 | RP-66 |  |  |
| 431 | 100.51.1 | Core part: LTE Advanced dual uplink inter-band Carrier Aggregation Class A1 in REL-13 | 262d? | 2014-12-15 A | 2015-12-15 | 40% | 157.2d? |  |  |  | 392d | finish no earlier than 2015-12-15 | R4 | 2096h | 838.4h | LTE_CA_2UL_R13-A1-Core | PCG-34 | Huawei | Huawei | Rel-13 | RP-66 | RP-150013 |  |
| 432 | 100.51.2 | Perf. part: LTE Advanced dual uplink inter-band Carrier Aggregation Class A1 in REL-13 | 262d? | 2014-12-15 A | 2015-12-15 | 40% | 157.2d? |  |  |  | 392d | finish no earlier than 2015-12-15 | R4 | 2096h | 838.4h | LTE_CA_2UL_R13-A1-Perf | PCG-34 | Huawei | Huawei | Rel-13 | RP-66 | RP-150013 |  |
| 433 | 100.52 | **LTE Advanced dual uplink inter-band Carrier Aggregation Class A2 in REL-13** | 262d? | 2014-12-15 A | 2015-12-15 | 50% | 131d? |  |  |  | 392d |  | R4 | 6288h | 3144h | LTE_CA_2UL_R13-A2 | PCG-34 | Qualcomm | Qualcomm | Rel-13 | RP-66 |  |  |
| 434 | 100.52.1 | Core part: LTE Advanced dual uplink inter-band Carrier Aggregation Class A2 in REL-13 | 262d? | 2014-12-15 A | 2015-12-15 | 50% | 131d? |  |  |  | 392d | finish no earlier than 2015-12-15 | R4 | 2096h | 1048h | LTE_CA_2UL_R13-A2-Core | PCG-34 | Qualcomm | Qualcomm | Rel-13 | RP-66 | RP-150013 |  |
| 435 | 100.52.2 | Perf. part: LTE Advanced dual uplink inter-band Carrier Aggregation Class A2 in REL-13 | 262d? | 2014-12-15 A | 2015-12-15 | 50% | 131d? |  |  |  | 392d | finish no earlier than 2015-12-15 | R4 | 2096h | 1048h | LTE_CA_2UL_R13-A2-Perf | PCG-34 | Qualcomm | Qualcomm | Rel-13 | RP-66 | RP-150013 |  |
| 436 | 100.53 | **LTE Advanced dual uplink inter-band Carrier Aggregation Class A3 in REL-13** | 262d? | 2014-12-15 A | 2015-12-15 | 25% | 196.5d? |  |  |  | 392d |  | R4 | 6288h | 1572h | LTE_CA_2UL_R13-A3 | PCG-34 | Ericsson | Ericsson | Rel-13 | RP-66 |  |  |
| 437 | 100.53.1 | Core part: LTE Advanced dual uplink inter-band Carrier Aggregation Class A3 in REL-13 | 262d? | 2014-12-15 A | 2015-12-15 | 25% | 196.5d? |  |  |  | 392d | finish no earlier than 2015-12-15 | R4 | 2096h | 524h | LTE_CA_2UL_R13-A3-Core | PCG-34 | Ericsson | Ericsson | Rel-13 | RP-66 | RP-150013 |  |
| 438 | 100.53.2 | Perf. part: LTE Advanced dual uplink inter-band Carrier Aggregation Class A3 in REL-13 | 262d? | 2014-12-15 A | 2015-12-15 | 25% | 196.5d? |  |  |  | 392d | finish no earlier than 2015-12-15 | R4 | 2096h | 524h | LTE_CA_2UL_R13-A3-Perf | PCG-34 | Ericsson | Ericsson | Rel-13 | RP-66 | RP-150013 |  |
| 439 | 100.54 | **LTE Advanced intra-band non-contiguous Carrier Aggregation in Band 41 for 4 DL** | 262d? | 2014-12-15 A | 2015-12-15 | 10% | 235.81d? |  |  |  | 392d |  | R4 | 6288h | 1257.49h | LTE_CA_NC_B41_4DL | PCG-34 | Alcatel-Lucent | Alcatel-Lucent | Rel-13 | RP-66 |  |  |
| 440 | 100.54.1 | Core part: LTE Advanced intra-band non-contiguous Carrier Aggregation in Band 41 for 4 DL | 262d? | 2014-12-15 A | 2015-12-15 | 10% | 235.8d? |  |  |  | 392d | finish no earlier than 2015-12-15 | R4 | 2096h | 209.6h | LTE_CA_NC_B41_4DL-Core | PCG-34 | Alcatel-Lucent | Alcatel-Lucent | Rel-13 | RP-66 | RP-150013 |  |
| 441 | 100.54.2 | Perf. part: LTE Advanced intra-band non-contiguous Carrier Aggregation in Band 41 for 4 DL | 262d? | 2014-12-15 A | 2015-12-15 | 10% | 235.8d? | 2013-09-18 | 2015-12-24 | 593d? | 392d | finish no earlier than 2015-12-15 | R4 | 2096h | 209.6h | LTE_CA_NC_B41_4DL-Perf | PCG-31 | Alcatel-Lucent | Alcatel-Lucent | Rel-13 | RP-66 | RP-150013 | TEI13 |

Notes:
- 419: 1st Apr 15: Compl:0%->50% 1st Apr 15: WID: RP-142201->RP-150452 1st Apr 15: Stat Rep: ->RP-150013
- 420: 1st Apr 15: Compl:0%->50% 1st Apr 15: WID: RP-142201->RP-150452 1st Apr 15: Stat Rep: ->RP-150013
- 422: 1st Apr 15: Compl:0%->50% 1st Apr 15: WID: RP-142202->RP-150451 1st Apr 15: Stat Rep: ->RP-150013
- 423: 1st Apr 15: Compl:0%->50% 1st Apr 15: WID: RP-142202->RP-150451 1st Apr 15: Stat Rep: ->RP-150013
- 425: 1st Apr 15: Compl:0%->50% 1st Apr 15: WID: RP-142203->RP-150453 1st Apr 15: Stat Rep: ->RP-150013
- 426: 1st Apr 15: Compl:0%->50% 1st Apr 15: WID: RP-142203->RP-150453 1st Apr 15: Stat Rep: ->RP-150013
- 428: 1st Apr 15: Compl:0%->50% 1st Apr 15: Stat Rep: ->RP-150013
- 429: 1st Apr 15: Compl:0%->25% 1st Apr 15: Stat Rep: ->RP-150013
- 431: 1st Apr 15: Compl:0%->40% 1st Apr 15: WID: RP-141935->RP-150411 1st Apr 15: Stat Rep: ->RP-150013
- 432: 1st Apr 15: Compl:0%->40% 1st Apr 15: WID: RP-141935->RP-150411 1st Apr 15: Stat Rep: ->RP-150013
- 434: 1st Apr 15: Compl:0%->50% 1st Apr 15: WID: RP-141975->RP-150408 1st Apr 15: Stat Rep: ->RP-150013
- 435: 1st Apr 15: Compl:0%->50% 1st Apr 15: WID: RP-141975->RP-150408 1st Apr 15: Stat Rep: ->RP-150013
- 437: 1st Apr 15: Compl:0%->25% 1st Apr 15: WID: RP-142010->RP-150409 1st Apr 15: Stat Rep: ->RP-150013
- 438: 1st Apr 15: Compl:0%->25% 1st Apr 15: WID: RP-142010->RP-150409 1st Apr 15: Stat Rep: ->RP-150013
- 440: 1st Apr 15: Compl:0%->10% 1st Apr 15: CD:Tue 15/03/16->Tue 15/12/15 1st Apr 15: Stat Rep: ->RP-150013
- 441: 1st Apr 15: Compl:0%->10% 1st Apr 15: CD:Tue 18/12/18->Tue 15/12/15 1st Apr 15: Stat Rep: -->RP-150013

| ID | WBS | Task | Duration | Start | Finish | Total slack | Constraint | Resources | Work | Acronym | PCG approved | WI rapporteur name | Release | TSG approved |
| --- | --- | --- | --- | --- | --- | --- | --- | --- | --- | --- | --- | --- | --- | --- |
| 442 | 100.55 | **LTE Advanced 3 Band Carrier Aggregation (3DL/1UL) of Band 1, Band 3 and Band 42** | 132d? | 2015-03-16 | 2015-09-15 | 457d |  | R4 | 3168h | LTE_CA_B1_B3_B42 | PCG-34 | NTT DOCOMO, INC. | Rel-13 | RP-67 |
| 443 | 100.55.1 | Core part: LTE Advanced 3 Band Carrier Aggregation (3DL/1UL) of Band 1, Band 3 and Band 42 | 132d? | 2015-03-16 | 2015-09-15 | 457d | finish no earlier than 2015-09-15 | R4 | 1056h | LTE_CA_B1_B3_B42-Core | PCG-34 | NTT DOCOMO, INC. | Rel-13 | RP-67 |
| 444 | 100.55.2 | Perf. part: LTE Advanced 3 Band Carrier Aggregation (3DL/1UL) of Band 1, Band 3 and Band 42 | 132d? | 2015-03-16 | 2015-09-15 | 457d | finish no earlier than 2015-09-15 | R4 | 1056h | LTE_CA_B1_B3_B42-Perf | PCG-34 | NTT DOCOMO, INC. | Rel-13 | RP-67 |
| 445 | 100.56 | **LTE Advanced 3 Band Carrier Aggregation (3DL/1UL) of Band 1, Band 19 and Band 42** | 132d? | 2015-03-16 | 2015-09-15 | 457d |  | R4 | 3168h | LTE_CA_B1_B19_B42 | PCG-34 | NTT DOCOMO, INC. | Rel-13 | RP-67 |
| 446 | 100.56.1 | Core part: LTE Advanced 3 Band Carrier Aggregation (3DL/1UL) of Band 1, Band 19 and Band 42 | 132d? | 2015-03-16 | 2015-09-15 | 457d | finish no earlier than 2015-09-15 | R4 | 1056h | LTE_CA_B1_B19_B42-Core | PCG-34 | NTT DOCOMO, INC. | Rel-13 | RP-67 |
| 447 | 100.56.2 | Perf. part: LTE Advanced 3 Band Carrier Aggregation (3DL/1UL) of Band 1, Band 19 and Band 42 | 132d? | 2015-03-16 | 2015-09-15 | 457d | finish no earlier than 2015-09-15 | R4 | 1056h | LTE_CA_B1_B19_B42-Perf | PCG-34 | NTT DOCOMO, INC. | Rel-13 | RP-67 |
| 448 | 100.57 | **LTE Advanced 3 Band Carrier Aggregation (3DL/1UL) of Band 1, Band 21 and Band 42** | 132d? | 2015-03-16 | 2015-09-15 | 457d |  | R4 | 3168h | LTE_CA_B1_B21_B42 | PCG-34 | NTT DOCOMO, INC. | Rel-13 | RP-67 |
| 449 | 100.57.1 | Core part: LTE Advanced 3 Band Carrier Aggregation (3DL/1UL) of Band 1, Band 21 and Band 42 | 132d? | 2015-03-16 | 2015-09-15 | 457d | finish no earlier than 2015-09-15 | R4 | 1056h | LTE_CA_B1_B21_B42-Core | PCG-34 | NTT DOCOMO, INC. | Rel-13 | RP-67 |
| 450 | 100.57.2 | Perf. part: LTE Advanced 3 Band Carrier Aggregation (3DL/1UL) of Band 1, Band 21 and Band 42 | 132d? | 2015-03-16 | 2015-09-15 | 457d | finish no earlier than 2015-09-15 | R4 | 1056h | LTE_CA_B1_B21_B42-Perf | PCG-34 | NTT DOCOMO, INC. | Rel-13 | RP-67 |
| 451 | 100.58 | **LTE Advanced 3 Band Carrier Aggregation (3DL/1UL) of Band 3, Band 19 and Band 42** | 132d? | 2015-03-16 | 2015-09-15 | 457d |  | R4 | 3168h | LTE_CA_B3_B19_B42 | PCG-34 | NTT DOCOMO, INC. | Rel-13 | RP-67 |
| 452 | 100.58.1 | Core part: LTE Advanced 3 Band Carrier Aggregation (3DL/1UL) of Band 3, Band 19 and Band 42 | 132d? | 2015-03-16 | 2015-09-15 | 457d | finish no earlier than 2015-09-15 | R4 | 1056h | LTE_CA_B3_B19_B42-Core | PCG-34 | NTT DOCOMO, INC. | Rel-13 | RP-67 |
| 453 | 100.58.2 | Perf. part: LTE Advanced 3 Band Carrier Aggregation (3DL/1UL) of Band 3, Band 19 and Band 42 | 132d? | 2015-03-16 | 2015-09-15 | 457d | finish no earlier than 2015-09-15 | R4 | 1056h | LTE_CA_B3_B19_B42-Perf | PCG-34 | NTT DOCOMO, INC. | Rel-13 | RP-67 |
| 454 | 100.59 | **LTE Advanced 3 Band Carrier Aggregation (3DL/1UL) of Band 19, Band 21 and Band 42** | 132d? | 2015-03-16 | 2015-09-15 | 457d |  | R4 | 3168h | LTE_CA_B19_B21_B42 | PCG-34 | NTT DOCOMO, INC. | Rel-13 | RP-67 |
| 455 | 100.59.1 | Core part: LTE Advanced 3 Band Carrier Aggregation (3DL/1UL) of Band 19, Band 21 and Band 42 | 132d? | 2015-03-16 | 2015-09-15 | 457d | finish no earlier than 2015-09-15 | R4 | 1056h | LTE_CA_B19_B21_B42-Core | PCG-34 | NTT DOCOMO, INC. | Rel-13 | RP-67 |
| 456 | 100.59.2 | Perf. part: LTE Advanced 3 Band Carrier Aggregation (3DL/1UL) of Band 19, Band 21 and Band 42 | 132d? | 2015-03-16 | 2015-09-15 | 457d | finish no earlier than 2015-09-15 | R4 | 1056h | LTE_CA_B19_B21_B42-Perf | PCG-34 | NTT DOCOMO, INC. | Rel-13 | RP-67 |
| 457 | 100.60 | **Additional bandwidth combination set for LTE Advanced 3 Band Carrier Aggregation (3DL/1UL) of Band 4, Band 4 and Band 7** | 132d? | 2015-03-16 | 2015-09-15 | 457d |  | R4 | 3168h | LTE_CA_B4_B4_B7_BWset | PCG-34 | Rogers Communications | Rel-13 | RP-67 |
| 458 | 100.60.1 | Core part: Additional bandwidth combination set for LTE Advanced 3 Band Carrier Aggregation (3DL/1UL) of Band 4, Band 4 and Band 7 | 132d? | 2015-03-16 | 2015-09-15 | 457d | finish no earlier than 2015-09-15 | R4 | 1056h | LTE_CA_B4_B4_B7_BWset-Core | PCG-34 | Rogers Communications | Rel-13 | RP-67 |
| 459 | 100.60.2 | Perf. part: Additional bandwidth combination set for LTE Advanced 3 Band Carrier Aggregation (3DL/1UL) of Band 4, Band 4 and Band 7 | 132d? | 2015-03-16 | 2015-09-15 | 457d | finish no earlier than 2015-09-15 | R4 | 1056h | LTE_CA_B4_B4_B7_BWset-Perf | PCG-34 | Rogers Communications | Rel-13 | RP-67 |
| 460 | 100.61 | **Additional bandwidth combination set for LTE Advanced 3 Band Carrier Aggregation (3DL/1UL) of Band 4, Band 7 and Band 12** | 132d? | 2015-03-16 | 2015-09-15 | 457d |  | R4 | 3168h | LTE_CA_B4_B7_B12_BWset | PCG-34 | Rogers Communications | Rel-13 | RP-67 |
| 461 | 100.61.1 | Core part: Additional bandwidth combination set for LTE Advanced 3 Band Carrier Aggregation (3DL/1UL) of Band 4, Band 7 and Band 12 | 132d? | 2015-03-16 | 2015-09-15 | 457d | finish no earlier than 2015-09-15 | R4 | 1056h | LTE_CA_B4_B7_B12_BWset-Core | PCG-34 | Rogers Communications | Rel-13 | RP-67 |
| 462 | 100.61.2 | Perf. part: Additional bandwidth combination set for LTE Advanced 3 Band Carrier Aggregation (3DL/1UL) of Band 4, Band 7 and Band 12 | 132d? | 2015-03-16 | 2015-09-15 | 457d | finish no earlier than 2015-09-15 | R4 | 1056h | LTE_CA_B4_B7_B12_BWset-Perf | PCG-34 | Rogers Communications | Rel-13 | RP-67 |
| 463 | 100.62 | **LTE Advanced 3 Band Carrier Aggregation (3DL/1UL) of Band 2, Band 7 and Band 12** | 197d? | 2015-03-16 | 2015-12-15 | 392d |  | R4 | 4728h | LTE_CA_B2_B7_B12 | PCG-34 | Rogers Communications | Rel-13 | RP-67 |
| 464 | 100.62.1 | Core part: LTE Advanced 3 Band Carrier Aggregation (3DL/1UL) of Band 2, Band 7 and Band 12 | 197d? | 2015-03-16 | 2015-12-15 | 392d | finish no earlier than 2015-12-15 | R4 | 1576h | LTE_CA_B2_B7_B12-Core | PCG-34 | Rogers Communications | Rel-13 | RP-67 |
| 465 | 100.62.2 | Perf. part: LTE Advanced 3 Band Carrier Aggregation (3DL/1UL) of Band 2, Band 7 and Band 12 | 197d? | 2015-03-16 | 2015-12-15 | 392d | finish no earlier than 2015-12-15 | R4 | 1576h | LTE_CA_B2_B7_B12-Perf | PCG-34 | Rogers Communications | Rel-13 | RP-67 |

| ID | WBS | Task | Duration | Start | Finish | Total slack | Constraint | Resources | Work | Acronym | PCG approved | WI rapporteur name | Release | TSG approved |
| --- | --- | --- | --- | --- | --- | --- | --- | --- | --- | --- | --- | --- | --- | --- |
| 466 | 100.63 | **LTE Advanced 3 Band Carrier Aggregation (3DL/1UL) of Band 2, Band 4 and Band 7** | 197d? | 2015-03-16 | 2015-12-15 | 392d |  | R4 | 4728h | LTE_CA_B2_B4_B7 | PCG-34 | Rogers Communications | Rel-13 | RP-67 |
| 467 | 100.63.1 | Core part: LTE Advanced 3 Band Carrier Aggregation (3DL/1UL) of Band 2, Band 4 and Band 7 | 197d? | 2015-03-16 | 2015-12-15 | 392d | finish no earlier than 2015-12-15 | R4 | 1576h | LTE_CA_B2_B4_B7-Core | PCG-34 | Rogers Communications | Rel-13 | RP-67 |
| 468 | 100.63.2 | Perf. part: LTE Advanced 3 Band Carrier Aggregation (3DL/1UL) of Band 2, Band 4 and Band 7 | 197d? | 2015-03-16 | 2015-12-15 | 392d | finish no earlier than 2015-12-15 | R4 | 1576h | LTE_CA_B2_B4_B7-Perf | PCG-34 | Rogers Communications | Rel-13 | RP-67 |
| 469 | 100.64 | **LTE Advanced 3 Band Carrier Aggregation (3DL/1UL) of Band 7, Band 20 and Band 38** | 197d? | 2015-03-16 | 2015-12-15 | 392d |  | R4 | 4728h | LTE_CA_B7_B20_B38 | PCG-34 | Nokia Networks | Rel-13 | RP-67 |
| 470 | 100.64.1 | Core part: LTE Advanced 3 Band Carrier Aggregation (3DL/1UL) of Band 7, Band 20 and Band 38 | 197d? | 2015-03-16 | 2015-12-15 | 392d | finish no earlier than 2015-12-15 | R4 | 1576h | LTE_CA_B7_B20_B38-Core | PCG-34 | Nokia Networks | Rel-13 | RP-67 |
| 471 | 100.64.2 | Perf. part: LTE Advanced 3 Band Carrier Aggregation (3DL/1UL) of Band 7, Band 20 and Band 38 | 197d? | 2015-03-16 | 2015-12-15 | 392d | finish no earlier than 2015-12-15 | R4 | 1576h | LTE_CA_B7_B20_B38-Perf | PCG-34 | Nokia Networks | Rel-13 | RP-67 |
| 472 | 100.65 | **LTE Advanced 4 Band Carrier Aggregation (4DL/1UL) of Band 2, Band 4, Band 4 and Band 12** | 197d? | 2015-03-16 | 2015-12-15 | 392d |  | R4 | 4728h | LTE_CA_B2_B4_B4_B12 | PCG-34 | Nokia Corporation | Rel-13 | RP-67 |
| 473 | 100.65.1 | Core part: LTE Advanced 4 Band Carrier Aggregation (4DL/1UL) of Band 2, Band 4, Band 4 and Band 12 | 197d? | 2015-03-16 | 2015-12-15 | 392d | finish no earlier than 2015-12-15 | R4 | 1576h | LTE_CA_B2_B4_B4_B12-Core | PCG-34 | Nokia Corporation | Rel-13 | RP-67 |
| 474 | 100.65.2 | Perf. part: LTE Advanced 4 Band Carrier Aggregation (4DL/1UL) of Band 2, Band 4, Band 4 and Band 12 | 197d? | 2015-03-16 | 2015-12-15 | 392d | finish no earlier than 2015-12-15 | R4 | 1576h | LTE_CA_B2_B4_B4_B12-Perf | PCG-34 | Nokia Corporation | Rel-13 | RP-67 |
| 475 | 100.66 | **LTE Advanced 4 Band Carrier Aggregation (4DL/1UL) of Band 2, Band 2, Band 4 and Band 12** | 197d? | 2015-03-16 | 2015-12-15 | 392d |  | R4 | 4728h | LTE_CA_B2_B2_B4_B12 | PCG-34 | Nokia Corporation | Rel-13 | RP-67 |
| 476 | 100.66.1 | Core part: LTE Advanced 4 Band Carrier Aggregation (4DL/1UL) of Band 2, Band 2, Band 4 and Band 12 | 197d? | 2015-03-16 | 2015-12-15 | 392d | finish no earlier than 2015-12-15 | R4 | 1576h | LTE_CA_B2_B2_B4_B12-Core | PCG-34 | Nokia Corporation | Rel-13 | RP-67 |
| 477 | 100.66.2 | Perf. part: LTE Advanced 4 Band Carrier Aggregation (4DL/1UL) of Band 2, Band 2, Band 4 and Band 12 | 197d? | 2015-03-16 | 2015-12-15 | 392d | finish no earlier than 2015-12-15 | R4 | 1576h | LTE_CA_B2_B2_B4_B12-Perf | PCG-34 | Nokia Corporation | Rel-13 | RP-67 |
| 478 | 100.67 | **LTE Advanced 4 Band Carrier Aggregation (4DL/1UL) of Band 2, Band 2, Band 4 and Band 4** | 197d? | 2015-03-16 | 2015-12-15 | 392d |  | R4 | 4728h | LTE_CA_B2_B2_B4_B4 | PCG-34 | Nokia Corporation | Rel-13 | RP-67 |
| 479 | 100.67.1 | Core part: LTE Advanced 4 Band Carrier Aggregation (4DL/1UL) of Band 2, Band 2, Band 4 and Band 4 | 197d? | 2015-03-16 | 2015-12-15 | 392d | finish no earlier than 2015-12-15 | R4 | 1576h | LTE_CA_B2_B2_B4_B4-Core | PCG-34 | Nokia Corporation | Rel-13 | RP-67 |
| 480 | 100.67.2 | Perf. part: LTE Advanced 4 Band Carrier Aggregation (4DL/1UL) of Band 2, Band 2, Band 4 and Band 4 | 197d? | 2015-03-16 | 2015-12-15 | 392d | finish no earlier than 2015-12-15 | R4 | 1576h | LTE_CA_B2_B2_B4_B4-Perf | PCG-34 | Nokia Corporation | Rel-13 | RP-67 |
| 481 | 100.68 | **LTE Advanced 4 Band Carrier Aggregation (4DL/1UL) of Band 1, Band 3, Band 5 and Band 40** | 132d? | 2015-03-16 | 2015-09-15 | 457d |  | R4 | 3168h | LTE_CA_B1_B3_B5_B40 | PCG-34 | SK Telecom | Rel-13 | RP-67 |
| 482 | 100.68.1 | Core part: LTE Advanced 4 Band Carrier Aggregation (4DL/1UL) of Band 1, Band 3, Band 5 and Band 40 | 132d? | 2015-03-16 | 2015-09-15 | 457d | finish no earlier than 2015-09-15 | R4 | 1056h | LTE_CA_B1_B3_B5_B40-Core | PCG-34 | SK Telecom | Rel-13 | RP-67 |
| 483 | 100.68.2 | Perf. part: LTE Advanced 4 Band Carrier Aggregation (4DL/1UL) of Band 1, Band 3, Band 5 and Band 40 | 132d? | 2015-03-16 | 2015-09-15 | 457d | finish no earlier than 2015-09-15 | R4 | 1056h | LTE_CA_B1_B3_B5_B40-Perf | PCG-34 | SK Telecom | Rel-13 | RP-67 |
| 484 | 100.69 | **LTE Advanced 4 Band Carrier Aggregation (4DL/1UL) of Band 1, Band 3, Band 7 and Band 8** | 197d? | 2015-03-16 | 2015-12-15 | 392d |  | R4 | 4728h | LTE_CA_B1_B3_B7_B8 | PCG-34 | Nokia Networks | Rel-13 | RP-67 |
| 485 | 100.69.1 | Core part: LTE Advanced 4 Band Carrier Aggregation (4DL/1UL) of Band 1, Band 3, Band 7 and Band 8 | 197d? | 2015-03-16 | 2015-12-15 | 392d | finish no earlier than 2015-12-15 | R4 | 1576h | LTE_CA_B1_B3_B7_B8-Core | PCG-34 | Nokia Networks | Rel-13 | RP-67 |
| 486 | 100.69.2 | Perf. part: LTE Advanced 4 Band Carrier Aggregation (4DL/1UL) of Band 1, Band 3, Band 7 and Band 8 | 197d? | 2015-03-16 | 2015-12-15 | 392d | finish no earlier than 2015-12-15 | R4 | 1576h | LTE_CA_B1_B3_B7_B8-Perf | PCG-34 | Nokia Networks | Rel-13 | RP-67 |
| 487 | 100.70 | **LTE Advanced 4 Band Carrier Aggregation (4DL/1UL) of Band 2, Band 4, Band 5 and Band 29** | 197d? | 2015-03-16 | 2015-12-15 | 392d |  | R4 | 4728h | LTE_CA_B2_B4_B5_B29 | PCG-34 | Huawei | Rel-13 | RP-67 |
| 488 | 100.70.1 | Core part: LTE Advanced 4 Band Carrier Aggregation (4DL/1UL) of Band 2, Band 4, Band 5 and Band 29 | 197d? | 2015-03-16 | 2015-12-15 | 392d | finish no earlier than 2015-12-15 | R4 | 1576h | LTE_CA_B2_B4_B5_B29-Core | PCG-34 | Huawei | Rel-13 | RP-67 |
| 489 | 100.70.2 | Perf. part: LTE Advanced 4 Band Carrier Aggregation (4DL/1UL) of Band 2, Band 4, Band 5 and Band 29 | 197d? | 2015-03-16 | 2015-12-15 | 392d | finish no earlier than 2015-12-15 | R4 | 1576h | LTE_CA_B2_B4_B5_B29-Perf | PCG-34 | Huawei | Rel-13 | RP-67 |

| ID | WBS | Task | Duration | Start | Finish | Complete | Remaining | Baseline start | Baseline finish | Baseline duration | Total slack | Constraint | Resources | Work | Actual work | Acronym | PCG approved | WI rapporteur name | Release | TSG approved | Status Report | Impacted TSs and TRs | WI rapporteur e-mail | Acronym_3GU_Export | Special Focus Doc | MCC resp |
| --- | --- | --- | --- | --- | --- | --- | --- | --- | --- | --- | --- | --- | --- | --- | --- | --- | --- | --- | --- | --- | --- | --- | --- | --- | --- | --- |
| 490 | 100.71 | **LTE Advanced dual uplink inter-band Carrier Aggregation FDD-TDD** | 197d? | 2015-03-16 | 2015-12-15 |  |  |  |  |  | 392d |  | R4 | 4208h |  | LTE_CA_2UL_FDD_TDD | PCG-34 | KDDI | Rel-13 | RP-67 |  |  |  |  |  |  |
| 491 | 100.71.1 | Core part: LTE Advanced dual uplink inter-band Carrier Aggregation FDD-TDD | 197d? | 2015-03-16 | 2015-12-15 |  |  |  |  |  | 392d | finish no earlier than 2015-12-15 | R4 | 1576h |  | LTE_CA_2UL_FDD_TDD-Core | PCG-34 | KDDI | Rel-13 | RP-67 |  |  |  |  |  |  |
| 492 | 100.71.2 | Perf. part: LTE Advanced dual uplink inter-band Carrier Aggregation FDD-TDD | 132d? | 2015-03-16 | 2015-09-15 |  |  |  |  |  | 457d | finish no earlier than 2015-09-15 | R4 | 1056h |  | LTE_CA_2UL_FDD_TDD-Perf | PCG-34 | KDDI | Rel-13 | RP-67 |  |  |  |  |  |  |
| 493 | 100.72 | **LTE Advanced dual uplink inter-band Carrier Aggregation Class A4** | 197d? | 2015-03-16 | 2015-12-15 |  |  |  |  |  | 392d |  | R4 | 4728h |  | LTE_CA_2UL_R13-A4 | PCG-34 | Nokia Corporation | Rel-13 | RP-67 |  |  |  |  |  |  |
| 494 | 100.72.1 | Core part: LTE Advanced dual uplink inter-band Carrier Aggregation Class A4 | 197d? | 2015-03-16 | 2015-12-15 |  |  |  |  |  | 392d | finish no earlier than 2015-12-15 | R4 | 1576h |  | LTE_CA_2UL_R13-A4-Core | PCG-34 | Nokia Corporation | Rel-13 | RP-67 |  |  |  |  |  |  |
| 495 | 100.72.2 | Perf. part: LTE Advanced dual uplink inter-band Carrier Aggregation Class A4 | 197d? | 2015-03-16 | 2015-12-15 |  |  |  |  |  | 392d | finish no earlier than 2015-12-15 | R4 | 1576h |  | LTE_CA_2UL_R13-A4-Perf | PCG-34 | Nokia Corporation | Rel-13 | RP-67 |  |  |  |  |  |  |
| 496 | 100.73 | **LTE Advanced 3DL/2UL inter-band Carrier Aggregation** | 262d? | 2015-03-16 | 2016-03-15 |  |  |  |  |  | 327d |  | R4 | 6288h |  | LTE_CA_3DL_2UL | PCG-34 | Nokia Corporation | Rel-13 | RP-67 |  |  |  |  |  |  |
| 497 | 100.73.1 | Core part: LTE Advanced 3DL/2UL inter-band Carrier Aggregation | 262d? | 2015-03-16 | 2016-03-15 |  |  |  |  |  | 327d | finish no earlier than 2016-03-15 | R4 | 2096h |  | LTE_CA_3DL_2UL-Core | PCG-34 | Nokia Corporation | Rel-13 | RP-67 |  |  |  |  |  |  |
| 498 | 100.73.2 | Perf. part: LTE Advanced 3DL/2UL inter-band Carrier Aggregation | 262d? | 2015-03-16 | 2016-03-15 |  |  |  |  |  | 327d | finish no earlier than 2016-03-15 | R4 | 2096h |  | LTE_CA_3DL_2UL-Perf | PCG-34 | Nokia Corporation | Rel-13 | RP-67 |  |  |  |  |  |  |
| 499 | 100.74 | **LTE Advanced intra-band non-contiguous Carrier Aggregation in Band 42 for 3DL** | 132d? | 2015-03-16 | 2015-09-15 |  |  |  |  |  | 457d |  | R4 | 3168h |  | LTE_CA_NC_B42_3DL | PCG-34 | Huawei | Rel-13 | RP-67 |  |  |  |  |  |  |
| 500 | 100.74.1 | Core part: LTE Advanced intra-band non-contiguous Carrier Aggregation in Band 42 for 3DL | 132d? | 2015-03-16 | 2015-09-15 |  |  |  |  |  | 457d | finish no earlier than 2015-09-15 | R4 | 1056h |  | LTE_CA_NC_B42_3DL-Core | PCG-34 | Huawei | Rel-13 | RP-67 |  |  |  |  |  |  |
| 501 | 100.74.2 | Perf. part: LTE Advanced intra-band non-contiguous Carrier Aggregation in Band 42 for 3DL | 132d? | 2015-03-16 | 2015-09-15 |  |  |  |  |  | 457d | finish no earlier than 2015-09-15 | R4 | 1056h |  | LTE_CA_NC_B42_3DL-Perf | PCG-34 | Huawei | Rel-13 | RP-67 |  |  |  |  |  |  |
| 502 | 100.75 | **LTE Advanced intra-band contiguous Carrier Aggregation in Band 8** | 132d? | 2015-03-16 | 2015-09-15 |  |  |  |  |  | 457d |  | R4 | 3168h |  | LTE_CA_C_B8 | PCG-34 | CMCC | Rel-13 | RP-67 |  |  |  |  |  |  |
| 503 | 100.75.1 | Core part: LTE Advanced intra-band contiguous Carrier Aggregation in Band 8 | 132d? | 2015-03-16 | 2015-09-15 |  |  |  |  |  | 457d | finish no earlier than 2015-09-15 | R4 | 1056h |  | LTE_CA_C_B8-Core | PCG-34 | CMCC | Rel-13 | RP-67 |  |  |  |  |  |  |
| 504 | 100.75.2 | Perf. part: LTE Advanced intra-band contiguous Carrier Aggregation in Band 8 | 132d? | 2015-03-16 | 2015-09-15 |  |  |  |  |  | 457d | finish no earlier than 2015-09-15 | R4 | 1056h |  | LTE_CA_C_B8-Perf | PCG-34 | CMCC | Rel-13 | RP-67 |  |  |  |  |  |  |
| 505 | 100.76 | **LTE Advanced intra-band contiguous Carrier Aggregation in Band 42 for 4DL** | 197d? | 2015-03-16 | 2015-12-15 |  |  |  |  |  | 392d |  | R4 | 4728h |  | LTE_CA_C_B42_4DL | PCG-34 | CATT | Rel-13 | RP-67 |  |  |  |  |  |  |
| 506 | 100.76.1 | Core part: LTE Advanced intra-band contiguous Carrier Aggregation in Band 42 for 4DL | 197d? | 2015-03-16 | 2015-12-15 |  |  |  |  |  | 392d | finish no earlier than 2015-12-15 | R4 | 1576h |  | LTE_CA_C_B42_4DL-Core | PCG-34 | CATT | Rel-13 | RP-67 |  |  |  |  |  |  |
| 507 | 100.76.2 | Perf. part: LTE Advanced intra-band contiguous Carrier Aggregation in Band 42 for 4DL | 197d? | 2015-03-16 | 2015-12-15 |  |  |  |  |  | 392d | finish no earlier than 2015-12-15 | R4 | 1576h |  | LTE_CA_C_B42_4DL-Perf | PCG-34 | CATT | Rel-13 | RP-67 |  |  |  |  |  |  |
| 508 | 101 | (Small) Technical Enhancements and Improvements for Rel-13 | 593d? | 2013-09-18 | 2015-12-21 |  |  |  |  |  | 388d | finish no earlier than 2015-12-21 | SP; CP; RP; R4 | 18976h |  | TEI13 | PCG-31 |  | Rel-13 | SP-61 | PCG-31 |  |  |  |  |  |
| 509 | 102 | Release 13 Studies | 602d? | 2013-09-12 | 2015-12-25 |  |  | 2014-07-31 | 2015-12-25 | 366.5d? | 384d | start no earlier than 2013-09-12 | SP; R2 | 9632h |  |  |  |  | Rel-13 |  |  |  |  |  |  |  |
| 510 | 103 | Study on Power saving for Machine-Type Communications (MTC) devices | 250.05d? | 2014-05-27 A | 2015-05-29 | 40% | 150.03d? | 2014-06-18 | 2015-02-20 | 160.5d? | 534d | finish no earlier than 2015-05-29 | G2; R4 | 4000.8h | 1600.32h | FS_uPoD | PCG-32 | China Mobile | Rel-13 | GP-60 |  | 43.869 | Jing Han (hanjing@chinamobile.com) | FS_uPoD |  |  |
| 511 | 104 | Study on Extended DRX cycle for Power Consumption Optimization | 268d? | 2014-12-03 A | 2015-12-11 | 30% | 187.6d? |  |  |  | 394d | finish no earlier than 2015-12-11 | S2 | 2144h | 643.2h | FS_eDRX | PCG-34 | Miguel Griot, Qualcomm | Rel-13 | SP-66 |  | 23.770 | mgriot@qti.qualcomm.com |  |  |  |
| 512 | 105 | Study on Cellular system support for ultra Low Complexity and low throughput Internet of Things | 329d? | 2014-05-30 A | 2015-08-28 | 40% | 197.4d? | 2015-01-14 | 2015-08-28 | 163d? | 469d | finish no earlier than 2015-08-28 | G1; R2 | 5264h | 2105.6h | FS_IoT_LC | PCG-33 | Vodafone | Rel-13 | GP-62 |  | 45.8xy | chris.pudney@vodafone.com | FS_IoT_LC | MTC, M2M |  |
| 513 | 106 | Study on architecture enhancements of cellular systems for ultra low complexity and low throughput Internet of Things | 196d? | 2015-03-13 | 2015-12-11 |  |  |  |  |  | 394d | finish no earlier than 2015-12-11 | S2 | 1568h |  | FS_AE_CIoT | PCG-34 | puneet.jain@intel.com | Rel-13 | SP-67 |  | New TR 23.8xx | puneet.jain@intel.com |  |  |  |
| 514 | 107 | Study on Battery Efficient Security for very low Throughput Machine Type Communication Devices | 196d? | 2015-03-13 | 2015-12-11 |  |  |  |  |  | 394d | finish no earlier than 2015-12-11 | S3 | 1568h |  | FS_BEST_MTC_Sec | PCG-34 | Barry, Aguibou, VODAFONE Group Plc | Rel-13 | SP-67 |  | 32.863 | Barry, Aguibou, VODAFONE Group Plc |  |  |  |
| 515 | 108 | Study on Small data transmission enhancements for UMTS | 197d? | 2014-09-16 A | 2015-06-15 | 55% | 88.65d? |  |  |  | 523d | finish no earlier than 2015-06-15 | R1; R3 | 3152h | 1733.6h | FS_UTRA_SDATA | PCG-33 | Ericsson | Rel-13 | RP-65 | RP-150196 | 25.705 | gerardo.agni.medina.acosta@ericsson.com | FS_UTRA_SDATA |  |  |
| 516 | 109 | Study on Application specific Congestion control for Data Communication | 531.29d? | 2012-09-17 A | 2014-09-17 A | 100% |  | 2012-09-13 | 2014-09-17 | 532d? |  | finish no earlier than 2014-09-17 | S1 | 4250.28h | 4250.28h | FS_ACDC | PCG-29 | NTT DOCOMO | Rel-13 | SP-57 | S1-143305 | 22.806 | Atsushi Minokuchi (minokuchi@nttdocomo.co.jp) | FS_ACDC |  | Alain |
| 517 | 110 | Study on Isolated E-UTRAN Operation for Public Safety | 261d? | 2013-06-25 A | 2014-06-18 A | 100% |  | 2013-06-21 | 2014-06-18 | 262d? |  | finish no earlier than 2014-06-18 | S1 | 2088h | 2088h | FS_IOPS | PCG-31 | General Dynamics | Rel-13 | SP-60 |  | 22.897 | paul.piggin@gd-broadband.com | FS_IOPS | Public Safety (A-A) | Alain |
| 518 | 111 | Study on Security Aspects of Isolated E-UTRAN Operation for Public Safety | 137d? | 2015-03-12 | 2015-09-18 |  |  |  |  |  | 454d | finish no earlier than 2015-09-18 | S3 | 1096h |  | FS_IOPS_Sec | PCG-34 | Paul Piggin, General Dynamics UK | Rel-13 | SP-67 |  | New TR 33.897 | paul.piggin@gd-broadband.com |  |  |  |
| 519 | 112 | Study on enhancements for Infrastructure based data Communication Between Devices | 266d? | 2013-09-14 A | 2014-09-17 A | 100% |  | 2013-09-12 | 2014-09-17 | 266d? |  | finish no earlier than 2014-09-17 | S1 | 2128h | 2128h | FS_eICBD | PCG-31 | KPN | Rel-13 | SP-61 | S1-143309 | 22.807 | toon.norp@tno.nl | FS_eICBD | MTC, M2M | Alain |
| 520 | 113 | (SA66: on hold) Study on Co-ordinated packet data network gateway (P-GW) change for SIPTO | 201d? | 2013-09-13 A | 2014-06-18 A | 100% |  | 2013-09-12 | 2014-06-18 | 202d? |  | finish no earlier than 2014-06-18 | S1 | 1608h | 1608h | FS_CSIPTO | PCG-31 | Intel | Rel-13 | SP-61 |  | 22.828 | Eric.siow@intel.com | FS_CSIPTO |  | Alain |
| 521 | 114 | Study on Flexible Mobile Service Steering | 201d? | 2013-12-13 A | 2014-09-17 A | 100% |  | 2013-12-11 | 2014-09-17 | 202d? |  | finish no earlier than 2014-09-17 | S1 | 1608h | 1608h | FS_FMSS | PCG-32 | China Mobile | Rel-13 | SP-62 | S1-143310 | 22.808 | Lu Lu (lulu@chinamobile.com) | FS_FMSS |  | Alain |
| 522 | 115 | Study on Enhanced Calling Information Presentation | 201d? | 2013-12-13 A | 2014-09-17 A | 100% |  | 2013-12-11 | 2014-09-17 | 201d? |  | finish no earlier than 2014-09-17 | S1 | 1608h | 1608h | FS_ECIP | PCG-32 | China Mobile | Rel-13 | SP-62 | S1-143311 | 22.810 | LI Xiaofan (lixiaofan@chinamobile.com | FS_ECIP |  | Alain |
| 523 | 116 | Study on RAN Sharing Enhancements on GERAN and UTRAN | 140d? | 2014-03-07 A | 2014-09-17 A | 100% |  | 2014-03-07 | 2014-09-17 | 139d? |  | finish no earlier than 2014-09-17 | S1 | 1120h | 1120h | FS_GUSH | PCG-32 | Telefónica | Rel-13 | SP-63 |  | 22.852 updates | chris.friel@telefonica.com | FS_GUSH |  | Alain |

Notes:
- 508: -
- 509: -
- 510: GP#65 completion 02/15=>05/15. GP#60 approved WID. Linked to Rel-12 Feature MTCe, Stage 2 BB3: UE Power Consumptions Optimizations (UEPCOP). Dec.14: 30->40%
- 511: No Ran aspects yet. GERAN in FS_uPoD.29/1: TS number added Mar15: 0->30%
- 512: GP#62 approved WID. Dec.14: 15->40%
- 514: TR number added
- 515: 3/3/15: WID: RP-141861; Stat Rep: -->RP-141859. Impacted TR number added. 1st Apr 15: Compl:30%->55% 1st Apr 15: Stat Rep: RP-141859->RP-150196
- 516: SP#65 completed. SP#64 TR 22.806v200 for Approval. ACDC is applicable to UTRAN and E-UTRAN. Possible overlap with RAN2 TR 36.848 Study on smart congestion mitigation in E-UTRAN (prioritising MMTEL voice over other traffic during congestion)
- 517: SP#64 completed. TR 22.897v200 for Approval. Linked to Rel-12 TR 22.803 (FS_ProSe) and Features: ProSe, GCSE_LTE
- 518: TR added
- 519: SP#65 completed. TR 22.807v200 for Approval
- 520: SP#64 completed. TR 22.828v200 for Approval. Linked to Features: Rel-10 LIPA_SIPTO & Rel-12 LIMONET
- 521: SP#65 completed. TR 22.808v200 for Approval. Study supporting traffic classification and service chain selection capabilities per operators policy in order to realize efficient and flexible mobile service steering in the Gi-LAN network
- 522: SP#65 completed. TR 22.810v200 for Approval. Linked to Multimedia Telephony Service for IMS (UID_7038), Customized Alerting Tone (CAT) UID_370028, Customized Ringing Signal (CRS) UID_380067
- 523: SP#65 completed. Update on GERAN and UTRAN of Rel-12 TR 22.852 Study on RAN Sharing Enhancements (FS_RSE)

| ID | WBS | Task | Duration | Start | Finish | Complete | Remaining | Baseline start | Baseline finish | Baseline duration | Total slack | Constraint | Resources | Work | Actual work | Acronym | PCG approved | Impacted TSs and TRs | WI rapporteur name | Release | TSG approved | MCC resp | Acronym_3GU_Export | PCG stopped | TSG stopped | Special Focus Doc | Status Report |
| --- | --- | --- | --- | --- | --- | --- | --- | --- | --- | --- | --- | --- | --- | --- | --- | --- | --- | --- | --- | --- | --- | --- | --- | --- | --- | --- | --- |
| 524 | 117 | **Study on Usage Monitoring Enhancements for Service, Application and Subscriber Group** | 934d? | 2011-06-08 A | 2014-12-12 A | 100% |  | 2011-06-08 | 2014-12-10 | 929d? |  |  | S2 | 13978.1h | 13978.1h | FS_UMONC_sas | PCG-27 | 23.858 | China Telecom | Rel-13 | SP-52 | Maurice | FS_UMONC_sas |  |  |  |  |
| 525 | 117.1 | Deleted - SA1 part of Study on Usage Monitoring Control PCC Enhancement | 275d? | 2011-06-08 A | 2012-06-20 A | 100% |  | 2011-06-08 | 2012-06-20 | 275d? |  | finish no earlier than 2012-06-20 | S1 | 2200h | 2200h |  | PCG-27 | 23.858 | ZTE |  | SP-52 | Maurice | FS_UMONC | PCG-31 | SP-58 |  |  |
| 526 | 117.2 | SA2 part of Study on Usage Monitoring Control PCC Enhancement | 397.26d? | 2013-06-14 A | 2014-12-12 A | 100% |  | 2013-06-02 | 2014-12-10 | 403d? |  | finish no earlier than 2014-12-12 | S2 | 3178.08h | 3178.08h | FS_UMONC_sas | PCG-27 | 23.858 | China Telecom | Rel-13 | SP-52 | Maurice |  |  |  |  |  |
| 527 | 117.3 | Deleted - SA5 part of Study on Usage Monitoring Control enhancement | 141d? | 2012-03-02 A | 2012-09-12 A | 100% |  | 2012-03-02 | 2012-09-12 | 141d? |  | finish no earlier than 2012-09-12 | S5 | 1128h | 1128h |  | PCG-27 | 32.858 | Huawei |  | SP-52 | Mirko |  | PCG-29 | SP-57 |  |  |
| 528 | 118 | Study on Optimizations to support High Latency communications | 196d? | 2014-09-19 A | 2015-06-17 | 70% | 58.8d? |  |  |  | 521d | finish no earlier than 2015-06-17 | S2 | 1568h | 1097.6h | FS_HLcom | PCG-33 | New TR 23.7xy | Ericsson | Rel-13 | SP-65 |  | FS_HLcom |  |  |  |  |
| 529 | 119 | Study on Security aspects of Integration of Single Sign-On (SSO) frameworks with 3GPP networks | 1180d? | 2010-12-28 A | 2015-06-12 | 65% | 413d? | 2010-12-16 | 2014-09-17 | 988d? | 524d | finish no earlier than 2015-06-12 | S3 | 9440h | 6136h | FS_SSO_Int_Sec | PCG-26 | 33.895 | Ericsson | Rel-13 | SP-50 | Mirko | FS_SSO_Int_Sec |  |  |  |  |
| 530 | 120 | Study on Security for Proximity-based Services | 596d? | 2013-03-18 A | 2015-06-17 | 70% | 178.8d? | 2013-03-07 | 2014-09-17 | 401d? | 521d | finish no earlier than 2015-06-17 | S3 | 4768h | 3337.6h | FS_ProSe_Sec | PCG-30 | 33.833 | Qualcomm | Rel-13 | SP-59 | Mirko | FS_ProSe_Sec |  |  | Public Safety (A-A) |  |
| 531 | 121 | Study on Subscriber Privacy Impact in 3GPP | 591d? | 2013-09-17 A | 2015-12-16 | 85% | 88.65d? | 2013-09-12 | 2014-09-17 | 266d? | 391d | finish no earlier than 2015-12-16 | S3 | 4728h | 4018.8h | FS_SPI | PCG-31 | 33.849 | China Unicom | Rel-13 | SP-61 | Mirko | FS_SPI |  |  |  |  |
| 532 | 122 | Study on Lawful Interception Service Evolution | 386d? | 2014-06-23 A | 2015-12-09 | 5% | 366.7d? | 2014-06-18 | 2015-12-09 | 386d? | 396d | finish no earlier than 2015-12-09 | S3 | 3088h | 154.4h | FS_LISE | PCG-33 | 33.826 | Alcatel-Lucent | Rel-13 | SP-64 |  | FS_LISE |  |  |  |  |
| 533 | 123 | Study on IMS Enhanced Spoofed Call Prevention and Detection | 261d? | 2014-09-19 A | 2015-09-16 | 5% | 247.95d? |  |  |  | 456d | finish no earlier than 2015-09-16 | S3 | 2088h | 104.4h | FS_ESCAPADES | PCG-33 | 33.832 | Sprint | Rel-13 | SP-64 |  | FS_ESCAPADES |  |  |  |  |
| 534 | 124 | Study on Enhanced Acoustic Test Specifications | 598d? | 2013-03-18 A | 2015-06-19 | 40% | 358.8d? | 2013-03-06 | 2014-09-17 | 401d? | 519d | finish no earlier than 2015-06-19 | S4 | 4784h | 1913.6h | FS_SEATS | PCG-30 | 26.931 | Audience, Intel | Rel-13 | SP-59 | Paolo | FS_SEATS |  |  |  |  |
| 535 | 125 | Study on Compliance of 3GPP SA5 specifications to the NGMN NGCOR | 854d? | 2012-06-26 A | 2015-09-16 | 50% | 427d? | 2012-06-20 | 2015-09-16 | 854d? | 456d | finish no earlier than 2015-09-16 | S5 | 6832h | 3416h | FS_OAM_NGMN_NGCOR | PCG-29 | TR 32.837, TR 28.821 | Huawei | Rel-13 | SP-56 | Mirko | FS_OAM_NGMN_NGCOR |  |  |  |  |
| 536 | 126 | Study on Enhancements of OAM aspects of Distributed Mobility Load Balancing (MLB) SON function | 458d? | 2013-09-17 A | 2015-06-12 | 25% | 343.5d? | 2013-09-12 | 2014-12-10 | 326d? | 524d | finish no earlier than 2015-06-12 | S5 | 3664h | 916h | FS_D_MLB_SON_OAM | PCG-31 | 32.860 | Cisco | Rel-13 | SP-61 | Mirko | FS_D_MLB_SON_OAM |  |  | SON |  |
| 537 | 127 | Study on Application and Partitioning of Itf-N | 458d? | 2013-12-17 A | 2015-09-11 | 30% | 320.6d? | 2013-12-11 | 2014-12-10 | 261d? | 459d | finish no earlier than 2015-09-11 | S5 | 3664h | 1099.2h | FS_OAM_AP_Itf-N | PCG-32 | 32.861 | China Mobile | Rel-13 | SP-62 | Mirko | FS_OAM_AP_Itf-N |  |  |  |  |
| 538 | 128 | Study on Charging aspects on Roaming End-to-end scenarios with VoLTE IMS and interconnecting networks | 393d? | 2013-12-17 A | 2015-06-12 | 75% | 98.25d? | 2013-12-11 | 2014-12-10 | 261d? | 524d | finish no earlier than 2015-06-12 | S5 | 3144h | 2358h | FS_REVOLTE_IMS_CH | PCG-32 | 32.849 | Deutsche Telekom | Rel-13 | SP-62 | Mirko | FS_REVOLTE_IMS_CH |  |  |  |  |
| 539 | 129 | Study on Network Management of Virtualized Networks | 269d? | 2014-06-11 A | 2015-06-17 | 60% | 107.6d? | 2014-06-06 | 2015-06-17 | 269d? | 521d | finish no earlier than 2015-06-17 | S5 | 2152h | 1291.2h | FS_OAM_VIRNET | PCG-33 | 32.842 | China Mobile, Huawei | Rel-13 | SP-64 |  | FS_OAM_VIRNET |  |  |  |  |
| 540 | 130 | Study on Review of dedicated 3GPP UICC features | 729d? | 2013-03-04 A | 2015-12-16 A | 100% |  | 2013-03-04 | 2014-09-12 | 401d? |  | finish no earlier than 2015-12-16 | R4 | 5832h | 5832h | FS_Red_UCe | PCG-30 | 31.901 | BlackBerry | Rel-13 | CP-59 | Xavier | FS_Red_UCe |  |  |  |  |
| 541 | 131 | Study on Solutions for GSM/EDGE BTS Energy Saving | 226.4d? | 2010-09-10 A | 2014-11-21 | 95% | 11.32d? | 2009-03-10 | 2014-08-29 | 557d? | 669d | start no earlier than 2010-09-10 | G1; R4 | 3622.4h | 3441.28h | FS_Energy_BTS | PCG-25 | 45.926 | Nokia Networks, Vodafone | Rel-13 | GP-47 | Paolo | FS_Energy_BTS |  |  |  |  |
| 542 | 132 | Study on Downlink MIMO | 398d? | 2013-08-21 A | 2015-02-20 | 65% | 139.3d? | 2013-08-20 | 2015-02-20 | 396d? | 604d | finish no earlier than 2015-02-20 | G1; R4 | 3484.8h | 1288h | FS_DOMIMO | PCG-30 | 45.8xy | Nokia Networks | Rel-13 | GP-57 | Paolo | FS_DOMIMO |  |  |  |  |
| 543 | 133 | Study on MIMO OTA antenna test function for LTE | 462d? | 2013-03-18 A | 2014-12-15 A | 100% |  | 2013-03-15 | 2014-12-05 | 456d? |  | finish no earlier than 2014-12-15 | R4 | 3696h | 3696h | FS_LTE_MIMO_OTA_ATF | PCG-33 | 36.509, new TR 37.978 | Keysight | Rel-13 | RP-64 |  | FS_LTE_MIMO_OTA_ATF |  |  |  | RP-142045 |
| 544 | 134 | Study on UpLink MultiUser Multiple-Input Multiple-Output (UL MU-MIMO) | 255.5d? | 2014-04-17 A | 2015-05-15 | 20% | 204.4d? | 2014-04-17 | 2015-02-20 | 195.5d? | 544d | finish no earlier than 2015-05-15 | G1; R4 | 4088h | 817.6h | FS_UL_MU_MIMO | PCG-32 | 45.876 | Huawei | Rel-13 | GP-60 |  | FS_UL_MU_MIMO |  |  |  |  |
| 545 | 135 | Study on LTE FDD in the bands 1980-2010 MHz and 2170-2200 MHz | 723d? | 2012-09-11 A | 2015-06-15 | 90% | 72.3d? | 2012-09-11 | 2014-09-12 | 527d? | 523d | finish no earlier than 2015-06-15 | R4 | 5784h | 5205.6h | FS_LTE_1980_2170_Korea | PCG-29 | LTE 36.861 | KT | Rel-13 | RP-57 | Issam | FS_LTE_1980_2170_Korea |  |  |  | RP-150120 |
| 546 | 136 | Study on Positioning enhancements for E-UTRA | 524d? | 2012-05-01 A | 2014-12-15 A | 100% |  | 2013-04-25 | 2014-12-05 | 256d? |  | finish no earlier than 2014-12-15 | R4 | 4192h | 4192h | FS_LCSenh_LTE | PCG-31 | LTE 36.855 | Huawei | Rel-13 | RP-60 | Issam | FS_LCSenh_LTE |  |  |  | RP-142224 |
| 547 | 137 | Study on Multi-RAT joint coordination | 397d? | 2013-12-06 A | 2015-06-15 | 85% | 59.55d? | 2013-12-06 | 2014-12-05 | 261d? | 523d | finish no earlier than 2015-06-15 | R4 | 3176h | 2699.6h | FS_MultiRAT_JC | PCG-32 | UTRA, LTE 37.870 | China Mobile | Rel-13 | RP-62 | Juha | FS_MultiRAT_JC |  |  | WLAN | RP-150187 |
| 548 | 138 | Study on Advanced Wireless Services (AWS) - Extension band for LTE | 265d? | 2013-12-16 A | 2014-12-15 A | 100% |  | 2013-12-09 | 2014-12-05 | 261d? |  | finish no earlier than 2014-12-15 | R4 | 2120h | 2120h | FS_LTE_AWS_EXT | PCG-33 | 36.849, 36.869 | Qualcomm | Rel-13 | RP-64 |  | FS_LTE_AWS_EXT |  |  |  | RP-141968 |
| 549 | 139 | Study on Indoor Positioning Enhancements for UTRA and LTE | 328d? | 2014-06-18 A | 2015-09-15 | 30% | 229.6d? | 2014-06-13 | 2015-09-17 | 330d? | 457d | finish no earlier than 2015-09-15 | R1; R4 | 5248h | 1574.4h | FS_UTRA_LTE_iPos_enh | PCG-33 | UTRA, LTE 37.857 | NextNav | Rel-13 | RP-64 |  | FS_UTRA_LTE_iPos_enh |  |  |  | RP-150080 |
| 550 | 140 | Study on Downlink enhancements for UMTS | 199d? | 2014-09-12 A | 2015-06-15 | 80% | 39.8d? |  |  |  | 523d | finish no earlier than 2015-06-15 | R2; R1 | 3184h | 2547.2h | FS_UTRA_EDL | PCG-33 | UTRA TR 25.706 | Huawei | Rel-13 | RP-65 |  | FS_UTRA_EDL |  |  |  | RP-150223 |
| 551 | 141 | Study on Elevation Beamforming/Full-Dimension (FD) MIMO for LTE | 199d? | 2014-09-12 A | 2015-06-15 | 45% | 109.45d? |  |  |  | 523d | finish no earlier than 2015-06-15 | R1 | 1592h | 716.4h | FS_LTE_EBF_FDMIMO | PCG-33 | 36.897 | Nokia Networks (DL), Samsung (UL) | Rel-13 | RP-65 |  | FS_LTE_EBF_FDMIMO |  |  |  | RP-150346 |
| 552 | 142 | Study on Licensed-Assisted Access using LTE | 197d? | 2014-09-16 A | 2015-06-15 | 40% | 118.2d? |  |  |  | 523d | finish no earlier than 2015-06-15 | R1; R2; R4 | 4728h | 1891.2h | FS_LTE_LAA | PCG-33 | 36.889 | Ericsson, Huawei | Rel-13 | RP-65 |  | FS_LTE_LAA |  |  |  | RP-150414 |
| 553 | 143 | Study on KQIs for Service Experience | 203d? | 2014-12-03 | 2015-09-11 |  |  |  |  |  | 459d | finish no earlier than 2015-09-11 | S5 | 1624h |  | FS_KQISE | PCG-34 | TR 32.8xy | Huawei, Istvan Aba | Rel-13 | SP-66 |  |  |  |  |  |  |
| 554 | 144 | Study on Diameter Load Control Mechanisms | 203d? | 2014-12-03 A | 2015-09-11 | 10% | 182.7d? |  |  |  | 459d | finish no earlier than 2015-09-11 | R4 | 1624h | 162.4h | FS_DLoCME | PCG-34 | New 29.810 | Alcatel-Lucent | Rel-13 | CT-66 |  |  |  |  |  |  |
| 555 | 145 | Study on EPC Signalling Improvement for Race Scenarios | 203d? | 2014-12-03 A | 2015-09-11 | 20% | 162.4d? |  |  |  | 459d | finish no earlier than 2015-09-11 | R4 | 1624h | 324.8h | FS_EPC_SIG_RACE | PCG-34 | New TR 29.811 | Huawei | Rel-13 | CT-66 |  |  |  |  |  |  |
| 556 | 146 | Study on Video Enhancements in 3GPP Multimedia Services | 261d? | 2014-12-12 A | 2015-12-11 | 20% | 208.8d? |  |  |  | 394d | finish no earlier than 2015-12-11 | S4 | 2088h | 417.6h | FS_VE_3MS | PCG-34 |  | Ye-Kui Wang, Qualcomm Incorporated | Rel-13 | SP-66 |  |  |  |  |  |  |
| 557 | 147 | Study on Interactivity Support for 3GPP-based Streaming and Download Services | 261d? | 2014-12-12 A | 2015-12-11 | 5% | 247.95d? |  |  |  | 394d | finish no earlier than 2015-12-11 | S4 | 2088h | 104.4h | FS_IS3 | PCG-34 | 26.953 | Lo, Charles, Qualcomm | Rel-13 | SP-66 |  |  |  |  |  |  |
| 558 | 148 | Study on architecture enhancements for Public Safety | 131d? | 2014-12-12 | 2015-06-12 |  |  |  |  |  | 524d | finish no earlier than 2015-06-12 | S2 | 1048h |  | FS_IOPS_St2 | PCG-34 |  |  | Rel-13 | SP-66 |  |  |  |  |  |  |
| 559 | 149 | Study on possible additional configuration for LTE TDD | 197d? | 2014-12-15 A | 2015-09-15 | 5% | 187.15d? |  |  |  | 457d | finish no earlier than 2015-09-15 | R4 | 1576h | 78.8h | FS_LTE_TDD_add_config | PCG-34 | 36.825 | NTT DOCOMO | Rel-13 | RP-66 |  |  |  |  |  | RP-150151 |
| 560 | 150 | Study on Network-Assisted Interference Cancellation and Suppression for UMTS | 197d? | 2014-12-15 A | 2015-09-15 | 20% | 157.6d? |  |  |  | 457d | finish no earlier than 2015-09-15 | R1 | 1576h | 315.2h | FS_UTRA_NAICS | PCG-34 | 25.766 | Huawei | Rel-13 | RP-66 |  |  |  |  |  | RP-150175 |
| 561 | 151 | Study on Enhanced Multiuser Transmissions and Network Assisted Interference Cancellation for LTE | 65d? | 2014-12-15 | 2015-03-15 |  |  |  |  |  | 589d | finish no earlier than 2015-03-15 | R1 | 520h |  | FS_LTE_MUTX_NAIC | PCG-34 |  | MediaTek | Rel-13 | RP-66 |  |  |  |  |  | RP-150213 |
| 562 | 152 | Study on Support of single-cell point-to-multipoint transmission in LTE | 131d? | 2014-12-15 A | 2015-06-15 | 25% | 98.25d? |  |  |  | 523d | finish no earlier than 2015-06-15 | R4 | 1048h | 262h | FS_LTE_SC_PTM | PCG-34 | TR 36.890 | Jeff GAO | Rel-13 | RP-66 |  |  |  |  |  | RP-150176 |
| 563 | 153 | Study on Extension of Dual Connectivity in E-UTRAN | 131d? | 2014-12-15 A | 2015-06-15 | 85% | 19.65d? |  |  |  | 523d | finish no earlier than 2015-06-15 | R4 | 1048h | 890.8h | FS_LTE_dualC_ext | PCG-34 | 36.875 | Samsung | Rel-13 | RP-66 |  |  |  |  |  | RP-150163 |
| 564 | 154 | Study on further enhancements of small cell higher layer aspects for LTE | 197d? | 2014-12-15 A | 2015-09-15 | 10% | 177.3d? |  |  |  | 457d | finish no earlier than 2015-09-15 | R4 | 1576h | 157.6h | FS_LTE_SC_enh2_hilayer | PCG-34 | 37.876 | Huawei | Rel-13 | RP-66 |  |  |  |  |  | RP-150226 |
| 565 | 155 | Study on RAN sharing enhancements for UMTS | 131d? | 2014-12-15 A | 2015-06-15 | 10% | 117.9d? |  |  |  | 523d | finish no earlier than 2015-06-15 | R4 | 1048h | 104.8h | FS_RSE_UTRA_GUSH | PCG-34 | 25.756 | Huawei | Rel-13 | RP-66 |  |  |  |  |  | RP-150227 |
| 566 | 156 | Study on LTE DL 4 Rx antenna ports | 65d? | 2014-12-15 A | 2015-03-15 A | 100% |  |  |  |  |  | finish no earlier than 2015-03-15 | R4 | 520h | 520h | FS_LTE_4Rx_AP_DL | PCG-34 |  | Ericsson | Rel-13 | RP-66 |  |  |  |  |  | RP-150138 |
| 567 | 157 | Study on performance enhancements for high speed scenario in LTE | 197d? | 2014-12-15 A | 2015-09-15 | 5% | 187.15d? |  |  |  | 457d | finish no earlier than 2015-09-15 | R4 | 1576h | 78.8h | FS_LTE_high_speed | PCG-34 |  | NTTDoCoMo | Rel-13 | RP-66 |  |  |  |  |  | RP-150517 |
| 568 | 158 | Study on Determination of Completeness of Charging Information in IMS | 139d? | 2015-03-05 | 2015-09-15 |  |  |  |  |  | 457d | finish no earlier than 2015-09-15 | S5 | 1112h |  | FS_DCCHII | PCG-34 | 32.xyz | Jesske, Roland | Rel-13 | SP-67 |  |  |  |  |  |  |
| 569 | 159 | Study on OAM support for Licensed Shared Access (LSA) | 132d? | 2015-03-12 | 2015-09-11 |  |  |  |  |  | 459d | finish no earlier than 2015-09-11 | S5 | 1056h |  | FS_OAM_LSA | PCG-34 |  | Nokia Networks, Anatoly Andrianov | Rel-13 | SP-67 |  |  |  |  |  |  |
| 570 | 160 | Enhanced Multiuser Transmissions and Network | 261d? | 2014-12-12 | 2015-12-11 |  |  |  |  |  | 394d | finish no earlier than 2015-12-11 | R1 | 2088h |  | FS_MUIC_LTE | PCG-34 | 36.891 | Pei-Kai Liao | Rel-13 | SP-67 |  |  |  |  |  |  |
| 571 | 161 | Study on regulatory aspects for flexible duplex for E-UTRAN | 132d? | 2015-03-16 | 2015-09-15 |  |  |  |  |  | 457d | finish no earlier than 2015-09-15 | R | 1056h |  | FS_LTE_flex_duplex_reg | PCG-34 | 36.882 | LG Electronics Inc. | Rel-13 | RP-67 |  |  |  |  |  |  |
| 572 | 162 | Study on Latency reduction techniques for LTE | 328d? | 2015-03-16 | 2016-06-15 |  |  |  |  |  | 261d | finish no earlier than 2016-06-15 | R2 | 2624h |  | FS_LTE_LATRED | PCG-34 | 36.881 | Ericsson | Rel-13 | RP-67 |  |  |  |  |  |  |
| 573 | 163 | Study on further Enhancements of Minimization of Drive Tests for E-UTRAN | 132d? | 2015-03-16 | 2015-09-15 |  |  |  |  |  | 457d | finish no earlier than 2015-09-15 | R2 | 1056h |  | FS_LTE_eMDT2 | PCG-34 | 36.880 | CMCC | Rel-13 | RP-67 |  |  |  |  |  |  |
| 574 | 164 | Study on Downlink Multiuser Superposition Transmission for LTE | 197d? | 2015-03-16 | 2015-12-15 |  |  |  |  |  | 392d | finish no earlier than 2015-12-15 | R1 | 1576h |  | FS_LTE_MUST | PCG-34 | 36.859 | Mediatek | Rel-13 | RP-67 |  |  |  |  |  |  |
| 575 | 165 | Study on the Support of Emergency services over WLAN | 71d? | 2015-03-12 | 2015-06-18 |  |  |  |  |  | 520d | finish no earlier than 2015-06-18 | S2 | 568h |  | FS_SEW | PCG-34 |  | Laurent Thiebaut, Alcatel Lucent | Rel-13 | RP-67 |  |  |  |  |  |  |
| 576 | 166 | Study on EGPRS Access Security Enhancements with relation to cellular IoT | 197d? | 2015-03-12 | 2015-12-11 |  |  |  |  |  | 394d | finish no earlier than 2015-12-11 | S3 | 1576h |  | FS_EASE_IoT | PCG-34 | New 33.860 | Vesa Torvinen, Ericsson | Rel-13 | RP-67 |  |  |  |  |  |  |
| 577 | 167 | Release 12 Features | 306d? | 2013-10-14 A | 2014-12-12 | 65% | 108.4d? | 2013-10-14 | 2014-12-10 | 304d? | 654d | finish no earlier than 2014-12-12 | SP; CP; RP; GP | 9792h | 6323.2h |  |  |  |  | Rel-12 |  |  |  |  |  |  |  |
| 578 | 168 | Stage 1 - ONLY Features | 647d? | 2011-09-27 A | 2014-03-05 A | 100% |  | 2011-09-27 | 2014-03-05 | 647d? |  | start no earlier than 2011-09-27 | SP; CP | 10352h | 10352h |  | PCG-30 |  |  | Rel-12 | SP-58 |  |  |  |  |  |  |

Notes:
- 524: SP#64 revived. Added to the Title "for Service, Application and Subscriber Group", Changed Acronym: FS_UMONC=>FS_UMONC_sas / WI rapporteur e-mail: Jinyan Li (lijy@ctbri.com.cn)
- 525: SP#56 completed / WI rapporteur e-mail: Li.Mian@zte.com.cn
- 526: SP#64 revived. Updated WID SP-120554=>SP-140403. Changed Justification/objectives/Rapporteut ZTE=>China Unciom. SP#58 SA2 stopped (at 70% completion). Dec.14: 80->100%. Mar 15: WID SP-140403->SP-150029 / WI rapporteur e-mail: Jinyan Li (lijy@ctbri.com.cn)
- 527: SP#57 stopped / WI rapporteur e-mail: Hui Cai (Sarah.Cai@huawei.com)
- 528: Dec.14: 0->30%. Mar15: 70% / WI rapporteur e-mail: hans.ronneke@ericsson.com
- 529: SP#65 moved to Rel-13. Updated WID SP-100734=>SP-140576. Completion 09/14=>06/15. Dec.14: 60->65% / WI rapporteur e-mail: vesa.lehtovirta@ericsson.com
- 530: SP#65 updated WID SP-140300=>SP-140629 (Moved the TR phase to Rel-13 as a stand-alone Study). Completion 09/14=>06/15. SP#64 TR 33.833 v100 for Information. 4/3/15: 95%->70% (more topics to be included) / WI rapporteur e-mail: Adrian Escott (aescott@qti.qualcomm.com)
- 531: SP#65 moved to Rel-13. Completion 09/14=>12/15. Related to SA1 TR 22.949 Rel-6 Study on Privacy Capability (PrivCap) UID_31030 studied generalized privacy capability (protection of personal data and non-disclosure of identity). Dec.14: 80->85 / WI rapporteur e-mail: Feng Gao (gaofeng149@chinaunicom.cn)
- 532: Linked to LI13 which defines existing LI service requirements in TS 33.106 as well as existing HI1, HI2 & HI3 reference points. 3/3/15: 0->5% / WI rapporteur e-mail: terry.jacobson@alcatel-lucent.com
- 533: Dec.14: TR number added. 3/3/15: 0->5% / WI rapporteur e-mail: Gregory.schumacher@sprint.com
- 534: SP#65 completion 09/14=>12/14. Moved to Rel-13. Dec.14: 30->35%, CD 12/14->03/15. Mar.15: CD: 06/16. 40% / WI rapporteur e-mail: Chris Steck (Audience), David Isherwood (Intel)
- 535: SP#65 updated WID SP-140349=>SP-140539. Dec.14: 35->45, 12/14: 28.821 added. Mar 15: 45->50% / WI rapporteur e-mail: zoulan@huawei.com
- 536: SP#64 completion 06/14=>12/14. Dec.14: 20->25%, CD: 12/14->06/15 / WI rapporteur e-mail: Vladimir Yanover (vyanover@cisco.com)
- 537: -Dec.14: 15->30%, CD: 12/14->09/15 / WI rapporteur e-mail: Li Jian (lijian@chinamobile.com), Hu Yaxi (huyaxi@cmdi.chinamobile.com)
- 538: SP#64 moved to Rel-13. Completion 06/14=>12/14. Dec.14: 35->55, CD: 12/14->06/15. Mar 15: 55->75% / WI rapporteur e-mail: Roland Jesske (r.jesske@telekom.de)
- 539: Dec.14: 10->25%. Mar 15: 25->60% / WI rapporteur e-mail: Liu Jinglei (liujinglei@chinamobile.com), zoulan@huawei.com
- 540: CP#65 TR 31.901v100 for Information. Moved to Rel-13. Completion 09/14=>12/15. Waiting for feedback from external organizations (PTCRB/PVG). Dec.14: 65->100% / WI rapporteur e-mail: Adrian Buckley (abuckley@blackberry.com)
- 541: GP#63 moved to Rel-13. Completion 08/14=>11/14. GP#55 TR 45.926v100 for Information. GP#47 approved WID. Dec.14: 90->95%. 3/3/15: start date corrected (was 03/09) / WI rapporteur e-mail: juergen.hofmann@nsn.com, leo.patanapongpibul@vodafone.com
- 542: GP#62 completion 08/14=>02/15. Moved to Rel-13. GP#57 approved WID. Dec.14: 50->65%, CD: 02/15->05/15 / WI rapporteur e-mail: Khairul Hasan
- 543: CD:Thu 11/12/14->Mon 15/12/14; Compl:60%->100%; Stat Rep: RP-141124->RP-142045 / WI rapporteur e-mail: Moray_Rumney@keysight.com
- 544: GP#62 completion 11/14=>02/15. GP#60 approved WID. Dec.14: 02/15->05/15 / WI rapporteur e-mail: Chao Luo (chluo@huawei.com)
- 545: CD:Thu 11/12/14->Sun 15/03/15; Compl:85%->90%; Stat Rep: RP-141153->RP-141851 1st Apr 15: CD:Sun 15/03/15->Mon 15/06/15 1st Apr 15: WID: RP-141154->RP-150119 1st Apr 15: Stat Rep: RP-141851->RP-150120 / WI rapporteur e-mail: Chungwoo HWANG (cwhwang@kt.com)
- 546: WID: RP-140667->RP-130680; Stat Rep: RP-140639->RP-142224. 3/3/15: R1 removed as 2nd responsible WG / WI rapporteur e-mail: Jie Cui (cuijie@huawei.com)
- 547: ; WID: RP-142043->RP-132086; Stat Rep: RP-141301->RP-141838 1st Apr 15: Compl:55%->85% 1st Apr 15: WID: RP-132086->RP-150417 1st Apr 15: Stat Rep: RP-141838->RP-150187 / WI rapporteur e-mail: Kimba Dit Adamou, Boubacar (jinba@chinamobile.com)
- 548: CD:Thu 11/12/14->Mon 15/12/14; Compl:10%->100%; Stat Rep: RP-141429->RP-141968. 5/5/15: 2nd TR number added (to be clarified why two TR for a same topic) / WI rapporteur e-mail: Gene Fong (gfong@qti.qualcomm.com)
- 549: CD:Thu 17/09/15->Tue 15/09/15; Compl:0%->8%; Stat Rep: RP-141101->RP-141818 1st Apr 15: Compl:8%->30% 1st Apr 15: Stat Rep: RP-141818->RP-150080 / WI rapporteur e-mail: Vogedes Jerome (jvogedes@NextNav.com)
- 550: WID: RP-141901; Stat Rep: -->RP-142233 1st Apr 15: Compl:40%->80% 1st Apr 15: WID: RP-141901->RP-150224 1st Apr 15: Stat Rep: RP-142233->RP-150223. 5/5/15: R4 replaced by R1 (correction mistake) / WI rapporteur e-mail: jun.chen@huawei.com
- 551: 3/3/15: WID: RP-141831; Stat Rep: -->RP-141822, impacted TR number added. 1st Apr 15: Compl:30%->45% 1st Apr 15: Stat Rep: RP-141822->RP-150346. 5/5/15: "R4" replaced by "R1" (correction mistake) / WI rapporteur e-mail: bishwarup.mondal@nsn.com, hyoungju.ji@samsung.com
- 552: 3/3/15: WID: RP-141817; Stat Rep: -->RP-141816. Impacted TR number added. 1st Apr 15: Compl:30%->40% 1st Apr 15: Stat Rep: RP-141816->RP-150414 / WI rapporteur e-mail: havish.koorapaty@ericsson.com, david.mazzarese@huawei.com
- 553: Mar 15: 0->5% / WI rapporteur e-mail: istvan.aba(at)huawei.com
- 554: 0->5%. Mar. 15: 10%
- 555: Mar15: 0->20%
- 556: Mar. 15: 0->20% / WI rapporteur e-mail: yekuiw@qti.qualcomm.com
- 557: TR number added. Mar. 15: 0->5% / WI rapporteur e-mail: clo@qti.qualcomm.com
- 558: WI rapporteur e-mail: phil.young@gd-broadband.com
- 559: TR 36.825 rapporteur: CATT. TR number added. 1st Apr 15: Compl:0%->5% 1st Apr 15: Stat Rep: ->RP-150151 / WI rapporteur e-mail: NTT DOCOMO
- 560: TS number added 1st Apr 15: Compl:0%->20% 1st Apr 15: WID: RP-142250->RP-150174 1st Apr 15: Stat Rep: ->RP-150175. 5/5/15: "R4" replaced by "R1" (correction mistake) / WI rapporteur e-mail: Huawei
- 561: 1st Apr 15: CD:Tue 15/12/15->Sun 15/03/15 1st Apr 15: Stat Rep: ->RP-150213. 5/5/15: "R4" replaced by "R1" (correction mistake) / WI rapporteur e-mail: MediaTek
- 562: deleted 660062 (duplicated). 29/1: TR number added 1st Apr 15: Compl:0%->25% 1st Apr 15: WID: RP-142205->RP-150177 1st Apr 15: Stat Rep: ->RP-150176 / WI rapporteur e-mail: gaoyongqiang@huawei.com
- 563: TR number added 1st Apr 15: Compl:0%->85% 1st Apr 15: CD:Sun 15/03/15->Mon 15/06/15 1st Apr 15: WID: RP-142257->RP-150170 1st Apr 15: Stat Rep: ->RP-150163 / WI rapporteur e-mail: Samsung
- 564: TR number added 1st Apr 15: Compl:0%->10% 1st Apr 15: Stat Rep: ->RP-150226 / WI rapporteur e-mail: Huawei
- 565: TR number added 1st Apr 15: Compl:0%->10% 1st Apr 15: Stat Rep: ->RP-150227 / WI rapporteur e-mail: Huawei
- 566: 1st Apr 15: Compl:0%->100% 1st Apr 15: WID: RP-142299->RP-150457 1st Apr 15: Stat Rep: ->RP-150138 / WI rapporteur e-mail: Ericsson
- 567: TR Rapporteur is Huawei 1st Apr 15: Compl:0%->5% 1st Apr 15: WID: RP-142307->RP-150159 1st Apr 15: Stat Rep: ->RP-150517 / WI rapporteur e-mail: NTTDoCoMo
- 568: 11/03/15: WID changed from FS_DCCII to FS_DCCHII as per SA5 chair request / WI rapporteur e-mail: r.jesske@telekom.de
- 569: WI rapporteur e-mail: anatoly<dot>andrianov<at>nokia<dot>com
- 570: TR added / WI rapporteur e-mail: pk.liao@mediatek.com
- 571: TR added
- 574: TR added
- 575: WI rapporteur e-mail: Laurent.thiebaut@alcatel-lucent.com
- 576: TR added
- 577: -
- 578: -

| ID | WBS | Task | Duration | Start | Finish | Complete | Baseline start | Baseline finish | Baseline duration | Constraint | Resources | Work | Actual work | Acronym | PCG approved | Impacted TSs and TRs | WI rapporteur name | WI rapporteur e-mail | Release | TSG approved | MCC resp | Special Focus Doc | Acronym_3GU_Export | PCG stopped | TSG stopped |
| --- | --- | --- | --- | --- | --- | --- | --- | --- | --- | --- | --- | --- | --- | --- | --- | --- | --- | --- | --- | --- | --- | --- | --- | --- | --- |
| 579 | 169 | **SIPTO Service Continuity of IP Data Session** | 262d? | 2010-09-23 A | 2011-09-21 A | 100% | 2010-09-23 | 2011-09-21 | 262d? |  | S1 | 4176h | 4176h | SIPTO_SC | PCG-25 | Stage 1 | Vodafone | mona.mustapha@vodafone.com | Rel-12 | SP-49 | Alain | HNB | SIPTO_SC |  |  |
| 580 | 169.1 | Stage 1 for SIPTO Service Continuity of IP Data Session | 262d? | 2010-09-23 A | 2011-09-21 A | 100% | 2010-09-23 | 2011-09-21 | 262d? | finish no earlier than 2011-09-21 | S1 | 2080h | 2080h | SIPTO_SC-SA1 | PCG-25 | 22.101, 22.220 | Vodafone | mona.mustapha@vodafone.com | Rel-12 | SP-49 | Alain | HNB |  |  |  |
| 581 | 170 | **Interworking between Mobile Operators using the Evolved Packet System and Data Application Providers** | 792d? | 2010-12-16 A | 2013-12-11 A | 100% | 2010-12-16 | 2013-12-11 | 792d? |  | S1; S2 | 22794.7h | 22794.7h | MOSAP | PCG-26 | Stage 1 | Cisco | Vojislav Vucetic (vvucetic@cisco.com) | Rel-12 | SP-50 | Alain |  | MOSAP |  |  |
| 582 | 170.1 | Stage 1 for MOSAP | 202d? | 2010-12-16 A | 2011-09-21 A | 100% | 2010-12-16 | 2011-09-21 | 202d? | finish no earlier than 2011-09-21 | S1 | 1600h | 1600h | MOSAP-SA1 | PCG-26 | 22.278 | Cisco | Vojislav Vucetic (vvucetic@cisco.com) | Rel-12 | SP-50 | Alain |  |  |  |  |
| 583 | 170.2 | TR on Stage 2 for MOSAP | 669d? | 2011-06-06 A | 2013-12-11 A | 100% | 2011-06-06 | 2013-12-11 | 669d? | finish no earlier than 2012-12-12 | S2 | 5338.74h | 5338.74h | MOSAP-SA2TR | PCG-27 | new TR 23.862 | Intel | chang.hong.shan@intel.com | Rel-12 | SP-52 | Maurice |  |  |  |  |
| 584 | 170.3 | Deleted - Stage 2 for MOSAP | 399d? | 2011-06-14 A | 2012-12-12 A | 100% | 2011-06-14 | 2012-12-12 | 399d? | finish no earlier than 2012-12-12 | S2 | 3184h | 3184h | MOSAP-SA2Del | PCG-27 | TBD | Intel | chang.hong.shan@intel.com | Rel-12 | SP-52 | Maurice |  |  | PCG-30 | SP-58 |
| 585 | 171 | **IMS Network-Independent Public User Identities** | 275d? | 2011-06-08 A | 2012-06-20 A | 100% | 2011-06-08 | 2012-06-20 | 275d? |  | S1 | 4390.4h | 4390.4h | INIPUI | PCG-27 | Stage 1 | Vodafone | mona.mustapha@vodafone.com | Rel-12 | SP-52 | Alain |  | INIPUI |  |  |
| 586 | 171.1 | Stage 1 for IMS Network-Independent Public User Identities | 275d? | 2011-06-08 A | 2012-06-20 A | 100% | 2011-06-08 | 2012-06-20 | 275d? | finish no earlier than 2012-06-20 | S1 | 2190.4h | 2190.4h | INIPUI-SA1 | PCG-27 | 22.115, 22.228 | Vodafone | mona.mustapha@vodafone.com | Rel-12 | SP-52 | Alain |  |  |  |  |
| 587 | 172 | **Service and Media Reachability for Users over Restrictive Firewalls** | 198d? | 2011-09-21 A | 2012-06-20 A | 100% | 2011-09-21 | 2012-06-20 | 198d? |  | S1 | 3161.67h | 3161.67h | SMURFs | PCG-27 | Stage 1 | Vodafone | mona.mustapha@vodafone.com | Rel-12 | SP-53 | Alain |  | SMURFs |  |  |
| 588 | 172.1 | Stage 1 for Service and Media Reachability for Users over Restrictive Firewalls | 198d? | 2011-09-21 A | 2012-06-20 A | 100% | 2011-09-21 | 2012-06-20 | 198d? | finish no earlier than 2012-06-08 | S1 | 1577.67h | 1577.67h | SMURFs-SA1 | PCG-27 | 22.278 | Vodafone | mona.mustapha@vodafone.com | Rel-12 | SP-53 | Alain |  |  |  |  |
| 589 | 173 | **Advanced IP Interconnection of Services (IPXS) for national interconnect** | 139d? | 2012-03-06 A | 2012-09-12 A | 100% | 2012-03-06 | 2012-09-12 | 139d? |  | S1 | 2208h | 2208h | IPXSNAT | PCG-28 | Stage 1 | KPN | toon.norp@tno.nl | Rel-12 | SP-55 | Alain |  | IPXSNAT |  |  |
| 590 | 173.1 | Stage 1 for Advanced IP Interconnection of Services (IPXS) for national interconnect | 139d? | 2012-03-06 A | 2012-09-12 A | 100% | 2012-03-06 | 2012-09-12 | 139d? | finish no earlier than 2012-09-12 | S1 | 1096h | 1096h | IPXSNAT-SA1 | PCG-28 | 22.228 CR#0161 | KPN | toon.norp@tno.nl | Rel-12 | SP-55 | Alain |  |  |  |  |
| 591 | 174 | **Integration of Single Sign-On (SSO) frameworks with 3GPP networks** | 137d? | 2012-03-08 A | 2012-09-12 A | 100% | 2012-03-08 | 2012-09-12 | 137d? |  | S1 | 2184h | 2184h | SSO_Int | PCG-28 | Stage 1 | InterDigital | christopher.wallace@interdigital.com | Rel-12 | SP-55 | Alain |  | SSO_Int |  |  |
| 592 | 174.1 | Stage 1 for Integration of Single Sign-On (SSO) frameworks with 3GPP networks | 137d? | 2012-03-08 A | 2012-09-12 A | 100% | 2012-03-08 | 2012-09-12 | 137d? | finish no earlier than 2012-09-12 | S1 | 1088h | 1088h | SSO_Int-SA1 | PCG-28 | 22.101 | InterDigital | christopher.wallace@interdigital.com | Rel-12 | SP-55 | Alain |  |  |  |  |
| 593 | 175 | **Explicit Communication Transfer Blind (ECT Blind) service interactions** | 3d? | 2012-06-18 A | 2012-06-20 A | 100% | 2012-06-18 | 2012-06-20 | 3d? |  | S1 | 48h | 48h | ECTB | PCG-29 | Stage 1 | Orange | philippe.lottin@orange.com | Rel-12 | SP-56 | Alain |  | ECTB |  |  |
| 594 | 175.1 | Stage 1 for Explicit Communication Transfer Blind (ECT Blind) service interactions | 3d? | 2012-06-18 A | 2012-06-20 A | 100% | 2012-06-18 | 2012-06-20 | 3d? | finish no earlier than 2012-06-20 | S1 | 24h | 24h | ECTB-SA1 | PCG-29 | 22.173 | Orange | philippe.lottin@orange.com | Rel-12 | SP-56 | Alain |  |  |  |  |
| 595 | 176 | **IMS access via Digital Video Broadcast - Return Channel via Satellite (DVB-RCS2)** | 162d? | 2012-02-02 A | 2012-09-12 A | 100% | 2012-02-02 | 2012-09-12 | 162d? |  | S1 | 2584h | 2584h | IMSSat | PCG-29 | Stage 1 | KPN | toon.norp@tno.nl | Rel-12 | SP-57 | Alain |  | IMSSat |  |  |
| 596 | 176.1 | Stage 1 for IMS access via DVB-RCS2 | 162d? | 2012-02-02 A | 2012-09-12 A | 100% | 2012-02-02 | 2012-09-12 | 162d? | finish no earlier than 2012-09-12 | S1 | 1288h | 1288h | IMSSat-SA1 | PCG-29 | 22.228 | KPN | toon.norp@tno.nl | Rel-12 | SP-57 | Alain |  |  |  |  |
| 597 | 177 | **Sequential Flexible Alerting** | 3d? | 2012-12-10 A | 2012-12-12 A | 100% | 2012-12-10 | 2012-12-12 | 3d? |  | S1 | 48h | 48h | SEQ_FA | PCG-30 | Stage 1 | Orange | bruno.tossou@orange-ftgroup.com | Rel-12 | SP-58 | Alain |  | IMSSat |  |  |
| 598 | 177.1 | Stage 1 for Sequential Flexible Alerting | 3d? | 2012-12-10 A | 2012-12-12 A | 100% | 2012-12-10 | 2012-12-12 | 3d? | finish no earlier than 2012-12-12 | S1 | 24h | 24h | SEQ_FA | PCG-30 | 22.173 | Orange | bruno.tossou@orange-ftgroup.com | Rel-12 | SP-58 | Alain |  |  |  |  |
| 599 | 178 | **Language and Modality Information for communications** | 63d? | 2012-12-11 A | 2013-03-06 A | 100% | 2012-12-11 | 2013-03-06 | 63d? |  | S1 | 1008h | 1008h | LangInfo | PCG-30 | Stage 1 | Orange | philippe.lottin@orange.com | Rel-12 | SP-58 | Alain |  | LangInfo |  |  |
| 600 | 178.1 | Stage 1 for Language and Modality Information for communications | 63d? | 2012-12-11 A | 2013-03-06 A | 100% | 2012-12-11 | 2013-03-06 | 63d? | finish no earlier than 2013-03-06 | S1 | 504h | 504h | LangInfo-SA1 | PCG-30 | 22.228 | Orange | philippe.lottin@orange.com | Rel-12 | SP-58 | Alain |  |  |  |  |
| 601 | 179 | **Emergency Session Identification** | 3d? | 2013-03-04 A | 2013-03-06 A | 100% | 2013-03-04 | 2013-03-06 | 3d? |  | S1 | 48h | 48h | ESID | PCG-30 | Stage 1 | Telecom Italia | carmen.catalano@telecomitalia.it | Rel-12 | SP-59 | Alain |  | ESID |  |  |
| 602 | 179.1 | Stage 1 for Emergency Session Identification | 3d? | 2013-03-04 A | 2013-03-06 A | 100% | 2013-03-04 | 2013-03-06 | 3d? | finish no earlier than 2013-03-06 | S1 | 24h | 24h | ESID-SA1 | PCG-30 | 22.101 | Telecom Italia | carmen.catalano@telecomitalia.it | Rel-12 | SP-59 | Alain |  |  |  |  |

Notes:
- 579: SP#57 moved to Rel-12 (Reason: Stage 2 for requirements in TS 22.101 clause 4.3.5 have not been implemented in Rel-11). Linked to Rel-10 Local IP Access and Selected Internet IP Traffic Offload (LIPA_SIPTO)
- 580: SP#57 moved to Rel-12. SP#53 completed
- 581: SP#58 Stage 2 stopped (TR only, no normative work done)
- 582: SP#53 completed
- 583: SP#62 completed. TR 23.862v200 for Approval. SP#58 frozen as v100.
- 584: SP#58 stopped (no normative work done)
- 585: Triggered by Rel-11 TR 22.894 (FS_INIPUI)
- 586: SP#56 re-completed. Updated WID SP-110381=>SP-120425 (Re-opened & moved to Rel-12 by adding new reqs & removing reqs from Rel-11). SP#53 Rel-11 Stage 1 completed
- 587: SP#56 Stage 1 completed
- 588: SP#56 completed
- 589: SP#57 Stage 1 completed. Linked to Rel-11 Feature Advanced IP Interconnection of Services (IPXS) UID_470051.
- 590: SP#57 completed
- 591: SP#57 Stage 1 completed. Triggered by Rel-12 TR 22.895. Linked to SA3 33.8xy (Study on Security aspects of SSO_Int), 33.914 (SSO application security for common IMS based on SIP Digest), 33.924 (i/w GBA and OpenID), 33.980 (i/w GBA and Liberty Alliance)
- 592: SP#57 completed
- 593: SP#56 WID approved & Stage 1 completed
- 594: SP#56 new WID approved & work completed. Clarify the service interactions between ECT Blind and other MMTEL Supplementary Services
- 595: SP#57 Stage 1 completed. Integrate Satcom access with IMS. Specify DVB-RCS2 as an IP Connectivity Access Network for IMS
- 596: SP#57 completed. Definition of DVB-RCS2 as a non-3GPP IP Connectivity Access Network for IMS
- 597: SP#58 approved WID & Stage 1 completed. Currently Flexible Alerting (FA) group members are simultaneously alerted by the incoming call. Add the possibility to alert FA group members sequentially. 22/01: acronym modified
- 598: SP#58 approved WID & Stage 1 completed
- 599: SP#59 Stage 1 completed. Triggered by Rel-11 Study on Non Voice Emergency Services (FS_NOVES) TR 22.871 use case 10
- 600: SP#59 completed. Updated WID SP-120937=>SP-130108
- 601: SP#59 Stage 1 completed.
- 602: SP#59 completed (22.101 CR#0445)

| ID | WBS | Task | Duration | Start | Finish | Complete | Baseline start | Baseline finish | Baseline duration | Constraint | Resources | Work | Actual work | Acronym | PCG approved | WI rapporteur name | WI rapporteur e-mail | Release | TSG approved | MCC resp | PCG stopped | TSG stopped | Acronym_3GU_Export | Special Focus Doc | Status Report |
| --- | --- | --- | --- | --- | --- | --- | --- | --- | --- | --- | --- | --- | --- | --- | --- | --- | --- | --- | --- | --- | --- | --- | --- | --- | --- |
| 603 | 180 | **Deleted - Application and Service Access Control** | 77d? | 2013-03-06 A | 2013-06-19 A | 100% | 2013-03-06 | 2013-06-19 | 77d? |  | S1 | 1224h | 1224h | ASAC | PCG-30 | NTT DOCOMO | Atsushi Minokuchi (minokuchi@nttdocomo.co.jp) | Rel-12 | SP-59 | Alain | PCG-31 | SP-60 | ASAC |  |  |
| 604 | 180.1 | Deleted - Stage 1 for Application and Service Access Control | 77d? | 2013-03-06 A | 2013-06-19 A | 100% | 2013-03-06 | 2013-06-19 | 77d? | finish no earlier than 2013-06-19 | S1 | 608h | 608h | ASAC-SA1del | PCG-30 | NTT DOCOMO | Atsushi Minokuchi (minokuchi@nttdocomo.co.jp) | Rel-12 | SP-59 | Alain | PCG-31 | SP-60 |  |  |  |
| 605 | 181 | **Prevention of Mobile-Originating signalling and/or data traffic of UE in Connected mode** | 3d? | 2013-03-04 A | 2013-03-06 A | 100% | 2013-03-04 | 2013-03-06 | 3d? |  | S1 | 48h | 48h | PMOC | PCG-30 | NTT DOCOMO | Atsushi Minokuchi (minokuchi@nttdocomo.co.jp) | Rel-12 | SP-59 | Alain |  |  | PMOC |  |  |
| 606 | 181.1 | Stage 1 for Prevention of Mobile-Originating signalling and/or data traffic of UE in Connected mode | 3d? | 2013-03-04 A | 2013-03-06 A | 100% | 2013-03-04 | 2013-03-06 | 3d? | finish no earlier than 2013-03-06 | S1 | 24h | 24h | PMOC-SA1 | PCG-30 | NTT DOCOMO | Atsushi Minokuchi (minokuchi@nttdocomo.co.jp) | Rel-12 | SP-59 | Alain |  |  |  |  |  |
| 607 | 182 | SA1/SA2 Features | 216d? | 2013-05-17 A | 2014-03-07 A | 100% | 2013-05-17 | 2014-03-07 | 216d? | finish no earlier than 2014-03-07 | SP; CP; RP | 5184h | 5184h |  | PCG-30 |  |  | Rel-12 | SP-58 |  |  |  |  |  |  |
| 608 | 183 | **LIPA Mobility and SIPTO at the Local Network** | 898d? | 2010-10-15 A | 2014-03-06 A | 100% | 2010-10-15 | 2014-03-06 | 898d? |  | S2; C4; C1; R3 | 87994h | 87994h | LIMONET | PCG-26 | Huawei | zhufenqin@huawei.com | Rel-12 | SP-50 | Maurice |  |  | LIMONET | HNB |  |
| 609 | 183.1 | TR on Stage 2 for LIPA Mobility and SIPTO at the Local Network | 580.85d? | 2010-10-15 A | 2013-03-06 A | 100% | 2010-10-15 | 2013-03-06 | 580.85d? | finish no earlier than 2013-03-06 | S2 | 4646.8h | 4646.8h | LIMONET-SA3 | PCG-26 | Huawei | zhufenqin@huawei.com | Rel-12 | SP-50 | Maurice |  |  |  | HNB |  |
| 610 | 183.2 | **BB1: SIPTO at the Local Network** | 892d? | 2010-10-22 A | 2014-03-05 A | 100% | 2010-10-22 | 2014-03-05 | 892d? |  | S2 | 31685.6h | 31685.6h | LIMONET-SIPTO | PCG-26 | Huawei | zhufenqin@huawei.com | Rel-12 | SP-50 | Maurice |  |  | LIMONET-SIPTO | HNB |  |
| 611 | 183.2.1 | Stage 2 for SIPTO at the Local Network | 655.85d? | 2010-10-22 A | 2013-06-19 A | 100% | 2010-10-22 | 2013-06-19 | 655.85d? | finish no earlier than 2013-06-19 | S2 | 5246.8h | 5246.8h | LIMONET-SIPTO-SA2 | PCG-26 | Huawei | zhufenqin@huawei.com | Rel-12 | SP-50 | Maurice |  |  |  | HNB |  |
| 612 | 183.2.2 | **Stage 3 CN aspects of SIPTO at the Local Network** | 649d? | 2011-09-24 A | 2014-03-05 A | 100% | 2011-09-24 | 2014-03-05 | 649d? |  | C4; C1 | 19680h | 19680h | LIMONET-SIPTO | PCG-27 | Huawei | peter.schmitt@huawei.com | Rel-12 | CP-53 | Kimmo |  |  |  | HNB |  |
| 613 | 183.2.2.1 | CT4 part of Stage 3 CN aspects of SIPTO at the Local Network | 518d? | 2011-09-24 A | 2013-09-06 A | 100% | 2011-09-24 | 2013-09-06 | 518d? | finish no earlier than 2013-09-06 | C4 | 4136h | 4136h | LIMONET-SIPTO-CT4 | PCG-27 | Huawei | peter.schmitt@huawei.com | Rel-12 | CP-53 | Kimmo |  |  |  | HNB |  |
| 614 | 183.2.2.2 | CT1 part of Stage 3 CN aspects of SIPTO at the Local Network | 646d? | 2011-09-24 A | 2014-03-05 A | 100% | 2011-09-24 | 2014-03-05 | 646d? | finish no earlier than 2014-01-29 | C1 | 5160h | 5160h | LIMONET-SIPTO-CT1 | PCG-27 | Huawei | peter.schmitt@huawei.com | Rel-12 | CP-53 | Frederic |  |  |  | HNB |  |
| 615 | 183.3 | **RAN aspects for SIPTO at the Local Network** | 269d? | 2013-03-04 A | 2014-03-06 A | 100% | 2013-03-04 | 2014-03-06 | 269d? |  | R3 | 4272h | 4272h | LIMONET-RAN | PCG-30 | Huawei | zheng.zhou@huawei.com | Rel-12 | RP-59 | Juha |  |  | LIMONET-RAN | HNB |  |
| 616 | 183.3.1 | Core part: RAN aspects for SIPTO at the Local Network | 266d? | 2013-03-04 A | 2014-03-06 A | 100% | 2013-03-04 | 2014-03-06 | 266d? | finish no earlier than 2014-03-06 | R3 | 2120h | 2120h | LIMONET-RAN-Core | PCG-30 | Huawei | zheng.zhou@huawei.com | Rel-12 | RP-59 | Juha |  |  | LIMONET-RAN-Core | HNB | RP-131512 |
| 617 | 183.4 | **Deleted - BB2: Stand-alone L-GW and associated Mobility for LIPA and SIPTO at the Local Network** | 566d? | 2010-10-22 A | 2012-12-12 A | 100% | 2010-10-22 | 2012-12-12 | 566d? |  | S2 | 18653.6h | 18653.6h | LIMONET-LIPA | PCG-26 | Huawei | zhufenqin@huawei.com | Rel-12 | SP-50 | Maurice | PCG-30 | SP-58 | LIMONET-LIPA | HNB |  |
| 618 | 183.4.1 | Deleted - Stage 2 for stand-alone L-GW and associated Mobility for LIPA and SIPTO at the Local Network | 519.85d? | 2010-10-22 A | 2012-12-12 A | 100% | 2010-10-22 | 2012-12-12 | 519.85d? | finish no earlier than 2012-12-12 | S2 | 4158.8h | 4158.8h | LIMONET-LIPA-del1 | PCG-26 | Huawei | zhufenqin@huawei.com | Rel-12 | SP-50 | Maurice | PCG-30 | SP-58 |  | HNB |  |
| 619 | 183.4.2 | **Deleted - Stage 3 CN aspects of LIPA Mobility** | 323d? | 2011-09-24 A | 2012-12-12 A | 100% | 2011-09-24 | 2012-12-12 | 323d? |  | C1; C4 | 10336h | 10336h | LIMONET-LIPA-del2 | PCG-27 | Huawei | christian.herrero@huawei.com | Rel-12 | CP-53 | Frederic | PCG-30 | SP-58 |  | HNB |  |
| 620 | 183.4.2.1 | Deleted - CT1 part of CN aspects of LIPA Mobility | 323d? | 2011-09-24 A | 2012-12-12 A | 100% | 2011-09-24 | 2012-12-12 | 323d? | finish no earlier than 2012-12-12 | C1 | 2584h | 2584h | LIMONET-LIPA-del3 | PCG-27 | Huawei | christian.herrero@huawei.com | Rel-12 | CP-53 | Frederic | PCG-30 | SP-58 |  | HNB |  |
| 621 | 183.4.2.2 | Deleted - CT4 part of CN aspects of LIPA Mobility | 323d? | 2011-09-24 A | 2012-12-12 A | 100% | 2011-09-24 | 2012-12-12 | 323d? | finish no earlier than 2012-12-12 | C4 | 2584h | 2584h | LIMONET-LIPA-del4 | PCG-27 | Huawei | christian.herrero@huawei.com | Rel-12 | CP-53 | Kimmo | PCG-30 | SP-58 |  | HNB |  |
| 622 | 184 | **Operator Policies for IP Interface Selection** | 720d? | 2011-03-23 A | 2013-12-06 A | 100% | 2011-03-23 | 2013-12-06 | 720d? |  | S2; C1 | 20256h | 20256h | OPIIS | PCG-26 | LG Electronics | taehyeon.kim@lge.com | Rel-12 | SP-51 | Maurice |  |  | OPIIS |  |  |
| 623 | 184.1 | TR on Stage 2 for Operator Policies for IP Interface Selection | 457d? | 2011-03-23 A | 2012-12-12 A | 100% | 2011-03-23 | 2012-12-12 | 457d? | finish no earlier than 2012-12-12 | S2 | 3640h | 3640h | OPIIS | PCG-26 | LG Electronics | taehyeon.kim@lge.com | Rel-12 | SP-51 | Maurice |  |  |  |  |  |
| 624 | 184.2 | Stage 2 for Operator Policies for IP Interface Selection | 511d? | 2011-04-04 A | 2013-03-06 A | 100% | 2011-04-04 | 2013-03-06 | 511d? | finish no earlier than 2013-03-06 | S2 | 4088h | 4088h | OPIIS | PCG-26 | LG Electronics | taehyeon.kim@lge.com | Rel-12 | SP-51 | Maurice |  |  |  |  |  |
| 625 | 184.3 | Stage 3 for Operator Policies for IP Interface Selection | 126d? | 2013-06-14 A | 2013-12-06 A | 100% | 2013-06-14 | 2013-12-06 | 126d? | finish no earlier than 2013-12-06 | C1 | 1008h | 1008h | OPIIS-CT | PCG-31 | LG Electronics | Jaehyun Kim (jaehyun7.kim@lge.com) | Rel-12 | CP-60 | Frederic |  |  | OPIIS-CT |  |  |
| 626 | 185 | **Short Message Service (SMS) submit and delivery without MSISDN in IMS** | 665d? | 2011-06-08 A | 2013-12-06 A | 100% | 2011-06-08 | 2013-12-06 | 665d? |  | S2; C1; C4 | 28336.3h | 28336.3h | SMSMI | PCG-27 | Nokia Siemens Networks | curt.wong@nsn.com | Rel-12 | SP-52 | Maurice |  |  | SMSMI |  |  |
| 627 | 185.1 | TR on Stage 2 for SMS submit and delivery without MSISDN in IMS | 402d? | 2011-06-08 A | 2012-12-12 A | 100% | 2011-06-08 | 2012-12-12 | 402d? | finish no earlier than 2012-12-12 | S2 | 3192.32h | 3192.32h | SMSMI-SA2TR | PCG-27 | Nokia Siemens Networks | curt.wong@nsn.com | Rel-12 | SP-52 | Maurice |  |  |  |  |  |
| 628 | 185.2 | Stage 2 for SMS submit and delivery without MSISDN in IMS | 400d? | 2011-06-13 A | 2012-12-12 A | 100% | 2011-06-13 | 2012-12-12 | 400d? | finish no earlier than 2012-12-12 | S2 | 3192h | 3192h | SMSMI-SA2 | PCG-27 | Nokia Siemens Networks | curt.wong@nsn.com | Rel-12 | SP-52 | Maurice |  |  |  |  |  |

Notes:
- 603: SP#60 stopped and Rel-13 FS_ACDC continues. Triggered by TR 22.806 Study on Application specific Congestion control for Data Communication (FS_ACDC) UID_570034 / Impacted TSs and TRs: Stage 1
- 604: SP#60 stopped and Rel-13 FS_ACDC contd. Allow/prohibit for E-UTRAN idle mode UE initiation of particular applications defined by operator and subject to regional regulations. Prevent/mitigate overload of AN/CN defined by operator (congestion or disaster) / Impacted TSs and TRs: 22.011
- 605: SP#59 Stage 1 completed / Impacted TSs and TRs: Stage 1
- 606: SP#59 completed / Impacted TSs and TRs: 22.011
- 607: -
- 608: CP#63 completed. SP#58 updated WID SP-120256=>SP-120926 (stopped BB2 LIMONET-LIPA on Mobility). Linked to UID_450035 Local IP Access and Selected IP Traffic Offload (LIPA_SIPTO) / Impacted TSs and TRs: Stage 2/3
- 609: SP#59 completed. TR 23.859 v100 for Information and Approval / Impacted TSs and TRs: new TR 23.859
- 610: SP#60 completed / Impacted TSs and TRs: 23.060, 23.401
- 611: SP#60 completed / Impacted TSs and TRs: 23.060, 23.401
- 612: CP#63 completed / Impacted TSs and TRs: Stage 3
- 613: CP#61 completed / Impacted TSs and TRs: 23.003, 23.008, 29.002, 29.060, 29.230, 29.272, 29.274, 29.303
- 614: CP#63 completed / Impacted TSs and TRs: 24.008, 24.301
- 615: - / Impacted TSs and TRs: UTRA, LTE
- 616: RP#62 completed / Impacted TSs and TRs: 25.401, 25.413, 25.423, 25.467, 25.469, 36.300, 36.413, 36.423
- 617: SP#58 updated WID SP-120256=>SP-120926 (stopped BB2 LIMONET-LIPA on Mobility) / Impacted TSs and TRs: 23.060, 23.401
- 618: SP#58 updated WID SP-120256=>SP-120926 (stopped BB2 LIMONET-LIPA on Mobility) / Impacted TSs and TRs: 23.060, 23.401
- 619: SP#58 CT Stage 3 part stopped because of SA stopping Stage 2 for BB2 LIMONET-LIPA on Mobility) / Impacted TSs and TRs: Stage 3
- 620: SP#58 CT Stage 3 part stopped because of SA stopping Stage 2 for BB2 LIMONET-LIPA on Mobility) / Impacted TSs and TRs: 24.008, 24.301
- 621: SP#58 CT Stage 3 part stopped because of SA stopping Stage 2 for BB2 LIMONET-LIPA on Mobility) / Impacted TSs and TRs: 29.060, 29.274, 29.281, 29.303, 29.002, 29.272, 29.275, 29.282, 29.305
- 622: Linked to Rel-10 IFOM IP Flow Mobility and seamless WLAN offload (non-seamless WLAN offload aspects) & Rel-11 LIMONET (support traffic offload at local network) / Impacted TSs and TRs: Stage 2/3
- 623: SP#58 completed / Impacted TSs and TRs: new TR 23.853
- 624: SP#59 completed (23.402 CR#152: Introduction of Inter-APN Routing Policies) / Impacted TSs and TRs: 23.402
- 625: CP#62 completed. Specify Inter-APN Routing Policies for selecting an IP interface to route IP flows among a choice of available interfaces in both 3GPP and non-3GPP accesses / Impacted TSs and TRs: 24.302, 24.312
- 626: Linked to Rel-7 SMSIP (Support of SMS over generic 3GPP IP access), Rel-11 SIMTC, Rel-12 TR 22.988 SA1 Study on alternatives to E.164 for MTC / Impacted TSs and TRs: Stage 2/3
- 627: SP#58 completed / Impacted TSs and TRs: new TR 23.863
- 628: SP#58 completed / Impacted TSs and TRs: 23.204, 23.682

| ID | WBS | Task | Duration | Start | Finish | Complete | Remaining | Baseline start | Baseline finish | Baseline duration | Total slack | Constraint | Resources | Work | Actual work | Acronym | PCG approved | Impacted TSs and TRs | WI rapporteur name | WI rapporteur e-mail | Release | TSG approved | MCC resp | Acronym_3GU_Export | Status Report | Special Focus Doc |
| --- | --- | --- | --- | --- | --- | --- | --- | --- | --- | --- | --- | --- | --- | --- | --- | --- | --- | --- | --- | --- | --- | --- | --- | --- | --- | --- |
| 629 | 185.3 | **Stage 3 for SMS submit and delivery without MSISDN in IMS** | 205d? | 2013-03-01 A | 2013-12-06 A | 100% |  | 2013-03-01 | 2013-12-06 | 205d? |  |  | C1; C4 | 5992h | 5992h | SMSMI-CT | PCG-30 | Stage 3 | NSN | peter.leis@nsn.com | Rel-12 | CP-59 | Frederic | SMSMI-CT |  |  |
| 630 | 185.3.1 | CT1 part of Stage 3 for SMS submit and delivery without MSISDN in IMS | 205d? | 2013-03-01 A | 2013-12-06 A | 100% |  | 2013-03-01 | 2013-12-06 | 205d? |  | finish no earlier than 2013-12-06 | C1 | 1608h | 1608h | SMSMI-CT | PCG-30 | 23.040, 24.341 | NSN | peter.leis@nsn.com | Rel-12 | CP-59 | Frederic |  |  |  |
| 631 | 185.3.2 | CT4 part of Stage 3 for SMS submit and delivery without MSISDN in IMS | 139d? | 2013-03-01 A | 2013-09-06 A | 100% |  | 2013-03-01 | 2013-09-06 | 139d? |  | finish no earlier than 2013-09-06 | C4 | 1104h | 1104h | SMSMI-CT | PCG-30 | 23.008, 29.002, 29.305, 29.328, 29.338 | NSN | peter.leis@nsn.com | Rel-12 | CP-59 | Kimmo |  |  |  |
| 632 | 186 | **IMS-based Telepresence** | 1247.5d? | 2010-03-22 A | 2014-12-09 | 66% | 430.02d? | 2010-03-19 | 2014-12-05 | 1243.5d? | 657d |  | S1; C1; C3; C4; IETF | 122882h | 38645.9h | IMS_TELEP | PCG-27 | Stage 1/2/3 | Orange | bruno.tossou@orange-ftgroup.com | Rel-12 | SP-53 | Alain | IMS_TELEP |  |  |
| 633 | 186.1 | Stage 1 for IMS-based Telepresence | 197d? | 2011-09-22 A | 2012-06-20 A | 100% |  | 2011-09-22 | 2012-06-20 | 197d? |  | finish no earlier than 2012-06-08 | S1 | 1569.86h | 1569.86h | IMS_TELEP | PCG-27 | 22.228 | Orange | bruno.tossou@orange-ftgroup.com | Rel-12 | SP-53 | Alain |  |  |  |
| 634 | 186.2 | **CT part for IMS Telepresence (Stage 2/3)** | 1247.5d? | 2010-03-22 A | 2014-12-09 | 64% | 444.19d? | 2010-03-19 | 2014-12-05 | 1243.5d? | 657d |  | C1; C3; C4; IETF | 87712h | 30772h | IMS_TELEP | PCG-30 | Stage 2/3 | Huawei | Weiwei(Tommy) Yang (tommy@huawei.com) | Rel-12 | CP-58 | Frederic |  |  |  |
| 635 | 186.2.1 | TR on CT part of IMS Telepresence (Stage 2/3) | 399d? | 2012-12-07 A | 2014-06-13 A | 100% |  | 2012-12-07 | 2014-06-13 | 399d? |  | finish no earlier than 2014-06-13 | C1 | 3184h | 3184h | IMS_TELEP | PCG-30 | New TR 24.803 | Huawei | Weiwei(Tommy) Yang (tommy@huawei.com) | Rel-12 | CP-58 | Frederic |  |  |  |
| 636 | 186.2.2 | CT1 part of IMS Telepresence (Stage 3) | 526d? | 2012-12-07 A | 2014-12-09 A | 100% |  | 2012-12-07 | 2014-09-12 | 464d? |  | finish no earlier than 2014-12-09 | C1 | 4208h | 4208h | IMS_TELEP | PCG-30 | 24.147, 24.166, 24.229, New TS 24.103 | Huawei | Weiwei(Tommy) Yang (tommy@huawei.com) | Rel-12 | CP-58 | Frederic |  | CP-140616 |  |
| 637 | 186.2.3 | (IETF) CT1 part of IMS Telepresence (mmusic-sctp-sdp) | 851d? | 2010-03-22 A | 2014-12-09 | 50% | 425.5d? | 2010-03-19 | 2014-12-05 | 849d? | 657d | finish no earlier than 2014-12-09 | C1-IETF | 6808h | 3404h | IMS_TELEP | PCG-33 | draft-ietf-mmusic-sctp-sdp | christer.holmberg@ericsson.com | christer.holmberg@ericsson.com | Rel-12 | CP-64 |  |  |  |  |
| 638 | 186.2.4 | (IETF) CT1 part of IMS Telepresence (clue-framework ) | 851d? | 2010-03-22 A | 2014-12-09 | 50% | 425.5d? | 2010-03-19 | 2014-12-05 | 849d? | 657d | finish no earlier than 2014-12-09 | C1-IETF | 6808h | 3404h | IMS_TELEP | PCG-33 | draft-ietf-clue-framework | christer.holmberg@ericsson.com | christer.holmberg@ericsson.com | Rel-12 | CP-64 |  |  |  |  |
| 639 | 186.2.5 | (IETF) CT1 part of IMS Telepresence (clue-datachannel) | 851d? | 2010-03-22 A | 2014-12-09 | 50% | 425.5d? | 2010-03-19 | 2014-12-05 | 849d? | 657d | finish no earlier than 2014-12-09 | C1-IETF | 6808h | 3404h | IMS_TELEP | PCG-33 | draft-ietf-clue-datachannel | christer.holmberg@ericsson.com | christer.holmberg@ericsson.com | Rel-12 | CP-64 |  |  |  |  |
| 640 | 186.2.6 | (IETF) CT1 part of IMS Telepresence (clue-signaling) | 851d? | 2010-03-22 A | 2014-12-09 | 50% | 425.5d? | 2010-03-19 | 2014-12-05 | 849d? | 657d | finish no earlier than 2014-12-09 | C1-IETF | 6808h | 3404h | IMS_TELEP | PCG-33 | draft-ietf-clue-signaling | christer.holmberg@ericsson.com | christer.holmberg@ericsson.com | Rel-12 | CP-64 |  |  |  |  |
| 641 | 186.2.7 | (IETF) CT1 part of IMS Telepresence (clue-data-model-schema) | 851d? | 2010-03-22 A | 2014-12-09 | 50% | 425.5d? | 2010-03-19 | 2014-12-05 | 849d? | 657d | finish no earlier than 2014-12-09 | C1-IETF | 6808h | 3404h | IMS_TELEP | PCG-33 | draft-ietf-clue-data-model-schema | christer.holmberg@ericsson.com | christer.holmberg@ericsson.com | Rel-12 | CP-64 |  |  |  |  |
| 642 | 186.2.8 | CT3 part of IMS Telepresence (Stage 3) | 467d? | 2012-12-07 A | 2014-09-11 A | 100% |  | 2012-12-07 | 2014-09-12 | 467d? |  | finish no earlier than 2014-09-12 | C3 | 3736h | 3736h | IMS_TELEP | PCG-30 | 29.165 | Huawei | Weiwei(Tommy) Yang (tommy@huawei.com) | Rel-12 | CP-58 | Adrian |  |  |  |
| 643 | 186.2.9 | CT4 part of IMS Telepresence (Stage 2/3) | 328d? | 2013-09-13 A | 2014-12-09 A | 100% |  | 2013-09-10 | 2014-09-12 | 266d? |  | finish no earlier than 2014-12-09 | C4 | 2624h | 2624h | IMS_TELEP | PCG-31 | 23.333, 29.333 | Huawei | Weiwei(Tommy) Yang (tommy@huawei.com) | Rel-12 | CP-61 | Kimmo |  | CP-140477 |  |
| 644 | 187 | **Group Communication System Enablers for LTE** | 727d? | 2012-06-18 A | 2015-03-15 | 99% | 0d? | 2012-06-18 | 2014-09-17 | 597d? | 0d |  | S1; S2; S3; C3; C4; R3; C1 | 59744h | 37184h | GCSE_LTE | PCG-29 | Stage 1/2/3 | Nokia Networks | Juergen.Merkel@nsn.com | Rel-12 | SP-56 | Alain | GCSE_LTE |  | Public Safety (A-A) |
| 645 | 187.1 | Stage 1 for Group Communication System Enablers for LTE | 267d? | 2012-06-18 A | 2013-06-19 A | 100% |  | 2012-06-18 | 2013-06-19 | 267d? |  | finish no earlier than 2013-06-19 | S1 | 2128h | 2128h | GCSE_LTE | PCG-29 | New TS 22.468 | Nokia Networks | Juergen.Merkel@nsn.com | Rel-12 | SP-56 | Alain |  |  | Public Safety (A-A) |
| 646 | 187.2 | TR on Architecture enhancements to support Group Communication System Enablers for LTE | 267d? | 2013-03-07 A | 2014-03-07 A | 100% |  | 2013-03-07 | 2014-03-07 | 267d? |  | finish no earlier than 2014-03-07 | S2 | 2128h | 2128h | GCSE_LTE | PCG-30 | New TR 23.768 | Nokia Networks | rainer.liebhart@nsn.com | Rel-12 | SP-59 | Maurice |  |  | Public Safety (A-A) |
| 647 | 187.3 | Stage 2 for Group Communication System Enablers for LTE | 402d? | 2013-03-12 A | 2014-09-16 A | 100% |  | 2013-03-12 | 2014-09-17 | 402d? |  | finish no earlier than 2014-09-17 | S2 | 3208h | 3208h | GCSE_LTE | PCG-30 | New TS 23.468 | Nokia Networks | rainer.liebhart@nsn.com | Rel-12 | SP-59 | Maurice |  |  | Public Safety (A-A) |
| 648 | 187.4 | TR on Security for Group Communication System Enablers for LTE (Stage 2) | 201d? | 2013-09-12 A | 2014-06-18 A | 100% |  | 2013-09-12 | 2014-06-18 | 201d? |  | finish no earlier than 2014-06-18 | S3 | 1608h | 1608h | GCSE_LTE | PCG-31 | New TR 33.888 | Nokia Networks | anja.jerichow@nsn.com | Rel-12 | SP-61 | Mirko |  |  | Public Safety (A-A) |
| 649 | 187.5 | Security for Group Communication System Enablers for LTE (Stage 2) | 201d? | 2013-09-13 A | 2014-06-18 A | 100% |  | 2013-09-13 | 2014-06-18 | 201d? |  | finish no earlier than 2014-06-18 | S3 | 1608h | 1608h | GCSE_LTE | PCG-31 | 33.246 | Nokia Networks | anja.jerichow@nsn.com | Rel-12 | SP-61 | Mirko |  |  | Public Safety (A-A) |
| 650 | 187.6 | **CT aspects of Group Communication System Enablers for LTE** | 131d? | 2014-06-13 A | 2014-12-09 | 100% | 0d? | 2014-06-13 | 2014-09-12 | 66d? | 0d |  | C3; C4; C1 | 5200h | 4152h | GCSE_LTE-CT | PCG-33 | Stage 3 | Nokia Networks | thomas.belling@nsn.com | Rel-12 | CP-64 |  | GCSE_LTE-CT |  | Public Safety (A-A) |
| 651 | 187.6.1 | CT3 part of Group Communication System Enablers for LTE | 66d? | 2014-06-13 A | 2014-09-11 A | 100% |  | 2014-06-13 | 2014-09-12 | 66d? |  | finish no earlier than 2014-09-12 | C3 | 528h | 528h | GCSE_LTE-CT | PCG-33 | 29.212, 29.213, 29.214, 29.274, New TS 29.468 | Nokia Networks | thomas.belling@nsn.com | Rel-12 | CP-64 |  |  |  | Public Safety (A-A) |
| 652 | 187.6.2 | CT4 part of Group Communication System Enablers for LTE | 128d? | 2014-06-13 A | 2014-12-09 A | 100% |  | 2014-06-13 | 2014-09-12 | 66d? |  | finish no earlier than 2014-12-09 | C4 | 1024h | 1024h | GCSE_LTE-CT | PCG-33 | 23.007, 23.008 | Nokia Networks | thomas.belling@nsn.com | Rel-12 | CP-64 |  |  | CP-140725 | Public Safety (A-A) |
| 653 | 187.6.3 | CT1 part of Group Communication System Enablers for LTE | 63d? | 2014-09-12 A | 2014-12-09 A | 100% |  |  |  |  |  | finish no earlier than 2014-12-09 | C1 | 504h | 504h | GCSE_LTE-CT | PCG-33 | 24.301 | Nokia Networks | thomas.belling@nsn.com | Rel-12 | CP-65 |  |  | CP-140614 | Public Safety (A-A) |

Notes:
- 629: CP#62 completed. Address scenario IMS client to IMS client SMS (comprises SMS receive and send SMS without requiring an MSISDN associated as part of their subscription record in HSS
- 630: CP#62 completed
- 631: CP#61 completed
- 632: This feature does not introduce any changes to the IMS architecture, and no stage 2 impacts are identified
- 633: SP#56 completed. 2/4/15: acronym changed to IMS_TELEP
- 634: CP#65 updated WID CP-140196=>CP-140624. 2/4/15: acronym changed to IMS_TELEP
- 635: CP#64 completed. 2/4/15: acronym changed to IMS_TELEP
- 636: CP#65 TS 24.103v100 for Information. Updated WID CP-140196=>CP-140624. Completion 09/14=>12/14. Exception in CP-140616. Dec.14: 90->100%. 2/4/15: acronym changed to IMS_TELEP
- 637: work in progress. 2/4/15: acronym changed to IMS_TELEP
- 638: work in progress. 2/4/15: acronym changed to IMS_TELEP
- 639: work in progress. 2/4/15: acronym changed to IMS_TELEP
- 640: work in progress. 2/4/15: acronym changed to IMS_TELEP
- 641: work in progress. 2/4/15: acronym changed to IMS_TELEP
- 642: CP#65 completed. 2/4/15: acronym changed to IMS_TELEP
- 643: CP#65 updated WID CP-140196=>CP-140624. Completion 09/14=>12/14. Exception in CP-140477. Mar.15: 0->100%. 2/4/15: acronym changed to IMS_TELEP
- 644: Linked to Rel-12 FS_ProSe TR 22.803 Study on Proximity-based Services. External requirements: NIST, MESA, APCO Global Alliance, TCCA. Specify 3GPP system enablers to support group communication over LTE for Public Safety
- 645: SP#60 completed. TS 22.468 v100 for 1-step Approval
- 646: SP#63 completed. TR 23.768v200 for Approval
- 647: SP#65 completed. Updated WID SP-140113=>SP-140433. SP#63 TS 23.468v100 for 1-step Approval
- 648: SP#64 completed. TR 33.888v100 for 1-step Approval
- 649: SP#64 completed
- 650: CP#65 updated WID CP-140452=>C3-143199 (added CT1 part)
- 651: CP#65 completed. TS 29.468v200 for Approval
- 652: CP#65 completion 09/14=>12/14. Exception in CP-140725. Dec.14: 35->100
- 653: CP#65 updated WID CP-140452=>CP-140559 (added CT1 part). Exception in CP-140614. Dec.14: 90->100%

| ID | WBS | Task | Duration | Start | Finish | Complete | Remaining | Baseline start | Baseline finish | Baseline duration | Total slack | Constraint | Resources | Work | Actual work | Acronym | PCG approved | Impacted TSs and TRs | WI rapporteur name | WI rapporteur e-mail | Release | TSG approved | Special Focus Doc | Acronym_3GU_Export | Status Report | MCC resp | PCG stopped | TSG stopped |
| --- | --- | --- | --- | --- | --- | --- | --- | --- | --- | --- | --- | --- | --- | --- | --- | --- | --- | --- | --- | --- | --- | --- | --- | --- | --- | --- | --- | --- |
| 654 | 187.7 | **Group Call eMBMS congestion management for LTE** | 198d? | 2014-06-16 A | 2015-03-15 A | 100% |  | 2014-06-13 | 2014-09-12 | 66d? |  |  | R3 | 3152h | 3152h | GCSE_LTE-MBMS_CM | PCG-33 | LTE | Alcatel-Lucent | hakon.helmers@alcatel-lucent.com | Rel-12 | RP-64 | Public Safety (A-A) | GCSE_LTE-MBMS_CM |  |  |  |  |
| 655 | 187.7.1 | Core part: Group Call eMBMS congestion management for LTE | 196d? | 2014-06-16 A | 2015-03-15 A | 100% |  | 2014-06-13 | 2014-09-12 | 66d? |  | finish no earlier than 2015-03-15 | R3 | 1568h | 1568h | GCSE_LTE-MBMS_CM-Core | PCG-33 | 36.413 | Alcatel-Lucent | hakon.helmers@alcatel-lucent.com | Rel-12 | RP-64 | Public Safety (A-A) | GCSE_LTE-MBMS_CM-Core | RP-150081 |  |  |  |
| 656 | 188 | **Machine-Type and other mobile data applications Communications enhancements** | 1320d? | 2009-12-10 A | 2014-12-09 | 99% | 7.35d? | 2009-12-10 | 2014-09-12 | 1255d? | 657d |  | S2; S1; S3; C1; C3; C4; C6; R2; R3; G1 | 180632h | 179281h | MTCe | PCG-29 | Stage 1/2/3 | Intel | puneet.jain@intel.com | Rel-12 | SP-56 | MTC, M2M | MTCe |  | Maurice |  |  |
| 657 | 188.1 | Stage 1 for Support for Interworking with M2M Service Enablement | 189d? | 2012-06-18 A | 2013-03-06 A | 100% |  | 2012-06-18 | 2013-03-06 | 189d? |  | finish no earlier than 2013-03-06 | S1 | 1504h | 1504h | MTCe-SIMSE | PCG-29 | 22.368 | KPN | toon.norp@tno.nl | Rel-12 | SP-56 | MTC, M2M | MTCe-SIMSE |  | Alain |  |  |
| 658 | 188.2 | Stage 1 for Machine-Type and other mobile data applications Communications – Service Requirement Maintenance | 127d? | 2012-09-13 A | 2013-03-06 A | 100% |  | 2012-09-13 | 2013-03-06 | 127d? |  | finish no earlier than 2013-03-06 | S1 | 1008h | 1008h | MTCe-SRM | PCG-29 | 22.101, 22.368 | KPN | toon.norp@tno.nl | Rel-12 | SP-57 | MTC, M2M | MTCe-SRM |  | Alain |  |  |
| 659 | 188.3 | TR on Security aspects of Machine-Type Communications | 1113d? | 2009-12-10 A | 2014-03-07 A | 100% |  | 2009-12-10 | 2014-03-07 | 1113d? |  | finish no earlier than 2014-03-07 | S3 | 8896h | 8896h | MTCe-SA3TR | PCG-29 | New TR 33.868 | Samsung | Rajavelsamy R (rajvel@samsung.com) | Rel-12 | SP-56 | MTC, M2M |  |  | Mirko |  |  |
| 660 | 188.4 | Security and Privacy aspects for Machine-Type and other mobile data applications Communications enhancements (Stage 2) | 452d? | 2012-06-22 A | 2014-03-07 A | 100% |  | 2012-06-22 | 2014-03-07 | 452d? |  | finish no earlier than 2014-03-07 | S3 | 3608h | 3608h | MTCe-SA3 | PCG-29 | New TS 33.187 | Samsung | Rajavelsamy R (rajvel@samsung.com) | Rel-12 | SP-56 | MTC, M2M |  |  | Mirko |  |  |
| 661 | 188.5 | **BB1: Small Data and Device Triggering Enhancements (SDDTE)** | 594d? | 2012-06-18 A | 2014-09-11 A | 100% |  | 2012-06-18 | 2014-09-12 | 594d? |  |  | S2; C4; C3 | 24400h | 24400h | MTCe-SDDTE | PCG-29 |  | Intel | puneet.jain@intel.com | Rel-12 | SP-56 | MTC, M2M | MTCe-SDDTE |  | Maurice |  |  |
| 662 | 188.5.1 | TR on Stage 2 BB1: Small Data and Device Triggering Enhancements | 394d? | 2012-06-18 A | 2013-12-11 A | 100% |  | 2012-06-18 | 2013-12-11 | 394d? |  | finish no earlier than 2013-12-11 | S2 | 3128h | 3128h | MTCe-SDDTE | PCG-29 | New TR 23.887 | Intel | puneet.jain@intel.com | Rel-12 | SP-56 | MTC, M2M |  |  | Maurice |  |  |
| 663 | 188.5.2 | Stage 2 for BB1: Small Data and Device Triggering Enhancements | 390d? | 2012-06-26 A | 2013-12-11 A | 100% |  | 2012-06-26 | 2013-12-11 | 390d? |  | finish no earlier than 2013-12-11 | S2 | 3120h | 3120h | MTCe-SDDTE | PCG-29 | 23.682 | Intel | puneet.jain@intel.com | Rel-12 | SP-56 | MTC, M2M |  |  | Maurice |  |  |
| 664 | 188.5.3 | **Stage 3 for BB1: Small Data and Device Triggering Enhancements** | 138d? | 2014-03-05 A | 2014-09-11 A | 100% |  | 2014-03-05 | 2014-09-12 | 138d? |  |  | C4; C3 | 3896h | 3896h | MTCe-SDDTE-CT | PCG-32 | Stage 3 | Huawei | peter.schmitt@huawei.com | Rel-12 | CP-63 | MTC, M2M | MTCe-SDDTE-CT |  | Kimmo |  |  |
| 665 | 188.5.3.1 | CT4 part of Stage 3 for BB1: Small Data and Device Triggering Enhancement | 138d? | 2014-03-05 A | 2014-09-11 A | 100% |  | 2014-03-05 | 2014-09-12 | 138d? |  | finish no earlier than 2014-09-12 | C4 | 1104h | 1104h | MTCe-SDDTE-CT | PCG-32 | 29.002, 29.336, 23.008, 29.337, 29.338, 29.230 | Huawei | peter.schmitt@huawei.com | Rel-12 | CP-63 | MTC, M2M |  |  | Kimmo |  |  |
| 666 | 188.5.3.2 | CT3 part of Stage 3 for BB1: Small Data and Device Triggering Enhancement | 73d? | 2014-03-05 A | 2014-06-13 A | 100% |  | 2014-03-05 | 2014-06-13 | 73d? |  | finish no earlier than 2014-06-13 | C3 | 584h | 584h | MTCe-SDDTE-CT | PCG-32 | 29.368 | Huawei | peter.schmitt@huawei.com | Rel-12 | CP-63 | MTC, M2M |  |  | Adrian |  |  |
| 667 | 188.6 | Deleted - BB2: Monitoring Enhancements (MONTE) | 131d? | 2012-06-18 A | 2012-12-12 A | 100% |  | 2012-06-18 | 2012-12-12 | 131d? |  | finish no earlier than 2012-12-12 | S2 | 1048h | 1048h | MTCe-MONTE | PCG-29 | 23.682 | Intel | puneet.jain@intel.com | Rel-12 | SP-56 | MTC, M2M | MTCe-MONTE |  | Maurice | PCG-30 | SP-58 |
| 668 | 188.7 | **BB3: UE Power Consumptions Optimizations (UEPCOP)** | 659d? | 2012-06-18 A | 2014-12-09 | 98% | 11.91d? | 2012-06-18 | 2014-09-12 | 594d? | 657d |  | S2; C1; C4; C6; G1 | 36221.3h | 35422.5h | MTCe-UEPCOP | PCG-29 |  | Ericsson | peter.hedman@ericsson.com | Rel-12 | SP-56 | MTC, M2M | MTCe-UEPCOP |  | Maurice |  |  |
| 669 | 188.7.1 | TR on Stage 2 BB3: UE Power Consumptions Optimizations (UEPCOP) | 394d? | 2012-06-18 A | 2013-12-11 A | 100% |  | 2012-06-18 | 2013-12-11 | 394d? |  | finish no earlier than 2013-12-11 | S2 | 3128h | 3128h | MTCe-UEPCOP | PCG-29 | New TR 23.887 | Ericsson | peter.hedman@ericsson.com | Rel-12 | SP-56 | MTC, M2M |  |  | Maurice |  |  |
| 670 | 188.7.2 | Stage 2 for BB3: UE Power Consumptions Optimizations (UEPCOP) | 390d? | 2012-06-26 A | 2013-12-11 A | 100% |  | 2012-06-26 | 2013-12-11 | 390d? |  | finish no earlier than 2013-12-11 | S2 | 3120h | 3120h | MTCe-UEPCOP | PCG-29 | 23.060, 23.401, 23.682 | Ericsson | peter.hedman@ericsson.com | Rel-12 | SP-56 | MTC, M2M |  |  | Maurice |  |  |
| 671 | 188.7.3 | **Stage 3 for BB3: UE Power Consumptions Optimizations (UEPCOP)** | 267d? | 2013-12-06 A | 2014-12-09 | 96% | 10.54d? | 2013-12-06 | 2014-09-12 | 202d? | 657d |  | C1; C4; C6 | 11728h | 11264.6h | MTCe-UEPCOP-CT | PCG-32 | Stage 3 | Ericsson | mikael.wass@ericsson.com | Rel-12 | CP-62 | MTC, M2M | MTCe-UEPCOP-CT |  | Frederic |  |  |
| 672 | 188.7.3.1 | CT1 part of Stage 3 for BB3: UE Power Consumptions Optimizations (UEPCOP) | 202d? | 2013-12-06 A | 2014-09-11 A | 100% |  | 2013-12-06 | 2014-09-12 | 202d? |  | finish no earlier than 2014-09-12 | C1 | 1608h | 1608h | MTCe-UEPCOP-CT1 | PCG-32 | 24.008, 24.301 | Ericsson | mikael.wass@ericsson.com | Rel-12 | CP-62 | MTC, M2M |  |  | Frederic |  |  |
| 673 | 188.7.3.2 | Deleted - CT4 part of Stage 3 for BB3: UE Power Consumptions Optimizations (UEPCOP) | 201d? | 2013-12-09 A | 2014-09-11 A | 100% |  | 2013-12-09 | 2014-09-12 | 201d? |  | finish no earlier than 2014-09-12 | C4 | 1608h | 1608h | MTCe-UEPCOP-CT4 | PCG-32 | 29.274, 29.060, 23.008 | Ericsson | mikael.wass@ericsson.com | Rel-12 | CP-62 | MTC, M2M |  |  | Kimmo | PCG-33 | CP-65 |
| 674 | 188.7.3.3 | CT6 part of Stage 3 for BB3: UE Power Consumptions Optimizations (UEPCOP) | 263d? | 2013-12-09 A | 2014-12-09 | 90% | 26.3d? | 2013-12-09 | 2014-09-12 | 201d? | 657d | finish no earlier than 2014-12-09 | C6 | 2104h | 1893.6h | MTCe-UEPCOP-CT6 | PCG-32 | 31.101, 31.102, 31.111 | Ericsson | mikael.wass@ericsson.com | Rel-12 | CP-62 | MTC, M2M |  | CP-140697 | Xavier |  |  |
| 675 | 188.7.4 | Support of Power Saving Mode in GERAN | 5d? | 2014-08-25 A | 2014-08-29 A | 100% |  |  |  |  |  | finish no earlier than 2014-08-29 | G1 | 40h | 40h | MTCe-UEPCOP-GERAN | PCG-33 | 43.022 | Ericsson | sajal.kumar.das@ericsson.com | Rel-12 | GP-63 |  | MTCe-UEPCOP-GERAN |  |  |  |  |
| 676 | 188.8 | Deleted - BB4: Group based MTC feature (GROUP) | 129d? | 2012-06-20 A | 2012-12-12 A | 100% |  | 2012-06-20 | 2012-12-12 | 129d? |  | finish no earlier than 2012-12-12 | S2 | 1032h | 1032h | MTCe-GROUP | PCG-29 | 23.682 | KPN | Annemieke Kips | Rel-12 | SP-56 | MTC, M2M | MTCe-GROUP |  | Maurice | PCG-30 | SP-58 |
| 677 | 188.9 | **RAN enhancements for Machine-Type and other mobile data applications Communications** | 161.2d? | 2014-02-03 A | 2014-09-12 A | 100% |  | 2014-02-03 | 2014-09-12 | 160.2d? |  |  | R2; R3 | 3651h | 3651h | MTCe-RAN | PCG-32 | UTRA, LTE | ZTE | sergio.parolari@zte.com.cn | Rel-12 | RP-62 | MTC, M2M | MTCe-RAN |  | Yong-Jun |  |  |
| 678 | 188.9.1 | Core part: RAN enhancements for Machine-Type and other mobile data applications Communications | 133d? | 2014-02-03 A | 2014-09-12 A | 100% |  | 2014-02-03 | 2014-09-12 | 133d? |  | finish no earlier than 2014-09-12 | R2; R3 | 2128h | 2128h | MTCe-RAN-Core | PCG-32 | 25.300, 25.304, 25.413, 36.300, 36.304, 36.413, 36.423 | ZTE | sergio.parolari@zte.com.cn | Rel-12 | RP-62 | MTC, M2M | MTCe-RAN-Core | RP-141096 | Yong-Jun |  |  |

Notes:
- 654: -
- 655: CD:Thu 11/12/14->Sun 15/03/15; Compl:25%->80%; Stat Rep: RP-141327->RP-141863 1st Apr 15: Compl:80%->100% 1st Apr 15: Stat Rep: RP-141863->RP-150081
- 656: -
- 657: SP#59 completed. Define requirements for interworking with M2M service enablement layer specified by ETSI TC M2M in TS 102 689 ( specification for Service Enablement layer)
- 658: SP#59 completed. Updated WID SP-120541=>SP-130105
- 659: SP#63 completed. TR 33.868v100 for 1-step Approval. Was Rel-10 UID_460023 (Security for NIMTC). Was Rel-11 UID_490028 (TR on Security aspects of MTC). SP#56 activity transferred to Rel-12 Feature MTCe
- 660: SP#63 completed. TS 33.187v100 for 1-step Approval
- 661: -
- 662: SP#62 completed. TR 23.887v200 for Approval
- 663: SP#62 completed
- 664: CP#65 updated WID CP-140272=>CP-140489
- 665: CP#65 completed. Updated WID CP-140272=>CP-140489
- 666: CP#64 completed
- 667: SP#58 stopped (at 20% completion)
- 668: -
- 669: SP#62 completed. TR 23.887v200 for Approval
- 670: SP#62 completed
- 671: -
- 672: CP#65 completed
- 673: CP#65 stopped (no inpact on CT4)
- 674: CP#65 completion 09/14=>12/14. Exception in CP-140697
- 675: GP#63 approved WID and completed
- 676: SP#58 stopped (at 25% completion)
- 677: Triggered by TR 23.887 Machine Type and other mobile data applications Communications Enhancements (MTCe), TR 37.869 Study on Enhancements MTC and other Mobile Data Applications; RAN aspects (FS_MTCe_RAN), Rel-11 TR 23.888 SIMTC
- 678: RP#65 completed

| ID | WBS | Task | Duration | Start | Finish | Complete | Baseline start | Baseline finish | Baseline duration | Constraint | Resources | Work | Actual work | Acronym | PCG approved | Impacted TSs and TRs | WI rapporteur name | WI rapporteur e-mail | Release | TSG approved | MCC resp | Acronym_3GU_Export | Special Focus Doc | PCG stopped | TSG stopped | Status Report |
| --- | --- | --- | --- | --- | --- | --- | --- | --- | --- | --- | --- | --- | --- | --- | --- | --- | --- | --- | --- | --- | --- | --- | --- | --- | --- | --- |
| 679 | 189 | **Policy and Charging Control for supporting fixed broadband access networks** | 660d? | 2012-06-20 A | 2014-12-12 A | 100% | 2012-06-20 | 2014-09-17 | 595d? |  | S2; S1; S5; C3; C1; C4 | 84075.4h | 84075.4h | P4C | PCG-29 | Stage 1/2/3 | Huawei | marco.spini@huawei.com | Rel-12 | SP-56 | Maurice | P4C |  |  |  |  |
| 680 | 189.1 | Stage 1 for Policy and Charging Support for Fixed Mobile Convergence | 3d? | 2012-09-10 A | 2012-09-12 A | 100% | 2012-09-10 | 2012-09-12 | 3d? | finish no earlier than 2012-09-12 | S1 | 24h | 24h | P4C-FMC | PCG-29 | 22.278 | Huawei | amar.deol@huawei.com | Rel-12 | SP-57 | Alain | P4C-FMC |  |  |  |  |
| 681 | 189.2 | **BB1: Policy and Charging Control for supporting traffic from fixed terminals and NSWO (Non Seamless WLAN Offload) traffic from 3GPP UEs in fixed broadband access networks (P4C-F)** | 660d? | 2012-06-20 A | 2014-12-12 A | 100% | 2012-06-20 | 2014-09-17 | 595d? |  | S2; S5; C3; C1; C4 | 45657.3h | 45657.3h | P4C-F | PCG-29 |  | Huawei | marco.spini@huawei.com | Rel-12 | SP-56 | Maurice | P4C-F | WLAN |  |  |  |
| 682 | 189.2.1 | TR on Stage 2 for BB1: Policy and Charging Control for supporting traffic from fixed terminals and NSWO traffic from 3GPP UEs in fixed broadband access networks (P4C-F) | 539.9d? | 2012-06-20 A | 2014-12-12 A | 100% | 2012-06-20 | 2014-09-17 | 476.9d? | finish no earlier than 2014-12-12 | S2 | 4290.1h | 4290.1h | P4C-F-SA2TR | PCG-29 | new TR 23.896 | Huawei | marco.spini@huawei.com | Rel-12 | SP-56 | Maurice |  | WLAN |  |  |  |
| 683 | 189.2.2 | Stage 2 for BB1: Policy and Charging Control for supporting traffic from fixed terminals and NSWO traffic from 3GPP UEs in fixed broadband access networks (P4C-F) | 272.9d? | 2012-06-20 A | 2013-12-11 A | 100% | 2012-06-20 | 2013-12-11 | 272.9d? | finish no earlier than 2013-12-11 | S2 | 2183.2h | 2183.2h | P4C-F-SA2 | PCG-29 | 23.139, 23.203 | Huawei | marco.spini@huawei.com | Rel-12 | SP-56 | Maurice |  | WLAN |  |  |  |
| 684 | 189.2.3 | **Stage 3 for BB1: Policy and Charging Control for supporting traffic from fixed terminals and NSWO traffic from 3GPP UEs in fixed broadband access networks** | 203d? | 2013-09-06 A | 2014-06-13 A | 100% | 2013-09-06 | 2014-06-13 | 203d? |  | C3; C1; C4 | 8088h | 8088h | P4C-F-CT3 | PCG-31 | Stage 3 | Huawei | Xia Haitao (xiahaitao@huawei.com) | Rel-12 | CP-61 | Adrian | P4C-F-CT3 | WLAN |  |  |  |
| 685 | 189.2.3.1 | CT3 part of Stage 3 for BB1: Policy and Charging Control for supporting traffic from fixed terminals and NSWO traffic from 3GPP UEs in fixed broadband access networks | 203d? | 2013-09-06 A | 2014-06-13 A | 100% | 2013-09-06 | 2014-06-13 | 203d? | finish no earlier than 2014-06-13 | C3 | 1608h | 1608h | P4C-F-CT3 | PCG-31 | 29.212, 29.213, 29.215, 29.219 | Huawei | Xia Haitao (xiahaitao@huawei.com) | Rel-12 | CP-61 | Adrian |  | WLAN |  |  |  |
| 686 | 189.2.3.2 | CT1 part of Stage 3 for BB1: Policy and Charging Control for supporting traffic from fixed terminals and NSWO traffic from 3GPP UEs in fixed broadband access networks | 65d? | 2013-12-06 A | 2014-03-05 A | 100% | 2013-12-06 | 2014-03-05 | 65d? | finish no earlier than 2014-03-05 | C1 | 512h | 512h | P4C-F-CT3 | PCG-32 | 24.302 | Huawei | Xia Haitao (xiahaitao@huawei.com) | Rel-12 | CP-62 | Frederic |  | WLAN |  |  |  |
| 687 | 189.2.3.3 | CT4 part of Stage 3 for BB1: Policy and Charging Control for supporting traffic from fixed terminals and NSWO traffic from 3GPP UEs in fixed broadband access networks | 137d? | 2013-12-06 A | 2014-06-13 A | 100% | 2013-12-06 | 2014-06-13 | 137d? | finish no earlier than 2014-06-13 | C4 | 1096h | 1096h | P4C-F-CT3 | PCG-32 | 29.273 | Huawei | Xia Haitao (xiahaitao@huawei.com) | Rel-12 | CP-62 | Kimmo |  | WLAN |  |  |  |
| 688 | 189.2.4 | Policy and Charging Enforcement Function (PCEF) based Charging for traffic from fixed terminals and NSWO traffic from 3GPP UEs in fixed broadband access networks (Stage 2/3) | 326d? | 2013-06-21 A | 2014-09-17 A | 100% | 2013-06-21 | 2014-09-17 | 326d? | finish no earlier than 2014-09-17 | S5 | 2608h | 2608h | P4C-F-CH_P | PCG-31 | Stage 2 (32.240, 32.251), Stage 3 (32.298, 32.299) | Alcatel-Lucent | maryse.gardella@alcatel-lucent.com | Rel-12 | SP-60 | Mirko | P4C-F-CH_P | WLAN |  |  |  |
| 689 | 189.2.5 | Traffic Detection Function (TDF) based Charging for traffic from fixed terminals and NSWO traffic from 3GPP UEs in fixed broadband access networks (Stage 2/3) | 261d? | 2013-06-24 A | 2014-06-18 A | 100% | 2013-06-24 | 2014-06-18 | 261d? | finish no earlier than 2014-06-18 | S5 | 2088h | 2088h | P4C-F-CH_T | PCG-31 | Stage 2 (32.240, 32.251), Stage 3 (32.298, 32.299) | Openet Telecom | alan.mcnamee@openet.com | Rel-12 | SP-60 | Mirko | P4C-F-CH_T | WLAN |  |  |  |
| 690 | 189.3 | **BB2: Policy and Charging Control for 3GPP UEs connected to BroadBand Forum access network as Trusted network in Interworking scenario (P4C-TI)** | 266d? | 2012-06-20 A | 2013-06-19 A | 100% | 2012-06-20 | 2013-06-19 | 266d? |  | S2 | 2610.07h | 2610.07h | P4C-TI | PCG-29 |  | Alcatel-Lucent | konstantin.livanos@alcatel-lucent.com | Rel-12 | SP-56 | Maurice | P4C-TI |  |  |  |  |
| 691 | 189.3.1 | TR on Stage 2 for BB2: Policy and Charging Control for 3GPP UEs connected to BroadBand Forum access network as Trusted network in Interworking scenario (P4C-TI) | 109.2d? | 2012-06-20 A | 2013-06-19 A | 100% | 2012-06-20 | 2013-06-19 | 109.2d? | finish no earlier than 2013-06-06 | S2 | 862.87h | 862.87h | P4C-TI-SA2TR | PCG-29 | new TR 23.839 | Alcatel-Lucent | konstantin.livanos@alcatel-lucent.com | Rel-12 | SP-56 | Maurice |  |  |  |  |  |
| 692 | 189.3.2 | Stage 2 for BB2: Policy and Charging Control for 3GPP UEs connected to BroadBand Forum access network as Trusted network in Interworking scenario (P4C-TI) | 109.2d? | 2012-06-20 A | 2013-06-19 A | 100% | 2012-06-20 | 2013-06-19 | 109.2d? | finish no earlier than 2013-06-19 | S2 | 873.6h | 873.6h | P4C-TI-SA2 | PCG-29 | 23.139, 23.203 | Alcatel-Lucent | konstantin.livanos@alcatel-lucent.com | Rel-12 | SP-56 | Maurice |  |  |  |  |  |
| 693 | 189.4 | Deleted - BB3: Policy and Charging Control for 3GPP UEs connected to fixed broadband access network via S2b and S2c reference points for EPC routed traffic (P4C-S2bc) | 128d? | 2012-06-21 A | 2012-12-12 A | 100% | 2012-06-21 | 2012-12-12 | 128d? | finish no earlier than 2012-12-12 | S2 | 1024h | 1024h | P4C-S2bc | PCG-29 | 23.139, 23.203, new TR 23.896 | ZTE | Tricci So (tso@zteusa.com) | Rel-12 | SP-56 | Maurice | P4C-S2bc |  | PCG-30 | SP-58 |  |
| 694 | 189.5 | Deleted - BB4: Policy and Charging Control for EPC routed traffic over fixed broadband access networks of 3GPP UEs connected via H(e)NB in convergent scenarios (P4C-HeNB) | 128d? | 2012-06-21 A | 2012-12-12 A | 100% | 2012-06-21 | 2012-12-12 | 128d? | finish no earlier than 2012-12-12 | S2 | 1024h | 1024h | P4C-HeNB | PCG-29 | 23.139, 23.203, new TR 23.896 | NEC | Stefan.Schmid@neclab.eu | Rel-12 | SP-56 | Maurice | P4C-HeNB |  | PCG-30 | SP-58 |  |
| 695 | 189.6 | Deleted - BB5: Policy and Charging Control for supporting Layer 2 traffic in fixed broadband access network (P4C-FL2) | 128d? | 2012-06-21 A | 2012-12-12 A | 100% | 2012-06-21 | 2012-12-12 | 128d? | finish no earlier than 2012-12-12 | S2 | 1024h | 1024h | P4C-FL2 | PCG-29 | 23.139, 23.203, new TR 23.896 | Huawei | marco.spini@huawei.com | Rel-12 | SP-56 | Maurice | P4C-FL2 |  | PCG-30 | SP-58 |  |
| 696 | 189.7 | Deleted - BB6: Policy and Charging Control for 3GPP UEs connected to fixed broadband access networks via S2a reference point for EPC routed traffic in convergence (P4C-TC) | 129d? | 2012-06-20 A | 2012-12-12 A | 100% | 2012-06-20 | 2012-12-12 | 129d? | finish no earlier than 2012-12-12 | S2 | 1032h | 1032h | P4C-TC | PCG-29 | 23.139, 23.203, new TR 23.896 | ZTE | Tricci So (tso@zteusa.com) | Rel-12 | SP-56 | Maurice | P4C-TC |  | PCG-30 | SP-58 |  |
| 697 | 190 | **IMS Business Trunking for IP-PBX in Static Mode of Operation** | 847.1d? | 2011-09-28 A | 2014-12-09 A | 100% | 2011-09-28 | 2014-09-12 | 782.1d? |  | S2; S1; C1; C3 | 43555.2h | 43555.2h | BusTI | PCG-29 | Stage 1/2/3 | Deutsche Telekom | michele.zarri@telekom.com | Rel-12 | SP-56 | Maurice | BusTI |  |  |  |  |
| 698 | 190.1 | Stage 1 for IMS Business Trunking for IP-PBX in Static Mode of Operation | 64d? | 2011-09-28 A | 2012-09-12 A | 100% | 2011-09-28 | 2012-09-12 | 64d? | finish no earlier than 2012-08-30 | S1 | 504h | 504h | BusTI-SA1 | PCG-29 | 22.228 | Deutsche Telekom | kurt.bischinger@t-mobile.at | Rel-12 | SP-56 | Alain |  |  |  |  |  |
| 699 | 190.2 | TR on IMS Business Trunking for IP-PBX in Static Mode of Operation | 268d? | 2012-06-18 A | 2013-06-19 A | 100% | 2012-06-18 | 2013-06-19 | 268d? | finish no earlier than 2013-06-19 | S2; S1 | 4288h | 4288h | BusTI-SATR | PCG-29 | new TR 23.897 | Deutsche Telekom | michele.zarri@telekom.com | Rel-12 | SP-56 | Maurice |  |  |  |  |  |
| 700 | 190.3 | Stage 2 for IMS Business Trunking for IP-PBX in Static Mode of Operation | 263d? | 2012-06-25 A | 2013-06-19 A | 100% | 2012-06-25 | 2013-06-19 | 263d? | finish no earlier than 2013-06-19 | S2 | 2104h | 2104h | BusTI-SA2 | PCG-29 | 23.228 | Deutsche Telekom | michele.zarri@telekom.com | Rel-12 | SP-56 | Maurice |  |  |  |  |  |
| 701 | 190.4 | **CT aspects of IMS Business Trunking for IP-PBX in Static Mode of Operation (Stage 3)** | 333d? | 2013-09-06 A | 2014-12-09 A | 100% | 2013-09-06 | 2014-09-12 | 268d? |  | C1; C3 | 9552h | 9552h | BusTI-CT | PCG-31 | Stage 3 | Deutsche Telekom | michael.kreipl@telekom.de | Rel-12 | CP-61 | Frederic | BusTI-CT |  |  |  |  |
| 702 | 190.4.1 | CT1 part of CT aspects of IMS Business Trunking for IP-PBX in Static Mode of Operation (Stage 3) | 329d? | 2013-09-06 A | 2014-12-09 A | 100% | 2013-09-06 | 2014-09-12 | 267d? | finish no earlier than 2014-12-09 | C1 | 2632h | 2632h | BusTI-CT | PCG-31 | 23.218, 24.229, 24.525 (transfer of ETSI TS 182 025) | Deutsche Telekom | michael.kreipl@telekom.de | Rel-12 | CP-61 | Frederic |  |  |  |  | CP-140607 |
| 703 | 190.4.2 | CT3 part of CT aspects of IMS Business Trunking for IP-PBX in Static Mode of Operation (Stage 3) | 201d? | 2013-09-06 A | 2014-06-11 A | 100% | 2013-09-06 | 2014-06-13 | 201d? | finish no earlier than 2014-06-13 | C3 | 1608h | 1608h | BusTI-CT | PCG-31 | 29.165 | Deutsche Telekom | michael.kreipl@telekom.de | Rel-12 | CP-61 | Adrian |  |  |  |  |  |

Notes:
- 679: Linked to BBF, IETF work. SP#58 stopped BB3 to BB6. Split BB1 and BB2 into TR and Stage 2 work
- 680: SP#57 completed
- 681: -
- 682: SP#64 TR 23.896 was never sent for approval due to incomplete P4C BBs. SP#61 TR 23.896v100 for Information. Dec.14: 90->100%. Mar15: 23.896 for approval.
- 683: SP#62 completed
- 684: -
- 685: CP#64 completed
- 686: CP#63 completed
- 687: CP#64 completed
- 688: SP#65 completed. Introduce Charging Characteristics in Convergent scenario, Include missing fixed user location information for NSWO
- 689: SP#64 completed
- 690: -
- 691: SP#60 completed
- 692: SP#60 completed
- 693: SP#58 stopped (at 0% completion)
- 694: SP#58 stopped (at 0% completion)
- 695: SP#58 stopped (at 0% completion)
- 696: SP#58 stopped (at 30% completion)
- 697: Linked to Rel-11 IPXS Feature UID_470051 Advanced IP Interconnection of Services. This WI defines a generic framework for interconnecting with any type of IMS based network including IP-PBXs.
- 698: SP#57 completed. 22.228CR#0171
- 699: SP#60 completed
- 700: SP#60 completed
- 701: -
- 702: CP#65 completion 09/14=>12/14. Exception in CP-140607. Dec.14: 85->100%
- 703: CP#64 completed

| ID | WBS | Task | Duration | Start | Finish | Complete | Remaining | Baseline start | Baseline finish | Baseline duration | Total slack | Constraint | Resources | Work | Actual work | Acronym | PCG approved | Impacted TSs and TRs | WI rapporteur name | WI rapporteur e-mail | Release | TSG approved | MCC resp | Special Focus Doc | Acronym_3GU_Export | PCG stopped | TSG stopped | Status Report |
| --- | --- | --- | --- | --- | --- | --- | --- | --- | --- | --- | --- | --- | --- | --- | --- | --- | --- | --- | --- | --- | --- | --- | --- | --- | --- | --- | --- | --- |
| 704 | 191 | **WLAN Network Selection for 3GPP Terminals** | 659d? | 2012-06-18 A | 2014-12-09 A | 100% |  | 2012-06-18 | 2014-09-12 | 594d? |  |  | S2; S1; S3; C1 | 35272h | 35272h | WLAN_NS | PCG-29 | Stage 1/2/3 | Intel | vivek.g.gupta@intel.com | Rel-12 | SP-56 | Maurice | WLAN | WLAN_NS |  |  |  |
| 705 | 191.1 | TR on Stage 2 for WLAN Network Selection for 3GPP Terminals | 396d? | 2012-06-18 A | 2013-12-11 A | 100% |  | 2012-06-18 | 2013-12-11 | 396d? |  | finish no earlier than 2013-12-11 | S2; S1 | 6336h | 6336h | WLAN_NS-SATR | PCG-29 | New TR 23.865 | Intel | vivek.g.gupta@intel.com | Rel-12 | SP-56 | Maurice | WLAN |  |  |  |  |
| 706 | 191.2 | Stage 2 for WLAN Network Selection for 3GPP Terminals | 392d? | 2012-06-22 A | 2013-12-11 A | 100% |  | 2012-06-22 | 2013-12-11 | 392d? |  | finish no earlier than 2013-12-11 | S2 | 3136h | 3136h | WLAN_NS-SA2 | PCG-29 | 23.402, 23.865 | Intel | vivek.g.gupta@intel.com | Rel-12 | SP-56 | Maurice | WLAN |  |  |  |  |
| 707 | 191.3 | Deleted - TR on Security Aspects of WLAN Network Selection for 3GPP Terminals | 326d? | 2012-12-13 A | 2014-03-07 A | 100% |  | 2012-12-13 | 2014-03-07 | 326d? |  | finish no earlier than 2014-03-07 | S3 | 2608h | 2608h | WLAN_Nsdel | PCG-30 | New TR 33.865 | Huawei | Lydia Xu (xuyixian@huawei.com) | Rel-12 | SP-58 | Mirko | WLAN |  | PCG-32 | CP-63 |  |
| 708 | 191.4 | CT aspects of WLAN Network Selection for 3GPP Terminals (Stage 3) | 263d? | 2013-12-06 A | 2014-12-09 A | 100% |  | 2013-12-06 | 2014-09-12 | 201d? |  | finish no earlier than 2014-12-09 | C1 | 2104h | 2104h | WLAN_NS-CT | PCG-32 | 24.302, 24.312 | Qualcomm | Amer Catovic, amerc@qualcomm.com | Rel-12 | CP-62 | Frederic | WLAN | WLAN_NS-CT |  |  | CP-140622 |
| 709 | 192 | **Deleted - IMS Registration Control** | 496d? | 2012-01-31 A | 2013-12-11 A | 100% |  | 2012-01-31 | 2013-12-11 | 496d? |  |  | S1; S2; C1; C4 | 23400h | 23400h | IMS_RegCon | PCG-29 | Stage 1/2/3 | China Mobile | lulu@chinamobile.com | Rel-12 | SP-57 | Alain |  | IMS_RegCon | PCG-32 | SP-62 |  |
| 710 | 192.1 | Deleted - Stage 1 for IMS Registration Control | 164d? | 2012-01-31 A | 2012-09-12 A | 100% |  | 2012-01-31 | 2012-09-12 | 164d? |  | finish no earlier than 2012-09-12 | S1 | 1304h | 1304h | IMS_RegCon-del1 | PCG-29 | 22.228 | China Mobile | lulu@chinamobile.com | Rel-12 | SP-57 | Alain |  |  | PCG-32 | SP-62 |  |
| 711 | 192.2 | Deleted - Stage 2 for IMS Registration Control | 262d? | 2012-12-13 A | 2013-12-11 A | 100% |  | 2012-12-13 | 2013-12-11 | 262d? |  | finish no earlier than 2013-12-11 | S2 | 2096h | 2096h | IMS_RegCon-del2 | PCG-30 | 23.228 | China Mobile | Jiang Yi (jiangyi@chinamobile.com) | Rel-12 | SP-58 | Maurice |  |  | PCG-32 | SP-62 |  |
| 712 | 192.3 | **Deleted - CT aspects of IMS registration control** | 129d? | 2013-06-19 A | 2013-12-11 A | 100% |  | 2013-06-19 | 2013-12-11 | 129d? |  |  | C1; C4 | 4128h | 4128h | IMS_RegCon-CT | PCG-31 | Stage 2/3 | China Mobile | Jiang Yi (jiangyi@chinamobile.com) | Rel-12 | CP-60 | Frederic |  | IMS_RegCon-CT | PCG-32 | SP-62 |  |
| 713 | 192.3.1 | Deleted - CT1 aspects of CT aspects of IMS registration control (Stage 2/3) | 129d? | 2013-06-19 A | 2013-12-11 A | 100% |  | 2013-06-19 | 2013-12-11 | 129d? |  | finish no earlier than 2013-12-11 | C1 | 1032h | 1032h | IMS_RegCon-CT1 | PCG-31 | 23.218, 24.229 | China Mobile | Jiang Yi (jiangyi@chinamobile.com) | Rel-12 | CP-60 | Frederic |  |  | PCG-32 | SP-62 |  |
| 714 | 192.3.2 | Deleted - CT4 aspects of CT aspects of IMS registration control (Stage 3) | 129d? | 2013-06-19 A | 2013-12-11 A | 100% |  | 2013-06-19 | 2013-12-11 | 129d? |  | finish no earlier than 2013-12-11 | C4 | 1032h | 1032h | IMS_RegCon-CT4 | PCG-31 | 29.228, 29.229, 23.008 | China Mobile | Jiang Yi (jiangyi@chinamobile.com) | Rel-12 | CP-60 | Kimmo |  |  | PCG-32 | SP-62 |  |
| 715 | 193 | **Proximity-based Services** | 793d? | 2012-12-13 A | 2015-12-15 | 83% | 131.36d? | 2012-12-13 | 2015-03-13 | 593d? | 392d |  | S1; S2; S3; C1; C3; C4; C6; R1; R2; R4; S5; IETF | 124281h | 41508.6h | ProSe | PCG-30 | Stage 1/2 | Qualcomm | Rich Hovey (rhovey@qualcomm.com) | Rel-12 | SP-58 | Alain | Public Safety (A-A) | ProSe |  |  |  |
| 716 | 193.1 | Stage 1 for Proximity-based Services | 137d? | 2012-12-13 A | 2013-06-19 A | 100% |  | 2012-12-13 | 2013-06-19 | 137d? |  | finish no earlier than 2013-06-19 | S1 | 1088h | 1088h | ProSe-SA1 | PCG-30 | 22.115, 22.278 | Qualcomm | Rich Hovey (rhovey@qualcomm.com) | Rel-12 | SP-58 | Alain | Public Safety (A-A) |  |  |  |  |
| 717 | 193.2 | TR on Stage 2 for Proximity-based Services | 327d? | 2012-12-13 A | 2014-03-07 A | 100% |  | 2012-12-13 | 2014-03-07 | 327d? |  | finish no earlier than 2014-03-07 | S2 | 2608h | 2608h | ProSe-SA2TR | PCG-30 | New TR 23.703 | Qualcomm | Haris Zisimopoulos (harisz@qti.qualcomm.com) | Rel-12 | SP-58 | Maurice | Public Safety (A-A) |  |  |  |  |
| 718 | 193.3 | Stage 2 for Proximity-based Services | 397d? | 2012-12-19 A | 2014-06-18 A | 100% |  | 2012-12-19 | 2014-06-18 | 397d? |  | finish no earlier than 2014-06-18 | S2 | 3168.8h | 3168.8h | ProSe-SA2 | PCG-30 | New TS 23.303 | Qualcomm | Haris Zisimopoulos (harisz@qti.qualcomm.com) | Rel-12 | SP-58 | Maurice | Public Safety (A-A) |  |  |  |  |
| 719 | 193.4 | Security for Proximity-based Services | 464d? | 2013-03-13 A | 2014-12-12 | 90% | 46.4d? | 2013-03-13 | 2014-06-18 | 336d? | 654d | finish no earlier than 2014-12-12 | S3 | 3712h | 3340.8h | ProSe-SA3 | PCG-30 | 33.220, New TS 33.303 | Qualcomm | Adrian Escott (aescott@qti.qualcomm.com) | Rel-12 | SP-59 | Mirko | Public Safety (A-A) |  |  |  | SP-140584 |
| 720 | 193.5 | (IETF) Security for Proximity-based Services (ietf-avtcore-srtp-aes-gcm) | 63d? | 2014-09-12 A | 2014-12-09 | 75% | 15.75d? |  |  |  | 657d | finish no earlier than 2014-12-09 | S3-IETF | 504h | 378h | ProSe | PCG-33 | ietf-avtcore-srtp-aes-gcm | Atle Monrad | atle.monrad@ericsson.com | Rel-12 | SP-65 |  | Public Safety (A-A) |  |  |  |  |
| 721 | 193.6 | **Charging Aspects of Proximity-based Services** | 195d? | 2014-06-19 A | 2015-03-13 A | 100% |  | 2014-06-18 | 2014-09-17 | 66d? |  |  | S5 | 4160h | 4160h | ProSe-CH | PCG-33 | Stage 2/3 | Qualcomm | Cheng Hong (hongc@qti.qualcomm.com) | Rel-12 | SP-64 |  | Public Safety (A-A) | ProSe-CH |  |  | SP-140543 |
| 722 | 193.6.1 | Study on Charging support for ProSe one-to-many Direct Communication for Public Safety use | 130d? | 2014-06-19 A | 2014-12-12 A | 100% |  | 2014-06-18 | 2014-09-17 | 66d? |  | finish no earlier than 2014-12-12 | S5 | 1040h | 1040h | ProSe-CH-SA5TR | PCG-33 | New TR 32.844 | Qualcomm | Cheng Hong (hongc@qti.qualcomm.com) | Rel-12 | SP-64 |  | Public Safety (A-A) |  |  |  | SP-140543 |
| 723 | 193.6.2 | Specification of Charging Aspects of Proximity-based Services | 195d? | 2014-06-19 A | 2015-03-13 A | 100% |  | 2014-06-18 | 2014-09-17 | 66d? |  | finish no earlier than 2015-03-13 | S5 | 1560h | 1560h | ProSe-CH-SA5 | PCG-33 | 32.240, 32.297, 32.298, 32.299, New TS 32.277 | Qualcomm | Cheng Hong (hongc@qti.qualcomm.com) | Rel-12 | SP-64 |  | Public Safety (A-A) |  |  |  | SP-140543 |
| 724 | 193.7 | **CT aspects of Proximity-based Services (Stage 3)** | 203d? | 2014-03-05 A | 2014-12-09 A | 100% |  | 2014-03-05 | 2014-09-12 | 138d? |  |  | C1; C3; C4; C6 | 12888h | 12888h | ProSe-CT | PCG-32 | Stage 3 | Qualcomm | Lena Chaponniere (lguellec@qti.qualcomm.com) | Rel-12 | CP-63 | Frederic | Public Safety (A-A) | ProSe-CT |  |  |  |
| 725 | 193.7.1 | CT1 part of CT aspects of Proximity-based Services | 200d? | 2014-03-05 A | 2014-12-09 A | 100% |  | 2014-03-05 | 2014-09-12 | 138d? |  | finish no earlier than 2014-12-09 | C1 | 1600h | 1600h | ProSe-CT | PCG-32 | 24.301, 23.122, New TSs (24.333, 24.334) | Qualcomm | Lena Chaponniere (lguellec@qti.qualcomm.com) | Rel-12 | CP-63 | Frederic | Public Safety (A-A) |  |  |  | CP-140615 |
| 726 | 193.7.2 | CT3 part of CT aspects of Proximity-based Services | 200d? | 2014-03-05 A | 2014-12-09 A | 100% |  | 2014-03-05 | 2014-09-12 | 138d? |  | finish no earlier than 2014-12-09 | C3 | 1600h | 1600h | ProSe-CT | PCG-32 | New TS 29.343 | Qualcomm | Lena Chaponniere (lguellec@qti.qualcomm.com) | Rel-12 | CP-63 | Adrian | Public Safety (A-A) |  |  |  | CP-140568 |
| 727 | 193.7.3 | CT4 part of CT aspects of Proximity-based Services | 200d? | 2014-03-05 A | 2014-12-09 A | 100% |  | 2014-03-05 | 2014-09-12 | 138d? |  | finish no earlier than 2014-12-09 | C4 | 1600h | 1600h | ProSe-CT | PCG-32 | 29.272, 23.008, 23.003, New TSs (29.344, 29.345) | Qualcomm | Lena Chaponniere (lguellec@qti.qualcomm.com) | Rel-12 | CP-63 | Kimmo | Public Safety (A-A) |  |  |  | CP-140484 |
| 728 | 193.7.4 | CT6 part of CT aspects of Proximity-based Services | 199d? | 2014-03-06 A | 2014-12-09 A | 100% |  | 2014-03-06 | 2014-09-12 | 137d? |  | finish no earlier than 2014-12-09 | C6 | 1592h | 1592h | ProSe-CT | PCG-32 | 31.102 | Qualcomm | Lena Chaponniere (lguellec@qti.qualcomm.com) | Rel-12 | CP-63 | Xavier | Public Safety (A-A) |  |  |  | CP-140695 |

Notes:
- 704: Evaluate and if needed enhance existing 3GPP solutions for WLAN network selection taking into account WFA Hotspot 2.0 solutions
- 705: SP#62 completed
- 706: SP#62 completed
- 707: SP#63 stopped (84% complete)
- 708: CP#65 completion 09/14=>12/14. CP#65 exception CP-140622. Dec.14: 95->100%
- 709: SP#62 stopped. Specify for fixed line the requirement of controlling user registration to IMS based on network information related to user location (e.g. IP address, DSLAM information)
- 710: SP#57 completed
- 711: SP#62 stopped at 50% completion
- 712: SP#62 no CT/Stage 3 work is needed (stopped at 0% completion)
- 713: SP#62 no CT/Stage 3 work is needed (stopped at 0% completion)
- 714: SP#62 no CT/Stage 3 work is needed (stopped at 0% completion)
- 715: SP#65 SA3 updated the SA-wide WID SP-140300=>SP-140574 (Moved the TR phase to Rel-13 as a stand-alone Study). Triggered by Rel-12 TR 22.803 Study on Proximity-based Services (FS_ProSe) UID_530044
- 716: SP#60 completed
- 717: SP#63 completed. TR 23.703v200 for Approval
- 718: SP#64 completed open issue/alignment to RAN/SA3 decisions. SP#63 TS 23.303v100 for 1-step Approval
- 719: SP#65 re-opened. Completion 06/14=>12/14. Exception in SP-140584. Updated WID SP-140300=>SP-140574 (Moved the TR phase to Rel-13 as a stand-alone Study). SP#64 completed. TS 33.303 v100 for 1-step Approval
- 720: Submitted to IESG for publication
- 721: SP#65 exception in SP-140543. Mar15: 85->100%
- 722: SP#65 completion 09/14=>12/14. Exception in SP-140543. TR 32.844v100 for Information. Dec.14: CD: 09/14->12/14, 60->100%
- 723: SP#65 completion 09/14=>12/14. Exception in SP-140543. SP#65 TR 32.277v100 for Information. Dec.14: CD: 09/14->03/15, 40->75%. Mar15: 75->100%
- 724: CP#64 updated WID CP-140194=>CP-140290
- 725: CP#65 completion 09/14=>12/14. Exception in CP-140615. TS 24.333/4v200 for Approval. Dec.14: 90->100%
- 726: CP#65 completion 09/14=>12/14. TS 29.343v100 for 1-step Approval. Exception in CP-140568. Dec.14: 90->100
- 727: CP#65 completion 09/14=>12/14. TS 29.344/5v100 for 1-step Approval. Exception in CP-140484. Dec.14: 90->100
- 728: CP#65 completion 09/14=>12/14. Exception in CP-140695. Dec.14: 60->100%

| ID | WBS | Task | Duration | Start | Finish | Complete | Remaining | Baseline start | Baseline finish | Baseline duration | Total slack | Constraint | Resources | Work | Actual work | Acronym | PCG approved | WI rapporteur name | WI rapporteur e-mail | Release | TSG approved | MCC resp | Special Focus Doc | Acronym_3GU_Export | Status Report |
| --- | --- | --- | --- | --- | --- | --- | --- | --- | --- | --- | --- | --- | --- | --- | --- | --- | --- | --- | --- | --- | --- | --- | --- | --- | --- |
| 729 | 193.8 | **LTE Device to Device Proximity Services** | 464d? | 2014-03-11 A | 2015-12-15 | 42% | 268.06d? | 2014-03-06 | 2015-03-13 | 267d? | 392d |  | R1; R2; R4 | 22216h | 8677h | LTE_D2D_Prox | PCG-32 | Qualcomm | Shailesh Patil (patil@qti.qualcomm.com) | Rel-12 | RP-63 | Patrick | Public Safety (A-A) | LTE_D2D_Prox |  |
| 730 | 193.8.1 | Core part: LTE Device to Device Proximity Services | 263d? | 2014-03-15 A | 2015-03-15 A | 100% |  | 2014-07-11 | 2014-09-12 | 45.67d? |  | finish no earlier than 2015-03-15 | R1; R2; R4 | 6312h | 6312h | LTE_D2D_Prox-Core | PCG-32 | Qualcomm | Shailesh Patil (patil@qti.qualcomm.com) | Rel-12 | RP-63 | Patrick | Public Safety (A-A) | LTE_D2D_Prox-Core | RP-150094 |
| 731 | 193.8.2 | Perf. part: LTE Device to Device Proximity Services | 399d? | 2014-03-11 A | 2015-09-15 | 25% | 299.25d? | 2014-03-06 | 2015-03-13 | 267d? | 457d | finish no earlier than 2015-09-15 | R4 | 3192h | 798h | LTE_D2D_Prox-Perf | PCG-32 | Qualcomm | Shailesh Patil (patil@qti.qualcomm.com) | Rel-12 | RP-63 | Issam | Public Safety (A-A) | LTE_D2D_Prox-Perf | RP-150094 |
| 732 | 193.8.3 | UE Conformance Test Aspects – LTE Device-to-Device Proximity Services | 197d? | 2015-03-16 | 2015-12-15 |  |  |  |  |  | 392d | finish no earlier than 2015-12-15 | R5 | 1576h |  | LTE_D2D_Prox-UEConTest | PCG-34 | Qualcomm | svora@qti.qualcomm.com | Rel-12 | RP-67 |  |  |  |  |
| 733 | 194 | **Web Real Time Communication access to IMS** | 530d? | 2012-12-14 A | 2014-12-12 | 81% | 100.18d? | 2012-12-14 | 2014-12-10 | 525d? | 654d |  | S1; S2; S3 | 34985.8h | 20877h | IMS_WebRTC | PCG-30 | China Mobile | lulu@chinamobile.com | Rel-12 | SP-58 | Alain |  | IMS_WebRTC |  |
| 734 | 194.1 | Stage 1 for Web Real Time Communication access to IMS | 136d? | 2012-12-14 A | 2013-06-19 A | 100% |  | 2012-12-14 | 2013-06-19 | 136d? |  | finish no earlier than 2013-06-19 | S1 | 1088h | 1088h | IMS_WebRTC | PCG-30 | China Mobile | lulu@chinamobile.com | Rel-12 | SP-58 | Alain |  |  |  |
| 735 | 194.2 | TR on Stage 2 for Web Real Time Communication access to IMS | 126d? | 2013-06-19 A | 2013-12-11 A | 100% |  | 2013-06-19 | 2013-12-11 | 126d? |  | finish no earlier than 2013-12-11 | S2 | 1008h | 1008h | IMS_WebRTC | PCG-31 | China Mobile | Yu Qing (yuqing@chinamobile.com) | Rel-12 | SP-60 | Maurice |  |  |  |
| 736 | 194.3 | Stage 2 for Web Real Time Communication access to IMS | 192d? | 2013-06-19 A | 2014-03-07 A | 100% |  | 2013-06-19 | 2014-03-07 | 192d? |  | finish no earlier than 2014-03-07 | S2 | 1528h | 1528h | IMS_WebRTC | PCG-31 | China Mobile | Yu Qing (yuqing@chinamobile.com) | Rel-12 | SP-60 | Maurice |  |  |  |
| 737 | 194.4 | (IETF) Web Real Time Communication access to IMS (rtcweb-overview) | 391d? | 2013-06-25 A | 2014-12-12 | 50% | 195.5d? | 2013-06-19 | 2014-12-10 | 389d? | 654d | finish no earlier than 2014-12-12 | C1-IETF | 3128h | 1564h | IMS_WebRTC | PCG-32 | Uwe Rauschenbach | Uwe Rauschenbach | Rel-12 | SP-63 |  |  |  |  |
| 738 | 194.5 | TR on Security for Web Real Time Communication access to IMS | 202d? | 2013-12-11 A | 2014-09-17 A | 100% |  | 2013-12-11 | 2014-09-17 | 202d? |  | finish no earlier than 2014-09-17 | S3 | 1608h | 1608h | IMS_WebRTC | PCG-32 | Ericsson | oscar.ohlsson@ericsson.com | Rel-12 | SP-62 | Mirko |  |  |  |
| 739 | 194.6 | Security for Web Real Time Communication access to IMS | 202d? | 2013-09-12 A | 2014-06-18 A | 100% |  | 2013-09-12 | 2014-06-18 | 202d? |  | finish no earlier than 2014-06-18 | S3 | 1609.85h | 1609.85h | IMS_WebRTC | PCG-31 | Ericsson | oscar.ohlsson@ericsson.com | Rel-12 | SP-61 | Mirko |  |  |  |
| 740 | 194.7 | **CT aspects of Web Real Time Communication (WebRTC) Access to IMS** | 203d? | 2014-03-05 A | 2014-12-09 | 77% | 47.25d? | 2014-03-05 | 2014-12-05 | 198d? | 657d |  | C1; C4; IETF | 12296h | 9207.2h | IMS_WebRTC-CT | PCG-32 | China Mobile | Jiang Yi (jiangyi@chinamobile.com) | Rel-12 | CP-63 | Frederic |  | IMS_WebRTC-CT |  |
| 741 | 194.7.1 | CT1 part of CT aspects of Web Real Time Communication (WebRTC) Access to IMS | 200d? | 2014-03-05 A | 2014-12-09 A | 100% |  | 2014-03-05 | 2014-09-12 | 138d? |  | finish no earlier than 2014-12-09 | C1 | 1600h | 1600h | IMS_WebRTC-CT1 | PCG-32 | China Mobile | Jiang Yi (jiangyi@chinamobile.com) | Rel-12 | CP-63 | Frederic |  |  | CP-140621 |
| 742 | 194.7.2 | (IETF) Web Real Time Communication access to IMS (rtcweb-data-channel) | 200d? | 2014-03-06 A | 2014-12-09 | 90% | 20d? | 2014-03-05 | 2014-12-05 | 198d? | 657d | finish no earlier than 2014-12-09 | C1-IETF | 1600h | 1440h | IMS_WebRTC-data | PCG-33 | christer.holmberg@ericsson.com | christer.holmberg@ericsson.com | Rel-12 | CP-64 |  |  |  |  |
| 743 | 194.7.3 | (IETF) Web Real Time Communication access to IMS (rtcweb-stun-consent-freshness) | 200d? | 2014-03-06 A | 2014-12-09 | 50% | 100d? | 2014-03-05 | 2014-12-05 | 198d? | 657d | finish no earlier than 2014-12-09 | C1-IETF | 1600h | 800h | IMS_WebRTC-stun | PCG-33 | christer.holmberg@ericsson.com | christer.holmberg@ericsson.com | Rel-12 | CP-64 |  |  |  |  |
| 744 | 194.7.4 | (IETF) Web Real Time Communication access to IMS (draft-yusef-sipcore-sip-oauth) | 63d? | 2014-09-12 A | 2014-12-09 | 25% | 47.25d? |  |  |  | 657d | finish no earlier than 2014-12-09 | C1-IETF | 504h | 126h | IMS_WebRTC-yusef | PCG-33 | christer.holmberg@ericsson.com | christer.holmberg@ericsson.com | Rel-12 | CP-65 |  |  |  |  |
| 745 | 194.7.5 | (IETF) Web Real Time Communication access to IMS (draft-holmberg-sipcore-auth-id) | 65d? | 2014-09-12 A | 2014-12-09 | 25% | 48.75d? |  |  |  | 657d | start no earlier than 2014-09-12 | C1-IETF | 520h | 130h | IMS_WebRTC-holmb | PCG-34 | christer.holmberg@ericsson.com |  | Rel-12 | CP-66 |  |  |  |  |
| 746 | 194.7.6 | CT4 part of CT aspects of Web Real Time Communication (WebRTC) Access to IMS | 200d? | 2014-03-05 A | 2014-12-09 A | 100% |  | 2014-03-05 | 2014-09-19 | 143d? |  | finish no earlier than 2014-12-09 | C4 | 1600h | 1600h | IMS_WebRTC-CT4 | PCG-32 | China Mobile | Jiang Yi (jiangyi@chinamobile.com) | Rel-12 | CP-63 | Kimmo |  |  | CP-140732 |
| 747 | 195 | **Usage Monitoring Control PCC enhancement** | 196d? | 2012-12-13 A | 2013-09-06 A | 100% |  | 2012-12-13 | 2013-09-06 | 196d? |  |  | S2; C3 | 4112h | 4112h | UMONC | PCG-30 | ZTE | bi.yifeng@zte.com.cn | Rel-12 | SP-58 | Maurice |  | UMONC |  |
| 748 | 195.1 | Stage 2 for Usage Monitoring Control PCC enhancement | 61d? | 2012-12-13 A | 2013-03-06 A | 100% |  | 2012-12-13 | 2013-03-06 | 61d? |  | finish no earlier than 2013-03-06 | S2 | 488h | 488h | UMONC | PCG-30 | ZTE | bi.yifeng@zte.com.cn | Rel-12 | SP-58 | Maurice |  |  |  |
| 749 | 195.2 | CT3 aspects of Usage Monitoring Control PCC enhancement (Stage 3) | 63d? | 2013-06-14 A | 2013-09-06 A | 100% |  | 2013-06-14 | 2013-09-06 | 63d? |  | finish no earlier than 2013-09-06 | C3 | 488h | 488h | UMONC-CT3 | PCG-31 | ZTE | zhou.xiaoyun@zte.com.cn | Rel-12 | CP-60 | Adrian |  | UMONC-CT3 |  |
| 750 | 196 | **Application Based Charging** | 340d? | 2013-03-07 A | 2014-06-18 A | 100% |  | 2013-03-07 | 2014-06-18 | 340d? |  |  | S2; S5; C3 | 11612h | 11612h | ABC | PCG-30 | Allot | Alla Goldner (agoldner@allot.com) | Rel-12 | SP-59 | Maurice |  | ABC |  |
| 751 | 196.1 | Stage 2 for Application Based Charging | 76d? | 2013-03-07 A | 2013-06-19 A | 100% |  | 2013-03-07 | 2013-06-19 | 76d? |  | finish no earlier than 2013-12-11 | S2 | 608h | 608h | ABC-SA2 | PCG-30 | Allot | Alla Goldner (agoldner@allot.com) | Rel-12 | SP-59 | Maurice |  |  |  |
| 752 | 196.2 | Charging for Application Based Charging | 232.5d? | 2013-06-19 A | 2014-06-18 A | 100% |  | 2013-06-19 | 2014-06-18 | 232.5d? |  | finish no earlier than 2014-06-18 | S5 | 1836h | 1836h | ABC-CT5 | PCG-31 | Openet Telecom | alan.mcnamee@openet.com | Rel-12 | SP-60 | Mirko |  |  |  |
| 753 | 196.3 | CT3 aspects of Application Based Charging (Stage 3) | 127d? | 2013-06-14 A | 2013-12-06 A | 100% |  | 2013-06-14 | 2013-12-06 | 127d? |  | finish no earlier than 2013-12-06 | C3 | 1008h | 1008h | ABC-CT3 | PCG-31 | Allot | Alla Goldner (agoldner@allot.com) | Rel-12 | CP-60 | Adrian |  | ABC-CT3 |  |

Notes:
- 729: follow-up of TR 36.843 FS_LTE_D2D_Prox / Impacted TSs and TRs: LTE
- 730: ; CD:Sat 15/03/14->Sun 15/03/15Compl:0%->95%; CD:Fri 13/03/15->Sun 15/03/15; Stat Rep: RP-141244->RP-141894 1st Apr 15: Compl:95%->100% 1st Apr 15: Stat Rep: RP-141894->RP-150094 / Impacted TSs and TRs: 36.101, 36.133, 36.211, 36.212, 36.213, 36.214, 36.300, 36.304, 36.306, 36.321, 36.322, 36.323, 36.331, 36.413, 36.423, New TR 36.877
- 731: ; CD:Sat 15/03/14->Sun 15/03/15; Stat Rep: RP-141244->RP-141894 1st Apr 15: Compl:10%->25% 1st Apr 15: Stat Rep: RP-141894->RP-150094 / Impacted TSs and TRs: 36.101, 36.133
- 732: rapporteur e-mail added
- 733: IETF RTCWEB and W3C WEBRTC groups are specifying a browser-based client to support communication services. Interoperability for WebRTC clients to access 3GPP IMS is needed. / Impacted TSs and TRs: Stage 1/2
- 734: SP#60 completed / Impacted TSs and TRs: 22.101, 22.228
- 735: SP#62 completed. TR 23.701v100 for Information & Approval / Impacted TSs and TRs: New TR 23.701
- 736: SP#63 completed / Impacted TSs and TRs: 23.228
- 737: In WGLC. Mar15: responsible WG changed from S2-IETF / Impacted TSs and TRs: draft-ietf-rtcweb-overview
- 738: SP#65 completed. TR 33.871v200 for Approval / Impacted TSs and TRs: New TR 33.871
- 739: SP#64 completed / Impacted TSs and TRs: 33.203, 33.328
- 740: - / Impacted TSs and TRs: Stage 3
- 741: CP#65 TS 24.371v100 for Information. Completion 09/14=>12/14. Exception in CP-140621. Dec.14: 70->90%. 3/3/15: 100% cpltd. / Impacted TSs and TRs: 24.229, New TS 24.371
- 742: Submitted to IESG for publication. Mar15: In RFC-Editors queue / Impacted TSs and TRs: draft-ietf-rtcweb-data-channel
- 743: Mar15: Publication requested / Impacted TSs and TRs: draft-ietf-rtcweb-stun-consent-freshness
- 744: work in progress / Impacted TSs and TRs: draft-yusef-sipcore-sip-oaut
- 745: Impacted TSs and TRs: draft-holmberg-sipcore-auth-id
- 746: CP#65 completion 09/14=>12/14. Exception in CP-140732. Dec.14: 30->80%. Mar. 15: 100% / Impacted TSs and TRs: 23.334, 29.334
- 747: SP#59 Stage 2 completed. Triggered by Rel-12 TR 23.858 Study on Usage Monitoring Control enhancement (UID_520035) / Impacted TSs and TRs: Stage 2/3
- 748: SP#59 completed. 23.203 CR#0782 (Time Based Usage Monitoring), CR#0784 (Usage Monitoring via Online Charging System) / Impacted TSs and TRs: 23.203
- 749: CP#61 completed. 2/4/15: acronym changed to "UMONC-CT3" / Impacted TSs and TRs: 29.212, 29.214, 29.215
- 750: Triggered by TR 23.800 Study on Application Based Charging (FS_ABC) UID_560038 / Impacted TSs and TRs: Stage 2/3
- 751: SP#60 completed / Impacted TSs and TRs: 23.203
- 752: SP#64 completed / Impacted TSs and TRs: 32.240, 32.251, 32.296, 32.298, 32.299
- 753: CP#62 completed / Impacted TSs and TRs: 29.212, 29.213, 29.214, 29.215, 29.219

| ID | WBS | Task | Duration | Start | Finish | Complete | Baseline start | Baseline finish | Baseline duration | Constraint | Resources | Work | Actual work | Acronym | PCG approved | WI rapporteur name | WI rapporteur e-mail | Release | TSG approved | MCC resp | Special Focus Doc | Acronym_3GU_Export | Status Report | PCG stopped | TSG stopped |
| --- | --- | --- | --- | --- | --- | --- | --- | --- | --- | --- | --- | --- | --- | --- | --- | --- | --- | --- | --- | --- | --- | --- | --- | --- | --- |
| 754 | 197 | **Enhanced S2a Mobility Over trusted WLAN access to EPC** | 332d? | 2013-09-09 A | 2014-12-09 A | 100% | 2013-09-09 | 2014-09-12 | 267d? |  | S2; C1; C4 | 19024h | 19024h | eSaMOG | PCG-31 | ZTE | Tricci So (tso@zteusa.com) | Rel-12 | SP-61 | Maurice | WLAN | eSaMOG |  |  |  |
| 755 | 197.1 | Stage 2 for Enhanced S2a Mobility Over trusted WLAN access to EPC | 130d? | 2013-09-11 A | 2014-03-07 A | 100% | 2013-09-11 | 2014-03-07 | 130d? | finish no earlier than 2014-03-07 | S2 | 1032h | 1032h | eSaMOG-SA2 | PCG-31 | ZTE | Tricci So (tso@zteusa.com) | Rel-12 | SP-61 | Maurice | WLAN |  |  |  |  |
| 756 | 197.2 | **Stage 3 for Enhanced S2a Mobility Over trusted WLAN access to EPC** | 332d? | 2013-09-09 A | 2014-12-09 A | 100% | 2013-09-09 | 2014-09-12 | 267d? |  | C1; C4 | 10048h | 10048h | eSaMOG-St3 | PCG-31 | ZTE | Joy Zhou (zhou.xingyue@zte.com.cn) | Rel-12 | CP-61 | Frederic | WLAN | eSaMOG-St3 |  |  |  |
| 757 | 197.2.1 | CT1 part of Stage 3 for Enhanced S2a Mobility Over trusted WLAN access to EPC | 329d? | 2013-09-09 A | 2014-12-09 A | 100% | 2013-09-09 | 2014-09-12 | 267d? | finish no earlier than 2014-12-09 | C1 | 2624h | 2624h | eSaMOG-St3 | PCG-31 | ZTE | Joy Zhou (zhou.xingyue@zte.com.cn) | Rel-12 | CP-61 | Frederic | WLAN |  | CP-140608 |  |  |
| 758 | 197.2.2 | CT4 part of Stage 3 for Enhanced S2a Mobility Over trusted WLAN access to EPC | 266d? | 2013-09-09 A | 2014-09-11 A | 100% | 2013-09-09 | 2014-09-12 | 266d? | finish no earlier than 2014-09-12 | C4 | 2128h | 2128h | eSaMOG-St3 | PCG-31 | ZTE | Joy Zhou (zhou.xingyue@zte.com.cn) | Rel-12 | CP-61 | Kimmo | WLAN |  |  |  |  |
| 759 | 198 | **Optimized Offloading to WLAN in 3GPP-RAT Mobility** | 199d? | 2013-09-12 A | 2014-06-13 A | 100% | 2013-09-12 | 2014-06-13 | 199d? |  | S2; C1 | 4800h | 4800h | WORM | PCG-31 | BlackBerry | Steve Barrett (sbarrett@blackberry.com) | Rel-12 | SP-61 | Maurice | WLAN | WORM |  |  |  |
| 760 | 198.1 | Stage 2 for Optimized Offloading to WLAN in 3GPP-RAT Mobility | 66d? | 2013-09-12 A | 2013-12-11 A | 100% | 2013-09-12 | 2013-12-11 | 66d? | finish no earlier than 2013-12-11 | S2 | 528h | 528h | WORM-SA2 | PCG-31 | BlackBerry | Steve Barrett (sbarrett@blackberry.com) | Rel-12 | SP-61 | Maurice | WLAN |  |  |  |  |
| 761 | 198.2 | CT aspects of Optimized Offloading to WLAN in 3GPP-RAT Mobility (Stage 3) | 136d? | 2013-12-06 A | 2014-06-13 A | 100% | 2013-12-06 | 2014-06-13 | 136d? | finish no earlier than 2014-06-13 | C1 | 1088h | 1088h | WORM-CT | PCG-32 | Intel | Chen-ho Chin (chen-hox.chin@intel.com) | Rel-12 | CP-62 | Frederic | WLAN | WORM-CT |  |  |  |
| 762 | 199 | **Network-provided Location information for IMS Trusted WLAN Access Network (TWAN) case** | 264d? | 2013-09-12 A | 2014-09-11 A | 100% | 2013-09-12 | 2014-09-12 | 264d? |  | S2; C3; C1; C4 | 18624h | 18624h | NETLOC_TWAN | PCG-31 | Alcatel-Lucent | Laurent.thiebaut@alcatel-lucent.com | Rel-12 | SP-61 | Maurice | WLAN | NETLOC_TWAN |  |  |  |
| 763 | 199.1 | Stage 2 for Network-provided Location information for IMS Trusted WLAN Access Network (TWAN) case | 129d? | 2013-09-12 A | 2014-03-07 A | 100% | 2013-09-12 | 2014-03-07 | 129d? | finish no earlier than 2014-03-07 | S2 | 1024h | 1024h | NETLOC_TWAN-SA2 | PCG-31 | Alcatel-Lucent | Laurent.thiebaut@alcatel-lucent.com | Rel-12 | SP-61 | Maurice |  |  |  |  |  |
| 764 | 199.2 | **CT aspects of Network-provided Location information for IMS Trusted WLAN Access Network (TWAN) case (Stage 3)** | 202d? | 2013-12-06 A | 2014-09-11 A | 100% | 2013-12-06 | 2014-09-12 | 202d? |  | C3; C1; C4 | 9152h | 9152h | NETLOC_TWAN-CT | PCG-32 | China Telecom | Xia Xu (xiaxu@ctbri.com.cn) | Rel-12 | CP-62 | Adrian |  | NETLOC_TWAN-CT |  |  |  |
| 765 | 199.2.1 | CT3 part of Network-provided Location information for IMS Trusted WLAN Access Network (TWAN) case | 137d? | 2013-12-06 A | 2014-06-13 A | 100% | 2013-12-06 | 2014-06-13 | 137d? | finish no earlier than 2014-06-13 | C3 | 1088h | 1088h | NETLOC_TWAN-CT | PCG-32 | China Telecom | Xia Xu (xiaxu@ctbri.com.cn) | Rel-12 | CP-62 | Adrian |  |  |  |  |  |
| 766 | 199.2.2 | CT1 part of Network-provided Location information for IMS Trusted WLAN Access Network (TWAN) case | 201d? | 2013-12-09 A | 2014-09-11 A | 100% | 2013-12-09 | 2014-09-12 | 201d? | finish no earlier than 2014-09-12 | C1 | 1608h | 1608h | NETLOC_TWAN-CT | PCG-32 | China Telecom | Xia Xu (xiaxu@ctbri.com.cn) | Rel-12 | CP-62 | Frederic |  |  |  |  |  |
| 767 | 199.2.3 | CT4 part of Network-provided Location information for IMS Trusted WLAN Access Network (TWAN) case | 201d? | 2013-12-06 A | 2014-09-11 A | 100% | 2013-12-06 | 2014-09-12 | 201d? | finish no earlier than 2014-09-12 | C4 | 1608h | 1608h | NETLOC_TWAN-CT | PCG-32 | China Telecom | Xia Xu (xiaxu@ctbri.com.cn) | Rel-12 | CP-62 | Kimmo |  |  |  |  |  |
| 768 | 200 | **Core Network Overload - User Location Information reporting improvement** | 203d? | 2013-12-11 A | 2014-09-17 A | 100% | 2013-12-11 | 2014-09-12 | 199d? |  | S2; C3; C4; S5 | 10920h | 10920h | CNO_ULI | PCG-32 | Alcatel-Lucent | nicolas.drevon@alcatel-lucent.com | Rel-12 | SP-62 | Maurice |  | CNO_ULI |  |  |  |
| 769 | 200.1 | Stage 2 for Core Network Overload - User Location Information reporting improvement | 64d? | 2013-12-11 A | 2014-03-07 A | 100% | 2013-12-11 | 2014-03-07 | 64d? | finish no earlier than 2014-03-07 | S2 | 504h | 504h | CNO_ULI-SA2 | PCG-32 | Alcatel-Lucent | nicolas.drevon@alcatel-lucent.com | Rel-12 | SP-62 | Maurice |  |  |  |  |  |
| 770 | 200.2 | Charging aspects of Core Network Overload – User Location Information reporting improvements | 3d? | 2014-09-15 A | 2014-09-17 A | 100% |  |  |  | finish no earlier than 2014-09-17 | S5 | 24h | 24h | CNO_ULI-CH | PCG-33 | Alcatel-Lucent | maryse.gardella@alcatel-lucent.com | Rel-12 | SP-65 |  |  | CNO_ULI-CH |  |  |  |
| 771 | 200.3 | **CT aspects of Core Network Overload – User Location Information reporting improvements** | 138d? | 2014-03-05 A | 2014-09-11 A | 100% | 2014-03-05 | 2014-09-12 | 138d? |  | C3; C4 | 3896h | 3896h | CNO_ULI-CT | PCG-32 | Alcatel-Lucent | horst.brinkmann@alcatel-lucent.com | Rel-12 | CP-63 | Adrian |  | CNO_ULI-CT |  |  |  |
| 772 | 200.3.1 | CT3 part of CT aspects of Core Network Overload – User Location Information reporting improvements | 73d? | 2014-03-05 A | 2014-06-13 A | 100% | 2014-03-05 | 2014-06-13 | 73d? | finish no earlier than 2014-06-13 | C3 | 584h | 584h | CNO_ULI-CT | PCG-32 | Alcatel-Lucent | horst.brinkmann@alcatel-lucent.com | Rel-12 | CP-63 | Adrian |  |  |  |  |  |
| 773 | 200.3.2 | CT4 part of CT aspects of Core Network Overload – User Location Information reporting improvements | 138d? | 2014-03-05 A | 2014-09-11 A | 100% | 2014-03-05 | 2014-09-12 | 138d? | finish no earlier than 2014-09-12 | C4 | 1104h | 1104h | CNO_ULI-CT | PCG-32 | Alcatel-Lucent | horst.brinkmann@alcatel-lucent.com | Rel-12 | CP-63 | Kimmo |  |  |  |  |  |
| 774 | 201 | Rel-12 Security small Enhancements | 923d? | 2011-03-23 A | 2014-09-17 A | 100% | 2011-03-23 | 2014-06-18 | 859d? | finish no earlier than 2014-09-17 | S3 | 7384h | 7384h | SEC12 | PCG-29 |  |  | Rel-12 | SP-56 | Mirko |  | SEC12 |  |  |  |
| 775 | 202 | **Security aspects of Public Warning System** | 925d? | 2011-03-23 A | 2014-09-17 A | 100% | 2011-03-23 | 2014-09-17 | 924d? |  | S3; S1 | 36832h | 36832h | PWS_Sec | PCG-26 | ST-Ericsson | john.mattsson@ericsson.com | Rel-12 | SP-51 | Mirko | Public Safety (I-A) | PWS_Sec |  |  |  |
| 776 | 202.1 | Stage 1 for Protection against false PWS Warning Notifications | 65d? | 2012-06-15 A | 2012-09-12 A | 100% | 2012-06-15 | 2012-09-12 | 65d? | finish no earlier than 2012-09-12 | S1 | 512h | 512h | PWS_Sec-SA1 | PCG-29 | Vodafone | adrian.neal@vodafone.com | Rel-12 | SP-56 | Alain | Public Safety (I-A) |  |  |  |  |
| 777 | 202.2 | TR on SA3 part for Security aspects of Public Warning System | 921d? | 2011-03-23 A | 2014-09-17 A | 100% | 2011-03-23 | 2014-09-17 | 921d? | finish no earlier than 2014-09-17 | S3 | 7360h | 7360h | PWS_Sec-SA3TR | PCG-26 | ST-Ericsson | john.mattsson@ericsson.com | Rel-12 | SP-51 | Mirko | Public Safety (I-A) |  |  |  |  |
| 778 | 202.3 | Deleted - SA3 part for Security aspects of Public Warning System | 852d? | 2011-03-30 A | 2014-06-18 A | 100% | 2011-03-30 | 2014-06-18 | 852d? | finish no earlier than 2014-06-18 | S3 | 6808h | 6808h | PWS_Sec-del1 | PCG-26 | ST-Ericsson | john.mattsson@ericsson.com | Rel-12 | SP-51 | Mirko | Public Safety (I-A) |  |  | PCG-33 | SP-64 |
| 779 | 202.4 | Deleted - Stage 1 for Security aspects of Public Warning System | 330d? | 2011-03-23 A | 2012-06-20 A | 100% | 2011-03-23 | 2012-06-20 | 330d? | start no earlier than 2011-03-23 | S1 | 2640h | 2640h | PWS_Sec-del2 | PCG-26 | ST-Ericsson | john.mattsson@ericsson.com | Rel-12 | SP-51 | Alain | Public Safety (I-A) |  |  | PCG-29 | SP-56 |
| 780 | 202.5 | Deleted - Stage 2 for Security aspects of Public Warning System | 133d? | 2011-03-23 A | 2011-09-21 A | 100% | 2011-03-23 | 2011-09-21 | 133d? | start no earlier than 2011-03-23 | S2 | 1064h | 1064h | PWS_Sec-del3 | PCG-26 | ST-Ericsson | john.mattsson@ericsson.com | Rel-12 | SP-51 | Maurice | Public Safety (I-A) |  |  | PCG-27 | SP-53 |
| 781 | 202.6 | Deleted - CT1 part for Security aspects of Public Warning System | 328d? | 2011-03-25 A | 2012-06-20 A | 100% | 2011-03-25 | 2012-06-20 | 328d? | finish no earlier than 2012-06-20 | C1 | 2624h | 2624h | PWS_Sec-del4 | PCG-26 | ST-Ericsson | mikael.wass@ericsson.com | Rel-12 | SP-51 | Frederic | Public Safety (I-A) |  |  | PCG-29 | SP-56 |
| 782 | 202.7 | Deleted - RAN2 part for Security aspects of Public Warning System | 128d? | 2011-03-25 A | 2011-09-16 A | 100% | 2011-03-25 | 2011-09-16 | 128d? | start no earlier than 2011-03-25 | R2 | 1024h | 1024h | PWS_Sec-del5 | PCG-26 | ST-Ericsson | john.mattsson@ericsson.com | Rel-12 | SP-51 | Yong-Jun | Public Safety (I-A) |  |  | PCG-27 | RP-53 |
| 783 | 203 | Security enhancements for usage of Generic Bootstrapping Architecture (GBA) from the browser (Stage 2) | 536d? | 2011-06-08 A | 2013-06-20 A | 100% | 2011-06-08 | 2013-06-19 | 536d? | finish no earlier than 2013-06-19 | S3 | 4256h | 4256h | Web_GBA | PCG-27 | Nokia | Silke.Holtmanns@nokia.com | Rel-12 | SP-52 | Mirko |  | Web_GBA |  |  |  |

Notes:
- 754: - / Impacted TSs and TRs: Stage 2/3
- 755: SP#63 completed / Impacted TSs and TRs: 23.402
- 756: CP#62 updated WID CP-130580=>CP-130715 / Impacted TSs and TRs: Stage 3
- 757: CP#65 completion 09/14=>12/14. Exception in CP-140608. TS 24.244 v200 for Approval. Dec.14: 95->100% / Impacted TSs and TRs: 24.302, New TS 24.244 (WLAN control plane protocol for trusted WLAN access to EPC)
- 758: CP#65 completed / Impacted TSs and TRs: 29.273, 29.274, 29.275
- 759: Linked to TR 23.890 Study on Optimized Offloading to WLAN in 3GPP-RAT mobility (FS_WORM), SAE for support for non-3GPP accesses, Multi-Access PDN Connectivity (MAPCON), IP Flow Mobility and Seamless WLAN Offload (IFOM), CS Fallback in EPS (SAES-CSFB) / Impacted TSs and TRs: Stage 2/3
- 760: SP#62 completed / Impacted TSs and TRs: 23.272, 23.401, 23.402
- 761: CP#64 completed. Stage 3 enabling differentiation/prioritization of 3GPP RATs relative to WLAN for traffic flow routing based on Inter-System Routing Policies / Impacted TSs and TRs: 24.302, 24.312
- 762: Rel-11 Network Provided Location Information for IMS (NWK-PL2IMS) covers the case where UE is served by a 3GPP RAN. This WI covers the case where the UE is served by a TWAN / Impacted TSs and TRs: Stage 2/3
- 763: SP#63 completed / Impacted TSs and TRs: 23.203, 23.228, 23.402
- 764: - / Impacted TSs and TRs: Stage 3
- 765: CP#64 completed / Impacted TSs and TRs: 29.212, 29.214
- 766: CP#65 completed / Impacted TSs and TRs: 24.229
- 767: CP#65 completed / Impacted TSs and TRs: 29.273, 29.274, 29.275, 29.328, 29.329
- 768: - / Impacted TSs and TRs: Stage 2/3
- 769: SP#63 completed / Impacted TSs and TRs: 23.060, 23.203, 23.401
- 770: SP#65 New WID approved & completed. Introduction of Presence Reporting Areas for Charging / Impacted TSs and TRs: 32.251, 32.298, 32.299
- 771: Specify Stage 3 procedures to support the ULI signalling optimizations / Impacted TSs and TRs: Stage 3
- 772: CP#64 completed / Impacted TSs and TRs: 29.212, 29.213
- 773: CP#65 completed / Impacted TSs and TRs: 23.008, 29.060, 29.274
- 774: SEC12 is an umbrella Feature for Security related TEI12 type of changes that are not part of any other dedicated feature / Impacted TSs and TRs: Stage 2/3
- 775: -
- 776: SP#57 completed. Specify reqs to protect against false PWS Warning Notifications (Optional as not all regions/countries require this functionality). WID covers all objectives in SA3 PWS_Sec Feature-level WID replacing the original Stage 1 UID_510154 / Impacted TSs and TRs: 22.268
- 777: SP#65 completed. TR 33.969v100 for 1-step Approval. Former TR 33.869 changed to 33.969. / Impacted TSs and TRs: New TR 33.869 changed to 33.969
- 778: SP#64 stopped / Impacted TSs and TRs: New TS 33.269
- 779: Completed in Rel-9 under PWS. SP#55 stopped, Stage 1 requirements removed from Rel-9 onwards (SP-120172). AP 55/1: SA1 to align Stage 1 PWS security for Rel-12. SA1 new WID PWS Security UID_560029. / Impacted TSs and TRs: 22.268
- 780: SP#53 work stopped as already done in previous releases / Impacted TSs and TRs: 23.401
- 781: TSG#56 work stopped. SP#56 updated WID SP-110223=>SP-120334 (removed all but SA3 impacted specs) / Impacted TSs and TRs: 23.041
- 782: RP#53 work stopped as no WI in RAN / Impacted TSs and TRs: 36.331
- 783: SP#60 completed / Impacted TSs and TRs: 33.220, 33.222, New TR 33.823

| ID | WBS | Task | Duration | Start | Finish | Complete | Remaining | Baseline start | Baseline finish | Baseline duration | Total slack | Constraint | Resources | Work | Actual work | Acronym | PCG approved | WI rapporteur name | Release | TSG approved | MCC resp | Acronym_3GU_Export | Status Report |
| --- | --- | --- | --- | --- | --- | --- | --- | --- | --- | --- | --- | --- | --- | --- | --- | --- | --- | --- | --- | --- | --- | --- | --- |
| 784 | 204 | **Extended IMS media plane security features** | 657d? | 2012-06-20 A | 2014-12-09 A | 100% |  | 2012-06-20 | 2014-12-10 | 655d? |  |  | S3; C4; C1; C3; IETF | 73585.2h | 73585.2h | eMEDIASEC | PCG-29 | Vodafone | Rel-12 | SP-56 | Mirko | eMEDIASEC |  |
| 785 | 204.1 | SA3 part of Extended IMS media plane security features (Stage 2) | 530d? | 2012-06-20 A | 2014-06-18 A | 100% |  | 2012-06-20 | 2014-06-18 | 530d? |  | finish no earlier than 2014-06-18 | S3 | 4185.2h | 4185.2h | eMEDIASEC-SA3 | PCG-29 | Vodafone | Rel-12 | SP-56 | Mirko |  |  |
| 786 | 204.2 | (IETF) SA3 part of Extended IMS media plane security features (RFC 7345) | 591d? | 2012-06-20 A | 2014-09-12 A | 100% |  | 2012-06-20 | 2014-12-10 | 654d? |  | finish no earlier than 2014-09-12 | S3-IETF | 4728h | 4728h | eMEDIASECSA3IETF | PCG-31 | christer.holmberg@ericsson.com | Rel-12 | SP-61 |  |  |  |
| 787 | 204.3 | **CT aspects of Extended IMS media plane security features (Stage 2/3)** | 528d? | 2012-12-13 A | 2014-12-09 A | 100% |  | 2012-12-13 | 2014-12-05 | 523d? |  |  | C4; C1; C3; IETF | 38392h | 38392h | eMEDIASEC-CT | PCG-30 | Alcatel-Lucent | Rel-12 | CP-58 | Kimmo | eMEDIASEC-CT |  |
| 788 | 204.3.1 | TR on Extended IMS media plane security features and TCP related NAT traversal support; IMS H.248 profiles aspects | 461d? | 2012-12-13 A | 2014-09-11 A | 100% |  | 2012-12-13 | 2014-09-12 | 461d? |  | finish no earlier than 2014-09-12 | C4 | 3688h | 3688h | eMEDIASEC-CT | PCG-30 | Alcatel-Lucent | Rel-12 | CP-58 | Kimmo |  |  |
| 789 | 204.3.2 | CT4 part of CT aspects of Extended IMS media plane security features | 520d? | 2012-12-19 A | 2014-12-09 A | 100% |  | 2012-12-19 | 2014-09-12 | 458d? |  | finish no earlier than 2014-12-09 | C4 | 4160h | 4160h | eMEDIASEC-CT | PCG-30 | Alcatel-Lucent | Rel-12 | CP-58 | Kimmo |  | CP-140479 |
| 790 | 204.3.3 | (IETF) CT4 part of Extended IMS media plane security features (RFC 7345) | 457d? | 2012-12-18 A | 2014-09-11 A | 100% |  | 2012-12-18 | 2014-12-05 | 519d? |  | finish no earlier than 2014-09-11 | C4-IETF | 3656h | 3656h | eMEDIASEC-CT | PCG-32 | christer.holmberg@ericsson.com | Rel-12 | CP-62 |  |  |  |
| 791 | 204.3.4 | (IETF) CT4 part of Extended IMS media plane security features (draft-schwarz-mmusic-sdp-for-gw) | 129d? | 2014-06-12 A | 2014-12-09 A | 100% |  | 2014-06-12 | 2014-12-05 | 127d? |  | finish no earlier than 2014-12-09 | C4-IETF | 1032h | 1032h | eMEDIASEC-CT | PCG-33 | christer.holmberg@ericsson.com | Rel-12 | CP-64 |  |  |  |
| 792 | 204.3.5 | CT1 part of CT aspects of Extended IMS media plane security features | 463d? | 2012-12-13 A | 2014-09-11 A | 100% |  | 2012-12-13 | 2014-09-12 | 463d? |  | finish no earlier than 2014-09-12 | C1 | 3696h | 3696h | eMEDIASEC-CT | PCG-30 | Alcatel-Lucent | Rel-12 | CP-58 | Frederic |  |  |
| 793 | 204.3.6 | (IETF) CT1 part of Extended IMS media plane security features (RFC 7345) | 137d? | 2014-03-06 A | 2014-09-11 A | 100% |  | 2014-03-06 | 2014-12-05 | 197d? |  | finish no earlier than 2014-09-11 | C1-IETF | 1096h | 1096h | eMEDIASEC-CT | PCG-32 | christer.holmberg@ericsson.com | Rel-12 | CP-62 |  |  |  |
| 794 | 204.3.7 | CT3 part of CT aspects of Extended IMS media plane security features | 521d? | 2012-12-19 A | 2014-12-09 A | 100% |  | 2012-12-19 | 2014-06-13 | 394d? |  | finish no earlier than 2014-12-09 | C3 | 4168h | 4168h | eMEDIASEC-CT | PCG-30 | Alcatel-Lucent | Rel-12 | CP-58 | Adrian |  | CP-140569 |
| 795 | 205 | Lawful Interception in the 3GPP Rel-12 | 592d? | 2012-09-17 A | 2014-12-12 A | 100% |  | 2012-09-17 | 2014-09-12 | 526d? |  | finish no earlier than 2014-12-12 | S3 | 4736h | 4736h | LI12 | PCG-29 | PIDS, Alcatel-Lucent | Rel-12 | SP-57 | Mirko | LI12 |  |
| 796 | 206 | **Tunneling of UE Services over Restrictive Access Networks (Stage 2/3)** | 401d? | 2012-12-13 A | 2014-06-18 A | 100% |  | 2012-12-13 | 2014-06-18 | 401d? |  |  | S3; C1 | 11662.5h | 11662.5h | TURAN | PCG-30 | Acme Packet | Rel-12 | SP-58 | Mirko | TURAN |  |
| 797 | 206.1 | SA3 part of Tunneling of UE Services over Restrictive Access Networks (Stage 2/3) | 400d? | 2012-12-13 A | 2014-06-18 A | 100% |  | 2012-12-13 | 2014-06-18 | 400d? |  | finish no earlier than 2014-06-18 | S3 | 3168h | 3168h | TURAN-SA3 | PCG-30 | Acme Packet | Rel-12 | SP-58 | Mirko |  |  |
| 798 | 206.2 | CT aspects of Tunneling of UE Services over Restrictive Access Networks (Stage 3) | 264d? | 2013-06-14 A | 2014-06-13 A | 100% |  | 2013-06-14 | 2014-06-13 | 264d? |  | finish no earlier than 2014-06-13 | C1 | 2094.45h | 2094.45h | TURAN-CT | PCG-31 | Huawei | Rel-12 | CP-60 | Frederic | TURAN-CT |  |
| 799 | 207 | Specification of the TUAK Algorithm Set | 139d? | 2013-12-09 A | 2014-06-18 A | 100% |  | 2013-12-09 | 2014-06-18 | 139d? |  | finish no earlier than 2014-06-18 | S3 | 1112h | 1112h | STAS | PCG-32 | Vodafone | Rel-12 | SP-62 | Mirko | STAS |  |
| 800 | 208 | **Codec for Enhanced Voice Services** | 1510d? | 2010-03-25 A | 2015-12-15 | 87% | 201.74d? | 2010-03-25 | 2014-12-12 | 1245d? | 392d |  | S4; S1; C4; C1; C3 | 84792h | 21368.8h | EVS_codec | PCG-24 | Huawei | Rel-12 | SP-47 | Paolo | EVS_codec |  |
| 801 | 208.1 | Stage 1 for Codec for Enhanced Voice Services | 1d? | 2010-03-25 A | 2010-03-25 A | 100% |  | 2010-03-25 | 2010-03-25 | 1d? |  | start no earlier than 2010-03-25 | S1 | 8h | 8h | EVS_codec-SA1 | PCG-24 | Huawei | Rel-12 | SP-47 | Paolo |  |  |
| 802 | 208.2 | Stage 2/3 for Codec for Enhanced Voice Services | 1240d? | 2010-03-25 A | 2014-12-12 | 95% | 62d? | 2010-03-25 | 2014-09-17 | 1178d? | 654d | finish no earlier than 2014-12-12 | S4 | 9896h | 9400h | EVS_codec-SA4 | PCG-24 | Huawei | Rel-12 | SP-47 | Paolo |  | SP-140467 |
| 803 | 208.3 | TR on Performance characterization of Codec for Enhanced Voice Services | 1239d? | 2010-03-25 A | 2014-12-12 | 90% | 123.9d? | 2010-03-25 | 2014-12-12 | 1239d? | 654d | finish no earlier than 2014-12-12 | S4 | 9888h | 8896.8h | EVS_codec-SA4TR | PCG-24 | Huawei | Rel-12 | SP-47 | Paolo |  | SP-140467 |
| 804 | 208.4 | **CT impacts of codec for Enhanced Voice Services** | 63d? | 2014-09-16 A | 2014-12-09 A | 100% |  |  |  |  |  |  | C4; C1; C3 | 3024h | 3024h | EVS_codec-CT | PCG-33 | Nokia Networks | Rel-12 | CP-65 |  | EVS_codec-CT |  |
| 805 | 208.4.1 | CT4 part of CT impacts of codec for Enhanced Voice Services | 63d? | 2014-09-16 A | 2014-12-09 A | 100% |  |  |  |  |  | finish no earlier than 2014-12-09 | C4 | 504h | 504h | EVS_codec-CT | PCG-33 | Nokia Networks | Rel-12 | CP-65 |  |  | CP-140478 |
| 806 | 208.4.2 | CT1 part of CT impacts of codec for Enhanced Voice Services | 63d? | 2014-09-16 A | 2014-12-09 A | 100% |  |  |  |  |  | finish no earlier than 2014-12-09 | C1 | 504h | 504h | EVS_codec-CT | PCG-33 | Nokia Networks | Rel-12 | CP-65 |  |  | CP-140618 |
| 807 | 208.4.3 | CT3 part of CT impacts of codec for Enhanced Voice Services | 63d? | 2014-09-16 A | 2014-12-09 A | 100% |  |  |  |  |  | finish no earlier than 2014-12-09 | C3 | 504h | 504h | EVS_codec-CT | PCG-33 | Nokia Networks | Rel-12 | CP-65 |  |  | CP-140560 |
| 808 | 208.5 | UE Conformance Test Aspects - Codec for Enhanced Voice Services (EVS) | 197d? | 2015-03-16 | 2015-12-15 |  |  |  |  |  | 392d | finish no earlier than 2015-12-15 | R5 | 1576h |  | EVS_codec-UEConTest | PCG-34 | Ericsson | Rel-12 | RP-67 |  |  |  |

Notes:
- 784: Triggered by Rel-11 TR 33.829 Study on Extended IMS media plane security features (FS_eMEDIASEC) / Impacted TSs and TRs: Stage 2/3 / WI rapporteur e-mail: Aguibou.Barry@vodafone.com
- 785: SP#64 completed / Impacted TSs and TRs: 33.328 / WI rapporteur e-mail: Aguibou.Barry@vodafone.com
- 786: SP#65 completed / Impacted TSs and TRs: RFC 7345 (was draft-ietf-mmusic-udptl-dtls) / WI rapporteur e-mail: christer.holmberg@ericsson.com
- 787: - / Impacted TSs and TRs: Stage 2/3 / WI rapporteur e-mail: bruno.landais@alcatel-lucent.com
- 788: CP#65 completed. TR 29.828v200 for Approval. 2/4/15: acronym changed to eMEDIASEC-CT / Impacted TSs and TRs: New TR 29.828 / WI rapporteur e-mail: bruno.landais@alcatel-lucent.com
- 789: CP#65 completion 09/14=>12/14. Exception in CP-140479. Dec.14: 90->100. 2/4/15: acronym changed to eMEDIASEC-CT / Impacted TSs and TRs: 23.334, 29.334, 29.238, 23.333, 29.333 / WI rapporteur e-mail: bruno.landais@alcatel-lucent.com
- 790: CP#65 completed. 2/4/15: acronym changed to eMEDIASEC-CT / Impacted TSs and TRs: RFC 7345 (was draft-ietf-mmusic-udptl-dtls) / WI rapporteur e-mail: christer.holmberg@ericsson.com
- 791: Work in progress. 2/4/15: acronym changed to eMEDIASEC-CT / Impacted TSs and TRs: draft-schwarz-mmusic-sdp-for-gw / WI rapporteur e-mail: christer.holmberg@ericsson.com
- 792: CP#65 completed. 2/4/15: acronym changed to eMEDIASEC-CT / Impacted TSs and TRs: 23.218, 24.147, 24.229, 24.247 / WI rapporteur e-mail: bruno.landais@alcatel-lucent.com
- 793: CP#65 completed. 2/4/15: acronym changed to eMEDIASEC-CT / Impacted TSs and TRs: RFC 7345 (was draft-ietf-mmusic-udptl-dtls) / WI rapporteur e-mail: christer.holmberg@ericsson.com
- 794: CP#65 completion 06/14=>12/14. Level 100%=>80%. Exception in CP-140569. CP#64 completed. Dec.14: 80->100. 2/4/15: acronym changed to eMEDIASEC-CT / Impacted TSs and TRs: 29.162 / WI rapporteur e-mail: bruno.landais@alcatel-lucent.com
- 795: 3/3/15: 75->100% / Impacted TSs and TRs: 33.106, 33.107, 33.108 / WI rapporteur e-mail: Koen Jaspers (k.b.jaspers@minjus.nl), terry.jacobson@alcatel-lucent.com
- 796: Linked to Rel-12 SMURFs. Related to TS 22.278 (EPS) cl.7.1.8 Service Reachability (Firewall traversal for IP based services for non-3GPP access), TS 22.228 (IMS) cl.5 (support Firewall traversal), TR 33.830 (Study on Firewall traversal) / Impacted TSs and TRs: Stage 2/3 / WI rapporteur e-mail: Prashant Kumar (PKumar@acmepacket.com)
- 797: SP#64 completed / Impacted TSs and TRs: 33.203, 33.402 / WI rapporteur e-mail: Prashant Kumar (PKumar@acmepacket.com)
- 798: CP#64 completed. Stage 3 for 2 new SA3 solutions for firewall traversal: 1) UE access to PLMN IP-based services via restrictive non-3GPP Ans, 2) UE access to IMS services via restrictive ANs / Impacted TSs and TRs: 24.229, 24.302, New TS 24.322 / WI rapporteur e-mail: Haitao Wei (weihaitao@huawei.com)
- 799: SP#64 completed. Triggered by SP-130602 LS from ETSI SAGE (TUAK as alternative to Milenage). 12/14: new TS added / Impacted TSs and TRs: New TSs: 35.231, 35.232, 35.233, TR 35.9nn, TR 35.9nn, TR 35.9nn / WI rapporteur e-mail: aguibou.barry@vodafone.com
- 800: Triggered by UID_370045 Study on enhanced voice service requirements for EPS (TR 22.813) / WI rapporteur e-mail: lei.miao@huawei.com
- 801: SP#47 completed / Impacted TSs and TRs: 22.173 / WI rapporteur e-mail: lei.miao@huawei.com
- 802: SP#65 completion 09/14=>12/14. Exception in SP-140467. TS 26.441v200 for Approval. TSs 26.442/44/45/46/47/48/49/50/51v100 for 1-step Approval. Ongoing TS 26.443 EVS Codec ANSI C code (floating point). Dec.14: 90->95 / Impacted TSs and TRs: 26.114, New TS (26.441, 26.442, 26.443, 26.444, 26.445, 26.446, 26.447, 26.448, 26.449, 26.450, 26.451) / WI rapporteur e-mail: lei.miao@huawei.com
- 803: SP#65 completion 09/14=>12/14. Ongoing TR 26.952 EVS Codec Performance Characterization. Exception in SP-140467 / Impacted TSs and TRs: New TR 26.952 / WI rapporteur e-mail: lei.miao@huawei.com
- 804: Stage 3; WID: CP-140492-> CP-140800 / WI rapporteur e-mail: Jan.Kall@nsn.com
- 805: CP#65 exception in CP-140478. Dec.14: 0->100; WID: CP-140492-> CP-140800 / Impacted TSs and TRs: 23.334, 29.232, 29.238, 29.332, 29.333, 29.334 / WI rapporteur e-mail: Jan.Kall@nsn.com
- 806: CP#65 exception in CP-140618. Dec.14: 0->100%; WID: CP-140492-> CP-140800 / Impacted TSs and TRs: 24.229 / WI rapporteur e-mail: Jan.Kall@nsn.com
- 807: CP#65 exception in CP-140560. Dec.14: 20->100; WID: CP-140492-> CP-140800 / Impacted TSs and TRs: 29.163, 29.292 / WI rapporteur e-mail: Jan.Kall@nsn.com

| ID | WBS | Task | Duration | Start | Finish | Complete | Remaining | Baseline start | Baseline finish | Baseline duration | Total slack | Constraint | Resources | Work | Actual work | Acronym | PCG approved | WI rapporteur name | WI rapporteur e-mail | Release | TSG approved | MCC resp | Acronym_3GU_Export | Impacted TSs and TRs | Status Report |
| --- | --- | --- | --- | --- | --- | --- | --- | --- | --- | --- | --- | --- | --- | --- | --- | --- | --- | --- | --- | --- | --- | --- | --- | --- | --- |
| 809 | 209 | **Coordination of Video Orientation** | 400d? | 2012-06-07 A | 2013-12-06 A | 100% |  | 2012-06-07 | 2013-12-06 | 400d? |  |  | S4; C4; C1; C3 | 20496.8h | 20496.8h | CVO | PCG-29 | Ericsson | frederic.gabin@ericsson.com | Rel-12 | SP-56 | Paolo | CVO |  |  |
| 810 | 209.1 | SA4 part of Coordination of Video Orientation | 196d? | 2012-06-07 A | 2013-03-06 A | 100% |  | 2012-06-07 | 2013-03-06 | 196d? |  | finish no earlier than 2013-03-06 | S4 | 1560h | 1560h | CVO-SA4 | PCG-29 | Ericsson | frederic.gabin@ericsson.com | Rel-12 | SP-56 | Paolo |  | 26.114, 26.141, 26.234, 26.346 |  |
| 811 | 209.2 | **CT aspects of Coordination of Video Orientation** | 129d? | 2013-06-14 A | 2013-12-06 A | 100% |  | 2013-06-14 | 2013-12-06 | 129d? |  |  | C4; C1; C3 | 6136.8h | 6136.8h | CVO-CT | PCG-31 | Ericsson | nevenka.biondic@ericsson.com | Rel-12 | CP-60 | Kimmo | CVO-CT | Stage 2/3 |  |
| 812 | 209.2.1 | CT4 part of CT aspects of Coordination of Video Orientation | 128.05d? | 2013-06-14 A | 2013-12-06 A | 100% |  | 2013-06-14 | 2013-12-06 | 128.05d? |  | finish no earlier than 2013-12-06 | C4 | 1008.4h | 1008.4h | CVO-CT | PCG-31 | Ericsson | nevenka.biondic@ericsson.com | Rel-12 | CP-60 | Kimmo |  | 23.333, 23.334, 29.238, 29.332, 29.333, 29.334 |  |
| 813 | 209.2.2 | CT1 part of CT aspects of Coordination of Video Orientation | 129d? | 2013-06-14 A | 2013-12-06 A | 100% |  | 2013-06-14 | 2013-12-06 | 129d? |  | finish no earlier than 2013-12-06 | C1 | 1016h | 1016h | CVO-CT | PCG-31 | Ericsson | nevenka.biondic@ericsson.com | Rel-12 | CP-60 | Frederic |  | 24.229 |  |
| 814 | 209.2.3 | CT3 part of CT aspects of Coordination of Video Orientation | 127.05d? | 2013-06-14 A | 2013-12-06 A | 100% |  | 2013-06-14 | 2013-12-06 | 127.05d? |  | finish no earlier than 2013-12-06 | C3 | 1016.4h | 1016.4h | CVO-CT | PCG-31 | Ericsson | nevenka.biondic@ericsson.com | Rel-12 | CP-60 | Adrian |  | 29.162, 29.163 |  |
| 815 | 210 | **High Efficiency Video Coding** | 594d? | 2012-09-12 A | 2014-12-05 | 81% | 115.23d? | 2012-09-12 | 2014-12-05 | 591d? | 659d |  | S4; IETF | 21576h | 13508h | HEVC | PCG-29 | Qualcomm | Ye-Kui Wang (yekuiw@qti.qualcomm.com) | Rel-12 | SP-57 | Paolo | HEVC |  |  |
| 816 | 210.1 | TR on Evaluation of High Efficiency Video Coding for 3GPP Services | 464d? | 2012-09-12 A | 2014-06-19 A | 100% |  | 2012-09-12 | 2014-06-19 | 464d? |  | finish no earlier than 2014-06-18 | S4 | 3704h | 3704h | HEVC-SA4TR | PCG-29 | Qualcomm | Ye-Kui Wang (yekuiw@qti.qualcomm.com) | Rel-12 | SP-57 | Paolo |  | New TR 26.906 |  |
| 817 | 210.2 | High Efficiency Video Coding in 3GPP services PSS, MBMS, DASH, MMS, MTSI, IMS Messaging and Presence | 462d? | 2012-09-17 A | 2014-06-18 A | 100% |  | 2012-09-17 | 2014-06-18 | 462d? |  | finish no earlier than 2014-06-18 | S4 | 3688h | 3688h | HEVC-SA4 | PCG-29 | Qualcomm | Ye-Kui Wang (yekuiw@qti.qualcomm.com) | Rel-12 | SP-57 | Paolo |  | 26.114, 26.140, 26.141, 26.234, 26.244, 26.247, 26.346 |  |
| 818 | 210.3 | (IETF) High Efficiency Video Coding | 587d? | 2012-09-17 A | 2014-12-05 | 50% | 293.5d? | 2012-09-17 | 2014-12-05 | 587d? | 659d | finish no earlier than 2014-12-05 | S4-IETF | 4696h | 2348h | HEVC-SA4IETF | PCG-32 | Thomas Stockhammer | Thomas Stockhammer | Rel-12 | CP-63 |  |  | draft-ietf-payload-rtp-h265 |  |
| 819 | 211 | Mobile stereoscopic 3D services extensions | 200d? | 2012-12-12 A | 2013-09-11 A | 100% |  | 2012-12-12 | 2013-09-11 | 200d? |  | finish no earlier than 2013-09-11 | S4 | 1568h | 1568h | M3DV_Ext | PCG-30 | Huawei | lukasz.kondrad@huawei.com | Rel-12 | SP-58 | Paolo | M3DV_Ext | 26.114, 26.245, 26.247, 26.430 |  |
| 820 | 212 | **IMS-based Streaming and Download Delivery Enhancements** | 329d? | 2012-12-12 A | 2014-03-07 A | 100% |  | 2012-12-12 | 2014-03-07 | 329d? |  |  | S4 | 7800h | 7800h | IMS_SDE | PCG-30 | Intel | ozgur.oyman@intel.com | Rel-12 | SP-58 | Paolo | IMS_SDE |  |  |
| 821 | 212.1 | TR on IMS-based Streaming and Download Delivery Enhancements | 326d? | 2012-12-12 A | 2014-03-07 A | 100% |  | 2012-12-12 | 2014-03-07 | 326d? |  | finish no earlier than 2014-03-07 | S4 | 2584h | 2584h | IMS_SDE-SA4TR | PCG-30 | Intel | ozgur.oyman@intel.com | Rel-12 | SP-58 | Paolo |  | new TR 26.827 |  |
| 822 | 212.2 | Specification on IMS-based Streaming and Download Delivery Enhancements | 327d? | 2012-12-13 A | 2014-03-07 A | 100% |  | 2012-12-13 | 2014-03-07 | 327d? |  | finish no earlier than 2014-03-07 | S4 | 2584h | 2584h | IMS_SDE-SA4 | PCG-30 | Intel | ozgur.oyman@intel.com | Rel-12 | SP-58 | Paolo |  | 26.237 |  |
| 823 | 213 | **Acoustic Requirements and Test methods for IMS-based conversational speech services over LTE** | 532d? | 2012-12-12 A | 2014-12-12 A | 100% |  | 2012-12-12 | 2014-09-17 | 467d? |  |  | S4 | 14224h | 14224h | ART_LTE | PCG-30 | Qualcomm | Andre Schevciw (aschevci@qualcomm.com) | Rel-12 | SP-58 | Paolo | ART_LTE | Stage 3 |  |
| 824 | 213.1 | Acoustic Requirements and Test methods for IMS-based conversational speech services over LTE - NarrowBand and WideBand aspects | 265d? | 2012-12-12 A | 2013-12-11 A | 100% |  | 2012-12-12 | 2013-12-11 | 265d? |  | finish no earlier than 2013-12-11 | S4 | 2088h | 2088h | ART_LTE-NBWB | PCG-30 | Sony Mobile Communications | peter.isberg@sonymobile.com | Rel-12 | SP-58 | Paolo | ART_LTE-NBWB | 26.131, 26.132 |  |
| 825 | 213.2 | Acoustic Requirements and Test methods for IMS-based conversational speech services over LTE - UE Delay aspects | 462d? | 2012-12-12 A | 2014-09-17 A | 100% |  | 2012-12-12 | 2014-09-17 | 461d? |  | finish no earlier than 2014-09-17 | S4 | 3696h | 3696h | ART_LTE-UED | PCG-30 | AT&T, Orange | luisa.marchetto@att.com, stephane.ragot@orange.com | Rel-12 | SP-58 | Paolo | ART_LTE-UED | 26.131, 26.132 |  |
| 826 | 213.3 | Acoustic Requirements and Test methods for IMS-based conversational speech services over LTE - Super wideband and fullband aspects | 523d? | 2012-12-12 A | 2014-12-12 A | 100% |  | 2012-12-12 | 2014-09-17 | 461d? |  | finish no earlier than 2014-12-12 | S4 | 4184h | 4184h | ART_LTE-SUPER | PCG-30 | Sony Mobile Communications | peter.isberg@sonymobile.com | Rel-12 | SP-58 | Paolo | ART_LTE-SUPER | 26.131, 26.132 | SP-140470 |
| 827 | 214 | **MBMS Improvements** | 471d? | 2013-03-06 A | 2014-12-12 A | 100% |  | 2013-03-06 | 2014-09-17 | 406d? |  |  | S4 | 18584h | 18584h | MI | PCG-30 | Ericsson | eric.turcotte@ericsson.com | Rel-12 | SP-59 | Paolo | MI |  | SP-140471 |
| 828 | 214.1 | TR on Enhanced MBMS Operation | 463d? | 2013-03-06 A | 2014-12-12 A | 100% |  | 2013-03-06 | 2014-09-17 | 401d? |  | finish no earlier than 2014-12-12 | S4 | 3704h | 3704h | MI-EMOTR | PCG-30 | Huawei | Zhiming Li (lizhiming@huawei.com) | Rel-12 | SP-59 | Paolo |  | New TR 26.848 | SP-140471 |
| 829 | 214.2 | Enhanced MBMS Operation | 463d? | 2013-03-06 A | 2014-12-12 A | 100% |  | 2013-03-06 | 2014-09-17 | 401d? |  | finish no earlier than 2014-12-12 | S4 | 3704h | 3704h | MI-EMO | PCG-30 | Huawei | Zhiming Li (lizhiming@huawei.com) | Rel-12 | SP-59 | Paolo | MI-EMO | 26.247, 26.346 | SP-140471 |
| 830 | 214.3 | TR on MBMS operation on Demand | 463d? | 2013-03-06 A | 2014-12-12 A | 100% |  | 2013-03-06 | 2014-09-17 | 401d? |  | finish no earlier than 2014-12-12 | S4 | 3704h | 3704h | MI-MooDTR | PCG-30 | Qualcomm | Charles Lo (clo@qti.qualcomm.com) | Rel-12 | SP-59 | Paolo |  | New TR 26.849 | SP-140471 |
| 831 | 214.4 | MBMS operation on Demand | 463d? | 2013-03-06 A | 2014-12-12 A | 100% |  | 2013-03-06 | 2014-09-17 | 401d? |  | finish no earlier than 2014-12-12 | S4 | 3704h | 3704h | MI-MooD | PCG-30 | Qualcomm | Charles Lo (clo@qti.qualcomm.com) | Rel-12 | SP-59 | Paolo | MI-MooD | 26.346 | SP-140471 |
| 832 | 215 | **End-to-End Multimedia Telephony Service for IMS (MTSI) extensions** | 667d? | 2013-03-06 A | 2015-09-14 | 99% | 0d? | 2013-03-06 | 2015-03-13 | 533d? | 0d |  | S4 | 32648h | 30552h | E2EMTSI | PCG-30 | Ericsson | tomas.frankkila@ericsson.com | Rel-12 | SP-59 | Paolo | E2EMTSI | 26.114 |  |
| 833 | 215.1 | S4 aspects of End-to-End Multimedia Telephony Service for IMS (MTSI) extensions | 406d? | 2013-03-06 A | 2014-09-16 A | 100% |  | 2013-03-06 | 2015-03-13 | 533d? |  | finish no earlier than 2014-09-17 | S4 | 3248h | 3248h | E2EMTSI | PCG-30 | Ericsson | tomas.frankkila@ericsson.com | Rel-12 | SP-59 | Paolo | E2EMTSI | 26.114 |  |

Notes:
- 809: CP#62 completed. Resolve backward compatible video orientation mis-alignment in MTSI real-time video communication via interaction between MTSI video clients at call setup & during mid-call of the video orientation for correct local rendering
- 810: SP#59 completed. Resolve backward compatible video orientation mis-alignment in MTSI real-time video communication via interaction between MTSI video clients at call setup & during mid-call of the video orientation for correct local rendering
- 811: Complete CVO support (both, basic 2 bit orientation and additional option for extra 6 bit granularity) within CN protocols/procedures for IMS nodes, e.g. IMS ALG/AGW,IBCF/TrGW,MRFC/MRFP & add support of CVO-related SDP attributes to be negotiated by UE
- 812: CP#62 completed
- 813: CP#62 completed
- 814: CP#62 completed
- 815: Specify the support of HEVC in 3GPP services (PSS, DASH, MTSI, MMS, MBMS, IMS Messaging and Presence)
- 816: SP#64 completed. TR 26.906v200 for Approval
- 817: SP#64 completed
- 818: Submitted to IESG for publication
- 819: SP#61 completed. Related to Rel-11 Study On Mobile 3D Video Coding (FS_M3DVC) TR 26.905 and Rel-11 Mobile 3D Video Coding (M3DVC)
- 820: Provide an extension of IMS based PSS and MBMS user services
- 821: SP#63 completed. Identify use cases and requirements based on Rel-10/11 PSS and MBMS functionality to be addressed for IMS-based streaming and download enhancements
- 822: SP#63 completed. Develop procedures towards enabling the IMS-based extensions of the identified use cases in TS 26.237. Refine existing MBMS download procedures to enable IMS-based MBMS file repair with the use of conventional HTTP web servers.
- 823: Triggered by Rel-12 Feature Codec for Enhanced Voice Services (EVS_codec) UID_470030. Need for super wideband acoustic requirements and test methods
- 824: SP#62 completed
- 825: SP#65 completed
- 826: SP#65 completion 09/14=>12/14. Exception in SP-140470. Dec.14: 65->100
- 827: Stage 3 based on existing Stage 2 in TS 23.246 MBMS Architecture and functional description
- 828: SP#65 completion 09/14=>12/14. Exception in SP-140471. SP#63 TR 26.848v100 for Information. Dec.14: 85->100.
- 829: SP#65 completion 09/14=>12/14. Exception in SP-140471. Dec.14: 85->100
- 830: SP#65 completion 09/14=>12/14. Exception in SP-140471. SP#63 TR 26.849v100 for Information. Dec.14: 75->100
- 831: SP#65 completion 09/14=>12/14. Exception in SP-140471. Dec.14: 75->100
- 832: SP#65 completed. Updated WID SP-130670=>SP-140594. Reduced Scope & Objectives. Moved work on new TR 26.924, etc. to Rel-13. Co-ordinate with CT1/3/4. Linked to SA4 Rel-7 Media handling and interaction in MTSI (MTSI-MHI) UID_7040
- 833: SP#65 completed. Updated WID SP-130670=>SP-140594. Reduced Scope & Objectives. Moved work on new TR 26.924, etc. to Rel-13. Co-ordinate with CT1/3/4. Linked to SA4 Rel-7 Media handling and interaction in MTSI (MTSI-MHI) UID_7040

| ID | WBS | Task | Duration | Start | Finish | Complete | Baseline start | Baseline finish | Baseline duration | Constraint | Resources | Work | Actual work | Acronym | PCG approved | WI rapporteur name | WI rapporteur e-mail | Release | TSG approved | MCC resp | Acronym_3GU_Export | Special Focus Doc | Status Report |
| --- | --- | --- | --- | --- | --- | --- | --- | --- | --- | --- | --- | --- | --- | --- | --- | --- | --- | --- | --- | --- | --- | --- | --- |
| 834 | 215.2 | **CT aspects of End-to-End Multimedia Telephony Service for IMS (MTSI) extensions** | 589d? | 2013-06-21 A | 2015-09-14 A | 100% | 2013-06-20 | 2014-09-12 | 326d? |  | C3; C1; C4 | 24064h | 24064h | E2EMTSI-CT | PCG-31 | Ericsson | susana.fernandez@ericsson.com | Rel-12 | CP-60 | Adrian |  |  |  |
| 835 | 215.2.1 | CT3 part of CT aspects of End-to-End Multimedia Telephony Service for IMS (MTSI) extensions | 589d? | 2013-06-21 A | 2015-09-14 A | 100% | 2013-06-20 | 2014-09-12 | 326d? | finish no earlier than 2015-09-14 | C3 | 4712h | 4712h | E2EMTSI-CT | PCG-31 | Ericsson | susana.fernandez@ericsson.com | Rel-12 | CP-60 | Adrian |  |  |  |
| 836 | 215.2.2 | CT1 part of CT aspects of End-to-End Multimedia Telephony Service for IMS (MTSI) extensions | 326d? | 2013-06-21 A | 2014-09-12 A | 100% | 2013-06-20 | 2014-09-12 | 326d? | finish no earlier than 2014-09-12 | C1 | 2608h | 2608h | E2EMTSI-CT | PCG-31 | Ericsson | susana.fernandez@ericsson.com | Rel-12 | CP-60 | Frederic |  |  |  |
| 837 | 215.2.3 | CT4 part of CT aspects of End-to-End Multimedia Telephony Service for IMS (MTSI) extensions | 326d? | 2013-06-21 A | 2014-09-12 A | 100% | 2013-06-20 | 2014-09-12 | 326d? | finish no earlier than 2014-09-12 | C4 | 2608h | 2608h | E2EMTSI-CT | PCG-31 | Ericsson | susana.fernandez@ericsson.com | Rel-12 | CP-60 | Kimmo |  |  |  |
| 838 | 216 | Video Coding Enhancements in IMS Messaging and Presence | 64d? | 2013-12-11 A | 2014-03-07 A | 100% | 2013-12-11 | 2014-03-07 | 64d? | finish no earlier than 2014-03-07 | S4 | 504h | 504h | VCEIMP | PCG-32 | Ericsson | frederic.gabin@ericsson.com | Rel-12 | SP-62 | Paolo | VCEIMP |  |  |
| 839 | 217 | Video Telephony Robustness Improvements | 66d? | 2014-06-18 A | 2014-09-16 A | 100% | 2014-06-18 | 2014-09-17 | 66d? | finish no earlier than 2014-09-17 | S4 | 528h | 528h | VTRI | PCG-33 | Qualcomm | Muhammed Coban (mcoban@qti.qualcomm.com) | Rel-12 | SP-64 |  | VTRI |  |  |
| 840 | 218 | **Rel-12 Operations, Administration, Maintenance and Provisioning (OAM&P)** | 857d? | 2011-09-21 A | 2014-12-12 A | 100% | 2011-09-21 | 2014-09-17 | 792d? |  | S5 | 58352.5h | 58352.5h | OAM12 | PCG-29 |  |  | Rel-12 | SP-56 | Mirko | OAM12 |  |  |
| 841 | 218.1 | **Rel-12 Self-Organizing Networks (SON) - OAM aspects** | 591d? | 2011-09-21 A | 2013-12-11 A | 100% | 2011-09-21 | 2013-12-11 | 591d? |  | S5 | 9408h | 9408h | OAM12-SON | PCG-29 |  |  | Rel-12 | SP-56 | Mirko | OAM12-SON | HNB, SON |  |
| 842 | 218.1.1 | Multi-vendor Plug and Play eNB connection to the network | 586d? | 2011-09-21 A | 2013-12-11 A | 100% | 2011-09-21 | 2013-12-11 | 586d? | finish no earlier than 2013-12-11 | S5 | 4680h | 4680h | SON-NM-MUPPET | PCG-29 | NSN | anatoly.andrianov@nsn.com | Rel-12 | SP-56 | Mirko | SON-NM-MUPPET | HNB, SON |  |
| 843 | 218.2 | **Compliance of 3GPP SA5 specifications to the NGMN Next Generation Converged Operations Requirements (NGCOR)** | 596d? | 2012-06-20 A | 2014-09-17 A | 100% | 2012-06-20 | 2014-09-17 | 595d? |  | S5 | 11616.5h | 11616.5h | OAM-NGMN_NGCOR | PCG-29 | Huawei | christian.toche@huawei.com | Rel-12 | SP-56 | Mirko | OAM-NGMN_NGCOR |  |  |
| 844 | 218.2.1 | Converged Management Model Alignment (Phase 2) | 593d? | 2012-06-20 A | 2014-09-17 A | 100% | 2012-06-20 | 2014-09-17 | 593d? | finish no earlier than 2014-09-17 | S5 | 4744h | 4744h | OAM-MODAL | PCG-29 | NSN | olaf.pollakowski@nsn.com | Rel-12 | SP-56 | Mirko | OAM-MODAL |  |  |
| 845 | 218.2.2 | 3GPP Fault Management Solution Profile for NGMN NGCOR | 266d? | 2012-06-20 A | 2013-06-19 A | 100% | 2012-06-20 | 2013-06-19 | 266d? | finish no earlier than 2013-06-19 | S5 | 2104.53h | 2104.53h | OAM-FMSP | PCG-29 | Ericsson | thomas.tovinger@ericsson.com | Rel-12 | SP-56 | Mirko | OAM-FMSP |  |  |
| 846 | 218.3 | **Network Management for 3GPP Interworking WLAN** | 793d? | 2011-09-21 A | 2014-09-17 A | 100% | 2011-09-21 | 2014-06-18 | 727d? |  | S5 | 17232h | 17232h | OAM-IWLAN | PCG-27 | China Mobile | Chengang@chinamobile.com, lijian@chinamobile.com | Rel-12 | SP-53 | Mirko | OAM-IWLAN | WLAN |  |
| 847 | 218.3.1 | Performance measurements part Network Management for 3GPP Interworking WLAN | 785d? | 2011-09-22 A | 2014-09-17 A | 100% | 2011-09-22 | 2014-06-18 | 720d? | finish no earlier than 2014-09-17 | S5 | 6272h | 6272h | OAM-IWLAN-SA5P | PCG-27 | China Mobile | Chengang@chinamobile.com, lijian@chinamobile.com | Rel-12 | SP-53 | Mirko |  | WLAN |  |
| 848 | 218.3.2 | NIM part Network Management for 3GPP Interworking WLAN | 585d? | 2011-09-21 A | 2013-12-11 A | 100% | 2011-09-21 | 2013-12-11 | 585d? | finish no earlier than 2013-12-11 | S5 | 4672h | 4672h | OAM-IWLAN-SA5NM | PCG-27 | China Mobile | Chengang@chinamobile.com, lijian@chinamobile.com | Rel-12 | SP-53 | Mirko |  | WLAN |  |
| 849 | 218.4 | **Rel-12 Network Infrastructure Management** | 267d? | 2013-12-11 A | 2014-12-12 A | 100% | 2013-12-11 | 2014-09-17 | 202d? |  | S5 | 5848h | 5848h | OAM12-NIM | PCG-30 |  |  | Rel-12 | SP-58 | Mirko | OAM12-NIM |  |  |
| 850 | 218.4.1 | Alarm quality improvements | 263d? | 2013-12-11 A | 2014-12-12 A | 100% | 2013-12-11 | 2014-09-17 | 201d? | finish no earlier than 2014-12-12 | S5 | 2104h | 2104h | OAM-AMI-SA5 | PCG-32 | TeliaSonera | tommy.berggren@teliasonera.com | Rel-12 | SP-62 | Mirko | OAM-AMI |  | SP-140544 |
| 851 | 218.4.2 | Radio Planning Tool (RPT) interface | 201d? | 2014-03-07 A | 2014-12-12 A | 100% | 2014-03-07 | 2014-09-17 | 139d? | finish no earlier than 2014-12-12 | S5 | 1608h | 1608h | OAM-RPTi-SA5 | PCG-32 | Nokia Networks | olaf.pollakowski@nsn.com | Rel-12 | SP-63 | Mirko | OAM-RPTi |  | SP-140546 |
| 852 | 218.5 | Deleted - Rel-12 Performance Management | 328d? | 2013-06-21 A | 2014-09-16 A | 100% | 2013-06-21 | 2014-09-17 | 328d? |  | S5 | 2624h | 2624h | OAM12-PM | PCG-30 |  |  | Rel-12 | SP-58 | Mirko | OAM12-PM |  |  |
| 853 | 218.6 | **OAM aspects of Network Sharing** | 267d? | 2013-12-11 A | 2014-12-12 A | 100% | 2013-12-11 | 2014-09-17 | 202d? |  | S5 | 6344h | 6344h | OAM-SHARE | PCG-32 | Orange | jeanmichel.cornily@orange.com | Rel-12 | SP-62 | Mirko | OAM-SHARE |  | SP-140545 |
| 854 | 218.6.1 | OAM aspects of Network Sharing - Concepts and high-level requirements | 263d? | 2013-12-11 A | 2014-12-12 A | 100% | 2013-12-11 | 2014-09-17 | 201d? | finish no earlier than 2014-12-12 | S5 | 2104h | 2104h | OAM-SHARE-SA5c | PCG-32 | Orange | jeanmichel.cornily@orange.com | Rel-12 | SP-62 | Mirko |  |  | SP-140545 |
| 855 | 218.6.2 | OAM aspects of Network Sharing - Impacts on existing specifications | 263d? | 2013-12-12 A | 2014-12-12 A | 100% | 2013-12-12 | 2014-09-17 | 201d? | finish no earlier than 2014-12-12 | S5 | 2104h | 2104h | OAM-SHARE-SA5imp | PCG-32 | Orange | jeanmichel.cornily@orange.com | Rel-12 | SP-62 | Mirko |  |  | SP-140545 |
| 856 | 219 | **Rel-12 Charging** | 402d? | 2012-12-12 A | 2014-06-18 A | 100% | 2012-12-12 | 2014-06-18 | 402d? |  | S5 | 10112h | 10112h | CH12 | PCG-29 |  |  | Rel-12 | SP-57 | Mirko | CH12 |  |  |
| 857 | 219.1 | Short Message Service - Service Center (SMS-SC) Offline Charging | 325d? | 2012-12-12 A | 2014-03-10 A | 100% | 2012-12-12 | 2014-03-07 | 325d? | finish no earlier than 2014-03-07 | S5 | 2592h | 2592h | SMS-SC-CH | PCG-30 | Alcatel-Lucent | maryse.gardella@alcatel-lucent.com | Rel-12 | SP-58 | Mirko | SMS-SC-CH |  |  |
| 858 | 219.2 | Charging per IP - Connectivity Access Network (IP-CAN) Session (Stage 2/3) | 201d? | 2013-09-12 A | 2014-06-18 A | 100% | 2013-09-12 | 2014-06-18 | 201d? | finish no earlier than 2014-06-18 | S5 | 1608h | 1608h | CHIPCAN | PCG-31 | Ericsson | david.shrader@ericsson.com | Rel-12 | SP-61 | Mirko | CHIPS |  |  |
| 859 | 219.3 | Charging using an Alternative Roaming Provider (Stage 2/3) | 202d? | 2013-09-12 A | 2014-06-18 A | 100% | 2013-09-12 | 2014-06-18 | 202d? | finish no earlier than 2014-06-18 | S5 | 1608h | 1608h | CHARP | PCG-31 | Ericsson | david.shrader@ericsson.com | Rel-12 | SP-61 | Mirko | CHARP |  |  |
| 860 | 219.4 | Charging for IMS centralized service (ICS) control (Stage 2/3) | 137d? | 2013-12-11 A | 2014-06-18 A | 100% | 2013-12-11 | 2014-06-18 | 137d? | finish no earlier than 2014-06-18 | S5 | 1088h | 1088h | CHICS | PCG-32 | NSN | Gerald.Goermer@nsn.com | Rel-12 | SP-62 | Mirko | CHICS |  |  |

Notes:
- 834: Stage 2/3. 5/5/15: corrected to be Rel-12. Nothing to be done in the end (covered by Rel-13 QOSE2EMTSI-CT), so 100% / Impacted TSs and TRs: Stage 2/3
- 835: Dec.14: CD: 09/14->09/15. 5/5/15: corrected to be Rel-12. Nothing to be done in the end (covered by Rel-13 QOSE2EMTSI-CT), so 100% / Impacted TSs and TRs: 29.162, 29.163, 29.213, 29.214
- 836: CP#64 completion 06/14=>09/14. 5/5/15: corrected to be Rel-12. Nothing to be done in the end (covered by Rel-13 QOSE2EMTSI-CT), so 100% / Impacted TSs and TRs: 24.229
- 837: CP#64 completion 06/14=>09/14. 5/5/15: corrected to be Rel-12. Nothing to be done in the end (covered by Rel-13 QOSE2EMTSI-CT), so 100% / Impacted TSs and TRs: 23.333, 23.334, 29.238, 29.332, 29.333, 29.334
- 838: SP#63 completed. Linked to Rel-6 Media Codecs and Formats for IMS Messaging and Presence (PRESNC-COFIMP) UID_34025. Work item which gave rise to TS 26.141 / Impacted TSs and TRs: 26.141
- 839: SP#65 completed. Linked to E2EMTSI (End-to-End Multimedia Telephony Service for IMS extensions). Add Reqs&guidelines for video telephony robustness to improve service perf. for PLI, Generic NACK, and FIR messages within overall bitrate limit / Impacted TSs and TRs: 26.114
- 840: OAM12 is an umbrella Feature for changes that are not part of any other dedicated feature/WI
- 841: OAM12-SON is an umbrella BB also for SON related TEI12 type of changes that are not part of any other dedicated feature/WI
- 842: SP#62 completed. TS 32.508v200 for Approval, TS 32.509v100 for 1-step Approval / Impacted TSs and TRs: 32.501, New TSs (32.508, 32.509)
- 843: SP#65 moved to Rel-13 OAM-PMID (Converged management Performance Management Interface Definition) UID_560235
- 844: SP#65 completed. TR 28.280v100 for 1-step Approval / Impacted TSs and TRs: 32.156, new TR 28.820
- 845: SP#60 completed. TS 28.390v200 for Approval / Impacted TSs and TRs: new TS 28.390
- 846: SP#65 updated WID SP-120779=>SP-140542 (removed parts on CN and non-3GPP access). Discontinue I-WLAN spec.
- 847: SP#65 completed. TS 28.402v100 for 1-step Approval, withdraw New TS 28.401 (CN and non-3GPP access i/w PMs). Moved PMs for EPC and non-3GPP access i/w from 28.401=>28.402 / Impacted TSs and TRs: new TS 28.401, withdrawn new TS 28.402
- 848: SP#65 discontinue I-WLAN specs: Move parts (e.g. IOCs) applicable for EPC and non-3GPP access interworking NRMs from 28.601/2/6 to 28.611/2/6. Withdraw 28.601/2/6 (CN and non-3GPP access i/w NRMs). SP#62 completed. TSs 28.601/2/6/11/12/16 for Approval / Impacted TSs and TRs: 32.632, 32.636, 32.752, 32.756, new TS (28.611, 28.612, 28.616, withdrawn 28.601, 28.602, 28.606)
- 849: -
- 850: SP#65 completion 09/14=>12/14. Exception in SP-140544. Triggered by Rel-12 TR 32.859 Study on Alarm Management (FS_OAM_AM) . Dec.14: 50->100 / Impacted TSs and TRs: 32.111-1, 32.111-2, 32.111-6
- 851: SP#65 completion 09/14=>12/14. Exception in SP-140546. SP#65 v100 TS 28.667/8 for Information. Dec.14: 60->100 / Impacted TSs and TRs: 32.101, New TSs (28.667, 28.668, 28.669)
- 852: OAM12-PM is an umbrella BB also for PM related TEI12 type of changes that are not part of any other dedicated feature/WI
- 853: SP#65 completion 09/14=>12/14. Exception in SP-140545. Triggered by Rel-12 TR 32.851 Study on OAM aspects of Network Sharing (FS_OAM_SHARE), Rel-6 Network Sharing (NTShar) UID_31018 / Impacted TSs and TRs: Stage 1/2/3
- 854: SP#65 completion 09/14=>12/14. Exception in SP-140545. LM 80->100 / Impacted TSs and TRs: new TS 32.130
- 855: SP#65 completion 09/14=>12/14. Exception in SP-140545. Dec.14: 60->100 / Impacted TSs and TRs: 28.401,28.621/2/3,28.651/2/3,28.654/5/6,28.657/8/9,28.701/2/3,28.731/2/3,28.734/5/6,32.101/2,32.111-1/2/3/6,32.121/2/6,32.155,32.171/2/6,32.300/1/2/6,32.311/2/6,32.321/2/6,32.331/2/6,32.341/2/6,32.351/352/6,32.361/2/6,32.381/2/6,32.405/6/7/8/9/10/11/12/41
- 856: CH12 is an umbrella Feature for changes that are not part of any other dedicated feature/WI
- 857: Stage 2/3. SP#63 completed. Updated WID SP-120775=>SP-140027 / Impacted TSs and TRs: 32.240, 32.274, 32.297, 32.298, 32.299
- 858: SP#64 completed / Impacted TSs and TRs: 32.251, 32.298, 32.299
- 859: SP#64 completed. TS 32.276v200 for Approval, 32.293v100 for 1-step Approval / Impacted TSs and TRs: 32.240, 32.299, New TSs [32.276 (Voice Call Service Charging), 32.293 (Proxy Function)]
- 860: SP#64 completed. Align SA5 Charging specifications with Rel-8 Feature IMS Centralized Service control (ICSRA) and subsequent enhancements under TEIx (SA2 23.292 ICSRA Stage 2, CT3 29.292, CT1 24.607, 24.611) / Impacted TSs and TRs: 32.250, 32.298

| ID | WBS | Task | Duration | Start | Finish | Complete | Remaining | Baseline start | Baseline finish | Baseline duration | Total slack | Constraint | Resources | Work | Actual work | Acronym | PCG approved | WI rapporteur name | Release | TSG approved | MCC resp | Special Focus Doc | Acronym_3GU_Export | Status Report |
| --- | --- | --- | --- | --- | --- | --- | --- | --- | --- | --- | --- | --- | --- | --- | --- | --- | --- | --- | --- | --- | --- | --- | --- | --- |
| 861 | 220 | **IMS Emergency PSAP Callback (Stage 3)** | 724d? | 2011-09-21 A | 2014-06-13 A | 100% |  | 2011-09-21 | 2014-06-13 | 724d? |  |  | C1; C3; IETF | 38848h | 38848h | EMC_PC | PCG-27 | Ericsson | Rel-12 | CP-53 | Frederic | Public Safety (I-A) | EMC_PC |  |
| 862 | 220.1 | CT1 part of IMS Emergency PSAP Callback | 721d? | 2011-09-22 A | 2014-06-13 A | 100% |  | 2011-09-22 | 2014-06-13 | 721d? |  | finish no earlier than 2014-06-13 | C1 | 5760h | 5760h | EMC_PC | PCG-27 | Ericsson | Rel-12 | CP-53 | Frederic | Public Safety (I-A) |  |  |
| 863 | 220.2 | (IETF) CT1 part of IMS Emergency PSAP Callback (RFC 7090) | 723d? | 2011-09-21 A | 2014-06-13 A | 100% |  | 2011-09-21 | 2014-06-13 | 723d? |  | finish no earlier than 2014-06-13 | C1-IETF | 5776h | 5776h | EMC_PC | PCG-27 | christer.holmberg@ericsson.com | Rel-12 | CP-53 | Frederic | Public Safety (I-A) |  |  |
| 864 | 220.3 | CT3 part of IMS Emergency PSAP Callback | 519d? | 2011-09-24 A | 2013-09-06 A | 100% |  | 2011-09-24 | 2013-09-06 | 519d? |  | finish no earlier than 2013-09-06 | C3 | 4152h | 4152h | EMC_PC | PCG-27 | Ericsson | Rel-12 | CP-53 | Adrian | Public Safety (I-A) |  |  |
| 865 | 220.4 | (IETF) CT3 part of IMS Emergency PSAP Callback (RFC 7090) | 724d? | 2011-09-21 A | 2014-06-13 A | 100% |  | 2011-09-21 | 2014-06-13 | 724d? |  | finish no earlier than 2014-06-13 | C3-IETF | 5784h | 5784h | EMC_PC | PCG-31 | christer.holmberg@ericsson.com | Rel-12 | CP-60 | Adrian | Public Safety (I-A) |  |  |
| 866 | 221 | Interworking between a PLMN with WLAN to access the EPC and a PDN (Stage 3) | 265d? | 2012-09-10 A | 2013-09-06 A | 100% |  | 2012-09-10 | 2013-09-06 | 265d? |  | finish no earlier than 2013-08-12 | C3 | 2091.72h | 2091.72h | SAES_WLAN_EPC_intwk | PCG-29 | Huawei | Rel-12 | CP-57 | Adrian | WLAN | SAES_WLAN_EPC_intwk |  |
| 867 | 222 | **Reporting Enhancements in Warning Message Delivery (Stage 2/3)** | 402d? | 2012-12-07 A | 2014-06-13 A | 100% |  | 2012-12-07 | 2014-06-13 | 402d? |  |  | C1; C4; R3 | 20832.2h | 20832.2h | REP_WMD | PCG-30 | one2many | Rel-12 | CP-58 | Frederic | Public Safety (I-A) | REP_WMD |  |
| 868 | 222.1 | CT1 part of Reporting Enhancements in Warning Message Delivery (Stage 2) | 329d? | 2012-12-07 A | 2014-03-04 A | 100% |  | 2012-12-07 | 2014-03-04 | 329d? |  | finish no earlier than 2014-03-06 | C1 | 2592.18h | 2592.18h | REP_WMD-CT1 | PCG-30 | one2many | Rel-12 | CP-58 | Frederic | Public Safety (I-A) |  |  |
| 869 | 222.2 | CT4 part of Reporting Enhancements in Warning Message Delivery (Stage 2/3) | 400d? | 2012-12-10 A | 2014-06-13 A | 100% |  | 2012-12-10 | 2014-06-13 | 400d? |  | finish no earlier than 2014-06-13 | C4 | 3168h | 3168h | REP_WMD-CT4 | PCG-30 | one2many | Rel-12 | CP-58 | Kimmo | Public Safety (I-A) |  |  |
| 870 | 222.3 | **Public Warning System - Reset/Failure/Restart in Warning Message Delivery in LTE** | 340d? | 2013-03-04 A | 2014-06-13 A | 100% |  | 2013-03-04 | 2014-06-13 | 340d? |  |  | R3 | 5424h | 5424h | REP_WMD-RFR_PWS | PCG-30 | one2many, Huawei | Rel-12 | RP-59 | Juha | Public Safety (I-A) | REP_WMD-RFR_PWS |  |
| 871 | 222.3.1 | Core part: PWS - Reset/Failure/Restart in Warning Message Delivery in LTE | 338d? | 2013-03-04 A | 2014-06-13 A | 100% |  | 2013-03-04 | 2014-06-13 | 338d? |  | finish no earlier than 2014-06-13 | R3 | 2704h | 2704h | REP_WMD-RFR_PWS-Core | PCG-30 | one2many, Huawei | Rel-12 | RP-59 | Juha | Public Safety (I-A) | REP_WMD-RFR_PWS-Core | RP-140637 |
| 872 | 223 | **Single Radio Voice Call Continuity (SRVCC) before ringing (Stage 3)** | 331d? | 2012-12-07 A | 2014-03-06 A | 100% |  | 2012-12-07 | 2014-03-06 | 331d? |  |  | C1; C3; R5 | 9584h | 9584h | bSRVCC | PCG-30 | NTT DOCOMO | Rel-12 | CP-58 | Frederic |  | bSRVCC |  |
| 873 | 223.1 | CT1 part of Single Radio Voice Call Continuity (SRVCC) before ringing | 138d? | 2012-12-07 A | 2013-06-14 A | 100% |  | 2012-12-07 | 2013-06-14 | 138d? |  | finish no earlier than 2013-06-14 | C1 | 1096h | 1096h | bSRVCC | PCG-30 | NTT DOCOMO | Rel-12 | CP-58 | Frederic |  |  |  |
| 874 | 223.2 | CT3 part of Single Radio Voice Call Continuity (SRVCC) before ringing | 3d? | 2013-06-12 A | 2013-06-14 A | 100% |  | 2013-06-12 | 2013-06-14 | 3d? |  | finish no earlier than 2013-06-14 | C3 | 24h | 24h | bSRVCC | PCG-31 | NTT DOCOMO | Rel-12 | CP-60 | Adrian |  |  |  |
| 875 | 223.3 | Test part: Single Radio Voice Call Continuity (SRVCC) before ringing | 65d? | 2013-12-06 A | 2014-03-06 A | 100% |  | 2013-12-06 | 2014-03-06 | 65d? |  | finish no earlier than 2014-03-06 | R5 | 520h | 520h | bSRVCC-UEConTest | PCG-32 | NTT DOCOMO | Rel-12 | CP-62 | Ingbert |  | bSRVCC-UEConTest | RP-140422 |
| 876 | 224 | **IMS Stage 3 IETF Protocol Alignment - phase 6** | 532d? | 2012-12-07 A | 2014-12-09 | 67% | 176.89d? | 2012-12-07 | 2014-12-05 | 527d? | 657d |  | C1; C3; IETF | 20640.6h | 13665.2h | IMSProtoc6 | PCG-30 | Alcatel-Lucent | Rel-12 | CP-58 | Frederic |  | IMSProtoc6 |  |
| 877 | 224.1 | CT1 part of IMS Stage 3 IETF Protocol Alignment - phase 6 | 464d? | 2012-12-07 A | 2014-09-11 A | 100% |  | 2012-12-07 | 2014-09-12 | 464d? |  | finish no earlier than 2014-09-12 | C1 | 3712h | 3712h | IMSProtoc6 | PCG-30 | Alcatel-Lucent | Rel-12 | CP-58 | Frederic |  |  |  |
| 878 | 224.2 | (IETF) CT1 part of IMS Stage 3 IETF Protocol Alignment - phase 6 (holmberg-sipcore-received-realm) | 410d? | 2013-05-21 A | 2014-12-09 | 50% | 206d? | 2013-05-21 | 2014-12-05 | 408d? | 657d | finish no earlier than 2014-12-09 | C1-IETF | 3256.25h | 1608.25h | IMSProtoc6 | PCG-31 | christer.holmberg@ericsson.com | Rel-12 | CP-60 | Frederic |  |  |  |
| 879 | 224.3 | (IETF) CT1 part of IMS Stage 3 IETF Protocol Alignment - phase 6 (allen-sipcore-sip-tree-cap-indicators) | 63d? | 2014-09-12 A | 2014-12-09 | 25% | 47.25d? |  |  |  | 657d | finish no earlier than 2014-12-09 | C1-IETF | 504h | 126h | IMSProtoc6 | PCG-33 | christer.holmberg@ericsson.com | Rel-12 | CP-65 |  |  |  |  |
| 880 | 224.4 | (IETF) CT1 part of IMS Stage 3 IETF Protocol Alignment - phase 6 (draft-ietf-insipid-session-id) | 65d? | 2014-09-12 A | 2014-12-09 | 25% | 48.75d? |  |  |  | 657d | start no earlier than 2014-09-12 | C1-IETF | 520h | 130h | IMSProtoc6 | PCG-34 | christer.holmberg@ericsson.com | Rel-12 | CP-65 |  |  |  |  |
| 881 | 224.5 | CT3 part of IMS Stage 3 IETF Protocol Alignment - phase 6 | 71d? | 2014-06-06 A | 2014-09-11 A | 100% |  | 2014-06-06 | 2014-09-12 | 71d? |  | finish no earlier than 2014-09-12 | C3 | 568h | 568h | IMSProtoc6 | PCG-30 | Alcatel-Lucent | Rel-12 | CP-58 | Adrian |  |  |  |
| 882 | 224.6 | (IETF) CT3 part of IMS Stage 3 IETF Protocol Alignment - phase 6 (holmberg-sipcore-received-realm) | 327d? | 2013-09-06 A | 2014-12-05 | 50% | 163.5d? | 2013-09-06 | 2014-12-05 | 327d? | 659d | finish no earlier than 2014-12-05 | C3-IETF | 2608h | 1300h | IMSProtoc6 | PCG-31 | christer.holmberg@ericsson.com | Rel-12 | CP-61 |  |  |  |  |
| 883 | 225 | **SAE Protocol Development - Phase 3** | 467d? | 2012-12-07 A | 2014-09-11 A | 100% |  | 2012-12-07 | 2014-09-12 | 467d? |  |  | C1 | 14920h | 14920h | SAES3 | PCG-30 | InterDigital | Rel-12 | CP-58 | Frederic |  | SAES3 |  |
| 884 | 225.1 | SAE Protocol Development (Stage 3) - Phase 3 | 466d? | 2012-12-07 A | 2014-09-11 A | 100% |  | 2012-12-07 | 2014-09-12 | 466d? |  | finish no earlier than 2014-09-12 | C1 | 3728h | 3728h | SAES3-CT1 | PCG-30 | InterDigital | Rel-12 | CP-58 | Frederic |  |  |  |
| 885 | 225.2 | CS Fallback in EPS - Phase 3 | 466d? | 2012-12-07 A | 2014-09-11 A | 100% |  | 2012-12-07 | 2014-09-12 | 466d? |  | finish no earlier than 2014-09-12 | C1 | 3728h | 3728h | SAES3-CSFB | PCG-30 | InterDigital | Rel-12 | CP-58 | Frederic |  | SAES3-CSFB |  |
| 886 | 225.3 | SAE for support for non-3GPP accesses - Phase 3 | 466d? | 2012-12-07 A | 2014-09-11 A | 100% |  | 2012-12-07 | 2014-09-12 | 466d? |  | finish no earlier than 2014-09-12 | C1 | 3728h | 3728h | SAES3-non3GPP | PCG-30 | InterDigital | Rel-12 | CP-58 | Frederic |  | SAES3-non3GPP |  |

Notes:
- 861: Dep. IETF ECRIT on PSAP call back. Fulfill SA1/2 Rel-7 EMC1 reqs UID_32045 PS domain and IMS impacts for supporting IMS Emergency calls (related to BB UID_1653 Emergency Call Enhancements for IP& PS Based Calls / Impacted TSs and TRs: Stage 3 / WI rapporteur e-mail: christer.holmberg@ericsson.com
- 862: CP#64 completed. 2/4/15: acronym changed to EMC_PC / Impacted TSs and TRs: 24.229, tied to completion of IETF dependencies: 24.604, 24.605, 24.610, 24.611, 24.629 / WI rapporteur e-mail: christer.holmberg@ericsson.com
- 863: CP#64 completed. 2/4/15: acronym changed to EMC_PC / Impacted TSs and TRs: RFC 7090 (was draft-ietf-ecrit-psap-callback / WI rapporteur e-mail: christer.holmberg@ericsson.com
- 864: CP#61 completed. 2/4/15: acronym changed to EMC_PC / Impacted TSs and TRs: 29.163, 29.165 / WI rapporteur e-mail: christer.holmberg@ericsson.com
- 865: CP#64 completed. 2/4/15: acronym changed to EMC_PC / Impacted TSs and TRs: RFC 7090 (was draft-ietf-ecrit-psap-callback) / WI rapporteur e-mail: christer.holmberg@ericsson.com
- 866: CP#61 completed. Linked to Rel-8 Feature SAES: System Architecture Evolution specification - Evolved Packet System (non RAN aspects) UID_320005 / Impacted TSs and TRs: 29.061 / WI rapporteur e-mail: Christian.Herrero@huawei.com
- 867: Stage 1 for Cell Broadcast does not exist. This WID enhances the reporting capabilities of Warning Message Delivery. Introduce LTE functionality requested by regulators, equivalent to existing 2G/3G functionality. / Impacted TSs and TRs: Stage 2/3 / WI rapporteur e-mail: peter.sanders@one2many.eu
- 868: CP#63 completed / Impacted TSs and TRs: 23.041 / WI rapporteur e-mail: peter.sanders@one2many.eu
- 869: CP#64 completed / Impacted TSs and TRs: 23.007, 29.168 / WI rapporteur e-mail: peter.sanders@one2many.eu
- 870: - / Impacted TSs and TRs: LTE / WI rapporteur e-mail: peter.sanders@one2many.eu, Dai Mingzeng (daimingzeng@huawei.com)
- 871: RP#64 completed / Impacted TSs and TRs: 36.413 / WI rapporteur e-mail: peter.sanders@one2many.eu, Dai Mingzeng (daimingzeng@huawei.com)
- 872: Linked to Rel-8 Feature IMS Service Continuity (IMS-Cont) UID_390056. TS 23.237 Rel-12 CR#0444 under TEI12 / Impacted TSs and TRs: GERAN, UTRA, LTE / WI rapporteur e-mail: keisuke.sasada.kx@nttdocomo.com
- 873: CP#60 completed. 2/4/15: acronym changed to bSRVCC / Impacted TSs and TRs: 24.008, 24.237 / WI rapporteur e-mail: keisuke.sasada.kx@nttdocomo.com
- 874: CP#60 completedbSRVCC / Impacted TSs and TRs: 29.165 / WI rapporteur e-mail: keisuke.sasada.kx@nttdocomo.com
- 875: RP#63 completed. Testing for CT1 TS 24.237 (IMS service continuity Stage 3) / Impacted TSs and TRs: 34.229-1, 34.229-2, 36.523-1, 36.523-2 / WI rapporteur e-mail: Masahiro.Tamaoki.eu@nttdocomo.com
- 876: - / Impacted TSs and TRs: Stage 3 / WI rapporteur e-mail: keith.drage@alcatel-lucent.com
- 877: CP#65 completed. 4/2/15: acronym changed to IMSProtoc6 / Impacted TSs and TRs: 23.218, 24.229, 24.930 / WI rapporteur e-mail: keith.drage@alcatel-lucent.com
- 878: Not completed internet-draft. 4/2/15: acronym changed to IMSProtoc6 / Impacted TSs and TRs: draft-holmberg-sipcore-received-realm / WI rapporteur e-mail: christer.holmberg@ericsson.com
- 879: Not completed internet-draft. 4/2/15: acronym changed to IMSProtoc6 / Impacted TSs and TRs: draft-allen-sipcore-sip-tree-cap-indicators / WI rapporteur e-mail: christer.holmberg@ericsson.com
- 880: work in progress. 4/2/15: acronym changed to IMSProtoc6 / Impacted TSs and TRs: draft-ietf-insipid-session-id
- 881: CP#65 completed. 4/2/15: acronym changed to IMSProtoc6 / Impacted TSs and TRs: 29.163, 29.165 / WI rapporteur e-mail: keith.drage@alcatel-lucent.com
- 882: Not completed internet-draft. 4/2/15: acronym changed to IMSProtoc6 / Impacted TSs and TRs: draft-holmberg-sipcore-received-realm / WI rapporteur e-mail: christer.holmberg@ericsson.com
- 883: Stage 3 continuation of Rel-8 Feature SAES (3GPP System Architecture Evolution Specification - Evolved Packet System) UID_320005 / Impacted TSs and TRs: Stage 2/3 / WI rapporteur e-mail: behrouz.aghili@interdigital.com
- 884: CP#65 completed / Impacted TSs and TRs: 23.122, 24.008, 24.167, 24.229, 24.301, 24.302, 24.303, 24.304, 24.305, 24.312, 29.018, 29.118 / WI rapporteur e-mail: behrouz.aghili@interdigital.com
- 885: CP#65 completed / Impacted TSs and TRs: 23.122, 24.008, 24.167, 24.229, 24.301, 24.302, 24.303, 24.304, 24.305, 24.312, 29.018, 29.118 / WI rapporteur e-mail: behrouz.aghili@interdigital.com
- 886: CP#65 completed / Impacted TSs and TRs: 23.122, 24.008, 24.167, 24.229, 24.301, 24.302, 24.303, 24.304, 24.305, 24.312, 29.018, 29.118 / WI rapporteur e-mail: behrouz.aghili@interdigital.com

| ID | WBS | Task | Duration | Start | Finish | Complete | Baseline start | Baseline finish | Baseline duration | Constraint | Resources | Work | Actual work | Acronym | PCG approved | Impacted TSs and TRs | WI rapporteur name | WI rapporteur e-mail | Release | TSG approved | MCC resp | Acronym_3GU_Export | Status Report |
| --- | --- | --- | --- | --- | --- | --- | --- | --- | --- | --- | --- | --- | --- | --- | --- | --- | --- | --- | --- | --- | --- | --- | --- |
| 887 | 226 | **IM-SSF Application Server Service Data Descriptions (Stage 2/3)** | 138d? | 2012-12-07 A | 2013-06-14 A | 100% | 2012-12-07 | 2013-06-14 | 138d? |  | C4; C1 | 3780h | 3780h | IMS_SSFDD | PCG-30 | Stage 2/3 | Huawei | susan.shishufeng@huawei.com | Rel-12 | CP-58 | Kimmo | IMS_SSFDD |  |
| 888 | 226.1 | Stage 2 for IM-SSF Application Server Service Data Descriptions | 62d? | 2012-12-07 A | 2013-03-01 A | 100% | 2012-12-07 | 2013-03-01 | 62d? | finish no earlier than 2013-06-14 | C1 | 488h | 488h | IMS_SSFDD | PCG-30 | 23.218 | Huawei | susan.shishufeng@huawei.com | Rel-12 | CP-58 | Frederic |  |  |
| 889 | 226.2 | Stage 3 for IM-SSF Application Server Service Data Descriptions | 136.5d? | 2012-12-10 A | 2013-06-14 A | 100% | 2012-12-10 | 2013-06-14 | 136.5d? | finish no earlier than 2013-06-14 | C4 | 1084h | 1084h | IMS_SSFDD | PCG-30 | 29.328, 29.329, 29.364 | Huawei | susan.shishufeng@huawei.com | Rel-12 | CP-58 | Kimmo |  |  |
| 890 | 227 | **Diameter based interface between SGSN and SMS central functions (Stage 2/3)** | 265d? | 2012-12-10 A | 2013-12-06 A | 100% | 2012-12-10 | 2013-12-06 | 265d? |  | C4; C1 | 7952h | 7952h | Dia_SGSN_SMS | PCG-30 | Stage 2/3 | Alcatel-Lucent | jean-jacques.trottin@alcatel-lucent.com | Rel-12 | CP-58 | Kimmo | Dia_SGSN_SMS |  |
| 891 | 227.1 | Stage 2 for Diameter based interface between SGSN and SMS central functions | 201d? | 2013-03-07 A | 2013-12-06 A | 100% | 2013-03-07 | 2013-12-06 | 201d? | finish no earlier than 2013-12-06 | C1 | 1608h | 1608h | Dia_SGSN_SMS | PCG-30 | 23.040 | Alcatel-Lucent | jean-jacques.trottin@alcatel-lucent.com | Rel-12 | CP-59 | Frederic |  |  |
| 892 | 227.2 | Stage 3 for Diameter based interface between SGSN and SMS central functions | 265d? | 2012-12-10 A | 2013-12-06 A | 100% | 2012-12-10 | 2013-12-06 | 265d? | finish no earlier than 2013-12-06 | C4 | 2104h | 2104h | Dia_SGSN_SMS | PCG-30 | 29.002, 29.230, 29.272, 29.305, 29.336, 29.337, 29.338 | Alcatel-Lucent | jean-jacques.trottin@alcatel-lucent.com | Rel-12 | CP-58 | Kimmo |  |  |
| 893 | 228 | Diameter based interface between SGSN-GMLC (Stage 3) | 265d? | 2012-12-10 A | 2013-12-06 A | 100% | 2012-12-10 | 2013-12-06 | 265d? | finish no earlier than 2013-12-06 | C4 | 2096h | 2096h | Dia_SGSN_GMLC | PCG-30 | 29.002, 29.172, 29.173, 29.230, 29.272 | Cisco | Nirav Salot (nsalot@cisco.com) | Rel-12 | CP-58 | Kimmo | Dia_SGSN_GMLC |  |
| 894 | 229 | IMS impacts on UICC Application Aspects (Stage 3) | 465d? | 2013-03-04 A | 2014-12-09 A | 100% | 2013-03-04 | 2014-09-12 | 403d? | finish no earlier than 2014-12-09 | C6 | 3720h | 3720h | IMS_UApAs | PCG-30 | 31.102, 31.103, 31.111, 31.130 | Giesecke & Devrient | sergi.espi@gi-de.com | Rel-12 | CP-59 | Xavier | IMS_UApAs | CP-140696 |
| 895 | 230 | **eMBMS restoration procedures** | 406d? | 2013-03-01 A | 2014-09-11 A | 100% | 2013-03-01 | 2014-06-13 | 341d? |  | C4; C3 | 10272h | 10272h | eMBMS_Rest | PCG-30 | Stage 3 | Alcatel-Lucent | bruno.landais@alcatel-lucent.com | Rel-12 | CP-59 | Kimmo | eMBMS_Rest |  |
| 896 | 230.1 | CT4 part of eMBMS restoration procedures | 205d? | 2013-03-01 A | 2013-12-06 A | 100% | 2013-03-01 | 2013-12-06 | 205d? | finish no earlier than 2013-12-06 | C4 | 1616h | 1616h | eMBMS_Rest | PCG-30 | 23.007, 23.008, 29.274 | Alcatel-Lucent | bruno.landais@alcatel-lucent.com | Rel-12 | CP-59 | Kimmo |  |  |
| 897 | 230.2 | CT3 part of eMBMS restoration procedures | 270d? | 2013-09-04 A | 2014-09-11 A | 100% | 2013-09-04 | 2014-06-13 | 205d? | finish no earlier than 2014-09-12 | C3 | 2160h | 2160h | eMBMS_Rest | PCG-31 | 29.061 | Alcatel-Lucent | bruno.landais@alcatel-lucent.com | Rel-12 | CP-61 | Kimmo |  |  |
| 898 | 231 | **Dual Radio VCC enhancements (Stage 2/3)** | 325d? | 2012-09-19 A | 2013-12-06 A | 100% | 2012-09-19 | 2013-12-06 | 325d? |  | C1; C3.S2 | 10866.2h | 10866.2h | eDRVCC | PCG-30 | Stage 2/3 | Ericsson | Jan.Holm@ericsson.com | Rel-12 | CP-59 | Maurice | eDRVCC |  |
| 899 | 231.1 | Stage 2 for Dual Radio VCC enhancements | 57.55d? | 2012-09-19 A | 2013-03-01 A | 100% | 2012-09-19 | 2013-03-01 | 57.55d? | finish no earlier than 2013-03-01 | S2 | 460.4h | 460.4h | eDRVCC | PCG-30 | 23.237 | Ericsson | Jan.Holm@ericsson.com | Rel-12 | CP-59 | Maurice |  |  |
| 900 | 231.2 | **Stage 3 for Dual Radio VCC enhancements** | 205d? | 2013-03-01 A | 2013-12-06 A | 100% | 2013-03-01 | 2013-12-06 | 205d? |  | C1; C3 | 5205.8h | 5205.8h | eDRVCC | PCG-30 | Stage 3 | Ericsson | Jan.Holm@ericsson.com | Rel-12 | CP-59 | Frederic |  |  |
| 901 | 231.2.1 | CT1 part of Stage 3 for Dual Radio VCC enhancements | 205d? | 2013-03-01 A | 2013-12-06 A | 100% | 2013-03-01 | 2013-12-06 | 205d? | finish no earlier than 2013-12-06 | C1 | 1608h | 1608h | eDRVCC | PCG-30 | 24.237, 24.292 | Ericsson | Jan.Holm@ericsson.com | Rel-12 | CP-59 | Frederic |  |  |
| 902 | 231.2.2 | CT3 part of Stage 3 for Dual Radio VCC enhancements | 41.7d? | 2013-03-01 A | 2013-09-06 A | 100% | 2013-03-01 | 2013-09-06 | 41.7d? | finish no earlier than 2013-09-06 | C3 | 317.8h | 317.8h | eDRVCC | PCG-30 | 29.165 | Ericsson | Jan.Holm@ericsson.com | Rel-12 | CP-59 | Adrian |  |  |
| 903 | 232 | **CT aspects of Signalling of Image Size (Stage 2/3)** | 129d? | 2013-06-14 A | 2013-12-06 A | 100% | 2013-06-14 | 2013-12-06 | 129d? |  | C4; C1; C3 | 6136.8h | 6136.8h | SIS_CT | PCG-31 | Stage 2/3 | Ericsson | nevenka.biondic@ericsson.com | Rel-12 | CP-60 | Kimmo | SIS_CT |  |
| 904 | 232.1 | CT4 part of Signalling of Image Size | 128.05d? | 2013-06-14 A | 2013-12-06 A | 100% | 2013-06-14 | 2013-12-06 | 128.05d? | finish no earlier than 2013-12-06 | C4 | 1008.4h | 1008.4h | SIS_CT | PCG-31 | 23.333, 23.334, 29.238, 29.332, 29.333, 29.334 | Ericsson | nevenka.biondic@ericsson.com | Rel-12 | CP-60 | Kimmo |  |  |
| 905 | 232.2 | CT1 part of CT Aspects of Signalling of Image Size | 129d? | 2013-06-14 A | 2013-12-06 A | 100% | 2013-06-14 | 2013-12-06 | 129d? | finish no earlier than 2013-12-06 | C1 | 1016h | 1016h | SIS_CT | PCG-31 | 24.229 | Ericsson | nevenka.biondic@ericsson.com | Rel-12 | CP-60 | Frederic |  |  |
| 906 | 232.3 | CT3 part of CT Aspects of Signalling of Image Size | 128.05d? | 2013-06-14 A | 2013-12-06 A | 100% | 2013-06-14 | 2013-12-06 | 128.05d? | finish no earlier than 2013-12-06 | C3 | 1016.4h | 1016.4h | SIS_CT | PCG-31 | 29.162, 29.163 | Ericsson | nevenka.biondic@ericsson.com | Rel-12 | CP-60 | Adrian |  |  |
| 907 | 233 | IMS Centralized Services (ICS) InterWorking Enhancement in Mobile Switching Center Server (MSC-S) | 129d? | 2013-06-14 A | 2013-12-06 A | 100% | 2013-06-14 | 2013-12-06 | 129d? | finish no earlier than 2013-12-06 | C3 | 1008h | 1008h | ICS_IWE | PCG-31 | 29.292 | Orange | marianne.mohali@orange.com | Rel-12 | CP-60 | Adrian | ICS_IWE |  |
| 908 | 234 | GPRS Tunnelling Protocol for the Control plane (GTP-C) Overload Control Mechanisms | 267d? | 2013-09-06 A | 2014-09-11 A | 100% | 2013-09-06 | 2014-09-12 | 267d? | finish no earlier than 2014-09-12 | C4 | 2136h | 2136h | GOCMe | PCG-31 | 23.008, 29.230, 29.273, 29.274, 29.303, New TR 29.807 | Cisco | Nirav Salot (nsalot@cisco.com) | Rel-12 | CP-61 | Kimmo | GOCMe |  |
| 909 | 235 | **Proxy Call Session Control Function (P-CSCF) restoration enhancements (Stage 2/3)** | 447.1d? | 2013-04-03 A | 2014-12-09 A | 100% | 2013-04-03 | 2014-12-05 | 442.1d? |  | C4; C3; C1 | 54903.2h | 54903.2h | PCSCF_RES | PCG-31 | Stage 2/3 | Ericsson | maria.cruz.bartolome@ericsson.com | Rel-12 | CP-61 | Kimmo | PCSCF_RES |  |
| 910 | 235.1 | TR on Proxy Call Session Control Function (P-CSCF) restoration enhancements | 266d? | 2013-09-06 A | 2014-09-11 A | 100% | 2013-09-06 | 2014-09-12 | 266d? | finish no earlier than 2014-09-12 | C4 | 2128h | 2128h | PCSCF_RES | PCG-31 | New TR 29.806 | Ericsson | maria.cruz.bartolome@ericsson.com | Rel-12 | CP-61 | Kimmo |  |  |

Notes:
- 887: CP#60 completed
- 888: CP#59 completed
- 889: CP#60 completed
- 890: CP#62 completed
- 891: CP#62 completed
- 892: CP#62 completed
- 893: CP#62 completed. Updated WID CP-130273=>CP-130598. No Stage 2 impact. Define a Diameter variant for the protocol used over existing reference points between SGSN and GMLC for LCS (replace the use of MAP by Diameter protocol)
- 894: CP#65 completion 09/14=>12/14. Exception in CP-140696. Dec.14: 85->100%
- 895: CP#62 completed. Linked to Rel-9 MBMS support in EPS (MBMS_EPS). Rel-10 CT Features EPC Node Restoration with/out Idle mode Signalling Reduction (ISR) activated (EPC_NR/EPC_NR_ISR)
- 896: CP#62 completed
- 897: CP#65 completed
- 898: CP#62 completed. Stage 2 in Rel-12 TEI12 TS 23.237 CR#0431, CR#0440, CR#0441, CR#0453 (pre-alerting). Stage 3 linked to Rel-8 Feature IMS Service Continuity (IMS-Cont) UID_390056 (Stage 2 in TS 23.237). 2/4/15: acronym changed to eDRVCC
- 899: Stage 2 in Rel-12 TEI12 TS 23.237 CR#0431, CR#0440, CR#0441, CR#0453 (pre-alerting). 2/4/15: acronym changed to eDRVCC
- 900: CP#62 completed
- 901: CP#62 completed. 2/4/15: acronym changed to eDRVCC
- 902: CP#61 completed. 2/4/15: acronym changed to eDRVCC
- 903: CP#62 completed. SA4 Rel-8 MTSI Video: Dynamic Rate Adaptation/Signalling of Image Size UID_34041 has included service aspects to support image attribute (a=imageattr) in TS 26.114 as in RFC 6236. But associated CN aspects were not included
- 904: CP#62 completed
- 905: CP#62 completed
- 906: CP#62 completed
- 907: CP#62 completed. Stage 3 enhancement interworking between IMS and MSC-S for IMS Centralized Services (ICS)
- 908: CP#65 completed. Updated WID CP-130433=>CP-140488
- 909: CP#65 updated WID CP-140443=>CP-140490. Based TR 29.806, solutions B and D are selected for standardization. Dec.14: 95->100
- 910: CP#65 completed. TR 29.806v200 for Approval

| ID | WBS | Task | Duration | Start | Finish | Complete | Remaining | Baseline start | Baseline finish | Baseline duration | Total slack | Constraint | Resources | Work | Actual work | Acronym | PCG approved | WI rapporteur name | WI rapporteur e-mail | Release | TSG approved | MCC resp | Status Report | Acronym_3GU_Export |
| --- | --- | --- | --- | --- | --- | --- | --- | --- | --- | --- | --- | --- | --- | --- | --- | --- | --- | --- | --- | --- | --- | --- | --- | --- |
| 911 | 235.2 | **Common for HSS & PCRF solutions** | 447.1d? | 2013-04-03 A | 2014-12-09 A | 100% |  |  |  |  |  |  | C4; C3; C1 | 18602.4h | 18602.4h | PCSCF_RES | PCG-33 | Ericsson | maria.cruz.bartolome@ericsson.com | Rel-12 | CP-64 |  |  |  |
| 912 | 235.2.1 | CT4 part of Common for HSS & PCRF solutions | 328d? | 2013-09-06 A | 2014-12-09 A | 100% |  | 2013-09-06 | 2014-12-05 | 326d? |  | finish no earlier than 2014-12-09 | C4 | 2624h | 2624h | PCSCF_RES | PCG-31 | Ericsson | maria.cruz.bartolome@ericsson.com | Rel-12 | CP-61 | Kimmo | CP-140481 |  |
| 913 | 235.2.2 | CT1 part of Common for HSS & PCRF solutions | 328d? | 2013-04-03 A | 2014-12-05 A | 100% |  | 2013-04-03 | 2014-12-05 | 326d? |  | finish no earlier than 2014-12-09 | C1 | 2624h | 2624h | PCSCF_RES | PCG-33 | Ericsson | maria.cruz.bartolome@ericsson.com | Rel-12 | CP-64 | Kimmo |  |  |
| 914 | 235.2.3 | CT3 part of Common for HSS & PCRF solutions | 328d? | 2013-05-03 A | 2014-12-09 A | 100% |  | 2013-05-03 | 2014-12-05 | 326d? |  | finish no earlier than 2014-12-09 | C3 | 2624h | 2624h | PCSCF_RES | PCG-33 | Huawei | susan.shishufeng@huawei.com | Rel-12 | CP-65 | Kimmo | CP-140687 |  |
| 915 | 235.3 | **HSS based solution** | 447.1d? | 2013-04-03 A | 2014-12-09 A | 100% |  |  |  |  |  |  | C4; C1 | 12401.6h | 12401.6h | PCSCF_RES | PCG-33 | Ericsson | maria.cruz.bartolome@ericsson.com | Rel-12 | CP-64 |  |  |  |
| 916 | 235.3.1 | CT4 part of HSS based solution | 328d? | 2013-09-06 A | 2014-12-09 A | 100% |  | 2013-09-06 | 2014-12-05 | 326d? |  | finish no earlier than 2014-12-09 | C4 | 2624h | 2624h | PCSCF_RES | PCG-31 | Ericsson | maria.cruz.bartolome@ericsson.com | Rel-12 | CP-61 | Kimmo | CP-140481 |  |
| 917 | 235.3.2 | CT1 part of HSS based solution | 328d? | 2013-04-03 A | 2014-12-09 A | 100% |  | 2013-04-03 | 2014-12-05 | 326d? |  | finish no earlier than 2014-12-09 | C1 | 2624h | 2624h | PCSCF_RES | PCG-33 | Ericsson | maria.cruz.bartolome@ericsson.com | Rel-12 | CP-64 | Kimmo | CP-140605 |  |
| 918 | 235.4 | **PCRF based solution** | 447.1d? | 2013-04-03 A | 2014-12-09 A | 100% |  |  |  |  |  |  | C3; C1 | 12401.6h | 12401.6h | PCSCF_RES | PCG-33 | Huawei | susan.shishufeng@huawei.com | Rel-12 | CP-64 |  |  |  |
| 919 | 235.4.1 | CT3 part of PCRF based solution | 328d? | 2013-05-03 A | 2014-12-09 A | 100% |  | 2013-05-03 | 2014-12-05 | 326d? |  | finish no earlier than 2014-12-09 | C3 | 2624h | 2624h | PCSCF_RES | PCG-33 | Huawei | susan.shishufeng@huawei.com | Rel-12 | CP-64 | Kimmo | CP-140687 |  |
| 920 | 235.4.2 | CT1 part of PCRF based solution | 328d? | 2013-04-03 A | 2014-12-09 A | 100% |  | 2013-04-03 | 2014-12-05 | 326d? |  | finish no earlier than 2014-12-09 | C1 | 2624h | 2624h | PCSCF_RES | PCG-33 | Huawei | susan.shishufeng@huawei.com | Rel-12 | CP-64 | Kimmo | CP-140605 |  |
| 921 | 236 | **Updating IMS to conform to RFC 6665 (Stage 3)** | 400d? | 2013-09-09 A | 2015-03-13 | 99% | 1.51d? | 2013-09-09 | 2014-09-12 | 267d? | 589d |  | C1; C3 | 9576h | 4220h | UP6665 | PCG-31 | BlackBerry | Andrew Allen (aallen@blackberry.com) | Rel-12 | CP-61 | Frederic |  | UP6665 |
| 922 | 236.1 | CT1 part of Updating IMS to conform to RFC 6665 | 329d? | 2013-09-09 A | 2014-12-09 A | 100% |  | 2013-09-09 | 2014-09-12 | 267d? |  | finish no earlier than 2014-12-09 | C1 | 2624h | 2624h | UP6665 | PCG-31 | BlackBerry | Andrew Allen (aallen@blackberry.com) | Rel-12 | CP-61 | Frederic | CP-140620 |  |
| 923 | 236.2 | CT3 part of Updating IMS to conform to RFC 6665 | 66d? | 2013-09-09 A | 2013-12-06 A | 100% |  | 2013-09-09 | 2013-12-06 | 66d? |  | finish no earlier than 2013-12-06 | C3 | 528h | 528h | UP6665 | PCG-31 | BlackBerry | Andrew Allen (aallen@blackberry.com) | Rel-12 | CP-61 | Maurice |  |  |
| 924 | 236.3 | (IETF) CT1 part of Updating IMS to conform to RFC 6665 (draft-ietf-sipcore-refer-clarifications) | 1d? | 2015-03-13 A | 2015-03-13 | 50% | 0.5d? |  |  |  | 589d |  | C1-IETF | 8h | 4h | UP6665 | PCG-34 | BlackBerry | Andrew Allen (aallen@blackberry.com) | Rel-12 | CT-67 |  |  |  |
| 925 | 236.4 | (IETF) CT1 part of Updating IMS to conform to RFC 6665 (draft-ietf-sipcore-refer-explicit-subscription) | 1d? | 2015-03-13 A | 2015-03-13 | 50% | 0.5d? |  |  |  | 589d |  | C1-IETF | 8h | 4h | UP6665 | PCG-34 | BlackBerry | Andrew Allen (aallen@blackberry.com) | Rel-12 | CT-67 |  |  |  |
| 926 | 236.5 | (IETF) CT1 part of Updating IMS to conform to RFC 6665 (draft-roach-sipcore-6665-clarifications) | 1d? | 2015-03-13 A | 2015-03-13 | 50% | 0.5d? |  |  |  | 589d |  | C1-IETF | 8h | 4h | UP6665 | PCG-34 | BlackBerry | Andrew Allen (aallen@blackberry.com) | Rel-12 | CT-67 |  |  |  |
| 927 | 237 | **IMS Operator Determined Call Barring enhancements (Stage 3)** | 202d? | 2013-12-06 A | 2014-09-11 A | 100% |  | 2013-12-06 | 2014-06-13 | 137d? |  |  | C1; C3 | 5928h | 5928h | eIODB | PCG-32 | Ericsson | Jorgen.Axell@ericsson.com | Rel-12 | CP-62 | Frederic |  | eIODB |
| 928 | 237.1 | CT1 part of IMS Operator Determined Call Barring enhancements | 136d? | 2013-12-06 A | 2014-06-13 A | 100% |  | 2013-12-06 | 2014-06-13 | 136d? |  | finish no earlier than 2014-06-13 | C1 | 1088h | 1088h | eIODB | PCG-32 | Ericsson | Jorgen.Axell@ericsson.com | Rel-12 | CP-62 | Frederic |  |  |
| 929 | 237.2 | CT3 part of IMS Operator Determined Call Barring enhancements | 201d? | 2013-12-09 A | 2014-09-11 A | 100% |  | 2013-12-09 | 2014-06-13 | 136d? |  | finish no earlier than 2014-09-12 | C3 | 1608h | 1608h | eIODB | PCG-32 | Ericsson | Jorgen.Axell@ericsson.com | Rel-12 | CP-62 | Adrian |  |  |
| 930 | 238 | Signalling Improvements for Network Efficiency (Stage 3) | 264d? | 2013-12-06 A | 2014-12-09 A | 100% |  | 2013-12-06 | 2014-09-12 | 202d? |  | finish no earlier than 2014-12-09 | C1 | 2112h | 2112h | SINE | PCG-32 | Huawei | Lin Shu (shulin@huawei.com) | Rel-12 | CP-62 | Frederic | CP-140617 | SINE |
| 931 | 239 | **Interactive Connectivity Establishment (ICE, IETF RFC 5245) impacts on IMS H.248 profiles** | 138d? | 2014-03-05 A | 2014-09-11 A | 100% |  | 2014-03-05 | 2014-09-12 | 138d? |  |  | C4; C3 | 3896h | 3896h | ICEH248 | PCG-32 | NSN | Jan.Kall@nsn.com | Rel-12 | CP-63 | Kimmo |  | ICEH248 |
| 932 | 239.1 | CT4 part of ICE impacts on IMS H.248 profiles (Stage 2/3) | 138d? | 2014-03-05 A | 2014-09-11 A | 100% |  | 2014-03-05 | 2014-09-12 | 138d? |  | finish no earlier than 2014-09-12 | C4 | 1104h | 1104h | ICEH248 | PCG-32 | NSN | Jan.Kall@nsn.com | Rel-12 | CP-63 | Kimmo |  |  |
| 933 | 239.2 | CT3 part of ICE impacts on IMS H.248 profiles (Stage 2) | 73d? | 2014-03-05 A | 2014-06-13 A | 100% |  | 2014-03-05 | 2014-06-13 | 73d? |  | finish no earlier than 2014-06-13 | C3 | 584h | 584h | ICEH248 | PCG-32 | NSN | Jan.Kall@nsn.com | Rel-12 | CP-63 | Adrian |  |  |
| 934 | 240 | **Transfer of ETSI business trunking specifications** | 203d? | 2014-03-05 A | 2014-12-09 A | 100% |  | 2014-03-05 | 2014-09-17 | 141d? |  |  | C1; S1 | 5976h | 5976h | IMS_Corp2 | PCG-32 | Alcatel-Lucent | keith.drage@alcatel-lucent.com, Youssef Chadli | Rel-12 | CP-63 | Frederic |  | IMS_Corp2 |
| 935 | 240.1 | SA1 part of Transfer of ETSI business trunking specifications | 141d? | 2014-03-05 A | 2014-09-17 A | 100% |  | 2014-03-05 | 2014-09-17 | 141d? |  | finish no earlier than 2014-09-17 | S1 | 1128h | 1128h | IMS_Corp2 | PCG-32 | Alcatel-Lucent | betsy.covell@alcatel-lucent.com | Rel-12 | SP-63 | Alain | S1-143300 |  |
| 936 | 240.2 | CT1 part of Transfer of ETSI business trunking specifications | 200d? | 2014-03-05 A | 2014-12-09 A | 100% |  | 2014-03-05 | 2014-09-12 | 138d? |  | finish no earlier than 2014-12-09 | C1 | 1600h | 1600h | IMS_Corp2 | PCG-32 | Alcatel-Lucent | keith.drage@alcatel-lucent.com, Youssef Chadli | Rel-12 | CP-63 | Frederic | CP-140619 |  |

Notes:
- 911: -
- 912: CP#65 completion 09/14=>12/14. Exception in CP-140481. Dec.14: 90->100 / Impacted TSs and TRs: 23.380, 29.060, 29.274
- 913: CP#65 completed / Impacted TSs and TRs: 24.008
- 914: CP#65 updated WID CP-140443=>CP-140490 (added CT3 part). Exception in CP-140687 / Impacted TSs and TRs: 29.061, 29.165
- 915: -
- 916: CP#65 completion 09/14=>12/14. Exception in CP-140481. Dec.14: 90->100 / Impacted TSs and TRs: 29.002, 29.228, 29.229, 29.272, 29.305
- 917: CP#65 completion 09/14=>12/14. Exception in CP-140605. Dec.14: 65->100% / Impacted TSs and TRs: 24.229
- 918: -
- 919: CP#65 updated WID CP-140443=>CP-140490 (added CT3 part). Exception in CP-140687 / Impacted TSs and TRs: 29.212, 29.213, 29.214, 29.215
- 920: CP#65 completion 09/14=>12/14. Exception in CP-140605. Dec.14: 65->100 / Impacted TSs and TRs: 24.229
- 921: Stage 3. Review the references related to RFC 3265 in the 3GPP IMS specifications and determine the impact of the RFC 6665 changes / Impacted TSs and TRs: Stage 3
- 922: CP#65 completion 09/14=>12/14. Exception in CP-140620. 3/3/15: 100% cpltd. / Impacted TSs and TRs: 23.218, 24.141, 24.147, 24.229, 24.237, 24.292, 24.337, 24.341, 24.604, 24.606, 24.623, 24.628, 24.629, 24.642
- 923: CP#62 completed / Impacted TSs and TRs: 29.163, 29.165
- 924: Added as per CT chair indications on 12th March 2015, no WID, no end date / Impacted TSs and TRs: draft-ietf-sipcore-refer-clarification
- 925: Added as per CT chair indications on 12th March 2015, no WID, no end date / Impacted TSs and TRs: draft-ietf-sipcore-refer-explicit-subscription
- 926: Added as per CT chair indications on 12th March 2015, no WID, no end date / Impacted TSs and TRs: draft-roach-sipcore-6665-clarification
- 927: Handling of premium rate numbers remained OPEN in Rel-11 (shifted to Rel-12). CP-130384 LS_out sent to SA1 / GSMA informing this TSG CP#60 decision / Impacted TSs and TRs: Stage 3
- 928: CP#64 completed / Impacted TSs and TRs: 24.229, 24.315
- 929: CP#65 completed / Impacted TSs and TRs: 29.165
- 930: CP#65 completion 09/14=>12/14. Exception in CP-140617.Dec.14: 80->85%. 3/3/15: 100% cpltd. / Impacted TSs and TRs: 24.008, 24.301
- 931: Add optional ICE support as defined in Rel-8 TS (23.228, 24.229) to Iq, Ix, Mn, Mp, Mc interfaces. SA2 Rel-12 TS 23.228 requires support for ICE in eP-CSCF, eIMS-AGW for WebRTC / Impacted TSs and TRs: Stage 2/3
- 932: CP#65 completed / Impacted TSs and TRs: 23.333, 23.334, 29.232, 29.238, 29.332, 29.333, 29.334
- 933: CP#64 completed / Impacted TSs and TRs: 29.162, 29.163, 29.292
- 934: Rel-12 enhancements to business trunking (BusTI). ETSI E2NA(14)000019 asked 3GPP to take responsibility of business communications over IMS: TS 181 019, TS 182 023, TS 182 024, TS 182 025, TR 183 060
- 935: SP#65 completed. TS 22.519v200 for Approval / Impacted TSs and TRs: New TS 22.519 (ETSI TS 181 019)
- 936: CP#65 TS 24.525v200 for Approval. TR 24.969v100 for Information. Completion 09/14=>12/14. Exception in CP-140619. Dec.14: 90->100 / Impacted TSs and TRs: New TSs [24.523 (TS 182 023), 24.524 (TS 182 024), 24.525 (TS 182 025)], New TR 24.969 (TR 183 069)

| ID | WBS | Task | Duration | Start | Finish | Complete | Remaining | Baseline start | Baseline finish | Baseline duration | Total slack | Constraint | Resources | Work | Actual work | Acronym | PCG approved | WI rapporteur name | Release | TSG approved | MCC resp | Acronym_3GU_Export | Status Report |
| --- | --- | --- | --- | --- | --- | --- | --- | --- | --- | --- | --- | --- | --- | --- | --- | --- | --- | --- | --- | --- | --- | --- | --- |
| 937 | 241 | **Support of ALT-C attribute** | 200d? | 2014-03-10 A | 2014-12-09 A | 100% |  | 2014-03-05 | 2014-09-12 | 138d? |  |  | C4; C1; C3 | 9600h | 9600h | ALTC | PCG-32 | Orange | Rel-12 | CP-63 | Kimmo | ALTC |  |
| 938 | 241.1 | CT4 part of Support of ALT-C attribute | 200d? | 2014-03-10 A | 2014-12-09 A | 100% |  | 2014-03-05 | 2014-09-12 | 138d? |  | finish no earlier than 2014-12-09 | C4 | 1600h | 1600h | ALTC | PCG-32 | Orange | Rel-12 | CP-63 | Kimmo |  | CP-140485 |
| 939 | 241.2 | CT1 part of Support of ALT-C attribute | 200d? | 2014-03-10 A | 2014-12-09 A | 100% |  | 2014-03-05 | 2014-09-12 | 138d? |  | finish no earlier than 2014-12-09 | C1 | 1600h | 1600h | ALTC | PCG-32 | Orange | Rel-12 | CP-63 | Frederic |  | CP-140611 |
| 940 | 241.3 | CT3 part of Support of ALT-C attribute | 200d? | 2014-03-10 A | 2014-12-09 A | 100% |  | 2014-03-05 | 2014-06-13 | 73d? |  | finish no earlier than 2014-12-09 | C3 | 1600h | 1600h | ALTC | PCG-32 | Orange | Rel-12 | CP-63 | Adrian |  | CP-140563 |
| 941 | 242 | **Diameter Overload Control Mechanisms** | 131d? | 2014-06-13 A | 2014-12-09 | 75% | 32.75d? | 2014-06-13 | 2014-12-05 | 126d? | 657d |  | C4; IETF | 4144h | 2197.5h | DOCME | PCG-33 | Orange | Rel-12 | CP-64 |  | DOCME |  |
| 942 | 242.1 | CT4 part of Diameter Overload Control Mechanisms | 128d? | 2014-06-13 A | 2014-12-09 A | 100% |  | 2014-06-13 | 2014-09-12 | 66d? |  | finish no earlier than 2014-12-09 | C4 | 1024h | 1024h | DOCME | PCG-33 | Orange | Rel-12 | CP-64 |  |  | CP-140486 |
| 943 | 242.2 | (IETF) Diameter Overload Control Mechanisms | 128d? | 2014-06-13 A | 2014-12-09 | 50% | 64d? | 2014-06-13 | 2014-12-05 | 126d? | 657d | finish no earlier than 2014-12-09 | C4-IETF | 1024h | 512h | DOCME | PCG-33 | christer.holmberg@ericsson.com | Rel-12 | CP-64 |  |  |  |
| 944 | 243 | **Impacts of RFC7044 for introduction of the new History-Info header field** | 131d? | 2014-06-13 A | 2014-12-09 A | 100% |  | 2014-06-13 | 2014-09-12 | 66d? |  |  | C1; C3 | 3648h | 3648h | HISTORY_CT | PCG-33 | Deutsche Telekom | Rel-12 | CP-64 |  | HISTORY_CT |  |
| 945 | 243.1 | CT1 part of Impacts of RFC7044 for introduction of the new History-Info header field | 128d? | 2014-06-13 A | 2014-12-09 A | 100% |  | 2014-06-13 | 2014-09-12 | 66d? |  | finish no earlier than 2014-12-09 | C1 | 1024h | 1024h | HISTORY_CT | PCG-33 | Deutsche Telekom | Rel-12 | CP-64 |  |  | CP-140609 |
| 946 | 243.2 | CT3 part of Impacts of RFC7044 for introduction of the new History-Info header field | 66d? | 2014-06-13 A | 2014-09-11 A | 100% |  | 2014-06-13 | 2014-09-12 | 66d? |  | finish no earlier than 2014-09-12 | C3 | 528h | 528h | HISTORY_CT | PCG-33 | Deutsche Telekom | Rel-12 | CP-64 |  |  |  |
| 947 | 244 | **Indication of NNI Routeing scenarios in SIP requests** | 131d? | 2014-06-13 A | 2014-12-09 | 84% | 21.53d? | 2014-06-13 | 2014-12-05 | 126d? | 657d |  | C1; C3; IETF | 5456h | 2284h | NNI_RS | PCG-33 | Ericsson | Rel-12 | CP-64 |  | NNI_RS |  |
| 948 | 244.1 | CT1 part of Indication of NNI Routeing scenarios in SIP requests | 128d? | 2014-06-13 A | 2014-12-09 A | 100% |  | 2014-06-13 | 2014-09-12 | 66d? |  | finish no earlier than 2014-12-09 | C1 | 1024h | 1024h | NNI_RS | PCG-33 | Ericsson | Rel-12 | CP-64 |  |  | CP-140613 |
| 949 | 244.2 | (IETF) CT1 part of Indication of NNI Routeing scenarios in SIP requests (holmberg-dispatch-iotl) | 95d? | 2014-06-13 A | 2014-12-09 | 50% | 47.5d? | 2014-06-13 | 2014-12-05 | 93d? | 657d | finish no earlier than 2014-12-09 | C1-IETF | 760h | 380h | NNI_RS | PCG-33 | christer.holmberg@ericsson.com | Rel-12 | CP-64 |  |  |  |
| 950 | 244.3 | CT3 part of Indication of NNI Routeing scenarios in SIP requests | 66d? | 2014-06-13 A | 2014-09-11 A | 100% |  | 2014-06-13 | 2014-09-12 | 66d? |  | finish no earlier than 2014-09-12 | C3 | 528h | 528h | NNI_RS | PCG-33 | Ericsson | Rel-12 | CP-64 |  |  |  |
| 951 | 245 | Unstructured Supplementary Service Data (USSD) method selection (Stage 3) | 3d? | 2014-06-11 A | 2014-06-13 A | 100% |  | 2014-06-11 | 2014-06-13 | 3d? |  | finish no earlier than 2014-06-13 | C1 | 24h | 24h | USSD_MS | PCG-33 | Ericsson | Rel-12 | CP-64 |  | USSD_MS |  |
| 952 | 246 | Representational State Transfer (REST) reference point between Application Function (AF) and Protocol Converter (PC) | 128d? | 2014-06-13 A | 2014-12-09 A | 100% |  | 2014-06-13 | 2014-09-12 | 66d? |  | finish no earlier than 2014-12-09 | C3 | 1024h | 1024h | REST_AF_PC | PCG-33 | Alcatel-Lucent | Rel-12 | CP-64 |  | REST_AF_PC | CP-140561 |
| 953 | 247 | **Overload Control for PCC based Diameter applications** | 131d? | 2014-06-13 A | 2014-12-09 | 67% | 43.22d? | 2014-06-13 | 2014-12-05 | 126d? | 657d |  | C3; IETF | 3648h | 2444.54h | DOCME-PCC | PCG-33 | Huawei | Rel-12 | CP-64 |  | DOCME-PCC |  |
| 954 | 247.1 | CT3 part of Overload Control for PCC based Diameter applications | 66d? | 2014-06-13 A | 2014-09-11 A | 100% |  | 2014-06-13 | 2014-09-12 | 66d? |  | finish no earlier than 2014-09-12 | C3 | 528h | 528h | DOCME-PCC | PCG-33 | Huawei | Rel-12 | CP-64 |  |  |  |
| 955 | 247.2 | (IETF) Overload Control for PCC based Diameter applications | 128d? | 2014-06-13 A | 2014-12-09 | 50% | 64d? | 2014-06-13 | 2014-12-05 | 126d? | 657d | finish no earlier than 2014-12-09 | C3-IETF | 1024h | 512h | DOCME-PCC | PCG-33 | christer.holmberg@ericsson.com | Rel-12 | CP-64 |  |  |  |
| 956 | 248 | Network Initiated USSD Simulation Services in IMS | 63d? | 2014-09-12 A | 2014-12-09 A | 100% |  |  |  |  |  | finish no earlier than 2014-12-09 | C1 | 504h | 504h | USSI-NET | PCG-33 | AT&T | Rel-12 | CP-65 |  | USSI-NET | CP-140610 |
| 957 | 249 | **Introduction of ER-GSM band for GSM-R** | 651d? | 2011-09-16 A | 2014-02-28 A | 100% |  | 2011-09-16 | 2014-02-28 | 651d? |  |  | G1; C1; G3new | 26496h | 26496h | RT_ERGSM | PCG-27 | Kapsch Carriercom, Sierra Wireless | Rel-12 | GP-51 | Paolo | RT_ERGSM |  |
| 958 | 249.1 | GERAN1 part of Introduction of ER-GSM band for GSM-R | 647d? | 2011-09-16 A | 2014-02-28 A | 100% |  | 2011-09-16 | 2014-02-28 | 647d? |  | finish no earlier than 2014-02-28 | G1 | 5168h | 5168h | RT_ERGSM | PCG-27 | Kapsch Carriercom, Sierra Wireless | Rel-12 | GP-51 | Paolo |  |  |
| 959 | 249.2 | Test part: Introduction of ER-GSM band for GSM-R | 131d? | 2013-09-02 A | 2014-02-28 A | 100% |  | 2013-09-02 | 2014-02-28 | 131d? |  | finish no earlier than 2014-02-28 | G3new | 1048h | 1048h | RT_ERGSM | PCG-31 | Kapsch Carriercom, Sierra Wireless | Rel-12 | GP-59 | Ingbert |  |  |
| 960 | 249.3 | CT1 part of Introduction of ER-GSM band for GSM-R | 582d? | 2011-09-28 A | 2013-12-06 A | 100% |  | 2011-09-28 | 2013-12-06 | 582d? |  | finish no earlier than 2013-12-06 | C1 | 4656h | 4656h | RT_ERGSM | PCG-27 | Kapsch Carriercom, Sierra Wireless | Rel-12 | CP-53 | Frederic |  |  |

Notes:
- 937: SA2 TS 23.228 requires UEs supporting IPv4, IPv6 or both IPv4 and IPv6 IP address formats shall be supported by IMS. Specify procedures to support altc SDP attribute within IMS for terminating communications destined to an enterprise network. / WI rapporteur e-mail: lionel.morand@orange.com
- 938: CP#65 completion 09/14=>12/14. Exception in CP-140485. Dec.14: 0->100 / Impacted TSs and TRs: 23.334, 29.238, 29.334 / WI rapporteur e-mail: lionel.morand@orange.com
- 939: CP#65 completion 09/14=>12/14. Exception in CP-140611. Dec.14: 0->100 / Impacted TSs and TRs: 24.229 / WI rapporteur e-mail: lionel.morand@orange.com
- 940: CP#65 completion 09/14=>12/14. Exception in CP-140563. Dec.14: 0->100 / Impacted TSs and TRs: 29.162 / WI rapporteur e-mail: lionel.morand@orange.com
- 941: Triggered by TR 29.809 Study on Diameter overload control mechanism (FS_DOCME) / WI rapporteur e-mail: lionel.morand@orange.com
- 942: CP#65 completion 09/14=>12/14. Exception in CP-140486. Dec.14: 70->100 / Impacted TSs and TRs: 29.228, 29.229, 29.272, 29.273, 29.328, 29.329, 29.336, 29.337, 29.344, 29.345 / WI rapporteur e-mail: lionel.morand@orange.com
- 943: Mar15: In WGLC / Impacted TSs and TRs: draft-ietf-dime-ovli / WI rapporteur e-mail: christer.holmberg@ericsson.com
- 944: IETF updated RFC4244 for History-Info header field to RFC7044. IETF introduced new features which could be useful for 3GPP use cases. / WI rapporteur e-mail: Roland Jesske (r.jesske@telekom.de)
- 945: CP#65 completion 09/14=>12/14. Exception in CP-140609. Dec.14: 85->100 / Impacted TSs and TRs: 24.229, 24.259, 24.604 / WI rapporteur e-mail: Roland Jesske (r.jesske@telekom.de)
- 946: CP#65 completed / Impacted TSs and TRs: 29.163, 29.165, 29.292 / WI rapporteur e-mail: Roland Jesske (r.jesske@telekom.de)
- 947: Triggered by TR 24.802 Study on Indication of Network to Network Interface (NNI) Routeing scenarios in SIP requests UID_580025 / WI rapporteur e-mail: Jan.Holm@ericsson.com
- 948: CP#65 completion 09/14=>12/14. Exception in CP-140613. Dec.14: 95->100 / Impacted TSs and TRs: 24.229 / WI rapporteur e-mail: Jan.Holm@ericsson.com
- 949: Publication requested / Impacted TSs and TRs: draft-holmberg-dispatch-iotl / WI rapporteur e-mail: christer.holmberg@ericsson.com
- 950: CP#65 completed / Impacted TSs and TRs: 29.079, 29.165 / WI rapporteur e-mail: Jan.Holm@ericsson.com
- 951: CP#64 approved WID & completed. Related to R11 USSD simulation service in IMS (delivery of UE originating USSD request using IMS, I.e. introduce 2nd method for delivery of UE originating USSD request to network (additional to USSD using CS domain) / Impacted TSs and TRs: 24.173, 24.390, New TS 24.391 / WI rapporteur e-mail: ivo.sedlacek@ericsson.com
- 952: CP#65 completion 09/14=>12/14. TS 29.201v200 for Approval. Exception in CP-140561. Dec.14: 80->100 / Impacted TSs and TRs: 29.213, 29.214, new TS 29.201 / WI rapporteur e-mail: horst.brinkmann@alcatel-lucent.com
- 953: Triggered by TR 29.809 Study on Diameter overload control mechanism (FS_DOCME) / WI rapporteur e-mail: Xia Haitao (xiahaitao@huawei.com)
- 954: CP#65 completed / Impacted TSs and TRs: 29.212, 29.213, 29.214 / WI rapporteur e-mail: Xia Haitao (xiahaitao@huawei.com)
- 955: work in progress / Impacted TSs and TRs: draft-ietf-dime-ovli / WI rapporteur e-mail: christer.holmberg@ericsson.com
- 956: CP#65 exception in CP-140610. Dec.14: 75->100 / Impacted TSs and TRs: 24.390 / WI rapporteur e-mail: Martin Dolly (md3135@att.com)
- 957: Use of band 870-876/915-921 MHz for land mobile service on national possibilities/market demand - as per ECC/DEC/(04)06. Introduction of ERGSM band, Performance requirements and Deployment scenarios. / Impacted TSs and TRs: GERAN / WI rapporteur e-mail: thomas.chatelet@kapsch.net, Rémi Lascoux (rlascoux@sierrawireless.com)
- 958: GP#61 completed. GP#51 approved WID / Impacted TSs and TRs: 45.001, 45.005, 45.008, 45.050 / WI rapporteur e-mail: thomas.chatelet@kapsch.net, Rémi Lascoux (rlascoux@sierrawireless.com)
- 959: GP#61 completed / Impacted TSs and TRs: 51.010, 51.021 / WI rapporteur e-mail: thomas.chatelet@kapsch.net, Rémi Lascoux (rlascoux@sierrawireless.com)
- 960: CP#62 completed. Added ERGSM capability indication (24.008 CR#2469R1) / Impacted TSs and TRs: 24.008 / WI rapporteur e-mail: thomas.chatelet@kapsch.net, Rémi Lascoux (rlascoux@sierrawireless.com)

| ID | WBS | Task | Duration | Start | Finish | Complete | Remaining | Baseline start | Baseline finish | Baseline duration | Total slack | Constraint | Resources | Work | Actual work | Acronym | PCG approved | WI rapporteur name | Release | TSG approved | MCC resp | Acronym_3GU_Export | Status Report | Special Focus Doc | PCG stopped | TSG stopped |
| --- | --- | --- | --- | --- | --- | --- | --- | --- | --- | --- | --- | --- | --- | --- | --- | --- | --- | --- | --- | --- | --- | --- | --- | --- | --- | --- |
| 961 | 250 | **Downlink Multi Carrier GERAN** | 666d? | 2012-09-10 A | 2015-03-13 | 91% | 61.92d? | 2012-09-10 | 2014-09-12 | 533d? | 589d |  | G2; G1; C1; G3new | 34536h | 12164.8h | DMCG | PCG-29 | Ericsson | Rel-12 | GP-55 | Gert | DMCG |  |  |  |  |
| 962 | 250.1 | Core part: Downlink Multi Carrier GERAN | 229d? | 2013-07-22 A | 2014-05-30 A | 100% |  | 2013-07-22 | 2014-05-30 | 229d? |  | finish no earlier than 2014-05-30 | G2; G1 | 3664h | 3664h | DMCG | PCG-29 | Ericsson | Rel-12 | GP-55 | Gert |  |  |  |  |  |
| 963 | 250.2 | CT part: Downlink Multi Carrier GERAN | 533d? | 2012-09-10 A | 2014-09-11 A | 100% |  | 2012-09-10 | 2014-09-12 | 533d? |  | finish no earlier than 2014-09-12 | C1 | 4264h | 4264h | DMCG | PCG-29 | Ericsson | Rel-12 | GP-55 | Frederic |  |  |  |  |  |
| 964 | 250.3 | Test part: Downlink Multi Carrier GERAN | 662d? | 2012-09-10 A | 2015-03-13 | 80% | 132.4d? | 2012-09-10 | 2014-08-29 | 522d? | 589d | finish no earlier than 2015-03-13 | G3new | 5296h | 4236.8h | DMCG-MStest | PCG-29 | ST-Ericsson | Rel-12 | GP-55 | Ingbert | DMCG-MStest |  |  |  |  |
| 965 | 251 | **Mobile Station Receive Diversity (MSRD) for Voice Services over Adaptive Multi-user channels on One Slot (VAMOS)** | 459d? | 2013-03-01 A | 2014-11-21 A | 100% |  | 2013-03-01 | 2014-08-29 | 396d? |  |  | G1; G2; C1; G3new | 24064h | 24064h | MSRD_VAMOS | PCG-30 | Nokia Networks, Microsoft | Rel-12 | GP-57 | Paolo | MSRD_VAMOS | GP-140579 |  |  |  |
| 966 | 251.1 | CT1 introduction of MS capability support for MS supporting MSRD for VAMOS | 205d? | 2013-03-01 A | 2013-12-06 A | 100% |  | 2013-03-01 | 2013-12-06 | 205d? |  | finish no earlier than 2013-12-06 | C1 | 1640h | 1640h | MSRD_VAMOS | PCG-30 | Nokia Networks, Microsoft | Rel-12 | GP-57 | Frederic |  |  |  |  |  |
| 967 | 251.2 | MSRD for VAMOS - Performance Requirements | 257.5d? | 2013-11-28 A | 2014-11-21 A | 100% |  | 2013-11-28 | 2014-08-29 | 197.5d? |  | finish no earlier than 2014-11-21 | G1; G2 | 4120h | 4120h | MSRD_VAMOS-PerfReq | PCG-30 | Nokia Networks, Microsoft | Rel-12 | GP-57 | Paolo | MSRD_VAMOS-PerfReq | GP-140579 |  |  |  |
| 968 | 251.3 | MSRD for VAMOS - MS Conformance Test | 453d? | 2013-03-06 A | 2014-11-21 A | 100% |  | 2013-03-06 | 2014-08-29 | 393d? |  | finish no earlier than 2014-11-21 | G3new | 3616h | 3616h | MSRD_VAMOS-Test | PCG-30 | Nokia Networks, Microsoft | Rel-12 | GP-57 | Ingbert | MSRD_VAMOS-Test | GP-140579 |  |  |  |
| 969 | 252 | **New Training Sequence Codes (TSC) for GERAN** | 277d? | 2013-11-22 A | 2014-12-09 | 93% | 18.18d? | 2013-11-22 | 2014-08-29 | 202d? | 657d |  | G1; G2; C1 | 11184h | 10449.7h | NewToN | PCG-32 | Ericsson | Rel-12 | GP-60 | Paolo | NewToN | GP-140542 |  |  |  |
| 970 | 252.1 | GERAN1 part of New Training Sequence Codes (TSC) for GERAN | 261d? | 2013-11-22 A | 2014-11-21 A | 100% |  | 2013-11-22 | 2014-08-29 | 201d? |  | finish no earlier than 2014-11-21 | G1 | 2088h | 2088h | NewToN | PCG-32 | Ericsson | Rel-12 | GP-60 | Paolo |  | GP-140542 |  |  |  |
| 971 | 252.2 | GERAN2 part of New Training Sequence Codes (TSC) for GERAN | 261d? | 2013-11-22 A | 2014-11-21 | 80% | 52.2d? | 2013-11-22 | 2014-08-29 | 201d? | 669d | finish no earlier than 2014-11-21 | G2 | 2088h | 1670.4h | NewToN | PCG-32 | Ericsson | Rel-12 | GP-60 | Gert |  | GP-140542 |  |  |  |
| 972 | 252.3 | CT1 part of New Training Sequence Codes (TSC) for GERAN (Stage 3) | 273d? | 2013-11-22 A | 2014-12-09 A | 100% |  | 2013-11-22 | 2014-08-29 | 201d? |  | finish no earlier than 2014-12-09 | C1 | 2184h | 2184h | NewToN | PCG-32 | Ericsson | Rel-12 | GP-60 | Frederic |  | CP-140604 |  |  |  |
| 973 | 253 | **Verification of radiated multi-antenna reception performance of UEs in LTE/UMTS** | 469d? | 2012-03-05 A | 2013-12-06 A | 100% |  | 2012-03-05 | 2013-12-06 | 469d? |  |  | R4 | 7464h | 7464h | HSPA_LTE_measRP_MIMO | PCG-28 | Vodafone | Rel-12 | RP-55 | Issam | HSPA_LTE_measRP_MIMO |  |  |  |  |
| 974 | 253.1 | Perf. Part: Verification of radiated multi-antenna reception performance of UEs in LTE/UMTS | 464d? | 2012-03-05 A | 2013-12-06 A | 100% |  | 2012-03-05 | 2013-12-06 | 464d? |  | finish no earlier than 2013-12-06 | R4 | 3712h | 3712h | HSPA_LTE_measRP_MIMO-Perf | PCG-28 | Vodafone | Rel-12 | RP-55 | Issam | HSPA_LTE_measRP_MIMO-Perf | RP-131507 |  |  |  |
| 975 | 254 | **Further enhancements to H(e)NB mobility - Part 3 (Stage 2/3)** | 330d? | 2012-09-12 A | 2013-12-06 A | 100% |  | 2012-09-12 | 2013-12-06 | 330d? |  |  | R3; R2 | 10560h | 10560h | EHNB_enh3 | PCG-29 | Alcatel-Lucent | Rel-12 | RP-57 | Juha | EHNB_enh3 |  | HNB |  |  |
| 976 | 254.1 | Core part: Further enhancements to H(e)NB mobility - Part 3 | 330d? | 2012-09-12 A | 2013-12-06 A | 100% |  | 2012-09-12 | 2013-12-06 | 330d? |  | finish no earlier than 2013-12-06 | R3; R2 | 5280h | 5280h | EHNB_enh3-Core | PCG-29 | Alcatel-Lucent | Rel-12 | RP-57 | Juha | EHNB_enh3-Core | RP-131508 | HNB |  |  |
| 977 | 255 | **Support for BeiDou Navigation Satellite System (BDS) for UTRA and LTE** | 604d? | 2013-03-04 A | 2015-06-15 | 98% | 11.8d? | 2013-03-04 | 2015-06-12 | 600d? | 523d |  | R2; R3; R4; R5 | 31680h | 16790.4h | LCS_BDS | PCG-30 | CATR | Rel-12 | RP-59 | Yong-Jun | LCS_BDS |  |  |  |  |
| 978 | 255.1 | Core part: Support for BeiDou Navigation Satellite System (BDS) for UTRA | 204d? | 2013-06-02 A | 2014-03-06 A | 100% |  | 2013-06-02 | 2014-03-06 | 204d? |  | finish no earlier than 2014-03-06 | R2; R3 | 3264h | 3264h | LCS_BDS-UTRA-Core | PCG-30 | ZTE | Rel-12 | RP-59 | Yong-Jun | LCS_BDS-UTRA-Core | RP-131500 |  |  |  |
| 979 | 255.2 | Perf. part: Support for BeiDou Navigation Satellite System (BDS) for UTRA | 336d? | 2013-03-07 A | 2014-06-13 A | 100% |  | 2013-03-07 | 2014-06-13 | 336d? |  | finish no earlier than 2014-06-13 | R4 | 2688h | 2688h | LCS_BDS-UTRA-Perf | PCG-30 | ZTE | Rel-12 | RP-59 | Issam | LCS_BDS-UTRA-Perf | RP-140714 |  |  |  |
| 980 | 255.3 | Core part: Support for BeiDou Navigation Satellite System (BDS) for LTE | 202d? | 2013-03-04 A | 2013-12-06 A | 100% |  | 2013-03-04 | 2013-12-06 | 202d? |  | finish no earlier than 2013-12-06 | R2 | 1616h | 1616h | LCS_BDS-LTE-Core | PCG-30 | CATR | Rel-12 | RP-59 | Yong-Jun | LCS_BDS-LTE-Core | RP-131525 |  |  |  |
| 981 | 255.4 | Perf. part: Support for BeiDou Navigation Satellite System (BDS) for LTE | 336d? | 2013-03-07 A | 2014-06-13 A | 100% |  | 2013-03-07 | 2014-06-13 | 336d? |  | finish no earlier than 2014-06-13 | R4 | 2688h | 2688h | LCS_BDS-LTE-Perf | PCG-30 | ZTE | Rel-12 | RP-59 | Issam | LCS_BDS-LTE-Perf | RP-140713 |  |  |  |
| 982 | 255.5 | Test part: BeiDou Navigation Satellite System (BDS) Positioning Support for LTE and UMTS | 262d? | 2014-06-15 A | 2015-06-15 | 90% | 26.2d? | 2014-06-13 | 2015-06-12 | 261d? | 523d | finish no earlier than 2015-06-15 | R5 | 2096h | 1886.4h | LCS_BDS-UEConTest | PCG-33 | CATT | Rel-12 | RP-64 |  | LCS_BDS-UEConTest | RP-150357 |  |  |  |
| 983 | 256 | **Support for BeiDou Navigation Satellite System (BDS) for LCS in GERAN** | 345d? | 2013-11-22 A | 2015-03-13 | 93% | 25.19d? | 2013-11-22 | 2014-11-21 | 262d? | 589d |  | G2; G1; G3new | 14213.2h | 5848.39h | LCS_BDS_GERAN | PCG-32 | ZTE | Rel-12 | GP-60 | Gert | LCS_BDS_GERAN |  |  |  |  |
| 984 | 256.1 | GERAN2 part of Support for BeiDou Navigation Satellite System (BDS) for LCS in GERAN | 201d? | 2013-11-22 A | 2014-08-29 A | 100% |  | 2013-11-22 | 2014-08-29 | 201d? |  | finish no earlier than 2014-08-29 | G2 | 1608h | 1608h | LCS_BDS_GERAN | PCG-32 | ZTE | Rel-12 | GP-60 | Gert |  |  |  |  |  |
| 985 | 256.2 | GERAN1 part of Support for BeiDou Navigation Satellite System (BDS) for LCS in GERAN | 201d? | 2013-11-22 A | 2014-08-29 A | 100% |  | 2013-11-22 | 2014-08-29 | 201d? |  | finish no earlier than 2014-08-29 | G1 | 1608h | 1608h | LCS_BDS_GERAN | PCG-32 | ZTE | Rel-12 | GP-60 | Paolo |  |  |  |  |  |
| 986 | 256.3 | Support for BeiDou Navigation Satellite System (BDS) for LCS in GERAN3new | 272d? | 2014-03-01 A | 2015-03-13 | 80% | 54.4d? | 2014-02-28 | 2014-11-21 | 192d? | 589d | finish no earlier than 2015-03-13 | G3new | 2176h | 1740.8h | LCS_BDS_GERAN-GERAN3new | PCG-32 | CATR | Rel-12 | GP-61 | Ingbert | LCS_BDS_GERAN-GERAN3new |  |  |  |  |
| 987 | 256.4 | Deleted - Test part: Support for BeiDou Navigation Satellite System (BDS) for LCS in GERAN | 71d? | 2013-11-22 A | 2014-02-28 A | 100% |  | 2013-11-22 | 2014-02-28 | 71d? |  | finish no earlier than 2014-08-29 | G3new | 565.19h | 565.19h | LCS_BDS_GERAN-MStest | PCG-32 | ZTE | Rel-12 | GP-60 | Ingbert | LCS_BDS_GERAN-MStest |  |  | PCG-32 | GP-61 |

Notes:
- 961: Linked to Rel-7 Downlink Dual Carrier UID_50579 (Previous work on multiple carriers on the downlink was limited to two). Ref: TR 45.912 Feasibility study for evolved GERAN, TS 43.064 GPRS Stage 2 / Impacted TSs and TRs: GERAN / WI rapporteur e-mail: paul.schliwa-bertling@ericsson.com
- 962: GP#62 completed. GP#55 approved WID / Impacted TSs and TRs: 43.064, 44.004, 44.018, 44.060, 45.002, 45.003, 45.005, 45.008, 48.018 / WI rapporteur e-mail: paul.schliwa-bertling@ericsson.com
- 963: CP#65 completed / Impacted TSs and TRs: 24.008 / WI rapporteur e-mail: paul.schliwa-bertling@ericsson.com
- 964: GP#63 completion 08/14=>11/14. Dec.14: 35->80%, CD:11/14->03/15 / Impacted TSs and TRs: 51.010-1, 51.010-2 / WI rapporteur e-mail: hakan.e.grunditz@stericsson.com
- 965: GP#63 completion 08/14=>11/14. Exception in GP-140579. Linked to Rel-7 Mobile Station Receive Diversity (DARP Phase II) UID_50569, Rel-9 Voice Services over Adaptive Multiuser channels on One Slot (VAMOS) UID_420002 / Impacted TSs and TRs: GERAN / WI rapporteur e-mail: Khairul Hasan (Nokia Networks), Markku Tarkiainen (Nokia=>Microsoft)
- 966: CP#62 completed / Impacted TSs and TRs: 24.008 / WI rapporteur e-mail: Khairul Hasan (Nokia Networks), Markku Tarkiainen (Nokia=>Microsoft)
- 967: GP#63 completion 08/14=>11/14. Exception in GP-140579. Dec.14: 95->100 / Impacted TSs and TRs: 44.018, 45.001, 45.002, 45.005, 45.008, 45.009 / WI rapporteur e-mail: Khairul Hasan (Nokia Networks), Markku Tarkiainen (Nokia=>Microsoft)
- 968: GP#63 completion 08/14=>11/14. Exception in GP-140579. Dec.14: 85->100 / Impacted TSs and TRs: 51.010-1, 51.010-2 / WI rapporteur e-mail: Khairul Hasan (Nokia Networks), Markku Tarkiainen (Nokia=>Microsoft)
- 969: GP#63 completion 08/14=>11/14. Exception in GP-140542. GP#60 approved WID. Triggered by GP-131041, GP#40 GP-081949 (WID VAMOS). Linked to Rel-9 VAMOS (Previous work where new TSCs were defined for GMSK modulation) UID_420002 / Impacted TSs and TRs: GERAN / WI rapporteur e-mail: Mårten Sundberg
- 970: GP#63 completion 08/14=>11/14. Exception in GP-140542. Dec.14: 80->100% / Impacted TSs and TRs: 45.001, 45.002, 45.008, 45.009, 45.050 / WI rapporteur e-mail: Mårten Sundberg
- 971: GP#63 completion 08/14=>11/14. Exception in GP-140542. / Impacted TSs and TRs: 44.018, 44.060 / WI rapporteur e-mail: Mårten Sundberg
- 972: CP#65 completion 09/14=>12/14. CP#65 exception in CP-140604. 3/3/15: 100% cpltd. / Impacted TSs and TRs: 24.008 / WI rapporteur e-mail: Mårten Sundberg
- 973: RP#59 moved to Rel-12. Triggered by FS_HSPA_LTE_measRP_MIMO_multi-antenna. Core functionality exists since Rel-6 & Rel-7 (MIMO). Adds a very generic test method to test UEs with 2 or more Rx antennas / Impacted TSs and TRs: UTRA, LTE / WI rapporteur e-mail: Luis Anaya
- 974: RP#62 completed. Rx diversity (defined as Rel-6 HSDPA RAN4 enhanced type 1 req.) & MIMO (defined as Rel-7 HSDPA MIMO for HSPA). Rx diversity & MIMO (defined as part of Rel-8 basic LTE WI) / Impacted TSs and TRs: new TR 37.977 / WI rapporteur e-mail: luis.anaya@vodafone.com
- 975: Triggered by FS_EHNB_enh (TR 37.803) / Impacted TSs and TRs: UTRA, LTE / WI rapporteur e-mail: Martin.Warner@alcatel-lucent.com
- 976: RP#62 completed / Impacted TSs and TRs: 25.304, 25.331, 25.367, 25.467, 25.469, 36.300, 36.331 / WI rapporteur e-mail: Martin.Warner@alcatel-lucent.com
- 977: BeiDou = Chinese Navigation Satellite System. Location Services (LCS) TS 22.071 Stage 1, TS 23.271 Stage 2 / Impacted TSs and TRs: UTRA, LTE / WI rapporteur e-mail: Ying Du (duying1@catr.cn)
- 978: RP#62 completed / Impacted TSs and TRs: 25.305, 25.306, 25.331, 25.453, 25.413, 25.423, 25.433 / WI rapporteur e-mail: Huang He (huang.he4@zte.com.cn)
- 979: RP#64 completed. TS 25.173v100 for 1-step Approval / Impacted TSs and TRs: 25.172 (FDD), new TS 25.173 (TDD) / WI rapporteur e-mail: Ling Soonleh (soonleh.ling@zte.com.cn)
- 980: RP#62 completed / Impacted TSs and TRs: 36.305, 36.355 / WI rapporteur e-mail: Ying Du (duying1@catr.cn)
- 981: RP#64 completed / Impacted TSs and TRs: 36.171 / WI rapporteur e-mail: Ling Soonleh (soonleh.ling@zte.com.cn)
- 982: ; Stat Rep: RP-141350->RP-141950 1st Apr 15: Compl:80%->90% 1st Apr 15: Stat Rep: RP-141950->RP-150357 / Impacted TSs and TRs: 34.108, 36.508, 37.571-1, 37.571-2, 37.571-3, 37.571-4, 37.571-5 / WI rapporteur e-mail: Chen Xiaiozhong (chenxiaozhong@catt.cn)
- 983: GP#60 approved WID. Based on the same framework used in Rel-8 Support for Additional Navigation Satellite Systems (ANSS) for LCS UID_38001 / Impacted TSs and TRs: GERAN / WI rapporteur e-mail: Wang Xinhui (wangxinhui@zte.com.cn)
- 984: GP#63 completed / Impacted TSs and TRs: 44.031, 49.031, 44.071, 48.031 / WI rapporteur e-mail: Wang Xinhui (wangxinhui@zte.com.cn)
- 985: GP#63 completed / Impacted TSs and TRs: 43.059, 45.005 / WI rapporteur e-mail: Wang Xinhui (wangxinhui@zte.com.cn)
- 986: Dec.14: 25->80%, CD: 11/14->03/15 / Impacted TSs and TRs: 51010-1, 51.010-2, 51.010-7 / WI rapporteur e-mail: Zhou DaiWei, China Academy of Telecommunication Research, zhoudaiwei@catr.cn
- 987: GP#61 stopped / Impacted TSs and TRs: 51.010-1 / WI rapporteur e-mail: Wang Xinhui (wangxinhui@zte.com.cn)

| ID | WBS | Task | Duration | Start | Finish | Complete | Remaining | Baseline start | Baseline finish | Baseline duration | Total slack | Constraint | Resources | Work | Actual work | Acronym | PCG approved | WI rapporteur name | WI rapporteur e-mail | Release | TSG approved | MCC resp | PCG stopped | TSG stopped | Acronym_3GU_Export | Status Report | Special Focus Doc |
| --- | --- | --- | --- | --- | --- | --- | --- | --- | --- | --- | --- | --- | --- | --- | --- | --- | --- | --- | --- | --- | --- | --- | --- | --- | --- | --- | --- |
| 988 | 257 | **Deleted - New Base Station specification structure** | 127d? | 2013-06-18 A | 2013-12-06 A | 100% |  | 2013-06-18 | 2013-12-06 | 127d? |  |  | R4 | 3024h | 3024h | BSspec_struc | PCG-31 | Ericsson | johan.skold@ericsson.com | Rel-12 | RP-60 | Issam | PCG-32 | RP-62 | BSspec_struc |  |  |
| 989 | 257.1 | Deleted - Core part: New Base Station specification structure | 126d? | 2013-06-18 A | 2013-12-06 A | 100% |  | 2013-06-18 | 2013-12-06 | 126d? |  | finish no earlier than 2013-12-06 | R4 | 1008h | 1008h | BSspec_struc-Core | PCG-31 | Ericsson | johan.skold@ericsson.com | Rel-12 | RP-60 | Issam | PCG-32 | RP-62 | BSspec_struc-Core | RP-131513 |  |
| 990 | 257.2 | Deleted - Perf. part: New Base Station specification structure | 125d? | 2013-06-20 A | 2013-12-06 A | 100% |  | 2013-06-20 | 2013-12-06 | 125d? |  | finish no earlier than 2013-12-06 | R4 | 1000h | 1000h | BSspec_struc-Perf | PCG-31 | Ericsson | johan.skold@ericsson.com | Rel-12 | RP-60 | Issam | PCG-32 | RP-62 | BSspec_struc-Perf | RP-131514 |  |
| 991 | 258 | **L-band for Supplemental Downlink in E-UTRA and UTRA** | 528d? | 2013-06-17 A | 2015-06-15 | 84% | 83.5d? | 2013-06-17 | 2014-06-13 | 264d? | 523d |  | R4; R2; R3 | 17408h | 10544h | LTE_UTRA_SDL_BandL | PCG-31 | Orange | olfa.benhaddada@orange.com | Rel-12 | RP-60 | Issam |  |  | LTE_UTRA_SDL_BandL |  |  |
| 992 | 258.1 | Core part: L-band for Supplemental Downlink in E-UTRA and UTRA | 87.33d? | 2014-02-13 A | 2014-06-13 A | 100% |  | 2014-02-13 | 2014-06-13 | 87.33d? |  | finish no earlier than 2014-06-13 | R4; R2; R3 | 2096h | 2096h | LTE_UTRA_SDL_BandL-Core | PCG-31 | Orange | olfa.benhaddada@orange.com | Rel-12 | RP-60 | Issam |  |  | LTE_UTRA_SDL_BandL-Core | RP-140633 |  |
| 993 | 258.2 | Perf. part: L-band for Supplemental Downlink in E-UTRA and UTRA | 264d? | 2013-06-17 A | 2014-06-13 A | 100% |  | 2013-06-17 | 2014-06-13 | 264d? |  | finish no earlier than 2014-06-13 | R4 | 2112h | 2112h | LTE_UTRA_SDL_BandL-Perf | PCG-31 | Orange | olfa.benhaddada@orange.com | Rel-12 | RP-60 | Issam |  |  | LTE_UTRA_SDL_BandL-Perf | RP-140633 |  |
| 994 | 258.3 | UE Conformance Test Aspects - L-band for Supplemental Downlink in E-UTRA and UTRA | 66d? | 2015-03-16 | 2015-06-15 |  |  |  |  |  | 523d | finish no earlier than 2015-06-15 | R5 | 528h |  | LTE_UTRA_SDL_BandL-UEConTest | PCG-34 | Ericsson |  | Rel-12 | RP-67 |  |  |  |  |  |  |
| 995 | 259 | **LTE-HRPD (High Rate Packet Data in 3GPP2) inter-RAT SON** | 263d? | 2013-06-18 A | 2014-06-13 A | 100% |  | 2013-06-18 | 2014-06-13 | 263d? |  |  | R3; S2; C4; G2 | 11096h | 11096h | LTE_HRPD_SON | PCG-31 | China Telecom | Jinlian_wu@189.cn | Rel-12 | RP-60 | Juha |  |  | LTE_HRPD_SON |  | SON |
| 996 | 259.1 | Stage 2 for LTE-HRPD (High Rate Packet Data in 3GPP2) inter-RAT SON | 67d? | 2013-09-11 A | 2013-12-11 A | 100% |  | 2013-09-11 | 2013-12-11 | 67d? |  | finish no earlier than 2013-09-11 | S2 | 528h | 528h | LTE_HRPD_SON | PCG-31 | Huawei | Huan Li (ivy.lihuan@huawei.com) | Rel-12 | SP-61 | Maurice |  |  |  |  |  |
| 997 | 259.2 | Core part: LTE-HRPD (High Rate Packet Data in 3GPP2) inter-RAT SON | 263d? | 2013-06-18 A | 2014-06-13 A | 100% |  | 2013-06-18 | 2014-06-13 | 263d? |  | finish no earlier than 2014-06-13 | R3 | 2088h | 2088h | LTE_HRPD_SON-Core | PCG-31 | China Telecom | Jinlian_wu@189.cn | Rel-12 | RP-60 | Juha |  |  | LTE_HRPD_SON-Core | RP-140745 |  |
| 998 | 259.3 | CT aspects for LTE-HRPD (High Rate Packet Data in 3GPP2) inter-RAT SON (Stage 3) | 3d? | 2013-09-04 A | 2013-09-06 A | 100% |  | 2013-09-04 | 2013-09-06 | 3d? |  | finish no earlier than 2013-09-06 | C4 | 24h | 24h | LTE_HRPD_SON-CT | PCG-31 | Huawei | Xiaoyan SHI (sean.shixiaoyan@huawei.com | Rel-12 | CP-61 | Kimmo |  |  | LTE_HRPD_SON-CT |  |  |
| 999 | 259.4 | GERAN aspects for LTE-HRPD inter-RAT SON, RAN Information Management (RIM) - Stage 3 | 5d? | 2013-08-26 A | 2013-08-30 A | 100% |  | 2013-08-26 | 2013-08-30 | 5d? |  | finish no earlier than 2013-09-06 | G2 | 40h | 40h | LTE_HRPD_SON-RIM | PCG-31 | Alcatel-Lucent | marguerite.woch@alcatel-lucent.com | Rel-12 | GP-59 | Gert |  |  | LTE_HRPD_SON-RIM |  |  |
| 1000 | 260 | **Increasing the minimum number of carriers for UE monitoring in UTRA and E-UTRA** | 395d? | 2013-12-15 A | 2015-06-15 | 60% | 157.07d? | 2013-12-09 | 2015-03-13 | 331d? | 523d |  | R4; R2 | 11324.4h | 3217.2h | LTE_UTRA_IncMon | PCG-32 | Ericsson | christopher.callender@ericsson.com | Rel-12 | RP-62 | Issam |  |  | LTE_UTRA_IncMon |  |  |
| 1001 | 260.1 | Core part: Increasing the minimum number of carriers for UE monitoring in UTRA and E-UTRA | 201d? | 2013-12-15 A | 2014-12-15 A | 100% |  | 2014-01-06 | 2014-09-12 | 133d? |  | finish no earlier than 2014-12-15 | R4; R2 | 1844.4h | 1844.4h | LTE_UTRA_IncMon-Core | PCG-32 | Ericsson | christopher.callender@ericsson.com | Rel-12 | RP-62 | Issam |  |  | LTE_UTRA_IncMon-Core | RP-141787 |  |
| 1002 | 260.2 | Perf. part: Increasing the minimum number of carriers for UE monitoring in UTRA and E-UTRA | 395d? | 2013-12-15 A | 2015-06-15 | 40% | 237d? | 2013-12-09 | 2015-03-13 | 331d? | 523d | finish no earlier than 2015-06-15 | R4 | 3160h | 1264h | LTE_UTRA_IncMon-Perf | PCG-32 | Ericsson | christopher.callender@ericsson.com | Rel-12 | RP-62 | Issam |  |  | LTE_UTRA_IncMon-Perf | RP-150063 |  |
| 1003 | 261 | **WLAN/3GPP Radio Interworking** | 532d? | 2013-12-06 A | 2015-12-15 | 66% | 180.16d? | 2013-12-06 | 2014-09-17 | 205d? | 392d |  | R2; S2; C1; C4 | 15237h | 7316.5h | UTRA_LTE_WLAN_interw | PCG-32 | Intel | sasha.sirotkin@intel.com | Rel-12 | RP-62 | Yong-Jun |  |  | UTRA_LTE_WLAN_interw |  | WLAN |
| 1004 | 261.1 | Core part: WLAN/3GPP Radio Interworking | 202d? | 2013-12-06 A | 2014-09-12 A | 100% |  | 2013-12-06 | 2014-09-12 | 202d? |  | finish no earlier than 2014-09-12 | R2 | 1616h | 1616h | UTRA_LTE_WLAN_interw-Core | PCG-32 | Intel | sasha.sirotkin@intel.com | Rel-12 | RP-62 | Yong-Jun |  |  | UTRA_LTE_WLAN_interw-Core | RP-141310 | WLAN |
| 1005 | 261.2 | SA2 aspects of WLAN/3GPP Radio Interworking | 140d? | 2014-03-07 A | 2014-09-17 A | 100% |  | 2014-03-07 | 2014-09-17 | 139d? |  | finish no earlier than 2014-09-17 | S2 | 1120h | 1120h | UTRA_LTE_WLAN_interw-SA2 | PCG-32 | Alcatel-Lucent | nicolas.drevon@alcatel-lucent.com | Rel-12 | SP-63 | Maurice |  |  | UTRA_LTE_WLAN_interw-SA2 |  | WLAN |
| 1006 | 261.3 | **CT aspects of WLAN/3GPP Radio Interworking (Stage 2/3)** | 68d? | 2014-09-09 A | 2014-12-09 | 99% | 0d? | 2014-06-13 | 2014-09-12 | 66d? | 0d |  | C1; C4 | 1665.6h | 1560h | UTRA_LTE_WLAN_interw-CT | PCG-33 | Alcatel-Lucent | jennifer.liu@alcatel-lucent.com | Rel-12 | CP-64 |  |  |  | UTRA_LTE_WLAN_interw-CT |  | WLAN |
| 1007 | 261.3.1 | CT1 part of CT aspects of WLAN/3GPP Radio Interworking (Stage 3) | 68d? | 2014-09-09 A | 2014-12-09 A | 100% |  | 2014-06-13 | 2014-09-12 | 66d? |  | finish no earlier than 2014-12-09 | C1 | 528h | 528h | UTRA_LTE_WLAN_interw-CT | PCG-33 | Alcatel-Lucent | jennifer.liu@alcatel-lucent.com | Rel-12 | CP-64 |  |  |  |  | CP-140720 | WLAN |
| 1008 | 261.3.2 | CT4 part of CT aspects of WLAN/3GPP Radio Interworking (Stage 2/3) | 63d? | 2014-09-12 A | 2014-12-09 A | 100% |  |  |  |  |  | finish no earlier than 2014-12-09 | C4 | 504h | 504h | UTRA_LTE_WLAN_interw-CT | PCG-33 | Alcatel-Lucent | jennifer.liu@alcatel-lucent.com | Rel-12 | CP-65 |  |  |  |  | CP-140482 | WLAN |
| 1009 | 261.4 | UE Conformance Test Aspects – WLAN/3GPP Radio Interworking | 262d? | 2014-12-15 A | 2015-12-15 | 5% | 248.9d? |  |  |  | 392d | finish no earlier than 2015-12-15 | R5 | 2096h | 104.8h | UTRA_LTE_WLAN_interw-UEConTest | PCG-34 | Intel | Intel | Rel-12 | RP-66 |  |  |  |  | RP-150098 |  |
| 1010 | 262 | **Rel-12 LTE Carrier Aggregation** | 1121d? | 2011-09-19 A | 2015-12-15 | 99% | 14.74d? | 2011-09-19 | 2014-12-11 | 855d? | 392d |  | R4 | 563774h | 546890h | LTE_CA_Rel-12 | PCG-30 |  |  | Rel-12 | RP-58 | Issam |  |  | LTE_CA_Rel-12 |  | CA |
| 1011 | 262.1 | **LTE Advanced inter-band Carrier Aggregation of Band 1 and Band 7** | 792d? | 2011-09-19 A | 2014-09-12 A | 100% |  | 2011-09-19 | 2014-09-12 | 791d? |  |  | R4 | 18896h | 18896h | LTE_CA_B1_B7 | PCG-27 | Ericsson | christian.bergljung@ericsson.com | Rel-12 | RP-53 | Issam |  |  | LTE_CA_B1_B7 |  | CA |
| 1012 | 262.1.1 | Core part: LTE Advanced inter-band Carrier Aggregation of Band 1 and Band 7 | 790d? | 2011-09-19 A | 2014-09-12 A | 100% |  | 2011-09-19 | 2014-09-12 | 790d? |  | finish no earlier than 2014-09-12 | R4 | 6312h | 6312h | LTE_CA_B1_B7-Core | PCG-27 | Ericsson | christian.bergljung@ericsson.com | Rel-12 | RP-53 | Issam |  |  | LTE_CA_B1_B7-Core | RP-141084 | CA |
| 1013 | 262.1.2 | Perf. part: LTE Advanced inter-band Carrier Aggregation of Band 1 and Band 7 | 781d? | 2011-10-03 A | 2014-09-12 A | 100% |  | 2011-09-30 | 2014-09-12 | 781d? |  | finish no earlier than 2014-09-12 | R4 | 6248h | 6248h | LTE_CA_B1_B7-Perf | PCG-27 | Ericsson | christian.bergljung@ericsson.com | Rel-12 | RP-53 | Issam |  |  | LTE_CA_B1_B7-Perf | RP-141084 | CA |

Notes:
- 988: Triggered by Rel-12 TR 37.810 Study on Base Station specification structure (FS_BSspec_struc) / Impacted TSs and TRs: UTRA, LTE, MSR
- 989: RP#62 stopped (at 20% completion) / Impacted TSs and TRs: 25.104, 25.105, 36.104, 37.104, 37.810, New TR 37.811 (New BS specification structure), New TS 37.xya (New RF core specification)
- 990: RP#62 stopped (at 0% completion) / Impacted TSs and TRs: 25.113, 25.141, 25.142, 36.113, 36.141, 37.113, 37.141, 37.810, New TS 37.xyz (New RF test specification, New TS 37.xyw (ew EMC specification)
- 991: ECC(12)052 CEPT decision to harmonize 1452-1492 MHz (L-band) for mobile communications Supplemental Downlink (SDL) => standardize L-band and corresponding E-UTRA and UTRA requirements for SDL operation in Region 1 / Impacted TSs and TRs: UTRA, LTE
- 992: RP#64 completed. RP#65 forgotten TR 37.814 v100 for 1-step Approval / Impacted TSs and TRs: 25.101, 25.104, 25.113, 25.133, 25.307, 25.327, 25.461, 25.466, 34.124, 36.101, 36.104, 36.113, 36.124, 36.133, 36.307, 36.331, 37.104, 37.113, new TR 37.814
- 993: RP#64 completed / Impacted TSs and TRs: 25.133, 25.141, 25.307, 25.327, 36.133, 36.141, 36.307, 37.141
- 995: Triggered by Rel-12 TR 37.813 (FS_LTE_HRPD_SON). SA2 should verify the architecture solution in TR 37.813 for inter-RAT load balancing between LTE-HRPD. CT4 should specify the RIM extension to support the feature. / Impacted TSs and TRs: UTRA, LTE
- 996: SP#62 completed / Impacted TSs and TRs: 23.402
- 997: RP#64 completed / Impacted TSs and TRs: 36.300, 36.413
- 998: CP#61 WID approved & Completed / Impacted TSs and TRs: 29.274, 29.276, 29.280
- 999: GP#59 WID approved & Completed / Impacted TSs and TRs: 48.018
- 1000: - / Impacted TSs and TRs: UTRA, LTE
- 1001: ; CD:Thu 18/12/14->Mon 15/12/14; WID: RP-141966->RP-142235; Stat Rep: RP-141600->RP-141787 / Impacted TSs and TRs: 25.133, 25.331, 36.133
- 1002: ; CD:Fri 12/06/15->Mon 15/06/15; WID: RP-141966->RP-142235; Stat Rep: RP-141600->RP-141787 1st Apr 15: Compl:5%->40% 1st Apr 15: Stat Rep: RP-141787->RP-150063 / Impacted TSs and TRs: 25.133, 36.133
- 1003: Triggered by Rel-12 TR 37.834 Study on WLAN/3GPP Radio Interworking (FS_UTRA_LTE_WLAN_interw) / Impacted TSs and TRs: UTRA, LTE
- 1004: SP#65 completed / Impacted TSs and TRs: 25.304, 25.306, 25.331, 36.304, 36.306, 36.331
- 1005: SP#65 completed / Impacted TSs and TRs: 23.402, 23.401, 23.060, 23.251
- 1006: CP#65 revised WID CP-140287=>CP-140623 (added CT4 part) / Impacted TSs and TRs: Stage 2/3
- 1007: CP#65 completion 09/14=>12/14. Exception in CP-140720. 78%->95%. 12/12: 95->78%. 3/3/15: 100% cpltd. / Impacted TSs and TRs: 24.008, 24.301, 24.302, 24.312
- 1008: CP#65 revised WID CP-140287=>CP-140623 (added CT4 part). Exception in CP-140482. Dec.14: 50->100 / Impacted TSs and TRs: 23.008, 29.002, 29.272, 29.274, 29.305
- 1009: Rel13->Rel-12; Moved at appropriate place 1st Apr 15: Compl:0%->5% 1st Apr 15: Stat Rep: ->RP-150098
- 1010: LTE_CA_Rel-12 / Impacted TSs and TRs: LTE
- 1011: Inter-band CA 2DL / Impacted TSs and TRs: LTE
- 1012: RP#65 completed. Updated WID RP-132042=>RP-141487 / Impacted TSs and TRs: 36.101, 36.104, new generic TR 36.851
- 1013: RP#65 completed / Impacted TSs and TRs: 36.141, 36.307

| ID | WBS | Task | Duration | Start | Finish | Complete | Remaining | Baseline start | Baseline finish | Baseline duration | Total slack | Constraint | Resources | Work | Actual work | Acronym | PCG approved | Impacted TSs and TRs | WI rapporteur name | WI rapporteur e-mail | Release | TSG approved | MCC resp | Special Focus Doc | Acronym_3GU_Export | Status Report | PCG stopped | TSG stopped |
| --- | --- | --- | --- | --- | --- | --- | --- | --- | --- | --- | --- | --- | --- | --- | --- | --- | --- | --- | --- | --- | --- | --- | --- | --- | --- | --- | --- | --- |
| 1014 | 262.2 | **LTE Advanced intra-band non-contiguous Carrier Aggregation in Band 25** | 462d? | 2011-09-19 A | 2013-06-14 A | 100% |  | 2011-09-19 | 2013-06-14 | 462d? |  |  | R4 | 11056h | 11056h | LTE_CA_NC_B25 | PCG-27 | LTE | Sprint | George.Cummings@sprint.com | Rel-12 | RP-53 | Issam | CA | LTE_CA_NC_B25 |  |  |  |
| 1015 | 262.2.1 | Core part: LTE Advanced intra-band non-contiguous Carrier Aggregation in Band 25 | 459d? | 2011-09-19 A | 2013-06-14 A | 100% |  | 2011-09-19 | 2013-06-14 | 459d? |  | finish no earlier than 2013-06-14 | R4 | 3672h | 3672h | LTE_CA_NC_B25-Core | PCG-27 | 36.101, 36.104, 36.133, new TR 36.833-2-25 | Sprint | George.Cummings@sprint.com | Rel-12 | RP-53 | Issam | CA | LTE_CA_NC_B25-Core | RP-130563 |  |  |
| 1016 | 262.2.2 | Perf. part: LTE Advanced intra-band non-contiguous Carrier Aggregation in Band 25 | 461d? | 2011-09-19 A | 2013-06-14 A | 100% |  | 2011-09-19 | 2013-06-14 | 461d? |  | finish no earlier than 2013-06-14 | R4 | 3688h | 3688h | LTE_CA_NC_B25-Perf | PCG-27 | 36.141, 36.307 | Sprint | George.Cummings@sprint.com | Rel-12 | RP-53 | Issam | CA | LTE_CA_NC_B25-Perf | RP-130759 |  |  |
| 1017 | 262.3 | **Deleted - LTE Advanced inter-band Carrier Aggregation of Band 3 and Band 5 with 2UL** | 265d? | 2012-03-05 A | 2013-03-01 | 99% | 0d? | 2012-03-05 | 2013-03-01 | 265d? | 0d |  | R4 | 6296h | 6291.94h | LTE_CA_B3_B5_2UL | PCG-28 | LTE | SK Telecom | Seungpyo Hong | Rel-12 | RP-55 | Issam | CA | LTE_CA_B3_B5_2UL |  | PCG-30 | RP-59 |
| 1018 | 262.3.1 | Deleted - Core part: LTE Advanced inter-band Carrier Aggregation of Band 3 and Band 5 with 2UL | 262d? | 2012-03-05 A | 2013-03-01 A | 100% |  | 2012-03-05 | 2013-03-01 | 262d? |  | finish no earlier than 2013-03-01 | R4 | 2096h | 2096h | LTE_CA_B3_B5_2UL-Core | PCG-28 | 36.101, 36.104, 36.133, 36.307, new generic TR 36.851 | SK Telecom | Seungpyo Hong | Rel-12 | RP-55 | Issam | CA | LTE_CA_B3_B5_2UL-Core | RP-130098 | PCG-30 | RP-59 |
| 1019 | 262.3.2 | Deleted - Perf. part: LTE Advanced inter-band Carrier Aggregation of Band 3 and Band 5 with 2UL | 260d? | 2012-03-12 A | 2013-03-01 A | 100% |  | 2012-03-12 | 2013-03-01 | 260d? |  | finish no earlier than 2013-03-01 | R4 | 2080h | 2080h | LTE_CA_B3_B5_2UL-Perf | PCG-28 | 36.133, 36.141 | SK Telecom | Seungpyo Hong | Rel-12 | RP-55 | Issam | CA | LTE_CA_B3_B5_2UL-Perf | RP-130099 | PCG-30 | RP-59 |
| 1020 | 262.4 | UE Conformance Test Aspects - Further Rel-12 configurations for LTE Advanced Carrier Aggregation with 2UL | 197d? | 2015-03-16 | 2015-12-15 |  |  |  |  |  | 392d | start no earlier than 2015-03-16 | R5 | 1576h |  | LTE_CA_Rel12_2UL-UEConTest | PCG-34 |  | Ericsson | NA | Rel-12 | RP-67 |  |  |  |  |  |  |
| 1021 | 262.5 | **LTE Advanced intra-band non-contiguous Carrier Aggregation in Band 3** | 469d? | 2012-03-05 A | 2013-12-06 A | 100% |  | 2012-03-05 | 2013-12-06 | 469d? |  |  | R4 | 11136h | 11136h | LTE_CA_NC_B3 | PCG-28 | LTE | SK Telecom | haesung.park@sk.com | Rel-12 | RP-55 | Issam | CA | LTE_CA_NC_B3 |  |  |  |
| 1022 | 262.5.1 | Core part: LTE Advanced intra-band non-contiguous Carrier Aggregation in Band 3 | 462d? | 2012-03-05 A | 2013-12-06 A | 100% |  | 2012-03-05 | 2013-12-06 | 462d? |  | finish no earlier than 2013-12-06 | R4 | 3696h | 3696h | LTE_CA_NC_B3-Core | PCG-28 | 36.101, 36.104, 36.133, new TR 36.833-2-03 | SK Telecom | haesung.park@sk.com | Rel-12 | RP-55 | Issam | CA | LTE_CA_NC_B3-Core | RP-131573 |  |  |
| 1023 | 262.5.2 | Perf. part: LTE Advanced intra-band non-contiguous Carrier Aggregation in Band 3 | 461d? | 2012-03-15 A | 2013-12-06 A | 100% |  | 2012-03-15 | 2013-12-06 | 461d? |  | finish no earlier than 2013-12-06 | R4 | 3688h | 3688h | LTE_CA_NC_B3-Perf | PCG-28 | 36.101, 36.104, 36.133, 36.141, 36.307 | SK Telecom | haesung.park@sk.com | Rel-12 | RP-55 | Issam | CA | LTE_CA_NC_B3-Perf | RP-131574 |  |  |
| 1024 | 262.6 | **Deleted - LTE Advanced intra-band contiguous Carrier Aggregation in Band 1** | 265d? | 2012-06-18 A | 2013-06-14 A | 100% |  | 2012-06-18 | 2013-06-14 | 265d? |  |  | R4 | 6328h | 6328h | LTE_CA_C_B1 | PCG-29 | LTE | KDDI | Masaaki Obara (ms-obara@kddi.com) | Rel-12 | RP-56 | Issam | CA | LTE_CA_C_B1 |  | PCG-31 | RP-60 |
| 1025 | 262.6.1 | Deleted - Core part: LTE Advanced intra-band contiguous Carrier Aggregation in Band 1 | 265d? | 2012-06-18 A | 2013-06-14 A | 100% |  | 2012-06-18 | 2013-06-14 | 265d? |  | finish no earlier than 2013-06-14 | R4 | 2120h | 2120h | LTE_CA_C_B1-Core | PCG-29 | 36.101, 36.104, 36.133, 36.141, 36.307, new TR 36.835 | KDDI | Masaaki Obara (ms-obara@kddi.com) | Rel-12 | RP-56 | Issam | CA | LTE_CA_C_B1-Core | RP-130549 | PCG-31 | RP-60 |
| 1026 | 262.6.2 | Deleted - Perf. part: LTE Advanced intra-band contiguous Carrier Aggregation in Band 1 | 261d? | 2012-06-22 A | 2013-06-14 A | 100% |  | 2012-06-22 | 2013-06-14 | 261d? |  | finish no earlier than 2013-06-14 | R4 | 2088h | 2088h | LTE_CA_C_B1-Perf | PCG-29 | 36.101, 36.104, 36.133, 36.141, 36.307 | KDDI | Masaaki Obara (ms-obara@kddi.com) | Rel-12 | RP-56 | Issam | CA | LTE_CA_C_B1-Perf | RP-130550 | PCG-31 | RP-60 |
| 1027 | 262.7 | **LTE Advanced intra-band non-contiguous Carrier Aggregation in Band 4** | 327d? | 2012-06-18 A | 2013-09-06 A | 100% |  | 2012-06-18 | 2013-09-06 | 327d? |  |  | R4 | 7752h | 7752h | LTE_CA_NC_B4 | PCG-29 | LTE | T-Mobile USA | nelson.ueng@t-mobile.com | Rel-12 | RP-56 | Issam | CA | LTE_CA_NC_B4 |  |  |  |
| 1028 | 262.7.1 | Core part: LTE Advanced intra-band non-contiguous Carrier Aggregation in Band 4 | 323d? | 2012-06-18 A | 2013-09-06 A | 100% |  | 2012-06-18 | 2013-09-06 | 323d? |  | finish no earlier than 2013-09-06 | R4 | 2568h | 2568h | LTE_CA_NC_B4-Core | PCG-29 | 36.101, 36.104, 36.133, new TR 36.833-2-04 | T-Mobile USA | nelson.ueng@t-mobile.com | Rel-12 | RP-56 | Issam | CA | LTE_CA_NC_B4-Core | RP-131039 |  |  |
| 1029 | 262.7.2 | Perf. part: LTE Advanced intra-band non-contiguous Carrier Aggregation in Band 4 | 323d? | 2012-06-22 A | 2013-09-06 A | 100% |  | 2012-06-22 | 2013-09-06 | 323d? |  | finish no earlier than 2013-09-06 | R4 | 2568h | 2568h | LTE_CA_NC_B4-Perf | PCG-29 | 36.101, 36.104, 36.133, 36.141, 36.307 | T-Mobile USA | nelson.ueng@t-mobile.com | Rel-12 | RP-56 | Issam | CA | LTE_CA_NC_B4-Perf | RP-131040 |  |  |
| 1030 | 262.8 | **LTE Advanced inter-band Carrier Aggregation of Band 2 and Band 4** | 327d? | 2012-06-18 A | 2013-09-06 A | 100% |  | 2012-06-18 | 2013-09-06 | 327d? |  |  | R4 | 7752h | 7752h | LTE_CA_B2_B4 | PCG-29 | LTE | T-Mobile USA | nelson.ueng@t-mobile.com | Rel-12 | RP-56 | Issam | CA | LTE_CA_B2_B4 |  |  |  |
| 1031 | 262.8.1 | Core part: LTE Advanced inter-band Carrier Aggregation of Band 2 and Band 4 | 321d? | 2012-06-18 A | 2013-09-06 A | 100% |  | 2012-06-18 | 2013-09-06 | 321d? |  | finish no earlier than 2013-09-06 | R4 | 2568h | 2568h | LTE_CA_B2_B4-Core | PCG-29 | 36.101, 36.104, 36.133, new generic TR 36.851 | T-Mobile USA | nelson.ueng@t-mobile.com | Rel-12 | RP-56 | Issam | CA | LTE_CA_B2_B4-Core | RP-131007 |  |  |
| 1032 | 262.8.2 | Perf. part: LTE Advanced inter-band Carrier Aggregation of Band 2 and Band 4 | 321d? | 2012-06-22 A | 2013-09-06 A | 100% |  | 2012-06-22 | 2013-09-06 | 321d? |  | finish no earlier than 2013-09-06 | R4 | 2568h | 2568h | LTE_CA_B2_B4-Perf | PCG-29 | 36.101, 36.104, 36.133, 36.141, 36.307 | T-Mobile USA | nelson.ueng@t-mobile.com | Rel-12 | RP-56 | Issam | CA | LTE_CA_B2_B4-Perf | RP-131376 |  |  |
| 1033 | 262.9 | **LTE Advanced inter-band Carrier Aggregation of Band 23 and Band 29** | 202d? | 2012-09-12 A | 2013-06-14 A | 100% |  | 2012-09-12 | 2013-06-14 | 202d? |  |  | R4 | 4832h | 4832h | LTE_CA_B23_B29 | PCG-29 | LTE | DISH Network | mariam.sorond@dish.com, johny.kim@dish.com | Rel-12 | RP-57 | Issam | CA | LTE_CA_B23_B29 |  |  |  |
| 1034 | 262.9.1 | Core part: LTE Advanced inter-band Carrier Aggregation of Band 23 and Band 29 | 201d? | 2012-09-12 A | 2013-06-14 A | 100% |  | 2012-09-12 | 2013-06-14 | 201d? |  | finish no earlier than 2013-06-14 | R4 | 1608h | 1608h | LTE_CA_B23_B29-Core | PCG-29 | 36.101, 36.104, 36.133, new generic TR 36.851 | DISH Network | mariam.sorond@dish.com, johny.kim@dish.com | Rel-12 | RP-57 | Issam | CA | LTE_CA_B23_B29-Core | RP-130535 |  |  |
| 1035 | 262.9.2 | Perf. part: LTE Advanced inter-band Carrier Aggregation of Band 23 and Band 29 | 201d? | 2012-09-12 A | 2013-06-14 A | 100% |  | 2012-09-12 | 2013-06-14 | 201d? |  | finish no earlier than 2013-06-14 | R4 | 1608h | 1608h | LTE_CA_B23_B29-Perf | PCG-29 | 36.141, 36.307 | DISH Network | mariam.sorond@dish.com, johny.kim@dish.com | Rel-12 | RP-57 | Issam | CA | LTE_CA_B23_B29-Perf | RP-130536 |  |  |
| 1036 | 262.10 | **LTE Advanced inter-band Carrier Aggregation of Band 3 and Band 26** | 203d? | 2012-09-11 A | 2013-06-14 A | 100% |  | 2012-09-11 | 2013-06-14 | 203d? |  |  | R4 | 4840h | 4840h | LTE_CA_B3_B26 | PCG-29 | LTE | KT | Chungwoo HWANG (cwhwang@kt.com) | Rel-12 | RP-57 | Issam | CA | LTE_CA_B3_B26 |  |  |  |
| 1037 | 262.10.1 | Core part: LTE Advanced inter-band Carrier Aggregation of Band 3 and Band 26 | 202d? | 2012-09-11 A | 2013-06-14 A | 100% |  | 2012-09-11 | 2013-06-14 | 202d? |  | finish no earlier than 2013-06-14 | R4 | 1608h | 1608h | LTE_CA_B3_B26-Core | PCG-29 | 36.101, 36.104, 36.133, 36.307, new generic TR 36.851 | KT | Chungwoo HWANG (cwhwang@kt.com) | Rel-12 | RP-57 | Issam | CA | LTE_CA_B3_B26-Core | RP-130527 |  |  |
| 1038 | 262.10.2 | Perf. part: LTE Advanced inter-band Carrier Aggregation of Band 3 and Band 26 | 202d? | 2012-09-11 A | 2013-06-14 A | 100% |  | 2012-09-11 | 2013-06-14 | 202d? |  | finish no earlier than 2013-06-14 | R4 | 1608h | 1608h | LTE_CA_B3_B26-Perf | PCG-29 | 36.101, 36.104, 36.133, 36.141, 36.307 | KT | Chungwoo HWANG (cwhwang@kt.com) | Rel-12 | RP-57 | Issam | CA | LTE_CA_B3_B26-Perf | RP-130528 |  |  |

Notes:
- 1014: Intra-band NC
- 1015: RP#60 completed. TR 36.841 for 1-step Approval
- 1016: RP#60 completed
- 1017: Inter-band 2UL
- 1018: RP#59 stopped (covered by new WI LTE_CA_2UL-A4)
- 1019: RP#59 stopped (covered by new WI LTE_CA_2UL-A4)
- 1021: Intra-band NC
- 1022: RP#62 completed
- 1023: RP#62 completed
- 1024: Intra-band C
- 1025: RP#60 stopped at 10% completion (rationale in RP-130670)
- 1026: RP#60 stopped at 0% completion
- 1027: Intra-band NC
- 1028: RP#61 completed. Updated WID RP-130842=>RP-131135
- 1029: RP#61 completed. Updated WID RP-130842=>RP-131135
- 1030: Inter-band 1 UL
- 1031: RP#61 completed
- 1032: RP#61 completed
- 1033: Inter-band 1 UL
- 1034: RP#60 completed
- 1035: RP#60 completed
- 1036: Inter-band 1 UL
- 1037: RP#60 completed. Updated WID RP-130199=>RP-130658
- 1038: RP#60 completed. Updated WID RP-130199=>RP-130658

| ID | WBS | Task | Duration | Start | Finish | Complete | Baseline start | Baseline finish | Baseline duration | Constraint | Resources | Work | Actual work | Acronym | PCG approved | WI rapporteur name | WI rapporteur e-mail | Release | TSG approved | MCC resp | Special Focus Doc | Acronym_3GU_Export | Status Report | PCG stopped | TSG stopped |
| --- | --- | --- | --- | --- | --- | --- | --- | --- | --- | --- | --- | --- | --- | --- | --- | --- | --- | --- | --- | --- | --- | --- | --- | --- | --- |
| 1039 | 262.11 | **LTE Advanced inter-band Carrier Aggregation of Band 3 and Band 19** | 203d? | 2012-09-11 A | 2013-06-14 A | 100% | 2012-09-11 | 2013-06-14 | 203d? |  | R4 | 4840h | 4840h | LTE_CA_B3_B19 | PCG-29 | NTT DOCOMO | Kei ANDO | Rel-12 | RP-57 | Issam | CA | LTE_CA_B3_B19 |  |  |  |
| 1040 | 262.11.1 | Core part: LTE Advanced inter-band Carrier Aggregation of Band 3 and Band 19 | 201d? | 2012-09-11 A | 2013-06-14 A | 100% | 2012-09-11 | 2013-06-14 | 201d? | finish no earlier than 2013-06-14 | R4 | 1608h | 1608h | LTE_CA_B3_B19-Core | PCG-29 | NTT DOCOMO | Kei ANDO | Rel-12 | RP-57 | Issam | CA | LTE_CA_B3_B19-Core | RP-130525 |  |  |
| 1041 | 262.11.2 | Perf. part: LTE Advanced inter-band Carrier Aggregation of Band 3 and Band 19 | 201d? | 2012-09-13 A | 2013-06-14 A | 100% | 2012-09-13 | 2013-06-14 | 201d? | finish no earlier than 2013-06-14 | R4 | 1608h | 1608h | LTE_CA_B3_B19-Perf | PCG-29 | NTT DOCOMO | Kei ANDO | Rel-12 | RP-57 | Issam | CA | LTE_CA_B3_B19-Perf | RP-130526 |  |  |
| 1042 | 262.12 | **Deleted - LTE Advanced inter-band Carrier Aggregation of Band 38 and Band 39** | 66d? | 2012-09-11 A | 2012-12-07 A | 100% | 2012-09-11 | 2012-12-07 | 66d? |  | R4 | 1584h | 1584h | LTE_CA_B38_B39 | PCG-29 | China Mobile | Pan Qun (panqun@chinamobile.com) | Rel-12 | RP-57 | Issam | CA | LTE_CA_B38_B39 |  | PCG-30 | RP-58 |
| 1043 | 262.12.1 | Deleted - Core part: LTE Advanced inter-band Carrier Aggregation of Band 38 and Band 39 | 66d? | 2012-09-11 A | 2012-12-07 A | 100% | 2012-09-11 | 2012-12-07 | 66d? | finish no earlier than 2012-12-07 | R4 | 528h | 528h | LTE_CA_B38_B39-Core | PCG-29 | China Mobile | Pan Qun (panqun@chinamobile.com) | Rel-12 | RP-57 | Issam | CA | LTE_CA_B38_B39-Core | RP-121624 | PCG-30 | RP-58 |
| 1044 | 262.12.2 | Deleted - Perf. part: LTE Advanced inter-band Carrier Aggregation of Band 38 and Band 39 | 66d? | 2012-09-11 A | 2012-12-07 A | 100% | 2012-09-11 | 2012-12-07 | 66d? | finish no earlier than 2012-12-07 | R4 | 528h | 528h | LTE_CA_B38_B39-Perf | PCG-29 | China Mobile | Pan Qun (panqun@chinamobile.com) | Rel-12 | RP-57 | Issam | CA | LTE_CA_B38_B39-Perf | RP-121625 | PCG-30 | RP-58 |
| 1045 | 262.13 | **LTE Advanced intra-band contiguous Carrier Aggregation in Band 3** | 265d? | 2012-09-11 A | 2013-09-06 A | 100% | 2012-09-11 | 2013-09-06 | 265d? |  | R4 | 6312h | 6312h | LTE_CA_C_B3 | PCG-29 | China Unicom | Fei CUI (cuifei1@chinaunicom.cn) | Rel-12 | RP-57 | Issam | CA | LTE_CA_C_B3 |  |  |  |
| 1046 | 262.13.1 | Core part: LTE Advanced intra-band contiguous Carrier Aggregation in Band 3 | 263d? | 2012-09-11 A | 2013-09-06 A | 100% | 2012-09-11 | 2013-09-06 | 263d? | finish no earlier than 2013-09-06 | R4 | 2096h | 2096h | LTE_CA_C_B3-Core | PCG-29 | China Unicom | Fei CUI (cuifei1@chinaunicom.cn) | Rel-12 | RP-57 | Issam | CA | LTE_CA_C_B3-Core | RP-131029 |  |  |
| 1047 | 262.13.2 | Perf. part: LTE Advanced intra-band contiguous Carrier Aggregation in Band 3 | 263d? | 2012-09-11 A | 2013-09-06 A | 100% | 2012-09-11 | 2013-09-06 | 263d? | finish no earlier than 2013-09-06 | R4 | 2096h | 2096h | LTE_CA_C_B3-Perf | PCG-29 | China Unicom | Fei CUI (cuifei1@chinaunicom.cn) | Rel-12 | RP-57 | Issam | CA | LTE_CA_C_B3-Perf | RP-131030 |  |  |
| 1048 | 262.14 | **LTE Advanced inter-band Carrier Aggregation of Band 1 and Band 8** | 362.8d? | 2012-02-02 A | 2013-06-14 A | 100% | 2012-02-02 | 2013-06-14 | 362.8d? |  | R4 | 6118.4h | 6118.4h | LTE_CA_B1_B8 | PCG-29 | Softbank Mobile | Kenichi Kihara | Rel-12 | RP-57 | Issam | CA | LTE_CA_B1_B8 |  |  |  |
| 1049 | 262.14.1 | Core part: LTE Advanced inter-band Carrier Aggregation of Band 1 and Band 8 | 201d? | 2012-02-02 A | 2013-06-14 A | 100% | 2012-02-02 | 2013-06-14 | 201d? | finish no earlier than 2013-06-14 | R4 | 1608h | 1608h | LTE_CA_B1_B8-Core | PCG-29 | Softbank Mobile | Kenichi Kihara | Rel-12 | RP-57 | Issam | CA | LTE_CA_B1_B8-Core | RP-130515 |  |  |
| 1050 | 262.14.2 | Perf. part: LTE Advanced inter-band Carrier Aggregation of Band 1 and Band 8 | 202d? | 2012-09-11 A | 2013-06-14 A | 100% | 2012-09-11 | 2013-06-14 | 202d? | finish no earlier than 2013-06-14 | R4 | 1608h | 1608h | LTE_CA_B1_B8-Perf | PCG-29 | Softbank Mobile | Kenichi Kihara | Rel-12 | RP-57 | Issam | CA | LTE_CA_B1_B8-Perf | RP-130516 |  |  |
| 1051 | 262.15 | **LTE Advanced inter-band Carrier Aggregation of Band 3 and Band 28** | 203d? | 2012-09-11 A | 2013-06-14 A | 100% | 2012-09-11 | 2013-06-14 | 203d? |  | R4 | 4840h | 4840h | LTE_CA_B3_B28 | PCG-29 | eAccess | FukumotoShiro@eaccess.net | Rel-12 | RP-57 | Issam | CA | LTE_CA_B3_B28 |  |  |  |
| 1052 | 262.15.1 | Core part: LTE Advanced inter-band Carrier Aggregation of Band 3 and Band 28 | 202d? | 2012-09-11 A | 2013-06-14 A | 100% | 2012-09-11 | 2013-06-14 | 202d? | finish no earlier than 2013-06-14 | R4 | 1608h | 1608h | LTE_CA_B3_B28-Core | PCG-29 | eAccess | FukumotoShiro@eaccess.net | Rel-12 | RP-57 | Issam | CA | LTE_CA_B3_B28-Core | RP-130529 |  |  |
| 1053 | 262.15.2 | Perf. part: LTE Advanced inter-band Carrier Aggregation of Band 3 and Band 28 | 201d? | 2012-09-12 A | 2013-06-14 A | 100% | 2012-09-12 | 2013-06-14 | 201d? | finish no earlier than 2013-06-14 | R4 | 1608h | 1608h | LTE_CA_B3_B28-Perf | PCG-29 | eAccess | FukumotoShiro@eaccess.net | Rel-12 | RP-57 | Issam | CA | LTE_CA_B3_B28-Perf | RP-130530 |  |  |
| 1054 | 262.16 | **LTE Advanced inter-band Carrier Aggregation of Band 1 and Band 26** | 200d? | 2012-12-07 A | 2013-09-06 A | 100% | 2012-12-07 | 2013-09-06 | 200d? |  | R4 | 4768h | 4768h | LTE_CA_B1_B26 | PCG-30 | KDDI | Masaaki Obara (ms-obara@kddi.com) | Rel-12 | RP-58 | Issam | CA | LTE_CA_B1_B26 |  |  |  |
| 1055 | 262.16.1 | Core part: LTE Advanced inter-band Carrier Aggregation of Band 1 and Band 26 | 200d? | 2012-12-07 A | 2013-09-06 A | 100% | 2012-12-07 | 2013-09-06 | 200d? | finish no earlier than 2013-09-06 | R4 | 1576h | 1576h | LTE_CA_B1_B26-Core | PCG-30 | KDDI | Masaaki Obara (ms-obara@kddi.com) | Rel-12 | RP-58 | Issam | CA | LTE_CA_B1_B26-Core | RP-131005 |  |  |
| 1056 | 262.16.2 | Perf. part: LTE Advanced inter-band Carrier Aggregation of Band 1 and Band 26 | 200d? | 2012-12-07 A | 2013-09-06 A | 100% | 2012-12-07 | 2013-09-06 | 200d? | finish no earlier than 2013-09-06 | R4 | 1600h | 1600h | LTE_CA_B1_B26-Perf | PCG-30 | KDDI | Masaaki Obara (ms-obara@kddi.com) | Rel-12 | RP-58 | Issam | CA | LTE_CA_B1_B26-Perf | RP-131006 |  |  |
| 1057 | 262.17 | **LTE Advanced inter-band Carrier Aggregation of Band 39 and Band 41** | 330d? | 2012-12-10 A | 2014-03-06 A | 100% | 2012-12-10 | 2014-03-06 | 330d? |  | R4 | 7848h | 7848h | LTE_CA_B39_B41 | PCG-30 | China Mobile | Pan Qun (panqun@chinamobile.com) | Rel-12 | RP-58 | Issam | CA | LTE_CA_B39_B41 | RP-140428 |  |  |
| 1058 | 262.17.1 | Core part: LTE Advanced inter-band Carrier Aggregation of Band 39 and Band 41 | 326d? | 2012-12-10 A | 2014-03-06 A | 100% | 2012-12-10 | 2014-03-06 | 326d? | finish no earlier than 2014-03-06 | R4 | 2608h | 2608h | LTE_CA_B39_B41-Core | PCG-30 | China Mobile | Pan Qun (panqun@chinamobile.com) | Rel-12 | RP-58 | Issam | CA | LTE_CA_B39_B41-Core | RP-140428 |  |  |
| 1059 | 262.17.2 | Perf. part: LTE Advanced inter-band Carrier Aggregation of Band 39 and Band 41 | 325d? | 2012-12-14 A | 2014-03-06 A | 100% | 2012-12-14 | 2014-03-06 | 325d? | finish no earlier than 2014-03-06 | R4 | 2600h | 2600h | LTE_CA_B39_B41-Perf | PCG-30 | China Mobile | Pan Qun (panqun@chinamobile.com) | Rel-12 | RP-58 | Issam | CA | LTE_CA_B39_B41-Perf | RP-140428 |  |  |
| 1060 | 262.18 | **LTE Advanced inter-band Carrier Aggregation of Band 2 and Band 12** | 467d? | 2012-12-10 A | 2014-09-12 A | 100% | 2012-12-10 | 2014-09-12 | 466d? |  | R4 | 10040h | 10040h | LTE_CA_B2_B12 | PCG-30 | US Cellular | sebastian.thalanany@uscellular.com | Rel-12 | RP-58 | Issam | CA | LTE_CA_B2_B12 |  |  |  |
| 1061 | 262.18.1 | Core part: LTE Advanced inter-band Carrier Aggregation of Band 2 and Band 12 | 464d? | 2012-12-10 A | 2014-09-12 A | 100% | 2012-12-10 | 2014-09-12 | 464d? | finish no earlier than 2014-09-12 | R4 | 3704h | 3704h | LTE_CA_B2_B12-Core | PCG-30 | US Cellular | sebastian.thalanany@uscellular.com | Rel-12 | RP-58 | Issam | CA | LTE_CA_B2_B12-Core | RP-141084 |  |  |
| 1062 | 262.18.2 | Perf. part: LTE Advanced inter-band Carrier Aggregation of Band 2 and Band 12 | 325d? | 2012-12-14 A | 2014-03-06 A | 100% | 2012-12-14 | 2014-03-06 | 325d? | finish no earlier than 2014-06-13 | R4 | 2600h | 2600h | LTE_CA_B2_B12-Perf | PCG-30 | US Cellular | sebastian.thalanany@uscellular.com | Rel-12 | RP-58 | Issam | CA | LTE_CA_B2_B12-Perf | RP-140428 |  |  |

Notes:
- 1039: Inter-band 1 UL / Impacted TSs and TRs: LTE
- 1040: RP#60 completed / Impacted TSs and TRs: 36.101, 36.104, 36.133, new generic TR 36.851
- 1041: RP#60 completed / Impacted TSs and TRs: 36.141, 36.307
- 1042: Inter-band 1 UL / Impacted TSs and TRs: LTE
- 1043: RP#58 stopped at 10% completion following regulatory decisions (see instead new WI LTE_CA_B39_B41) / Impacted TSs and TRs: 36.101, 36.104, 36.307, new generic TR 36.851
- 1044: RP#58 stopped at 0% completion following regulatory decisions (see instead new WI LTE_CA_B39_B41) / Impacted TSs and TRs: 36.133, 36.141
- 1045: Intra-band NC / Impacted TSs and TRs: LTE
- 1046: RP#61 completed. Updated WID RP-130294=>RP-131184 (impacted specs) / Impacted TSs and TRs: 36.101, 36.104, 36.133, new TR 36.833-1-03
- 1047: RP#61 completed / Impacted TSs and TRs: 36.141, 36.307
- 1048: Inter-band 1 UL / Impacted TSs and TRs: LTE
- 1049: RP#60 completed / Impacted TSs and TRs: 36.101, 36.104, new generic TR 36.851
- 1050: RP#60 completed / Impacted TSs and TRs: 36.141, 36.307
- 1051: Inter-band 1 UL / Impacted TSs and TRs: LTE
- 1052: RP#60 completed / Impacted TSs and TRs: 36.101, 36.104, new generic TR 36.851
- 1053: RP#60 completed / Impacted TSs and TRs: 36.141, 36.307
- 1054: Inter-band 1UL/2DL / Impacted TSs and TRs: LTE
- 1055: RP#61 completed / Impacted TSs and TRs: 36.101, 36.104, 36.133, new generic TR 36.851
- 1056: RP#61 completed / Impacted TSs and TRs: 36.141, 36.307
- 1057: Inter-band 2DL / Impacted TSs and TRs: LTE
- 1058: RP#63 completed. Replaces the Stopped WI - LTE Advanced inter-band Carrier Aggregation of Band 38 and Band 39 (LTE_CA_B38_B39) UID_570015 / Impacted TSs and TRs: 36.101, 36.104, 36.307, new generic TR 36.851
- 1059: RP#63 completed / Impacted TSs and TRs: 36.133, 36.141
- 1060: Inter-band CA 2DL / Impacted TSs and TRs: LTE
- 1061: RP#65 completed / Impacted TSs and TRs: 36.101, 36.104, 36.133, 36.141, 36.307, new generic TR 36.851
- 1062: RP#63 completed / Impacted TSs and TRs: 36.101, 36.104, 36.133, 36.141, 36.307

| ID | WBS | Task | Duration | Start | Finish | Complete | Baseline start | Baseline finish | Baseline duration | Constraint | Resources | Work | Actual work | Acronym | PCG approved | Impacted TSs and TRs | WI rapporteur name | WI rapporteur e-mail | Release | TSG approved | MCC resp | Special Focus Doc | Acronym_3GU_Export | Status Report | PCG stopped | TSG stopped |
| --- | --- | --- | --- | --- | --- | --- | --- | --- | --- | --- | --- | --- | --- | --- | --- | --- | --- | --- | --- | --- | --- | --- | --- | --- | --- | --- |
| 1063 | 262.19 | **LTE Advanced intra-band non-contiguous Carrier Aggregation in Band 7** | 265d? | 2012-12-10 A | 2013-12-06 A | 100% | 2012-12-10 | 2013-12-06 | 265d? |  | R4 | 6296h | 6296h | LTE_CA_NC_B7 | PCG-30 | LTE | Ericsson | christian.bergljung@ericsson.com | Rel-12 | RP-58 | Issam | CA | LTE_CA_NC_B7 |  |  |  |
| 1064 | 262.19.1 | Core part: LTE Advanced intra-band non-contiguous Carrier Aggregation in Band 7 | 261d? | 2012-12-10 A | 2013-12-06 A | 100% | 2012-12-10 | 2013-12-06 | 261d? | finish no earlier than 2013-12-06 | R4 | 2088h | 2088h | LTE_CA_NC_B7-Core | PCG-30 | 36.101, 36.104, 36.133, new TR 36.833-2-07 | Ericsson | christian.bergljung@ericsson.com | Rel-12 | RP-58 | Issam | CA | LTE_CA_NC_B7-Core | RP-131575 |  |  |
| 1065 | 262.19.2 | Perf. part: LTE Advanced intra-band non-contiguous Carrier Aggregation in Band 7 | 261d? | 2012-12-14 A | 2013-12-06 A | 100% | 2012-12-14 | 2013-12-06 | 261d? | finish no earlier than 2013-12-06 | R4 | 2088h | 2088h | LTE_CA_NC_B7-Perf | PCG-30 | 36.141, 36.307 | Ericsson | christian.bergljung@ericsson.com | Rel-12 | RP-58 | Issam | CA | LTE_CA_NC_B7-Perf | RP-131576 |  |  |
| 1066 | 262.20 | **LTE Advanced intra-band contiguous Carrier Aggregation in Band 27** | 401d? | 2012-12-10 A | 2014-06-13 A | 100% | 2012-12-10 | 2014-06-13 | 401d? |  | R4 | 8472h | 8472h | LTE_CA_C_B27 | PCG-30 | LTE | NII Holdings | bill.shvodian@nii.com | Rel-12 | RP-58 | Issam | CA | LTE_CA_C_B27 |  |  |  |
| 1067 | 262.20.1 | Core part: LTE Advanced intra-band contiguous Carrier Aggregation in Band 27 | 261d? | 2012-12-10 A | 2013-12-06 A | 100% | 2012-12-10 | 2013-12-06 | 261d? | finish no earlier than 2013-12-06 | R4 | 2088h | 2088h | LTE_CA_C_B27-Core | PCG-30 | 36.101, 36.104, new TR 36.833-1-27 | NII Holdings | bill.shvodian@nii.com | Rel-12 | RP-58 | Issam | CA | LTE_CA_C_B27-Core | RP-131567 |  |  |
| 1068 | 262.20.2 | Perf part: LTE Advanced intra-band contiguous Carrier Aggregation in Band 27 | 397d? | 2012-12-14 A | 2014-06-13 A | 100% | 2012-12-14 | 2014-06-13 | 397d? | finish no earlier than 2014-06-13 | R4 | 3176h | 3176h | LTE_CA_C_B27-Perf | PCG-30 | 36.101, 36.133, 36.141, 36.307, new TR 36.833-1-27 | NII Holdings | bill.shvodian@nii.com | Rel-12 | RP-58 | Issam | CA | LTE_CA_C_B27-Perf | RP-140569 |  |  |
| 1069 | 262.21 | **LTE Advanced inter-band Carrier Aggregation of Band 2 and Band 13** | 76d? | 2013-03-04 A | 2013-06-14 A | 100% | 2013-03-04 | 2013-06-14 | 76d? |  | R4 | 1824h | 1824h | LTE_CA_B2_B13 | PCG-30 | LTE | Ericsson | christian.bergljung@ericsson.com | Rel-12 | RP-59 | Issam | CA | LTE_CA_B2_B13 |  |  |  |
| 1070 | 262.21.1 | Core part: LTE Advanced inter-band Carrier Aggregation of Band 2 and Band 13 | 76d? | 2013-03-04 A | 2013-06-14 A | 100% | 2013-03-04 | 2013-06-14 | 76d? | finish no earlier than 2013-06-14 | R4 | 608h | 608h | LTE_CA_B2_B13-Core | PCG-30 | 36.101, 36.104, 36.133, new generic TR 36.851 | Ericsson | christian.bergljung@ericsson.com | Rel-12 | RP-59 | Issam | CA | LTE_CA_B2_B13-Core | RP-130523 |  |  |
| 1071 | 262.21.2 | Perf. part: LTE Advanced inter-band Carrier Aggregation of Band 2 and Band 13 | 76d? | 2013-03-04 A | 2013-06-14 A | 100% | 2013-03-04 | 2013-06-14 | 76d? | finish no earlier than 2013-06-14 | R4 | 608h | 608h | LTE_CA_B2_B13-Perf | PCG-30 | 36.101, 36.104, 36.133, 36.141, 36.307 | Ericsson | christian.bergljung@ericsson.com | Rel-12 | RP-59 | Issam | CA | LTE_CA_B2_B13-Perf | RP-130524 |  |  |
| 1072 | 262.22 | **LTE Advanced inter-band Carrier Aggregation of Band 19 and Band 21** | 76d? | 2013-03-04 A | 2013-06-14 A | 100% | 2013-03-04 | 2013-06-14 | 76d? |  | R4 | 1824h | 1824h | LTE_CA_B19_B21 | PCG-30 | LTE | NTT DOCOMO | Kei ANDO | Rel-12 | RP-59 | Issam | CA | LTE_CA_B19_B21 |  |  |  |
| 1073 | 262.22.1 | Core part: LTE Advanced inter-band Carrier Aggregation of Band 19 and Band 21 | 76d? | 2013-03-04 A | 2013-06-14 A | 100% | 2013-03-04 | 2013-06-14 | 76d? | finish no earlier than 2013-06-14 | R4 | 608h | 608h | LTE_CA_B19_B21-Core | PCG-30 | 36.101, 36.104, 36.133, new generic TR 36.851 | NTT DOCOMO | Kei ANDO | Rel-12 | RP-59 | Issam | CA | LTE_CA_B19_B21-Core | RP-130533 |  |  |
| 1074 | 262.22.2 | Perf. part: LTE Advanced inter-band Carrier Aggregation of Band 19 and Band 21 | 76d? | 2013-03-04 A | 2013-06-14 A | 100% | 2013-03-04 | 2013-06-14 | 76d? | finish no earlier than 2013-06-14 | R4 | 608h | 608h | LTE_CA_B19_B21-Perf | PCG-30 | 36.141, 36.307 | NTT DOCOMO | Kei ANDO | Rel-12 | RP-59 | Issam | CA | LTE_CA_B19_B21-Perf | RP-130534 |  |  |
| 1075 | 262.23 | **Deleted - LTE Advanced inter-band Carrier Aggregation of Band 8 and Band 26** | 204d? | 2013-03-04 A | 2013-12-06 A | 100% | 2013-03-04 | 2013-12-06 | 204d? |  | R4 | 4848h | 4848h | LTE_CA_B8_B26 | PCG-30 | LTE | KT | Chungwoo HWANG (cwhwang@kt.com) | Rel-12 | RP-59 | Issam | CA | LTE_CA_B8_B26 |  | PCG-32 | RP-62 |
| 1076 | 262.23.1 | Deleted - Core part: LTE Advanced inter-band Carrier Aggregation of Band 8 and Band 26 | 201d? | 2013-03-04 A | 2013-12-06 A | 100% | 2013-03-04 | 2013-12-06 | 201d? | finish no earlier than 2013-12-06 | R4 | 1608h | 1608h | LTE_CA_B8_B26-Core | PCG-30 | 36.101, 36.104, 36.133, new generic TR 36.851 | KT | Chungwoo HWANG (cwhwang@kt.com) | Rel-12 | RP-59 | Issam | CA | LTE_CA_B8_B26-Core | RP-131549 | PCG-32 | RP-62 |
| 1077 | 262.23.2 | Deleted - Perf. part: LTE Advanced inter-band Carrier Aggregation of Band 8 and Band 26 | 201d? | 2013-03-04 A | 2013-12-06 A | 100% | 2013-03-04 | 2013-12-06 | 201d? | finish no earlier than 2013-12-06 | R4 | 1608h | 1608h | LTE_CA_B8_B26-Perf | PCG-30 | 36.141, 36.307 | KT | Chungwoo HWANG (cwhwang@kt.com) | Rel-12 | RP-59 | Issam | CA | LTE_CA_B8_B26-Perf | RP-131550 | PCG-32 | RP-62 |
| 1078 | 262.24 | **LTE Advanced dual uplink inter-band Carrier Aggregation Class A1** | 474d? | 2013-03-04 A | 2014-12-15 A | 100% | 2013-03-04 | 2014-09-12 | 405d? |  | R4 | 11272h | 11272h | LTE_CA_2UL-A1 | PCG-30 | LTE | Huawei | Liu Ye (leo.liuye@huawei.com) | Rel-12 | RP-59 | Issam | CA | LTE_CA_2UL-A1 |  |  |  |
| 1079 | 262.24.1 | Core part: LTE Advanced dual uplink inter-band Carrier Aggregation Class A1 | 468d? | 2013-03-04 A | 2014-12-15 A | 100% | 2013-03-04 | 2014-09-12 | 402d? | finish no earlier than 2014-12-15 | R4 | 3744h | 3744h | LTE_CA_2UL-A1-Core | PCG-30 | 36.101, 36.104, New generic TR 36.860 | Huawei | Liu Ye (leo.liuye@huawei.com) | Rel-12 | RP-59 | Issam | CA | LTE_CA_2UL-A1-Core | RP-141732 |  |  |
| 1080 | 262.24.2 | Perf. part: LTE Advanced dual uplink inter-band Carrier Aggregation Class A1 | 467d? | 2013-03-13 A | 2014-12-15 A | 100% | 2013-03-08 | 2014-09-12 | 401d? | finish no earlier than 2014-12-15 | R4 | 3736h | 3736h | LTE_CA_2UL-A1-Perf | PCG-30 | 36.133 | Huawei | Liu Ye (leo.liuye@huawei.com) | Rel-12 | RP-59 | Issam | CA | LTE_CA_2UL-A1-Perf | RP-141732 |  |  |
| 1081 | 262.25 | **LTE Advanced dual uplink inter-band Carrier Aggregation Class A2** | 474d? | 2013-03-04 A | 2014-12-15 A | 100% | 2013-03-04 | 2014-09-12 | 405d? |  | R4 | 11272h | 11272h | LTE_CA_2UL-A2 | PCG-30 | LTE | Qualcomm | Gene Fong (gfong@qti.qualcomm.com) | Rel-12 | RP-59 | Issam | CA | LTE_CA_2UL-A2 |  |  |  |
| 1082 | 262.25.1 | Core part: LTE Advanced dual uplink inter-band Carrier Aggregation Class A2 | 468d? | 2013-03-04 A | 2014-12-15 A | 100% | 2013-03-04 | 2014-09-12 | 402d? | finish no earlier than 2014-12-15 | R4 | 3744h | 3744h | LTE_CA_2UL-A2-Core | PCG-30 | 36.101, 36.104, 36.133, New generic TR 36.860 | Qualcomm | Gene Fong (gfong@qti.qualcomm.com) | Rel-12 | RP-59 | Issam | CA | LTE_CA_2UL-A2-Core | RP-141732 |  |  |
| 1083 | 262.25.2 | Perf. part: LTE Advanced dual uplink inter-band Carrier Aggregation Class A2 | 467d? | 2013-03-13 A | 2014-12-15 A | 100% | 2013-03-08 | 2014-09-12 | 401d? | finish no earlier than 2014-12-15 | R4 | 3736h | 3736h | LTE_CA_2UL-A2-Perf | PCG-30 | 36.141, 36.307 | Qualcomm | Gene Fong (gfong@qti.qualcomm.com) | Rel-12 | RP-59 | Issam | CA | LTE_CA_2UL-A2-Perf | RP-141732 |  |  |
| 1084 | 262.26 | **LTE Advanced dual uplink inter-band Carrier Aggregation Class A3** | 474d? | 2013-03-04 A | 2014-12-15 A | 100% | 2013-03-04 | 2014-09-12 | 405d? |  | R4 | 11264h | 11264h | LTE_CA_2UL-A3 | PCG-30 | LTE | Ericsson | christian.bergljung@ericsson.com | Rel-12 | RP-59 | Issam | CA | LTE_CA_2UL-A3 |  |  |  |
| 1085 | 262.26.1 | Core part: LTE Advanced dual uplink inter-band Carrier Aggregation Class A3 | 467d? | 2013-03-04 A | 2014-12-15 A | 100% | 2013-03-04 | 2014-09-12 | 401d? | finish no earlier than 2014-12-15 | R4 | 3736h | 3736h | LTE_CA_2UL-A3-Core | PCG-30 | 36.101, 36.104, 36.133, New generic TR 36.860 | Ericsson | christian.bergljung@ericsson.com | Rel-12 | RP-59 | Issam | CA | LTE_CA_2UL-A3-Core | RP-141732 |  |  |
| 1086 | 262.26.2 | Perf. part: LTE Advanced dual uplink inter-band Carrier Aggregation Class A3 | 467d? | 2013-03-13 A | 2014-12-15 A | 100% | 2013-03-08 | 2014-09-12 | 401d? | finish no earlier than 2014-12-15 | R4 | 3736h | 3736h | LTE_CA_2UL-A3-Perf | PCG-30 | 36.141, 36.307 | Ericsson | christian.bergljung@ericsson.com | Rel-12 | RP-59 | Issam | CA | LTE_CA_2UL-A3-Perf | RP-141732 |  |  |

Notes:
- 1063: Intra-band NC
- 1064: RP#62 completed
- 1065: RP#62 completed
- 1066: Intra-band contig. CA 2DL/1UL
- 1067: RP#62 completed
- 1068: RP#64 completed. TR 36.833-1-27v200 for Approval
- 1069: Inter-band 1 UL
- 1070: RP#60 completed
- 1071: RP#60 completed
- 1072: Inter-band 1 UL
- 1073: RP#60 completed
- 1074: RP#60 completed
- 1075: Inter-band 1 UL
- 1076: RP#62 stopped (at 20%)
- 1077: RP#62 stopped (at 20%)
- 1078: Inter-band CA 2UL
- 1079: ; WID: RP-142043->RP-141941; Stat Rep: RP-141084->RP-141732
- 1080: ; WID: RP-142043->RP-141941; Stat Rep: RP-141084->RP-141732
- 1081: Inter-band CA 2UL
- 1082: ; Stat Rep: RP-141084->RP-141732
- 1083: ; Stat Rep: RP-141084->RP-141732
- 1084: Inter-band CA 2UL
- 1085: ; Stat Rep: RP-141084->RP-141732
- 1086: ; Stat Rep: RP-141084->RP-141732

| ID | WBS | Task | Duration | Start | Finish | Complete | Baseline start | Baseline finish | Baseline duration | Constraint | Resources | Work | Actual work | Acronym | PCG approved | WI rapporteur name | WI rapporteur e-mail | Release | TSG approved | MCC resp | Special Focus Doc | Acronym_3GU_Export | Status Report | PCG stopped | TSG stopped |
| --- | --- | --- | --- | --- | --- | --- | --- | --- | --- | --- | --- | --- | --- | --- | --- | --- | --- | --- | --- | --- | --- | --- | --- | --- | --- |
| 1087 | 262.27 | **LTE Advanced dual uplink inter-band Carrier Aggregation Class A4** | 474d? | 2013-03-04 A | 2014-12-15 A | 100% | 2013-03-04 | 2014-09-12 | 405d? |  | R4 | 11272h | 11272h | LTE_CA_2UL-A4 | PCG-30 | Nokia | petri.j.vasenkari@nokia.com | Rel-12 | RP-59 | Issam | CA | LTE_CA_2UL-A4 |  |  |  |
| 1088 | 262.27.1 | Core part: LTE Advanced dual uplink inter-band Carrier Aggregation Class A4 | 468d? | 2013-03-04 A | 2014-12-15 A | 100% | 2013-03-04 | 2014-09-12 | 402d? | finish no earlier than 2014-12-15 | R4 | 3744h | 3744h | LTE_CA_2UL-A4-Core | PCG-30 | Nokia | petri.j.vasenkari@nokia.com | Rel-12 | RP-59 | Issam | CA | LTE_CA_2UL-A4-Core | RP-141732 |  |  |
| 1089 | 262.27.2 | Perf. part: LTE Advanced dual uplink inter-band Carrier Aggregation Class A4 | 467d? | 2013-03-13 A | 2014-12-15 A | 100% | 2013-03-08 | 2014-09-12 | 401d? | finish no earlier than 2014-12-15 | R4 | 3736h | 3736h | LTE_CA_2UL-A4-Perf | PCG-30 | Nokia | petri.j.vasenkari@nokia.com | Rel-12 | RP-59 | Issam | CA | LTE_CA_2UL-A4-Perf | RP-141732 |  |  |
| 1090 | 262.28 | **LTE Advanced dual uplink inter-band Carrier Aggregation Class A5** | 474d? | 2013-03-04 A | 2014-12-15 A | 100% | 2013-03-04 | 2014-09-12 | 405d? |  | R4 | 11264h | 11264h | LTE_CA_2UL-A5 | PCG-30 | NTT DOCOMO | kei.andou.ye@nttdocomo.com | Rel-12 | RP-59 | Issam | CA | LTE_CA_2UL-A5 |  |  |  |
| 1091 | 262.28.1 | Core part: LTE Advanced dual uplink inter-band Carrier Aggregation Class A5 | 467d? | 2013-03-04 A | 2014-12-15 A | 100% | 2013-03-04 | 2014-09-12 | 401d? | finish no earlier than 2014-12-15 | R4 | 3736h | 3736h | LTE_CA_2UL-A5-Core | PCG-30 | NTT DOCOMO | kei.andou.ye@nttdocomo.com | Rel-12 | RP-59 | Issam | CA | LTE_CA_2UL-A5-Core | RP-141732 |  |  |
| 1092 | 262.28.2 | Perf. part: LTE Advanced dual uplink inter-band Carrier Aggregation Class A5 | 467d? | 2013-03-13 A | 2014-12-15 A | 100% | 2013-03-08 | 2014-09-12 | 401d? | finish no earlier than 2014-12-15 | R4 | 3736h | 3736h | LTE_CA_2UL-A5-Perf | PCG-30 | NTT DOCOMO | kei.andou.ye@nttdocomo.com | Rel-12 | RP-59 | Issam | CA | LTE_CA_2UL-A5-Perf | RP-141732 |  |  |
| 1093 | 262.29 | **LTE Advanced intra-band contiguous Carrier Aggregation in Band 39** | 269d? | 2013-03-04 A | 2014-03-06 A | 100% | 2013-03-04 | 2014-03-06 | 269d? |  | R4 | 6400h | 6400h | LTE_CA_C_B39 | PCG-30 | China Mobile | Li Nan (linan@chinamobile.com) | Rel-12 | RP-59 | Issam | CA | LTE_CA_C_B39 |  |  |  |
| 1094 | 262.29.1 | Core part: LTE Advanced intra-band contiguous Carrier Aggregation in Band 39 | 266d? | 2013-03-04 A | 2014-03-06 A | 100% | 2013-03-04 | 2014-03-06 | 266d? | finish no earlier than 2014-03-06 | R4 | 2128h | 2128h | LTE_CA_C_B39-Core | PCG-30 | China Mobile | Li Nan (linan@chinamobile.com) | Rel-12 | RP-59 | Issam | CA | LTE_CA_C_B39-Core | RP-140428 |  |  |
| 1095 | 262.29.2 | Perf. part: LTE Advanced intra-band contiguous Carrier Aggregation in Band 39 | 265d? | 2013-03-07 A | 2014-03-06 A | 100% | 2013-03-07 | 2014-03-06 | 265d? | finish no earlier than 2014-03-06 | R4 | 2120h | 2120h | LTE_CA_C_B39-Perf | PCG-30 | China Mobile | Li Nan (linan@chinamobile.com) | Rel-12 | RP-59 | Issam | CA | LTE_CA_C_B39-Perf | RP-140428 |  |  |
| 1096 | 262.30 | **LTE Advanced intra-band non-contiguous Carrier Aggregation: framework requirements for 2UL** | 397d? | 2013-06-18 A | 2014-12-15 A | 100% | 2013-06-18 | 2014-09-12 | 328d? |  | R4 | 6328h | 6328h | LTE_CA_NC_2UL | PCG-31 | Nokia | petri.j.vasenkari@nokia.com | Rel-12 | RP-60 | Issam | CA | LTE_CA_NC_2UL |  |  |  |
| 1097 | 262.30.1 | Core part: LTE Advanced intra-band non-contiguous Carrier Aggregation: framework requirements for 2UL | 394d? | 2013-06-18 A | 2014-12-15 A | 100% | 2013-06-18 | 2014-09-12 | 328d? | finish no earlier than 2014-12-15 | R4 | 3152h | 3152h | LTE_CA_NC_2UL-Core | PCG-31 | Nokia | petri.j.vasenkari@nokia.com | Rel-12 | RP-60 | Issam | CA | LTE_CA_NC_2UL-Core | RP-141732 |  |  |
| 1098 | 262.31 | **Deleted - LTE Advanced intra-band non-contiguous Carrier Aggregation in Band 41 for 2UL** | 191d? | 2013-06-19 A | 2014-03-06 A | 100% | 2013-06-19 | 2014-03-06 | 191d? |  | R4 | 4576h | 4576h | LTE_CA_NC_B41_2UL | PCG-31 | Sprint | yang.xu@clearwire.com | Rel-12 | RP-60 | Issam | CA | LTE_CA_NC_B41_2UL | RP-140428 | PCG-32 | RP-63 |
| 1099 | 262.31.1 | Deleted - Core part: LTE Advanced intra-band non-contiguous Carrier Aggregation in Band 41 for 2UL | 191d? | 2013-06-19 A | 2014-03-06 A | 100% | 2013-06-19 | 2014-03-06 | 191d? | finish no earlier than 2014-03-06 | R4 | 1528h | 1528h | LTE_CA_NC_B41_2UL-Core | PCG-31 | Sprint | yang.xu@clearwire.com | Rel-12 | RP-60 | Issam | CA | LTE_CA_NC_B41_2UL-Core | RP-140428 | PCG-32 | RP-63 |
| 1100 | 262.31.2 | Deleted - Perf. part: LTE Advanced intra-band non-contiguous Carrier Aggregation in Band 41 for 2UL | 190d? | 2013-06-20 A | 2014-03-06 A | 100% | 2013-06-20 | 2014-03-06 | 190d? | finish no earlier than 2014-03-06 | R4 | 1520h | 1520h | LTE_CA_NC_B41_2UL-Perf | PCG-31 | Sprint | yang.xu@clearwire.com | Rel-12 | RP-60 | Issam | CA | LTE_CA_NC_B41_2UL-Perf | RP-140428 | PCG-32 | RP-63 |
| 1101 | 262.32 | **LTE Advanced intra-band non-contiguous Carrier Aggregation in Band 4 for 2UL** | 396d? | 2013-06-19 A | 2014-12-15 A | 100% | 2013-06-19 | 2014-09-12 | 327d? |  | R4 | 9448h | 9448h | LTE_CA_NC_B4_2UL | PCG-31 | T-Mobile USA | nelson.ueng@t-mobile.com | Rel-12 | RP-60 | Issam | CA | LTE_CA_NC_B4_2UL |  |  |  |
| 1102 | 262.32.1 | Core part: LTE Advanced intra-band non-contiguous Carrier Aggregation in Band 4 for 2UL | 393d? | 2013-06-19 A | 2014-12-15 A | 100% | 2013-06-19 | 2014-09-12 | 327d? | finish no earlier than 2014-12-15 | R4 | 3144h | 3144h | LTE_CA_NC_B4_2UL-Core | PCG-31 | T-Mobile USA | nelson.ueng@t-mobile.com | Rel-12 | RP-60 | Issam | CA | LTE_CA_NC_B4_2UL-Core | RP-141732 |  |  |
| 1103 | 262.32.2 | Perf. part: LTE Advanced intra-band non-contiguous Carrier Aggregation in Band 4 for 2UL | 392d? | 2013-06-25 A | 2014-12-15 A | 100% | 2013-06-20 | 2014-09-12 | 326d? | finish no earlier than 2014-12-15 | R4 | 3136h | 3136h | LTE_CA_NC_B4_2UL-Perf | PCG-31 | T-Mobile USA | nelson.ueng@t-mobile.com | Rel-12 | RP-60 | Issam | CA | LTE_CA_NC_B4_2UL-Perf | RP-141732 |  |  |
| 1104 | 262.33 | **LTE Advanced intra-band contiguous Carrier Aggregation in Band 23** | 127d? | 2013-06-18 A | 2013-12-06 A | 100% | 2013-06-18 | 2013-12-06 | 127d? |  | R4 | 3032h | 3032h | LTE_CA_C_B23 | PCG-31 | Dish Network | mariam.sorond@dish.com, johny.kim@dish.com | Rel-12 | RP-60 | Issam | CA | LTE_CA_C_B23 |  |  |  |
| 1105 | 262.33.1 | Core part: LTE Advanced intra-band contiguous Carrier Aggregation in Band 23 | 126d? | 2013-06-18 A | 2013-12-06 A | 100% | 2013-06-18 | 2013-12-06 | 126d? | finish no earlier than 2013-12-06 | R4 | 1008h | 1008h | LTE_CA_C_B23-Core | PCG-31 | Dish Network | mariam.sorond@dish.com, johny.kim@dish.com | Rel-12 | RP-60 | Issam | CA | LTE_CA_C_B23-Core | RP-131565 |  |  |
| 1106 | 262.33.2 | Perf. part: LTE Advanced intra-band contiguous Carrier Aggregation in Band 23 | 126d? | 2013-06-18 A | 2013-12-06 A | 100% | 2013-06-18 | 2013-12-06 | 126d? | finish no earlier than 2013-12-06 | R4 | 1008h | 1008h | LTE_CA_C_B23-Perf | PCG-31 | Dish Network | mariam.sorond@dish.com, johny.kim@dish.com | Rel-12 | RP-60 | Issam | CA | LTE_CA_C_B23-Perf | RP-131566 |  |  |
| 1107 | 262.34 | **LTE Advanced intra-band non-contiguous Carrier Aggregation in Band 23** | 263d? | 2013-06-18 A | 2014-06-13 A | 100% | 2013-06-18 | 2014-06-13 | 263d? |  | R4 | 5216h | 5216h | LTE_CA_NC_B23 | PCG-31 | Dish Network | mariam.sorond@dish.com, johny.kim@dish.com | Rel-12 | RP-60 | Issam | CA | LTE_CA_NC_B23 |  |  |  |
| 1108 | 262.34.1 | Core part: LTE Advanced intra-band non-contiguous Carrier Aggregation in Band 23 | 126d? | 2013-06-18 A | 2013-12-06 A | 100% | 2013-06-18 | 2013-12-06 | 126d? | finish no earlier than 2013-12-06 | R4 | 1008h | 1008h | LTE_CA_NC_B23-Core | PCG-31 | Dish Network | mariam.sorond@dish.com, johny.kim@dish.com | Rel-12 | RP-60 | Issam | CA | LTE_CA_NC_B23-Core | RP-131577 |  |  |
| 1109 | 262.34.2 | Perf. part: LTE Advanced intra-band non-contiguous Carrier Aggregation in Band 23 | 263d? | 2013-06-18 A | 2014-06-13 A | 100% | 2013-06-18 | 2014-06-13 | 263d? | finish no earlier than 2014-06-13 | R4 | 2104h | 2104h | LTE_CA_NC_B23-Perf | PCG-31 | Dish Network | mariam.sorond@dish.com, johny.kim@dish.com | Rel-12 | RP-60 | Issam | CA | LTE_CA_NC_B23-Perf | RP-140569 |  |  |
| 1110 | 262.35 | **LTE Advanced inter-band Carrier Aggregation of Band 12 and Band 25** | 127d? | 2013-06-18 A | 2013-12-06 A | 100% | 2013-06-18 | 2013-12-06 | 127d? |  | R4 | 3032h | 3032h | LTE_CA_B12_B25 | PCG-31 | US Cellular | sebastian.thalanany@uscellular.com | Rel-12 | RP-60 | Issam | CA | LTE_CA_B12_B25 |  |  |  |
| 1111 | 262.35.1 | Core part: LTE Advanced inter-band Carrier Aggregation of Band 12 and Band 25 | 126d? | 2013-06-18 A | 2013-12-06 A | 100% | 2013-06-18 | 2013-12-06 | 126d? | finish no earlier than 2013-12-06 | R4 | 1008h | 1008h | LTE_CA_B12_B25-Core | PCG-31 | US Cellular | sebastian.thalanany@uscellular.com | Rel-12 | RP-60 | Issam | CA | LTE_CA_B12_B25-Core | RP-131705 |  |  |
| 1112 | 262.35.2 | Perf. part: LTE Advanced inter-band Carrier Aggregation of Band 12 and Band 25 | 126d? | 2013-06-19 A | 2013-12-06 A | 100% | 2013-06-19 | 2013-12-06 | 126d? | finish no earlier than 2013-12-06 | R4 | 1008h | 1008h | LTE_CA_B12_B25-Perf | PCG-31 | US Cellular | sebastian.thalanany@uscellular.com | Rel-12 | RP-60 | Issam | CA | LTE_CA_B12_B25-Perf | RP-131706 |  |  |

Notes:
- 1087: Inter-band CA 2UL. RP#65 updated WID RP-140476=>RP-141160. / Impacted TSs and TRs: LTE
- 1088: ; WID: RP-142043->RP-141967; Stat Rep: RP-141084->RP-141732 / Impacted TSs and TRs: 36.101, 36.104, 36.133, New generic TR 36.860
- 1089: ; WID: RP-142043->RP-141967; Stat Rep: RP-141084->RP-141732 / Impacted TSs and TRs: 36.141, 36.307
- 1090: Inter-band CA 2UL. RP#65 updated WID RP-131146=>RP-141195. Changed Rapp Renesas=>Broadcom=>NTT DOCOMO / Impacted TSs and TRs: LTE
- 1091: ; Stat Rep: RP-141084->RP-141732 / Impacted TSs and TRs: 36.101, 36.104, 36.133, New generic TR 36.860
- 1092: ; Stat Rep: RP-141084->RP-141732 / Impacted TSs and TRs: 36.141, 36.307
- 1093: Intra-band C 2DL/2UL / Impacted TSs and TRs: LTE
- 1094: RP#63 completed / Impacted TSs and TRs: 36.101, 36.104, 36.133, New TR 36.833-1-39 [instead of 36.845]
- 1095: RP#63 completed / Impacted TSs and TRs: 36.141, 36.307
- 1096: Intra-band non-contig. CA 2DL / Impacted TSs and TRs: LTE
- 1097: ; WID: RP-142043->RP-141962; Stat Rep: RP-141084->RP-141732 / Impacted TSs and TRs: 36.101, 36.104, 36.133, 36.306, 36.331, New TR 36.833-4
- 1098: Intra-band NC 2UL / Impacted TSs and TRs: LTE
- 1099: RP#63 stopped (5% complete). Reason: Market conditions have eliminated the need for this feature, at least for the foreseeable future / Impacted TSs and TRs: 36.101, 36.104, 36.133, new TR 36.833-3-41
- 1100: RP#63 stopped (0% complete). / Impacted TSs and TRs: 36.101, 36.104, 36.133, 36.141, 36.307
- 1101: Intra-band non-contig. CA 2DL / Impacted TSs and TRs: LTE
- 1102: ; WID: RP-142043->RP-141784; Stat Rep: RP-141084->RP-141732 / Impacted TSs and TRs: 36.101, 36.104, 36.133, new TR 36.833-4-04
- 1103: ; WID: RP-142043->RP-141784; Stat Rep: RP-141084->RP-141732 / Impacted TSs and TRs: 36.101, 36.104, 36.133, 36.141, 36.307
- 1104: Intra-band C CA / Impacted TSs and TRs: LTE
- 1105: RP#62 completed / Impacted TSs and TRs: 36.101, 36.104, 36.133, new TR 36.833-1-23 [instead of 36.864]
- 1106: RP#62 completed / Impacted TSs and TRs: 36.141, 36.307
- 1107: Intra-band non-contig. CA 2DL / Impacted TSs and TRs: LTE
- 1108: RP#62 completed / Impacted TSs and TRs: 36.101, 36.104, 36.133, new TR 36.833-2-23
- 1109: RP#64 completed. TR 36.833-2-23v200 for Approval / Impacted TSs and TRs: 36.101, 36.133, 36.141, 36.307, new TR 36.833-2-23
- 1110: Inter-band 1UL/2DL / Impacted TSs and TRs: LTE
- 1111: RP#62 completed / Impacted TSs and TRs: 36.101, 36.104, 36.133, new generic TR 36.851
- 1112: RP#62 completed / Impacted TSs and TRs: 36.141, 36.307

| ID | WBS | Task | Duration | Start | Finish | Complete | Baseline start | Baseline finish | Baseline duration | Constraint | Resources | Work | Actual work | Acronym | PCG approved | WI rapporteur name | WI rapporteur e-mail | Release | TSG approved | MCC resp | Special Focus Doc | Acronym_3GU_Export | Status Report | PCG stopped | TSG stopped |
| --- | --- | --- | --- | --- | --- | --- | --- | --- | --- | --- | --- | --- | --- | --- | --- | --- | --- | --- | --- | --- | --- | --- | --- | --- | --- |
| 1113 | 262.36 | **LTE Advanced inter-band Carrier Aggregation of Band 1 and Band 18 - Additional bandwidth combination set** | 61d? | 2013-06-18 A | 2013-09-06 A | 100% | 2013-06-18 | 2013-09-06 | 61d? |  | R4 | 1464h | 1464h | LTE_CA_B1_B18_BWset | PCG-31 | KDDI | Masaaki Obara (ms-obara@kddi.com) | Rel-12 | RP-60 | Issam | CA | LTE_CA_B1_B18_BWset |  |  |  |
| 1114 | 262.36.1 | Core part: LTE Advanced inter-band Carrier Aggregation of Band 1 and Band 18 - Additional bandwidth combination set | 61d? | 2013-06-18 A | 2013-09-06 A | 100% | 2013-06-18 | 2013-09-06 | 61d? | finish no earlier than 2013-09-06 | R4 | 488h | 488h | LTE_CA_B1_B18_BWset-Core | PCG-31 | KDDI | Masaaki Obara (ms-obara@kddi.com) | Rel-12 | RP-60 | Issam | CA | LTE_CA_B1_B18_BWset-Core | RP-131003 |  |  |
| 1115 | 262.36.2 | Perf. part: LTE Advanced inter-band Carrier Aggregation of Band 1 and Band 18 - Additional bandwidth combination set | 61d? | 2013-06-18 A | 2013-09-06 A | 100% | 2013-06-18 | 2013-09-06 | 61d? | finish no earlier than 2013-09-06 | R4 | 488h | 488h | LTE_CA_B1_B18_BWset-Perf | PCG-31 | KDDI | Masaaki Obara (ms-obara@kddi.com) | Rel-12 | RP-60 | Issam | CA | LTE_CA_B1_B18_BWset-Perf | RP-131004 |  |  |
| 1116 | 262.37 | **LTE Advanced inter-band Carrier Aggregation of Band 2 and Band 5** | 61d? | 2013-06-18 A | 2013-09-06 A | 100% | 2013-06-18 | 2013-09-06 | 61d? |  | R4 | 1464h | 1464h | LTE_CA_B2_B5 | PCG-31 | AT&T | marc.grant@att.com | Rel-12 | RP-60 | Issam | CA | LTE_CA_B2_B5 |  |  |  |
| 1117 | 262.37.1 | Core part: LTE Advanced inter-band Carrier Aggregation of Band 2 and Band 5 | 61d? | 2013-06-18 A | 2013-09-06 A | 100% | 2013-06-18 | 2013-09-06 | 61d? | finish no earlier than 2013-09-06 | R4 | 488h | 488h | LTE_CA_B2_B5-Core | PCG-31 | AT&T | marc.grant@att.com | Rel-12 | RP-60 | Issam | CA | LTE_CA_B2_B5-Core | RP-131009 |  |  |
| 1118 | 262.37.2 | Perf. part: LTE Advanced inter-band Carrier Aggregation of Band 2 and Band 5 | 61d? | 2013-06-18 A | 2013-09-06 A | 100% | 2013-06-18 | 2013-09-06 | 61d? | finish no earlier than 2013-12-06 | R4 | 488h | 488h | LTE_CA_B2_B5-Perf | PCG-31 | AT&T | marc.grant@att.com | Rel-12 | RP-60 | Issam | CA | LTE_CA_B2_B5-Perf | RP-131010 |  |  |
| 1119 | 262.38 | **LTE Advanced 3 Band Carrier Aggregation (3DL/1UL) of Band 2, Band 5 and Band 30** | 329d? | 2013-06-18 A | 2014-09-12 A | 100% | 2013-06-18 | 2014-09-12 | 328d? |  | R4 | 7872h | 7872h | LTE_CA_B2_B5_B30 | PCG-31 | AT&T | marc.grant@att.com | Rel-12 | RP-60 | Issam | CA | LTE_CA_B2_B5_B30 |  |  |  |
| 1120 | 262.38.1 | Core part: LTE Advanced 3 Band Carrier Aggregation (3DL/1UL) of Band 2, Band 5 and Band 30 | 328d? | 2013-06-18 A | 2014-09-12 A | 100% | 2013-06-18 | 2014-09-12 | 328d? | finish no earlier than 2014-09-12 | R4 | 2624h | 2624h | LTE_CA_B2_B5_B30-Core | PCG-31 | AT&T | marc.grant@att.com | Rel-12 | RP-60 | Issam | CA | LTE_CA_B2_B5_B30-Core | RP-141084 |  |  |
| 1121 | 262.38.2 | Perf. part: LTE Advanced 3 Band Carrier Aggregation (3DL/1UL) of Band 2, Band 5 and Band 30 | 327d? | 2013-06-18 A | 2014-09-12 A | 100% | 2013-06-18 | 2014-09-12 | 327d? | finish no earlier than 2014-09-12 | R4 | 2616h | 2616h | LTE_CA_B2_B5_B30-Perf | PCG-31 | AT&T | marc.grant@att.com | Rel-12 | RP-60 | Issam | CA | LTE_CA_B2_B5_B30-Perf | RP-141084 |  |  |
| 1122 | 262.39 | **Deleted - LTE Advanced 3 Band Carrier Aggregation (3DL/1UL) of Band 2, Band 17 and Band 30** | 127d? | 2013-06-18 A | 2013-12-06 A | 100% | 2013-06-18 | 2013-12-06 | 127d? |  | R4 | 3024h | 3024h | LTE_CA_B2_B17_B30 | PCG-31 | AT&T | marc.grant@att.com | Rel-12 | RP-60 | Issam | CA | LTE_CA_B2_B17_B30 |  | PCG-32 | RP-62 |
| 1123 | 262.39.1 | Deleted - Core part: LTE Advanced 3 Band Carrier Aggregation (3DL/1UL) of Band 2, Band 17 and Band 30 | 126d? | 2013-06-18 A | 2013-12-06 A | 100% | 2013-06-18 | 2013-12-06 | 126d? | finish no earlier than 2014-06-13 | R4 | 1008h | 1008h | LTE_CA_B2_B17_B30-Core | PCG-31 | AT&T | marc.grant@att.com | Rel-12 | RP-60 | Issam | CA | LTE_CA_B2_B17_B30-Core | RP-131590 | PCG-32 | RP-62 |
| 1124 | 262.39.2 | Deleted - Perf. part: LTE Advanced 3 Band Carrier Aggregation (3DL/1UL) of Band 2, Band 17 and Band 30 | 125d? | 2013-06-19 A | 2013-12-06 A | 100% | 2013-06-19 | 2013-12-06 | 125d? | finish no earlier than 2014-09-12 | R4 | 1000h | 1000h | LTE_CA_B2_B17_B30-Perf | PCG-31 | AT&T | marc.grant@att.com | Rel-12 | RP-60 | Issam | CA | LTE_CA_B2_B17_B30-Perf | RP-131591 | PCG-32 | RP-62 |
| 1125 | 262.40 | **LTE Advanced 3 Band Carrier Aggregation (3DL/1UL) of Band 2, Band 29 and Band 30** | 328d? | 2013-06-19 A | 2014-09-12 A | 100% | 2013-06-19 | 2014-09-12 | 327d? |  | R4 | 7856h | 7856h | LTE_CA_B2_B29_B30 | PCG-31 | AT&T | marc.grant@att.com | Rel-12 | RP-60 | Issam | CA | LTE_CA_B2_B29_B30 |  |  |  |
| 1126 | 262.40.1 | Core part: LTE Advanced 3 Band Carrier Aggregation (3DL/1UL) of Band 2, Band 29 and Band 30 | 327d? | 2013-06-19 A | 2014-09-12 A | 100% | 2013-06-19 | 2014-06-13 | 262d? | finish no earlier than 2014-09-12 | R4 | 2616h | 2616h | LTE_CA_B2_B29_B30-Core | PCG-31 | AT&T | marc.grant@att.com | Rel-12 | RP-60 | Issam | CA | LTE_CA_B2_B29_B30-Core | RP-141084 |  |  |
| 1127 | 262.40.2 | Perf. part: LTE Advanced 3 Band Carrier Aggregation (3DL/1UL) of Band 2, Band 29 and Band 30 | 327d? | 2013-06-19 A | 2014-09-12 A | 100% | 2013-06-19 | 2014-09-12 | 327d? | finish no earlier than 2014-09-12 | R4 | 2616h | 2616h | LTE_CA_B2_B29_B30-Perf | PCG-31 | AT&T | marc.grant@att.com | Rel-12 | RP-60 | Issam | CA | LTE_CA_B2_B29_B30-Perf | RP-141084 |  |  |
| 1128 | 262.41 | **LTE Advanced 3 Band Carrier Aggregation (3DL/1UL) of Band 4, Band 5 and Band 30** | 331d? | 2013-06-14 A | 2014-09-12 A | 100% | 2013-06-14 | 2014-09-12 | 330d? |  | R4 | 7904h | 7904h | LTE_CA_B4_B5_B30 | PCG-31 | AT&T | marc.grant@att.com | Rel-12 | RP-60 | Issam | CA | LTE_CA_B4_B5_B30 |  |  |  |
| 1129 | 262.41.1 | Core part: LTE Advanced 3 Band Carrier Aggregation (3DL/1UL) of Band 4, Band 5 and Band 30 | 330d? | 2013-06-14 A | 2014-09-12 A | 100% | 2013-06-14 | 2014-09-12 | 330d? | finish no earlier than 2014-09-12 | R4 | 2640h | 2640h | LTE_CA_B4_B5_B30-Core | PCG-31 | AT&T | marc.grant@att.com | Rel-12 | RP-60 | Issam | CA | LTE_CA_B4_B5_B30-Core | RP-141084 |  |  |
| 1130 | 262.41.2 | Perf. part: LTE Advanced 3 Band Carrier Aggregation (3DL/1UL) of Band 4, Band 5 and Band 30 | 327d? | 2013-06-19 A | 2014-09-12 A | 100% | 2013-06-19 | 2014-09-12 | 327d? | finish no earlier than 2014-09-12 | R4 | 2616h | 2616h | LTE_CA_B4_B5_B30-Perf | PCG-31 | AT&T | marc.grant@att.com | Rel-12 | RP-60 | Issam | CA | LTE_CA_B4_B5_B30-Perf | RP-141084 |  |  |
| 1131 | 262.42 | **Deleted - LTE Advanced 3 Band Carrier Aggregation (3DL/1UL) of Band 4, Band 17 and Band 30** | 127d? | 2013-06-18 A | 2013-12-06 A | 100% | 2013-06-18 | 2013-12-06 | 127d? |  | R4 | 3040h | 3040h | LTE_CA_B4_B17_B30 | PCG-31 | AT&T | marc.grant@att.com | Rel-12 | RP-60 | Issam | CA | LTE_CA_B4_B17_B30 |  | PCG-32 | RP-62 |
| 1132 | 262.42.1 | Deleted - Core part: LTE Advanced 3 Band Carrier Aggregation (3DL/1UL) of Band 4, Band 17 and Band 30 | 127d? | 2013-06-18 A | 2013-12-06 A | 100% | 2013-06-18 | 2013-12-06 | 127d? | finish no earlier than 2013-12-06 | R4 | 1016h | 1016h | LTE_CA_B4_B17_B30-Core | PCG-31 | AT&T | marc.grant@att.com | Rel-12 | RP-60 | Issam | CA | LTE_CA_B4_B17_B30-Core | RP-131598 | PCG-32 | RP-62 |
| 1133 | 262.42.2 | Deleted - Perf. part: LTE Advanced 3 Band Carrier Aggregation (3DL/1UL) of Band 4, Band 17 and Band 30 | 126d? | 2013-06-19 A | 2013-12-06 A | 100% | 2013-06-19 | 2013-12-06 | 126d? | finish no earlier than 2013-12-06 | R4 | 1008h | 1008h | LTE_CA_B4_B17_B30-Perf | PCG-31 | AT&T | marc.grant@att.com | Rel-12 | RP-60 | Issam | CA | LTE_CA_B4_B17_B30-Perf | RP-131599 | PCG-32 | RP-62 |
| 1134 | 262.43 | **LTE Advanced 3 Band Carrier Aggregation (3DL/1UL) of Band 4, Band 29 and Band 30** | 331d? | 2013-06-14 A | 2014-09-12 A | 100% | 2013-06-14 | 2014-09-12 | 330d? |  | R4 | 7904h | 7904h | LTE_CA_B4_B29_B30 | PCG-31 | AT&T | marc.grant@att.com | Rel-12 | RP-60 | Issam | CA | LTE_CA_B4_B29_B30 |  |  |  |
| 1135 | 262.43.1 | Core part: LTE Advanced 3 Band Carrier Aggregation (3DL/1UL) of Band 4, Band 29 and Band 30 | 330d? | 2013-06-14 A | 2014-09-12 A | 100% | 2013-06-14 | 2014-09-12 | 330d? | finish no earlier than 2014-09-12 | R4 | 2640h | 2640h | LTE_CA_B4_B29_B30-Core | PCG-31 | AT&T | marc.grant@att.com | Rel-12 | RP-60 | Issam | CA | LTE_CA_B4_B29_B30-Core | RP-141084 |  |  |
| 1136 | 262.43.2 | Perf. part: LTE Advanced 3 Band Carrier Aggregation (3DL/1UL) of Band 4, Band 29 and Band 30 | 327d? | 2013-06-19 A | 2014-09-12 A | 100% | 2013-06-19 | 2014-09-12 | 327d? | finish no earlier than 2014-09-12 | R4 | 2616h | 2616h | LTE_CA_B4_B29_B30-Perf | PCG-31 | AT&T | marc.grant@att.com | Rel-12 | RP-60 | Issam | CA | LTE_CA_B4_B29_B30-Perf | RP-141084 |  |  |

Notes:
- 1113: Inter-band 1UL/2DL / Impacted TSs and TRs: LTE
- 1114: RP#61 completed / Impacted TSs and TRs: 36.101, new generic TR 36.851
- 1115: RP#61 completed / Impacted TSs and TRs: 36.307
- 1116: Inter-band 2DL / Impacted TSs and TRs: LTE
- 1117: RP#61 completed / Impacted TSs and TRs: 36.101, 36.104, 36.307
- 1118: RP#61 completed / Impacted TSs and TRs: 36.101, 36.104, 36.133, 36.141, 36.307
- 1119: Inter-band 3DL / Impacted TSs and TRs: LTE
- 1120: RP#65 completed. TR 36.853v200 for Approval / Impacted TSs and TRs: 36.101, 36.104, 36.133, 36.141, 36.307, new generic TR 36.853 (3 Band CA with 1UL)
- 1121: RP#65 completed / Impacted TSs and TRs: 36.101, 36.104, 36.133, 36.141, 36.307
- 1122: Inter-band 3DL / Impacted TSs and TRs: LTE
- 1123: RP#62 stopped (25% complete) following RP-131652 discussion / Impacted TSs and TRs: 36.101, 36.104, 36.133, 36.141, 36.307, new generic TR 36.853 (3 Band CA with 1UL)
- 1124: RP#62 stopped (25% complete) following RP-131652 discussion / Impacted TSs and TRs: 36.101, 36.104, 36.133, 36.141, 36.307
- 1125: Inter-band 3DL / Impacted TSs and TRs: LTE
- 1126: RP#65 completed. Updated WID RP-131697=>RP-141212 / Impacted TSs and TRs: 36.101, 36.104, 36.133, 36.141, 36.307, new generic TR 36.853 (3 Band CA with 1UL)
- 1127: RP#65 completed / Impacted TSs and TRs: 36.101, 36.104, 36.133, 36.141, 36.307
- 1128: Inter-band CA 3DL / Impacted TSs and TRs: LTE
- 1129: RP#65 completed. Updated WID RP-131698=>RP-141213 / Impacted TSs and TRs: 36.101, 36.104, 36.133, 36.141, 36.307, new generic TR 36.853 (3 Band CA with 1UL)
- 1130: RP#65 completed / Impacted TSs and TRs: 36.101, 36.104, 36.133, 36.141, 36.307
- 1131: Inter-band 3DL / Impacted TSs and TRs: LTE
- 1132: RP#62 stopped (25% complete) following RP-131653 discussion / Impacted TSs and TRs: 36.101, 36.104, 36.133, 36.141, 36.307, new generic TR 36.853 (3 Band CA with 1UL)
- 1133: RP#62 stopped (25% complete) following RP-131653 discussion / Impacted TSs and TRs: 36.101, 36.104, 36.133, 36.141, 36.307
- 1134: Inter-band CA 3DL / Impacted TSs and TRs: LTE
- 1135: RP#65 completed. Updated WID RP-131699=>RP- 141215 / Impacted TSs and TRs: 36.101, 36.104, 36.133, 36.141, 36.307, new generic TR 36.853 (3 Band CA with 1UL)
- 1136: RP#65 completed / Impacted TSs and TRs: 36.101, 36.104, 36.133, 36.141, 36.307

| ID | WBS | Task | Duration | Start | Finish | Complete | Baseline start | Baseline finish | Baseline duration | Constraint | Resources | Work | Actual work | Acronym | PCG approved | WI rapporteur name | WI rapporteur e-mail | Release | TSG approved | MCC resp | Special Focus Doc | Acronym_3GU_Export | Status Report |
| --- | --- | --- | --- | --- | --- | --- | --- | --- | --- | --- | --- | --- | --- | --- | --- | --- | --- | --- | --- | --- | --- | --- | --- |
| 1137 | 262.44 | **LTE Advanced 3 Band Carrier Aggregation (3DL/1UL) of Band 2, Band 4 and Band 13** | 331d? | 2013-06-14 A | 2014-09-12 A | 100% | 2013-06-14 | 2014-09-12 | 330d? |  | R4 | 7904h | 7904h | LTE_CA_B2_B4_B13 | PCG-31 | Verizon | zheng.zhao@verizonwireless.com | Rel-12 | RP-60 | Issam | CA | LTE_CA_B2_B4_B13 |  |
| 1138 | 262.44.1 | Core part: LTE Advanced 3 Band Carrier Aggregation (3DL/1UL) of Band 2, Band 4 and Band 13 | 330d? | 2013-06-14 A | 2014-09-12 A | 100% | 2013-06-14 | 2014-09-12 | 330d? | finish no earlier than 2014-09-12 | R4 | 2640h | 2640h | LTE_CA_B2_B4_B13-Core | PCG-31 | Verizon | zheng.zhao@verizonwireless.com | Rel-12 | RP-60 | Issam | CA | LTE_CA_B2_B4_B13-Core | RP-141084 |
| 1139 | 262.44.2 | Perf. part: LTE Advanced 3 Band Carrier Aggregation (3DL/1UL) of Band 2, Band 4 and Band 13 | 327d? | 2013-06-19 A | 2014-09-12 A | 100% | 2013-06-19 | 2014-09-12 | 327d? | finish no earlier than 2014-09-12 | R4 | 2616h | 2616h | LTE_CA_B2_B4_B13-Perf | PCG-31 | Verizon | zheng.zhao@verizonwireless.com | Rel-12 | RP-60 | Issam | CA | LTE_CA_B2_B4_B13-Perf | RP-141084 |
| 1140 | 262.45 | **LTE Advanced 3 Band Carrier Aggregation (3DL/1UL) of Band 2, Band 2 and Band 13** | 329d? | 2013-06-18 A | 2014-09-12 A | 100% | 2013-06-18 | 2014-09-12 | 328d? |  | R4 | 7864h | 7864h | LTE_CA_B2_B2_B13 | PCG-31 | Verizon | zheng.zhao@verizonwireless.com | Rel-12 | RP-60 | Issam | CA | LTE_CA_B2_B2_B13 |  |
| 1141 | 262.45.1 | Core part: LTE Advanced 3 Band Carrier Aggregation (3DL/1UL) of Band 2, Band 2 and Band 13 | 327d? | 2013-06-18 A | 2014-09-12 A | 100% | 2013-06-18 | 2014-09-12 | 327d? | finish no earlier than 2014-09-12 | R4 | 2616h | 2616h | LTE_CA_B2_B2_B13-Core | PCG-31 | Verizon | zheng.zhao@verizonwireless.com | Rel-12 | RP-60 | Issam | CA | LTE_CA_B2_B2_B13-Core | RP-141084 |
| 1142 | 262.45.2 | Perf. part: LTE Advanced 3 Band Carrier Aggregation (3DL/1UL) of Band 2, Band 2 and Band 13 | 327d? | 2013-06-19 A | 2014-09-12 A | 100% | 2013-06-19 | 2014-09-12 | 327d? | finish no earlier than 2014-09-12 | R4 | 2616h | 2616h | LTE_CA_B2_B2_B13-Perf | PCG-31 | Verizon | zheng.zhao@verizonwireless.com | Rel-12 | RP-60 | Issam | CA | LTE_CA_B2_B2_B13-Perf | RP-141084 |
| 1143 | 262.46 | **LTE Advanced 3 Band Carrier Aggregation (3DL/1UL) of Band 4, Band 4 and Band 13** | 331d? | 2013-06-14 A | 2014-09-12 A | 100% | 2013-06-14 | 2014-09-12 | 330d? |  | R4 | 7928h | 7928h | LTE_CA_B4_B4_B13 | PCG-31 | Verizon | zheng.zhao@verizonwireless.com | Rel-12 | RP-60 | Issam | CA | LTE_CA_B4_B4_B13 |  |
| 1144 | 262.46.1 | Core part: LTE Advanced 3 Band Carrier Aggregation (3DL/1UL) of Band 4, Band 4 and Band 13 | 330d? | 2013-06-14 A | 2014-09-12 A | 100% | 2013-06-14 | 2014-09-12 | 330d? | finish no earlier than 2014-09-12 | R4 | 2640h | 2640h | LTE_CA_B4_B4_B13-Core | PCG-31 | Verizon | zheng.zhao@verizonwireless.com | Rel-12 | RP-60 | Issam | CA | LTE_CA_B4_B4_B13-Core | RP-141084 |
| 1145 | 262.46.2 | Perf. part: LTE Advanced 3 Band Carrier Aggregation (3DL/1UL) of Band 4, Band 4 and Band 13 | 330d? | 2013-06-14 A | 2014-09-12 A | 100% | 2013-06-14 | 2014-09-12 | 330d? | finish no earlier than 2014-09-12 | R4 | 2640h | 2640h | LTE_CA_B4_B4_B13-Perf | PCG-31 | Verizon | zheng.zhao@verizonwireless.com | Rel-12 | RP-60 | Issam | CA | LTE_CA_B4_B4_B13-Perf | RP-141084 |
| 1146 | 262.47 | **LTE Advanced inter-band Carrier Aggregation of Band 7 and Band 28** | 66d? | 2013-09-09 A | 2013-12-06 A | 100% | 2013-09-09 | 2013-12-06 | 66d? |  | R4 | 1584h | 1584h | LTE_CA_B7_B28 | PCG-31 | Huawei | Liehai Liu (liuliehai@huawei.com) | Rel-12 | RP-61 | Issam | CA | LTE_CA_B7_B28 |  |
| 1147 | 262.47.1 | Core part: LTE Advanced inter-band Carrier Aggregation of Band 7 and Band 28 | 66d? | 2013-09-09 A | 2013-12-06 A | 100% | 2013-09-09 | 2013-12-06 | 66d? | finish no earlier than 2013-12-06 | R4 | 528h | 528h | LTE_CA_B7_B28-Core | PCG-31 | Huawei | Liehai Liu (liuliehai@huawei.com) | Rel-12 | RP-61 | Issam | CA | LTE_CA_B7_B28-Core | RP-131545 |
| 1148 | 262.47.2 | Perf. part: LTE Advanced inter-band Carrier Aggregation of Band 7 and Band 28 | 66d? | 2013-09-09 A | 2013-12-06 A | 100% | 2013-09-09 | 2013-12-06 | 66d? | finish no earlier than 2013-12-06 | R4 | 528h | 528h | LTE_CA_B7_B28-Perf | PCG-31 | Huawei | Liehai Liu (liuliehai@huawei.com) | Rel-12 | RP-61 | Issam | CA | LTE_CA_B7_B28-Perf | RP-131546 |
| 1149 | 262.48 | **LTE Advanced inter-band Carrier Aggregation of Band 5 and Band 25** | 66d? | 2013-09-09 A | 2013-12-06 A | 100% | 2013-09-09 | 2013-12-06 | 66d? |  | R4 | 1584h | 1584h | LTE_CA_B5_B25 | PCG-31 | U.S. Cellular | sebastian.thalanany@uscellular.com | Rel-12 | RP-61 | Issam | CA | LTE_CA_B5_B25 |  |
| 1150 | 262.48.1 | Core part: LTE Advanced inter-band Carrier Aggregation of Band 5 and Band 25 | 66d? | 2013-09-09 A | 2013-12-06 A | 100% | 2013-09-09 | 2013-12-06 | 66d? | finish no earlier than 2013-12-06 | R4 | 528h | 528h | LTE_CA_B5_B25-Core | PCG-31 | U.S. Cellular | sebastian.thalanany@uscellular.com | Rel-12 | RP-61 | Issam | CA | LTE_CA_B5_B25-Core | RP-131543 |
| 1151 | 262.48.2 | Perf. part: LTE Advanced inter-band Carrier Aggregation of Band 5 and Band 25 | 66d? | 2013-09-09 A | 2013-12-06 A | 100% | 2013-09-09 | 2013-12-06 | 66d? | finish no earlier than 2013-12-06 | R4 | 528h | 528h | LTE_CA_B5_B25-Perf | PCG-31 | U.S. Cellular | sebastian.thalanany@uscellular.com | Rel-12 | RP-61 | Issam | CA | LTE_CA_B5_B25-Perf | RP-131705 |
| 1152 | 262.49 | **LTE Advanced inter-band Carrier Aggregation of Band 1 and Band 11** | 202d? | 2013-09-09 A | 2014-06-13 A | 100% | 2013-09-09 | 2014-06-13 | 202d? |  | R4 | 4848h | 4848h | LTE_CA_B1_B11 | PCG-31 | SoftBank Mobile | kenichi.kihara@g.softbank.co.jp | Rel-12 | RP-61 | Issam | CA | LTE_CA_B1_B11 |  |
| 1153 | 262.49.1 | Core part: LTE Advanced inter-band Carrier Aggregation of Band 1 and Band 11 | 202d? | 2013-09-09 A | 2014-06-13 A | 100% | 2013-09-09 | 2014-06-13 | 202d? | finish no earlier than 2014-06-13 | R4 | 1616h | 1616h | LTE_CA_B1_B11-Core | PCG-31 | SoftBank Mobile | kenichi.kihara@g.softbank.co.jp | Rel-12 | RP-61 | Issam | CA | LTE_CA_B1_B11-Core | RP-140569 |
| 1154 | 262.49.2 | Perf. part: LTE Advanced inter-band Carrier Aggregation of Band 1 and Band 11 | 202d? | 2013-09-09 A | 2014-06-13 A | 100% | 2013-09-09 | 2014-06-13 | 202d? | finish no earlier than 2014-06-13 | R4 | 1616h | 1616h | LTE_CA_B1_B11-Perf | PCG-31 | SoftBank Mobile | kenichi.kihara@g.softbank.co.jp | Rel-12 | RP-61 | Issam | CA | LTE_CA_B1_B11-Perf | RP-140569 |
| 1155 | 262.50 | **LTE Advanced inter-band Carrier Aggregation of Band 8 and Band 11** | 268d? | 2013-09-09 A | 2014-09-12 A | 100% | 2013-09-09 | 2014-09-12 | 267d? |  | R4 | 6416h | 6416h | LTE_CA_B8_B11 | PCG-31 | SoftBank Mobile | kenichi.kihara@g.softbank.co.jp | Rel-12 | RP-61 | Issam | CA | LTE_CA_B8_B11 |  |
| 1156 | 262.50.1 | Core part: LTE Advanced inter-band Carrier Aggregation of Band 8 and Band 11 | 267d? | 2013-09-09 A | 2014-09-12 A | 100% | 2013-09-09 | 2014-09-12 | 267d? | finish no earlier than 2014-09-12 | R4 | 2136h | 2136h | LTE_CA_B8_B11-Core | PCG-31 | SoftBank Mobile | kenichi.kihara@g.softbank.co.jp | Rel-12 | RP-61 | Issam | CA | LTE_CA_B8_B11-Core | RP-141084 |
| 1157 | 262.50.2 | Perf. part: LTE Advanced inter-band Carrier Aggregation of Band 8 and Band 11 | 267d? | 2013-09-09 A | 2014-09-12 A | 100% | 2013-09-09 | 2014-09-12 | 267d? | finish no earlier than 2014-09-12 | R4 | 2136h | 2136h | LTE_CA_B8_B11-Perf | PCG-31 | SoftBank Mobile | kenichi.kihara@g.softbank.co.jp | Rel-12 | RP-61 | Issam | CA | LTE_CA_B8_B11-Perf | RP-141084 |
| 1158 | 262.51 | **LTE Advanced inter-band Carrier Aggregation of Band 5 and Band 7** | 62d? | 2013-09-09 A | 2013-12-02 A | 100% | 2013-09-09 | 2013-12-02 | 62d? |  | R4 | 1488h | 1488h | LTE_CA_B5_B7 | PCG-31 | LG Uplus | Yeonsang KOO (yskoo@lguplus.co.kr) | Rel-12 | RP-61 | Issam | CA | LTE_CA_B5_B7 |  |
| 1159 | 262.51.1 | Core part: LTE Advanced inter-band Carrier Aggregation of Band 5 and Band 7 | 62d? | 2013-09-09 A | 2013-12-02 A | 100% | 2013-09-09 | 2013-12-02 | 62d? | finish no earlier than 2013-12-02 | R4 | 496h | 496h | LTE_CA_B5_B7-Core | PCG-31 | LG Uplus | Yeonsang KOO (yskoo@lguplus.co.kr) | Rel-12 | RP-61 | Issam | CA | LTE_CA_B5_B7-Core | RP-131541 |
| 1160 | 262.51.2 | Perf. part: LTE Advanced inter-band Carrier Aggregation of Band 5 and Band 7 | 62d? | 2013-09-09 A | 2013-12-02 A | 100% | 2013-09-09 | 2013-12-02 | 62d? | finish no earlier than 2013-12-02 | R4 | 496h | 496h | LTE_CA_B5_B7-Perf | PCG-31 | LG Uplus | Yeonsang KOO (yskoo@lguplus.co.kr) | Rel-12 | RP-61 | Issam | CA | LTE_CA_B5_B7-Perf | RP-131542 |

Notes:
- 1137: Inter-band CA 3DL / Impacted TSs and TRs: LTE
- 1138: RP#65 completed. Updated RP-131684=>RP-141434 / Impacted TSs and TRs: 36.101, 36.104, 36.133, new generic TR 36.853 (3 Band CA with 1UL)
- 1139: RP#65 completed / Impacted TSs and TRs: 36.101, 36.133, 36.141, 36.307
- 1140: Inter-band CA 3DL / Impacted TSs and TRs: LTE
- 1141: RP#65 completed. Updated WID RP-131682=>RP-141435 / Impacted TSs and TRs: 36.101, 36.104, 36.133, new generic TR 36.853 (3 Band CA with 1UL)
- 1142: RP#65 completed / Impacted TSs and TRs: 36.101, 36.133, 36.141, 36.307
- 1143: Inter-band CA 3DL / Impacted TSs and TRs: LTE
- 1144: RP#65 completed. Updated WID RP-131683=>RP-141433 / Impacted TSs and TRs: 36.101, 36.104, 36.133, new generic TR 36.853 (3 Band CA with 1UL)
- 1145: RP#65 completed / Impacted TSs and TRs: 36.101, 36.133, 36.141, 36.307
- 1146: Inter-band 1UL/2DL / Impacted TSs and TRs: LTE
- 1147: RP#62 completed / Impacted TSs and TRs: 36.101, 36.104, 36.307
- 1148: RP#62 completed / Impacted TSs and TRs: 36.141
- 1149: Inter-band 1UL/2DL / Impacted TSs and TRs: LTE
- 1150: RP#62 completed / Impacted TSs and TRs: 36.101, 36.104, 36.133, new generic TR 36.851
- 1151: RP#62 completed / Impacted TSs and TRs: 36.141, 36.307
- 1152: Inter-band CA 2DL / Impacted TSs and TRs: LTE
- 1153: RP#64 completed / Impacted TSs and TRs: 36.101, 36.104, new generic TR 36.851
- 1154: RP#64 completed / Impacted TSs and TRs: 36.141, 36.307
- 1155: Inter-band CA 2DL / Impacted TSs and TRs: LTE
- 1156: RP#65 completed / Impacted TSs and TRs: 36.101, 36.104, new generic TR 36.851
- 1157: RP#65 completed / Impacted TSs and TRs: 36.141, 36.307
- 1158: Inter-band 1UL/2DL / Impacted TSs and TRs: LTE
- 1159: RP#62 completed / Impacted TSs and TRs: 36.101, 36.104, 36.133, new generic TR 36.851
- 1160: RP#62 completed / Impacted TSs and TRs: 36.141, 36.307

| ID | WBS | Task | Duration | Start | Finish | Complete | Remaining | Baseline start | Baseline finish | Baseline duration | Total slack | Constraint | Resources | Work | Actual work | Acronym | PCG approved | Impacted TSs and TRs | WI rapporteur name | WI rapporteur e-mail | Release | TSG approved | MCC resp | Special Focus Doc | Acronym_3GU_Export | Status Report |
| --- | --- | --- | --- | --- | --- | --- | --- | --- | --- | --- | --- | --- | --- | --- | --- | --- | --- | --- | --- | --- | --- | --- | --- | --- | --- | --- |
| 1161 | 262.52 | **LTE Advanced intra-band contiguous Carrier Aggregation in Band 41 for 3DL** | 400d? | 2013-09-09 A | 2015-03-15 | 99% | 0d? | 2013-09-09 | 2014-09-12 | 267d? | 0d |  | R4 | 8512h | 6647.02h | LTE_CA_C_B41_3DL | PCG-31 | LTE | Alcatel-Lucent | man-hung.ng@alcatel-lucent.com | Rel-12 | RP-61 | Issam | CA | LTE_CA_C_B41_3DL |  |
| 1162 | 262.52.1 | Core part: LTE Advanced intra-band contiguous Carrier Aggregation in Band 41 for 3DL | 267d? | 2013-09-09 A | 2014-09-12 A | 100% |  | 2013-09-09 | 2014-09-12 | 267d? |  | finish no earlier than 2014-09-12 | R4 | 2136h | 2136h | LTE_CA_C_B41_3DL-Core | PCG-31 | 36.101, 36.104, 36.133, 36.307, New TR 36.833-5-41 | Alcatel-Lucent | man-hung.ng@alcatel-lucent.com | Rel-12 | RP-61 | Issam | CA | LTE_CA_C_B41_3DL-Core | RP-141084 |
| 1163 | 262.52.2 | Perf. part: LTE Advanced intra-band contiguous Carrier Aggregation in Band 41 for 3DL | 397d? | 2013-09-09 A | 2015-03-15 A | 100% |  | 2013-09-09 | 2014-09-12 | 267d? |  | finish no earlier than 2015-03-15 | R4 | 3176h | 3176h | LTE_CA_C_B41_3DL-Perf | PCG-31 | 36.141 | Alcatel-Lucent | man-hung.ng@alcatel-lucent.com | Rel-12 | RP-61 | Issam | CA | LTE_CA_C_B41_3DL-Perf | RP-150013 |
| 1164 | 262.53 | **LTE Advanced intra-band non-contiguous Carrier Aggregation in Band 2** | 202d? | 2013-09-09 A | 2014-06-13 A | 100% |  | 2013-09-09 | 2014-06-13 | 202d? |  |  | R4 | 4840h | 4840h | LTE_CA_NC_B2 | PCG-31 | LTE | Ericsson | imadur.rahman@ericsson.com | Rel-12 | RP-61 | Issam | CA | LTE_CA_NC_B2 |  |
| 1165 | 262.53.1 | Core part: LTE Advanced intra-band non-contiguous Carrier Aggregation in Band 2 | 202d? | 2013-09-09 A | 2014-06-13 A | 100% |  | 2013-09-09 | 2014-06-13 | 202d? |  | finish no earlier than 2014-06-13 | R4 | 1616h | 1616h | LTE_CA_NC_B2-Core | PCG-31 | 36.101, 36.104, 36.133, New TR 36.833-2-02 | Ericsson | imadur.rahman@ericsson.com | Rel-12 | RP-61 | Issam | CA | LTE_CA_NC_B2-Core | RP-140569 |
| 1166 | 262.53.2 | Perf. part: LTE Advanced intra-band non-contiguous Carrier Aggregation in Band 2 | 201d? | 2013-09-10 A | 2014-06-13 A | 100% |  | 2013-09-10 | 2014-06-13 | 201d? |  | finish no earlier than 2014-06-13 | R4 | 1608h | 1608h | LTE_CA_NC_B2-Perf | PCG-31 | 36.141, 36.307 | Ericsson | imadur.rahman@ericsson.com | Rel-12 | RP-61 | Issam | CA | LTE_CA_NC_B2-Perf | RP-140569 |
| 1167 | 262.54 | **LTE Advanced inter-band Carrier Aggregation of Band 1 and Band 3** | 202d? | 2013-12-09 A | 2014-09-12 A | 100% |  | 2013-12-09 | 2014-09-12 | 201d? |  |  | R4 | 4832h | 4832h | LTE_CA_B1_B3 | PCG-32 | LTE | China Unicom | Hao Chen (chenhao49@chinaunicom.cn) | Rel-12 | RP-62 | Issam | CA | LTE_CA_B1_B3 |  |
| 1168 | 262.54.1 | Core part: LTE Advanced inter-band Carrier Aggregation of Band 1 and Band 3 | 201d? | 2013-12-09 A | 2014-09-12 A | 100% |  | 2013-12-09 | 2014-09-12 | 201d? |  | finish no earlier than 2014-09-12 | R4 | 1608h | 1608h | LTE_CA_B1_B3-Core | PCG-32 | 36.101, 36.104, 36.133, new generic TR 36.851 | China Unicom | Hao Chen (chenhao49@chinaunicom.cn) | Rel-12 | RP-62 | Issam | CA | LTE_CA_B1_B3-Core | RP-141084 |
| 1169 | 262.54.2 | Perf. part: LTE Advanced inter-band Carrier Aggregation of Band 1 and Band 3 | 201d? | 2013-12-09 A | 2014-09-12 A | 100% |  | 2013-12-09 | 2014-09-12 | 201d? |  | finish no earlier than 2014-09-12 | R4 | 1608h | 1608h | LTE_CA_B1_B3-Perf | PCG-32 | 36.141, 36.307 | China Unicom | Hao Chen (chenhao49@chinaunicom.cn) | Rel-12 | RP-62 | Issam | CA | LTE_CA_B1_B3-Perf | RP-141084 |
| 1170 | 262.55 | **LTE Advanced inter-band Carrier Aggregation of Band 1 and Band 28** | 270d? | 2013-12-09 A | 2014-12-15 A | 100% |  | 2013-12-09 | 2014-09-12 | 201d? |  |  | R4 | 6432h | 6432h | LTE_CA_B1_B28 | PCG-32 | LTE | KDDI | Masaaki Obara (ms-obara@kddi.com) | Rel-12 | RP-62 | Issam | CA | LTE_CA_B1_B28 |  |
| 1171 | 262.55.1 | Core part: LTE Advanced inter-band Carrier Aggregation of Band 1 and Band 28 | 267d? | 2013-12-09 A | 2014-12-15 A | 100% |  | 2013-12-09 | 2014-09-12 | 201d? |  | finish no earlier than 2014-12-15 | R4 | 2136h | 2136h | LTE_CA_B1_B28-Core | PCG-32 | 36.101, 36.104, 36.133, 36.307, new generic TR 36.851 | KDDI | Masaaki Obara (ms-obara@kddi.com) | Rel-12 | RP-62 | Issam | CA | LTE_CA_B1_B28-Core | RP-141732 |
| 1172 | 262.55.2 | Perf. part: LTE Advanced inter-band Carrier Aggregation of Band 1 and Band 28 | 267d? | 2013-12-12 A | 2014-12-15 A | 100% |  | 2013-12-09 | 2014-09-12 | 201d? |  | finish no earlier than 2014-12-15 | R4 | 2136h | 2136h | LTE_CA_B1_B28-Perf | PCG-32 | 36.133, 36.141 | KDDI | Masaaki Obara (ms-obara@kddi.com) | Rel-12 | RP-62 | Issam | CA | LTE_CA_B1_B28-Perf | RP-141732 |
| 1173 | 262.56 | **LTE Advanced inter-band Carrier Aggregation of Band 2 and Band 4 - Additional bandwidth combination set** | 65d? | 2013-12-09 A | 2014-03-06 A | 100% |  | 2013-12-09 | 2014-03-06 | 65d? |  |  | R4 | 1560h | 1560h | LTE_CA_B2_B4_BWset | PCG-32 | LTE | T-Mobile USA | nelson.ueng@t-mobile.com | Rel-12 | RP-62 | Issam | CA | LTE_CA_B2_B4_BWset |  |
| 1174 | 262.56.1 | Core part: LTE Advanced inter-band Carrier Aggregation of Band 2 and Band 4 - Additional bandwidth combination set | 65d? | 2013-12-09 A | 2014-03-06 A | 100% |  | 2013-12-09 | 2014-03-06 | 65d? |  | finish no earlier than 2014-03-06 | R4 | 520h | 520h | LTE_CA_B2_B4_BWset-Core | PCG-32 | 36.101, new generic TR 36.851 | T-Mobile USA | nelson.ueng@t-mobile.com | Rel-12 | RP-62 | Issam | CA | LTE_CA_B2_B4_BWset-Core | RP-140428 |
| 1175 | 262.56.2 | Perf. part: LTE Advanced inter-band Carrier Aggregation of Band 2 and Band 4 - Additional bandwidth combination set | 65d? | 2013-12-09 A | 2014-03-06 A | 100% |  | 2013-12-09 | 2014-03-06 | 65d? |  | finish no earlier than 2014-03-06 | R4 | 520h | 520h | LTE_CA_B2_B4_BWset-Perf | PCG-32 | 36.307 | T-Mobile USA | nelson.ueng@t-mobile.com | Rel-12 | RP-62 | Issam | CA | LTE_CA_B2_B4_BWset-Perf | RP-140428 |
| 1176 | 262.57 | **LTE Advanced inter-band Carrier Aggregation of Band 4 and Band 27** | 136d? | 2013-12-09 A | 2014-06-13 A | 100% |  | 2013-12-09 | 2014-06-13 | 136d? |  |  | R4 | 3264h | 3264h | LTE_CA_B4_B27 | PCG-32 | LTE | NII Holdings | bill.shvodian@nii.com | Rel-12 | RP-62 | Issam | CA | LTE_CA_B4_B27 |  |
| 1177 | 262.57.1 | Core part: LTE Advanced inter-band Carrier Aggregation of Band 4 and Band 27 | 136d? | 2013-12-09 A | 2014-06-13 A | 100% |  | 2013-12-09 | 2014-06-13 | 136d? |  | finish no earlier than 2014-06-13 | R4 | 1088h | 1088h | LTE_CA_B4_B27-Core | PCG-32 | 36.101, 36.104, 36.133, new generic TR 36.851 | NII Holdings | bill.shvodian@nii.com | Rel-12 | RP-62 | Issam | CA | LTE_CA_B4_B27-Core | RP-140569 |
| 1178 | 262.57.2 | Perf. part: LTE Advanced inter-band Carrier Aggregation of Band 4 and Band 27 | 136d? | 2013-12-09 A | 2014-06-13 A | 100% |  | 2013-12-09 | 2014-06-13 | 136d? |  | finish no earlier than 2014-06-13 | R4 | 1088h | 1088h | LTE_CA_B4_B27-Perf | PCG-32 | 36.141, 36.307 | NII Holdings | bill.shvodian@nii.com | Rel-12 | RP-62 | Issam | CA | LTE_CA_B4_B27-Perf | RP-140569 |
| 1179 | 262.58 | **LTE Advanced inter-band Carrier Aggregation of Band 3 and Band 27** | 65d? | 2013-12-09 A | 2014-03-06 A | 100% |  | 2013-12-09 | 2014-03-06 | 65d? |  |  | R4 | 1560h | 1560h | LTE_CA_B3_B27 | PCG-32 | LTE | KT | Chungwoo HWANG (cwhwang@kt.com) | Rel-12 | RP-62 | Issam | CA | LTE_CA_B3_B27 | RP-140428 |
| 1180 | 262.58.1 | Core part: LTE Advanced inter-band Carrier Aggregation of Band 3 and Band 27 | 65d? | 2013-12-09 A | 2014-03-06 A | 100% |  | 2013-12-09 | 2014-03-06 | 65d? |  | finish no earlier than 2014-03-06 | R4 | 520h | 520h | LTE_CA_B3_B27-Core | PCG-32 | 36.101, 36.104, 36.133, 36.307, New generic TR 36.851 | KT | Chungwoo HWANG (cwhwang@kt.com) | Rel-12 | RP-62 | Issam | CA | LTE_CA_B3_B27-Core | RP-140428 |
| 1181 | 262.58.2 | Perf. part: LTE Advanced inter-band Carrier Aggregation of Band 3 and Band 27 | 65d? | 2013-12-09 A | 2014-03-06 A | 100% |  | 2013-12-09 | 2014-03-06 | 65d? |  | finish no earlier than 2014-03-06 | R4 | 520h | 520h | LTE_CA_B3_B27-Perf | PCG-32 | 36.101, 36.104, 36.133, 36.141 | KT | Chungwoo HWANG (cwhwang@kt.com) | Rel-12 | RP-62 | Issam | CA | LTE_CA_B3_B27-Perf | RP-140428 |
| 1182 | 262.59 | **LTE Advanced inter-band Carrier Aggregation in Band 8 and Band 20 - Additional channel bandwidth** | 65d? | 2013-12-09 A | 2014-03-06 A | 100% |  | 2013-12-09 | 2014-03-06 | 65d? |  |  | R4 | 1560h | 1560h | LTE_CA_B8_B20_BW | PCG-32 | LTE | Vodafone | luis.anaya@vodafone.com | Rel-12 | RP-62 | Issam | CA | LTE_CA_B8_B20_BW | RP-140428 |
| 1183 | 262.59.1 | Core part: LTE Advanced inter-band Carrier Aggregation in Band 8 and Band 20 - Additional channel bandwidth | 65d? | 2013-12-09 A | 2014-03-06 A | 100% |  | 2013-12-09 | 2014-03-06 | 65d? |  | finish no earlier than 2014-03-06 | R4 | 520h | 520h | LTE_CA_B8_B20_BW-Core | PCG-32 | 36.101, 36.104, 36.307 | Vodafone | luis.anaya@vodafone.com | Rel-12 | RP-62 | Issam | CA | LTE_CA_B8_B20_BW-Core | RP-140428 |
| 1184 | 262.59.2 | Perf. part: LTE Advanced inter-band Carrier Aggregation in Band 8 and Band 20 - Additional channel bandwidth | 65d? | 2013-12-09 A | 2014-03-06 A | 100% |  | 2013-12-09 | 2014-03-06 | 65d? |  | finish no earlier than 2014-03-06 | R4 | 520h | 520h | LTE_CA_B8_B20_BW-Perf | PCG-32 | 36.141 | Vodafone | luis.anaya@vodafone.com | Rel-12 | RP-62 | Issam | CA | LTE_CA_B8_B20_BW-Perf | RP-140428 |

Notes:
- 1161: Intra-band contig. CA 3DL
- 1162: RP#65 completed
- 1163: ; WID: RP-142043->RP-142017; Stat Rep: RP-141084->RP-141732 1st Apr 15: Compl:70%->100% 1st Apr 15: Stat Rep: RP-141732->RP-150013
- 1164: Intra-band non-contig. CA 2DL
- 1165: RP#64 completed. TR 36.833-2-02v100 for 1-step Approval
- 1166: RP#64 completed
- 1167: Inter-band CA 2DL
- 1168: RP#65 completed
- 1169: RP#65 completed
- 1170: Inter-band CA 2DL
- 1171: ; WID: RP-142043->RP-141803; Stat Rep: RP-141084->RP-141732
- 1172: ; WID: RP-142043->RP-141803; Stat Rep: RP-141084->RP-141732
- 1173: Inter-band 2DL
- 1174: RP#63 completed
- 1175: RP#63 completed
- 1176: Inter-band CA 2DL
- 1177: RP#64 completed
- 1178: RP#64 completed
- 1179: Inter-band CA 2DL/1UL
- 1180: RP#63 completed. Updated WID RP-131752=>RP-140119
- 1181: RP#63 completed. Updated WID RP-131752=>RP-140119
- 1182: Inter-band 2DL
- 1183: RP#63 completed
- 1184: RP#63 completed

| ID | WBS | Task | Duration | Start | Finish | Complete | Remaining | Baseline start | Baseline finish | Baseline duration | Total slack | Constraint | Resources | Work | Actual work | Acronym | PCG approved | WI rapporteur name | WI rapporteur e-mail | Release | TSG approved | MCC resp | Special Focus Doc | Acronym_3GU_Export | Status Report |
| --- | --- | --- | --- | --- | --- | --- | --- | --- | --- | --- | --- | --- | --- | --- | --- | --- | --- | --- | --- | --- | --- | --- | --- | --- | --- |
| 1185 | 262.60 | **LTE Advanced 3 Band Carrier Aggregation (3DL/1UL) for Band 1, Band 3 and Band 8** | 202d? | 2013-12-09 A | 2014-09-12 A | 100% |  | 2013-12-09 | 2014-09-12 | 201d? |  |  | R4 | 4832h | 4832h | LTE_CA_B1_B3_B8 | PCG-32 | KT | Ilwhan Kim (ilwhan.kim@kt.com) | Rel-12 | RP-62 | Issam | CA | LTE_CA_B1_B3_B8 |  |
| 1186 | 262.60.1 | Core part: LTE Advanced 3 Band Carrier Aggregation (3DL/1UL) for Band 1, Band 3 and Band 8 | 201d? | 2013-12-09 A | 2014-09-12 A | 100% |  | 2013-12-09 | 2014-09-12 | 201d? |  | finish no earlier than 2014-09-12 | R4 | 1608h | 1608h | LTE_CA_B1_B3_B8-Core | PCG-32 | KT | Ilwhan Kim (ilwhan.kim@kt.com) | Rel-12 | RP-62 | Issam | CA | LTE_CA_B1_B3_B8-Core | RP-141084 |
| 1187 | 262.60.2 | Perf. part: LTE Advanced 3 Band Carrier Aggregation (3DL/1UL) for Band 1, Band 3 and Band 8 | 201d? | 2013-12-09 A | 2014-09-12 A | 100% |  | 2013-12-09 | 2014-09-12 | 201d? |  | finish no earlier than 2014-09-12 | R4 | 1608h | 1608h | LTE_CA_B1_B3_B8-Perf | PCG-32 | KT | Ilwhan Kim (ilwhan.kim@kt.com) | Rel-12 | RP-62 | Issam | CA | LTE_CA_B1_B3_B8-Perf | RP-141084 |
| 1188 | 262.61 | **LTE Advanced 3 Band Carrier Aggregation (3DL/1UL) for Band 1, Band 5 and Band 7** | 202d? | 2013-12-09 A | 2014-09-12 A | 100% |  | 2013-12-09 | 2014-09-12 | 201d? |  |  | R4 | 4832h | 4832h | LTE_CA_B1_B5_B7 | PCG-32 | LG Uplus | Yeonsang KOO (yskoo@lguplus.co.kr) | Rel-12 | RP-62 | Issam | CA | LTE_CA_B1_B5_B7 |  |
| 1189 | 262.61.1 | Core part: LTE Advanced 3 Band Carrier Aggregation (3DL/1UL) for Band 1, Band 5 and Band 7 | 201d? | 2013-12-09 A | 2014-09-12 A | 100% |  | 2013-12-09 | 2014-09-12 | 201d? |  | finish no earlier than 2014-09-12 | R4 | 1608h | 1608h | LTE_CA_B1_B5_B7-Core | PCG-32 | LG Uplus | Yeonsang KOO (yskoo@lguplus.co.kr) | Rel-12 | RP-62 | Issam | CA | LTE_CA_B1_B5_B7-Core | RP-141084 |
| 1190 | 262.61.2 | Perf. part: LTE Advanced 3 Band Carrier Aggregation (3DL/1UL) for Band 1, Band 5 and Band 7 | 201d? | 2013-12-09 A | 2014-09-12 A | 100% |  | 2013-12-09 | 2014-09-12 | 201d? |  | finish no earlier than 2014-09-12 | R4 | 1608h | 1608h | LTE_CA_B1_B5_B7-Perf | PCG-32 | LG Uplus | Yeonsang KOO (yskoo@lguplus.co.kr) | Rel-12 | RP-62 | Issam | CA | LTE_CA_B1_B5_B7-Perf | RP-141084 |
| 1191 | 262.62 | **LTE Advanced 3 Band Carrier Aggregation (3DL/1UL) for Band 2, Band 4 and Band 5** | 202d? | 2013-12-09 A | 2014-09-12 A | 100% |  | 2013-12-09 | 2014-09-12 | 201d? |  |  | R4 | 4832h | 4832h | LTE_CA_B2_B4_B5 | PCG-32 | U.S. Cellular | sebastian.thalanany@uscellular.com | Rel-12 | RP-62 | Issam | CA | LTE_CA_B2_B4_B5 |  |
| 1192 | 262.62.1 | Core part: LTE Advanced 3 Band Carrier Aggregation (3DL/1UL) for Band 2, Band 4 and Band 5 | 201d? | 2013-12-09 A | 2014-09-12 A | 100% |  | 2013-12-09 | 2014-09-12 | 201d? |  | finish no earlier than 2014-09-12 | R4 | 1608h | 1608h | LTE_CA_B2_B4_B5-Core | PCG-32 | U.S. Cellular | sebastian.thalanany@uscellular.com | Rel-12 | RP-62 | Issam | CA | LTE_CA_B2_B4_B5-Core | RP-141084 |
| 1193 | 262.62.2 | Perf. part: LTE Advanced 3 Band Carrier Aggregation (3DL/1UL) for Band 2, Band 4 and Band 5 | 201d? | 2013-12-09 A | 2014-09-12 A | 100% |  | 2013-12-09 | 2014-09-12 | 201d? |  | finish no earlier than 2014-09-12 | R4 | 1608h | 1608h | LTE_CA_B2_B4_B5-Perf | PCG-32 | U.S. Cellular | sebastian.thalanany@uscellular.com | Rel-12 | RP-62 | Issam | CA | LTE_CA_B2_B4_B5-Perf | RP-141084 |
| 1194 | 262.63 | **LTE Advanced 3 Band Carrier Aggregation (3DL/1UL) for Band 2, Band 4 and Band 12** | 268d? | 2013-12-09 A | 2014-12-11 | 99% | 3.04d? | 2013-12-09 | 2014-09-12 | 201d? | 655d |  | R4 | 5872h | 5204.78h | LTE_CA_B2_B4_B12 | PCG-32 | U.S. Cellular | sebastian.thalanany@uscellular.com | Rel-12 | RP-62 | Issam | CA | LTE_CA_B2_B4_B12 |  |
| 1195 | 262.63.1 | Core part: LTE Advanced 3 Band Carrier Aggregation (3DL/1UL) for Band 2, Band 4 and Band 12 | 201d? | 2013-12-09 A | 2014-09-12 A | 100% |  | 2013-12-09 | 2014-09-12 | 201d? |  | finish no earlier than 2014-09-12 | R4 | 1608h | 1608h | LTE_CA_B2_B4_B12-Core | PCG-32 | U.S. Cellular | sebastian.thalanany@uscellular.com | Rel-12 | RP-62 | Issam | CA | LTE_CA_B2_B4_B12-Core | RP-141084 |
| 1196 | 262.63.2 | Perf. part: LTE Advanced 3 Band Carrier Aggregation (3DL/1UL) for Band 2, Band 4 and Band 12 | 265d? | 2013-12-09 A | 2014-12-11 | 98% | 5.3d? | 2013-12-09 | 2014-09-12 | 201d? | 655d | finish no earlier than 2014-12-11 | R4 | 2120h | 2077.6h | LTE_CA_B2_B4_B12-Perf | PCG-32 | U.S. Cellular | sebastian.thalanany@uscellular.com | Rel-12 | RP-62 | Issam | CA | LTE_CA_B2_B4_B12-Perf | RP-141084 |
| 1197 | 262.64 | **LTE Advanced 3 Band Carrier Aggregation (3DL/1UL) for Band 2, Band 5 and Band 12** | 202d? | 2013-12-09 A | 2014-09-12 A | 100% |  | 2013-12-09 | 2014-09-12 | 201d? |  |  | R4 | 4832h | 4832h | LTE_CA_B2_B5_B12 | PCG-32 | U.S. Cellular | sebastian.thalanany@uscellular.com | Rel-12 | RP-62 | Issam | CA | LTE_CA_B2_B5_B12 |  |
| 1198 | 262.64.1 | Core part: LTE Advanced 3 Band Carrier Aggregation (3DL/1UL) for Band 2, Band 5 and Band 12 | 201d? | 2013-12-09 A | 2014-09-12 A | 100% |  | 2013-12-09 | 2014-09-12 | 201d? |  | finish no earlier than 2014-09-12 | R4 | 1608h | 1608h | LTE_CA_B2_B5_B12-Core | PCG-32 | U.S. Cellular | sebastian.thalanany@uscellular.com | Rel-12 | RP-62 | Issam | CA | LTE_CA_B2_B5_B12-Core | RP-141084 |
| 1199 | 262.64.2 | Perf. part: LTE Advanced 3 Band Carrier Aggregation (3DL/1UL) for Band 2, Band 5 and Band 12 | 201d? | 2013-12-10 A | 2014-09-12 A | 100% |  | 2013-12-09 | 2014-09-12 | 201d? |  | finish no earlier than 2014-09-12 | R4 | 1608h | 1608h | LTE_CA_B2_B5_B12-Perf | PCG-32 | U.S. Cellular | sebastian.thalanany@uscellular.com | Rel-12 | RP-62 | Issam | CA | LTE_CA_B2_B5_B12-Perf | RP-141084 |
| 1200 | 262.65 | **LTE Advanced 3 Band Carrier Aggregation (3DL/1UL) for Band 2, Band 12 and Band 12** | 202d? | 2013-12-09 A | 2014-09-12 A | 100% |  | 2013-12-09 | 2014-09-12 | 201d? |  |  | R4 | 4832h | 4832h | LTE_CA_B2_B12_B12 | PCG-32 | AT&T | marc.grant@att.com | Rel-12 | RP-62 | Issam | CA | LTE_CA_B2_B12_B12 |  |
| 1201 | 262.65.1 | Core part: LTE Advanced 3 Band Carrier Aggregation (3DL/1UL) for Band 2, Band 12 and Band 12 | 201d? | 2013-12-09 A | 2014-09-12 A | 100% |  | 2013-12-09 | 2014-09-12 | 201d? |  | finish no earlier than 2014-09-12 | R4 | 1608h | 1608h | LTE_CA_B2_B12_B12-Core | PCG-32 | AT&T | marc.grant@att.com | Rel-12 | RP-62 | Issam | CA | LTE_CA_B2_B12_B12-Core | RP-141084 |
| 1202 | 262.65.2 | Perf. part: LTE Advanced 3 Band Carrier Aggregation (3DL/1UL) for Band 2, Band 12 and Band 12 | 201d? | 2013-12-09 A | 2014-09-12 A | 100% |  | 2013-12-09 | 2014-09-12 | 201d? |  | finish no earlier than 2014-09-12 | R4 | 1608h | 1608h | LTE_CA_B2_B12_B12-Perf | PCG-32 | AT&T | marc.grant@att.com | Rel-12 | RP-62 | Issam | CA | LTE_CA_B2_B12_B12-Perf | RP-141084 |
| 1203 | 262.66 | **LTE Advanced 3 Band Carrier Aggregation (3DL/1UL) for Band 2, Band 12 and Band 30** | 202d? | 2013-12-09 A | 2014-09-12 A | 100% |  | 2013-12-09 | 2014-09-12 | 201d? |  |  | R4 | 4832h | 4832h | LTE_CA_B2_B12_B30 | PCG-32 | AT&T | marc.grant@att.com | Rel-12 | RP-62 | Issam | CA | LTE_CA_B2_B12_B30 |  |
| 1204 | 262.66.1 | Core part: LTE Advanced 3 Band Carrier Aggregation (3DL/1UL) for Band 2, Band 12 and Band 30 | 201d? | 2013-12-09 A | 2014-09-12 A | 100% |  | 2013-12-09 | 2014-09-12 | 201d? |  | finish no earlier than 2014-09-12 | R4 | 1608h | 1608h | LTE_CA_B2_B12_B30-Core | PCG-32 | AT&T | marc.grant@att.com | Rel-12 | RP-62 | Issam | CA | LTE_CA_B2_B12_B30-Core | RP-141084 |
| 1205 | 262.66.2 | Perf. part: LTE Advanced 3 Band Carrier Aggregation (3DL/1UL) for Band 2, Band 12 and Band 30 | 201d? | 2013-12-09 A | 2014-09-12 A | 100% |  | 2013-12-09 | 2014-09-12 | 201d? |  | finish no earlier than 2014-09-12 | R4 | 1608h | 1608h | LTE_CA_B2_B12_B30-Perf | PCG-32 | AT&T | marc.grant@att.com | Rel-12 | RP-62 | Issam | CA | LTE_CA_B2_B12_B30-Perf | RP-141084 |
| 1206 | 262.67 | **LTE Advanced 3 Band Carrier Aggregation (3DL/1UL) for Band 3, Band 7 and Band 20** | 202d? | 2013-12-09 A | 2014-09-12 A | 100% |  | 2013-12-09 | 2014-09-12 | 201d? |  |  | R4 | 4832h | 4832h | LTE_CA_B3_B7_B20 | PCG-32 | Vodafone | luis.anaya@vodafone.com | Rel-12 | RP-62 | Issam | CA | LTE_CA_B3_B7_B20 |  |
| 1207 | 262.67.1 | Core part: LTE Advanced 3 Band Carrier Aggregation (3DL/1UL) for Band 3, Band 7 and Band 20 | 201d? | 2013-12-09 A | 2014-09-12 A | 100% |  | 2013-12-09 | 2014-09-12 | 201d? |  | finish no earlier than 2014-09-12 | R4 | 1608h | 1608h | LTE_CA_B3_B7_B20-Core | PCG-32 | Vodafone | luis.anaya@vodafone.com | Rel-12 | RP-62 | Issam | CA | LTE_CA_B3_B7_B20-Core | RP-141084 |
| 1208 | 262.67.2 | Perf. part: LTE Advanced 3 Band Carrier Aggregation (3DL/1UL) for Band 3, Band 7 and Band 20 | 201d? | 2013-12-10 A | 2014-09-12 A | 100% |  | 2013-12-09 | 2014-09-12 | 201d? |  | finish no earlier than 2014-09-12 | R4 | 1608h | 1608h | LTE_CA_B3_B7_B20-Perf | PCG-32 | Vodafone | luis.anaya@vodafone.com | Rel-12 | RP-62 | Issam | CA | LTE_CA_B3_B7_B20-Perf | RP-141084 |

Notes:
- 1185: Inter-band CA 3DL / Impacted TSs and TRs: LTE
- 1186: RP#65 completed. Updated WID RP-131753=>RP-141654 / Impacted TSs and TRs: 36.101, 36.104, 36.133, 36.141, 36.307, new generic TR 36.853 (3 Band CA with 1UL)
- 1187: RP#65 completed / Impacted TSs and TRs: 36.101, 36.104, 36.133, 36.141, 36.307
- 1188: Inter-band CA 3DL / Impacted TSs and TRs: LTE
- 1189: RP#65 completed. Updated WID RP-140209=>RP-141462 / Impacted TSs and TRs: 36.101, 36.104, 36.133, new generic TR 36.853 (3 Band CA with 1UL)
- 1190: RP#65 completed / Impacted TSs and TRs: 36.141, 36.307
- 1191: Inter-band CA 3DL / Impacted TSs and TRs: LTE
- 1192: RP#65 completed / Impacted TSs and TRs: 36.101, 36.104, 36.133, new generic TR 36.853 (3 Band CA with 1UL)
- 1193: RP#65 completed / Impacted TSs and TRs: 36.141, 36.307
- 1194: Inter-band CA 3DL / Impacted TSs and TRs: LTE
- 1195: RP#65 completed / Impacted TSs and TRs: 36.101, 36.104, 36.133, new generic TR 36.853 (3 Band CA with 1UL)
- 1196: RP#65 completion 09/14=>12/14 / Impacted TSs and TRs: 36.141, 36.307
- 1197: Inter-band CA 3DL / Impacted TSs and TRs: LTE
- 1198: RP#65 completed / Impacted TSs and TRs: 36.101, 36.104, 36.133, new generic TR 36.853 (3 Band CA with 1UL)
- 1199: RP#65 completed / Impacted TSs and TRs: 36.141, 36.307
- 1200: Inter-band CA 3DL / Impacted TSs and TRs: LTE
- 1201: RP#65 completed / Impacted TSs and TRs: 36.101, 36.104, 36.133, 36.141, 36.307, new generic TR 36.853
- 1202: RP#65 completed / Impacted TSs and TRs: 36.101, 36.104, 36.133, 36.141, 36.307
- 1203: Inter-band CA 3DL / Impacted TSs and TRs: LTE
- 1204: RP#65 completed. Updated WID RP-131652=>RP-141211. / Impacted TSs and TRs: 36.101, 36.104, 36.133, 36.141, 36.307, new generic TR 36.853 (3 Band CA with 1UL)
- 1205: RP#65 completed / Impacted TSs and TRs: 36.101, 36.104, 36.133, 36.141, 36.307
- 1206: Inter-band CA 3DL / Impacted TSs and TRs: LTE
- 1207: RP#65 completed. Updated WID RP-140244=>RP-141224 / Impacted TSs and TRs: 36.101, 36.104, 36.133, new generic TR 36.853 (3 Band CA with 1UL)
- 1208: RP#65 completed / Impacted TSs and TRs: 36.101, 36.133, 36.141, 36.307

| ID | WBS | Task | Duration | Start | Finish | Complete | Remaining | Baseline start | Baseline finish | Baseline duration | Total slack | Constraint | Resources | Work | Actual work | Acronym | PCG approved | WI rapporteur name | WI rapporteur e-mail | Release | TSG approved | MCC resp | Special Focus Doc | Acronym_3GU_Export | Status Report |
| --- | --- | --- | --- | --- | --- | --- | --- | --- | --- | --- | --- | --- | --- | --- | --- | --- | --- | --- | --- | --- | --- | --- | --- | --- | --- |
| 1209 | 262.68 | **LTE Advanced 3 Band Carrier Aggregation (3DL/1UL) for Band 4, Band 5 and Band 12** | 202d? | 2013-12-09 A | 2014-09-12 A | 100% |  | 2013-12-09 | 2014-09-12 | 201d? |  |  | R4 | 4832h | 4832h | LTE_CA_B4_B5_B12 | PCG-32 | U.S. Cellular | sebastian.thalanany@uscellular.com | Rel-12 | RP-62 | Issam | CA | LTE_CA_B4_B5_B12 |  |
| 1210 | 262.68.1 | Core part: LTE Advanced 3 Band Carrier Aggregation (3DL/1UL) for Band 4, Band 5 and Band 12 | 201d? | 2013-12-09 A | 2014-09-12 A | 100% |  | 2013-12-09 | 2014-09-12 | 201d? |  | finish no earlier than 2014-09-12 | R4 | 1608h | 1608h | LTE_CA_B4_B5_B12-Core | PCG-32 | U.S. Cellular | sebastian.thalanany@uscellular.com | Rel-12 | RP-62 | Issam | CA | LTE_CA_B4_B5_B12-Core | RP-141084 |
| 1211 | 262.68.2 | Perf. part: LTE Advanced 3 Band Carrier Aggregation (3DL/1UL) for Band 4, Band 5 and Band 12 | 201d? | 2013-12-09 A | 2014-09-12 A | 100% |  | 2013-12-09 | 2014-09-12 | 201d? |  | finish no earlier than 2014-09-12 | R4 | 1608h | 1608h | LTE_CA_B4_B5_B12-Perf | PCG-32 | U.S. Cellular | sebastian.thalanany@uscellular.com | Rel-12 | RP-62 | Issam | CA | LTE_CA_B4_B5_B12-Perf | RP-141084 |
| 1212 | 262.69 | **LTE Advanced 3 Band Carrier Aggregation (3DL/1UL) for Band 4, Band 12 and Band 12** | 202d? | 2013-12-09 A | 2014-09-12 A | 100% |  | 2013-12-09 | 2014-09-12 | 201d? |  |  | R4 | 4832h | 4832h | LTE_CA_B4_B12_B12 | PCG-32 | AT&T | marc.grant@att.com | Rel-12 | RP-62 | Issam | CA | LTE_CA_B4_B12_B12 |  |
| 1213 | 262.69.1 | Core part: LTE Advanced 3 Band Carrier Aggregation (3DL/1UL) for Band 4, Band 12 and Band 12 | 201d? | 2013-12-09 A | 2014-09-12 A | 100% |  | 2013-12-09 | 2014-09-12 | 201d? |  | finish no earlier than 2014-09-12 | R4 | 1608h | 1608h | LTE_CA_B4_B12_B12-Core | PCG-32 | AT&T | marc.grant@att.com | Rel-12 | RP-62 | Issam | CA | LTE_CA_B4_B12_B12-Core | RP-141084 |
| 1214 | 262.69.2 | Perf. part: LTE Advanced 3 Band Carrier Aggregation (3DL/1UL) for Band 4, Band 12 and Band 12 | 201d? | 2013-12-09 A | 2014-09-12 A | 100% |  | 2013-12-09 | 2014-09-12 | 201d? |  | finish no earlier than 2014-09-12 | R4 | 1608h | 1608h | LTE_CA_B4_B12_B12-Perf | PCG-32 | AT&T | marc.grant@att.com | Rel-12 | RP-62 | Issam | CA | LTE_CA_B4_B12_B12-Perf | RP-141084 |
| 1215 | 262.70 | **LTE Advanced 3 Band Carrier Aggregation (3DL/1UL) for Band 4, Band 12 and Band 30** | 202d? | 2013-12-09 A | 2014-09-12 A | 100% |  | 2013-12-09 | 2014-09-12 | 201d? |  |  | R4 | 4832h | 4832h | LTE_CA_B4_B12_B30 | PCG-32 | AT&T | marc.grant@att.com | Rel-12 | RP-62 | Issam | CA | LTE_CA_B4_B12_B30 |  |
| 1216 | 262.70.1 | Core part: LTE Advanced 3 Band Carrier Aggregation (3DL/1UL) for Band 4, Band 12 and Band 30 | 201d? | 2013-12-09 A | 2014-09-12 A | 100% |  | 2013-12-09 | 2014-09-12 | 201d? |  | finish no earlier than 2014-09-12 | R4 | 1608h | 1608h | LTE_CA_B4_B12_B30-Core | PCG-32 | AT&T | marc.grant@att.com | Rel-12 | RP-62 | Issam | CA | LTE_CA_B4_B12_B30-Core | RP-141084 |
| 1217 | 262.70.2 | Perf. part: LTE Advanced 3 Band Carrier Aggregation (3DL/1UL) for Band 4, Band 12 and Band 30 | 201d? | 2013-12-09 A | 2014-09-12 A | 100% |  | 2013-12-09 | 2014-09-12 | 201d? |  | finish no earlier than 2014-09-12 | R4 | 1608h | 1608h | LTE_CA_B4_B12_B30-Perf | PCG-32 | AT&T | marc.grant@att.com | Rel-12 | RP-62 | Issam | CA | LTE_CA_B4_B12_B30-Perf | RP-141084 |
| 1218 | 262.71 | **LTE Advanced intra-band contiguous Carrier Aggregation in Band 42** | 136d? | 2013-12-09 A | 2014-06-13 A | 100% |  | 2013-12-09 | 2014-06-13 | 136d? |  |  | R4 | 3264h | 3264h | LTE_CA_C_B42 | PCG-32 | CATT | Yuexia Song (songyuexia@catt.cn) | Rel-12 | RP-62 | Issam | CA | LTE_CA_C_B42 |  |
| 1219 | 262.71.1 | Core part: LTE Advanced intra-band contiguous Carrier Aggregation in Band 42 | 136d? | 2013-12-09 A | 2014-06-13 A | 100% |  | 2013-12-09 | 2014-06-13 | 136d? |  | finish no earlier than 2014-06-13 | R4 | 1088h | 1088h | LTE_CA_C_B42-Core | PCG-32 | CATT | Yuexia Song (songyuexia@catt.cn) | Rel-12 | RP-62 | Issam | CA | LTE_CA_C_B42-Core | RP-140569 |
| 1220 | 262.71.2 | Perf. part: LTE Advanced intra-band contiguous Carrier Aggregation in Band 42 | 136d? | 2013-12-09 A | 2014-06-13 A | 100% |  | 2013-12-09 | 2014-06-13 | 136d? |  | finish no earlier than 2014-06-13 | R4 | 1088h | 1088h | LTE_CA_C_B42-Perf | PCG-32 | CATT | Yuexia Song (songyuexia@catt.cn) | Rel-12 | RP-62 | Issam | CA | LTE_CA_C_B42-Perf | RP-140569 |
| 1221 | 262.72 | **LTE Advanced intra-band contiguous Carrier Aggregation in Band 7 - Additional bandwidth combinations** | 136d? | 2013-12-09 A | 2014-06-13 A | 100% |  | 2013-12-09 | 2014-06-13 | 136d? |  |  | R4 | 3264h | 3264h | LTE_CA_C_B7_BW | PCG-32 | Orange | Olfa BEN HADDADA | Rel-12 | RP-62 | Issam | CA | LTE_CA_C_B7_BW |  |
| 1222 | 262.72.1 | Core part: LTE Advanced intra-band contiguous Carrier Aggregation in Band 7 - Additional bandwidth combinations | 136d? | 2013-12-09 A | 2014-06-13 A | 100% |  | 2013-12-09 | 2014-06-13 | 136d? |  | finish no earlier than 2014-06-13 | R4 | 1088h | 1088h | LTE_CA_C_B7_BW-Core | PCG-32 | Orange | Olfa BEN HADDADA | Rel-12 | RP-62 | Issam | CA | LTE_CA_C_B7_BW-Core | RP-140569 |
| 1223 | 262.72.2 | Perf. part: LTE Advanced intra-band contiguous Carrier Aggregation in Band 7 - Additional bandwidth combinations | 136d? | 2013-12-09 A | 2014-06-13 A | 100% |  | 2013-12-09 | 2014-06-13 | 136d? |  | finish no earlier than 2014-06-13 | R4 | 1088h | 1088h | LTE_CA_C_B7_BW-Perf | PCG-32 | Orange | Olfa BEN HADDADA | Rel-12 | RP-62 | Issam | CA | LTE_CA_C_B7_BW-Perf | RP-140569 |
| 1224 | 262.73 | **LTE Advanced intra-band non-contiguous Carrier Aggregation in Band 41 for 3 DL** | 334d? | 2013-12-09 A | 2015-03-15 | 99% | 0d? | 2013-12-09 | 2014-09-12 | 200d? | 0d |  | R4 | 6920h | 5132.4h | LTE_CA_NC_B41_3DL | PCG-32 | Sprint, Alcatel-Lucent | man-hung.ng@alcatel-lucent.com | Rel-12 | RP-62 | Issam | CA | LTE_CA_NC_B41_3DL |  |
| 1225 | 262.73.1 | Core part: LTE Advanced intra-band non-contiguous Carrier Aggregation in Band 41 for 3 DL | 200d? | 2013-12-09 A | 2014-09-11 A | 100% |  | 2013-12-09 | 2014-09-12 | 200d? |  | finish no earlier than 2014-09-12 | R4 | 1600h | 1600h | LTE_CA_NC_B41_3DL-Core | PCG-32 | Sprint, Alcatel-Lucent | man-hung.ng@alcatel-lucent.com | Rel-12 | RP-62 | Issam | CA | LTE_CA_NC_B41_3DL-Core | RP-141084 |
| 1226 | 262.73.2 | Perf. part: LTE Advanced intra-band non-contiguous Carrier Aggregation in Band 41 for 3 DL | 331d? | 2013-12-09 A | 2015-03-15 A | 100% |  | 2013-12-09 | 2014-09-12 | 200d? |  | finish no earlier than 2015-03-15 | R4 | 2648h | 2648h | LTE_CA_NC_B41_3DL-Perf | PCG-32 | Sprint, Alcatel-Lucent | man-hung.ng@alcatel-lucent.com | Rel-12 | RP-62 | Issam | CA | LTE_CA_NC_B41_3DL-Perf | RP-150013 |
| 1227 | 262.74 | **LTE Advanced intra-band non-contiguous Carrier Aggregation in Band 42** | 136d? | 2013-12-09 A | 2014-06-13 A | 100% |  | 2013-12-09 | 2014-06-13 | 136d? |  |  | R4 | 3264h | 3264h | LTE_CA_NC_B42 | PCG-32 | Huawei | Liu Liehai (liuliehai@huawei.com) | Rel-12 | RP-62 | Issam | CA | LTE_CA_NC_B42 |  |
| 1228 | 262.74.1 | Core part: LTE Advanced intra-band non-contiguous Carrier Aggregation in Band 42 | 136d? | 2013-12-09 A | 2014-06-13 A | 100% |  | 2013-12-09 | 2014-06-13 | 136d? |  | finish no earlier than 2014-06-13 | R4 | 1088h | 1088h | LTE_CA_NC_B42-Core | PCG-32 | Huawei | Liu Liehai (liuliehai@huawei.com) | Rel-12 | RP-62 | Issam | CA | LTE_CA_NC_B42-Core | RP-140569 |
| 1229 | 262.74.2 | Perf. part: LTE Advanced intra-band non-contiguous Carrier Aggregation in Band 42 | 136d? | 2013-12-09 A | 2014-06-13 A | 100% |  | 2013-12-09 | 2014-06-13 | 136d? |  | finish no earlier than 2014-06-13 | R4 | 1088h | 1088h | LTE_CA_NC_B42-Perf | PCG-32 | Huawei | Liu Liehai (liuliehai@huawei.com) | Rel-12 | RP-62 | Issam | CA | LTE_CA_NC_B42-Perf | RP-140569 |
| 1230 | 262.75 | **LTE Advanced 3 Band Carrier Aggregation (3DL/1UL) for Band 1, Band 3 and Band 5** | 203d? | 2013-12-06 A | 2014-09-12 A | 100% |  | 2013-12-06 | 2014-09-12 | 202d? |  |  | R4 | 4856h | 4856h | LTE_CA_B1_B3_B5 | PCG-32 | SK Telecom | haesung.park@sk.com | Rel-12 | RP-62 | Issam | CA | LTE_CA_B1_B3_B5 |  |
| 1231 | 262.75.1 | Core part: LTE Advanced 3 Band Carrier Aggregation(3DL/1UL) for Band 1, Band 3 and Band 5 | 202d? | 2013-12-06 A | 2014-09-12 A | 100% |  | 2013-12-06 | 2014-09-12 | 202d? |  | finish no earlier than 2014-09-12 | R4 | 1616h | 1616h | LTE_CA_B1_B3_B5-Core | PCG-32 | SK Telecom | haesung.park@sk.com | Rel-12 | RP-62 | Issam | CA | LTE_CA_B1_B3_B5-Core | RP-141084 |
| 1232 | 262.75.2 | Perf. part: LTE Advanced 3 Band Carrier Aggregation(3DL/1UL) for Band 1, Band 3 and Band 5 | 202d? | 2013-12-06 A | 2014-09-12 A | 100% |  | 2013-12-06 | 2014-09-12 | 202d? |  | finish no earlier than 2014-09-12 | R4 | 1616h | 1616h | LTE_CA_B1_B3_B5-Perf | PCG-32 | SK Telecom | haesung.park@sk.com | Rel-12 | RP-62 | Issam | CA | LTE_CA_B1_B3_B5-Perf | RP-141084 |

Notes:
- 1209: Inter-band CA 3DL / Impacted TSs and TRs: LTE
- 1210: RP#65 completed / Impacted TSs and TRs: 36.101, 36.104, 36.133, new generic TR 36.853 (3 Band CA with 1UL)
- 1211: RP#65 completed / Impacted TSs and TRs: 36.141, 36.307
- 1212: Inter-band CA 3DL / Impacted TSs and TRs: LTE
- 1213: RP#65 completed / Impacted TSs and TRs: 36.101, 36.104, 36.133, 36.141, 36.307, new generic TR 36.853 (3 Band CA with 1UL)
- 1214: RP#65 completed / Impacted TSs and TRs: 36.101, 36.104, 36.133, 36.141, 36.307
- 1215: Inter-band CA 3DL / Impacted TSs and TRs: LTE
- 1216: RP#65 completed. Updated WID RP-131653=>RP-141214 / Impacted TSs and TRs: 36.101, 36.104, 36.133, 36.141, 36.307, new generic TR 36.853 (3 Band CA with 1UL)
- 1217: RP#65 completed / Impacted TSs and TRs: 36.101, 36.104, 36.133, 36.141, 36.307
- 1218: Intra-band contig. CA 2DL/2UL / Impacted TSs and TRs: LTE
- 1219: RP#64 completed. TR 36.833-1-42v100 for 1-step Approval. Updated WID RP-132029=>RP-140728 / Impacted TSs and TRs: 36.101, 36.104, 36.133, new TR 36.833-1-42
- 1220: RP#64 completed. TR 36.833-1-42v100 for 1-step Approval. Updated WID RP-132029=>RP-140728 / Impacted TSs and TRs: 36.141, 36.307
- 1221: Intra-band contig. CA 2DL/2UL / Impacted TSs and TRs: LTE
- 1222: RP#64 completed / Impacted TSs and TRs: 36.101, 36.307
- 1223: RP#64 completed / Impacted TSs and TRs: 36.307
- 1224: Intra-band non-contig. CA 3DL / Impacted TSs and TRs: LTE
- 1225: RP#65 completed / Impacted TSs and TRs: 36.101, 36.104, 36.133, 36.307, new TR 36.833-6-xy
- 1226: CD:Thu 12/03/15->Sun 15/03/15; Compl:60%->70%; Stat Rep: RP-141084->RP-141732 1st Apr 15: Compl:70%->100% 1st Apr 15: Stat Rep: RP-141732->RP-150013 / Impacted TSs and TRs: 36.141
- 1227: Intra-band non-contig. CA 2DL / Impacted TSs and TRs: LTE
- 1228: RP#64 completed. Updated WID RP-140404=>RP-140671. TR 36.833-2-42v100 for 1-step Approval / Impacted TSs and TRs: 36.101, 36.104, 36.133, new TR 36.833-2-42
- 1229: RP#64 completed / Impacted TSs and TRs: 36.141, 36.307
- 1230: Inter-band CA 3DL / Impacted TSs and TRs: LTE
- 1231: RP#65 completed. Updated WID RP-132121=>RP-141454 / Impacted TSs and TRs: 36.101, 36.104, 36.133, new generic TR 36.853 (3 Band CA with 1UL)
- 1232: RP#65 completed. Updated WID RP-132121=>RP-141454 / Impacted TSs and TRs: 36.141, 36.307

| ID | WBS | Task | Duration | Start | Finish | Complete | Baseline start | Baseline finish | Baseline duration | Constraint | Resources | Work | Actual work | Acronym | PCG approved | WI rapporteur name | WI rapporteur e-mail | Release | TSG approved | MCC resp | Special Focus Doc | Acronym_3GU_Export | Status Report |
| --- | --- | --- | --- | --- | --- | --- | --- | --- | --- | --- | --- | --- | --- | --- | --- | --- | --- | --- | --- | --- | --- | --- | --- |
| 1233 | 262.76 | **LTE Advanced 3 Band Carrier Aggregation (3DL/1UL) for Band 1, Band 3 and Band 20** | 202d? | 2013-12-09 A | 2014-09-12 A | 100% | 2013-12-09 | 2014-09-12 | 201d? |  | R4 | 4832h | 4832h | LTE_CA_B1_B3_B20 | PCG-32 | Vodafone | luis.anaya@vodafone.com | Rel-12 | RP-62 | Issam | CA | LTE_CA_B1_B3_B20 |  |
| 1234 | 262.76.1 | Core part: LTE Advanced 3 Band Carrier Aggregation (3DL/1UL) for Band 1, Band 3 and Band 20 | 201d? | 2013-12-09 A | 2014-09-12 A | 100% | 2013-12-09 | 2014-09-12 | 201d? | finish no earlier than 2014-09-12 | R4 | 1608h | 1608h | LTE_CA_B1_B3_B20-Core | PCG-32 | Vodafone | luis.anaya@vodafone.com | Rel-12 | RP-62 | Issam | CA | LTE_CA_B1_B3_B20-Core | RP-141084 |
| 1235 | 262.76.2 | Perf. part: LTE Advanced 3 Band Carrier Aggregation (3DL/1UL) for Band 1, Band 3 and Band 20 | 201d? | 2013-12-10 A | 2014-09-12 A | 100% | 2013-12-09 | 2014-09-12 | 201d? | finish no earlier than 2014-09-12 | R4 | 1608h | 1608h | LTE_CA_B1_B3_B20-Perf | PCG-32 | Vodafone | luis.anaya@vodafone.com | Rel-12 | RP-62 | Issam | CA | LTE_CA_B1_B3_B20-Perf | RP-141084 |
| 1236 | 262.77 | **LTE Advanced 3 Band Carrier Aggregation (3DL/1UL) for Band 1, Band 7 and Band 20** | 202d? | 2013-12-09 A | 2014-09-12 A | 100% | 2013-12-09 | 2014-09-12 | 201d? |  | R4 | 4832h | 4832h | LTE_CA_B1_B7_B20 | PCG-32 | Vodafone | luis.anaya@vodafone.com | Rel-12 | RP-62 | Issam | CA | LTE_CA_B1_B7_B20 |  |
| 1237 | 262.77.1 | Core part: LTE Advanced 3 Band Carrier Aggregation (3DL/1UL) for Band 1, Band 7 and Band 20 | 201d? | 2013-12-09 A | 2014-09-12 A | 100% | 2013-12-09 | 2014-09-12 | 201d? | finish no earlier than 2014-09-12 | R4 | 1608h | 1608h | LTE_CA_B1_B7_B20-Core | PCG-32 | Vodafone | luis.anaya@vodafone.com | Rel-12 | RP-62 | Issam | CA | LTE_CA_B1_B7_B20-Core | RP-141084 |
| 1238 | 262.77.2 | Perf. part: LTE Advanced 3 Band Carrier Aggregation (3DL/1UL) for Band 1, Band 7 and Band 20 | 201d? | 2013-12-10 A | 2014-09-12 A | 100% | 2013-12-09 | 2014-09-12 | 201d? | finish no earlier than 2014-09-12 | R4 | 1608h | 1608h | LTE_CA_B1_B7_B20-Perf | PCG-32 | Vodafone | luis.anaya@vodafone.com | Rel-12 | RP-62 | Issam | CA | LTE_CA_B1_B7_B20-Perf | RP-141084 |
| 1239 | 262.78 | **LTE Advanced 3 Band Carrier Aggregation (3DL/1UL) for Band 7, Band 8 and Band 20** | 270d? | 2013-12-09 A | 2014-12-15 A | 100% | 2013-12-09 | 2014-09-12 | 201d? |  | R4 | 6432h | 6432h | LTE_CA_B7_B8_B20 | PCG-32 | Vodafone | luis.anaya@vodafone.com | Rel-12 | RP-62 | Issam | CA | LTE_CA_B7_B8_B20 |  |
| 1240 | 262.78.1 | Core part: LTE Advanced 3 Band Carrier Aggregation (3DL/1UL) for Band 7, Band 8 and Band 20 | 267d? | 2013-12-09 A | 2014-12-15 A | 100% | 2013-12-09 | 2014-09-12 | 201d? | finish no earlier than 2014-12-15 | R4 | 2136h | 2136h | LTE_CA_B7_B8_B20-Core | PCG-32 | Vodafone | luis.anaya@vodafone.com | Rel-12 | RP-62 | Issam | CA | LTE_CA_B7_B8_B20-Core | RP-141732 |
| 1241 | 262.78.2 | Perf. part: LTE Advanced 3 Band Carrier Aggregation (3DL/1UL) for Band 7, Band 8 and Band 20 | 267d? | 2013-12-12 A | 2014-12-15 A | 100% | 2013-12-09 | 2014-09-12 | 201d? | finish no earlier than 2014-12-15 | R4 | 2136h | 2136h | LTE_CA_B7_B8_B20-Perf | PCG-32 | Vodafone | luis.anaya@vodafone.com | Rel-12 | RP-62 | Issam | CA | LTE_CA_B7_B8_B20-Perf | RP-141732 |
| 1242 | 262.79 | **Additional bandwidth combinations for LTE Advanced inter-band Carrier Aggregation of Band 2 and Band 29 and of Band 4 and Band 29** | 4d? | 2014-03-03 A | 2014-03-06 A | 100% | 2014-03-03 | 2014-03-06 | 4d? |  | R4 | 64h | 64h | LTE_DL_FDD700_B29_Bwset | PCG-32 | AT&T | marc.grant@att.com | Rel-12 | RP-63 | Issam | CA | LTE_DL_FDD700_B29_Bwset |  |
| 1243 | 262.79.1 | Core part: Additional bandwidth combinations for LTE Advanced inter-band Carrier Aggregation of Band 2 and Band 29 and of Band 4 and Band 29 | 4d? | 2014-03-03 A | 2014-03-06 A | 100% | 2014-03-03 | 2014-03-06 | 4d? | finish no earlier than 2014-03-06 | R4 | 32h | 32h | LTE_DL_FDD700_B29_BWset-Core | PCG-32 | AT&T | marc.grant@att.com | Rel-12 | RP-63 | Issam | CA | LTE_DL_FDD700_B29_BWset-Core | RP-140428 |
| 1244 | 262.80 | **Additional bandwidth combination set for LTE Advanced inter-band Carrier Aggregation of Band 3 and Band 20** | 72d? | 2014-03-06 A | 2014-06-13 A | 100% | 2014-03-06 | 2014-06-13 | 72d? |  | R4 | 1152h | 1152h | LTE_CA_B3_B20_BWset | PCG-32 | NSN | iwajlo.angelow@nsn.com | Rel-12 | RP-63 | Issam | CA | LTE_CA_B3_B20_BWset |  |
| 1245 | 262.80.1 | Core part: Additional bandwidth combination set for LTE Advanced inter-band Carrier Aggregation of Band 3 and Band 20 | 72d? | 2014-03-06 A | 2014-06-13 A | 100% | 2014-03-06 | 2014-06-13 | 72d? | finish no earlier than 2014-06-13 | R4 | 576h | 576h | LTE_CA_B3_B20_BWset-Core | PCG-32 | NSN | iwajlo.angelow@nsn.com | Rel-12 | RP-63 | Issam | CA | LTE_CA_B3_B20_BWset-Core | RP-140569 |
| 1246 | 262.81 | **Additional bandwidth combination set for LTE Advanced inter-band Carrier Aggregation of Band 7 and Band 20** | 72d? | 2014-03-06 A | 2014-06-13 A | 100% | 2014-03-06 | 2014-06-13 | 72d? |  | R4 | 1152h | 1152h | LTE_CA_B7_B20_BWset | PCG-32 | NSN | iwajlo.angelow@nsn.com | Rel-12 | RP-63 | Issam | CA | LTE_CA_B7_B20_BWset |  |
| 1247 | 262.81.1 | Core part: Additional bandwidth combination set for LTE Advanced inter-band Carrier Aggregation of Band 7 and Band 20 | 72d? | 2014-03-06 A | 2014-06-13 A | 100% | 2014-03-06 | 2014-06-13 | 72d? | finish no earlier than 2014-06-13 | R4 | 576h | 576h | LTE_CA_B7_B20_BWset-Core | PCG-32 | NSN | iwajlo.angelow@nsn.com | Rel-12 | RP-63 | Issam | CA | LTE_CA_B7_B20_BWset-Core | RP-140569 |
| 1248 | 262.82 | **Additional bandwidth combinations for LTE Advanced inter-band Carrier Aggregation to support 3DL fallback** | 72d? | 2014-03-06 A | 2014-06-13 A | 100% | 2014-03-06 | 2014-06-13 | 72d? |  | R4 | 1152h | 1152h | LTE_CA_3DL_FB_BW | PCG-32 | Qualcomm | Fong Gene (gfong@qti.qualcomm.com) | Rel-12 | RP-63 | Issam | CA | LTE_CA_3DL_FB_BW |  |
| 1249 | 262.82.1 | Core part: Additional bandwidth combinations for LTE Advanced inter-band Carrier Aggregation to support 3DL fallback | 72d? | 2014-03-06 A | 2014-06-13 A | 100% | 2014-03-06 | 2014-06-13 | 72d? | finish no earlier than 2014-06-13 | R4 | 576h | 576h | LTE_CA_3DL_FB_BW-Core | PCG-32 | Qualcomm | Fong Gene (gfong@qti.qualcomm.com) | Rel-12 | RP-63 | Issam | CA | LTE_CA_3DL_FB_BW-Core | RP-140569 |
| 1250 | 262.83 | **LTE Advanced 3 Band Carrier Aggregation (3DL/1UL) of Band 3, Band 7 and Band 7** | 138d? | 2014-03-06 A | 2014-09-12 A | 100% | 2014-03-06 | 2014-09-12 | 137d? |  | R4 | 3296h | 3296h | LTE_CA_B3_B7_B7 | PCG-32 | Nokia Networks | iwajlo.angelow@nsn.com | Rel-12 | RP-63 | Issam | CA | LTE_CA_B3_B7_B7 |  |
| 1251 | 262.83.1 | Core part: LTE Advanced 3 Band Carrier Aggregation (3DL/1UL) of Band 3, Band 7 and Band 7 | 137d? | 2014-03-06 A | 2014-09-12 A | 100% | 2014-03-06 | 2014-09-12 | 137d? | finish no earlier than 2014-09-12 | R4 | 1096h | 1096h | LTE_CA_B3_B7_B7-Core | PCG-32 | Nokia Networks | iwajlo.angelow@nsn.com | Rel-12 | RP-63 | Issam | CA | LTE_CA_B3_B7_B7-Core | RP-141084 |
| 1252 | 262.83.2 | Perf. part: LTE Advanced 3 Band Carrier Aggregation (3DL/1UL) of Band 3, Band 7 and Band 7 | 137d? | 2014-03-06 A | 2014-09-12 A | 100% | 2014-03-06 | 2014-09-12 | 137d? | finish no earlier than 2014-09-12 | R4 | 1096h | 1096h | LTE_CA_B3_B7_B7-Perf | PCG-32 | Nokia Networks | iwajlo.angelow@nsn.com | Rel-12 | RP-63 | Issam | CA | LTE_CA_B3_B7_B7-Perf | RP-141084 |
| 1253 | 262.84 | **LTE Advanced 3 Band Carrier Aggregation (3DL/1UL) of Band 1, Band 19 and Band 21** | 138d? | 2014-03-06 A | 2014-09-12 A | 100% | 2014-03-06 | 2014-09-12 | 137d? |  | R4 | 3296h | 3296h | LTE_CA_B1_B19_B21 | PCG-32 | NTT DOCOMO | teruaki.toeda.zf@nttdocomo.com | Rel-12 | RP-63 | Issam | CA | LTE_CA_B1_B19_B21 |  |
| 1254 | 262.84.1 | Core part: LTE Advanced 3 Band Carrier Aggregation (3DL/1UL) of Band 1, Band 19 and Band 21 | 137d? | 2014-03-06 A | 2014-09-12 A | 100% | 2014-03-06 | 2014-09-12 | 137d? | finish no earlier than 2014-09-12 | R4 | 1096h | 1096h | LTE_CA_B1_B19_B21-Core | PCG-32 | NTT DOCOMO | teruaki.toeda.zf@nttdocomo.com | Rel-12 | RP-63 | Issam | CA | LTE_CA_B1_B19_B21-Core | RP-141084 |
| 1255 | 262.84.2 | Perf. part: LTE Advanced 3 Band Carrier Aggregation (3DL/1UL) of Band 1, Band 19 and Band 21 | 137d? | 2014-03-06 A | 2014-09-12 A | 100% | 2014-03-06 | 2014-09-12 | 137d? | finish no earlier than 2014-09-12 | R4 | 1096h | 1096h | LTE_CA_B1_B19_B21-Perf | PCG-32 | NTT DOCOMO | teruaki.toeda.zf@nttdocomo.com | Rel-12 | RP-63 | Issam | CA | LTE_CA_B1_B19_B21-Perf | RP-141084 |
| 1256 | 262.85 | **LTE Advanced 3 Band Carrier Aggregation (3DL/1UL) of Band 3, Band 3 and Band 7** | 138d? | 2014-03-06 A | 2014-09-12 A | 100% | 2014-03-06 | 2014-09-12 | 137d? |  | R4 | 3296h | 3296h | LTE_CA_B3_B3_B7 | PCG-32 | TeliaSonera | Ralf.Schuh@TeliaSonera.com | Rel-12 | RP-63 | Issam | CA | LTE_CA_B3_B3_B7 |  |
| 1257 | 262.85.1 | Core part: LTE-Advanced 3 Band Carrier Aggregation (3DL/1UL) of Band 3, Band 3 and Band 7 | 137d? | 2014-03-06 A | 2014-09-12 A | 100% | 2014-03-06 | 2014-09-12 | 137d? | finish no earlier than 2014-09-12 | R4 | 1096h | 1096h | LTE_CA_B3_B3_B7-Core | PCG-32 | TeliaSonera | Ralf.Schuh@TeliaSonera.com | Rel-12 | RP-63 | Issam | CA | LTE_CA_B3_B3_B7-Core | RP-141084 |
| 1258 | 262.85.2 | Perf. part: LTE-Advanced 3 Band Carrier Aggregation (3DL/1UL) of Band 3, Band 3 and Band 7 | 137d? | 2014-03-06 A | 2014-09-12 A | 100% | 2014-03-06 | 2014-09-12 | 137d? | finish no earlier than 2014-09-12 | R4 | 1096h | 1096h | LTE_CA_B3_B3_B7-Perf | PCG-32 | TeliaSonera | Ralf.Schuh@TeliaSonera.com | Rel-12 | RP-63 | Issam | CA | LTE_CA_B3_B3_B7-Perf | RP-141084 |

Notes:
- 1233: Inter-band CA 3DL / Impacted TSs and TRs: LTE
- 1234: RP#65 completed. Updated WID RP-141017=>RP-141222 / Impacted TSs and TRs: 36.101, 36.104, 36.133, new generic TR 36.851 (2 Band CA with 1UL), TR 36.853 (3 Band CA with 1UL)
- 1235: RP#65 completed / Impacted TSs and TRs: 36.101, 36.133, 36.141, 36.307
- 1236: Inter-band CA 3DL / Impacted TSs and TRs: LTE
- 1237: RP#65 completed. Updated WID RP-140243=>RP-141223 / Impacted TSs and TRs: 36.101, 36.104, 36.133, new generic TR 36.853 (3 Band CA with 1UL), TR 36.851 (2 Band CA with 1UL)
- 1238: RP#65 completed / Impacted TSs and TRs: 36.101, 36.133, 36.141, 36.307
- 1239: Inter-band CA 3DL / Impacted TSs and TRs: LTE
- 1240: CD:Thu 11/12/14->Mon 15/12/14; Compl:85%->100%; Stat Rep: RP-141084->RP-141732 / Impacted TSs and TRs: 36.101, 36.104, 36.133, new generic TR 36.853 (3 Band CA with 1UL), TR 36.851 (2 Band CA with 1UL)
- 1241: CD:Thu 11/12/14->Mon 15/12/14; Compl:0%->100%; Stat Rep: RP-141084->RP-141732 / Impacted TSs and TRs: 36.101, 36.133, 36.141, 36.307
- 1242: Inter-band 2DL/1UL / Impacted TSs and TRs: LTE
- 1243: RP#63 approved WI (no Perf. Part) & completed. Rel-10 and Rel-11 versions of 36.307 affected / Impacted TSs and TRs: 36.101, 36.307
- 1244: Inter-band CA 2DL / Impacted TSs and TRs: LTE
- 1245: RP#64 completed / Impacted TSs and TRs: 36.101, TR 36.851
- 1246: Inter-band CA 2DL / Impacted TSs and TRs: LTE
- 1247: RP#64 completed / Impacted TSs and TRs: 36.101, TR 36.851
- 1248: Inter-band CA 2DL / Impacted TSs and TRs: LTE
- 1249: RP#64 completed, Additional BW combinations added for 6 Wis: 3 open Rel-12 Wis (B1_B5_B7, B2_B29_B30, B4_B29_B30) and 3 completed Rel-11 Wis (B3_B5, B4_B5, B4_B12) / Impacted TSs and TRs: 36.101, 36.307
- 1250: Inter-band CA 3DL. Mar15: acronym reverted to LTE_CA_B3_B7_B7_ / Impacted TSs and TRs: LTE
- 1251: RP#65 completed. Updated WID RP-140095=>RP-141196. Mar15: acronym reverted to LTE_CA_B3_B7_B7-Core_ / Impacted TSs and TRs: 36.101, 36.104, 36.133, new generic TR 36.853 (3 Band CA with 1UL)
- 1252: RP#65 completed. Updated WID RP-140095=>RP-141196. Mar15: acronym reverted from LTE_CA_B3_B7_B7-Perf_ / Impacted TSs and TRs: 36.141, 36.307
- 1253: Inter-band CA 3DL / Impacted TSs and TRs: LTE
- 1254: RP#65 completed. Updated WID RP-140106=>RP-141193 / Impacted TSs and TRs: 36.101, 36.104, 36.133, new generic TR 36.853 (3 Band CA with 1UL)
- 1255: RP#65 completed. Updated WID RP-140106=>RP-141193 / Impacted TSs and TRs: 36.141, 36.307
- 1256: Inter-band CA 3DL / Impacted TSs and TRs: LTE
- 1257: RP#65 completed. Updated RP-140390=>RP-141126 / Impacted TSs and TRs: 36.101, 36.104, 36.133, new generic TR 36.853 (3 Band CA with 1UL)
- 1258: RP#65 completed. Updated RP-140390=>RP-141126 / Impacted TSs and TRs: 36.141, 36.307

| ID | WBS | Task | Duration | Start | Finish | Complete | Remaining | Baseline start | Baseline finish | Baseline duration | Total slack | Constraint | Resources | Work | Actual work | Acronym | PCG approved | WI rapporteur name | WI rapporteur e-mail | Release | TSG approved | MCC resp | Special Focus Doc | Acronym_3GU_Export | Status Report | PCG stopped | TSG stopped |
| --- | --- | --- | --- | --- | --- | --- | --- | --- | --- | --- | --- | --- | --- | --- | --- | --- | --- | --- | --- | --- | --- | --- | --- | --- | --- | --- | --- |
| 1259 | 262.86 | **LTE Advanced intra-band contiguous Carrier Aggregation in Band 40 for 3DL** | 72d? | 2014-03-06 A | 2014-06-13 A | 100% |  | 2014-03-06 | 2014-06-13 | 72d? |  |  | R4 | 1728h | 1728h | LTE_CA_C_B40_3DL | PCG-32 | China Mobile | Pan Qun (panqun@chinamobile.com) | Rel-12 | RP-63 | Issam | CA | LTE_CA_C_B40_3DL |  |  |  |
| 1260 | 262.86.1 | Core part: LTE Advanced intra-band contiguous Carrier Aggregation in Band 40 for 3DL | 72d? | 2014-03-06 A | 2014-06-13 A | 100% |  | 2014-03-06 | 2014-06-13 | 72d? |  | finish no earlier than 2014-06-13 | R4 | 576h | 576h | LTE_CA_C_B40_3DL-Core | PCG-32 | China Mobile | Pan Qun (panqun@chinamobile.com) | Rel-12 | RP-63 | Issam | CA | LTE_CA_C_B40_3DL-Core | RP-140569 |  |  |
| 1261 | 262.86.2 | Perf. part: LTE Advanced intra-band contiguous Carrier Aggregation in Band 40 for 3DL | 72d? | 2014-03-06 A | 2014-06-13 A | 100% |  | 2014-03-06 | 2014-06-13 | 72d? |  | finish no earlier than 2014-06-13 | R4 | 576h | 576h | LTE_CA_C_B40_3DL-Perf | PCG-32 | China Mobile | Pan Qun (panqun@chinamobile.com) | Rel-12 | RP-63 | Issam | CA | LTE_CA_C_B40_3DL-Perf | RP-140569 |  |  |
| 1262 | 262.87 | **Additional bandwidth combination set for LTE Advanced inter-band Carrier Aggregation of Band 4 and Band 12** | 137d? | 2014-03-07 A | 2014-09-12 A | 100% |  | 2014-03-06 | 2014-12-05 | 197d? |  |  | R4 | 3288h | 3288h | LTE_CA_B4_B12_BWset | PCG-32 | T-Mobile USA | nelson.ueng@t-mobile.com | Rel-12 | RP-63 | Issam | CA | LTE_CA_B4_B12_BWset |  |  |  |
| 1263 | 262.87.1 | Core part: Additional bandwidth combination set for LTE Advanced inter-band Carrier Aggregation of Band 4 and Band 12 | 137d? | 2014-03-07 A | 2014-09-12 A | 100% |  | 2014-03-06 | 2014-12-05 | 197d? |  | finish no earlier than 2014-09-12 | R4 | 1096h | 1096h | LTE_CA_B4_B12_BWset-Core | PCG-32 | T-Mobile USA | nelson.ueng@t-mobile.com | Rel-12 | RP-63 | Issam | CA | LTE_CA_B4_B12_BWset-Core | RP-141084 |  |  |
| 1264 | 262.87.2 | Deleted - Perf. part: Additional bandwidth combination set for LTE Advanced inter-band Carrier Aggregation of Band 4 and Band 12 | 137d? | 2014-03-07 A | 2014-09-12 A | 100% |  | 2014-03-06 | 2014-12-05 | 197d? |  | finish no earlier than 2014-09-12 | R4 | 1096h | 1096h | LTE_CA_B4_B12_BWset-Perf | PCG-32 | T-Mobile USA | nelson.ueng@t-mobile.com | Rel-12 | RP-63 | Issam | CA | LTE_CA_B4_B12_BWset-Perf | RP-141084 | PCG-33 | RP-65 |
| 1265 | 262.88 | **LTE Advanced inter-band Carrier Aggregation of Band 41 and Band 42** | 138d? | 2014-03-06 A | 2014-09-12 A | 100% |  | 2014-03-06 | 2014-09-12 | 137d? |  |  | R4 | 2776h | 2776h | LTE_CA_B41_B42 | PCG-32 | Huawei | leo.liuye@huawei.com | Rel-12 | RP-63 | Issam | CA | LTE_CA_B41_B42 |  |  |  |
| 1266 | 262.88.1 | Core part: LTE Advanced inter-band Carrier Aggregation of Band 41 and Band 42 | 72d? | 2014-03-06 A | 2014-09-12 A | 100% |  | 2014-03-06 | 2014-09-12 | 72d? |  | finish no earlier than 2014-09-12 | R4 | 576h | 576h | LTE_CA_B41_B42-Core | PCG-32 | Huawei | leo.liuye@huawei.com | Rel-12 | RP-63 | Issam | CA | LTE_CA_B41_B42-Core | RP-141084 |  |  |
| 1267 | 262.88.2 | Perf. Part: LTE Advanced inter-band Carrier Aggregation of Band 41 and Band 42 | 137d? | 2014-03-07 A | 2014-09-12 A | 100% |  | 2014-03-06 | 2014-09-12 | 137d? |  | finish no earlier than 2014-09-12 | R4 | 1096h | 1096h | LTE_CA_B41_B42-Perf | PCG-32 | Huawei | leo.liuye@huawei.com | Rel-12 | RP-63 | Issam | CA | LTE_CA_B41_B42-Perf | RP-141084 |  |  |
| 1268 | 262.89 | **LTE Advanced 3 Band Carrier Aggregation (3DL/1UL) of Band 4, Band 4, and Band 12** | 138d? | 2014-03-06 A | 2014-09-12 A | 100% |  | 2014-03-06 | 2014-12-05 | 197d? |  |  | R4 | 3296h | 3296h | LTE_CA_B4_B4_B12 | PCG-32 | T-Mobile USA | nelson.ueng@t-mobile.com | Rel-12 | RP-63 | Issam | CA | LTE_CA_B4_B4_B12 |  |  |  |
| 1269 | 262.89.1 | Core part: LTE Advanced 3 Band Carrier Aggregation (3DL/1UL) of Band 4, Band 4, and Band 12 | 137d? | 2014-03-06 A | 2014-09-12 A | 100% |  | 2014-03-06 | 2014-12-05 | 197d? |  | finish no earlier than 2014-09-12 | R4 | 1096h | 1096h | LTE_CA_B4_B4_B12-Core | PCG-32 | T-Mobile USA | nelson.ueng@t-mobile.com | Rel-12 | RP-63 | Issam | CA | LTE_CA_B4_B4_B12-Core | RP-141084 |  |  |
| 1270 | 262.89.2 | Perf. part: LTE Advanced 3 Band Carrier Aggregation (3DL/1UL) of Band 4, Band 4, and Band 12 | 137d? | 2014-03-07 A | 2014-09-12 A | 100% |  | 2014-03-06 | 2014-12-05 | 197d? |  | finish no earlier than 2014-09-12 | R4 | 1096h | 1096h | LTE_CA_B4_B4_B12-Perf | PCG-32 | T-Mobile USA | nelson.ueng@t-mobile.com | Rel-12 | RP-63 | Issam | CA | LTE_CA_B4_B4_B12-Perf | RP-141084 |  |  |
| 1271 | 262.90 | **LTE Advanced 3 Band Carrier Aggregation (3DL/1UL) of Band 2, Band 4, and Band 4** | 138d? | 2014-03-06 A | 2014-09-12 A | 100% |  | 2014-03-06 | 2014-12-05 | 197d? |  |  | R4 | 3296h | 3296h | LTE_CA_B2_B4_B4 | PCG-32 | T-Mobile USA | nelson.ueng@T-Mobile.com | Rel-12 | RP-63 | Issam | CA | LTE_CA_B2_B4_B4 |  |  |  |
| 1272 | 262.90.1 | Core part: LTE Advanced 3 Band Carrier Aggregation (3DL/1UL) of Band 2, Band 4, and Band 4 | 137d? | 2014-03-06 A | 2014-09-12 A | 100% |  | 2014-03-06 | 2014-12-05 | 197d? |  | finish no earlier than 2014-09-12 | R4 | 1096h | 1096h | LTE_CA_B2_B4_B4-Core | PCG-32 | T-Mobile USA | nelson.ueng@T-Mobile.com | Rel-12 | RP-63 | Issam | CA | LTE_CA_B2_B4_B4-Core | RP-141084 |  |  |
| 1273 | 262.90.2 | Perf. part: LTE Advanced 3 Band Carrier Aggregation (3DL/1UL) of Band 2, Band 4, and Band 4 | 137d? | 2014-03-07 A | 2014-09-12 A | 100% |  | 2014-03-06 | 2014-12-05 | 197d? |  | finish no earlier than 2014-09-12 | R4 | 1096h | 1096h | LTE_CA_B2_B4_B4-Perf | PCG-32 | T-Mobile USA | nelson.ueng@T-Mobile.com | Rel-12 | RP-63 | Issam | CA | LTE_CA_B2_B4_B4-Perf | RP-141084 |  |  |
| 1274 | 262.91 | **Additional bandwidth combinations for LTE Advanced intra-band non-contiguous Carrier Aggregation in Band 25** | 138d? | 2014-03-06 A | 2014-09-12 A | 100% |  | 2014-03-06 | 2014-09-12 | 137d? |  |  | R4 | 3296h | 3296h | LTE_CA_NC_B25_BWset | PCG-32 | Huawei | Liu Liehai (liuliehai@huawei.com) | Rel-12 | RP-63 | Issam | CA | LTE_CA_NC_B25_BWset |  |  |  |
| 1275 | 262.91.1 | Core part: Additional bandwidth combinations for LTE Advanced intra-band non-contiguous Carrier Aggregation in Band 25 | 137d? | 2014-03-06 A | 2014-09-12 A | 100% |  | 2014-03-06 | 2014-09-12 | 137d? |  | finish no earlier than 2014-09-12 | R4 | 1096h | 1096h | LTE_CA_NC_B25_BWset-Core | PCG-32 | Huawei | Liu Liehai (liuliehai@huawei.com) | Rel-12 | RP-63 | Issam | CA | LTE_CA_NC_B25_BWset-Core | RP-141084 |  |  |
| 1276 | 262.91.2 | Perf. part: Additional bandwidth combinations for LTE Advanced intra-band non-contiguous Carrier Aggregation in Band 25 | 137d? | 2014-03-07 A | 2014-09-12 A | 100% |  | 2014-03-06 | 2014-09-12 | 137d? |  | finish no earlier than 2014-09-12 | R4 | 1096h | 1096h | LTE_CA_NC_B25_BWset-Perf | PCG-32 | Huawei | Liu Liehai (liuliehai@huawei.com) | Rel-12 | RP-63 | Issam | CA | LTE_CA_NC_B25_BWset-Perf | RP-141084 |  |  |
| 1277 | 262.92 | **Additional bandwidth combination set for LTE Advanced inter-band Carrier Aggregation of Band 2 and Band 4** | 66d? | 2014-06-15 A | 2014-09-15 A | 100% |  | 2014-06-13 | 2014-09-12 | 66d? |  |  | R4 | 1056h | 1056h | LTE_CA_B2_B4_Bwset2 | PCG-33 | T-Mobile USA | nelson.ueng@T-Mobile.com | Rel-12 | RP-64 |  | CA | LTE_CA_B2_B4_BWset |  |  |  |
| 1278 | 262.92.1 | Core part: Additional bandwidth combination set 2 for LTE Advanced inter-band Carrier Aggregation of Band 2 and Band 4 | 66d? | 2014-06-15 A | 2014-09-15 A | 100% |  | 2014-06-13 | 2014-09-12 | 66d? |  | finish no earlier than 2014-09-15 | R4 | 528h | 528h | LTE_CA_B2_B4_BWset2-Core | PCG-33 | T-Mobile USA | nelson.ueng@T-Mobile.com | Rel-12 | RP-64 |  | CA | LTE_CA_B2_B4_BWset-Core | RP-141084 |  |  |
| 1279 | 262.93 | **Additional bandwidth combination set for LTE Advanced inter-band Carrier Aggregation of Band 2 and Band 5** | 132d? | 2014-06-18 A | 2014-12-15 | 50% | 66d? | 2014-06-13 | 2014-09-12 | 66d? | 653d |  | R4 | 3168h | 1584h | LTE_CA_B2_B5_BWset | PCG-33 | AT&T | marc.grant@att.com | Rel-12 | RP-64 |  | CA | LTE_CA_B2_B5_BWset |  |  |  |
| 1280 | 262.93.1 | Core part: Additional bandwidth combination set for LTE Advanced inter-band Carrier Aggregation of Band 2 and Band 5 | 132d? | 2014-06-18 A | 2014-12-15 A | 100% |  | 2014-06-13 | 2014-09-12 | 66d? |  | finish no earlier than 2014-12-15 | R4 | 1056h | 1056h | LTE_CA_B2_B5_Bwset-Core | PCG-33 | AT&T | marc.grant@att.com | Rel-12 | RP-64 |  | CA | LTE_CA_B2_B5_Bwset-Core | RP-141732 |  |  |
| 1281 | 262.93.2 | Perf. Part: Additional bandwidth combination set for LTE Advanced inter-band Carrier Aggregation of Band 2 and Band 5 | 132d? | 2014-06-18 | 2014-12-15 |  |  | 2014-06-13 | 2014-09-12 | 66d? | 653d | finish no earlier than 2014-12-15 | R4 | 1056h |  | LTE_CA_B2_B5_BWset-Perf | PCG-33 | AT&T | marc.grant@att.com | Rel-12 | RP-64 |  | CA | LTE_CA_B2_B5_BWset-Perf | RP-141732 |  |  |
| 1282 | 262.94 | **E-UTRA UE demodulation/Channel State Information (CSI) performance requirements for multiple Carrier Aggregation configurations** | 198d? | 2014-06-16 A | 2015-03-15 A | 100% |  | 2014-06-13 | 2015-03-13 | 196d? |  |  | R4 | 3152h | 3152h | LTE_CA_Mult | PCG-33 | China Mobile | Zhang Xiaoran (zhangxiaoran@chinamobile.com) | Rel-12 | RP-64 |  | CA | LTE_CA_Mult |  |  |  |
| 1283 | 262.94.1 | Perf. Part: E-UTRA UE demodulation/Channel State Information (CSI) performance requirements for multiple Carrier Aggregation configurations | 196d? | 2014-06-16 A | 2015-03-15 A | 100% |  | 2014-06-13 | 2015-03-13 | 196d? |  | finish no earlier than 2015-03-15 | R4 | 1568h | 1568h | LTE_CA_Mult-Perf | PCG-33 | China Mobile | Zhang Xiaoran (zhangxiaoran@chinamobile.com) | Rel-12 | RP-64 |  | CA | LTE_CA_Mult-Perf | RP-150188 |  |  |

Notes:
- 1259: Intra-band contig. CA 3DL / Impacted TSs and TRs: LTE
- 1260: RP#64 completed. Updated WID RP-140453=>RP-140948 / Impacted TSs and TRs: 36.101, 36.104, 36.133, New TR 36.833-5-40
- 1261: RP#64 completed. Updated WID RP-140453=>RP-140948 / Impacted TSs and TRs: 36.141, 36.307
- 1262: Inter-band CA 2DL / Impacted TSs and TRs: LTE
- 1263: RP#65 completed. Updated WID RP-140987=>RP-141235 (removed Perf. Part) / Impacted TSs and TRs: 36.101, generic TR 36.850
- 1264: RP#65 stopped. Updated WID RP-140987=>RP-141235 (removed Perf. Part) / Impacted TSs and TRs: 36.307
- 1265: Inter-band CA 2DL / Impacted TSs and TRs: LTE
- 1266: RP#65 completed / Impacted TSs and TRs: 36.101, 36.104, TR 36.851
- 1267: RP#65 completed / Impacted TSs and TRs: 36.141
- 1268: Inter-band CA 3DL / Impacted TSs and TRs: LTE
- 1269: RP#65 completed. Updated WID RP-140116=>RP-141709 / Impacted TSs and TRs: 36.101, 36.104, 36.133, 36.141, 36.307, generic TR 36.853 (3 Band CA with 1UL)
- 1270: RP#65 completed / Impacted TSs and TRs: 36.101, 36.104, 36.133, 36.141, 36.307
- 1271: Inter-band CA 3DL / Impacted TSs and TRs: LTE
- 1272: RP#65 completed. Updated WID RP-140117=>RP-141236 / Impacted TSs and TRs: 36.101, 36.104, 36.133, 36.141, 36.307, generic TR 36.853 (3 Band CA with 1UL)
- 1273: RP#65 completed / Impacted TSs and TRs: 36.101, 36.104, 36.133, 36.141, 36.307
- 1274: Intra-band non-contig. CA 2DL / Impacted TSs and TRs: LTE
- 1275: RP#65 completed / Impacted TSs and TRs: 36.101, 36.307, TR 36.833-2-25
- 1276: RP#65 completed / Impacted TSs and TRs: 36.307
- 1277: Inter-band CA 2DL. Mar 15: acronym changed from LTE_CA_B2_B4_Bwset_ / Impacted TSs and TRs: LTE
- 1278: Dec 14: Prev CD:Fri 12/09/14; Prev %:100%, title changed. Mar 15: Acronym changed to LTE_CA_B2_B4_BWset2-Core_ / Impacted TSs and TRs: 36.101, 36.851
- 1279: 2DL/1UL / Impacted TSs and TRs: LTE
- 1280: ; WID: RP-142043->RP-141803; Stat Rep: RP-141084->RP-141732 / Impacted TSs and TRs: 36.101, 36.851
- 1281: CD:Thu 11/12/14->Mon 15/12/14; Compl:0%->0%; Stat Rep: RP-141084->RP-141732 / Impacted TSs and TRs: 36.307
- 1282: LTE / Impacted TSs and TRs: LTE
- 1283: CD:Thu 12/03/15->Sun 15/03/15; Compl:10%->90%; Stat Rep: RP-141303->RP-141839 1st Apr 15: Compl:90%->100% 1st Apr 15: Stat Rep: RP-141839->RP-150188 / Impacted TSs and TRs: 36.101

| ID | WBS | Task | Duration | Start | Finish | Complete | Remaining | Baseline start | Baseline finish | Baseline duration | Total slack | Constraint | Resources | Work | Actual work | Acronym | PCG approved | WI rapporteur name | WI rapporteur e-mail | Release | TSG approved | Special Focus Doc | Acronym_3GU_Export | Status Report | MCC resp |
| --- | --- | --- | --- | --- | --- | --- | --- | --- | --- | --- | --- | --- | --- | --- | --- | --- | --- | --- | --- | --- | --- | --- | --- | --- | --- |
| 1284 | 262.95 | **LTE Advanced 3 Band Carrier Aggregation (3DL/1UL) of Band 1, Band 3 and Band 19** | 66d? | 2014-06-16 A | 2014-09-12 A | 100% |  | 2014-06-13 | 2014-09-12 | 66d? |  |  | R4 | 1584h | 1584h | LTE_CA_B1_B3_B19 | PCG-33 | NTT DOCOMO | teruaki.toeda.zf@nttdocomo.com | Rel-12 | RP-64 | CA | LTE_CA_B1_B3_B19 |  |  |
| 1285 | 262.95.1 | Core part: LTE Advanced 3 Band Carrier Aggregation (3DL/1UL) of Band 1, Band 3 and Band 19 | 66d? | 2014-06-16 A | 2014-09-12 A | 100% |  | 2014-06-13 | 2014-09-12 | 66d? |  | finish no earlier than 2014-09-12 | R4 | 528h | 528h | LTE_CA_B1_B3_B19-Core | PCG-33 | NTT DOCOMO | teruaki.toeda.zf@nttdocomo.com | Rel-12 | RP-64 | CA | LTE_CA_B1_B3_B19-Core | RP-141084 |  |
| 1286 | 262.95.2 | Perf. Part: LTE Advanced 3 Band Carrier Aggregation (3DL/1UL) of Band 1, Band 3 and Band 19 | 66d? | 2014-06-16 A | 2014-09-12 A | 100% |  | 2014-06-13 | 2014-09-12 | 66d? |  | finish no earlier than 2014-09-12 | R4 | 528h | 528h | LTE_CA_B1_B3_B19-Perf | PCG-33 | NTT DOCOMO | teruaki.toeda.zf@nttdocomo.com | Rel-12 | RP-64 | CA | LTE_CA_B1_B3_B19-Perf | RP-141084 |  |
| 1287 | 262.96 | **LTE Advanced 3 Band Carrier Aggregation (3DL/1UL) of Band 19, Band 42 and Band 42** | 66d? | 2014-06-16 A | 2014-09-12 A | 100% |  | 2014-06-13 | 2014-09-12 | 66d? |  |  | R4 | 1584h | 1584h | LTE_CA_B19_B42_B42 | PCG-33 | NTT DOCOMO | teruaki.toeda.zf@nttdocomo.com | Rel-12 | RP-64 | CA | LTE_CA_B19_B42_B42 |  |  |
| 1288 | 262.96.1 | Core part: LTE Advanced 3 Band Carrier Aggregation (3DL/1UL) of Band 19, Band 42 and Band 42 | 66d? | 2014-06-16 A | 2014-09-12 A | 100% |  | 2014-06-13 | 2014-09-12 | 66d? |  | finish no earlier than 2014-09-12 | R4 | 528h | 528h | LTE_CA_B19_B42_B42-Core | PCG-33 | NTT DOCOMO | teruaki.toeda.zf@nttdocomo.com | Rel-12 | RP-64 | CA | LTE_CA_B19_B42_B42-Core | RP-141084 |  |
| 1289 | 262.96.2 | Perf. Part: LTE Advanced 3 Band Carrier Aggregation (3DL/1UL) of Band 19, Band 42 and Band 42 | 66d? | 2014-06-16 A | 2014-09-12 A | 100% |  | 2014-06-13 | 2014-09-12 | 66d? |  | finish no earlier than 2014-09-12 | R4 | 528h | 528h | LTE_CA_B19_B42_B42-Perf | PCG-33 | NTT DOCOMO | teruaki.toeda.zf@nttdocomo.com | Rel-12 | RP-64 | CA | LTE_CA_B19_B42_B42-Perf | RP-141084 |  |
| 1290 | 262.97 | **LTE Advanced 3 Band Carrier Aggregation (3DL/1UL) of Band 3, Band 42 and Band 42** | 198d? | 2014-06-16 A | 2015-03-15 | 99% | 0d? | 2014-06-13 | 2014-09-12 | 66d? | 0d |  | R4 | 4720h | 3664h | LTE_CA_B3_B42_B42 | PCG-33 | NTT DOCOMO | ANDO Kei (kei.andou.ye@nttdocomo.com) | Rel-12 | RP-64 | CA | LTE_CA_B3_B42_B42 |  |  |
| 1291 | 262.97.1 | Core part: LTE Advanced 3 Band Carrier Aggregation (3DL/1UL) of Band 3, Band 42 and Band 42 | 196d? | 2014-06-16 A | 2015-03-15 A | 100% |  | 2014-06-13 | 2014-09-12 | 66d? |  | finish no earlier than 2015-03-15 | R4 | 1568h | 1568h | LTE_CA_B3_B42_B42-Core | PCG-33 | NTT DOCOMO | ANDO Kei (kei.andou.ye@nttdocomo.com) | Rel-12 | RP-64 | CA | LTE_CA_B3_B42_B42-Core | RP-150013 |  |
| 1292 | 262.97.2 | Perf. Part: LTE Advanced 3 Band Carrier Aggregation (3DL/1UL) of Band 3, Band 42 and Band 42 | 196d? | 2014-06-16 A | 2015-03-15 A | 100% |  | 2014-06-13 | 2014-09-12 | 66d? |  | finish no earlier than 2016-03-15 | R4 | 1568h | 1568h | LTE_CA_B3_B42_B42-Perf | PCG-33 | NTT DOCOMO | ANDO Kei (kei.andou.ye@nttdocomo.com) | Rel-12 | RP-64 | CA | LTE_CA_B3_B42_B42-Perf | RP-150013 |  |
| 1293 | 262.98 | **LTE Advanced 3 Band Carrier Aggregation (3DL/1UL) of Band 1, Band 42 and Band 42** | 66d? | 2014-06-16 A | 2014-09-12 A | 100% |  | 2014-06-13 | 2014-09-12 | 66d? |  |  | R4 | 1584h | 1584h | LTE_CA_B1_B42_B42 | PCG-33 | NTT DOCOMO | ANDO Kei (kei.andou.ye@nttdocomo.com) | Rel-12 | RP-64 | CA | LTE_CA_B1_B42_B42 |  |  |
| 1294 | 262.98.1 | Core part: LTE Advanced 3 Band Carrier Aggregation (3DL/1UL) of Band 1, Band 42 and Band 42 | 66d? | 2014-06-16 A | 2014-09-12 A | 100% |  | 2014-06-13 | 2014-09-12 | 66d? |  | finish no earlier than 2014-09-12 | R4 | 528h | 528h | LTE_CA_B1_B42_B42-Core | PCG-33 | NTT DOCOMO | ANDO Kei (kei.andou.ye@nttdocomo.com) | Rel-12 | RP-64 | CA | LTE_CA_B1_B42_B42-Core | RP-141084 |  |
| 1295 | 262.98.2 | Perf. Part: LTE Advanced 3 Band Carrier Aggregation (3DL/1UL) of Band 1, Band 42 and Band 42 | 66d? | 2014-06-16 A | 2014-09-12 A | 100% |  | 2014-06-13 | 2014-09-12 | 66d? |  | finish no earlier than 2014-09-12 | R4 | 528h | 528h | LTE_CA_B1_B42_B42-Perf | PCG-33 | NTT DOCOMO | ANDO Kei (kei.andou.ye@nttdocomo.com) | Rel-12 | RP-64 | CA | LTE_CA_B1_B42_B42-Perf | RP-141084 |  |
| 1296 | 262.99 | **Additional bandwidth combination set for LTE Advanced intra-band contiguous Carrier Aggregation in Band 40 for 3DL** | 66d? | 2014-06-16 A | 2014-09-12 A | 100% |  | 2014-06-13 | 2014-09-12 | 66d? |  |  | R4 | 1096h | 1096h | LTE_CA_C_B40_3DL_BW | PCG-33 | TeliaSonera | Ralf.Schuh@TeliaSonera.com | Rel-12 | RP-64 | CA | LTE_CA_C_B40_3DL_BW |  |  |
| 1297 | 262.99.1 | Core part: Additional bandwidth combination set for LTE Advanced intra-band contiguous Carrier Aggregation in Band 40 for 3DL | 66d? | 2014-06-16 A | 2014-09-12 A | 100% |  | 2014-06-13 | 2014-09-12 | 66d? |  | finish no earlier than 2014-09-12 | R4 | 528h | 528h | LTE_CA_C_B40_3DL_BW-Core | PCG-33 | TeliaSonera | Ralf.Schuh@TeliaSonera.com | Rel-12 | RP-64 | CA | LTE_CA_C_B40_3DL_BW-Core | RP-141084 |  |
| 1298 | 262.99.2 | Perf. part: Additional bandwidth combination set for LTE Advanced intra-band contiguous Carrier Aggregation in Band 40 for 3DL | 5d? | 2014-09-08 A | 2014-09-12 A | 100% |  |  |  |  |  | finish no earlier than 2014-09-12 | R4 | 40h | 40h | LTE_CA_C_B40_3DL_BW-Perf | PCG-33 | TeliaSonera | Ralf.Schuh@TeliaSonera.com | Rel-12 | RP-65 |  | LTE_CA_C_B40_3DL_BW-Perf | RP-141084 |  |
| 1299 | 262.100 | **LTE Advanced inter-band Carrier Aggregation of Band 18 and Band 28** | 3d? | 2014-09-10 A | 2014-09-12 A | 100% |  | 2014-03-06 | 2015-03-13 | 267d? |  |  | R4 | 72h | 72h | LTE_CA_B18_B28 | PCG-33 | KDDI | Masaaki Obara (ms-obara@kddi.com) | Rel-12 | RP-65 | CA | LTE_CA_B18_B28 |  | Issam |
| 1300 | 262.100.1 | Core part: LTE Advanced inter-band Carrier Aggregation of Band 18 and Band 28 | 3d? | 2014-09-10 A | 2014-09-12 A | 100% |  | 2014-03-06 | 2015-03-13 | 267d? |  | finish no earlier than 2014-09-12 | R4 | 24h | 24h | LTE_CA_B18_B28-Core | PCG-33 | KDDI | Masaaki Obara (ms-obara@kddi.com) | Rel-12 | RP-65 | CA | LTE_CA_B18_B28-Core |  | Issam |
| 1301 | 262.100.2 | Perf. Part: LTE Advanced inter-band Carrier Aggregation of Band 18 and Band 28 | 3d? | 2014-09-10 A | 2014-09-12 A | 100% |  | 2014-03-06 | 2015-03-13 | 267d? |  | finish no earlier than 2014-09-12 | R4 | 24h | 24h | LTE_CA_B18_B28-Perf | PCG-33 | KDDI | Masaaki Obara (ms-obara@kddi.com) | Rel-12 | RP-65 | CA | LTE_CA_B18_B28-Perf |  | Issam |
| 1302 | 262.101 | **LTE Advanced inter-band Carrier Aggregation of Band 5 and Band 13** | 206d? | 2014-03-06 A | 2014-12-15 A | 100% |  | 2014-03-06 | 2014-12-05 | 197d? |  |  | R4 | 4896h | 4896h | LTE_CA_B5_B13 | PCG-32 | Intel | xinrong.wang@intel.com | Rel-12 | RP-63 | CA | LTE_CA_B5_B13 |  | Issam |
| 1303 | 262.101.1 | Core part: LTE Advanced inter-band Carrier Aggregation of Band 5 and Band 13 | 203d? | 2014-03-06 A | 2014-12-15 A | 100% |  | 2014-03-06 | 2014-12-05 | 197d? |  | finish no earlier than 2014-12-15 | R4 | 1624h | 1624h | LTE_CA_B5_B13-Core | PCG-32 | Intel | xinrong.wang@intel.com | Rel-12 | RP-63 | CA | LTE_CA_B5_B13-Core | RP-141732 | Issam |
| 1304 | 262.101.2 | Perf. part: LTE Advanced inter-band Carrier Aggregation of Band 5 and Band 13 | 203d? | 2014-03-06 A | 2014-12-15 A | 100% |  | 2014-03-06 | 2014-12-05 | 197d? |  | finish no earlier than 2014-12-15 | R4 | 1624h | 1624h | LTE_CA_B5_B13-Perf | PCG-32 | Intel | xinrong.wang@intel.com | Rel-12 | RP-63 | CA | LTE_CA_B5_B13-Perf | RP-141732 | Issam |
| 1305 | 262.102 | **LTE Advanced 3 Band Carrier Aggregation (3DL/1UL) of Band 2, Band 2 and Band 5** | 206d? | 2014-03-06 A | 2014-12-15 A | 100% |  | 2014-03-06 | 2014-12-05 | 197d? |  |  | R4 | 4912h | 4912h | LTE_CA_B2_B2_B5 | PCG-32 | Intel | peiling.zhang@intel.com | Rel-12 | RP-63 | CA | LTE_CA_B2_B2_B5 |  | Issam |
| 1306 | 262.102.1 | Core part: LTE Advanced 3 Band Carrier Aggregation (3DL/1UL) of Band 2, Band 2 and Band 5 | 205d? | 2014-03-06 A | 2014-12-15 A | 100% |  | 2014-03-06 | 2014-12-05 | 197d? |  | finish no earlier than 2014-12-15 | R4 | 1640h | 1640h | LTE_CA_B2_B2_B5-Core | PCG-32 | Intel | peiling.zhang@intel.com | Rel-12 | RP-63 | CA | LTE_CA_B2_B2_B5-Core | RP-141732 | Issam |
| 1307 | 262.102.2 | Perf. part: LTE Advanced 3 Band Carrier Aggregation (3DL/1UL) of Band 2, Band 2 and Band 5 | 203d? | 2014-03-06 A | 2014-12-15 A | 100% |  | 2014-03-06 | 2014-12-05 | 197d? |  | finish no earlier than 2014-12-15 | R4 | 1624h | 1624h | LTE_CA_B2_B2_B5-Perf | PCG-32 | Intel | peiling.zhang@intel.com | Rel-12 | RP-63 | CA | LTE_CA_B2_B2_B5-Perf | RP-141732 | Issam |

Notes:
- 1284: Inter-band CA 3DL / Impacted TSs and TRs: LTE
- 1285: RP#65 completed / Impacted TSs and TRs: 36.101, 36.104, 36.133, generic TR 36.853 (3 Band CA with 1UL)
- 1286: RP#65 completed / Impacted TSs and TRs: 36.141, 36.307
- 1287: Inter-band CA 3DL / Impacted TSs and TRs: LTE
- 1288: RP#65 completed / Impacted TSs and TRs: 36.101, 36.104, 36.133, generic TR 36.853 (3 Band CA with 1UL)
- 1289: RP#65 completed / Impacted TSs and TRs: 36.141, 36.307
- 1290: 3DL/1UL / Impacted TSs and TRs: LTE
- 1291: CD:Thu 11/12/14->Sun 15/03/15; Compl:50%->70%; Stat Rep: RP-141084->RP-141732 1st Apr 15: Compl:70%->100% 1st Apr 15: Stat Rep: RP-141732->RP-150013 / Impacted TSs and TRs: 36.101, 36.104, 36.133, generic TR 36.853 (3 Band CA with 1UL)
- 1292: CD:Thu 11/12/14->Tue 15/03/16; Compl:50%->70%; Stat Rep: RP-141084->RP-141732 1st Apr 15: Compl:70%->100% 1st Apr 15: CD:Tue 15/03/16->Sun 15/03/15 1st Apr 15: Stat Rep: RP-141732->RP-150013 / Impacted TSs and TRs: 36.141, 36.307
- 1293: Inter-band CA 3DL / Impacted TSs and TRs: LTE
- 1294: RP#65 completed / Impacted TSs and TRs: 36.101, 36.104, 36.133, generic TR 36.853 (3 Band CA with 1UL)
- 1295: RP#65 completed / Impacted TSs and TRs: 36.141, 36.307
- 1296: Inter-band CA 3DL / Impacted TSs and TRs: LTE
- 1297: RP#65 completed. Updated WID RP-140950=>RP-141127 / Impacted TSs and TRs: 36.101
- 1298: RP#65 updated WID RP-140950=>RP-141127 (added Perf. Part). Completed. / Impacted TSs and TRs: 36.307
- 1299: Inter-band CA 2DL / Impacted TSs and TRs: LTE
- 1300: RP#65 WID approved & completed. Triggered by revised Rel-13 WID RP-140451=>RP-141610 (take out B18_B28 for Rel-12 from the Rel-13 B1_B18_B28) / Impacted TSs and TRs: 36.101, 36.104, 36.133
- 1301: - / Impacted TSs and TRs: 36.141, 36.307
- 1302: Inter-band CA 2DL / Impacted TSs and TRs: LTE
- 1303: CD:Thu 12/03/15->Mon 15/12/14; Compl:50%->100%; Stat Rep: RP-141084->RP-141732; Release: Rel-13->Rel-12 / Impacted TSs and TRs: 36.101, 36.104, 36.133, generic TR 36.851 (2 Band CA with 1UL)
- 1304: CD:Thu 12/03/15->Mon 15/12/14; Compl:10%->100%; Stat Rep: RP-141084->RP-141732; Release: Rel-13->Rel-12 / Impacted TSs and TRs: 36.101, 36.133, 36.141, 36.307
- 1305: Inter-band CA 3DL / Impacted TSs and TRs: LTE
- 1306: CD:Thu 12/03/15->Mon 15/12/14; Compl:90%->100%; Stat Rep: RP-141084->RP-141732; Release: Rel-13->Rel-12 / Impacted TSs and TRs: 36.101, 36.104, 36.133, generic TR 36.853 (3 Band CA with 1UL)
- 1307: CD:Thu 12/03/15->Mon 15/12/14; Compl:10%->100%; Stat Rep: RP-141084->RP-141732; Release: Rel-13->Rel-12 / Impacted TSs and TRs: 36.101, 36.133, 36.141, 36.307

| ID | WBS | Task | Duration | Start | Finish | Complete | Baseline start | Baseline finish | Baseline duration | Constraint | Resources | Work | Actual work | Acronym | PCG approved | WI rapporteur name | WI rapporteur e-mail | Release | TSG approved | MCC resp | Special Focus Doc | Acronym_3GU_Export | Status Report |
| --- | --- | --- | --- | --- | --- | --- | --- | --- | --- | --- | --- | --- | --- | --- | --- | --- | --- | --- | --- | --- | --- | --- | --- |
| 1308 | 262.103 | **LTE Advanced 3 Band Carrier Aggregation (3DL/1UL) of Band 4, Band 4 and Band 5** | 206d? | 2014-03-06 A | 2014-12-15 A | 100% | 2014-03-06 | 2014-12-05 | 197d? |  | R4 | 4912h | 4912h | LTE_CA_B4_B4_B5 | PCG-32 | Intel | peiling.zhang@intel.com | Rel-12 | RP-63 | Issam | CA | LTE_CA_B4_B4_B5 |  |
| 1309 | 262.103.1 | Core part: LTE Advanced 3 Band Carrier Aggregation (3DL/1UL) of Band 4, Band 4 and Band 5 | 205d? | 2014-03-06 A | 2014-12-15 A | 100% | 2014-03-06 | 2014-12-05 | 197d? | finish no earlier than 2014-12-15 | R4 | 1640h | 1640h | LTE_CA_B4_B4_B5-Core | PCG-32 | Intel | peiling.zhang@intel.com | Rel-12 | RP-63 | Issam | CA | LTE_CA_B4_B4_B5-Core | RP-141732 |
| 1310 | 262.103.2 | Perf. part: LTE Advanced 3 Band Carrier Aggregation (3DL/1UL) of Band 4, Band 4 and Band 5 | 203d? | 2014-03-06 A | 2014-12-15 A | 100% | 2014-03-06 | 2014-12-05 | 197d? | finish no earlier than 2014-12-15 | R4 | 1624h | 1624h | LTE_CA_B4_B4_B5-Perf | PCG-32 | Intel | peiling.zhang@intel.com | Rel-12 | RP-63 | Issam | CA | LTE_CA_B4_B4_B5-Perf | RP-141732 |
| 1311 | 262.104 | **LTE Advanced 3 Band Carrier Aggregation (3DL/1UL) of Band 2, Band 5 and Band 13** | 206d? | 2014-03-06 A | 2014-12-15 A | 100% | 2014-03-06 | 2014-12-05 | 197d? |  | R4 | 4896h | 4896h | LTE_CA_B2_B5_B13 | PCG-32 | Intel | xinrong.wang@intel.com | Rel-12 | RP-63 | Issam | CA | LTE_CA_B2_B5_B13 |  |
| 1312 | 262.104.1 | Core part: LTE Advanced 3 Band Carrier Aggregation (3DL/1UL) of Band 2, Band 5 and Band 13 | 203d? | 2014-03-06 A | 2014-12-15 A | 100% | 2014-03-06 | 2014-12-05 | 197d? | finish no earlier than 2014-12-15 | R4 | 1624h | 1624h | LTE_CA_B2_B5_B13-Core | PCG-32 | Intel | xinrong.wang@intel.com | Rel-12 | RP-63 | Issam | CA | LTE_CA_B2_B5_B13-Core | RP-141732 |
| 1313 | 262.104.2 | Perf. part: LTE Advanced 3 Band Carrier Aggregation (3DL/1UL) of Band 2, Band 5 and Band 13 | 203d? | 2014-03-06 A | 2014-12-15 A | 100% | 2014-03-06 | 2014-12-05 | 197d? | finish no earlier than 2014-12-15 | R4 | 1624h | 1624h | LTE_CA_B2_B5_B13-Perf | PCG-32 | Intel | xinrong.wang@intel.com | Rel-12 | RP-63 | Issam | CA | LTE_CA_B2_B5_B13-Perf | RP-141732 |
| 1314 | 262.105 | **LTE Advanced 3 Band Carrier Aggregation (3DL/1UL) of Band 4, Band 5 and Band 13** | 206d? | 2014-03-06 A | 2014-12-15 A | 100% | 2014-03-06 | 2014-12-05 | 197d? |  | R4 | 4896h | 4896h | LTE_CA_B4_B5_B13 | PCG-32 | Intel | xinrong.wang@intel.com | Rel-12 | RP-63 | Issam | CA | LTE_CA_B4_B5_B13 |  |
| 1315 | 262.105.1 | Core part: LTE Advanced 3 Band Carrier Aggregation (3DL/1UL) of Band 4, Band 5 and Band 13 | 203d? | 2014-03-06 A | 2014-12-15 A | 100% | 2014-03-06 | 2014-12-05 | 197d? | finish no earlier than 2014-12-15 | R4 | 1624h | 1624h | LTE_CA_B4_B5_B13-Core | PCG-32 | Intel | xinrong.wang@intel.com | Rel-12 | RP-63 | Issam | CA | LTE_CA_B4_B5_B13-Core | RP-141732 |
| 1316 | 262.105.2 | Perf. part: LTE Advanced 3 Band Carrier Aggregation (3DL/1UL) of Band 4, Band 5 and Band 13 | 203d? | 2014-03-06 A | 2014-12-15 A | 100% | 2014-03-06 | 2014-12-05 | 197d? | finish no earlier than 2014-12-15 | R4 | 1624h | 1624h | LTE_CA_B4_B5_B13-Perf | PCG-32 | Intel | xinrong.wang@intel.com | Rel-12 | RP-63 | Issam | CA | LTE_CA_B4_B5_B13-Perf | RP-141732 |
| 1317 | 262.106 | **LTE Advanced 3 Band Carrier Aggregation (3DL/1UL) of Band 1, Band 3 and Band 26** | 206d? | 2014-03-06 A | 2014-12-15 A | 100% | 2014-03-06 | 2014-12-05 | 197d? |  | R4 | 4896h | 4896h | LTE_CA_B1_B3_B26 | PCG-32 | China Telecom | Zhao Dong (zhaodong@ctbri.com.cn) | Rel-12 | RP-63 | Issam | CA | LTE_CA_B1_B3_B26 |  |
| 1318 | 262.106.1 | Core part: LTE Advanced 3 Band Carrier Aggregation (3DL/1UL) of Band 1, Band 3 and Band 26 | 203d? | 2014-03-06 A | 2014-12-15 A | 100% | 2014-03-06 | 2014-12-05 | 197d? | finish no earlier than 2014-12-15 | R4 | 1624h | 1624h | LTE_CA_B1_B3_B26-Core | PCG-32 | China Telecom | Zhao Dong (zhaodong@ctbri.com.cn) | Rel-12 | RP-63 | Issam | CA | LTE_CA_B1_B3_B26-Core | RP-141732 |
| 1319 | 262.106.2 | Perf. part: LTE Advanced 3 Band Carrier Aggregation (3DL/1UL) of Band 1, Band 3 and Band 26 | 203d? | 2014-03-06 A | 2014-12-15 A | 100% | 2014-03-06 | 2014-12-05 | 197d? | finish no earlier than 2014-12-15 | R4 | 1624h | 1624h | LTE_CA_B1_B3_B26-Perf | PCG-32 | China Telecom | Zhao Dong (zhaodong@ctbri.com.cn) | Rel-12 | RP-63 | Issam | CA | LTE_CA_B1_B3_B26-Perf | RP-141732 |
| 1320 | 262.107 | **LTE Advanced 3 Band Carrier Aggregation (3DL/1UL) of Band 1, Band 18 and Band 28** | 206d? | 2014-03-06 A | 2014-12-15 A | 100% | 2014-03-06 | 2015-03-13 | 267d? |  | R4 | 4896h | 4896h | LTE_CA_B1_B18_B28 | PCG-32 | KDDI | Masaaki Obara (ms-obara@kddi.com) | Rel-12 | RP-63 | Issam | CA | LTE_CA_B1_B18_B28 |  |
| 1321 | 262.107.1 | Core part: LTE Advanced 3 Band Carrier Aggregation (3DL/1UL) of Band 1, Band 18 and Band 28 | 203d? | 2014-03-06 A | 2014-12-15 A | 100% | 2014-03-06 | 2015-03-13 | 267d? | finish no earlier than 2014-12-15 | R4 | 1624h | 1624h | LTE_CA_B1_B18_B28-Core | PCG-32 | KDDI | Masaaki Obara (ms-obara@kddi.com) | Rel-12 | RP-63 | Issam | CA | LTE_CA_B1_B18_B28-Core | RP-141732 |
| 1322 | 262.107.2 | Perf. part: LTE Advanced 3 Band Carrier Aggregation (3DL/1UL) of Band 1, Band 18 and Band 28 | 203d? | 2014-03-11 A | 2014-12-15 A | 100% | 2014-03-06 | 2015-03-13 | 267d? | finish no earlier than 2014-12-15 | R4 | 1624h | 1624h | LTE_CA_B1_B18_B28-Perf | PCG-32 | KDDI | Masaaki Obara (ms-obara@kddi.com) | Rel-12 | RP-63 | Issam | CA | LTE_CA_B1_B18_B28-Perf | RP-141732 |
| 1323 | 262.108 | **LTE Advanced 3 Band Carrier Aggregation (3DL/1UL) of Band 4, Band 7 and Band 12** | 132d? | 2014-06-18 A | 2014-12-15 A | 100% | 2014-06-13 | 2015-03-13 | 196d? |  | R4 | 3168h | 3168h | LTE_CA_B4_B7_B12 | PCG-33 | Rogers Wireless | pavlo.nebesny@rci.rogers.com | Rel-12 | RP-64 |  | CA | LTE_CA_B4_B7_B12 |  |
| 1324 | 262.108.1 | Core part: LTE Advanced 3 Band Carrier Aggregation (3DL/1UL) of Band 4, Band 7 and Band 12 | 132d? | 2014-06-18 A | 2014-12-15 A | 100% | 2014-06-13 | 2015-03-13 | 196d? | finish no earlier than 2014-12-15 | R4 | 1056h | 1056h | LTE_CA_B4_B7_B12-Core | PCG-33 | Rogers Wireless | pavlo.nebesny@rci.rogers.com | Rel-12 | RP-64 |  | CA | LTE_CA_B4_B7_B12-Core | RP-141732 |
| 1325 | 262.108.2 | Perf. Part: LTE Advanced 3 Band Carrier Aggregation (3DL/1UL) of Band 4, Band 7 and Band 12 | 132d? | 2014-06-18 A | 2014-12-15 A | 100% | 2014-06-13 | 2015-03-13 | 196d? | finish no earlier than 2014-12-15 | R4 | 1056h | 1056h | LTE_CA_B4_B7_B12-Perf | PCG-33 | Rogers Wireless | pavlo.nebesny@rci.rogers.com | Rel-12 | RP-64 |  | CA | LTE_CA_B4_B7_B12-Perf | RP-141732 |
| 1326 | 262.109 | **LTE Advanced 3 Band Carrier Aggregation (3DL/1UL) of Band 4, Band 4 and Band 7** | 132d? | 2014-06-18 A | 2014-12-15 A | 100% | 2014-06-13 | 2015-03-13 | 196d? |  | R4 | 3168h | 3168h | LTE_CA_B4_B4_B7 | PCG-33 | Rogers Wireless | pavlo.nebesny@rci.rogers.com | Rel-12 | RP-64 |  | CA | LTE_CA_B4_B4_B7 |  |
| 1327 | 262.109.1 | Core part: LTE Advanced 3 Band Carrier Aggregation (3DL/1UL) of Band 4, Band 4 and Band 7 | 132d? | 2014-06-18 A | 2014-12-15 A | 100% | 2014-06-13 | 2015-03-13 | 196d? | finish no earlier than 2014-12-15 | R4 | 1056h | 1056h | LTE_CA_B4_B4_B7-Core | PCG-33 | Rogers Wireless | pavlo.nebesny@rci.rogers.com | Rel-12 | RP-64 |  | CA | LTE_CA_B4_B4_B7-Core | RP-141732 |
| 1328 | 262.109.2 | Perf. Part: LTE Advanced 3 Band Carrier Aggregation (3DL/1UL) of Band 4, Band 4 and Band 7 | 132d? | 2014-06-18 A | 2014-12-15 A | 100% | 2014-06-13 | 2015-03-13 | 196d? | finish no earlier than 2014-12-15 | R4 | 1056h | 1056h | LTE_CA_B4_B4_B7-Perf | PCG-33 | Rogers Wireless | pavlo.nebesny@rci.rogers.com | Rel-12 | RP-64 |  | CA | LTE_CA_B4_B4_B7-Perf | RP-141732 |
| 1329 | 262.110 | **LTE Advanced 3 Band Carrier Aggregation (3DL/1UL) of Band 39, Band 41 and Band 41** | 134d? | 2014-06-16 A | 2014-12-15 A | 100% | 2014-06-13 | 2014-12-05 | 126d? |  | R4 | 3184h | 3184h | LTE_CA_B39_B41_B41 | PCG-33 | China Mobile | PAN Qun (panqun@chinamobile.com) | Rel-12 | RP-64 |  | CA | LTE_CA_B39_B41_B41 |  |
| 1330 | 262.110.1 | Core part: LTE Advanced 3 Band Carrier Aggregation (3DL/1UL) of Band 39, Band 41 and Band 41 | 132d? | 2014-06-16 A | 2014-12-15 A | 100% | 2014-06-13 | 2014-12-05 | 126d? | finish no earlier than 2014-12-15 | R4 | 1056h | 1056h | LTE_CA_B39_B41_B41-Core | PCG-33 | China Mobile | PAN Qun (panqun@chinamobile.com) | Rel-12 | RP-64 |  | CA | LTE_CA_B39_B41_B41-Core | RP-141732 |
| 1331 | 262.110.2 | Perf. Part: LTE Advanced 3 Band Carrier Aggregation (3DL/1UL) of Band 39, Band 41 and Band 41 | 132d? | 2014-06-18 A | 2014-12-15 A | 100% | 2014-06-13 | 2014-12-05 | 126d? | finish no earlier than 2014-12-15 | R4 | 1056h | 1056h | LTE_CA_B39_B41_B41-Perf | PCG-33 | China Mobile | PAN Qun (panqun@chinamobile.com) | Rel-12 | RP-64 |  | CA | LTE_CA_B39_B41_B41-Perf | RP-141732 |

Notes:
- 1308: Inter-band CA 3DL / Impacted TSs and TRs: LTE
- 1309: CD:Thu 12/03/15->Mon 15/12/14; Compl:90%->100%; Stat Rep: RP-141084->RP-141732; Release: Rel-13->Rel-12 / Impacted TSs and TRs: 36.101, 36.104, 36.133, generic TR 36.853 (3 Band CA with 1UL)
- 1310: CD:Thu 12/03/15->Mon 15/12/14; Compl:10%->100%; Stat Rep: RP-141084->RP-141732; Release: Rel-13->Rel-12 / Impacted TSs and TRs: 36.101, 36.133, 36.141, 36.307
- 1311: Inter-band CA 3DL / Impacted TSs and TRs: LTE
- 1312: CD:Thu 12/03/15->Mon 15/12/14; Compl:50%->100%; Stat Rep: RP-141084->RP-141732; Release: Rel-13->Rel-12 / Impacted TSs and TRs: 36.101, 36.104, 36.133, generic TR 36.853 (3 Band CA with 1UL)
- 1313: CD:Thu 12/03/15->Mon 15/12/14; Compl:10%->100%; Stat Rep: RP-141084->RP-141732; Release: Rel-13->Rel-12 / Impacted TSs and TRs: 36.101, 36.133, 36.141, 36.307
- 1314: Inter-band CA 3DL / Impacted TSs and TRs: LTE
- 1315: CD:Thu 12/03/15->Mon 15/12/14; Compl:50%->100%; Stat Rep: RP-141084->RP-141732; Release: Rel-13->Rel-12 / Impacted TSs and TRs: 36.101, 36.104, 36.133, generic TR 36.853 (3 Band CA with 1UL)
- 1316: CD:Thu 12/03/15->Mon 15/12/14; Compl:10%->100%; Stat Rep: RP-141084->RP-141732; Release: Rel-13->Rel-12 / Impacted TSs and TRs: 36.101, 36.133, 36.141, 36.307
- 1317: Inter-band CA 3DL / Impacted TSs and TRs: LTE
- 1318: CD:Thu 11/12/14->Mon 15/12/14; Compl:90%->100%; Stat Rep: RP-141084->RP-141732; Release: Rel-13->Rel-12 / Impacted TSs and TRs: 36.101, 36.104, 36.133, generic TR 36.853 (3 Band CA with 1UL)
- 1319: CD:Thu 11/12/14->Mon 15/12/14; Compl:90%->100%; Stat Rep: RP-141084->RP-141732; Release: Rel-13->Rel-12 / Impacted TSs and TRs: 36.141, 36.307
- 1320: Inter-band CA 3DL / Impacted TSs and TRs: LTE
- 1321: ; WID: RP-142043->RP-141788; Stat Rep: RP-141084->RP-141732; Release: Rel-13->Rel-12 / Impacted TSs and TRs: 36.101, 36.104, 36.133, generic TR 36.853 (3 Band CA with 1UL)
- 1322: ; WID: RP-142043->RP-141788; Stat Rep: RP-141084->RP-141732; Release: Rel-13->Rel-12 / Impacted TSs and TRs: 36.141, 36.307
- 1323: Inter-band CA 3DL/1UL / Impacted TSs and TRs: LTE
- 1324: CD:Thu 12/03/15->Mon 15/12/14; Compl:0%->100%; Stat Rep: RP-141084->RP-141732; Release: Rel-13->Rel-12 / Impacted TSs and TRs: 36.101, 36.104, 36.133, 36.307, generic TR 36.851 (2 Band CA with 1UL), generic TR 36.853 (3 Band CA with 1UL)
- 1325: CD:Thu 12/03/15->Mon 15/12/14; Compl:0%->100%; Stat Rep: RP-141084->RP-141732; Release: Rel-13->Rel-12 / Impacted TSs and TRs: 36.133, 36.141
- 1326: Inter-band CA 3DL/1UL / Impacted TSs and TRs: LTE
- 1327: CD:Thu 12/03/15->Mon 15/12/14; Compl:0%->100%; Stat Rep: RP-141084->RP-141732; Release: Rel-13->Rel-12 / Impacted TSs and TRs: 36.101, 36.104, 36.133, 36.307, generic TR 36.853 (3 Band CA with 1UL)
- 1328: CD:Thu 12/03/15->Mon 15/12/14; Compl:0%->100%; Stat Rep: RP-141084->RP-141732; Release: Rel-13->Rel-12 / Impacted TSs and TRs: 36.133, 36.141
- 1329: Inter-band CA 3DL/1UL / Impacted TSs and TRs: LTE
- 1330: ; WID: RP-140708->RP-142301; Stat Rep: RP-141084->RP-141732; Release: Rel-13->Rel-12 / Impacted TSs and TRs: 36.101, 36.104, 36.133, generic TR 36.853 (3 Band CA with 1UL)
- 1331: ; WID: RP-140708->RP-142301; Stat Rep: RP-141084->RP-141732; Release: Rel-13->Rel-12 / Impacted TSs and TRs: 36.141, 36.307

| ID | WBS | Task | Duration | Start | Finish | Complete | Remaining | Baseline start | Baseline finish | Baseline duration | Total slack | Constraint | Resources | Work | Actual work | Acronym | PCG approved | WI rapporteur name | WI rapporteur e-mail | Release | TSG approved | Special Focus Doc | Acronym_3GU_Export | Status Report | MCC resp | PCG stopped | TSG stopped |
| --- | --- | --- | --- | --- | --- | --- | --- | --- | --- | --- | --- | --- | --- | --- | --- | --- | --- | --- | --- | --- | --- | --- | --- | --- | --- | --- | --- |
| 1332 | 262.111 | **LTE Advanced 3 Band Carrier Aggregation (3DL/1UL) of Band 1, Band 41 and Band 41** | 132d? | 2014-06-18 A | 2014-12-15 | 50% | 66d? | 2014-06-13 | 2015-03-13 | 196d? | 653d |  | R4 | 3168h | 1584h | LTE_CA_B1_B41_B41 | PCG-33 | KDDI | Masaaki Obara (ms-obara@kddi.com) | Rel-12 | RP-64 | CA | LTE_CA_B1_B41_B41 |  |  |  |  |
| 1333 | 262.111.1 | Core part: LTE Advanced 3 Band Carrier Aggregation (3DL/1UL) of Band 1, Band 41 and Band 41 | 132d? | 2014-06-18 A | 2014-12-15 A | 100% |  | 2014-06-13 | 2015-03-13 | 196d? |  | finish no earlier than 2014-12-15 | R4 | 1056h | 1056h | LTE_CA_B1_B41_B41-Core | PCG-33 | KDDI | Masaaki Obara (ms-obara@kddi.com) | Rel-12 | RP-64 | CA | LTE_CA_B1_B41_B41-Core | RP-141732 |  |  |  |
| 1334 | 262.111.2 | Perf. Part: LTE Advanced 3 Band Carrier Aggregation (3DL/1UL) of Band 1, Band 41 and Band 41 | 132d? | 2014-06-18 | 2014-12-15 |  |  | 2014-06-13 | 2015-03-13 | 196d? | 653d | finish no earlier than 2014-12-15 | R4 | 1056h |  | LTE_CA_B1_B41_B41-Perf | PCG-33 | KDDI | Masaaki Obara (ms-obara@kddi.com) | Rel-12 | RP-64 | CA | LTE_CA_B1_B41_B41-Perf | RP-141732 |  |  |  |
| 1335 | 262.112 | **LTE Advanced 3 Band Carrier Aggregation (3DL/1UL) of Band 26, Band 41 and Band 41** | 132d? | 2014-06-18 A | 2014-12-15 | 50% | 66d? | 2014-06-13 | 2015-03-13 | 196d? | 653d |  | R4 | 3168h | 1584h | LTE_CA_B26_B41_B41 | PCG-33 | KDDI | Masaaki Obara (ms-obara@kddi.com) | Rel-12 | RP-64 | CA | LTE_CA_B26_B41_B41 |  |  |  |  |
| 1336 | 262.112.1 | Core part: LTE Advanced 3 Band Carrier Aggregation (3DL/1UL) of Band 26, Band 41 and Band 41 | 132d? | 2014-06-18 A | 2014-12-15 A | 100% |  | 2014-06-13 | 2015-03-13 | 196d? |  | finish no earlier than 2014-12-15 | R4 | 1056h | 1056h | LTE_CA_B26_B41_B41-Core | PCG-33 | KDDI | Masaaki Obara (ms-obara@kddi.com) | Rel-12 | RP-64 | CA | LTE_CA_B26_B41_B41-Core | RP-141732 |  |  |  |
| 1337 | 262.112.2 | Perf. Part: LTE Advanced 3 Band Carrier Aggregation (3DL/1UL) of Band 26, Band 41 and Band 41 | 132d? | 2014-06-18 | 2014-12-15 |  |  | 2014-06-13 | 2015-03-13 | 196d? | 653d | finish no earlier than 2014-12-15 | R4 | 1056h |  | LTE_CA_B26_B41_B41-Perf | PCG-33 | KDDI | Masaaki Obara (ms-obara@kddi.com) | Rel-12 | RP-64 | CA | LTE_CA_B26_B41_B41-Perf | RP-141732 |  |  |  |
| 1338 | 262.113 | **LTE Advanced 3 Band Carrier Aggregation (3DL/1UL) of Band 25, Band 41 and Band 41** | 68d? | 2014-09-15 A | 2014-12-15 A | 100% |  | 2014-06-13 | 2015-03-13 | 196d? |  |  | R4 | 1632h | 1632h | LTE_CA_B25_B41_B41 | PCG-33 | Alcatel-Lucent | Ng, Man Hung (man-hung.ng@alcatel-lucent.com) | Rel-12 | RP-65 | CA | LTE_CA_B25_B41_B41 |  |  |  |  |
| 1339 | 262.113.1 | Core part: LTE Advanced 3 Band Carrier Aggregation (3DL/1UL) of Band 25, Band 41 and Band 41 | 68d? | 2014-09-15 A | 2014-12-15 A | 100% |  | 2014-06-13 | 2015-03-13 | 196d? |  | finish no earlier than 2014-12-15 | R4 | 544h | 544h | LTE_CA_B25_B41_B41-Core | PCG-33 | Alcatel-Lucent | Ng, Man Hung (man-hung.ng@alcatel-lucent.com) | Rel-12 | RP-65 | CA | LTE_CA_B25_B41_B41-Core | RP-141732 |  |  |  |
| 1340 | 262.113.2 | Perf. Part: LTE Advanced 3 Band Carrier Aggregation (3DL/1UL) of Band 25, Band 41 and Band 41 | 68d? | 2014-09-15 A | 2014-12-15 A | 100% |  | 2014-06-13 | 2015-03-13 | 196d? |  | finish no earlier than 2014-12-15 | R4 | 544h | 544h | LTE_CA_B25_B41_B41-Perf | PCG-33 | Alcatel-Lucent | Ng, Man Hung (man-hung.ng@alcatel-lucent.com) | Rel-12 | RP-65 | CA | LTE_CA_B25_B41_B41-Perf | RP-141732 |  |  |  |
| 1341 | 262.114 | **LTE Advanced 3 Band Carrier Aggregation (3DL/1UL) of Band 39, Band 39 and Band 41** | 68d? | 2014-09-15 A | 2014-12-15 A | 100% |  | 2014-06-13 | 2015-03-13 | 196d? |  |  | R4 | 1632h | 1632h | LTE_CA_B39_B39_B41 | PCG-33 | China Mobile | PAN, Qun (panqun@chinamobile.com) | Rel-12 | RP-65 | CA | LTE_CA_B39_B39_B41 |  |  |  |  |
| 1342 | 262.114.1 | Core part: LTE Advanced 3 Band Carrier Aggregation (3DL/1UL) of Band 39, Band 39 and Band 41 | 68d? | 2014-09-15 A | 2014-12-15 A | 100% |  | 2014-06-13 | 2015-03-13 | 196d? |  | finish no earlier than 2014-12-15 | R4 | 544h | 544h | LTE_CA_B39_B39_B41-Core | PCG-33 | China Mobile | PAN, Qun (panqun@chinamobile.com) | Rel-12 | RP-65 | CA | LTE_CA_B39_B39_B41-Core | RP-141732 |  |  |  |
| 1343 | 262.114.2 | Perf. Part: LTE Advanced 3 Band Carrier Aggregation (3DL/1UL) of Band 39, Band 39 and Band 41 | 68d? | 2014-09-15 A | 2014-12-15 A | 100% |  | 2014-06-13 | 2015-03-13 | 196d? |  | finish no earlier than 2014-12-15 | R4 | 544h | 544h | LTE_CA_B39_B39_B41-Perf | PCG-33 | China Mobile | PAN, Qun (panqun@chinamobile.com) | Rel-12 | RP-65 | CA | LTE_CA_B39_B39_B41-Perf | RP-141732 |  |  |  |
| 1344 | 262.115 | **LTE Advanced 3 Band Carrier Aggregation (3DL/1UL) of Band 2, Band 2 and Band 29** | 68d? | 2014-09-15 A | 2014-12-15 A | 100% |  | 2014-06-13 | 2015-03-13 | 196d? |  |  | R4 | 1632h | 1632h | LTE_CA_B2_B2_B29 | PCG-33 | AT&T | marc.grant@att.com | Rel-12 | RP-65 | CA | LTE_CA_B2_B2_B29 |  |  |  |  |
| 1345 | 262.115.1 | Core part: LTE Advanced 3 Band Carrier Aggregation (3DL/1UL) of Band 2, Band 2 and Band 29 | 68d? | 2014-09-15 A | 2014-12-15 A | 100% |  | 2014-06-13 | 2015-03-13 | 196d? |  | finish no earlier than 2014-12-15 | R4 | 544h | 544h | LTE_CA_B2_B2_B29-Core | PCG-33 | AT&T | marc.grant@att.com | Rel-12 | RP-65 | CA | LTE_CA_B2_B2_B29-Core | RP-141732 |  |  |  |
| 1346 | 262.115.2 | Perf. Part: LTE Advanced 3 Band Carrier Aggregation (3DL/1UL) of Band 2, Band 2 and Band 29 | 68d? | 2014-09-15 A | 2014-12-15 A | 100% |  | 2014-06-13 | 2015-03-13 | 196d? |  | finish no earlier than 2014-12-15 | R4 | 544h | 544h | LTE_CA_B2_B2_B29-Perf | PCG-33 | AT&T | marc.grant@att.com | Rel-12 | RP-65 | CA | LTE_CA_B2_B2_B29-Perf | RP-141732 |  |  |  |
| 1347 | 262.116 | **LTE Advanced 3 Band Carrier Aggregation (3DL/1UL) of Band 2, Band 4 and Band 29** | 68d? | 2014-09-15 A | 2014-12-15 A | 100% |  | 2014-06-13 | 2015-03-13 | 196d? |  |  | R4 | 1632h | 1632h | LTE_CA_B2_B4_B29 | PCG-33 | Huawei | SHAN Huiping (shanhuiping@huawei.com) | Rel-12 | RP-65 | CA | LTE_CA_B2_B4_B29 |  |  |  |  |
| 1348 | 262.116.1 | Core part: LTE Advanced 3 Band Carrier Aggregation (3DL/1UL) of Band 2, Band 4 and Band 29 | 68d? | 2014-09-15 A | 2014-12-15 A | 100% |  | 2014-06-13 | 2015-03-13 | 196d? |  | finish no earlier than 2014-12-15 | R4 | 544h | 544h | LTE_CA_B2_B4_B29-Core | PCG-33 | Huawei | SHAN Huiping (shanhuiping@huawei.com) | Rel-12 | RP-65 | CA | LTE_CA_B2_B4_B29-Core | RP-141732 |  |  |  |
| 1349 | 262.116.2 | Perf. Part: LTE Advanced 3 Band Carrier Aggregation (3DL/1UL) of Band 2, Band 4 and Band 29 | 68d? | 2014-09-15 A | 2014-12-15 A | 100% |  | 2014-06-13 | 2015-03-13 | 196d? |  | finish no earlier than 2014-12-15 | R4 | 544h | 544h | LTE_CA_B2_B4_B29-Perf | PCG-33 | Huawei | SHAN Huiping (shanhuiping@huawei.com) | Rel-12 | RP-65 | CA | LTE_CA_B2_B4_B29-Perf | RP-141732 |  |  |  |
| 1350 | 263 | UE Conformance Test Aspects – Further Rel-12 configurations for LTE Advanced Carrier Aggregation | 393d? | 2013-09-15 A | 2015-03-15 A | 100% |  | 2013-09-09 | 2014-12-05 | 327d? |  | finish no earlier than 2015-03-15 | R5 | 3144h | 3144h | LTE_CA_Rel12-UEConTest | PCG-31 | Microsoft | jussi.kuusisto@microsoft.com | Rel-12 | RP-61 | CA | LTE_CA_Rel12-UEConTest | RP-150076 | Ingbert |  |  |
| 1351 | 264 | UE Conformance Test Aspects – Further Rel-12 configurations for LTE Advanced Carrier Aggregation with 3DL | 329d? | 2014-09-15 A | 2015-12-15 | 12% | 289.52d? |  |  |  | 392d | finish no earlier than 2015-12-15 | R5 | 2632h | 315.84h | LTE_CA_Rel12_3DL-UEConTest | PCG-33 | Microsoft | jussi.kuusisto@microsoft.com | Rel-12 | RP-65 | CA | LTE_CA_Rel12_3DL-UEConTest | RP-150078 |  |  |  |
| 1352 | 265 | **Deleted - Carrier based HetNet ICIC for LTE** | 595d? | 2011-03-18 A | 2013-06-14 A | 100% |  | 2011-03-18 | 2013-06-14 | 595d? |  |  | R3; R1; R2 | 28560h | 28560h | LTE_CA_HetNet_ICIC | PCG-26 | Nokia Siemens Networks | krzysztof.kordybach@nsn.com | Rel-12 | RP-51 |  | LTE_CA_HetNet_ICIC |  | Juha | PCG-31 | RP-60 |
| 1353 | 265.1 | Deleted - Core part: Carrier based HetNet ICIC for LTE | 595d? | 2011-03-18 A | 2013-06-14 A | 100% |  | 2011-03-18 | 2013-06-14 | 595d? |  | finish no earlier than 2013-06-14 | R3; R1; R2 | 14280h | 14280h | LTE_CA_HetNet_ICIC-Core | PCG-26 | Nokia Siemens Networks | krzysztof.kordybach@nsn.com | Rel-12 | RP-51 |  | LTE_CA_HetNet_ICIC-Core | RP-130500 | Juha | PCG-31 | RP-60 |
| 1354 | 266 | **LTE in the US Wireless Communications Service (WCS) Band 30** | 600d? | 2012-09-12 A | 2014-12-15 | 99% | 0d? | 2012-09-12 | 2014-12-05 | 591d? | 0d |  | R4; R2; R5 | 20312h | 20285.2h | LTE_WCS_band | PCG-29 | AT&T | marc.grant@att.com | Rel-12 | RP-57 |  | LTE_WCS_band |  | Issam |  |  |
| 1355 | 266.1 | Core part: LTE in the US Wireless Communications Service (WCS) Band 30 | 202d? | 2012-09-12 A | 2013-06-14 A | 100% |  | 2012-09-12 | 2013-06-14 | 202d? |  | finish no earlier than 2013-06-14 | R4; R2 | 3232h | 3232h | LTE_WCS_band-Core | PCG-29 | AT&T | marc.grant@att.com | Rel-12 | RP-57 |  | LTE_WCS_band-Core | RP-130569 | Issam |  |  |
| 1356 | 266.2 | Perf. Part: LTE in the US Wireless Communications Service (WCS) Band 30 | 201d? | 2012-09-13 A | 2013-06-14 A | 100% |  | 2012-09-13 | 2013-06-14 | 201d? |  | finish no earlier than 2013-06-14 | R4 | 1608h | 1608h | LTE_WCS_band-Perf | PCG-29 | AT&T | marc.grant@att.com | Rel-12 | RP-57 |  | LTE_WCS_band-Perf | RP-130570 | Issam |  |  |
| 1357 | 266.3 | Test Part: LTE in the US Wireless Communications Service (WCS) Band 30 | 134d? | 2014-06-15 A | 2014-12-15 A | 100% |  | 2014-06-13 | 2014-12-05 | 126d? |  | finish no earlier than 2014-12-15 | R5 | 1072h | 1072h | LTE_WCS_band-UEConTest | PCG-33 | Ericsson | fredrik.sundstrom@ericsson.com | Rel-12 | RP-64 |  | LTE_WCS_band-UEConTest | RP-141773 |  |  |  |

Notes:
- 1332: Inter-band CA 3DL/1UL / Impacted TSs and TRs: LTE
- 1333: ; WID: RP-142043->RP-142297; Stat Rep: RP-141084->RP-141732; Release: Rel-13->Rel-12 / Impacted TSs and TRs: 36.101, 36.104, 36.133, generic TR 36.853 (3 Band CA with 1UL)
- 1334: Compl:100%->0%; WID: RP-142043->RP-142297; Stat Rep: RP-141084->RP-141732; Release: Rel-13->Rel-12 / Impacted TSs and TRs: 36.141, 36.307
- 1335: Inter-band CA 3DL/1UL / Impacted TSs and TRs: LTE
- 1336: ; WID: RP-142043->RP-142298; Stat Rep: RP-141084->RP-141732; Release: Rel-13->Rel-12 / Impacted TSs and TRs: 36.101, 36.104, 36.133, generic TR 36.853 (3 Band CA with 1UL)
- 1337: Compl:100%->0%; WID: RP-142043->RP-142298; Stat Rep: RP-141084->RP-141732; Release: Rel-13->Rel-12 / Impacted TSs and TRs: 36.141, 36.307
- 1338: Inter-band CA 3DL/1UL / Impacted TSs and TRs: LTE
- 1339: ; WID: RP-142043->RP-142018; Stat Rep: -->RP-141732; Release: Rel-13->Rel-12 / Impacted TSs and TRs: 36.101, 36.104, 36.307, New TR 36.833-x-yz
- 1340: ; WID: RP-142043->RP-142018; Stat Rep: -->RP-141732; Release: Rel-13->Rel-12 / Impacted TSs and TRs: 36.141
- 1341: Inter-band CA 3DL/1UL / Impacted TSs and TRs: LTE
- 1342: ; WID: RP-141288->RP-142302; Stat Rep: -->RP-141732; Release: Rel-13->Rel-12 / Impacted TSs and TRs: 36.101, 36.104, 36.133, New TR 36.8xx
- 1343: ; WID: RP-141288->RP-142302; Stat Rep: -->RP-141732; Release: Rel-13->Rel-12 / Impacted TSs and TRs: 36.141, 36.307
- 1344: Inter-band CA 3DL/1UL / Impacted TSs and TRs: LTE
- 1345: CD:Thu 11/12/14->Mon 15/12/14; Compl:0%->100%; Stat Rep: -->RP-141732; Release: Rel-13->Rel-12 / Impacted TSs and TRs: 36.101, 36.104, 36.133, New TR 36.8xx
- 1346: CD:Thu 11/12/14->Mon 15/12/14; Compl:0%->100%; Stat Rep: -->RP-141732; Release: Rel-13->Rel-12 / Impacted TSs and TRs: 36.141, 36.307
- 1347: Inter-band CA 3DL/1UL / Impacted TSs and TRs: LTE
- 1348: CD:Fri 11/12/15->Mon 15/12/14; Compl:0%->100%; Stat Rep: -->RP-141732; Release: Rel-13->Rel-12 / Impacted TSs and TRs: 36.101, 36.104, 36.133, New TR 36.8xx
- 1349: CD:Thu 11/12/14->Mon 15/12/14; Compl:0%->100%; Stat Rep: -->RP-141732; Release: Rel-13->Rel-12 / Impacted TSs and TRs: 36.141, 36.307
- 1350: ; Stat Rep: RP-141444->RP-141774 1st Apr 15: Compl:75%->100% 1st Apr 15: WID: RP-140621->RP-150077 1st Apr 15: Stat Rep: RP-141774->RP-150076 / Impacted TSs and TRs: 36.508, 36.521-1, 36.521-2, 36.521-3, 36.523-1, 36.523-2, 36.523-3, 37.571-1, 37.571-3, 37.571-5
- 1351: ; Stat Rep: -->RP-141775 1st Apr 15: Compl:6%->12% 1st Apr 15: CD:Tue 15/09/15->Tue 15/12/15 1st Apr 15: WID: RP-142231->RP-150079 1st Apr 15: Stat Rep: RP-141775->RP-150078 / Impacted TSs and TRs: 36.508, 36.521-1, 36.521-2, 36.521-3, 36.523-1, 36.523-2, 36.523-3, 37.571-1, 37.571-3, 37.571-5
- 1352: RP#60 stopped. RP#58 on hold til June 2013 / Impacted TSs and TRs: LTE
- 1353: RP#60 stopped at 40% completion. RP#58 on hold til June 2013 / Impacted TSs and TRs: 36.300, 36.413, 36.420, 36.423
- 1354: RP#58 RP-121701 work can start based on FCC Order (FCC-12-130) http://hraunfoss.fcc.gov/edocs_public/attachmatch/FCC-12-130A1.pdf / Impacted TSs and TRs: LTE
- 1355: RP#60 completed. Updated WID RP-121419=>RP-130843 / Impacted TSs and TRs: 36.101, 36.104, 36.113, 36.124, 36.133, 36.307, 36.331, new TR 36.846
- 1356: RP#60 completed. Updated WID RP-121419=>RP-130843 / Impacted TSs and TRs: 36.101, 36.133, 36.141
- 1357: ; Stat Rep: RP-141166->RP-141773 / Impacted TSs and TRs: 36.508, 36.521-1, 36.521-2, 36.521-3, 36.523-2, 36.523-3, 37.571-1

| ID | WBS | Task | Duration | Start | Finish | Complete | Remaining | Baseline start | Baseline finish | Baseline duration | Total slack | Constraint | Resources | Work | Actual work | Acronym | PCG approved | WI rapporteur name | WI rapporteur e-mail | Release | TSG approved | MCC resp | Acronym_3GU_Export | Status Report | PCG stopped | TSG stopped | Special Focus Doc |
| --- | --- | --- | --- | --- | --- | --- | --- | --- | --- | --- | --- | --- | --- | --- | --- | --- | --- | --- | --- | --- | --- | --- | --- | --- | --- | --- | --- |
| 1358 | 267 | **Introduction of LTE 450 MHz band in Brazil** | 331d? | 2012-09-11 A | 2013-12-06 A | 100% |  | 2012-09-11 | 2013-12-06 | 331d? |  |  | R4; R5 | 10000h | 10000h | LTE450_Brazil | PCG-29 | Huawei | Liehai Liu (liuliehai@huawei.com) | Rel-12 | RP-57 | Issam | LTE450_Brazil |  |  |  |  |
| 1359 | 267.1 | Core part: Introduction of LTE 450 MHz band in Brazil | 201d? | 2012-09-11 A | 2013-06-14 A | 100% |  | 2012-09-11 | 2013-06-14 | 201d? |  | finish no earlier than 2013-06-14 | R4 | 1608h | 1608h | LTE450_Brazil-Core | PCG-29 | Huawei | Liehai Liu (liuliehai@huawei.com) | Rel-12 | RP-57 | Issam | LTE450_Brazil-Core | RP-130567 |  |  |  |
| 1360 | 267.2 | Perf. part: Introduction of LTE 450 MHz band in Brazil | 261d? | 2012-09-13 A | 2013-09-06 A | 100% |  | 2012-09-13 | 2013-09-06 | 261d? |  | finish no earlier than 2013-09-06 | R4 | 2088h | 2088h | LTE450_Brazil-Perf | PCG-29 | Huawei | Liehai Liu (liuliehai@huawei.com) | Rel-12 | RP-57 | Issam | LTE450_Brazil-Perf | RP-131070 |  |  |  |
| 1361 | 267.3 | Test part: Introduction of LTE 450 MHz band in Brazil | 126d? | 2013-06-18 A | 2013-12-06 A | 100% |  | 2013-06-18 | 2013-12-06 | 126d? |  | finish no earlier than 2013-12-06 | R5 | 1008h | 1008h | LTE450_Brazil-UEConTest | PCG-31 | Huawei | Xiang Li (tricia.li@huawei.com) | Rel-12 | RP-60 | Ingbert | LTE450_Brazil-UEConTest | RP-131457 |  |  |  |
| 1362 | 268 | **Further Downlink MIMO Enhancement for LTE Advanced** | 927d? | 2012-09-11 A | 2016-03-15 | 80% | 183.86d? | 2012-09-11 | 2014-09-12 | 532d? | 327d |  | R1; R4 | 25384.8h | 18063.7h | LTE_eDL_MIMO_enh | PCG-29 | Alcatel-Lucent | Min Zhang (min.hs.zhang@alcatel-lucent.com) | Rel-12 | RP-57 | Patrick | LTE_eDL_MIMO_enh |  |  |  |  |
| 1363 | 268.1 | Core part: Further Downlink MIMO Enhancement for LTE Advanced | 464d? | 2012-09-11 A | 2014-06-13 A | 100% |  | 2012-09-11 | 2014-06-13 | 464d? |  | finish no earlier than 2014-06-13 | R1 | 3696.76h | 3696.76h | LTE_eDL_MIMO_enh-Core | PCG-29 | Alcatel-Lucent | Min Zhang (min.hs.zhang@alcatel-lucent.com) | Rel-12 | RP-57 | Patrick | LTE_eDL_MIMO_enh-Core | RP-140652 |  |  |  |
| 1364 | 268.2 | Perf. part: Further Downlink MIMO Enhancement for LTE Advanced | 595d? | 2012-09-15 A | 2014-12-15 A | 100% |  | 2012-09-18 | 2014-09-12 | 526d? |  | finish no earlier than 2014-12-15 | R4 | 4760h | 4760h | LTE_eDL_MIMO_enh-Perf | PCG-29 | Alcatel-Lucent | ren.da@alcatel-lucent.com | Rel-12 | RP-57 | Issam | LTE_eDL_MIMO_enh-Perf | RP-142042 |  |  |  |
| 1365 | 268.3 | UE Conformance Test Aspects - Further DL MIMO Enhancement for LTE-Advanced | 262d? | 2015-03-16 | 2016-03-15 |  |  |  |  |  | 327d | finish no earlier than 2016-03-15 | R5 | 2096h |  | LTE_eDL_MIMO_enh-UEConTest | PCG-34 | ZTE |  | Rel-12 | RP-67 |  |  |  |  |  |  |
| 1366 | 269 | **Deleted - New Carrier Type for LTE** | 265d? | 2012-09-11 A | 2013-09-06 A | 100% |  | 2012-09-11 | 2013-09-06 | 265d? |  |  | R1; R2; R4 | 14808h | 14808h | LTE_NCT | PCG-29 | Ericsson | daniel.n.larsson@ericsson.com | Rel-12 | RP-57 | Patrick | LTE_NCT |  | PCG-31 | RP-61 |  |
| 1367 | 269.1 | Deleted - Core part: New Carrier Type for LTE | 265d? | 2012-09-11 A | 2013-09-06 A | 100% |  | 2012-09-11 | 2013-09-06 | 265d? |  | finish no earlier than 2013-09-06 | R1; R2; R4 | 6360h | 6360h | LTE_NCT-Core | PCG-29 | Ericsson | daniel.n.larsson@ericsson.com | Rel-12 | RP-57 | Patrick | LTE_NCT-Core | RP-130984 | PCG-31 | RP-61 |  |
| 1368 | 269.2 | Deleted - Perf. part: New Carrier Type for LTE | 261d? | 2012-09-17 A | 2013-09-06 A | 100% |  | 2012-09-17 | 2013-09-06 | 261d? |  | finish no earlier than 2013-09-06 | R4 | 2088h | 2088h | LTE_NCT-Perf | PCG-29 | Ericsson | daniel.n.larsson@ericsson.com | Rel-12 | RP-57 | Issam | LTE_NCT-Perf | RP-130985 | PCG-31 | RP-61 |  |
| 1369 | 270 | **Further Enhancements to LTE TDD for DL-UL Interference Management and Traffic Adaptation** | 666d? | 2012-12-07 A | 2015-06-15 | 57% | 288.93d? | 2012-12-07 | 2014-12-05 | 527d? | 523d |  | R1; R2; R3; R4 | 27370.6h | 7692.86h | LTE_TDD_eIMTA | PCG-30 | CATT | Zukang Shen (shenzukang@catt.cn) | Rel-12 | RP-58 | Patrick | LTE_TDD_eIMTA |  |  |  | Small cell |
| 1370 | 270.1 | Core part: Further Enhancements to LTE TDD for DL-UL Interference Management and Traffic Adaptation | 24.58d? | 2012-12-07 A | 2014-06-13 A | 100% |  | 2012-12-07 | 2014-06-13 | 24.58d? |  | finish no earlier than 2014-06-13 | R1; R2; R3; R4 | 786.56h | 786.56h | LTE_TDD_eIMTA-Core | PCG-30 | CATT | Zukang Shen (shenzukang@catt.cn) | Rel-12 | RP-58 | Patrick | LTE_TDD_eIMTA-Core | RP-140724 |  |  | Small cell |
| 1371 | 270.2 | Perf. part: Further Enhancements to LTE TDD for DL-UL Interference Management and Traffic Adaptation | 659d? | 2012-12-15 A | 2015-06-15 | 55% | 296.55d? | 2012-12-07 | 2014-12-05 | 527d? | 523d | finish no earlier than 2015-06-15 | R4 | 5272h | 2899.6h | LTE_TDD_eIMTA-Perf | PCG-30 | CATT | Zukang Shen (shenzukang@catt.cn) | Rel-12 | RP-58 | Patrick | LTE_TDD_eIMTA-Perf | RP-150154 |  |  | Small cell |
| 1372 | 271 | **HetNet Mobility enhancements for LTE** | 641.65d? | 2012-04-13 A | 2014-09-12 A | 100% |  | 2012-04-13 | 2014-09-12 | 640.65d? |  |  | R2; R4 | 11624h | 11624h | HetNet_eMOB_LTE | PCG-30 | Alcatel-Lucent | sudeep.palat@alcatel-lucent.com | Rel-12 | RP-58 | Yong-Jun | HetNet_eMOB_LTE |  |  |  |  |
| 1373 | 271.1 | Core part: HetNet Mobility enhancements for LTE | 263.5d? | 2012-04-13 A | 2014-09-12 A | 100% |  | 2012-04-13 | 2014-09-12 | 263.5d? |  | finish no earlier than 2014-09-12 | R2; R4 | 4216h | 4216h | HetNet_eMOB_LTE-Core | PCG-30 | Alcatel-Lucent | sudeep.palat@alcatel-lucent.com | Rel-12 | RP-58 | Yong-Jun | HetNet_eMOB_LTE-Core | RP-141413 |  |  |  |
| 1374 | 272 | **Further enhancements for HeNB mobility-X2-GW** | 401d? | 2012-12-10 A | 2014-06-13 A | 100% |  | 2012-12-10 | 2014-06-13 | 401d? |  |  | R3 | 6408h | 6408h | EHNB_enh2_X2GW | PCG-30 | Alcatel-Lucent | Philippe.Godin@alcatel-lucent.com | Rel-12 | RP-58 | Juha | EHNB_enh2_X2GW |  |  |  | HNB |
| 1375 | 272.1 | Core part: Further enhancements for HeNB mobility-X2-GW | 400d? | 2012-12-10 A | 2014-06-13 A | 100% |  | 2012-12-10 | 2014-06-13 | 400d? |  | finish no earlier than 2014-06-13 | R3 | 3200h | 3200h | EHNB_enh2_X2GW-Core | PCG-30 | Alcatel-Lucent | Philippe.Godin@alcatel-lucent.com | Rel-12 | RP-58 | Juha | EHNB_enh2_X2GW-Core | RP-140592 |  |  | HNB |
| 1376 | 273 | **8 Rx Antennas for LTE UL** | 265d? | 2012-12-10 A | 2013-12-06 A | 100% |  | 2012-12-10 | 2013-12-06 | 265d? |  |  | R4 | 4208h | 4208h | LTE_UL_8Rx | PCG-30 | China Telecom | Shan Yang (yangshan@ctbri.com.cn) | Rel-12 | RP-58 | Issam | LTE_UL_8Rx |  |  |  |  |
| 1377 | 273.1 | Perf. part: 8 Rx Antennas for LTE UL | 261d? | 2012-12-10 A | 2013-12-06 A | 100% |  | 2012-12-10 | 2013-12-06 | 261d? |  | finish no earlier than 2013-12-06 | R4 | 2088h | 2088h | LTE_UL_8Rx-Perf | PCG-30 | China Telecom | Shan Yang (yangshan@ctbri.com.cn) | Rel-12 | RP-58 | Issam | LTE_UL_8Rx-Perf | RP-131523 |  |  |  |
| 1378 | 274 | **Low cost & enhanced coverage MTC UE for LTE** | 659d? | 2013-06-15 A | 2015-12-15 | 72% | 183.76d? | 2013-06-20 | 2015-03-13 | 456d? | 392d |  | R1; R2; R4 | 25688h | 8497.6h | LC_MTC_LTE | PCG-31 | Vodafone | eric.bouton@vodafone.com | Rel-12 | RP-60 | Patrick | LC_MTC_LTE |  |  |  | MTC, M2M |
| 1379 | 274.1 | Core part: Low cost & enhanced coverage MTC UE for LTE | 174.67d? | 2013-06-15 A | 2014-12-15 A | 100% |  | 2013-10-15 | 2014-09-12 | 108.67d? |  | finish no earlier than 2014-12-15 | R1; R2; R4 | 4192h | 4192h | LC_MTC_LTE-Core | PCG-31 | Vodafone | eric.bouton@vodafone.com | Rel-12 | RP-60 | Patrick | LC_MTC_LTE-Core | RP-142024 |  |  | MTC, M2M |
| 1380 | 274.2 | Perf. part: Low cost & enhanced coverage MTC UE for LTE | 522d? | 2013-06-15 A | 2015-06-15 | 90% | 52.2d? | 2013-06-20 | 2015-03-13 | 456d? | 523d | finish no earlier than 2015-06-15 | R4 | 4176h | 3758.4h | LC_MTC_LTE-Perf | PCG-31 | Vodafone | eric.bouton@vodafone.com | Rel-12 | RP-60 | Issam | LC_MTC_LTE-Perf | RP-150149 |  |  | MTC, M2M |
| 1381 | 274.3 | UE Conformance Test Aspects - Low cost & enhanced coverage MTC UE for LTE | 197d? | 2015-03-16 | 2015-12-15 |  |  |  |  |  | 392d | finish no earlier than 2015-12-15 | R5 | 1576h |  | LC_MTC_LTE-UEConTest | PCG-34 | Ericsson |  | Rel-12 | RP-67 |  |  |  |  |  |  |

Notes:
- 1358: - / Impacted TSs and TRs: LTE
- 1359: RP#60 completed. TR 36.840 v100 for 1-step Approval / Impacted TSs and TRs: 36.101, 36.104, 36.113, 36.124, 36.133, 37.104, 37.113, 36.307, new TR 36.840
- 1360: RP#61 completed / Impacted TSs and TRs: 36.133, 36.141, 37.141
- 1361: RP#62 completed / Impacted TSs and TRs: 36.508, 36.521-1, 36.521-2, 36.521-3
- 1362: Stage 3 / Impacted TSs and TRs: LTE
- 1363: RP#64 completed / Impacted TSs and TRs: 36.211, 36.212, 36.213, 36.331
- 1364: ; CD:Fri 12/06/15->Mon 15/06/15; WID: RP-141966->RP-142235; Stat Rep: RP-141378->RP-142042 / Impacted TSs and TRs: 36.101
- 1366: RP#61 stopped. Continue discussion on use cases and requirements for a NCT in LTE beyond Rel-12. Action: Ericsson to provide at RP#62 a summary of work done so far / Impacted TSs and TRs: LTE
- 1367: RP#61 stopped at 20% completion / Impacted TSs and TRs: 36.101, 36.104, 36.133, 36.211, 36.212, 36.213, 36.321, 36.331
- 1368: RP#61 stopped at 0% completion / Impacted TSs and TRs: 36.101, 36.104, 36.133, 36.141
- 1369: Stage 3. Triggered by Rel-11 TR 36.828 Study on Further Enhancements to LTE TDD for DL-UL Interference Management and Traffic Adaptation (FS_LTE_TDD_eIMTA) UID_510039 / Impacted TSs and TRs: LTE
- 1370: RP#64 completed / Impacted TSs and TRs: 36.101, 36.104, 36.133, 36.211, 36.212, 36.213, 36.214, 36.300, 36.321, 36.331, 36.413, 36.423
- 1371: ; CD:Thu 18/06/15->Mon 15/06/15; WID: RP-141966->RP-142235; Stat Rep: RP-141342->RP-141948 1st Apr 15: Compl:30%->55% 1st Apr 15: Stat Rep: RP-141948->RP-150154 / Impacted TSs and TRs: 36.101, 36.104, 36.133, 36.141
- 1372: Stage 3. Triggered by Rel-11 TR 36.839 Study on HetNet mobility enhancements for LTE (FS_HetNet_eMOB_LTE) / Impacted TSs and TRs: LTE
- 1373: SP#65 completed / Impacted TSs and TRs: 36.133, 36.304, 36.331
- 1374: Rel-10 H(e)NB Mobility Enhancements adds signalling via horizontal RAN interfaces (Iurh, X2) to support H(e)NB to H(e)NB mobility. Rel-11 TR37.803 triggered WI UID_560014 partly completed in Rel-11; remaining work including solution definition is Rel-12 / Impacted TSs and TRs: LTE
- 1375: RP#64 completed / Impacted TSs and TRs: 36.300, 36.413, 36.423
- 1376: WI has perf. part only (as change from 4Rx to 8Rx has no Core spec impact) / Impacted TSs and TRs: LTE
- 1377: RP#62 completed / Impacted TSs and TRs: 36.104, 36.141
- 1378: Triggered by Rel-11 TR 36.888 (FS_LC_MTC_UE) / Impacted TSs and TRs: LTE
- 1379: ; CD:Thu 18/06/15->Mon 15/06/15; WID: RP-130848->RP-140522; Stat Rep: RP-141221->RP-142024 / Impacted TSs and TRs: 36.101, 36.104, 36.133, 36.201, 36.211, 36.212, 36.213, 36.300, 36.302, 36.306, 36.321, 36.331
- 1380: ; CD:Thu 18/06/15->Mon 15/06/15; WID: RP-130848->RP-140522; Stat Rep: RP-141221->RP-142024 1st Apr 15: Compl:65%->90% 1st Apr 15: CD:Sun 15/03/15->Mon 15/06/15 1st Apr 15: Stat Rep: RP-142024->RP-150149 / Impacted TSs and TRs: 36.101, 36.104, 36.133

| ID | WBS | Task | Duration | Start | Finish | Complete | Remaining | Baseline start | Baseline finish | Baseline duration | Total slack | Constraint | Resources | Work | Actual work | Acronym | PCG approved | WI rapporteur name | Release | TSG approved | MCC resp | Acronym_3GU_Export | Status Report | Special Focus Doc |
| --- | --- | --- | --- | --- | --- | --- | --- | --- | --- | --- | --- | --- | --- | --- | --- | --- | --- | --- | --- | --- | --- | --- | --- | --- |
| 1382 | 275 | **LTE TDD-FDD joint operation including Carrier Aggregation** | 444.03d? | 2013-04-12 A | 2014-12-15 | 99% | 0d? | 2013-04-12 | 2014-12-05 | 435.03d? | 0d |  | R1; R2; R4 | 14776h | 14756.4h | LTE_CA_TDD_FDD | PCG-31 | Nokia | Rel-12 | RP-60 | Patrick | LTE_CA_TDD_FDD |  |  |
| 1383 | 275.1 | Core part: LTE TDD-FDD joint operation including Carrier Aggregation | 87.33d? | 2013-04-12 A | 2014-06-13 A | 100% |  | 2013-04-12 | 2014-06-13 | 87.33d? |  | finish no earlier than 2014-06-13 | R1; R2; R4 | 2096h | 2096h | LTE_CA_TDD_FDD-Core | PCG-31 | Nokia, China Mobile (for TR) | Rel-12 | RP-60 | Patrick | LTE_CA_TDD_FDD-Core | RP-140982 |  |
| 1384 | 275.2 | Perf. part: LTE TDD-FDD joint operation including Carrier Aggregation | 397d? | 2013-06-15 A | 2014-12-15 A | 100% |  | 2013-06-20 | 2014-12-05 | 386d? |  | finish no earlier than 2014-12-15 | R4 | 3176h | 3176h | LTE_CA_TDD_FDD-Perf | PCG-31 | Nokia | Rel-12 | RP-60 | Issam | LTE_CA_TDD_FDD-Perf | RP-141972 |  |
| 1385 | 276 | **LTE Coverage Enhancements** | 670.17d? | 2013-03-01 A | 2015-09-15 | 66% | 224.7d? | 2013-03-01 | 2014-12-05 | 465.17d? | 457d |  | R1; R2; R4; R5 | 28821.4h | 11068.4h | Cov_Enh_LTE | PCG-31 | China Telecom | Rel-12 | RP-60 | Patrick | Cov_Enh_LTE |  |  |
| 1386 | 276.1 | Core part: LTE Coverage Enhancements | 87d? | 2013-03-01 A | 2014-06-13 A | 100% |  | 2013-03-01 | 2014-06-13 | 87d? |  | finish no earlier than 2014-06-13 | R1; R2; R4 | 2088h | 2088h | Cov_Enh_LTE-Core | PCG-31 | China Telecom | Rel-12 | RP-60 | Patrick | Cov_Enh_LTE-Core | RP-140683 |  |
| 1387 | 276.2 | Perf. part: LTE Coverage Enhancements | 397d? | 2013-06-15 A | 2014-12-15 A | 100% |  | 2013-06-20 | 2014-12-05 | 386d? |  | finish no earlier than 2014-12-15 | R4 | 3176h | 3176h | Cov_Enh_LTE-Perf | PCG-31 | China Telecom | Rel-12 | RP-60 | Issam | Cov_Enh_LTE-Perf | RP-141833 |  |
| 1388 | 276.3 | Test part: LTE Coverage Enhancements | 264d? | 2014-09-15 A | 2015-09-15 | 5% | 250.8d? |  |  |  | 457d | finish no earlier than 2015-09-15 | R5 | 2112h | 105.6h | Cov_Enh_LTE-UEConTest | PCG-33 | China Telecom | Rel-12 | RP-65 |  | Cov_Enh_LTE-UEConTest | RP-141834 |  |
| 1389 | 277 | **Further MBMS operations support for E-UTRAN** | 330d? | 2013-09-15 A | 2014-12-15 A | 100% |  | 2013-12-09 | 2014-09-12 | 201d? |  |  | R2; R1; R3; R4 | 21280h | 21280h | MBMS_LTE_OS | PCG-31 | Verizon | Rel-12 | RP-61 | Yong-Jun | MBMS_LTE_OS |  |  |
| 1390 | 277.1 | Core part: Further MBMS operations support for E-UTRAN | 329d? | 2013-09-15 A | 2014-12-15 A | 100% |  | 2014-04-04 | 2014-09-12 | 115.25d? |  | finish no earlier than 2014-12-15 | R2; R1; R3; R4 | 10528h | 10528h | MBMS_LTE_OS-Core | PCG-31 | Verizon | Rel-12 | RP-61 | Yong-Jun | MBMS_LTE_OS-Core | RP-141821 |  |
| 1391 | 277.2 | Perf. part: Further MBMS operations support for E-UTRAN | 264d? | 2013-12-15 A | 2014-12-15 A | 100% |  | 2013-12-09 | 2014-09-12 | 201d? |  | finish no earlier than 2014-12-15 | R4 | 2112h | 2112h | MBMS_LTE_OS-Perf | PCG-32 | Verizon | Rel-12 | RP-62 | Issam | MBMS_LTE_OS-Perf | RP-141821 |  |
| 1392 | 278 | **Dual connectivity for LTE** | 395d? | 2013-12-15 A | 2015-06-15 | 75% | 100.6d? | 2013-12-09 | 2014-12-05 | 261d? | 523d |  | R2; R1; R3; R4; S2; C4 | 32120h | 15563.1h | LTE_SC_enh_dualC | PCG-32 | NTT DOCOMO | Rel-12 | RP-62 | Yong-Jun | LTE_SC_enh_dualC |  | Small cell |
| 1393 | 278.1 | Core part: Dual connectivity for LTE | 264d? | 2013-12-15 A | 2014-12-15 A | 100% |  | 2014-04-29 | 2014-09-12 | 99d? |  | finish no earlier than 2014-12-15 | R2; R1; R3; R4 | 8448h | 8448h | LTE_SC_enh_dualC-Core | PCG-32 | NTT DOCOMO, NEC | Rel-12 | RP-62 | Yong-Jun | LTE_SC_enh_dualC-Core | RP-141796 | Small cell |
| 1394 | 278.2 | Perf. part: Dual Connectivity for LTE | 395d? | 2013-12-15 A | 2015-06-15 | 45% | 217.25d? | 2013-12-09 | 2014-12-05 | 261d? | 523d | finish no earlier than 2015-06-15 | R4 | 3160h | 1422h | LTE_SC_enh_dualC-Perf | PCG-32 | NTT DOCOMO | Rel-12 | RP-62 | Issam | LTE_SC_enh_dualC-Perf | RP-150160 | Small cell |
| 1395 | 278.3 | SA2 part of Dual connectivity for LTE | 131d? | 2014-03-19 A | 2014-09-17 A | 100% |  | 2014-03-19 | 2014-09-17 | 131d? |  | finish no earlier than 2014-09-17 | S2 | 1048h | 1048h |  | PCG-32 |  | Rel-12 | RP-63 |  |  |  | Small cell |
| 1396 | 278.4 | CT aspects of Dual connectivity for LTE | 63d? | 2014-09-12 A | 2014-12-09 A | 100% |  |  |  |  |  | finish no earlier than 2014-12-09 | C4 | 504h | 504h | LTE_SC_enh_dualC-CT | PCG-33 | Huawei | Rel-12 | CP-65 |  | LTE_SC_enh_dualC-CT | CP-140487 | Small cell |
| 1397 | 279 | **E-UTRA Small cell enhancements - Physical layer aspects** | 395d? | 2013-12-15 A | 2015-06-15 | 86% | 56.05d? | 2013-07-19 | 2014-12-05 | 364.75d? | 523d |  | R1; R2; R4 | 15588.7h | 8309.6h | LTE_SC_enh_L1 | PCG-32 | Huawei | Rel-12 | RP-62 | Patrick | LTE_SC_enh_L1 |  | Small cell |
| 1398 | 279.1 | Core part: E-UTRA Small cell enhancements - Physical layer aspects | 161.25d? | 2013-12-15 A | 2014-12-15 A | 100% |  | 2013-07-19 | 2014-09-12 | 202d? |  | finish no earlier than 2014-12-15 | R1; R2; R4 | 3870h | 3870h | LTE_SC_enh_L1-Core | PCG-32 | Huawei | Rel-12 | RP-62 | Patrick | LTE_SC_enh_L1-Core | RP-141899 | Small cell |
| 1399 | 279.2 | Perf. part: E-UTRA Small cell enhancements - Physical layer aspects | 394d? | 2013-12-15 A | 2015-06-15 | 80% | 78.8d? | 2013-12-09 | 2014-12-05 | 261d? | 523d | finish no earlier than 2015-06-15 | R4 | 3152h | 2521.6h | LTE_SC_enh_L1-Perf | PCG-32 | Huawei | Rel-12 | RP-62 | Issam | LTE_SC_enh_L1-Perf | RP-150173 | Small cell |
| 1400 | 280 | **Inter-eNB Coordinated Multi-Point (CoMP) for LTE** | 264d? | 2013-12-15 A | 2014-12-15 A | 100% |  | 2014-03-14 | 2014-09-12 | 130.65d? |  |  | R3; R1 | 4738.38h | 4738.38h | COMP_LTE_IeNB | PCG-32 | Samsung | Rel-12 | RP-62 | Juha | COMP_LTE_IeNB |  |  |
| 1401 | 280.1 | Core part: Inter-eNB Coordinated Multi-Point (CoMP) for LTE | 165.5d? | 2013-12-15 A | 2014-12-15 A | 100% |  | 2014-03-14 | 2014-09-12 | 100.5d? |  | finish no earlier than 2014-12-15 | R3; R1 | 2648h | 2648h | COMP_LTE_IeNB-Core | PCG-32 | Samsung | Rel-12 | RP-62 | Juha | COMP_LTE_IeNB-Core | RP-141804 |  |
| 1402 | 281 | **Smart Congestion Mitigation in E-UTRAN** | 403d? | 2014-03-05 A | 2015-09-15 | 61% | 157.38d? | 2014-03-05 | 2014-09-12 | 138d? | 457d |  | R2; S1; C1 | 12376h | 4984h | SCM_LTE | PCG-32 | LG Electronics | Rel-12 | RP-63 | Yong-Jun | SCM_LTE |  |  |
| 1403 | 281.1 | Core part: Smart Congestion Mitigation in E-UTRAN | 137d? | 2014-03-06 A | 2014-09-12 A | 100% |  | 2014-03-06 | 2014-09-12 | 137d? |  | finish no earlier than 2014-09-12 | R2 | 1096h | 1096h | SCM_LTE-Core | PCG-32 | LG Electronics | Rel-12 | RP-63 | Yong-Jun | SCM_LTE-Core | RP-141292 |  |
| 1404 | 281.2 | Stage 1 Prioritization of Multimedia Telephony (MMTel) and Mobile Originating-SMS for Access Class Barring (ACB) | 3d? | 2014-03-05 A | 2014-03-07 A | 100% |  | 2014-03-05 | 2014-03-07 | 3d? |  | finish no earlier than 2013-12-11 | S1 | 24h | 24h |  | PCG-33 |  | Rel-12 | CP-64 |  |  |  |  |
| 1405 | 281.3 | CT aspects of Smart Congestion Mitigation in E-UTRAN (Stage 3) | 66d? | 2014-06-13 A | 2014-09-11 A | 100% |  | 2014-06-13 | 2014-09-12 | 66d? |  | start no earlier than 2014-06-13 | C1 | 528h | 528h | SCM_LTE-CT | PCG-33 | LG Electronics | Rel-12 | CP-64 |  | SCM_LTE-CT |  |  |
| 1406 | 281.4 | UE Conformance Test Aspects - Smart Congestion Mitigation in E-UTRAN | 132d? | 2015-03-16 | 2015-09-15 |  |  |  |  |  | 457d | finish no earlier than 2015-09-15 | R5 | 1056h |  | SCM_LTE-UEConTest | PCG-34 | NTT DOCOMO | Rel-12 | RP-67 |  |  |  |  |

Notes:
- 1382: - / Impacted TSs and TRs: LTE / WI rapporteur e-mail: lars.e.lindh@nokia.com
- 1383: RP#64 completed / Impacted TSs and TRs: 36.101, 36.104, 36.133, 36.201, 36.211, 36.212, 36.213, 36.300, 36.302, 36.306, 36.331, new TR 36.847 / WI rapporteur e-mail: lars.e.lindh@nokia.com, Xiaodong Shen (shenxiaodong@chinamobile.com)
- 1384: ; CD:Thu 18/06/15->Mon 15/06/15; WID: RP-130848->RP-140522; Stat Rep: RP-141374->RP-141972 / Impacted TSs and TRs: 36.101, 36.104, 36.133 / WI rapporteur e-mail: lars.e.lindh@nokia.com
- 1385: Triggered by Rel-11 TR 36.824 (FS_Cov_Enh_LTE) / Impacted TSs and TRs: LTE / WI rapporteur e-mail: Xiaoming She (shexm@ctbri.com.cn)
- 1386: RP#64 completed / Impacted TSs and TRs: 36.101, 36.104, 36.133, 36.211, 36.212, 36.213, 36.300, 36.321, 36.331 / WI rapporteur e-mail: Xiaoming She (shexm@ctbri.com.cn)
- 1387: ; CD:Thu 18/06/15->Mon 15/06/15; WID: RP-141966->RP-142235; Stat Rep: RP-141149->RP-141833 / Impacted TSs and TRs: 36.101, 36.104, 36.133, 36.141 / WI rapporteur e-mail: Xiaoming She (shexm@ctbri.com.cn)
- 1388: ; Stat Rep: -->RP-141834 / Impacted TSs and TRs: 36.508, 36.523-1, 36.523-2, 36.523-3 / WI rapporteur e-mail: YANG Shan (yangshan@ctbri.com.cn)
- 1389: Solutions for Minimization of Drive Tests (MDT), in order to reduce the need for manual drive testing for MBMS. / Impacted TSs and TRs: LTE / WI rapporteur e-mail: yeesin.chan@verizonwireless.com
- 1390: ; CD:Thu 18/06/15->Mon 15/06/15; WID: RP-130848->RP-140522; Stat Rep: RP-141431->RP-141821 / Impacted TSs and TRs: 36.133, 36.214, 36.300, 36.304, 36.306, 36.331, 36.413, 36.423, 37.320 / WI rapporteur e-mail: yeesin.chan@verizonwireless.com
- 1391: ; CD:Wed 17/12/14->Mon 15/12/14; WID: RP-130848->RP-140522; Stat Rep: RP-141431->RP-141821 / Impacted TSs and TRs: 36.133 / WI rapporteur e-mail: yeesin.chan@verizonwireless.com
- 1392: Triggered by TR 36.842 Study on Small Cell Enhancements for E-UTRA and E-UTRAN Higher-layer aspects (UID_580044) / Impacted TSs and TRs: LTE / WI rapporteur e-mail: tooru.uchino.fv@nttdocomo.com
- 1393: ; CD:Wed 18/03/15->Sun 15/03/15; WID: RP-130848->RP-140522; Stat Rep: RP-141264->RP-141796 / Impacted TSs and TRs: 36.101, 36.104, 36.133, 36.211, 36.212, 36.213, 36.300, 36.302, 36.306, 36.321, 36.322, 36.323, 36.331, 36.410, 36.413, 36.420, 36.423, new RAN3 TS 36.425 / WI rapporteur e-mail: RAN1/2/4 tooru.uchino.fv@nttdocomo.com, RAN3 Chenghock Ng (ngcheng@da.jp.nec.com)
- 1394: ; Stat Rep: RP-141264->RP-141796 1st Apr 15: Compl:15%->45% 1st Apr 15: Stat Rep: RP-141796->RP-150160 / Impacted TSs and TRs: 36.101, 36.104, 36.133 / WI rapporteur e-mail: kunihiko.teshima.hg@nttdocomo.com
- 1395: SP#64 Three CRs agreed in SP-140262 (23.251CR0099, 23.401CR2658&CR2707). Dec.14:99->100% / Impacted TSs and TRs: 23.251, 23.401
- 1396: Stage 2/3. CP#65 exception in CP-140487. LM70->100 / Impacted TSs and TRs: 23.007, 23.008, 29.274, 29.281 / WI rapporteur e-mail: Xiaoyan SHI (sean.shixiaoyan@huawei.com)
- 1397: Triggered by TR 36.872 Study on Small Cell Enhancements for E-UTRA and E-UTRAN Physical-layer aspects (UID_580041) / Impacted TSs and TRs: LTE / WI rapporteur e-mail: Elean FAN (fanxiaoan@huawei.com)
- 1398: ; CD:Tue 12/05/15->Mon 15/12/14; WID: RP-130848->RP-140522; Stat Rep: RP-141632->RP-141899 / Impacted TSs and TRs: 36.101, 36.104, 36.133, 36.211, 36.212, 36.213, 36.214, 36.300, 36.306, 36.321, 36.331, 36.413, 36.423, 36.443 / WI rapporteur e-mail: Elean FAN (fanxiaoan@huawei.com)
- 1399: ; CD:Wed 18/03/15->Sun 15/03/15; WID: RP-130848->RP-140522; Stat Rep: RP-141632->RP-141899 1st Apr 15: Compl:40%->80% 1st Apr 15: CD:Sun 15/03/15->Mon 15/06/15 1st Apr 15: Stat Rep: RP-141899->RP-150173 / Impacted TSs and TRs: 36.101, 36.104, 36.133, 36.141 / WI rapporteur e-mail: Elean FAN (fanxiaoan@huawei.com)
- 1400: Stage 3. Rel-11 did not address support of a network interface for CoMP involving multiple eNBs with non-ideal backhaul (affected operators might not take advantage of performance benefit from inter-eNB CoMP operation). / Impacted TSs and TRs: LTE / WI rapporteur e-mail: Sung Hwan Won (sunghwan.won@samsung.com)
- 1401: CD:Thu 11/12/14->Mon 15/12/14; Compl:85%->100%; Stat Rep: RP-140597->RP-141804 / Impacted TSs and TRs: 36.300, 36.423 / WI rapporteur e-mail: Sung Hwan Won (sunghwan.won@samsung.com)
- 1402: follow-up of TR 36.848 FS_SCM_LTE / Impacted TSs and TRs: LTE / WI rapporteur e-mail: youngdae.lee@lge.com
- 1403: RP#65 completed / Impacted TSs and TRs: 36.331 / WI rapporteur e-mail: youngdae.lee@lge.com
- 1404: SP#63 SP-140065 CR under TEI12 / Impacted TSs and TRs: 22.011
- 1405: CP#65 completed / Impacted TSs and TRs: 24.173, 24.301, 24.341, 27.007 / WI rapporteur e-mail: Kim, Jaehyun (jaehyun7.kim@lge.com)

| ID | WBS | Task | Duration | Start | Finish | Complete | Remaining | Baseline start | Baseline finish | Baseline duration | Total slack | Constraint | Resources | Work | Actual work | Acronym | PCG approved | WI rapporteur name | WI rapporteur e-mail | Release | TSG approved | MCC resp | Acronym_3GU_Export | Status Report | Special Focus Doc |
| --- | --- | --- | --- | --- | --- | --- | --- | --- | --- | --- | --- | --- | --- | --- | --- | --- | --- | --- | --- | --- | --- | --- | --- | --- | --- |
| 1407 | 282 | **Positioning Enhancements for RF Pattern Matching in E-UTRA** | 36d? | 2014-04-25 A | 2014-06-13 A | 100% |  | 2014-04-25 | 2014-06-13 | 36d? |  |  | R3; R2 | 1152h | 1152h | LCS_LTE_RFPMT | PCG-32 | Polaris Wireless | Gordon Scot (sgordon@polariswireless.com) | Rel-12 | RP-63 | Juha | LCS_LTE_RFPMT |  |  |
| 1408 | 282.1 | Core part: Positioning Enhancements for RF Pattern Matching in E-UTRA | 36d? | 2014-04-25 A | 2014-06-13 A | 100% |  | 2014-04-25 | 2014-06-13 | 36d? |  | finish no earlier than 2014-06-13 | R3; R2 | 576h | 576h | LCS_LTE_RFPMT-Core | PCG-32 | Polaris Wireless | Gordon Scot (sgordon@polariswireless.com) | Rel-12 | RP-63 | Juha | LCS_LTE_RFPMT-Core | RP-140591 |  |
| 1409 | 283 | **Network-Assisted Interference Cancellation and Suppression for LTE** | 333d? | 2014-03-11 A | 2015-06-15 | 63% | 124.13d? | 2014-03-06 | 2015-06-12 | 332d? | 523d |  | R1; R2; R4; R3 | 16123.9h | 5806.83h | LTE_NAICS | PCG-32 | MediaTek | Craig.Burnet@mediatek.com | Rel-12 | RP-63 | Patrick | LTE_NAICS |  |  |
| 1410 | 283.1 | Core part: Network-Assisted Interference Cancellation and Suppression for LTE | 113.67d? | 2014-07-11 A | 2014-12-15 A | 100% |  | 2014-07-11 | 2014-09-12 | 45.67d? |  | finish no earlier than 2014-12-15 | R1; R2; R4; R3 | 2803.87h | 2803.87h | LTE_NAICS-Core | PCG-32 | MediaTek | Craig.Burnet@mediatek.com | Rel-12 | RP-63 | Patrick | LTE_NAICS-Core | RP-141866 |  |
| 1411 | 283.2 | Perf. part: Network-Assisted Interference Cancellation and Suppression for LTE | 333d? | 2014-03-11 A | 2015-06-15 | 50% | 166.5d? | 2014-03-06 | 2015-06-12 | 332d? | 523d | finish no earlier than 2015-06-15 | R4 | 2664h | 1332h | LTE_NAICS-Perf | PCG-32 | MediaTek | Craig.Burnet@mediatek.com | Rel-12 | RP-63 | Issam | LTE_NAICS-Perf | RP-150179 |  |
| 1412 | 284 | **Performance requirements of interference cancellation and suppression receiver for SU-MIMO** | 532d? | 2014-03-06 A | 2016-03-15 | 50% | 263.49d? | 2014-03-06 | 2015-03-13 | 267d? | 327d |  | R4 | 8488h | 4296h | LTE_SUMIMO_RX | PCG-32 | Huawei | Qian Cheng (Q.Cheng@Huawei.com) | Rel-12 | RP-63 | Issam | LTE_SUMIMO_RX |  |  |
| 1413 | 284.1 | Perf. part: Performance requirements of interference cancellation and suppression receiver for SU-MIMO | 267d? | 2014-03-06 A | 2015-03-15 A | 100% |  | 2014-03-06 | 2015-03-13 | 267d? |  | finish no earlier than 2015-03-15 | R4 | 2136h | 2136h | LTE_SUMIMO_RX-Perf | PCG-32 | Huawei | Qian Cheng (Q.Cheng@Huawei.com) | Rel-12 | RP-63 | Issam | LTE_SUMIMO_RX-Perf | RP-150229 |  |
| 1414 | 284.2 | UE Conformance Test Aspects - Performance Requirements of Interference Cancellation and Suppression Receiver for SU-MIMO for E-UTRA | 262d? | 2015-03-16 | 2016-03-15 |  |  |  |  |  | 327d | finish no earlier than 2016-03-15 | R5 | 2096h |  | LTE_SUMIMO_RX-UEConTest | PCG-34 | Huawei |  | Rel-12 | RP-67 |  |  |  |  |
| 1415 | 285 | **HSPA signalling enhancements for more efficient resource usage for LCR** | 274d? | 2012-12-11 A | 2013-12-20 A | 100% |  | 2012-12-10 | 2013-12-06 | 265d? |  |  | R1; R2; R3; R4 | 16832h | 16832h | LCR_TDD_HSPA_sign_enh | PCG-30 | CATT | Yanping Xing (xingyanping@catt.cn) | Rel-12 | RP-58 | Patrick | LCR_TDD_HSPA_sign_enh |  |  |
| 1416 | 285.1 | Core part: HSPA signalling enhancements for more efficient resource usage for LCR TDD | 270d? | 2012-12-15 A | 2013-12-20 A | 100% |  | 2012-12-10 | 2013-12-06 | 265d? |  | finish no earlier than 2013-12-15 | R1; R2; R3 | 6480h | 6480h | LCR_TDD_HSPA_sign_enh-Core | PCG-30 | CATT | Yanping Xing (xingyanping@catt.cn) | Rel-12 | RP-58 | Patrick | LCR_TDD_HSPA_sign_enh-Core | RP-131499 |  |
| 1417 | 285.2 | Perf. part: HSPA signalling enhancements for more efficient resource usage for LCR TDD | 198d? | 2012-12-11 A | 2013-09-06 A | 100% |  | 2012-12-11 | 2013-09-06 | 198d? |  | finish no earlier than 2013-09-06 | R4 | 1584h | 1584h | LCR_TDD_HSPA_sign_enh-Perf | PCG-30 | CATT | Yanping Xing (xingyanping@catt.cn) | Rel-12 | RP-58 | Issam | LCR_TDD_HSPA_sign_enh-Perf | RP-130968 |  |
| 1418 | 286 | **HNB Positioning for UTRA** | 127d? | 2013-06-18 A | 2013-12-06 A | 100% |  | 2013-06-18 | 2013-12-06 | 127d? |  |  | R3 | 2032h | 2032h | UTRA_HNB_Pos | PCG-31 | Alcatel-Lucent | Martin.Warner@alcatel-lucent.com | Rel-12 | RP-60 | Juha | UTRA_HNB_Pos |  | HNB |
| 1419 | 286.1 | Core part: HNB Positioning for UTRA | 127d? | 2013-06-18 A | 2013-12-06 A | 100% |  | 2013-06-18 | 2013-12-06 | 127d? |  | finish no earlier than 2013-12-06 | R3 | 1016h | 1016h | UTRA_HNB_Pos-Core | PCG-31 | Alcatel-Lucent | Martin.Warner@alcatel-lucent.com | Rel-12 | RP-60 | Juha | UTRA_HNB_Pos-Core | RP-131974 | HNB |
| 1420 | 287 | **Dedicated Channel (DCH) enhancements for UMTS** | 591d? | 2013-09-15 A | 2015-12-15 | 69% | 181.56d? | 2013-09-10 | 2014-12-05 | 326d? | 392d |  | R1; R2; R3; R4 | 26808h | 16880h | UTRA_DCHenh | PCG-31 | Qualcomm | arjunb@qti.qualcomm.com | Rel-12 | RP-61 | Patrick | UTRA_DCHenh |  |  |
| 1421 | 287.1 | Core part: Dedicated Channel (DCH) enhancements for UMTS | 115.25d? | 2013-11-18 A | 2014-09-12 A | 100% |  | 2013-11-18 | 2014-09-12 | 115.25d? |  | finish no earlier than 2014-09-12 | R1; R2; R3; R4 | 3688h | 3688h | UTRA_DCHenh-Core | PCG-31 | Qualcomm | arjunb@qti.qualcomm.com | Rel-12 | RP-61 | Patrick | UTRA_DCHenh-Core | RP-141137 |  |
| 1422 | 287.2 | Perf. part: Dedicated Channel (DCH) enhancements for UMTS | 329d? | 2013-09-15 A | 2014-12-15 A | 100% |  | 2013-09-10 | 2014-12-05 | 326d? |  | finish no earlier than 2014-12-15 | R4 | 2632h | 2632h | UTRA_DCHenh-Perf | PCG-31 | Qualcomm | arjunb@qti.qualcomm.com | Rel-12 | RP-61 | Issam | UTRA_DCHenh-Perf | RP-141970 |  |
| 1423 | 287.3 | UE Conformance Test Aspects - DCH Enhancements for UMTS | 197d? | 2015-03-16 | 2015-12-15 |  |  |  |  |  | 392d | finish no earlier than 2015-12-15 | R5 | 1576h |  | UTRA_DCHenh-UEConTest | PCG-34 | Qualcomm | NA | Rel-12 | RP-67 |  |  |  |  |
| 1424 | 288 | **UMTS Mobility enhancements for heterogeneous networks** | 237.85d? | 2013-07-23 A | 2014-06-13 A | 100% |  | 2013-07-23 | 2014-06-13 | 237.85d? |  |  | R2; R3; R4 | 8040h | 8040h | UTRA_HetNet_mob | PCG-31 | Huawei | Xudong Yang (yangxudong@huawei.com) | Rel-12 | RP-61 | Yong-Jun | UTRA_HetNet_mob |  |  |
| 1425 | 288.1 | Core part: UMTS Mobility enhancements for heterogeneous networks | 67d? | 2013-07-23 A | 2014-06-13 A | 100% |  | 2013-07-23 | 2014-06-13 | 67d? |  | finish no earlier than 2014-06-13 | R2; R3; R4 | 1608h | 1608h | UTRA_HetNet_mob-Core | PCG-31 | Huawei | Xudong Yang (yangxudong@huawei.com) | Rel-12 | RP-61 | Yong-Jun | UTRA_HetNet_mob-Core | RP-140636 |  |
| 1426 | 288.2 | Perf. part: UMTS Mobility enhancements for heterogeneous networks | 201d? | 2013-09-09 A | 2014-06-13 A | 100% |  | 2013-09-09 | 2014-06-13 | 201d? |  | finish no earlier than 2014-06-13 | R4 | 1608h | 1608h | UTRA_HetNet_mob-Perf | PCG-31 | Huawei | Xudong Yang (yangxudong@huawei.com) | Rel-12 | RP-61 | Issam | UTRA_HetNet_mob-Perf | RP-140636 |  |
| 1427 | 289 | **UMTS Heterogeneous Networks enhancements** | 271d? | 2013-12-06 A | 2014-12-15 | 99% | 0d? | 2013-12-06 | 2014-12-05 | 262d? | 0d |  | R1; R2; R3; R4 | 12408h | 12389.4h | UTRA_HetNet_enh | PCG-32 | Huawei | carmela.cozzo@huawei.com | Rel-12 | RP-62 | Patrick | UTRA_HetNet_enh |  |  |
| 1428 | 289.1 | Core part: Heterogeneous Networks enhancements | 202d? | 2013-12-06 A | 2014-09-12 A | 100% |  | 2013-12-06 | 2014-09-12 | 202d? |  | finish no earlier than 2014-09-15 | R1 | 1616h | 1616h | UTRA_HetNet_enh-Core | PCG-32 | Huawei | carmela.cozzo@huawei.com | Rel-12 | RP-62 | Patrick | UTRA_HetNet_enh-Core | RP-141702 |  |
| 1429 | 289.2 | Perf. part: Heterogeneous Networks enhancements | 265d? | 2013-12-15 A | 2014-12-15 A | 100% |  | 2013-12-09 | 2014-12-05 | 261d? |  | finish no earlier than 2014-12-15 | R4 | 2120h | 2120h | UTRA_HetNet_enh-Perf | PCG-32 | Huawei | carmela.cozzo@huawei.com | Rel-12 | RP-62 | Issam | UTRA_HetNet_enh-Perf | RP-141898 |  |
| 1430 | 290 | **Enhanced Broadcast of System Information** | 271d? | 2013-12-06 A | 2014-12-15 A | 100% |  | 2013-12-06 | 2014-12-05 | 262d? |  |  | R2; R1; R3; R4 | 16385.6h | 16385.6h | UTRA_SIBenh | PCG-32 | Ericsson | martin.van.der.zee@ericsson.com | Rel-12 | RP-62 | Yong-Jun | UTRA_SIBenh |  |  |
| 1431 | 290.1 | Core part: Enhanced Broadcast of System Information | 174.8d? | 2013-12-06 A | 2014-09-12 A | 100% |  | 2013-12-06 | 2014-09-12 | 174.8d? |  | finish no earlier than 2014-09-12 | R2; R1; R3; R4 | 5593.6h | 5593.6h | UTRA_SIBenh-Core | PCG-32 | Ericsson | martin.van.der.zee@ericsson.com | Rel-12 | RP-62 | Yong-Jun | UTRA_SIBenh-Core | RP-141230 |  |
| 1432 | 290.2 | Perf. part: Enhanced Broadcast of System Information | 265d? | 2013-12-15 A | 2014-12-15 A | 100% |  | 2013-12-09 | 2014-12-05 | 261d? |  | finish no earlier than 2014-12-15 | R4 | 2120h | 2120h | UTRA_SIBenh-Perf | PCG-32 | Ericsson | martin.van.der.zee@ericsson.com | Rel-12 | RP-62 | Issam | UTRA_SIBenh-Perf | RP-142080 |  |

Notes:
- 1407: follow-up of TR 36.809 FS_LCS_LTE_RFPMT / Impacted TSs and TRs: LTE
- 1408: RP#64 completed / Impacted TSs and TRs: 36.305, 36.455
- 1409: follow-up of TR 36.866 FS_LTE_NAICS / Impacted TSs and TRs: LTE
- 1410: CD:Mon 08/12/14->Mon 15/12/14; Compl:95%->100%; Stat Rep: RP-141621->RP-141866 / Impacted TSs and TRs: 36.211, 36.213, 36.300, 36.331, 36.423
- 1411: CD:Fri 12/06/15->Mon 15/06/15; Compl:0%->25%; Stat Rep: RP-141621->RP-141866 1st Apr 15: Compl:25%->50% 1st Apr 15: Stat Rep: RP-141866->RP-150179 / Impacted TSs and TRs: 36.101
- 1412: no Core part / Impacted TSs and TRs: LTE
- 1413: CD:Fri 13/03/15->Sun 15/03/15; Compl:50%->80%; Stat Rep: RP-141255->RP-141906 1st Apr 15: Compl:80%->100% 1st Apr 15: Stat Rep: RP-141906->RP-150229 / Impacted TSs and TRs: 36.101
- 1415: Stage 2/3. Triggered by Rel-11 TR 25.874 Study on HSPA feedback and signalling efficiency enhancements for LCR TDD (FS_LCRTDD_HSPAenh) UID_540026 / Impacted TSs and TRs: UTRA
- 1416: Prev CD:Fri 06/12/13; Prev %:100% / Impacted TSs and TRs: 25.222, 25.224, 25.331, 25.423, 25.433
- 1417: RP#61 completed / Impacted TSs and TRs: 25.102
- 1418: RP#62 completed / Impacted TSs and TRs: UTRA
- 1419: RP#62 closed at 85% completion. Not completed work on HNB positioning / No consensus (may be TEI12, if contribution and support). Updated WID RP-130868=>RP-132037 (HNB positiong was not addressed in this WI, however it was NOT remoded from the WID) / Impacted TSs and TRs: 25.305, 25.467, new TS 25.470
- 1420: Triggered by Rel-12 TR 25.702 Study on Dedicated Channel (DCH) enhancements for UMTS (FS_UTRA_DCHenh) UID_580040. Stage 2/3 / Impacted TSs and TRs: UTRA
- 1421: RP#65 completed / Impacted TSs and TRs: 25.101, 25.104, 25.133, 25.211, 25.212, 25.213, 25.214, 25.215, 25.306, 25.308, 25.321, 25.331, 25.423, 25.433
- 1422: ; Stat Rep: RP-141137->RP-141970 / Impacted TSs and TRs: 25.101, 25.104, 25.133
- 1424: Triggered by Rel-12 TR 25.800 Study on UMTS heterogeneous networks (FS_UTRA_hetnet) UID_570024. Stage 2/3 / Impacted TSs and TRs: UTRA
- 1425: RP#64 completed. TS 25.300v100 for 1-step Approval / Impacted TSs and TRs: 25.101, 25.104, 25.133, 25.141, 25.304, 25.306, 25.331, 25.433, new TS 25.300
- 1426: RP#64 completed / Impacted TSs and TRs: 25.101, 25.104, 25.133, 25.141
- 1427: Triggered by the 2nd part of TR 25.800 (FS_UTRA_HetNet); the 1st part is addressed by UTRA_HetNet_mob UID_610026 / Impacted TSs and TRs: UTRA
- 1428: RP#65 completed. Updated WID RP-140463=>RP-141701 / Impacted TSs and TRs: 25.101, 25.211, 25.212, 25.213, 25.214, 25.300, 25.302, 25.306, 25.308, 25.319, 25.331, 25.423, 25.433
- 1429: ; Stat Rep: RP-141702->RP-141898 / Impacted TSs and TRs: 25.101, 25.104, 25.133, 25.141
- 1430: Triggered by Rel-12 UTRA TR 25.704 Study on Enhanced Broadcast of System Information (FS_UTRA_SIBenh) / Impacted TSs and TRs: UTRA
- 1431: RP#65 completed / Impacted TSs and TRs: 25.211, 25.212 , 25.213, 25.214, 25.301, 25.302, 25.304, 25.306, 25.321, 25.331, 25.433
- 1432: ; Stat Rep: RP-141230->RP-142080 / Impacted TSs and TRs: 25.101, 25.104, 25.133, 25.141

| ID | WBS | Task | Duration | Start | Finish | Complete | Remaining | Baseline start | Baseline finish | Baseline duration | Total slack | Constraint | Resources | Work | Actual work | Acronym | PCG approved | WI rapporteur name | WI rapporteur e-mail | Release | TSG approved | MCC resp | Acronym_3GU_Export | Status Report | Special Focus Doc | PCG stopped | TSG stopped |
| --- | --- | --- | --- | --- | --- | --- | --- | --- | --- | --- | --- | --- | --- | --- | --- | --- | --- | --- | --- | --- | --- | --- | --- | --- | --- | --- | --- |
| 1433 | 291 | **Further Enhanced Uplink (EUL) enhancements** | 329d? | 2013-12-15 A | 2015-03-15 | 99% | 0d? | 2013-12-09 | 2014-12-05 | 261d? | 0d |  | R2 | 13704h | 11822.6h | EDCH_enh | PCG-32 | Ericsson | mark.curran@ericsson.com | Rel-12 | RP-62 | Yong-Jun | EDCH_enh |  |  |  |  |
| 1434 | 291.1 | Core part: Further Enhanced Uplink (EUL) enhancements | 264d? | 2013-12-15 A | 2014-12-15 A | 100% |  | 2014-04-29 | 2014-09-12 | 99d? |  | finish no earlier than 2014-12-15 | R2; R1; R3; R4 | 8448h | 8448h | EDCH_enh-Core | PCG-32 | Ericsson | mark.curran@ericsson.com | Rel-12 | RP-62 | Yong-Jun | EDCH_enh-Core | RP-141860 |  |  |  |
| 1435 | 291.2 | Perf. part: Further Enhanced Uplink (EUL) enhancements | 328d? | 2013-12-15 A | 2015-03-15 A | 100% |  | 2013-12-09 | 2014-12-05 | 261d? |  | finish no earlier than 2015-03-15 | R4 | 2624h | 2624h | EDCH_enh-Perf | PCG-32 | Ericsson | mark.curran@ericsson.com | Rel-12 | RP-62 | Issam | EDCH_enh-Perf | RP-150062 |  |  |  |
| 1436 | 292 | (Small) Technical Enhancements and Improvements for Rel-12 | 197.5d? | 2012-12-25 A | 2014-09-16 A | 100% |  | 2012-12-25 | 2014-09-17 | 197.5d? |  | finish no earlier than 2014-09-17 | SP; CP; RP; GP | 6320h | 6320h | TEI12 | PCG-29 |  |  | Rel-12 | RP-56 |  | TEI12 |  |  |  |  |
| 1437 | 293 | (IETF) (Small) Technical Enhancements and Improvements for Rel-12 (draft-ietf-insipid-session-id) | 131d? | 2014-06-13 A | 2014-12-09 | 50% | 65.5d? |  |  |  | 657d | start no earlier than 2014-06-13 | C1-IETF | 1048h | 524h | TEI12_IETF | PCG-34 | Alcatel-Lucent |  | Rel-12 | CT-66 |  |  |  |  |  |  |
| 1438 | 294 | Test - (Small) Technical Enhancements and Improvements for Rel-12 | 295.5d? | 2014-10-24 A | 2015-12-11 A | 100% |  | 2014-10-24 | 2015-12-11 | 295.5d? |  | finish no earlier than 2015-12-11 | R5; G3new | 4728h | 4728h | TEI12_Test | PCG-31 |  |  | Rel-12 | RP-61 | Ingbert | TEI12_Test |  |  |  |  |
| 1439 | 295 | Release 12 Studies | 296.5d? | 2013-08-05 A | 2014-09-17 | 80% | 59.3d? | 2013-08-05 | 2014-09-17 | 296.5d? | 718d | finish no earlier than 2014-09-17 | SP; CP; GP; RP | 9488h | 7590.4h |  |  |  |  | Rel-12 |  |  |  |  |  |  |  |
| 1440 | 296 | Study on Alternatives to E.164 for Machine-Type Communications | 513d? | 2010-03-25 A | 2012-03-07 A | 100% |  | 2010-03-25 | 2012-03-07 | 513d? |  | finish no earlier than 2012-03-07 | S1 | 4080h | 4080h | FS_AMTC | PCG-24 | T-Mobile USA | gary.jones@T-Mobile.com | Rel-12 | SP-47 | Alain | FS_AMTC |  | MTC, M2M |  |  |
| 1441 | 297 | Study on enhancements for Machine-Type Communications (MTC) | 720d? | 2010-06-10 A | 2013-03-06 A | 100% |  | 2010-06-10 | 2013-03-06 | 720d? |  | finish no earlier than 2013-03-06 | S1 | 5751.26h | 5751.26h | FS_MTCe | PCG-25 | Huawei | laurence.meriau@huawei.com | Rel-12 | SP-48 | Alain | FS_MTCe |  | MTC, M2M |  |  |
| 1442 | 298 | Study on Integration of Single Sign-On (SSO) frameworks with 3GPP networks | 383d? | 2010-09-23 A | 2012-03-07 A | 100% |  | 2010-09-23 | 2012-03-07 | 383d? |  | finish no earlier than 2011-09-08 | S1 | 3041.15h | 3041.15h | FS_SSO_Int | PCG-25 | InterDigital | christopher.wallace@interdigital.com | Rel-12 | SP-49 | Alain | FS_SSO_Int |  |  |  |  |
| 1443 | 299 | Study on Continuity of Data Sessions to Local Networks | 262.85d? | 2010-12-16 A | 2011-12-14 A | 100% |  | 2010-12-16 | 2011-12-14 | 262.85d? |  | finish no earlier than 2011-12-14 | S1 | 2084.27h | 2084.27h | FS_CSN | PCG-26 | NEC | joerg.swetina@neclab.eu | Rel-12 | SP-50 | Alain | FS_CSN |  |  |  |  |
| 1444 | 300 | Study on non-MTC Mobile Data Applications Impacts | 262.77d? | 2010-12-16 A | 2011-12-14 A | 100% |  | 2010-12-16 | 2011-12-14 | 262.77d? |  | finish no earlier than 2011-12-14 | S1 | 2083.59h | 2083.59h | FS_MODAI | PCG-26 | Huawei, China Mobile | Amar Deol (adeol@huawei.com), Gang Li | Rel-12 | SP-50 | Alain | FS_MODAI |  |  |  |  |
| 1445 | 301 | Study on Proximity-based Services | 384d? | 2011-09-22 A | 2013-03-05 A | 100% |  | 2011-09-22 | 2013-03-05 | 384d? |  | finish no earlier than 2012-12-12 | S1 | 3045.82h | 3045.82h | FS_ProSe | PCG-27 | Qualcomm | Rich Hovey (rhovey@qualcomm.com) | Rel-12 | SP-53 | Alain | FS_ProSe |  | Public Safety (A-A) |  |  |
| 1446 | 302 | Study on User Plane Congestion management | 198d? | 2011-12-14 A | 2012-09-12 A | 100% |  | 2011-12-14 | 2012-09-12 | 198d? |  | finish no earlier than 2012-09-12 | S1 | 1568h | 1568h | FS_UPCON | PCG-28 | KDDI | John Visser (jvisser@rogers.com) | Rel-12 | SP-54 | Alain | FS_UPCON |  |  |  |  |
| 1447 | 303 | Study on RAN Sharing Enhancements | 401d? | 2011-12-14 A | 2013-06-19 A | 100% |  | 2011-12-14 | 2013-06-19 | 401d? |  | finish no earlier than 2013-06-19 | S1 | 3192h | 3192h | FS_RSE | PCG-28 | NEC | joerg.swetina@neclab.eu | Rel-12 | SP-54 | Alain | FS_RSE |  |  |  |  |
| 1448 | 304 | Deleted - Study on UICC/USIM enhancements | 588d? | 2009-12-10 A | 2012-03-07 A | 100% |  | 2009-12-10 | 2012-03-07 | 588d? |  | finish no earlier than 2012-03-07 | S1 | 4704h | 4704h | FS_U2e | PCG-24 | Giesecke & Devrient | ilario.macchi@gi-de.com | Rel-12 | SP-46 | Alain | FS_U2e |  |  | PCG-28 | SP-55 |
| 1449 | 305 | **Study on IMS based Peer-to-Peer Content Distribution Services (Stage 2)** | 587d? | 2010-09-23 A | 2012-12-12 A | 100% |  | 2010-09-23 | 2012-12-12 | 587d? |  |  | S2; S1; S3 | 19472h | 19472h | FS_IMS_P2P_CDS | PCG-25 | China Mobile | Yu Qing (yuqing@chinamobile.com) | Rel-12 | SP-49 | Maurice | FS_IMS_P2P_CDS |  |  |  |  |
| 1450 | 305.1 | SA1 part of Study on IMS based Peer-to-Peer Content Distribution Services (Stage 2) | 262d? | 2010-09-23 A | 2011-09-21 A | 100% |  | 2010-09-23 | 2011-09-21 | 262d? |  | finish no earlier than 2011-09-21 | S1 | 2080h | 2080h | FS_IMS_P2P_CDS | PCG-25 | China Mobile | Yu Qing (yuqing@chinamobile.com) | Rel-12 | SP-49 | Maurice |  |  |  |  |  |
| 1451 | 305.2 | SA2 part of Study on IMS based Peer-to-Peer Content Distribution Services (Stage 2) | 347d? | 2010-09-23 A | 2012-06-20 A | 100% |  | 2010-09-23 | 2012-06-20 | 347d? |  | finish no earlier than 2012-06-08 | S2 | 2776h | 2776h | FS_IMS_P2P_CDS | PCG-25 | China Mobile | Yu Qing (yuqing@chinamobile.com) | Rel-12 | SP-49 | Maurice |  |  |  |  |  |
| 1452 | 305.3 | SA3 part of Study on IMS based Peer-to-Peer Content Distribution Services (Stage 2) | 68d? | 2012-09-12 A | 2012-12-12 A | 100% |  | 2012-09-12 | 2012-12-12 | 68d? |  | finish no earlier than 2012-12-12 | S3 | 528h | 528h | FS_IMS_P2P_CDS | PCG-29 | China Mobile | Zhu Judy(zhuhongru@chinamobile.com) | Rel-12 | SP-57 | Mirko |  |  |  |  |  |
| 1453 | 306 | **Study on Core Network Overload solutions** | 852d? | 2010-09-23 A | 2013-12-11 A | 100% |  | 2010-09-23 | 2013-12-11 | 852d? |  |  | S2 | 18240.6h | 18240.6h | FS_CNO | PCG-25 | Huawei | Mirko.Schramm@huawei.com | Rel-12 | SP-49 | Maurice | FS_CNO |  |  |  |  |
| 1454 | 306.1 | Study on Core Network Overload solutions (Phase 1) | 587d? | 2010-09-23 A | 2012-12-12 A | 100% |  | 2010-09-23 | 2012-12-12 | 587d? |  | finish no earlier than 2012-12-12 | S2 | 4684.11h | 4684.11h | FS_CNO | PCG-25 | Huawei | Mirko.Schramm@huawei.com | Rel-12 | SP-49 | Maurice |  |  |  |  |  |
| 1455 | 306.2 | Study on Core Network Overload solutions (Phase 2) | 844d? | 2010-09-23 A | 2013-12-11 A | 100% |  | 2010-09-23 | 2013-12-11 | 844d? |  | finish no earlier than 2013-12-11 | S2 | 6744h | 6744h | FS_CNO | PCG-25 | Huawei | Mirko.Schramm@huawei.com | Rel-12 | SP-49 | Maurice |  |  |  |  |  |
| 1456 | 307 | Study on System Enhancements for Energy Efficiency | 399d? | 2010-12-16 A | 2012-06-20 A | 100% |  | 2010-12-16 | 2012-06-20 | 399d? |  | finish no earlier than 2012-06-20 | S2 | 3192h | 3192h | FS_SEEE | PCG-26 | Huawei | frank.mademann@huawei.com | Rel-12 | SP-50 | Maurice | FS_SEEE |  |  |  |  |
| 1457 | 308 | Study on S2a Mobility based On GTP and WLAN access to EPC | 657d? | 2011-03-23 A | 2013-09-11 A | 100% |  | 2011-03-23 | 2013-09-11 | 657d? |  | finish no earlier than 2013-09-11 | S2 | 5165.94h | 5165.94h | FS_SaMOG | PCG-26 | ZTE | Tricci So (tso@zteusa.com) | Rel-12 | SP-51 | Maurice | FS_SaMOG |  | WLAN |  |  |
| 1458 | 309 | Study on Optimized Offloading to WLAN in 3GPP-RAT Mobility | 326d? | 2012-06-18 A | 2013-09-11 A | 100% |  | 2012-06-18 | 2013-09-11 | 326d? |  | finish no earlier than 2013-09-11 | S2 | 2592h | 2592h | FS_WORM | PCG-29 | BlackBerry | Steve Barrett (sbarrett@blackberry.com) | Rel-12 | SP-56 | Maurice | FS_WORM |  | WLAN |  |  |
| 1459 | 310 | Study on Application Based Charging | 190d? | 2012-06-18 A | 2013-03-06 A | 100% |  | 2012-06-18 | 2013-03-06 | 190d? |  | finish no earlier than 2013-03-06 | S2 | 1520h | 1520h | FS_ABC | PCG-29 | Allot | Alla Goldner (agoldner@allot.com) | Rel-12 | SP-56 | Maurice | FS_ABC |  |  |  |  |

Notes:
- 1433: Triggered by Rel-12 UTRA TR 25.700 Study on Further Enhanced Uplink (EUL) enhancements (FS_EDCH_enh) / Impacted TSs and TRs: UTRA
- 1434: ; Stat Rep: RP-141684->RP-141860 / Impacted TSs and TRs: 25.211, 25.212, 25.214, 25.304, 25.306, 25.308, 25.319, 25.321, 25.331, 25.423, 25.425, 25.433, 25.435
- 1435: ; CD:Wed 18/03/15->Sun 15/03/15; Stat Rep: RP-141684->RP-141860 1st Apr 15: Compl:75%->100% 1st Apr 15: Stat Rep: RP-141860->RP-150062 / Impacted TSs and TRs: 25.101, 25.104, 25.133, 25.141
- 1436: -
- 1437: Mar15: In WGLC / Impacted TSs and TRs: draft-ietf-insipid-session-id
- 1438: -
- 1439: -
- 1440: SP#55 completed. Determine an alternative to E.164 for identifying individual devices and route messages between those devices / Impacted TSs and TRs: 22.988
- 1441: SP#59 completed. TR 22.888 v100 for Information & Approval. Study addition of new MTC-related use cases and functionality and improvements to existing requirements in TS 22.368 / Impacted TSs and TRs: 22.888
- 1442: SP#55 completed. Linked to SA3 Study on Single Sign On (SSO) Application Security for IMS - based on SIP Digest (UID_480048), SA3 TR 33.924 Extended Identity Management (GBA-IdM) and SA3 TR 33.980 (LibSec) / Impacted TSs and TRs: 22.895
- 1443: SP#54 completed. Linked to SA1 Rel-11 Feature UID_490030 SIPTO Service Continuity of IP Data Session (SIPTO_SC) / Impacted TSs and TRs: 22.896
- 1444: SP#54 completed. Linked to UID_490036 SA2 Rel-11 TR 23.843 Study on Core Network Overload solutions (FS_CNO) / Impacted TSs and TRs: 22.801
- 1445: SP#59 completed / Impacted TSs and TRs: 22.803
- 1446: SP#57 completed. Linked to SAPP (Service Awareness and Privacy Policies), FS_UMONC (Study on Usage Monitoring Control Enhancement), QoS_SSL (QoS Control Based on Subscriber Spending Limits) / Impacted TSs and TRs: 22.805
- 1447: SP#60 completed. Extend Rel-6 Network Sharing UID_31018 (basic scenarios of network/RAN sharing) to cover more complex scenarios that arise due to recent needs for more dynamic co-operation among operators / Impacted TSs and TRs: 22.852
- 1448: SP#55 work stopped. Triggered by GSMA Smart SIM and 3GNBK projects, and to evolve from traditional USAT to multimedia USIM toolkit support, particularly to Smart Card Web Server / Impacted TSs and TRs: 22.817
- 1449: Triggered by TR 22.906 SA1 Study on IMS based Peer-to-Peer Content Distribution Services UID_450047 / Impacted TSs and TRs: 23.844
- 1450: SP#53 completed / Impacted TSs and TRs: 23.844
- 1451: SP#56 completed. TR 23.844v100 for Information and Approval / Impacted TSs and TRs: 23.844
- 1452: SP#58 completed. TR 33.844 v100 for Information and Approval / Impacted TSs and TRs: 33.844
- 1453: SP#62 completed. Linked to CT4 TR 23.857 Study on EPC Nodes Restoration (UID_490014) / Impacted TSs and TRs: 23.843
- 1454: Phase 1: complete study of overload control related to MAP /Diameter signalling, other 3GPP Core Network signalling optimization / Impacted TSs and TRs: 23.843
- 1455: SP#62 completed / Impacted TSs and TRs: 23.843
- 1456: SP#56 completed / Impacted TSs and TRs: 23.866
- 1457: SP#61 completed. Covers generic non-3GPP access (e.g. WLAN, WIMAX, CDMA/HRPD). Spin-off Feature SaMOG_WLAN. Linked to Rel-8 Support for non-3GPP accesses, Rel-10 SMOG, Rel-11 BBAI / Impacted TSs and TRs: 23.852
- 1458: SP#61 completed. Linked to UID_350027 SAE for support for non-3GPP accesses (SAES-SA-FP_n3GPP), UID_410043 MAPIM, UID_450041 IFOM, UID_530046 SaMOG / Impacted TSs and TRs: 23.890
- 1459: SP#59 completed. Linked to Rel-11 Feature UID_500032 Service Awareness and Privacy Policies (SAPP) / Impacted TSs and TRs: 23.800

| ID | WBS | Task | Duration | Start | Finish | Complete | Remaining | Baseline start | Baseline finish | Baseline duration | Total slack | Constraint | Resources | Work | Actual work | Acronym | PCG approved | Impacted TSs and TRs | WI rapporteur name | WI rapporteur e-mail | Release | TSG approved | MCC resp | Acronym_3GU_Export | PCG stopped | TSG stopped | Special Focus Doc | Status Report |
| --- | --- | --- | --- | --- | --- | --- | --- | --- | --- | --- | --- | --- | --- | --- | --- | --- | --- | --- | --- | --- | --- | --- | --- | --- | --- | --- | --- | --- |
| 1460 | 311 | **Study on Multi Access PDN connectivity and IP flow Mobility** | 1141.96d? | 2008-08-08 A | 2012-12-12 A | 100% |  | 2008-08-08 | 2012-12-12 | 1141.96d? |  |  | S2; S1 | 27327.4h | 27327.4h | FS_MAPIM | PCG-21 | 23.861 | Qualcomm | Gerardo Giaretta (gerardog@qualcomm.com) | Rel-12 | SP-41 | Maurice | FS_MAPIM |  |  |  |  |
| 1461 | 311.1 | SA1 part of Study on Multi Access PDN connectivity and IP flow Mobility | 22d? | 2008-08-08 A | 2011-09-21 A | 100% |  | 2008-08-08 | 2011-09-21 | 22d? |  | finish no earlier than 2011-09-21 | S1 | 160h | 160h | FS_MAPIM | PCG-21 | 23.861 | Qualcomm | Gerardo Giaretta (gerardog@qualcomm.com) | Rel-12 | SP-41 | Maurice |  |  |  |  |  |
| 1462 | 311.2 | SA2 part of Study on Multi Access PDN connectivity and IP flow Mobility | 1113d? | 2008-09-18 A | 2012-12-12 A | 100% |  | 2008-09-18 | 2012-12-12 | 1113d? |  | finish no earlier than 2012-12-12 | S2 | 8896h | 8896h | FS_MAPIM | PCG-21 | 23.861 | Qualcomm | Gerardo Giaretta (gerardog@qualcomm.com) | Rel-12 | SP-41 | Maurice |  |  |  |  |  |
| 1463 | 312 | Deleted - Study on IP Flow Mobility support for S2a and S2b Interfaces | 190d? | 2012-06-18 A | 2013-03-06 A | 100% |  | 2012-06-18 | 2013-03-06 | 190d? |  | finish no earlier than 2013-03-06 | S2 | 1520h | 1520h | FS_NBIFOM | PCG-29 | 23.861 | ZTE | Tricci So (tso@zteusa.com) | Rel-12 | SP-56 | Maurice | FS_NBIFOM | PCG-30 | SP-59 |  |  |
| 1464 | 313 | Study on Extended IMS Media Plane Security features | 719d? | 2010-06-10 A | 2013-03-06 A | 100% |  | 2010-06-10 | 2013-03-06 | 719d? |  | finish no earlier than 2013-03-06 | S3 | 5736h | 5736h | FS_eMEDIASEC | PCG-25 | 33.829 | Vodafone | Aguibou.Barry@vodafone.com | Rel-12 | SP-48 | Mirko | FS_eMEDIASEC |  |  |  |  |
| 1465 | 314 | Deleted - Study on Firewall traversal (Stage 2) | 854d? | 2011-06-17 A | 2014-09-17 A | 100% |  | 2011-06-17 | 2014-09-17 | 854d? |  | finish no earlier than 2014-09-17 | S3 | 6832h | 6832h | FS_Fire | PCG-27 | 33.830 | Acme Packet | Prashant Kumar (PKumar@acmepacket.com) | Rel-12 | SP-53 | Mirko | FS_Fire | PCG-33 | SP-65 |  |  |
| 1466 | 315 | Study on Security on spoofed call detection and prevention (Stage 2) | 662d? | 2012-03-07 A | 2014-09-17 A | 100% |  | 2012-03-07 | 2014-09-17 | 662d? |  | finish no earlier than 2014-09-17 | S3 | 5296h | 5296h | FS_SPOOF | PCG-28 | 33.831 | China Mobile | lixiangjun@chinamobile.com | Rel-12 | SP-55 | Mirko | FS_SPOOF |  |  |  |  |
| 1467 | 316 | Study on Security Assurance Methodology for 3GPP Network Elements | 466d? | 2012-09-13 A | 2014-06-18 A | 100% |  | 2012-09-13 | 2014-06-18 | 466d? |  | finish no earlier than 2014-03-07 | S3 | 3696h | 3696h | FS_SECAM | PCG-29 | 33.805 | Orange | loic.habermacher@orange.com | Rel-12 | SP-57 | Mirko | FS_SECAM |  |  |  |  |
| 1468 | 317 | Study on Improved Support for Dynamic Adaptive Streaming over HTTP in 3GPP | 729d? | 2011-12-14 A | 2014-09-16 A | 100% |  | 2011-12-14 | 2014-09-17 | 729d? |  | finish no earlier than 2014-09-17 | S4 | 5824h | 5824h | FS_IS_DASH | PCG-28 | 26.938 | Qualcomm | c_tstock@qualcomm.com | Rel-12 | RP-54 | Paolo | FS_IS_DASH |  |  |  |  |
| 1469 | 318 | Study on HTML5 for a new presentation layer in 3GPP services | 266d? | 2013-09-12 A | 2014-09-16 A | 100% |  | 2013-09-12 | 2014-09-17 | 266d? |  | finish no earlier than 2014-09-17 | S4 | 2128h | 2128h | FS_HTML5 | PCG-31 | 26.907 | Samsung | Imed Bouazizi (i.bouazizi@sta.samsung.com) | Rel-12 | RP-61 | Paolo | FS_HTML5 |  |  |  |  |
| 1470 | 319 | Study on version handling | 716d? | 2010-03-25 A | 2012-12-12 A | 100% |  | 2010-03-25 | 2012-12-12 | 716d? |  | finish no earlier than 2012-12-12 | S5 | 5704h | 5704h | FS_OAM_VH | PCG-24 | 32.830 | Ericsson | thomas.tovinger@ericsson.com | Rel-12 | SP-47 | Mirko | FS_OAM_VH |  |  |  |  |
| 1471 | 320 | Study on management of Heterogeneous Networks | 852d? | 2011-03-23 A | 2014-06-18 A | 100% |  | 2011-03-23 | 2014-06-18 | 852d? |  | finish no earlier than 2014-06-18 | S5 | 6816h | 6816h | FS_OAM_HetNet | PCG-26 | 32.835 | Ericsson | ulf.hubinette@ericsson.com | Rel-12 | SP-51 | Mirko | FS_OAM_HetNet |  |  |  |  |
| 1472 | 321 | Study on OAM aspects of Network Sharing | 464d? | 2011-12-07 A | 2013-09-11 A | 100% |  | 2011-12-07 | 2013-09-11 | 464d? |  | finish no earlier than 2013-09-11 | S5 | 3696h | 3696h | FS_OAM_SHARE | PCG-28 | 32.851 | Alcatel-Lucent, Huawei | Padma.Sudarsan@alcatel-lucent.com, zoulan@huawei.com | Rel-12 | SP-54 | Mirko | FS_OAM_SHARE |  |  |  |  |
| 1473 | 322 | Study on Enhanced Network Management (NM) centralized Coverage and Capacity Optimization | 590d? | 2011-09-21 A | 2014-09-17 A | 100% |  | 2011-09-21 | 2014-09-17 | 590d? |  | finish no earlier than 2014-09-17 | S5 | 4712h | 4712h | FS_SON_NM_CCO | PCG-29 | 32.836 | Ericsson | robert.petersen@ericsson.com | Rel-12 | SP-56 | Mirko | FS_SON_NM_CCO |  |  | SON |  |
| 1474 | 323 | Study on WLAN management | 788d? | 2011-09-21 A | 2014-09-17 A | 100% |  | 2012-06-20 | 2014-09-17 | 590d? |  | finish no earlier than 2014-09-17 | S5 | 6304h | 6304h | FS_WLAN_OAM | PCG-29 | 32.841 | Intel | joey.chou@intel.com | Rel-12 | SP-56 | Mirko | FS_WLAN_OAM |  |  | WLAN |  |
| 1475 | 324 | Study on Alarm Management | 201d? | 2012-12-07 A | 2013-09-11 A | 100% |  | 2012-12-07 | 2013-09-11 | 201d? |  | finish no earlier than 2013-09-11 | S5 | 1592h | 1592h | FS_OAM_AM | PCG-30 | 32.859 | TeliaSonera | tommy.berggren@teliasonera.com | Rel-12 | SP-58 | Mirko | FS_OAM_AM |  |  |  |  |
| 1476 | 325 | Study on Indication of Network to Network Interface (NNI) Routeing scenarios in SIP requests | 400d? | 2012-12-10 A | 2014-06-13 A | 100% |  | 2012-12-10 | 2014-06-13 | 400d? |  | finish no earlier than 2014-03-06 | C3 | 3190.27h | 3190.27h | FS_NNI_RS | PCG-30 | 24.802 | Ericsson | Jan.Holm@ericsson.com | Rel-12 | CP-58 | Adrian | FS_NNI_RS |  |  |  |  |
| 1477 | 326 | Study on Diameter Overload Control Mechanisms | 464d? | 2012-01-05 A | 2014-09-11 A | 100% |  | 2012-01-05 | 2014-09-12 | 464d? |  | finish no earlier than 2014-09-12 | C4 | 3712h | 3712h | FS_DOCME | PCG-30 | 29.809 | Orange | lionel.morand@orange.com | Rel-12 | CP-58 | Kimmo | FS_DOCME |  |  |  |  |
| 1478 | 327 | Study on XML based access of AF to the PCRF | 203d? | 2013-03-01 A | 2013-12-04 A | 100% |  | 2013-03-01 | 2014-06-13 | 341d? |  | finish no earlier than 2014-06-13 | C3 | 1608h | 1608h | FS_XML_AF_PCRF | PCG-30 | 29.817 | Alcatel-Lucent | horst.brinkman@alcatel-lucent.com | Rel-12 | CP-59 | Adrian | FS_XML_AF_PCRF |  |  |  |  |
| 1479 | 328 | Study on Technical aspects on Roaming End-to-end scenarios with VoLTE IMS and other networks | 328d? | 2013-09-09 A | 2014-12-09 A | 100% |  | 2013-09-09 | 2014-09-12 | 266d? |  | finish no earlier than 2014-12-09 | C3 | 2624h | 2624h | FS_REVOLTE_IMS | PCG-31 | 29.949 | Deutsche Telekom | Roland Jesske (r.jesske@telekom.de) | Rel-12 | CP-61 | Adrian | FS_REVOLTE_IMS |  |  |  |  |
| 1480 | 329 | Study on Development of conformance requirements for the IP Multimedia Services Identity Module (ISIM) application support in ME | 263d? | 2013-12-09 A | 2014-12-09 | 30% | 184.1d? | 2013-12-09 | 2014-09-12 | 201d? | 657d | finish no earlier than 2014-12-09 | C6 | 2104h | 631.2h | FS_ISIM_CR | PCG-32 | 31.829 | Gemalto | ly-thanh.phan@gemalto.com | Rel-12 | CP-62 | Xavier | FS_ISIM_CR |  |  |  |  |
| 1481 | 330 | Study on Shared Data Update for Multiple Subscribers | 263d? | 2013-12-06 A | 2014-12-09 A | 100% |  | 2013-12-06 | 2014-09-12 | 201d? |  | finish no earlier than 2014-12-09 | C4 | 2104h | 2104h | FS_SHARED_SubData_UPD | PCG-32 | 29.854 | Huawei | Susan Shi (susan.shishufeng@huawei.com) | Rel-12 | CP-62 | Kimmo | FS_SHARED_SubData_UPD |  |  |  |  |
| 1482 | 331 | Study on GERAN improvements for Machine-Type Communications | 661d? | 2010-05-24 A | 2012-11-23 A | 100% |  | 2010-05-24 | 2012-11-23 | 661d? |  | finish no earlier than 2012-11-23 | G1; G2 | 10576h | 10576h | FS_NIMTC_GERAN | PCG-24 | 43.868 | Ericsson | paul.schliwa-bertling@ericsson.com | Rel-12 | GP-44 | Paolo | FS_NIMTC_GERAN |  |  | MTC, M2M |  |
| 1483 | 332 | Study on Voice services over Adaptive Multi-user channels on One Slot (VAMOS) enhancements | 267.67d? | 2010-10-27 A | 2014-05-30 A | 100% |  | 2010-10-27 | 2014-05-30 | 267.67d? |  | finish no earlier than 2014-05-30 | GP; G2; G1 | 6424h | 6424h | FS_eVAMOS | PCG-27 | 43.801 | China Mobile, Huawei | Chao Luo (chluo@huawei.com), dengjuan@chinamobile.com | Rel-12 | GP-50 | Paolo | FS_eVAMOS |  |  |  |  |
| 1484 | 333 | Study on GERAN enhancements for Mobile Data Applications | 430d? | 2011-04-04 A | 2014-08-29 A | 100% |  | 2011-04-04 | 2014-08-29 | 430d? |  | finish no earlier than 2014-08-29 | G2; G1 | 6880h | 6880h | FS_GERAN_eMDA | PCG-27 | 43.802 | Huawei | ming.fang@huawei.com | Rel-12 | GP-50 | Gert | FS_GERAN_eMDA |  |  |  |  |
| 1485 | 334 | Study on Inclusion of RF Pattern Matching Technologies as a positioning method in the E-UTRAN | 722d? | 2010-12-10 A | 2013-09-06 A | 100% |  | 2010-12-10 | 2013-09-06 | 722d? |  | finish no earlier than 2013-09-06 | R4 | 5776h | 5776h | FS_LCS_LTE_RFPMT | PCG-26 | LTE 36.809 | Polaris Wireless | Scot Gordon (sgordon@polariswireless.com) | Rel-12 | RP-50 | Issam | FS_LCS_LTE_RFPMT |  |  |  | RP-131082 |
| 1486 | 335 | Study on Provision of low-cost MTC UEs based on LTE | 462d? | 2011-09-19 A | 2013-06-14 A | 100% |  | 2011-09-19 | 2013-06-14 | 462d? |  | finish no earlier than 2013-06-14 | R1; R2; R4 | 11088h | 11088h | FS_LC_MTC_LTE | PCG-27 | LTE 36.888 | Vodafone | prakash.bhat@vodafone.com | Rel-12 | RP-53 | Patrick | FS_LC_MTC_LTE |  |  | MTC, M2M | RP-130583 |
| 1487 | 336 | Deleted - Study on Mobile Relay for E-UTRA | 881.5d? | 2005-05-19 A | 2014-06-23 A | 100% |  | 2005-05-19 | 2014-06-23 | 881.5d? |  | finish no earlier than 2014-06-23 | R3; R1 | 14104h | 14104h | FS_LTE_mobRelay | PCG-27 | LTE 36.836 | CATT | Haijing Hu (huhaijing@catt.cn) | Rel-12 | RP-53 | Juha | FS_LTE_mobRelay | PCG-33 | RP-64 |  | RP-140726 |
| 1488 | 337 | Study on Scenarios and Requirements of LTE Small Cell Enhancements for E-UTRA and E-UTRAN | 66d? | 2012-09-11 A | 2012-12-07 A | 100% |  | 2012-09-11 | 2012-12-07 | 66d? |  | finish no earlier than 2012-12-07 | RP | 528h | 528h | FS_LTE_SC_enh_req | PCG-29 | LTE 36.932 | China Mobile | Hai TANG (tanghai@chinamobile.com) | Rel-12 | RP-57 | Yong-Jun | FS_LTE_SC_enh_req |  |  | Small cell | RP-121651 |
| 1489 | 338 | Study on Small Cell Enhancements for E-UTRA and E-UTRAN – Physical-layer aspects | 265d? | 2012-09-11 A | 2013-09-06 A | 100% |  | 2012-09-11 | 2013-09-06 | 265d? |  | finish no earlier than 2013-09-06 | R1; R2; R4 | 6360h | 6360h | FS_LTE_SC_enh_L1 | PCG-30 | LTE 36.872 | Huawei | Elean Fan (fanxiaoan@huawei.com) | Rel-12 | RP-58 | Patrick | FS_LTE_SC_enh_L1 |  |  | Small cell | RP-131618 |
| 1490 | 339 | Study on Small Cell Enhancements for E-UTRA and E-UTRAN – Higher-layer aspects | 265d? | 2012-12-10 A | 2013-12-06 A | 100% |  | 2012-12-10 | 2013-12-06 | 265d? |  | finish no earlier than 2013-12-06 | R2; R3 | 4240h | 4240h | FS_LTE_SC_enh_hilayer | PCG-30 | LTE 36.842 | NTT DOCOMO | Hideaki Takahashi (h-takahashi@nttdocomo.co.jp) | Rel-12 | RP-58 | Yong-Jun | FS_LTE_SC_enh_hilayer |  |  | Small cell | RP-131619 |
| 1491 | 340 | Study on LTE Device-to-Device Proximity Services - Radio Aspects | 325d? | 2012-12-17 A | 2014-03-06 A | 100% |  | 2012-12-17 | 2014-03-06 | 325d? |  | finish no earlier than 2014-03-06 | R1; R2; R3; R4 | 10400h | 10400h | FS_LTE_D2D_Prox | PCG-30 | LTE 36.843 | Qualcomm | Shailesh Patil (patil@qti.qualcomm.com) | Rel-12 | RP-58 | Patrick | FS_LTE_D2D_Prox |  |  | Public Safety (A-A) | RP-140416 |
| 1492 | 341 | Study on 3D-channel model for Elevation Beamforming and FD-MIMO studies for LTE | 463d? | 2012-12-10 A | 2014-09-12 A | 100% |  | 2012-12-10 | 2014-09-12 | 463d? |  | finish no earlier than 2014-09-12 | R1 | 3704h | 3704h | FS_LTE_3D_channel | PCG-30 | LTE 36.873 | Nokia Networks | bishwarup.mondal@nsn.com | Rel-12 | RP-58 | Patrick | FS_LTE_3D_channel |  |  |  | RP-141206 |
| 1493 | 342 | Study on Energy Saving Enhancement for E-UTRAN | 397d? | 2012-12-10 A | 2014-06-13 A | 100% |  | 2012-12-10 | 2014-06-13 | 397d? |  | finish no earlier than 2014-06-13 | R3 | 3176h | 3176h | FS_Netw_Energy_enh_LTE | PCG-30 | LTE 36.887 | China Mobile | Kimba Dit Adamou, Boubacar (jinba@chinamobile.com) | Rel-12 | RP-58 | Juha | FS_Netw_Energy_enh_LTE |  |  |  | RP-140604 |
| 1494 | 343 | Study on Expansion of LTE_FDD_1670_US to include 1670-1680MHz Band for LTE in the US | 469d? | 2013-03-01 A | 2014-12-15 A | 100% |  | 2013-03-01 | 2014-09-12 | 403d? |  | finish no earlier than 2014-12-15 | R4 | 3752h | 3752h | FS_LTE_FDD_1670_US | PCG-30 | LTE 36.844 | LightSquared | masoud.olfat@lightsquared.com | Rel-13 | RP-59 | Issam | FS_LTE_FDD_1670_US |  |  |  | RP-141815 |
| 1495 | 344 | Study on Cell-specific Reference Signals (CRS) Interference Mitigation for homogenous deployments for LTE | 201d? | 2013-03-04 A | 2013-12-06 A | 100% |  | 2013-03-04 | 2013-12-06 | 201d? |  | finish no earlier than 2013-12-06 | R4 | 1608h | 1608h | FS_LTE_CRSIC | PCG-30 | LTE 36.863 | Ericsson | shaohua.li@ericsson.com | Rel-12 | RP-59 | Issam | FS_LTE_CRSIC |  |  |  | RP-131623 |
| 1496 | 345 | Study on Network-Assisted Interference Cancellation and Suppression for LTE | 265d? | 2013-03-08 A | 2014-03-06 A | 100% |  | 2013-03-08 | 2014-03-06 | 265d? |  | finish no earlier than 2014-03-06 | R1; R4 | 4240h | 4240h | FS_LTE_NAICS | PCG-30 | LTE 36.866 | MediaTek | jeff.zhuang@mediatek.com | Rel-12 | RP-59 | Patrick | FS_LTE_NAICS |  |  |  | RP-132108 |
| 1497 | 346 | Study on Coordinated Multi-Point (CoMP) operation for LTE with Non-Ideal Backhaul | 126d? | 2013-06-18 A | 2013-12-06 A | 100% |  | 2013-06-18 | 2013-12-06 | 126d? |  | finish no earlier than 2013-12-06 | R1 | 1008h | 1008h | FS_COMP_LTE_nibackhaul | PCG-31 | LTE 36.874 | Samsung | Hyojin Lee (hyojin257.lee@samsung.com) | Rel-12 | RP-60 | Patrick | FS_COMP_LTE_nibackhaul |  |  |  | RP-131626 |
| 1498 | 347 | Study on Group Communication for LTE | 130d? | 2013-09-10 A | 2014-03-06 A | 100% |  | 2013-09-10 | 2014-03-06 | 130d? |  | finish no earlier than 2014-03-06 | R2; R3 | 2080h | 2080h | FS_LTE_GC | PCG-31 | LTE 36.868 | Alcatel-Lucent | chandrika.worrall@alcatel-lucent.com | Rel-12 | RP-61 | Yong-Jun | FS_LTE_GC |  |  | Public Safety (A-A) | RP-140182 |
| 1499 | 348 | Study on Smart Congestion Mitigation in E-UTRAN | 130d? | 2013-09-09 A | 2014-03-06 A | 100% |  | 2013-09-09 | 2014-03-06 | 130d? |  | finish no earlier than 2014-03-06 | R2 | 1040h | 1040h | FS_SCM_LTE | PCG-31 | LTE 36.848 | LG Electronics | youngdae.lee@lge.com | Rel-12 | RP-61 | Yong-Jun | FS_SCM_LTE |  |  |  | RP-140102 |
| 1500 | 349 | Study on RAN aspects of RAN Sharing Enhancements for LTE | 136d? | 2013-12-06 A | 2014-06-13 A | 100% |  | 2013-12-06 | 2014-06-13 | 136d? |  | finish no earlier than 2014-06-13 | R3 | 1088h | 1088h | FS_RSE-RAN_LTE | PCG-32 | LTE 36.856 | NEC | Siva.Vakeesar@emea.nec.com | Rel-12 | RP-62 | Juha | FS_RSE-RAN_LTE |  |  |  | RP-140746 |
| 1501 | 350 | Study on RF and EMC requirements for active Antenna Array System (AAS) Base Station | 386d? | 2011-09-19 A | 2013-03-01 A | 100% |  | 2011-09-19 | 2013-03-01 | 386d? |  | finish no earlier than 2013-03-01 | R4; R1 | 6176h | 6176h | FS_AAS_BS_LTE_UTRA | PCG-27 | UTRA, LTE 37.840 | Huawei | Ronnie.zhang@huawei.com | Rel-12 | RP-53 | Issam | FS_AAS_BS_LTE_UTRA |  |  |  | RP-130124 |
| 1502 | 351 | Study on LTE-HRPD (High Rate Packet Data in 3GPP2) inter-RAT SON | 340d? | 2012-03-02 A | 2013-06-14 A | 100% |  | 2012-03-02 | 2013-06-14 | 340d? |  | finish no earlier than 2013-06-14 | R3 | 2712h | 2712h | FS_LTE_HRPD_SON | PCG-28 | UTRA, LTE 37.813 | China Telecom | Wu Jinlian (wujl@gsta.com) | Rel-12 | RP-55 | Juha | FS_LTE_HRPD_SON |  |  | SON | RP-130585 |
| 1503 | 352 | Study on Passive InterModulation (PIM) handling for UTRA and LTE Base Stations | 403d? | 2012-03-05 A | 2013-09-06 A | 100% |  | 2012-03-05 | 2013-09-06 | 403d? |  | finish no earlier than 2013-09-06 | R4; G1 | 6448h | 6448h | FS_BS_PIM | PCG-28 | UTRA, LTE 37.808 | Ericsson | johan.skold@ericsson.com | Rel-12 | RP-55 | Issam | FS_BS_PIM |  |  |  | RP-131076 |
| 1504 | 353 | Study on WLAN/3GPP Radio Interworking | 264d? | 2012-12-10 A | 2013-12-06 A | 100% |  | 2012-12-10 | 2013-12-06 | 264d? |  | finish no earlier than 2013-12-06 | R2 | 2104h | 2104h | FS_UTRA_LTE_WLAN_interw | PCG-30 | UTRA, LTE 37.834 | Intel | sasha.sirotkin@intel.com | Rel-12 | RP-58 | Yong-Jun | FS_UTRA_LTE_WLAN_interw |  |  | WLAN | RP-131611 |
| 1505 | 354 | Study on RAN Enhancements for UMTS/HSPA and LTE Interworking | 261d? | 2012-12-10 A | 2013-12-06 A | 100% |  | 2012-12-10 | 2013-12-06 | 261d? |  | finish no earlier than 2013-12-06 | R3 | 2088h | 2088h | FS_HSPA_LTE_interworking | PCG-30 | UTRA, LTE 37.852 | China Unicom | Meng Zhang (zhangmeng68@chinaunicom.cn) | Rel-12 | RP-58 | Juha | FS_HSPA_LTE_interworking |  |  |  | RP-131612 |
| 1506 | 355 | Study on Next-Generation SON for UTRA and LTE | 397d? | 2012-12-10 A | 2014-06-13 A | 100% |  | 2012-12-10 | 2014-06-13 | 397d? |  | finish no earlier than 2014-06-13 | R3 | 3176h | 3176h | FS_UTRA_LTE_NG_SON | PCG-30 | UTRA, LTE 37.822 | NSN | krzysztof.kordybach@nsn.com | Rel-12 | RP-58 | Juha | FS_UTRA_LTE_NG_SON |  |  | SON | RP-140747 |
| 1507 | 356 | Study on 2GHz FDD for UTRA and LTE in Region 1 (1980-2010MHz and 2170-2200MHz Bands) | 462d? | 2012-12-11 A | 2014-09-12 A | 100% |  | 2012-12-11 | 2014-09-12 | 462d? |  | finish no earlier than 2014-09-12 | R4 | 3696h | 3696h | FS_UTRA_LTE_1980_2170_REG1 | PCG-30 | UTRA, LTE 37.846 | DISH Network | johny.kim@dish.com, mariam.sorond@dish.com | Rel-12 | RP-58 | Issam | FS_UTRA_LTE_1980_2170_REG1 |  |  |  | RP-141099 |
| 1508 | 357 | Study on Base Station specification structure | 136d? | 2012-12-10 A | 2013-06-14 A | 100% |  | 2012-12-10 | 2013-06-14 | 136d? |  | finish no earlier than 2013-06-14 | R4 | 1088h | 1088h | FS_BSspec_struc | PCG-30 | UTRA, LTE, MSR 37.810 | Ericsson | johan.skold@ericsson.com | Rel-12 | RP-58 | Issam | FS_BSspec_struc |  |  |  | RP-130580 |
| 1509 | 358 | Study on RAN aspects of Machine Type and other mobile data applications Communications enhancements | 137d? | 2013-03-01 A | 2013-09-06 A | 100% |  | 2013-03-01 | 2013-09-06 | 137d? |  | finish no earlier than 2013-09-06 | R2 | 1096h | 1096h | FS_MTCe_RAN | PCG-30 | UTRA, LTE 37.869 | ZTE | sergio.parolari@zteitaly.com | Rel-12 | RP-59 | Yong-Jun | FS_MTCe_RAN |  |  | MTC, M2M | RP-131081 |
| 1510 | 359 | Study on UMTS heterogeneous networks | 331d? | 2012-06-12 A | 2013-09-06 A | 100% |  | 2012-06-12 | 2013-09-06 | 331d? |  | finish no earlier than 2013-09-06 | R1; R2; R3 | 7944h | 7944h | FS_UTRA_HetNet | PCG-29 | UTRA 25.800 | Huawei | carmela.cozzo@huawei.com | Rel-12 | RP-57 | Patrick | FS_UTRA_HetNet |  |  |  | RP-131606 |
| 1511 | 360 | Study on Scalable UMTS FDD bandwidth | 265d? | 2012-12-10 A | 2013-12-06 A | 100% |  | 2012-12-10 | 2013-12-06 | 265d? |  | finish no earlier than 2013-12-06 | R1; R4 | 4240h | 4240h | FS_UTRA_SCAL | PCG-30 | UTRA TR 25.701 | China Unicom | Han Xiao (hanxiao91@chinaunicom.cn) | Rel-12 | RP-58 | Patrick | FS_UTRA_SCAL |  |  |  | RP-132035 |
| 1512 | 361 | Deleted - Study on Scalable UMTS FDD bandwidth by Filtering | 136d? | 2013-12-09 A | 2014-06-13 A | 100% |  | 2013-12-09 | 2014-06-13 | 136d? |  | finish no earlier than 2014-06-13 | R1 | 1088h | 1088h | FS_UTRA_SCAL_FILT | PCG-32 | UTRA TR 25.701 | China Unicom | Han Xiao (hanxiao91@chinaunicom.cn) | Rel-12 | RP-62 | Patrick | FS_UTRA_SCAL_FILT | PCG-33 | RP-64 |  | RP-140988 |
| 1513 | 362 | Study on Dedicated Channel (DCH) enhancements for UMTS | 197d? | 2012-12-10 A | 2013-09-06 A | 100% |  | 2012-12-10 | 2013-09-06 | 197d? |  | finish no earlier than 2013-09-06 | R1 | 1576h | 1576h | FS_UTRA_DCHenh | PCG-30 | UTRA TR 25.702 | Qualcomm | Arjun Bharadwaj (arjunb@qti.qualcomm.com) | Rel-12 | RP-58 | Patrick | FS_UTRA_DCHenh |  |  |  | RP-131073 |
| 1514 | 363 | Study on Further Enhanced Uplink (EUL) enhancements | 265d? | 2012-12-10 A | 2013-12-06 A | 100% |  | 2012-12-10 | 2013-12-06 | 265d? |  | finish no earlier than 2013-12-06 | R2; R1; R3 | 6360h | 6360h | FS_EDCH_enh | PCG-30 | UTRA TR 25.700 | Ericsson | alessandro.caverni@ericsson.com | Rel-12 | RP-58 | Yong-Jun | FS_EDCH_enh |  |  |  | RP-131608 |
| 1515 | 364 | Study on HNB Emergency Warning Area for UTRA | 191d? | 2013-06-18 A | 2014-03-06 A | 100% |  | 2013-06-18 | 2014-03-06 | 191d? |  | finish no earlier than 2014-03-06 | R3 | 1520h | 1520h | FS_HNB_warn_area | PCG-31 | UTRA TR 25.703 | Alcatel-Lucent, Ip.access | Martin.Warner@alcatel-lucent.com, Kit.kilgour@ipaccess.com | Rel-12 | RP-60 | Juha | FS_HNB_warn_area |  |  | HNB | RP-140129 |
| 1516 | 365 | Study on Enhanced Broadcast of System Information | 66d? | 2013-09-09 A | 2013-12-06 A | 100% |  | 2013-09-09 | 2013-12-06 | 66d? |  | finish no earlier than 2013-12-06 | R2; R1 | 1056h | 1056h | FS_UTRA_SIBenh | PCG-31 | UTRA TR 25.704 | Ericsson | martin.van.der.zee@ericsson.com | Rel-12 | RP-61 | Yong-Jun | FS_UTRA_SIBenh |  |  |  | RP-131610 |
| 1517 | 366 | Release 11 Features | 342.75d? | 2013-06-02 A | 2014-09-16 A | 100% |  | 2013-06-02 | 2014-09-17 | 342.75d? |  | finish no earlier than 2014-09-17 | SP; CP; GP; RP | 10968h | 10968h |  |  |  |  |  | Rel-11 |  | All |  |  |  |  |  |

Notes:
- 1460: Spin-off Features MAPCON, IFOM. SP#58 completed FS_MAPIM part of 23.861 (continued under FS_NBIFOM)
- 1461: SP#53 completed
- 1462: SP#43 TR 23.861v100 for Information. SP#56 Rel-9 TR 23.861v130 renamed & progressed under new Study FS_NBIFOM. SP#58 completed the FS_MAPIM part of TR 23.861 (TR continued under FS_NBIFOM).
- 1463: SP#59 stopped (at 40% completion). SP#56 revives dormant Study FS_MAPIM. TR 23.861 title changed from (Multi Access PDN connectivity and IP flow mobility) to (Network based IP flow mobility)
- 1464: SP#59 completed. Continuation of Rel-9 Feature UID_430036 IMS Media Plane Security (MEDIASEC). Study solutions and extensions to features and functionality described in TR 33.828 and TS 33.328
- 1465: SP#65 stopped. Linked to Rel-12 Service and Media Reachability for Users over Restrictive Firewalls (SMURFs) UID_530043
- 1466: SP#65 completed. TR 33.831v100 for 1-step Approval. Linked to Rel-11 SPUCI TR 33.838
- 1467: SP#64 completed. Spin-off Rel-13 Feature SCAS. Study methodologies for specifying product security assurance and hardening requirements on 3GPP network elements (with associated test cases when feasible)
- 1468: SP#65 completed. TR 26.938v200 for Approval. SP#60 TR 26.938v100 for Information. Linked to Feature UID_470034 HTTP-based Streaming and Download Services
- 1469: SP#65 completed. TR 26.907v200 for Approval. SP#64 TR 26.907v100 for Information.
- 1470: SP#58 completed
- 1471: SP#64 completed
- 1472: SP#61 completed. Linked to Network Sharing UID_31018, SA1 22.951 (Service aspects and requirements for network sharing), SA2 23.251 (Network Sharing; Architecture)
- 1473: SP#65 completed. TR 32.836v200 for Approval. SP#63 split of Rel-12 SP-130045 WID (Enhanced NM Centralized Coverage and Capacity Optimization) into a Rel-12 Study (SP-140028) and a Rel-13 Normative WID (SP-140060)
- 1474: SP#65 revised WID SP-130042=>SP-140536 (split into Rel-12 Study & Rel-13 normative WI). Changed Title from "TR on WLAN impacts to Type-2 management interface to the 3GPP Network Manager". TR 32.841v200 for Approval. Completed
- 1475: SP#61 completed
- 1476: CP#64 completed
- 1477: CP#65 completed. TR 29.809 v200 for Approval. Triggered by SA2 Rel-12 TR 23.843 Study on Core Network Overload solutions (FS_CNO) UID_490036. Coordinate with CT3, SA5
- 1478: CP#64 completed. Investigate introducing an XML-based protocol (e.g. SOAP, Restful HTTP, etc.) between AF and PCRF for non-IMS applications
- 1479: CP#65 completion 09/14=>12/14. CP#64 TR 29.949v100 for Information.Dec.14:95->100
- 1480: CP#65 completion 09/14=>12/14. Gathering of all ISIM-related conformance requirements and the assessment of CT6 coverage
- 1481: CP#65 TR 29.854v200 for Approval. Completion 09/14=>12/14. Dec.14: 80->85%. Mar.15: 100%
- 1482: GP#56 completed. GP#44 approved WID
- 1483: GP#62 completed. TR 43.801v100 for 1-step Approval. GP#50 approved WID. Triggered by Rel-8 TR 45.914 Study Multi-User-Reusing One Timeslot (MUROS) UID_50590 and Rel-9 VAMOS UID_420002
- 1484: GP#63 completed. TR~43.802v200 for Approval. GP#50 approved WID (mobile coucou). Triggered by RAN#51 (Mar 2011) WID in RP-110454 (LTE RAN Enhancements for Diverse Data Applications) UID_510031
- 1485: RP#61 completed. Linked to Rel-10 WI on Inclusion of RF Pattern Matching Technologies as a positioning method in the UTRAN (LCS_UMTS_RFPMT) UID_460005
- 1486: RP#60 completed
- 1487: RP#64 stopped at 80% completion
- 1488: RP#58 completed. TR 36.932 v100 for Information and Approval
- 1489: RP#62 completed. RP#61 TR 36.872v100 for 1-step approval. Triggered by Rel-12 TR 36.932 Study on Scenarios and Requirements of LTE Small Cell Enhancements for E-UTRA and E-UTRAN UID_570023
- 1490: RP#62 completed. Triggered by Rel-12 TR 36.932 Study on Scenarios and Requirements of LTE Small Cell Enhancements for E-UTRA and E-UTRAN UID_570023
- 1491: RP#63 completed. TR 36.843 for 1-step approval (90% complete). Started normative work. Linked to Rel-12 TR 22.803 Study on Proximity-based Services (FS_ProSe) and Feature ProSe
- 1492: RP#65 completed. Updated WID RP-130811=>RP-141237. TR 36.873v210 for Approval. Enhance performance with 3D-beamforming or with FD-MIMO. Study new channel modelling in both vertical and horizontal dimensions awa user locations in the network
- 1493: RP#64 completed. Identify potential solutions for energy saving in E-UTRAN non-overlapping scenario. Evaluate possible enhancements in overlapping scenario, so that a subset can be used for further investigation/standardization
- 1494: CD:Thu 11/12/14->Mon 15/12/14; Compl:80%->100%; Stat Rep: RP-141453->RP-141815
- 1495: RP#62 completed. Updated WID RP-130393=>RP-131840
- 1496: RP#63 completed. TR 36.866 (90% complete) for Approval. Started normative work
- 1497: RP#62 completed. Extension of Rel-11 CoMP Operation for LTE Downlink UID_530332)
- 1498: RP#63 completed. Evaluate ability of LTE to meet public safety requirements agreed in SA for GC (GC is a key functionality of Land Mobile Radio/Private Mobile Radio and public safety systems)
- 1499: RP#63 completed
- 1500: RP#64 completed. TR 36.856v100 for 1-step approval. Triggered by SA1 Re-12 TR 22.852 Study on RAN Sharing Enhancements (FS_RSE) and Rel-13 Feature RSE (TS 22.101 Stage 1)
- 1501: RP#59 completed
- 1502: RP#60 completed
- 1503: RP#61 completed (Conclusion: no spin-off WI). Linked to Rel-10 WI on Multi-standard radio Base Station RF requirements for non-contiguous spectrum deployments (MSR_NC) UID_480025
- 1504: RP#62 completed. Evaluate LTE-WLAN/UTRA-WLAN i/w procedures while improving (non-)seamless mobility. Deployed WLAN often under-utilized; User experience suboptimal when UE connects to overloaded WLAN.
- 1505: RP#62 completed. TR 37.852v100 for Information & Approval
- 1506: RP#64 completed. The study of SON features for small cell functionality covered by the Rel-12 small cell enhancement SIs (e.g. dual connectivity) is not in the scope of this study item
- 1507: RP#65 completed. Within EU these bands can be used for terrestrial mobile as a complement to mobile satellite services. Study adding an FDD band into UTRA/E-UTRA in applicable countries of Region 1
- 1508: RP#60 completed (1-step approval). Study new BS spec structure to avoid duplicate work for new RF features (in case of identical features among different RATs); avoid future discussions on how to implement new features in single-RAT/multi-RAT specs
- 1509: RP#61 completed
- 1510: RP#62 completed
- 1511: RP#62 completed. TR 25.701v200 for Approval
- 1512: RP#64 stopped at 85% completion. Follow-up of Rel-12 Study on scalable UMTS FDD bandwidth (FS_UTRA_SCAL). The result is captured in the same TR 25.701
- 1513: RP#61 completed
- 1514: RP#62 completed. TR 25.700v100 for Approval. Identify potential solutions to increase the uplink capacity, coverage and end-user performance (e.g. latency, achievable rates, etc.)
- 1515: RP#63 completed. TR 25.703 v100 for 1-step approval
- 1516: RP#62 completed. TR 25.704v100 for Information & Approval. Study need to add capacity to present SI Broadcast mechanism unchanged since R99
- 1517: -

| ID | WBS | Task | Duration | Start | Finish | Complete | Baseline start | Baseline finish | Baseline duration | Constraint | Resources | Work | Actual work | Acronym | PCG approved | WI rapporteur name | WI rapporteur e-mail | Release | TSG approved | MCC resp | Acronym_3GU_Export | Special Focus Doc | PCG stopped | TSG stopped |
| --- | --- | --- | --- | --- | --- | --- | --- | --- | --- | --- | --- | --- | --- | --- | --- | --- | --- | --- | --- | --- | --- | --- | --- | --- |
| 1518 | 367 | **Advanced IP Interconnection of Services** | 650d? | 2010-03-25 A | 2012-09-12 A | 100% | 2010-03-25 | 2012-09-12 | 650d? |  | S1; S2; C1; C3 | 34381.9h | 34381.9h | IPXS | PCG-24 | Telefónica | chris.friel@O2.com | Rel-11 | SP-47 | Alain | IPXS |  |  |  |
| 1519 | 367.1 | Stage 1 for Advanced IP Interconnection of Services | 392d | 2010-03-25 A | 2011-09-21 A | 100% | 2010-03-25 | 2011-09-21 | 392d | finish no earlier than 2011-09-21 | S1 | 3120h | 3120h | IPXS | PCG-24 | Telefónica | chris.friel@O2.com | Rel-11 | SP-47 | Alain |  |  |  |  |
| 1520 | 367.2 | Stage 2 for Advanced IP Interconnection of Services | 263d? | 2010-12-16 A | 2011-12-14 A | 100% | 2010-12-16 | 2011-12-14 | 263d? | finish no earlier than 2012-03-21 | S2 | 2085.91h | 2085.91h | IPXS | PCG-26 | Ericsson | fredrik.lindholm@ericsson.com | Rel-11 | SP-50 | Maurice |  |  |  |  |
| 1521 | 367.3 | **Stage 3 for Advanced IP Interconnection of Services** | 265d? | 2011-09-13 A | 2012-09-12 A | 100% | 2011-09-13 | 2012-09-12 | 265d? |  | C1; C3 | 8376h | 8376h | IPXS | PCG-27 | Ericsson | christer.holmberg@ericsson.com | Rel-11 | CP-53 | Frederic |  |  |  |  |
| 1522 | 367.3.1 | CT1 part of Stage 3 for Advanced IP Interconnection of Services | 262d? | 2011-09-16 A | 2012-09-12 A | 100% | 2011-09-16 | 2012-09-12 | 262d? | finish no earlier than 2012-12-07 | C1 | 2048h | 2048h | IPXS | PCG-27 | Ericsson | christer.holmberg@ericsson.com | Rel-11 | CP-53 | Frederic |  |  |  |  |
| 1523 | 367.3.2 | CT3 part of Stage 3 for Advanced IP Interconnection of Services | 262d? | 2011-09-13 A | 2012-09-07 A | 100% | 2011-09-13 | 2012-09-07 | 262d? | finish no earlier than 2012-09-07 | C3 | 2088h | 2088h | IPXS | PCG-27 | Ericsson | christer.holmberg@ericsson.com | Rel-11 | CP-53 | Adrian |  |  |  |  |
| 1524 | 368 | **System Improvements to Machine-Type Communications** | 1119d? | 2009-12-10 A | 2014-03-06 A | 100% | 2009-12-10 | 2014-03-06 | 1119d? |  | S1; S2; S5; C1; C3; C4; C6; R2; R3; R5 | 198763h | 198763h | SIMTC | PCG-25 | KPN | toon.norp@tno.nl | Rel-11 | SP-48 | Alain | SIMTC | MTC, M2M |  |  |
| 1525 | 368.1 | Stage 1 for SIMTC | 337d? | 2010-06-10 A | 2011-09-21 A | 100% | 2010-06-10 | 2011-09-21 | 337d? |  | S1 | 2683.46h | 2683.46h | SIMTC | PCG-25 | KPN | toon.norp@tno.nl | Rel-11 | SP-48 | Alain |  | MTC, M2M |  |  |
| 1526 | 368.2 | TR on Stage 2 for SIMTC | 593d? | 2010-06-10 A | 2012-09-12 A | 100% | 2010-06-10 | 2012-09-12 | 593d? | finish no earlier than 2012-09-12 | S2 | 4736h | 4736h | SIMTC | PCG-25 | Intel | puneet.jain@intel.com | Rel-11 | SP-48 | Maurice |  | MTC, M2M |  |  |
| 1527 | 368.3 | **BB1: Stage 2 Reachability Aspects of SIMTC** | 274d? | 2011-06-09 A | 2012-06-20 A | 100% | 2011-06-09 | 2012-06-20 | 274d? |  | S2 | 10773.1h | 10773.1h | SIMTC-Reach | PCG-27 | Intel | puneet.jain@intel.com | Rel-11 | SP-52 | Maurice | SIMTC-Reach | MTC, M2M |  |  |
| 1528 | 368.3.1 | Deleted - MTC Feature Control (described in TS 22.368, clause 7.1.1 and 23.888, clause 5.7) | 137d? | 2011-06-10 A | 2011-12-14 A | 100% | 2011-06-10 | 2011-12-14 | 137d? | finish no earlier than 2011-11-09 | S2 | 1088h | 1088h | SIMTC-Reach | PCG-27 | Intel | puneet.jain@intel.com | Rel-11 | SP-52 | Maurice |  | MTC, M2M | PCG-28 | SP-54 |
| 1529 | 368.3.2 | On-line device trigger | 273d? | 2011-06-09 A | 2012-06-20 A | 100% | 2011-06-09 | 2012-06-20 | 273d? | finish no earlier than 2012-06-20 | S2 | 2170.29h | 2170.29h | SIMTC-Reach | PCG-27 | Intel | puneet.jain@intel.com | Rel-11 | SP-52 | Maurice |  | MTC, M2M |  |  |
| 1530 | 368.3.3 | MTC Addressing | 138d? | 2011-06-09 A | 2011-12-14 A | 100% | 2011-06-09 | 2011-12-14 | 138d? | finish no earlier than 2012-03-21 | S2 | 1097.24h | 1097.24h | SIMTC-Reach | PCG-27 | Intel | puneet.jain@intel.com | Rel-11 | SP-52 | Maurice |  | MTC, M2M |  |  |
| 1531 | 368.3.4 | Identifiers – especially removal of MSISDN dependencies in the architecture | 273d? | 2011-06-09 A | 2012-06-20 A | 100% | 2011-06-09 | 2012-06-20 | 273d? | finish no earlier than 2012-06-20 | S2 | 2169.53h | 2169.53h | SIMTC-Reach | PCG-27 | Intel | puneet.jain@intel.com | Rel-11 | SP-52 | Maurice |  | MTC, M2M |  |  |
| 1532 | 368.3.5 | MSISDN-less / PS-Only | 196d? | 2011-06-13 A | 2012-03-07 A | 100% | 2011-06-13 | 2012-03-07 | 196d? | finish no earlier than 2012-03-07 | S2 | 1568h | 1568h | SIMTC-Reach | PCG-27 | Intel | puneet.jain@intel.com | Rel-11 | SP-52 | Maurice |  | MTC, M2M |  |  |
| 1533 | 368.3.6 | MTC related interfaces and functional entities to support above features (MTCsp, etc.) | 61d? | 2011-12-14 A | 2012-03-07 A | 100% | 2011-12-14 | 2012-03-07 | 61d? | finish no earlier than 2012-03-07 | S2 | 488h | 488h | SIMTC-Reach | PCG-28 | Intel | puneet.jain@intel.com | Rel-11 | SP-54 | Maurice |  | MTC, M2M |  |  |
| 1534 | 368.4 | **BB1: Stage 3 (CS+PS) Reachability Aspects of SIMTC** | 325d? | 2011-09-19 A | 2012-12-07 A | 100% | 2011-09-19 | 2012-12-07 | 325d? |  | C1; C3; C4; C6 | 19112h | 19112h | SIMTC-ReachCSPS | PCG-27 | Ericsson | mikael.wass@ericsson.com | Rel-11 | CP-53 | Frederic |  | MTC, M2M |  |  |
| 1535 | 368.4.1 | CT1 part of Stage 3 BB1: Reachability Aspects of SIMTC | 257d? | 2011-09-19 A | 2012-09-07 A | 100% | 2011-09-19 | 2012-09-07 | 257d? | finish no earlier than 2012-09-07 | C1 | 2048h | 2048h | SIMTC-ReachCSPS | PCG-27 | Ericsson | mikael.wass@ericsson.com | Rel-11 | CP-53 | Frederic |  | MTC, M2M |  |  |
| 1536 | 368.4.2 | CT3 part of Stage 3 BB1: Reachability Aspects of SIMTC | 257d? | 2011-09-19 A | 2012-09-07 A | 100% | 2011-09-19 | 2012-09-07 | 257d? | finish no earlier than 2012-09-07 | C3 | 2048h | 2048h | SIMTC-ReachCSPS | PCG-27 | Ericsson | mikael.wass@ericsson.com | Rel-11 | CP-53 | Adrian |  | MTC, M2M |  |  |
| 1537 | 368.4.3 | CT4 part of Stage 3 BB1: Reachability Aspects of SIMTC | 324d? | 2011-09-19 A | 2012-12-07 A | 100% | 2011-09-19 | 2012-12-07 | 324d? | finish no earlier than 2012-12-07 | C4 | 2568h | 2568h | SIMTC-ReachCSPS | PCG-27 | Ericsson | mikael.wass@ericsson.com | Rel-11 | CP-53 | Kimmo |  | MTC, M2M |  |  |
| 1538 | 368.4.4 | CT6 part of Stage 3 BB1: Reachability Aspects of SIMTC | 257d? | 2011-09-19 A | 2012-09-07 A | 100% | 2011-09-19 | 2012-09-07 | 257d? | finish no earlier than 2012-09-07 | C6 | 2048h | 2048h | SIMTC-ReachCSPS | PCG-27 | ST Ericsson | Andrzej Winiarski | Rel-11 | CP-53 | Xavier |  | MTC, M2M |  |  |
| 1539 | 368.5 | **Stage 2/3 for CS aspects for SIMTC** | 259d? | 2011-09-16 A | 2012-09-07 A | 100% | 2011-09-16 | 2012-09-07 | 259d? |  | C4; C1; C6 | 16544h | 16544h | SIMTC-CS | PCG-27 | Ericsson | mikael.wass@ericsson.com | Rel-11 | CP-53 | Kimmo | SIMTC-CS | MTC, M2M |  |  |
| 1540 | 368.5.1 | Deleted - Stage 2 CS aspects for SIMTC | 258d? | 2011-09-16 A | 2012-09-06 A | 100% | 2011-09-16 | 2012-09-06 | 258d? | finish no earlier than 2012-09-07 | C4 | 2056h | 2056h | SIMTC-CS | PCG-27 | Ericsson | mikael.wass@ericsson.com | Rel-11 | CP-53 | Kimmo |  | MTC, M2M | PCG-29 | CP-57 |
| 1541 | 368.5.2 | **Stage 3 CS aspects for SIMTC** | 259d? | 2011-09-16 A | 2012-09-07 A | 100% | 2011-09-16 | 2012-09-07 | 259d? |  | C1; C6 | 8272h | 8272h | SIMTC-CS | PCG-27 | Ericsson | mikael.wass@ericsson.com | Rel-11 | CP-53 | Frederic |  | MTC, M2M |  |  |
| 1542 | 368.5.2.1 | CT1 part of Stage 3 CS aspects for SIMTC | 259d? | 2011-09-16 A | 2012-09-07 A | 100% | 2011-09-16 | 2012-09-07 | 259d? | start no earlier than 2011-09-16 | C1 | 2064h | 2064h | SIMTC-CS | PCG-27 | Ericsson | mikael.wass@ericsson.com | Rel-11 | CP-53 | Frederic |  | MTC, M2M |  |  |
| 1543 | 368.5.2.2 | Deleted - CT6 part of Stage 3 CS aspects for SIMTC | 259d? | 2011-09-16 A | 2012-09-07 A | 100% | 2011-09-16 | 2012-09-07 | 259d? | start no earlier than 2011-09-16 | C6 | 2064h | 2064h | SIMTC-CS | PCG-27 | Ericsson | mikael.wass@ericsson.com | Rel-11 | CP-53 | Xavier |  | MTC, M2M | PCG-29 | CP-57 |

Notes:
- 1518: CP#58 completed. Triggered by Rel-10 TR 22.893 UID_380083 Study on advanced requirements for IP interconnect (FS_IPXS)
- 1519: SP#53 completed / Impacted TSs and TRs: 22.101, 22.228
- 1520: SP#54 completed / Impacted TSs and TRs: 23.228
- 1521: CP#58 completed / Impacted TSs and TRs: Stage 3
- 1522: CP#58 completed / Impacted TSs and TRs: 24.229
- 1523: CP#57 completed / Impacted TSs and TRs: 29.165
- 1524: SP#58 completed. Updated WID SP-110877=>SP-120848. Enhancements to Rel-10 Feature UID_410031 (NIMTC) based on Rel-11 Study on enhancements to MTC
- 1525: SP#53 completed. SP#57 added MTC definitions in 21.905 / Impacted TSs and TRs: 22.368, 21.905 (MTC definitions)
- 1526: SP#57 completed. TR 23.888v200 for Approval. Was Rel-10 UID_450028 (TR on Stage 2 for NIMTC) / Impacted TSs and TRs: New TR 23.888
- 1527: SP#56 completed. SP#58 updated WID SP-110877=>S3-121111 (SA3 normative work on Security aspects of SIMTC incorporated in SA2 TS 23.682) / Impacted TSs and TRs: 23.221, New 23.368
- 1528: SP#54 work stopped
- 1529: SP#56 completed / Impacted TSs and TRs: New 23.682
- 1530: SP#54 completed / Impacted TSs and TRs: 23.221, New 23.682
- 1531: SP#56 completed / Impacted TSs and TRs: New 23.682
- 1532: SP#55 completed / Impacted TSs and TRs: 23.060, 23.272, New 23.682
- 1533: SP#55 completed / Impacted TSs and TRs: New 23.682
- 1534: 22/01: acronym modified / Impacted TSs and TRs: Stage 3
- 1535: 22/01: acronym modified / Impacted TSs and TRs: 23.040, 24.008, 24.301, 24.341, 24.368
- 1536: 22/01: acronym modified / Impacted TSs and TRs: 29.061, New TS 29.368
- 1537: 22/01: acronym modified / Impacted TSs and TRs: 23.003, 23.008, 29.002, 29.060, 29.230, New TS (29.336, 29.337)
- 1538: 22/01: acronym modified / Impacted TSs and TRs: 31.102
- 1539: CP#57 completed. Updated WID CP-120418=>CP-120617 / Impacted TSs and TRs: Stage 2/3
- 1540: CP#57 stopped / Impacted TSs and TRs: 23.012
- 1541: CP#57 completed / Impacted TSs and TRs: Stage 3
- 1542: CP#57 completed / Impacted TSs and TRs: 24.008, 24.301
- 1543: CP#57 stopped / Impacted TSs and TRs: 31.102

| ID | WBS | Task | Duration | Start | Finish | Complete | Baseline start | Baseline finish | Baseline duration | Constraint | Resources | Work | Actual work | Acronym | PCG approved | WI rapporteur name | WI rapporteur e-mail | Release | TSG approved | MCC resp | Special Focus Doc | Acronym_3GU_Export | Status Report | PCG stopped | TSG stopped |
| --- | --- | --- | --- | --- | --- | --- | --- | --- | --- | --- | --- | --- | --- | --- | --- | --- | --- | --- | --- | --- | --- | --- | --- | --- | --- |
| 1544 | 368.6 | **Stage 2/3 for SMS in MME architecture option and related PS-only service subscription** | 129d? | 2012-06-15 A | 2012-12-07 A | 100% | 2012-06-15 | 2012-12-07 | 129d? |  | C1; C4 | 3560h | 3560h | SIMTC-PS_Only | PCG-29 | Ericsson | mikael.wass@ericsson.com | Rel-11 | CP-56 | Frederic | MTC, M2M | SIMTC-PS_Only |  |  |  |
| 1545 | 368.6.1 | CT1 part of Stage 2/3 for SMS in MME architecture option and related PS-only service subscription | 62d? | 2012-06-15 A | 2012-09-07 A | 100% | 2012-06-15 | 2012-09-07 | 62d? | finish no earlier than 2012-09-07 | C1 | 488h | 488h | SIMTC-PS_Only | PCG-29 | Ericsson | mikael.wass@ericsson.com | Rel-11 | CP-56 | Frederic | MTC, M2M |  |  |  |  |
| 1546 | 368.6.2 | CT4 part of Stage 2/3 for SMS in MME architecture option and related PS-only service subscription | 129d? | 2012-06-15 A | 2012-12-07 A | 100% | 2012-06-15 | 2012-12-07 | 129d? | finish no earlier than 2012-12-07 | C4 | 1008h | 1008h | SIMTC-PS_Only | PCG-29 | Ericsson | mikael.wass@ericsson.com | Rel-11 | CP-56 | Kimmo | MTC, M2M |  |  |  |  |
| 1547 | 368.7 | **RAN overload control for Machine-Type Communications** | 259d? | 2011-09-16 A | 2012-09-07 A | 100% | 2011-09-16 | 2012-09-07 | 259d? |  | R2; R3; C1; C6 | 20178.3h | 20178.3h | SIMTC-RAN_OC | PCG-27 | Huawei | Jeff Gao (gaoyongqiang@huawei.com) | Rel-11 | RP-53 | Yong-Jun | MTC, M2M | SIMTC-RAN_OC |  |  |  |
| 1548 | 368.7.1 | Core part: RAN overload control for Machine-Type Communications | 258d? | 2011-09-19 A | 2012-09-07 A | 100% | 2011-09-19 | 2012-09-07 | 258d? | finish no earlier than 2012-09-07 | R2; R3 | 4128h | 4128h | SIMTC-RAN_OC-Core | PCG-27 | Huawei | Jeff Gao (gaoyongqiang@huawei.com) | Rel-11 | RP-53 | Yong-Jun | MTC, M2M | SIMTC-RAN_OC-Core |  |  |  |
| 1549 | 368.7.2 | **Stage 3 (CS+PS) Extended Access Barring for UTRAN and E-UTRAN** | 259d? | 2011-09-16 A | 2012-09-07 A | 100% | 2011-09-16 | 2012-09-07 | 259d? |  | C1; C6 | 7762.29h | 7762.29h | SIMTC-RAN_OC | PCG-27 | Ericsson | mikael.wass@ericsson.com | Rel-11 | CP-53 | Frederic | MTC, M2M |  |  |  |  |
| 1550 | 368.7.2.1 | CT1 part of Stage 3 Extended Access Barring for UTRAN and E-UTRAN | 198d? | 2011-09-16 A | 2012-06-15 A | 100% | 2011-09-16 | 2012-06-15 | 198d? | finish no earlier than 2012-09-14 | C1 | 1570.29h | 1570.29h | SIMTC-RAN_OC | PCG-27 | Ericsson | mikael.wass@ericsson.com | Rel-11 | CP-53 | Frederic | MTC, M2M |  |  |  |  |
| 1551 | 368.7.2.2 | CT6 part of Stage 3 Extended Access Barring for UTRAN and E-UTRAN | 257d? | 2011-09-20 A | 2012-09-07 A | 100% | 2011-09-20 | 2012-09-07 | 257d? | finish no earlier than 2012-09-07 | C6 | 2048h | 2048h | SIMTC-RAN_OC | PCG-27 | ST Ericsson | Andrzej Winiarski | Rel-11 | CP-53 | Xavier | MTC, M2M |  |  |  |  |
| 1552 | 368.8 | Test part: System Improvements for Machine-Type Communications | 130d? | 2013-09-09 A | 2014-03-06 A | 100% | 2013-09-09 | 2014-03-06 | 130d? | finish no earlier than 2014-03-06 | R5 | 1040h | 1040h | SIMTC-UEConTest | PCG-31 | Ericsson | calle.hagenfeldt@ericsson.com | Rel-11 | RP-61 | Ingbert | MTC, M2M | SIMTC-UEConTest | RP-140075 |  |  |
| 1553 | 368.9 | BB5: Charging of SIMTC (Stage 2/3) | 269d? | 2011-12-07 A | 2012-12-12 A | 100% | 2011-12-07 | 2012-12-12 | 269d? | finish no earlier than 2012-12-12 | S5 | 2144h | 2144h | SIMTC-CH | PCG-28 | Ericsson | patrik.teppo@ericsson.com | Rel-11 | SP-54 | Mirko | MTC, M2M | SIMTC-CH |  |  |  |
| 1554 | 368.10 | **Deleted - BB2: Stage 2 Signalling Optimizations of SIMTC** | 137d? | 2011-06-10 A | 2011-12-14 A | 100% | 2011-06-10 | 2011-12-14 | 137d? |  | S2 | 5240h | 5240h | SIMTC-Sig | PCG-27 | Intel | puneet.jain@intel.com | Rel-11 | SP-52 | Maurice | MTC, M2M | SIMTC-Sig |  | PCG-28 | SP-55 |
| 1555 | 368.10.1 | Deleted - Effectively maintain connectivity for a large number of MTC Devices (TS 22.368, 7.1.1) | 137d? | 2011-06-10 A | 2011-12-14 A | 100% | 2011-06-10 | 2011-12-14 | 137d? | finish no earlier than 2011-12-07 | S2 | 1088h | 1088h | SIMTC-Sig | PCG-27 | Intel | puneet.jain@intel.com | Rel-11 | SP-52 | Maurice | MTC, M2M |  |  | PCG-28 | SP-55 |
| 1556 | 368.10.2 | Deleted - Small Data Transmissions (TS 22.368, 7.2.5) | 137d? | 2011-06-10 A | 2011-12-14 A | 100% | 2011-06-10 | 2011-12-14 | 137d? | finish no earlier than 2011-12-07 | S2 | 1088h | 1088h | SIMTC-Sig | PCG-27 | Intel | puneet.jain@intel.com | Rel-11 | SP-52 | Maurice | MTC, M2M |  |  | PCG-28 | SP-55 |
| 1557 | 368.10.3 | **Deleted - Stage 3 (CS+PS) Signalling Optimizations of SIMTC** | 62d? | 2011-09-16 A | 2011-12-09 A | 100% | 2011-09-16 | 2011-12-09 | 62d? |  | C1; C6 | 1968h | 1968h | SIMTC-Sig | PCG-27 | Ericsson | mikael.wass@ericsson.com | Rel-11 | CP-53 | Frederic | MTC, M2M |  |  | PCG-28 | CP-55 |
| 1558 | 368.10.3.1 | Deleted - CT1 part of Stage 3 Signalling Optimizations of SIMTC | 62d? | 2011-09-16 A | 2011-12-09 A | 100% | 2011-09-16 | 2011-12-09 | 62d? | finish no earlier than 2011-12-02 | C1 | 488h | 488h | SIMTC-Sig | PCG-27 | Ericsson | mikael.wass@ericsson.com | Rel-11 | CP-53 | Frederic | MTC, M2M |  |  | PCG-28 | CP-55 |
| 1559 | 368.10.3.2 | Deleted - CT6 part of Stage 3 Signalling Optimizations of SIMTC | 62d? | 2011-09-16 A | 2011-12-09 A | 100% | 2011-09-16 | 2011-12-09 | 62d? | finish no earlier than 2011-12-02 | C6 | 488h | 488h | SIMTC-Sig | PCG-27 | ST Ericsson | Andrzej Winiarski | Rel-11 | CP-53 | Xavier | MTC, M2M |  |  | PCG-28 | CP-55 |
| 1560 | 368.11 | **Deleted - BB3: Stage 2 CN-based requirements and Power Considerations of SIMTC** | 139d? | 2011-06-08 A | 2011-12-14 A | 100% | 2011-06-08 | 2011-12-14 | 139d? |  | S2 | 6360h | 6360h | SIMTC-CN_Pow | PCG-27 | Intel | puneet.jain@intel.com | Rel-11 | SP-52 | Maurice | MTC, M2M | SIMTC-CN_Pow |  | PCG-28 | SP-55 |
| 1561 | 368.11.1 | Deleted - Charging Requirements (TS 22.368, 7.1.5) | 137d? | 2011-06-10 A | 2011-12-14 A | 100% | 2011-06-10 | 2011-12-14 | 137d? | finish no earlier than 2012-03-21 | S2 | 1088h | 1088h | SIMTC-CN_Pow | PCG-27 | Intel | puneet.jain@intel.com | Rel-11 | SP-52 | Maurice | MTC, M2M |  |  | PCG-28 | SP-55 |
| 1562 | 368.11.2 | Deleted - Lower Power Consumption (TS 22.368, 7.1.1) | 137d? | 2011-06-10 A | 2011-12-14 A | 100% | 2011-06-10 | 2011-12-14 | 137d? | finish no earlier than 2011-12-07 | S2 | 1088h | 1088h | SIMTC-CN_Pow | PCG-27 | Intel | puneet.jain@intel.com | Rel-11 | SP-52 | Maurice | MTC, M2M |  |  | PCG-28 | SP-55 |
| 1563 | 368.11.3 | Deleted - MTC Monitoring (TS 22.368, 7.2.8) | 139d? | 2011-06-08 A | 2011-12-14 A | 100% | 2011-06-08 | 2011-12-14 | 139d? | finish no earlier than 2011-12-07 | S2 | 1104h | 1104h | SIMTC-CN_Pow | PCG-27 | Intel | puneet.jain@intel.com | Rel-11 | SP-52 | Maurice | MTC, M2M |  |  | PCG-28 | SP-55 |
| 1564 | 368.11.4 | **Deleted - Stage 3 (CS+PS) CN-based requirements and Power Considerations of SIMTC** | 62d? | 2011-09-16 A | 2011-12-09 A | 100% | 2011-09-16 | 2011-12-09 | 62d? |  | C1; C6 | 1968h | 1968h | SIMTC-CN_Pow | PCG-27 | Ericsson | mikael.wass@ericsson.com | Rel-11 | CP-53 | Frederic | MTC, M2M |  |  | PCG-28 | CP-55 |
| 1565 | 368.11.4.1 | Deleted - CT1 part of Stage 3 CN-based requirements and Power Considerations of SIMTC | 62d? | 2011-09-16 A | 2011-12-09 A | 100% | 2011-09-16 | 2011-12-09 | 62d? | finish no earlier than 2011-12-02 | C1 | 488h | 488h | SIMTC-CN_Pow | PCG-27 | Ericsson | mikael.wass@ericsson.com | Rel-11 | CP-53 | Frederic | MTC, M2M |  |  | PCG-28 | CP-55 |
| 1566 | 368.11.4.2 | Deleted - CT6 part of Stage 3 CN-based requirements and Power Considerations of SIMTC | 62d? | 2011-09-16 A | 2011-12-09 A | 100% | 2011-09-16 | 2011-12-09 | 62d? | finish no earlier than 2011-12-02 | C6 | 488h | 488h | SIMTC-CN_Pow | PCG-27 | ST Ericsson | Andrzej Winiarski | Rel-11 | CP-53 | Xavier | MTC, M2M |  |  | PCG-28 | CP-55 |
| 1567 | 368.12 | Deleted - TR on Security aspects of Machine-Type Communications | 662d? | 2009-12-10 A | 2012-06-20 A | 100% | 2009-12-10 | 2012-06-20 | 662d? | finish no earlier than 2012-06-20 | S3 | 5288h | 5288h |  | PCG-25 | Samsung | Rajavelsamy R (rajvel@samsung.com) | Rel-11 | SP-49 | Mirko | MTC, M2M |  |  | PCG-29 | SP-56 |

Notes:
- 1544: CP#58 completed / Impacted TSs and TRs: Stage 2/3
- 1545: CP#57 completed / Impacted TSs and TRs: 23.040, 24.008, 24.011, 24.301, 29.018, 29.118
- 1546: CP#58 completed. TS 29.338 v200 for Approval / Impacted TSs and TRs: 23.003, 23.008, 23.012, 29.002, 29.272, 29.305, New TS 29.338
- 1547: Stage 2,3. TSG#57 completed / Impacted TSs and TRs: UTRA, LTE
- 1548: RP#57 completed / Impacted TSs and TRs: 25.304, 25.331, 25.413, 36.304, 36.331, 36.413
- 1549: CP#57 completed. Updated WID CP-120418=>CP-120617 / Impacted TSs and TRs: Stage 3
- 1550: CP#56 completed / Impacted TSs and TRs: 23.122, 24.008, 24.301
- 1551: CP#57 completed / Impacted TSs and TRs: 31.102
- 1552: RP#63 completed. Updated WID RP-131341=>RP-140077 (added affected TS 36.508). Testing for core part: SIMTC-Reach, SIMTC-CS, SIMTC-PS_Only, SIMTC-RAN_OC / Impacted TSs and TRs: 34.123-1, 34.123-2, 34.123-3, 36.508, 36.523-1, 36.523-2, 36.523-3
- 1553: SP#58 completed / Impacted TSs and TRs: 32.240, 32.251, 32.298, 32.299
- 1554: SP#54 work stopped. SP#58 updated WID SP-110877=>SP-120848 / Impacted TSs and TRs: TBD
- 1555: SP#54 work stopped / Impacted TSs and TRs: TBD
- 1556: SP#54 work stopped / Impacted TSs and TRs: TBD
- 1557: CP#54 work stopped / Impacted TSs and TRs: Stage 3
- 1558: - / Impacted TSs and TRs: 23.122, 24.008, 24.301, 24.368
- 1559: - / Impacted TSs and TRs: 31.102
- 1560: SP#54 work stopped / Impacted TSs and TRs: TBD
- 1561: SP#54 work stopped / Impacted TSs and TRs: TBD
- 1562: SP#54 work stopped / Impacted TSs and TRs: TBD
- 1563: SP#54 work stopped / Impacted TSs and TRs: TBD
- 1564: CP#54 work stopped / Impacted TSs and TRs: Stage 3
- 1565: - / Impacted TSs and TRs: 23.122, 24.008, 24.301, 24.368
- 1566: - / Impacted TSs and TRs: 31.101, 31.102
- 1567: Was Rel-10 UID_460023 (Security for NIMTC). SP#56 stopped (activity transferred to Rel-12 Feature MTCe under UID_560722). / Impacted TSs and TRs: New TR 33.868

| ID | WBS | Task | Type | Duration | Start | Finish | Complete | Baseline start | Baseline finish | Baseline duration | Constraint | Resources | Work | Actual work | Acronym | PCG approved | Impacted TSs and TRs | WI rapporteur name | Release | TSG approved | MCC resp | PCG stopped | TSG stopped | Special Focus Doc | Acronym_3GU_Export |
| --- | --- | --- | --- | --- | --- | --- | --- | --- | --- | --- | --- | --- | --- | --- | --- | --- | --- | --- | --- | --- | --- | --- | --- | --- | --- |
| 1568 | 368.13 | **Deleted - BB4: Secure Connection and Privacy of SIMTC** |  | 336d? | 2011-06-08 A | 2012-09-12 A | 100% | 2011-06-08 | 2012-09-12 | 336d? |  | S3 | 7424h | 7424h | SIMTC-Sec | PCG-27 | TBD | Samsung | Rel-11 | SP-52 | Mirko | PCG-29 | CP-57 | MTC, M2M | SIMTC-Sec |
| 1569 | 368.13.1 | Deleted - Secure Connection MTC Feature (TS 22.368, 7.2.10) |  | 333d? | 2011-06-08 A | 2012-09-12 A | 100% | 2011-06-08 | 2012-09-12 | 333d? | finish no earlier than 2012-09-12 | S3 | 2656h | 2656h | SIMTC-Sec | PCG-27 | TBD | Samsung | Rel-11 | SP-52 | Mirko | PCG-29 | CP-57 | MTC, M2M |  |
| 1570 | 368.13.2 | Deleted - MTC Location Privacy |  | 261d? | 2011-09-19 A | 2012-09-12 A | 100% | 2011-09-19 | 2012-09-12 | 261d? | finish no earlier than 2012-09-12 | S3 | 2080h | 2080h | SIMTC-Priv | PCG-27 | TBD | Samsung | Rel-11 | SP-53 | Mirko | PCG-29 | CP-57 | MTC, M2M | SIMTC-Priv |
| 1571 | 368.14 | Deleted - Stage 2 on SA2 part for System Improvements to Machine-Type Communications |  | 260d? | 2010-06-10 A | 2011-06-08 A | 100% | 2010-06-10 | 2011-06-08 | 260d? | finish no earlier than 2011-06-08 | S2 | 2080h | 2080h | SIMTC | PCG-25 | TBD | Intel | Rel-11 | SP-48 | Maurice | PCG-27 | SP-52 | MTC, M2M |  |
| 1572 | 368.15 | Deleted - Stage 2 on Security part for System Improvements to Machine-Type Communications |  | 260d? | 2010-06-10 A | 2011-06-08 A | 100% | 2010-06-10 | 2011-06-08 | 260d? | finish no earlier than 2011-06-08 | S3 | 2080h | 2080h | SIMTC | PCG-25 | TBD | Samsung | Rel-11 | SP-48 | Mirko | PCG-27 | SP-52 | MTC, M2M |  |
| 1573 | 369 | **Unstructured Supplementary Service Data (USSD) simulation service in IMS** |  | 659d? | 2010-06-10 A | 2012-12-07 A | 100% | 2010-06-10 | 2012-12-07 | 659d? |  | S1; C1; C3 | 28112.1h | 28112.1h | USSI | PCG-25 |  | Deutsche Telekom | Rel-11 | SP-48 | Alain |  |  |  | USSI |
| 1574 | 369.1 | Stage 1 for USSD simulation service in IMS | milestone | 0d? | 2010-06-10 A | 2010-06-10 A | 100% | 2010-06-10 | 2010-06-10 | 0d? | finish no earlier than 2010-06-10 | S1 |  |  | USSI | PCG-25 | 22.173 | Deutsche Telekom | Rel-11 | SP-48 | Alain |  |  |  |  |
| 1575 | 369.2 | **Stage 3 for USSD simulation service in IMS** |  | 403d? | 2011-06-03 A | 2012-12-07 A | 100% | 2011-06-03 | 2012-12-07 | 403d? |  | C1; C3 | 12296.1h | 12296.1h | USSI | PCG-27 |  | Deutsche Telekom | Rel-11 | CP-52 | Frederic |  |  |  |  |
| 1576 | 369.2.1 | CT1 part of Stage 3 for USSD simulation service in IMS |  | 402d? | 2011-06-03 A | 2012-12-07 A | 100% | 2011-06-03 | 2012-12-07 | 402d? | finish no earlier than 2012-12-07 | C1 | 3184.06h | 3184.06h | USSI | PCG-27 | 24.173, 24.229, new TS 24.390 | Deutsche Telekom | Rel-11 | CP-52 | Frederic |  |  |  |  |
| 1577 | 369.2.2 | CT3 part of Stage 3 for USSD simulation service in IMS |  | 334d? | 2011-06-07 A | 2012-09-07 A | 100% | 2011-06-07 | 2012-09-07 | 334d? | finish no earlier than 2012-09-07 | C3 | 2664h | 2664h | USSI | PCG-27 | 29.165 | Deutsche Telekom | Rel-11 | CP-52 | Adrian |  |  |  |  |
| 1578 | 370 | **QoS Control Based on Subscriber Spending Limits** |  | 459d? | 2010-09-23 A | 2012-06-20 A | 100% | 2010-09-23 | 2012-06-20 | 459d? |  | S1; S2; S5; C3 | 23152h | 23152h | QoS_SSL | PCG-25 |  | Vodafone | Rel-11 | SP-49 | Alain |  |  |  | QoS_SSL |
| 1579 | 370.1 | Stage 1 for QoS Control Based on Subscriber Spending Limits |  | 262d? | 2010-09-23 A | 2011-09-21 A | 100% | 2010-09-23 | 2011-09-21 | 262d? | finish no earlier than 2011-09-21 | S1 | 2080h | 2080h | QoS_SSL | PCG-25 | 22.115 | Vodafone | Rel-11 | SP-49 | Alain |  |  |  |  |
| 1580 | 370.2 | Stage 2 for QoS Control Based on Subscriber Spending Limits |  | 133d? | 2011-03-23 A | 2011-09-21 A | 100% | 2011-03-23 | 2011-09-21 | 133d? | finish no earlier than 2011-12-14 | S2 | 1048h | 1048h | QoS_SSL | PCG-26 | 23.203 | Huawei | Rel-11 | SP-51 | Maurice |  |  |  |  |
| 1581 | 370.3 | Charging for QoS Control Based on Subscriber Spending Limits (Stage 2) |  | 397d? | 2010-12-16 A | 2012-06-20 A | 100% | 2010-12-16 | 2012-06-20 | 397d? | finish no earlier than 2012-06-20 | S5 | 3168h | 3168h | QoS_SSL | PCG-26 | 32.240, 32.296 | Nokia Siemens Networks, Huawei | Rel-11 | SP-50 | Mirko |  |  |  |  |
| 1582 | 370.4 | CT3 aspects of QoS Control Based on Subscriber Spending Limits (Stage 3) |  | 273d? | 2011-06-03 A | 2012-06-15 A | 100% | 2011-06-03 | 2012-06-15 | 273d? | finish no earlier than 2012-06-15 | C3 | 2168h | 2168h | QoS_SSL-CT3 | PCG-27 | 29.212, 29.213, 29.214, 29.215, new TS 29.219 | Huawei | Rel-11 | CP-52 | Adrian |  |  |  | QoS_SSL-CT3 |
| 1583 | 371 | **Optimized Service Charging and Allocation of Resources in IMS whilst Roaming** |  | 383d? | 2010-09-23 A | 2012-03-07 A | 100% | 2010-09-23 | 2012-03-07 | 383d? |  | S1; S2 | 14288h | 14288h | OSCAR | PCG-25 |  | Vodafone | Rel-11 | SP-49 | Alain |  |  |  | OSCAR |
| 1584 | 371.1 | TR on Stage 2 aspects of Optimized Service Charging and Allocation of Resources in IMS whilst Roaming |  | 383d? | 2010-09-23 A | 2012-03-07 A | 100% | 2010-09-23 | 2012-03-07 | 383d? | finish no earlier than 2011-12-07 | S2 | 3040h | 3040h | OSCAR | PCG-25 | new TR 23.849 | Vodafone | Rel-11 | SP-49 | Maurice |  |  |  |  |
| 1585 | 371.2 | Stage 1 for Optimized Service Charging and Allocation of Resources in IMS whilst Roaming |  | 262d? | 2010-09-23 A | 2011-09-21 A | 100% | 2010-09-23 | 2011-09-21 | 262d? | finish no earlier than 2011-09-21 | S1 | 2080h | 2080h | OSCAR | PCG-25 | 22.115, 22.173, 22.228 | Vodafone | Rel-11 | SP-49 | Alain |  |  |  |  |
| 1586 | 371.3 | Deleted - Stage 2 for Optimized Service Charging and Allocation of Resources in IMS whilst Roaming |  | 380d? | 2010-09-28 A | 2012-03-07 A | 100% | 2010-09-28 | 2012-03-07 | 380d? | finish no earlier than 2012-03-07 | S2 | 3040h | 3040h | OSCAR | PCG-25 | None | Vodafone | Rel-11 | SP-49 | Maurice | PCG-28 | SP-55 |  |  |
| 1587 | 372 | **Inclusion of Media Resource Broker (Stage 2/3)** |  | 463d? | 2011-09-16 A | 2013-06-14 A | 100% | 2011-09-16 | 2013-06-14 | 463d? |  | C1; C3; IETF | 30500h | 30500h | MRB | PCG-27 | Stage 2/3 | AT&T | Rel-11 | CP-53 | Frederic |  |  |  | MRB |
| 1588 | 372.1 | Stage 2 for Inclusion of Media Resource Broker |  | 259d? | 2011-09-16 A | 2012-09-07 A | 100% | 2011-09-16 | 2012-09-07 | 259d? | finish no earlier than 2012-09-07 | C1 | 2049.98h | 2049.98h | MRB | PCG-27 | 23.218 | AT&T | Rel-11 | CP-53 | Frederic |  |  |  |  |
| 1589 | 372.2 | **Stage 3 for Inclusion of Media Resource Broker** |  | 463d? | 2011-09-16 A | 2013-06-14 A | 100% | 2011-09-16 | 2013-06-14 | 463d? |  | C1; C3; IETF | 17338h | 17338h | MRB | PCG-27 |  | AT&T | Rel-11 | CP-53 | Frederic |  |  |  |  |
| 1590 | 372.2.1 | CT1 part of Stage 3 for Inclusion of Media Resource Broker |  | 258d? | 2011-09-16 A | 2012-09-07 A | 100% | 2011-09-16 | 2012-09-07 | 258d? | finish no earlier than 2012-09-07 | C1 | 2049.98h | 2049.98h | MRB | PCG-27 | 24.229, 29.165 | AT&T | Rel-11 | CP-53 | Frederic |  |  |  |  |
| 1591 | 372.2.2 | (IETF) Inclusion of Media Resource Broker [RFC 6917 (was draft-ietf-mediactrl-mrb)] |  | 462d? | 2011-09-16 A | 2013-06-14 A | 100% | 2011-09-16 | 2013-06-14 | 462d? | finish no earlier than 2013-06-14 | C1-IETF | 3688h | 3688h | MRB | PCG-27 | RFC 6917 (was draft-ietf-mediactrl-mrb) | Keith Drage | Rel-11 | CP-53 | Frederic |  |  |  |  |
| 1592 | 372.2.3 | CT3 part of Stage 3 for Inclusion of Media Resource Broker |  | 62d? | 2012-06-15 A | 2012-09-07 A | 100% | 2012-06-15 | 2012-09-07 | 62d? | finish no earlier than 2012-09-07 | C3 | 488h | 488h | MRB | PCG-29 | 29.165 | AT&T | Rel-11 | CP-56 | Adrian |  |  |  |  |

Notes:
- 1568: SP#57 stopped (activity transferred to Rel-12 Feature MTCe under UID_560522) / WI rapporteur e-mail: Rajavelsamy R (rajvel@samsung.com)
- 1569: SP#57 stopped (activity transferred to Rel-12 Feature MTCe / WI rapporteur e-mail: Rajavelsamy R (rajvel@samsung.com)
- 1570: SP#57 stopped (activity transferred to Rel-12 Feature MTCe / WI rapporteur e-mail: Rajavelsamy R (rajvel@samsung.com)
- 1571: SP#52 stopped / WI rapporteur e-mail: puneet.jain@intel.com
- 1572: SP#52 stopped / WI rapporteur e-mail: Rajavelsamy R (rajvel@samsung.com)
- 1573: CP#58 completed / WI rapporteur e-mail: kurt.bischinger@t-mobile.at
- 1574: SP#48 completed. Specify a CS domain USSD like service over IMS (see GSM Mobile User Initiated USSD) / WI rapporteur e-mail: kurt.bischinger@t-mobile.at
- 1575: SP#58 completed. No stage 2 impact, as reuse existing IMS architecture in TS 23.228 / WI rapporteur e-mail: reinhard.lauster@t-mobile.at
- 1576: CP#58 completed / WI rapporteur e-mail: reinhard.lauster@t-mobile.at, TS 24.390 Rapp: lili.yang@huawei.com
- 1577: CP#57 completed / WI rapporteur e-mail: reinhard.lauster@t-mobile.at
- 1578: TSG#56 completed / WI rapporteur e-mail: mona.mustapha@vodafone.com
- 1579: SP#53 completed. Use cases & service requirements to allow: 1) modification of QoS based on subscribers spending limits 2) enforcing of spending limits for roaming subscribers without having dedicated support in the visited network / WI rapporteur e-mail: mona.mustapha@vodafone.com
- 1580: SP#53 completed / WI rapporteur e-mail: Xu Xia (xiatony@huawei.com)
- 1581: SP#56 completed / WI rapporteur e-mail: Gerald.Goermer@nsn.com, shan.mingjun@huawei.com
- 1582: CP#56 completed / WI rapporteur e-mail: QiaoWeihua@huawei.com
- 1583: SP#55 completed (Stage 2/3 specified under CT1 Rel-11 Feature MRB (Inclusion of Media Resource Broker) UID_530021. Triggered by S1-102236/GSMA RILTE 10_007r1 (IREG LS_038 to 3GPP on Optimal Media Routing drawbacks) / WI rapporteur e-mail: mona.mustapha@vodafone.com
- 1584: SP#55 completed / WI rapporteur e-mail: Susana.Sabater@vodafone.com
- 1585: SP#53 completed / WI rapporteur e-mail: mona.mustapha@vodafone.com
- 1586: SP#55 no normative work in SA2. Stage 2/3 to be done in under CT1 Rel-11 Feature MRB (Inclusion of Media Resource Broker) UID_530021 / WI rapporteur e-mail: Susana.Sabater@vodafone.com
- 1587: Stage 1 and TR on Stage 2 in Rel-11 Feature OSCAR UID_490032 / WI rapporteur e-mail: Martin Dolly (md3135@att.com)
- 1588: CP#57 completed / WI rapporteur e-mail: Martin Dolly (md3135@att.com)
- 1589: CP#60 completed / WI rapporteur e-mail: Martin Dolly (md3135@att.com)
- 1590: CP#57 completed / WI rapporteur e-mail: Martin Dolly (md3135@att.com)
- 1591: CP#60 completed
- 1592: CP#57 completed / WI rapporteur e-mail: Martin Dolly (md3135@att.com)

| ID | WBS | Task | Duration | Start | Finish | Complete | Baseline start | Baseline finish | Baseline duration | Constraint | Resources | Work | Actual work | Acronym | PCG approved | WI rapporteur name | WI rapporteur e-mail | Release | TSG approved | MCC resp | Acronym_3GU_Export | Special Focus Doc | PCG stopped | TSG stopped |
| --- | --- | --- | --- | --- | --- | --- | --- | --- | --- | --- | --- | --- | --- | --- | --- | --- | --- | --- | --- | --- | --- | --- | --- | --- |
| 1593 | 373 | **Non Voice Emergency Services** | 323d? | 2010-12-16 A | 2012-03-07 A | 100% | 2010-12-16 | 2012-03-07 | 323d? |  | S1; S2 | 7736h | 7736h | NOVES | PCG-26 | Qualcomm | dwilliams@qualcomm.com | Rel-11 | SP-50 | Alain | NOVES |  |  |  |
| 1594 | 373.1 | Stage 1 for Non Voice Emergency Services | 202d? | 2010-12-16 A | 2011-09-21 A | 100% | 2010-12-16 | 2011-09-21 | 202d? | finish no earlier than 2011-09-21 | S1 | 1600h | 1600h | NOVES | PCG-26 | Qualcomm | dwilliams@qualcomm.com | Rel-11 | SP-50 | Alain |  |  |  |  |
| 1595 | 373.2 | Stage 2 for Non Voice Emergency Services (Support of IMS Emergency Sessions with Other Media on UTRAN and E-UTRAN) | 121d? | 2011-09-22 A | 2012-03-07 A | 100% | 2011-09-22 | 2012-03-07 | 121d? | finish no earlier than 2012-03-07 | S2 | 968h | 968h | NOVES-IMSESOM | PCG-27 | Alcatel-Lucent | Deb.Barclay@alcatel-lucent.com | Rel-11 | SP-53 | Maurice | NOVES-IMSESOM |  |  |  |
| 1596 | 374 | **Support for 3GPP Voice Interworking with Enterprise IP-PBX** | 516d? | 2011-03-23 A | 2013-03-01 A | 100% | 2011-03-23 | 2013-03-01 | 516d? |  | S1; C1 | 12376h | 12376h | VINE | PCG-26 | Tatara Systems | Phillip Brown (pbrown@tatarasystems.com) | Rel-11 | SP-51 | Alain | VINE |  |  |  |
| 1597 | 374.1 | Stage 1 for Support for 3GPP Voice Interworking with Enterprise IP-PBX | 133d? | 2011-03-23 A | 2011-09-21 A | 100% | 2011-03-23 | 2011-09-21 | 133d? | finish no earlier than 2011-09-21 | S1 | 1048h | 1048h | VINE | PCG-26 | Tatara Systems | Phillip Brown (pbrown@tatarasystems.com) | Rel-11 | SP-51 | Alain |  |  |  |  |
| 1598 | 374.2 | Stage 2/3 for Support for 3GPP Voice Interworking with Enterprise IP-PBX | 385d? | 2011-09-20 A | 2013-03-01 A | 100% | 2011-09-20 | 2013-03-01 | 385d? | finish no earlier than 2013-03-01 | C1 | 3072h | 3072h | VINE-CT1 | PCG-27 | Alcatel-Lucent | keith.drage@alcatel-lucent.com | Rel-11 | CP-53 | Frederic | VINE-CT1 |  |  |  |
| 1599 | 375 | **Anonymous Call Rejection in the CS domain** | 132d? | 2011-06-07 A | 2011-12-02 A | 100% | 2011-06-07 | 2011-12-02 | 132d? |  | S1; C4; C3 | 4616h | 4616h | ACR_CS | PCG-27 | Alcatel-Lucent | Betsy.Covell@alcatel-lucent.com | Rel-11 | SP-52 | Alain | ACR_CS |  |  |  |
| 1600 | 375.1 | Stage 1 for Anonymous Call Rejection in the CS domain | 2d? | 2011-06-07 A | 2011-06-08 A | 100% | 2011-06-07 | 2011-06-08 | 2d? | finish no earlier than 2011-06-07 | S1 | 16h | 16h | ACR_CS | PCG-27 | Alcatel-Lucent | Betsy.Covell@alcatel-lucent.com | Rel-11 | SP-52 | Alain |  |  |  |  |
| 1601 | 375.2 | **Core Network aspects of Anonymous Call Rejection in the CS domain** | 59d? | 2011-09-14 A | 2011-12-02 A | 100% | 2011-09-14 | 2011-12-02 | 59d? |  | C4; C3 | 1432h | 1432h | ACR_CS-CN | PCG-27 | Alcatel-Lucent | bruno.landais@alcatel-lucent.com | Rel-11 | CP-53 | Kimmo | ACR_CS-CN |  |  |  |
| 1602 | 375.2.1 | CT4 part of Core Network aspects of Anonymous Call Rejection in the CS domain (Stage 2/3) | 59d? | 2011-09-14 A | 2011-12-02 A | 100% | 2011-09-14 | 2011-12-02 | 59d? | finish no earlier than 2011-12-02 | C4 | 464h | 464h | ACR_CS-CN | PCG-27 | Alcatel-Lucent | bruno.landais@alcatel-lucent.com | Rel-11 | CP-53 | Kimmo |  |  |  |  |
| 1603 | 375.2.2 | CT3 part of Core Network aspects of Anonymous Call Rejection in the CS domain (Stage 3) | 3d? | 2011-09-14 A | 2011-09-16 A | 100% | 2011-09-14 | 2011-09-16 | 3d? | start no earlier than 2011-09-14 | C3 | 24h | 24h | ACR_CS-CN | PCG-27 | Alcatel-Lucent | bruno.landais@alcatel-lucent.com | Rel-11 | CP-53 | Adrian |  |  |  |  |
| 1604 | 376 | **Support for BroadBand Forum Accesses Interworking** | 792d? | 2009-12-10 A | 2012-12-12 A | 100% | 2009-12-10 | 2012-12-12 | 792d? |  | S2; S1; C1; C3; C4; IETF | 97983.8h | 97983.8h | BBAI | PCG-24 | Ericsson | peter.bleckert@ericsson.com | Rel-11 | SP-46 | Alain | BBAI | HNB, WLAN |  |  |
| 1605 | 376.1 | Stage 1 BB I: BBF interworking with home routed traffic for WLAN and H(e)NB | 76d? | 2009-12-10 A | 2010-03-25 A | 100% | 2009-12-10 | 2010-03-25 | 76d? | start no earlier than 2009-12-10 | S1 | 608h | 608h | BBAI | PCG-24 | Ericsson | Olle.Eriksson@ericsson.com | Rel-11 | SP-46 | Alain |  | HNB, WLAN |  |  |
| 1606 | 376.2 | TR on Stage 2 for BBAI | 588d? | 2010-03-26 A | 2012-06-20 A | 100% | 2010-03-26 | 2012-06-20 | 588d? | finish no earlier than 2012-06-19 | S2 | 4704h | 4704h | BBAI | PCG-24 | Ericsson | marco.spini@huawei.com | Rel-11 | SP-47 | Maurice |  | HNB, WLAN |  |  |
| 1607 | 376.3 | Stage 2 BB I: BBF interworking with home routed traffic for WLAN and H(e)NB | 588d? | 2010-03-26 A | 2012-06-20 A | 100% | 2010-03-26 | 2012-06-20 | 588d? | finish no earlier than 2012-06-20 | S2 | 4688.06h | 4688.06h | BBAI | PCG-24 | Ericsson | stefan.rommer@ericsson.com | Rel-11 | SP-47 | Maurice |  | HNB, WLAN |  |  |
| 1608 | 376.4 | (IETF) Stage 2 BB I: BBF interworking with home routed traffic for WLAN and H(e)NB | 266d? | 2011-12-12 A | 2012-12-12 A | 100% | 2011-12-12 | 2012-12-12 | 266d? | finish no earlier than 2012-11-24 | S2-IETF | 2119.59h | 2119.59h | BBAI | PCG-28 | Lionel Morand | Lionel Morand | Rel-11 | SP-54 | Maurice |  | HNB, WLAN |  |  |
| 1609 | 376.5 | **Stage 3 BB I - Core Network impacts: BBF interworking with home routed traffic for WLAN and H(e)NB** | 326d? | 2011-09-16 A | 2012-12-07 A | 100% | 2011-09-16 | 2012-12-07 | 326d? |  | C1; C3; C4 | 17288.2h | 17288.2h | BBAI_BBI-CT | PCG-27 | Ericsson | Zu.Qiang@Ericsson.com | Rel-11 | CP-53 | Frederic | BBAI_BBI-CT | HNB, WLAN |  |  |
| 1610 | 376.5.1 | TR on Stage 3 BB I for BBAI; UE to network protocols | 198d? | 2011-09-16 A | 2012-06-15 A | 100% | 2011-09-16 | 2012-06-15 | 198d? | finish no earlier than 2012-06-15 | C1 | 1568.15h | 1568.15h | BBAI_BBI-CT | PCG-27 | Ericsson | Zu.Qiang@Ericsson.com | Rel-11 | CP-53 | Frederic |  | HNB, WLAN |  |  |
| 1611 | 376.5.2 | TR on Stage 3 BB I for BBAI; Home (e)Node B – Security Gateway Interface | 77d? | 2012-03-02 A | 2012-06-15 A | 100% | 2012-03-02 | 2012-06-15 | 77d? | finish no earlier than 2012-06-01 | C4 | 608h | 608h | BBAI_BBI-CT | PCG-28 | Ericsson | Zu.Qiang@Ericsson.com | Rel-11 | CP-55 | Kimmo |  | HNB, WLAN |  |  |
| 1612 | 376.5.3 | Deleted - (IETF) on Stage 3 BB I for BBAI; Home (e)Node B – Security Gateway Interface | 77d? | 2012-03-02 A | 2012-06-15 A | 100% | 2012-03-02 | 2012-06-15 | 77d? | finish no earlier than 2012-06-15 | C4-IETF | 616h | 616h | BBAI_BBI-CT | PCG-28 | Lionel Morand |  | Rel-11 | CP-55 | Kimmo |  | HNB, WLAN | PCG-29 | CP-56 |
| 1613 | 376.5.4 | CT1 part of Stage 3 BB I: BBF interworking with home routed traffic for WLAN and H(e)NB | 258d? | 2011-09-16 A | 2012-09-07 A | 100% | 2011-09-16 | 2012-09-07 | 258d? | finish no earlier than 2012-09-07 | C1 | 2048h | 2048h | BBAI_BBI-CT | PCG-27 | Ericsson | Zu.Qiang@Ericsson.com | Rel-11 | CP-53 | Frederic |  | HNB, WLAN |  |  |
| 1614 | 376.5.5 | CT3 part of Stage 3 BB I: BBF interworking with home routed traffic for WLAN and H(e)NB | 259d? | 2011-09-16 A | 2012-09-07 A | 100% | 2011-09-16 | 2012-09-07 | 259d? | finish no earlier than 2012-09-07 | C3 | 2048h | 2048h | BBAI_BBI-CT | PCG-27 | Ericsson | Zu.Qiang@Ericsson.com | Rel-11 | CP-53 | Adrian |  | HNB, WLAN |  |  |
| 1615 | 376.5.6 | CT4 part of Stage 3 BB I: BBF interworking with home routed traffic for WLAN and H(e)NB | 326d? | 2011-09-16 A | 2012-12-07 A | 100% | 2011-09-16 | 2012-12-07 | 326d? | finish no earlier than 2012-12-07 | C4 | 2576h | 2576h | BBAI_BBI-CT | PCG-27 | Ericsson | Zu.Qiang@Ericsson.com | Rel-11 | CP-53 | Kimmo |  | HNB, WLAN |  |  |
| 1616 | 376.6 | Stage 1 BB II: BBF interworking with offload in access network for WLAN and for H(e)NB | 262d? | 2010-09-23 A | 2011-09-21 A | 100% | 2010-09-23 | 2011-09-21 | 262d? | finish no earlier than 2011-09-21 | S1 | 2080h | 2080h | BBAI_BBII-CTofldS1 | PCG-25 | Ericsson | Olle.Eriksson@ericsson.com | Rel-11 | SP-49 | Alain |  | HNB, WLAN |  |  |
| 1617 | 376.7 | Stage 2 BB II: BBF interworking with offload in access network for WLAN and for H(e)NB | 455d? | 2010-09-28 A | 2012-06-20 A | 100% | 2010-09-28 | 2012-06-20 | 455d? | finish no earlier than 2012-06-20 | S2 | 3640h | 3640h | BBAI_BBII-CTofldS2 | PCG-24 | Ericsson | stefan.rommer@ericsson.com | Rel-11 | SP-47 | Maurice |  | HNB, WLAN |  |  |

Notes:
- 1593: SP#55 Stage 2 completed. Triggered by SA1 Rel-11 TR 22.871 Study on Non Voice Emergency Services (FS_NOVES)
- 1594: SP#53 completed / Impacted TSs and TRs: 22.101
- 1595: SP#55 completed / Impacted TSs and TRs: 23.060, 23.167, 23.203, 23.401
- 1596: SP#53 Stage 1 completed. CP#59 completed. Triggered by Rel-11 TR 22.809 Study on Support for 3GPP Voice Interworking with Enterprise IP-PBX (FS_VINE) UID_480033
- 1597: SP#53 completed / Impacted TSs and TRs: 22.228
- 1598: CP#59 completed / Impacted TSs and TRs: 23.218, 24.229
- 1599: CP#54 completed
- 1600: SP#52 completed under TEI11. Approved WID and CRs in SP-110376 (22.082 CR#0005, 22.085 CR#0004, 22.081 CR#0007, 22.088 CR#0003, 22.004 CR#0013) / Impacted TSs and TRs: 22.004, 22.081, 22.082, 22.085, 22.088
- 1601: CP#54 completed / Impacted TSs and TRs: Stage 2/3
- 1602: CP#54 completed / Impacted TSs and TRs: 23.018, 23.081, 23.082, 23.085, 23.088, 23.205, 23.231, 24.088, 29.002, 29.011
- 1603: CP#53 completed / Impacted TSs and TRs: 29.163, 29.292
- 1604: SP#57 updated WID SP-120419=>SP-120539 (removed BB3 objectives not implemented in Stage 2). SP#56 completed. Triggered by BBF WT 203, WT-134 (interworking btw 3GPP EPS and BBF's fixed broadband accesses)
- 1605: SP#57 updated WID SP-120419=>SP-120539 (removed BB3 objectives not implemented in Stage 2). SP#47 completed. Provide service requirements for supporting interworking between 3GPP EPS and the fixed broadband accesses defined by BBF / Impacted TSs and TRs: 22.278 CR#0058
- 1606: TR 23.839 not Approved in Rel-11; progressed in Rel-12 under P4C-TI (UID_560824) / Impacted TSs and TRs: new TR 23.839
- 1607: SP#56 completed / Impacted TSs and TRs: 23.203, new 23.139
- 1608: Solved by IANA-registration. No RFC needed
- 1609: CP#58 completed / Impacted TSs and TRs: Stage 3
- 1610: CP#56 completed. Identify additional FMC specific procedures in addition to those in 24.302 (on access authentication & authorization and tunnel management; IP mobility mode selection; security aspects) / Impacted TSs and TRs: new TR 24.820
- 1611: CP#56 completed / Impacted TSs and TRs: new TR 29.839
- 1612: Draft removed from 3GPP documentation / Impacted TSs and TRs: draft-so-ipsecme-ikev2-cpext
- 1613: CP#57 completed / Impacted TSs and TRs: 24.229, new TS 24.139
- 1614: CP#57 completed / Impacted TSs and TRs: 29.212, 29.213, 29.215
- 1615: CP#58 completed / Impacted TSs and TRs: 23.008, 29.273, 29.274, new TS 29.139
- 1616: SP#53 completed. 22/01: acronym modified / Impacted TSs and TRs: 22.278
- 1617: SP#56 completed. 22/01: acronym modified / Impacted TSs and TRs: 23.203, 23.401, 23.402, 23.139

| ID | WBS | Task | Duration | Start | Finish | Complete | Baseline start | Baseline finish | Baseline duration | Constraint | Resources | Work | Actual work | Acronym | PCG approved | Impacted TSs and TRs | WI rapporteur name | WI rapporteur e-mail | Release | TSG approved | MCC resp | Special Focus Doc | Acronym_3GU_Export | PCG stopped | TSG stopped |
| --- | --- | --- | --- | --- | --- | --- | --- | --- | --- | --- | --- | --- | --- | --- | --- | --- | --- | --- | --- | --- | --- | --- | --- | --- | --- |
| 1618 | 376.8 | **Stage 3 BB II - Core Network impacts: BBF interworking with offload in access network for WLAN and for H(e)NB** | 259d? | 2011-09-16 A | 2012-09-07 A | 100% | 2011-09-16 | 2012-09-07 | 259d? |  | C3; C1; C4 | 12888h | 12888h | BBAI_BBII-CT | PCG-27 | Stage 3 | Ericsson | Susana.Fernandez@ericsson.com | Rel-11 | CP-53 | Adrian | HNB, WLAN | BBAI_BBII-CT |  |  |
| 1619 | 376.8.1 | TR on Stage 3 BB II for 3GPP System to Fixed Broadband Access Network Interworking; UE to network protocols | 198d? | 2011-09-16 A | 2012-06-15 A | 100% | 2011-09-16 | 2012-06-15 | 198d? | finish no earlier than 2012-06-15 | C1 | 1576h | 1576h | BBAI_BBII-CT | PCG-27 | 24.820 | Ericsson | Susana.Fernandez@ericsson.com | Rel-11 | CP-53 | Frederic | HNB, WLAN |  |  |  |
| 1620 | 376.8.2 | CT1 part of Stage 3 BB II: BBF interworking with offload in access network for WLAN and for H(e)NB | 259d? | 2011-09-16 A | 2012-09-07 A | 100% | 2011-09-16 | 2012-09-07 | 259d? | finish no earlier than 2012-09-07 | C1 | 2064h | 2064h | BBAI_BBII-CT | PCG-27 | new TS 24.320 | Ericsson | Susana.Fernandez@ericsson.com | Rel-11 | CP-53 | Frederic | HNB, WLAN |  |  |  |
| 1621 | 376.8.3 | CT3 part of Stage 3 BB II: BBF interworking with offload in access network for WLAN and for H(e)NB | 259d? | 2011-09-16 A | 2012-09-07 A | 100% | 2011-09-16 | 2012-09-07 | 259d? | start no earlier than 2011-09-16 | C3 | 2056h | 2056h | BBAI_BBII-CT | PCG-27 | 29.212, 29.213, 29.215 | Ericsson | Susana.Fernandez@ericsson.com | Rel-11 | CP-53 | Adrian | HNB, WLAN |  |  |  |
| 1622 | 376.8.4 | CT4 part of Stage 3 BB II: BBF interworking with offload in access network for WLAN and for H(e)NB | 122d? | 2011-09-16 A | 2012-03-02 A | 100% | 2011-09-16 | 2012-03-02 | 122d? | start no earlier than 2011-09-16 | C4 | 976h | 976h | BBAI_BBII-CT | PCG-27 | 23.008, 29.273 | Ericsson | Susana.Fernandez@ericsson.com | Rel-11 | CP-53 | Kimmo | HNB, WLAN |  |  |  |
| 1623 | 376.9 | Deleted - Stage 1 BB III: BBF convergence and network based mobility | 262d? | 2010-09-23 A | 2011-09-21 A | 100% | 2010-09-23 | 2011-09-21 | 262d? | finish no earlier than 2011-09-21 | S1 | 2080h | 2080h |  | PCG-25 | 22.278 | Huawei | Amar Deol (adeol@huawei.com) | Rel-11 | SP-49 | Alain | HNB, WLAN |  | PCG-29 | SP-57 |
| 1624 | 376.10 | Deleted - Stage 2 BB III: BBF convergence and network based mobility | 380d? | 2010-09-28 A | 2012-03-07 A | 100% | 2010-09-28 | 2012-03-07 | 380d? | finish no earlier than 2012-03-07 | S2 | 3040h | 3040h |  | PCG-24 | 23.203, 23.401, 23.402, 23.139 | Huawei | marco.spini@huawei.com | Rel-11 | SP-47 | Maurice | HNB, WLAN |  | PCG-28 | SP-55 |
| 1625 | 376.11 | **Deleted - Stage 3 BB III - Core Network impacts: BBF convergence and network based mobility** | 122d? | 2011-09-16 A | 2012-03-02 A | 100% | 2011-09-16 | 2012-03-02 | 122d? |  | C3; C1; C4 | 6832h | 6832h |  | PCG-27 | Stage 3 | Huawei | qiaoweihua@huawei.com | Rel-11 | CP-53 | Adrian | HNB, WLAN | BBAI_BBIII-CT | PCG-28 | CP-55 |
| 1626 | 376.11.1 | Deleted - TR on Stage 3 BB III for 3GPP System to Fixed Broadband Access Network Interworking; UE to network protocols | 122d? | 2011-09-16 A | 2012-03-02 A | 100% | 2011-09-16 | 2012-03-02 | 122d? | start no earlier than 2011-09-16 | C1 | 976h | 976h |  | PCG-27 | new TR 24.820 | Huawei | qiaoweihua@huawei.com | Rel-11 | CP-53 | Frederic | HNB, WLAN |  | PCG-28 | CP-55 |
| 1627 | 376.11.2 | Deleted - CT1 part of Stage 3 BB III: BBF convergence and network based mobility | 122d? | 2011-09-16 A | 2012-03-02 A | 100% | 2011-09-16 | 2012-03-02 | 122d? | start no earlier than 2011-09-16 | C1 | 976h | 976h |  | PCG-27 | TBD | Huawei | qiaoweihua@huawei.com | Rel-11 | CP-53 | Frederic | HNB, WLAN |  | PCG-28 | CP-55 |
| 1628 | 376.11.3 | Deleted - CT3 part of Stage 3 BB III: BBF convergence and network based mobility | 122d? | 2011-09-16 A | 2012-03-02 A | 100% | 2011-09-16 | 2012-03-02 | 122d? | start no earlier than 2011-09-16 | C3 | 976h | 976h |  | PCG-27 | 29.212, 29.213, 29.215 | Huawei | qiaoweihua@huawei.com | Rel-11 | CP-53 | Adrian | HNB, WLAN |  | PCG-28 | CP-55 |
| 1629 | 376.11.4 | Deleted - CT4 part of Stage 3 BB III: BBF convergence and network based mobility | 122d? | 2011-09-16 A | 2012-03-02 A | 100% | 2011-09-16 | 2012-03-02 | 122d? | start no earlier than 2011-09-16 | C4 | 976h | 976h |  | PCG-27 | 23.008, 29.273 | Huawei | qiaoweihua@huawei.com | Rel-11 | CP-53 | Kimmo | HNB, WLAN |  | PCG-28 | CP-55 |
| 1630 | 377 | **Single Radio Voice Call Continuity (SRVCC) aspect of enhancements for Multimedia Priority Service** | 398d? | 2010-06-10 A | 2011-12-14 A | 100% | 2010-06-10 | 2011-12-14 | 398d? |  | S2 | 8432h | 8432h | eMPS_SRVCC | PCG-25 | Stage 2 | NTT DoCoMo | Atsushi Minokuchi (minokuchi@nttdocomo.co.jp) | Rel-11 | SP-48 | Maurice | Public Safety (I-A) | eMPS_SRVCC |  |  |
| 1631 | 377.1 | TR on SRVCC for eMPS | 260d? | 2010-06-10 A | 2011-06-08 A | 100% | 2010-06-10 | 2011-06-08 | 260d? | finish no earlier than 2011-06-08 | S2 | 2080h | 2080h | eMPS_SRVCC | PCG-25 | new TR 23.854 | NTT DoCoMo | Atsushi Minokuchi (minokuchi@nttdocomo.co.jp) | Rel-11 | SP-48 | Maurice | Public Safety (I-A) |  |  |  |
| 1632 | 377.2 | Stage 2 on SRVCC for eMPS | 398d? | 2010-06-10 A | 2011-12-14 A | 100% | 2010-06-10 | 2011-12-14 | 398d? | finish no earlier than 2011-12-14 | S2 | 3168h | 3168h | eMPS_SRVCC | PCG-25 | 23.216, 23.237 | NTT DoCoMo | Atsushi Minokuchi (minokuchi@nttdocomo.co.jp) | Rel-11 | SP-48 | Maurice | Public Safety (I-A) |  |  |  |
| 1633 | 378 | **Single Radio Video Call Continuity for 3G-CS** | 440d? | 2010-10-15 A | 2012-06-15 A | 100% | 2010-10-15 | 2012-06-15 | 440d? |  | S2; C1; C3; C4 | 26572.4h | 26572.4h | vSRVCC | PCG-26 |  | Samsung | xiaowan.ke@samsung.com | Rel-11 | SP-50 | Maurice |  | vSRVCC |  |  |
| 1634 | 378.1 | Stage 2 for Single Radio Video Call Continuity for 3G-CS | 199.85d? | 2010-10-15 A | 2011-09-21 A | 100% | 2010-10-15 | 2011-09-21 | 199.85d? | finish no earlier than 2011-12-07 | S2 | 1580.41h | 1580.41h | vSRVCC | PCG-26 | 23.203, 23.216, 23.237 | Samsung | xiaowan.ke@samsung.com | Rel-11 | SP-50 | Maurice |  |  |  |  |
| 1635 | 378.2 | **CN aspects of Single Radio Video Call Continuity for 3G-CS** | 275d? | 2011-06-03 A | 2012-06-15 A | 100% | 2011-06-03 | 2012-06-15 | 275d? |  | C1; C3; C4 | 10912h | 10912h | vSRVCC-CT | PCG-27 |  | NEC | gottfried.punz@neclab.eu | Rel-11 | CP-52 | Frederic |  | vSRVCC-CT |  |  |
| 1636 | 378.2.1 | CT1 aspects of Single Radio Video Call Continuity for 3G-CS | 275d? | 2011-06-03 A | 2012-06-15 A | 100% | 2011-06-03 | 2012-06-15 | 275d? | finish no earlier than 2012-06-15 | C1 | 2184h | 2184h | vSRVCC-CT | PCG-27 | 24.008, 24.237, 24.301 | NEC | gottfried.punz@neclab.eu | Rel-11 | CP-52 | Frederic |  |  |  |  |
| 1637 | 378.2.2 | CT3 aspects of Single Radio Video Call Continuity for 3G-CS | 134d? | 2011-06-03 A | 2011-12-02 A | 100% | 2011-06-03 | 2011-12-02 | 134d? | finish no earlier than 2011-12-02 | C3 | 1064h | 1064h | vSRVCC-CT | PCG-27 | 29.211, 29.212, 29.213, 29.215 | NEC | gottfried.punz@neclab.eu | Rel-11 | CP-52 | Adrian |  |  |  |  |
| 1638 | 378.2.3 | CT4 aspects of Single Radio Video Call Continuity for 3G-CS | 134d? | 2011-06-03 A | 2011-12-02 A | 100% | 2011-06-03 | 2011-12-02 | 134d? | finish no earlier than 2011-12-02 | C4 | 1064h | 1064h | vSRVCC-CT | PCG-27 | 29.280 | NEC | gottfried.punz@neclab.eu | Rel-11 | CP-52 | Kimmo |  |  |  |  |
| 1639 | 379 | **Network-provided Location information for IMS (NETLOC)** | 720d? | 2010-06-10 A | 2013-03-01 A | 100% | 2010-06-10 | 2013-03-01 | 720d? |  | S2; S1; S5; C3; C4; C1 | 57274.7h | 57274.7h | NWK-PL2IMS | PCG-25 |  | T-Mobile | michele.zarri@t-mobile.co.uk | Rel-11 | SP-48 | Maurice |  | NWK-PL2IMS |  |  |
| 1640 | 379.1 | Stage 1 for Network-provided Location information for IMS | 203d? | 2010-12-15 A | 2011-09-21 A | 100% | 2010-12-15 | 2011-09-21 | 203d? | finish no earlier than 2011-09-21 | S1 | 1608h | 1608h | NWK-PL2IMS | PCG-26 | 22.115 | n/a | n/a | Rel-11 | SP-50 | Alain |  |  |  |  |
| 1641 | 379.2 | TR on Stage 2 for Network-provided Location information for IMS | 395d? | 2010-06-10 A | 2011-12-14 A | 100% | 2010-06-10 | 2011-12-14 | 395d? | finish no earlier than 2011-12-06 | S2 | 3160h | 3160h | NWK-PL2IMS | PCG-25 | new TR 23.842 | T-Mobile | michele.zarri@t-mobile.co.uk | Rel-11 | SP-48 | Maurice |  |  |  |  |
| 1642 | 379.3 | Stage 2 for Network-provided Location information for IMS | 455d? | 2010-06-15 A | 2012-03-07 A | 100% | 2010-06-15 | 2012-03-07 | 455d? | finish no earlier than 2012-03-07 | S2 | 3640h | 3640h | NWK-PL2IMS | PCG-25 | 23.060, 23.203, 23.228, 23.401 | T-Mobile | michele.zarri@t-mobile.co.uk | Rel-11 | SP-48 | Maurice |  |  |  |  |
| 1643 | 379.4 | Charging for Network-provided Location information for IMS | 515d? | 2010-09-23 A | 2012-09-12 A | 100% | 2010-09-23 | 2012-09-12 | 515d? | finish no earlier than 2012-09-12 | S5 | 4120h | 4120h | NWK-PL2IMS_CH | PCG-25 | Stage 2 (32.240, 32.260), Stage 3 (32.298, 32.299) | Nokia Siemens Networks | Gerald.Goermer@nsn.com | Rel-11 | SP-49 | Mirko |  | NWK-PL2IMS_CH |  |  |

Notes:
- 1618: CP#57 completed
- 1619: CP#56 completed
- 1620: CP#57 completed
- 1621: CP#57 completed
- 1622: CP#55 completed
- 1623: SP#57 stopped. Updated WID SP-120419=>SP-120539 (removed BB3 objectives not implemented in Stage 2). SP#53 completed
- 1624: SP#57 updated WID SP-120419=>SP-120539 (removed BB3 objectives not implemented in Stage 2). SP#55 stopped
- 1625: CP#55 stopped
- 1626: CP#55 stopped
- 1627: CP#55 stopped
- 1628: CP#55 stopped
- 1629: CP#55 stopped
- 1630: SP#54 completed. Analyze and if needed specify mechanisms for the priority handling of SRVCC with regard to LTE/EPC
- 1631: SP#52 completed
- 1632: SP#54 completed
- 1633: CP#56 completed. Provide Single Radio VIDEO Call Continuity from E-UTRAN to UTRAN-CS based on the agreed architecture alternative in TR 23.886
- 1634: SP#53 completed. Triggered by Feasibility Study on video call handover capability in TR 23.886 UID_470048 Study on Single Radio Video Call Continuity for 3G-CS (FS_vSRVCC)
- 1635: Stage 3. CP#56 completed
- 1636: CP#56 completed
- 1637: CP#54 completed
- 1638: CP#54 completed
- 1639: Covers the case where UE is served by a 3GPP RAN. Architecture making Cell/PLMN ID (UE is camped on) available to IMS nodes when the operator needs to record this information either to fulfil legal obligations or for charging.
- 1640: SP#53 completed
- 1641: SP#54 completed
- 1642: SP#55 completed
- 1643: SP#57 completed

| ID | WBS | Task | Type | Duration | Start | Finish | Complete | Remaining | Baseline start | Baseline finish | Baseline duration | Total slack | Constraint | Resources | Work | Actual work | Acronym | PCG approved | WI rapporteur name | WI rapporteur e-mail | Release | TSG approved | MCC resp | Acronym_3GU_Export | Special Focus Doc | PCG stopped | TSG stopped |
| --- | --- | --- | --- | --- | --- | --- | --- | --- | --- | --- | --- | --- | --- | --- | --- | --- | --- | --- | --- | --- | --- | --- | --- | --- | --- | --- | --- |
| 1644 | 379.5 | **CT aspects of Network-provided Location information for IMS (Stage 3)** |  | 266d? | 2012-03-02 A | 2013-03-01 A | 100% |  | 2012-03-02 | 2013-03-01 | 266d? |  |  | C3; C4; C1 | 10186.7h | 10186.7h | NWK-PL2IMS-CT | PCG-28 | Huawei | Qiao Weihua (qiaoweihua@huawei.com) | Rel-11 | CP-55 | Adrian | NWK-PL2IMS_CT |  |  |  |
| 1645 | 379.5.1 | CT3 part of CT aspects of Network-provided Location information for IMS |  | 138d? | 2012-03-02 A | 2012-09-07 A | 100% |  | 2012-03-02 | 2012-09-07 | 138d? |  | finish no earlier than 2012-09-07 | C3 | 1088h | 1088h | NWK-PL2IMS-CT | PCG-28 | Huawei | Qiao Weihua (qiaoweihua@huawei.com) | Rel-11 | CP-55 | Adrian |  |  |  |  |
| 1646 | 379.5.2 | CT4 part of CT aspects of Network-provided Location information for IMS |  | 77d? | 2012-03-02 A | 2012-06-15 A | 100% |  | 2012-03-02 | 2012-06-15 | 77d? |  | finish no earlier than 2012-06-01 | C4 | 608h | 608h | NWK-PL2IMS-CT | PCG-28 | Huawei | Qiao Weihua (qiaoweihua@huawei.com) | Rel-11 | CP-55 | Kimmo |  |  |  |  |
| 1647 | 379.5.3 | CT1 part of CT aspects of Network-provided Location information for IMS |  | 266d? | 2012-03-02 A | 2013-03-01 A | 100% |  | 2012-03-02 | 2013-03-01 | 266d? |  | finish no earlier than 2013-06-14 | C1 | 2106.67h | 2106.67h | NWK-PL2IMS-CT | PCG-28 | Huawei | Qiao Weihua (qiaoweihua@huawei.com) | Rel-11 | CP-55 | Frederic |  |  |  |  |
| 1648 | 380 | **Service Awareness and Privacy Policies** |  | 301.15d? | 2010-10-12 A | 2011-12-02 A | 100% |  | 2010-10-12 | 2011-12-02 | 301.15d? |  |  | S2; S1; C3 | 10667.6h | 10667.6h | SAPP | PCG-26 | Allot | Alla Goldner (agoldner@allot.com) | Rel-11 | SP-50 | Maurice | SAPP |  |  |  |
| 1649 | 380.1 | Stage 1 for Service Awareness and Privacy Policies |  | 46.15d? | 2010-10-12 A | 2010-12-15 A | 100% |  | 2010-10-12 | 2010-12-15 | 46.15d? |  | finish no earlier than 2010-12-15 | S1 | 369.2h | 369.2h | SAPP | PCG-26 | Allot | Alla Goldner (agoldner@allot.com) | Rel-11 | SP-50 | Maurice |  |  |  |  |
| 1650 | 380.2 | Stage 2 for Service Awareness and Privacy Policies |  | 199.85d? | 2010-10-15 A | 2011-09-21 A | 100% |  | 2010-10-15 | 2011-09-21 | 199.85d? |  | finish no earlier than 2011-09-21 | S2 | 1582.8h | 1582.8h | SAPP | PCG-26 | Allot | Alla Goldner (agoldner@allot.com) | Rel-11 | SP-50 | Maurice |  |  |  |  |
| 1651 | 380.3 | CT3 part of Service Awareness and Privacy Policies |  | 187d? | 2011-03-18 A | 2011-12-02 A | 100% |  | 2011-03-18 | 2011-12-02 | 187d? |  | finish no earlier than 2011-12-02 | C3 | 1488h | 1488h | SAPP-CT3 | PCG-26 | Allot | Alla Goldner (agoldner@allot.com) | Rel-11 | CP-51 | Adrian | SAPP-CT3 |  |  |  |
| 1652 | 381 | **VPLMN Autonomous CSG Roaming** |  | 307d? | 2010-10-15 A | 2011-12-14 A | 100% |  | 2010-10-15 | 2011-12-14 | 307d? |  |  | S2; C4 | 6974.61h | 6974.61h | VCSG | PCG-26 | Qualcomm | AC Mahendran (ac@qualcomm.com) | Rel-11 | SP-50 | Maurice | VCSG |  |  |  |
| 1653 | 381.1 | Stage 2 for VPLMN Autonomous CSG Roaming |  | 260.85d? | 2010-10-15 A | 2011-12-14 A | 100% |  | 2010-10-15 | 2011-12-14 | 260.85d? |  | finish no earlier than 2011-12-07 | S2 | 2062.61h | 2062.61h | VCSG | PCG-26 | Qualcomm | AC Mahendran (ac@qualcomm.com) | Rel-11 | SP-50 | Maurice |  |  |  |  |
| 1654 | 381.2 | CT aspects of VPLMN Autonomous CSG Roaming | milestone | 0d? | 2011-12-07 A | 2011-12-07 A | 100% |  | 2011-12-07 | 2011-12-07 | 0d? |  | finish no earlier than 2012-09-07 | C4 |  |  | VCSG-St3 | PCG-27 | ZTE | Fei Lu (lu.fei1@zte.com.cn) | Rel-11 | CP-53 | Kimmo | VCSG-St3 |  |  |  |
| 1655 | 382 | **Data Identification in Access Network Discovery and Selection Function (ANDSF)** |  | 455d? | 2011-03-23 A | 2012-12-07 A | 100% |  | 2011-03-23 | 2012-12-07 | 455d? |  |  | S2; C1 | 12488h | 12488h | DIDA | PCG-26 | Qualcomm | Gerardo Giaretta (gerardo@qualcomm.com) | Rel-11 | SP-51 | Maurice | DIDA |  |  |  |
| 1656 | 382.1 | TR on Stage 2 for Data Identification in ANDSF |  | 193d? | 2011-03-23 A | 2011-12-14 A | 100% |  | 2011-03-23 | 2011-12-14 | 193d? |  | finish no earlier than 2011-12-07 | S2 | 1544h | 1544h | DIDA | PCG-26 | Qualcomm | Gerardo Giaretta (gerardo@qualcomm.com) | Rel-11 | SP-51 | Maurice |  |  |  |  |
| 1657 | 382.2 | Stage 2 for Data Identification in ANDSF |  | 253d? | 2011-03-24 A | 2012-03-07 A | 100% |  | 2011-03-24 | 2012-03-07 | 253d? |  | finish no earlier than 2012-03-07 | S2 | 2024h | 2024h | DIDA | PCG-26 | Qualcomm | Gerardo Giaretta (gerardo@qualcomm.com) | Rel-11 | SP-51 | Maurice |  |  |  |  |
| 1658 | 382.3 | CT aspects of Data Identification in Access Network Discovery and Selection Function (ANDSF) Stage 3 |  | 205d? | 2012-03-02 A | 2012-12-07 A | 100% |  | 2012-03-02 | 2012-12-07 | 205d? |  | finish no earlier than 2012-12-07 | C1 | 1640h | 1640h | DIDA-CT | PCG-28 | Qualcomm | Patrick Stupar (pstupar@qualcomm.com) | Rel-11 | CP-55 | Frederic | DIDA-CT |  |  |  |
| 1659 | 383 | **LOcation-Based Selection of gaTEways foR WLAN** |  | 327d? | 2011-03-23 A | 2012-06-15 A | 100% |  | 2011-03-23 | 2012-06-15 | 327d? |  |  | S2; C4 | 10170.5h | 10170.5h | LOBSTER | PCG-26 | ZTE | zhu.chunhui@zte.com.cn | Rel-11 | SP-51 | Maurice | LOBSTER | WLAN |  |  |
| 1660 | 383.1 | Stage 2 for LOcation-Based Selection of gaTEways foR WLAN |  | 194d? | 2011-03-23 A | 2011-12-14 A | 100% |  | 2011-03-23 | 2011-12-14 | 194d? |  | finish no earlier than 2011-12-07 | S2 | 1546.52h | 1546.52h | LOBSTER | PCG-26 | ZTE | zhu.chunhui@zte.com.cn | Rel-11 | SP-51 | Maurice |  | WLAN |  |  |
| 1661 | 383.2 | **CT aspects of LOcation-Based Selection of gaTEways foR WLAN** |  | 142d? | 2011-12-02 A | 2012-06-15 A | 100% |  | 2011-12-02 | 2012-06-15 | 142d? |  |  | C4 | 3392h | 3392h | LOBSTER-CT | PCG-28 | ZTE | zhou.xingyue@zte.com.cn | Rel-11 | CP-54 | Kimmo | LOBSTER-CT | WLAN |  |  |
| 1662 | 383.2.1 | CT4 part of CT aspects of LOcation-Based Selection of gaTEways foR WLAN |  | 142d? | 2011-12-02 A | 2012-06-15 A | 100% |  | 2011-12-02 | 2012-06-15 | 142d? |  | finish no earlier than 2012-06-15 | C4 | 1128h | 1128h | LOBSTER-CT | PCG-28 | ZTE | zhou.xingyue@zte.com.cn | Rel-11 | CP-54 | Kimmo |  | WLAN |  |  |
| 1663 | 383.2.2 | Deleted - CT1 part of CT aspects of LOcation-Based Selection of gaTEways foR WLAN |  | 142d? | 2011-12-02 A | 2012-06-15 A | 100% |  | 2011-12-02 | 2012-06-15 | 142d? |  | finish no earlier than 2012-06-15 | C1 | 1128h | 1128h | LOBSTER-CT | PCG-28 | ZTE | zhou.xingyue@zte.com.cn | Rel-11 | CP-54 | Frederic |  | WLAN | PCG-29 | CP-56 |
| 1664 | 384 | **Single Radio Voice Call Continuity from UTRAN/GERAN to E-UTRAN/HSPA** |  | 929d? | 2011-09-12 A | 2015-03-15 | 99% | 0d? | 2011-09-12 | 2014-12-05 | 856d? | 0d |  | S2; C1; C3; C4; G2; R2; R3; R5 | 83776.8h | 54590.5h | rSRVCC | PCG-27 | Orange | antoine.mouquet@orange-ftgroup.com | Rel-11 | SP-53 | Maurice | rSRVCC |  |  |  |
| 1665 | 384.1 | Stage 2 for Single Radio Voice Call Continuity from UTRAN/GERAN to E-UTRAN/HSPA |  | 197d? | 2011-09-22 A | 2012-06-20 A | 100% |  | 2011-09-22 | 2012-06-20 | 197d? |  | finish no earlier than 2012-06-20 | S2 | 1568h | 1568h | rSRVCC | PCG-27 | Orange | antoine.mouquet@orange-ftgroup.com | Rel-11 | SP-53 | Maurice |  |  |  |  |
| 1666 | 384.2 | **CT aspects for Single Radio Voice Call Continuity from UTRAN/GERAN to E-UTRAN/HSPA (Stage 3)** |  | 259d? | 2011-09-16 A | 2012-09-07 A | 100% |  | 2011-09-16 | 2012-09-07 | 259d? |  |  | C1; C3; C4 | 12360h | 12360h | rSRVCC-CT | PCG-27 | Ericsson | ivo.sedlacek@ericsson.com | Rel-11 | CP-53 | Frederic | rSRVCC-CT |  |  |  |
| 1667 | 384.2.1 | CT1 part for Single Radio Voice Call Continuity from UTRAN/GERAN to E-UTRAN/HSPA |  | 258d? | 2011-09-16 A | 2012-09-07 A | 100% |  | 2011-09-16 | 2012-09-07 | 258d? |  | finish no earlier than 2012-09-07 | C1 | 2048h | 2048h | rSRVCC-CT | PCG-27 | Ericsson | ivo.sedlacek@ericsson.com | Rel-11 | CP-53 | Frederic |  |  |  |  |
| 1668 | 384.2.2 | CT3 part for Single Radio Voice Call Continuity from UTRAN/GERAN to E-UTRAN/HSPA |  | 257d? | 2011-09-19 A | 2012-09-07 A | 100% |  | 2011-09-19 | 2012-09-07 | 257d? |  | finish no earlier than 2012-09-07 | C3 | 2048h | 2048h | rSRVCC-CT | PCG-27 | Ericsson | ivo.sedlacek@ericsson.com | Rel-11 | CP-53 | Adrian |  |  |  |  |
| 1669 | 384.2.3 | CT4 part for Single Radio Voice Call Continuity from UTRAN/GERAN to E-UTRAN/HSPA |  | 257d? | 2011-09-19 A | 2012-09-07 A | 100% |  | 2011-09-19 | 2012-09-07 | 257d? |  | finish no earlier than 2012-09-07 | C4 | 2048h | 2048h | rSRVCC-CT | PCG-27 | Ericsson | ivo.sedlacek@ericsson.com | Rel-11 | CP-53 | Kimmo |  |  |  |  |
| 1670 | 384.3 | GERAN aspects of Single Radio Voice Call Continuity from UTRAN/GERAN to E-UTRAN/HSPA (Stage 3) |  | 476.1d? | 2011-09-12 A | 2013-06-28 A | 100% |  | 2011-09-12 | 2013-06-28 | 476.1d? |  | finish no earlier than 2013-11-22 | G2 | 2048h | 2048h | rSRVCC-GERAN | PCG-27 | ZTE | li.jing4@zte.com.cn | Rel-11 | GP-51 | Gert | rSRVCC-GERAN |  |  |  |

Notes:
- 1644: Stage 3. 3/3: Acronym changed from "NWK-PL2IMS_CT"
- 1645: CP#57 completed. 3/3: Acronym changed from "NWK-PL2IMS_CT" / Impacted TSs and TRs: 29.212, 29.214, 29.215
- 1646: CP#57 completed. 3/3: Acronym changed from "NWK-PL2IMS_CT" / Impacted TSs and TRs: 23.008, 29.002, 29.060, 29.230, 29.272, 29.274, 29.305, 29.328, 29.329
- 1647: CP#57 completed. 3/3: Acronym changed from "NWK-PL2IMS_CT" / Impacted TSs and TRs: 24.229, 24.292
- 1648: CP#54 completed. Triggered by the SA1,SA2 Rel-10 TR 23.813 Study on Policy solutions and enhancements (FS_PP) UID_440047
- 1649: For deep packet inspection (i.e. Traffic Detection Functionality) SA1 indicated that no new requirements are needed (see Objective of FS_PP SA1,SA2 Rel-10 Study on Policy solutions and enhancements UID_440047 TR 23.813)
- 1650: SP#53 completed / Impacted TSs and TRs: 23.203
- 1651: CP#54 completed. Stage 3 to support Application Detection and Control Functionality. Update Gx / introduce Sd reference points and procedures. Update S9 reference point in roaming scenarios / Impacted TSs and TRs: 29.212, 29.213, 29.214, 29.215
- 1652: CP#56 completed. Linked to Rel-10 UID_450053 Enhanced Home NodeB / eNodeB (EHNB). Implements Rel-9 requirements for CSG support in SA1 TS 22.220
- 1653: SP#54 completed / Impacted TSs and TRs: 23.002, 23.060, 23.401
- 1654: CP#57 completed / Impacted TSs and TRs: 23.003, 23.007, 23.008, 23.012, 29.002, 29.230, 29.272
- 1655: SP#58 completed. Linked to Rel-10 IFOM (IP Flow Mobility and seamless WLAN offload) UID_450041. Defines IP flow mobility, seamless and non seamless WLAN offload and respective ANDSF extensions / Impacted TSs and TRs: Stage 2/3
- 1656: SP#54 completed / Impacted TSs and TRs: New TR 23.855
- 1657: SP#55 completed / Impacted TSs and TRs: 23.402
- 1658: CP#58 completed / Impacted TSs and TRs: 24.302, 24.312
- 1659: CP#56 completed. Related to UID_350027 SAE for support for non-3GPP accesses (SAES-SA-FP_n3GPP). Enhancements to ePDG and PDN GW selection functions for S2b and S2c based on UE location
- 1660: SP#54 completed / Impacted TSs and TRs: 23.402
- 1661: Stage 3. CP#56 completed / Impacted TSs and TRs: Stage 3
- 1662: CP#56 completed / Impacted TSs and TRs: 29.273
- 1663: CP#56 stopped / Impacted TSs and TRs: 24.302
- 1664: Stage 1 in Rel-8 TS 22.278 clause 7.1.4.2. Triggered by Rel-11 TR 23.885 Study on Single Radio Voice Call Continuity from UTRAN/GERAN to E-UTRAN/HSPA (FS_rSRVCC) UID_460030
- 1665: SP#56 completed / Impacted TSs and TRs: 23.216, 23.237
- 1666: CP#57 completed / Impacted TSs and TRs: Stage 3
- 1667: CP#57 completed / Impacted TSs and TRs: 23.009, 24.008, 24.229, 24.237, 24.292, 24.301
- 1668: CP#57 completed / Impacted TSs and TRs: 29.165, 29.292
- 1669: CP#57 completed / Impacted TSs and TRs: 23.003, 23.008, 29.002, 29.230, 29.272, 29.280, 29.303, 29.305, 29.328
- 1670: GP#60 completed. GP#51 approved WID / Impacted TSs and TRs: 44.018, 48.008

| ID | WBS | Task | Duration | Start | Finish | Complete | Remaining | Baseline start | Baseline finish | Baseline duration | Total slack | Constraint | Resources | Work | Actual work | Acronym | PCG approved | Impacted TSs and TRs | WI rapporteur name | Release | TSG approved | MCC resp | Acronym_3GU_Export | Status Report | Special Focus Doc | PCG stopped | TSG stopped |
| --- | --- | --- | --- | --- | --- | --- | --- | --- | --- | --- | --- | --- | --- | --- | --- | --- | --- | --- | --- | --- | --- | --- | --- | --- | --- | --- | --- |
| 1671 | 384.4 | **UTRAN aspects of Single Radio Voice Call Continuity from UTRAN/GERAN to E-UTRAN/HSPA** | 325d? | 2011-09-19 A | 2012-12-07 A | 100% |  | 2011-09-19 | 2012-12-07 | 325d? |  |  | R3; R2 | 10400h | 10400h | rSRVCC-RAN_UTRA | PCG-27 | UTRA | Huawei | Rel-11 | RP-53 | Juha | rSRVCC-RAN_UTRA |  |  |  |  |
| 1672 | 384.4.1 | Core part: UTRAN aspects of Single Radio Voice Call Continuity from UTRAN/GERAN to E-UTRAN/HSPA | 325d? | 2011-09-19 A | 2012-12-07 A | 100% |  | 2011-09-19 | 2012-12-07 | 325d? |  | finish no earlier than 2012-12-07 | R3; R2 | 5200h | 5200h | rSRVCC-RAN_UTRA-Core | PCG-27 | 25.331, 25.401, 25.413 | Huawei | Rel-11 | RP-53 | Juha | rSRVCC-RAN_UTRA-Core | RP-121553 |  |  |  |
| 1673 | 384.5 | Test part: Single Radio Voice Call Continuity from UTRAN/GERAN to E-UTRAN/HSPA | 196d? | 2014-06-15 A | 2015-03-15 A | 100% |  | 2014-06-13 | 2014-12-05 | 126d? |  | finish no earlier than 2015-03-15 | R5 | 1568h | 1568h | rSRVCC-UEConTest | PCG-33 | 36.508, 36.523-1, 36.523-2, 36.523-3 | Ericsson | Rel-11 | RP-64 |  | rSRVCC-UEConTest | RP-150133 |  |  |  |
| 1674 | 385 | **S2a Mobility based On GTP and WLAN access to EPC** | 651d? | 2011-09-22 A | 2014-03-05 A | 100% |  | 2011-09-22 | 2014-03-05 | 651d? |  |  | S2; C4; C1; C3; IETF | 54000h | 54000h | SaMOG_WLAN | PCG-27 | Stage 2/3 | ZTE | Rel-11 | SP-53 | Maurice | SaMOG_WLAN |  | WLAN |  |  |
| 1675 | 385.1 | Stage 2 for S2a Mobility based On GTP and WLAN access to EPC | 121d? | 2011-09-22 A | 2012-03-07 A | 100% |  | 2011-09-22 | 2012-03-07 | 121d? |  | finish no earlier than 2012-03-07 | S2 | 968h | 968h | SaMOG_WLAN | PCG-27 | 23.002, 23.203, 23.402 | ZTE | Rel-11 | SP-53 | Maurice |  |  | WLAN |  |  |
| 1676 | 385.2 | **CN aspects of Mobility based On GTP & PMIPv6 for WLAN access to EPC** | 599d? | 2011-12-02 A | 2014-03-05 A | 100% |  | 2011-12-02 | 2014-03-05 | 599d? |  |  | C4; C1; C3; IETF | 26992h | 26992h | SaMOG_WLAN-CN | PCG-28 | Stage 3 | Alcatel-Lucent | Rel-11 | CP-54 | Kimmo | SaMOG_WLAN-CN |  | WLAN |  |  |
| 1677 | 385.2.1 | CT4 part of CN aspects of Mobility based On GTP & PMIPv6 for WLAN access to EPC | 203d? | 2011-12-02 A | 2012-09-07 A | 100% |  | 2011-12-02 | 2012-09-07 | 203d? |  | finish no earlier than 2012-09-07 | C4 | 1608h | 1608h | SaMOG_WLAN-CN | PCG-28 | 23.003, 23.007, 23.008, 29.273, 29.274, 29.281, 29.303 | Alcatel-Lucent | Rel-11 | CP-54 | Kimmo |  |  | WLAN |  |  |
| 1678 | 385.2.2 | Deleted - (IETF) CT4 part of CN aspects of Mobility based On GTP & PMIPv6 for WLAN access to EPC | 498d? | 2012-04-23 A | 2014-03-05 A | 100% |  | 2012-04-23 | 2014-03-05 | 498d? |  | finish no earlier than 2014-03-05 | C4-IETF | 3960h | 3960h | SaMOG_WLAN-CN | PCG-29 | draft-ietf-radext-ieee802ext | Lionel Morand | Rel-11 | CP-56 | Kimmo |  |  | WLAN | PCG-32 | CP-53 |
| 1679 | 385.2.3 | Deleted - CT1 part of CN aspects of Mobility based On GTP & PMIPv6 for WLAN access to EPC | 142d? | 2011-12-02 A | 2012-06-15 A | 100% |  | 2011-12-02 | 2012-06-15 | 142d? |  | finish no earlier than 2012-06-15 | C1 | 1128h | 1128h | SaMOG_WLAN-CN | PCG-28 | 24.302 | Alcatel-Lucent | Rel-11 | CP-54 | Frederic |  |  | WLAN | PCG-29 | CP-56 |
| 1680 | 385.2.4 | CT3 part of CN aspects of Mobility based On GTP & PMIPv6 for WLAN access to EPC | 142d? | 2011-12-02 A | 2012-06-15 A | 100% |  | 2011-12-02 | 2012-06-15 | 142d? |  | finish no earlier than 2012-09-07 | C3 | 1128h | 1128h | SaMOG_WLAN-CN | PCG-28 | 29.212, 29.213, 29.215 | Alcatel-Lucent | Rel-11 | CP-54 | Adrian |  |  | WLAN |  |  |
| 1681 | 386 | **Roaming Architecture for Voice over IMS with Local Breakout** | 273d? | 2011-11-28 A | 2012-12-07 A | 100% |  | 2011-11-28 | 2012-12-07 | 273d? |  |  | S2; S5; C1; C3 | 16904h | 16904h | RAVEL | PCG-28 | Stage 2/3 | Deutsche Telekom | Rel-11 | SP-54 | Maurice | RAVEL |  |  |  |  |
| 1682 | 386.1 | Stage 2 for Roaming Architecture for Voice over IMS with Local Breakout | 12d? | 2011-11-28 A | 2011-12-14 A | 100% |  | 2011-11-28 | 2011-12-14 | 12d? |  | finish no earlier than 2012-03-07 | S2 | 96h | 96h | RAVEL | PCG-28 | 23.002, 23.228 | Deutsche Telekom | Rel-11 | SP-54 | Maurice |  |  |  |  |  |
| 1683 | 386.2 | Charging for Roaming Architecture for Voice over IMS with Local Breakout | 196d? | 2011-12-14 A | 2012-09-12 A | 100% |  | 2011-12-14 | 2012-09-12 | 196d? |  | finish no earlier than 2012-09-12 | S5 | 1568h | 1568h | RAVEL-CH | PCG-28 | 32.240, 32.260, 32.298, 32.299 | Nokia Siemens Networks | Rel-11 | SP-54 | Mirko | RAVEL-CH |  |  |  |  |
| 1684 | 386.3 | **CT aspects of Roaming Architecture for Voice over IMS with Local Breakout (Stage 3)** | 205d? | 2012-03-02 A | 2012-12-07 A | 100% |  | 2012-03-02 | 2012-12-07 | 205d? |  |  | C1; C3 | 6504h | 6504h | RAVEL-CT | PCG-28 | Stage 3 | Deutsche Telekom | Rel-11 | CP-55 | Frederic | RAVEL-CT |  |  |  |  |
| 1685 | 386.3.1 | CT1 part of CT aspects of Roaming Architecture for Voice over IMS with Local Breakout | 204d? | 2012-03-02 A | 2012-12-07 A | 100% |  | 2012-03-02 | 2012-12-07 | 204d? |  | finish no earlier than 2012-12-07 | C1 | 1608h | 1608h | RAVEL-CT | PCG-28 | 24.229, 24.292, 24.237 | Deutsche Telekom | Rel-11 | CP-55 | Frederic |  |  |  |  |  |
| 1686 | 386.3.2 | CT3 part of CT aspects of Roaming Architecture for Voice over IMS with Local Breakout | 204d? | 2012-03-02 A | 2012-12-07 A | 100% |  | 2012-03-02 | 2012-12-07 | 204d? |  | finish no earlier than 2012-12-07 | C3 | 1616h | 1616h | RAVEL-CT | PCG-28 | 29.165, 29.162, 29.079 | Deutsche Telekom | Rel-11 | CP-55 | Adrian |  |  |  |  |  |
| 1687 | 387 | **IMS Overload Control** | 659d? | 2012-06-18 A | 2014-12-09 | 99% | 0d? | 2012-06-18 | 2014-12-05 | 654d? | 0d |  | S2; C1; C3; IETF | 52408h | 18920h | IOC | PCG-29 | Stage 2/3 | Orange, China Mobile | Rel-11 | SP-56 | Maurice | IOC |  |  |  |  |
| 1688 | 387.1 | Stage 2 for IMS Overload Control | 64d? | 2012-06-18 A | 2012-09-12 A | 100% |  | 2012-06-18 | 2012-09-12 | 64d? |  | finish no earlier than 2012-09-12 | S2 | 504h | 504h | IOC | PCG-29 | 23.228 | Orange, China Mobile | Rel-11 | SP-56 | Maurice |  |  |  |  |  |
| 1689 | 387.2 | **Stage 3 for IMS Overload Control** | 601d? | 2012-09-05 A | 2014-12-09 | 99% | 0d? | 2012-09-05 | 2014-12-05 | 596d? | 0d |  | C1; C3; IETF | 30816h | 16464h | IOC | PCG-29 |  | Alcatel-Lucent | Rel-11 | CP-57 | Frederic |  |  |  |  |  |
| 1690 | 387.2.1 | CT1 part of Stage 3 for IMS Overload Control | 70d? | 2012-09-05 A | 2012-12-07 A | 100% |  | 2012-09-05 | 2012-12-07 | 70d? |  | finish no earlier than 2012-12-07 | C1 | 544h | 544h | IOC | PCG-29 | 24.229 | Alcatel-Lucent | Rel-11 | CP-57 | Frederic |  |  |  |  |  |
| 1691 | 387.2.2 | CT3 part of Stage 3 for IMS Overload Control | 70d? | 2012-09-05 A | 2012-12-07 A | 100% |  | 2012-09-05 | 2012-12-07 | 70d? |  | finish no earlier than 2012-12-07 | C3 | 552h | 552h | IOC | PCG-29 | 29.165 | Alcatel-Lucent | Rel-11 | CP-57 | Adrian |  |  |  |  |  |
| 1692 | 387.2.3 | (IETF) CT part of Stage 3 for IMS Overload Control (soc-overload-control) | 361d? | 2013-07-29 A | 2014-12-09 A | 100% |  | 2013-07-29 | 2014-12-05 | 359d? |  | finish no earlier than 2014-12-09 | C1-IETF; C3-IETF | 5776h | 5776h | IOC | PCG-29 | RFC 7339 | Keith Drage | Rel-11 | CP-57 | Frederic |  |  |  |  |  |
| 1693 | 387.2.4 | (IETF) CT part of Stage 3 for IMS Overload Control (soc-overload-rate-control) | 361d? | 2013-07-29 A | 2014-12-09 A | 100% |  | 2013-07-29 | 2014-12-05 | 359d? |  | finish no earlier than 2014-12-09 | C1-IETF; C3-IETF | 5776h | 5776h | IOC | PCG-29 | RFC 7415 | Keith Drage | Rel-11 | CP-57 | Frederic |  |  |  |  |  |
| 1694 | 387.2.5 | (IETF) CT part of Stage 3 for IMS Overload Control (RFC 7200) | 234d? | 2013-07-29 A | 2014-06-13 A | 100% |  | 2013-07-29 | 2014-06-13 | 234d? |  | finish no earlier than 2014-06-13 | C1-IETF; C3-IETF | 3744h | 3744h | IOC | PCG-29 | RFC 7200 (was draft-ietf-soc-load-control-event-package) | Keith Drage | Rel-11 | CP-57 | Frederic |  |  |  |  |  |
| 1695 | 388 | Rel-11 Security small Enhancements | 336d? | 2011-06-08 A | 2012-09-12 A | 100% |  | 2011-06-08 | 2012-09-12 | 336d? |  | finish no earlier than 2012-09-12 | S3 | 2680h | 2680h | SEC11 | PCG-27 |  |  | Rel-11 | SP-52 | Mirko | SEC11 |  |  |  |  |
| 1696 | 389 | Lawful Interception in the 3GPP Rel-11 | 272d? | 2011-06-10 A | 2012-06-20 A | 100% |  | 2011-06-10 | 2012-06-20 | 272d? |  | finish no earlier than 2012-06-20 | S3 | 2176h | 2176h | LI11 | PCG-27 | 33.106, 33.107, 33.108 | PIDS, Alcatel-Lucent | Rel-11 | SP-52 | Mirko | LI11 |  |  |  |  |

Notes:
- 1671: RP#58 completed / WI rapporteur e-mail: liwei.qiu@huawei.com
- 1672: RP#58 completed / WI rapporteur e-mail: liwei.qiu@huawei.com
- 1673: ; Stat Rep: RP-141167->RP-141771 1st Apr 15: Compl:40%->100% 1st Apr 15: Stat Rep: RP-141771->RP-150133 / WI rapporteur e-mail: calle.hagenfeldt@ericsson.com
- 1674: Triggered by Rel-11 TR 23.852 FS_SaMOG UID_510061, Rel-8 UID_350027 SAE for support for non-3GPP accesses (defines PMIP-S2a) / WI rapporteur e-mail: Chunhui Zhu (zhu.chunhui@zte.com.cn)
- 1675: SP#55 completed / WI rapporteur e-mail: zhu.chunhui@zte.com.cn
- 1676: - / WI rapporteur e-mail: bruno.landais@alcatel-lucent.com
- 1677: CP#57 completed / WI rapporteur e-mail: bruno.landais@alcatel-lucent.com
- 1678: CP#63 Draft removed from 3GPP documentation
- 1679: CP#56 stopped (no CT1 impact) / WI rapporteur e-mail: bruno.landais@alcatel-lucent.com
- 1680: CP#56 completed / WI rapporteur e-mail: bruno.landais@alcatel-lucent.com
- 1681: CP#58 completed. Triggered by Rel-11 TR 23.850 Study on Roaming Architecture for Voice over IMS with Local Breakout (FS_RAVEL). GSMA CPWP LS_in S5-102806 asked 3GPP SA5 to check if CS voice charging principles also apply to voice over IMS / WI rapporteur e-mail: michele.zarri@telekom.com
- 1682: SP#54 completed / WI rapporteur e-mail: michele.zarri@telekom.com
- 1683: Stage 2/3. SP#57 completed / WI rapporteur e-mail: Gerald.Goermer@nsn.com
- 1684: CP#58 completed / WI rapporteur e-mail: reinhard.lauster@)t-mobile.at
- 1685: CP#58 completed / WI rapporteur e-mail: reinhard.lauster@)t-mobile.at
- 1686: CP#58 completed / WI rapporteur e-mail: reinhard.lauster@)t-mobile.at
- 1687: SP#57 Stage 2 completed. Moved Rel-12=>Rel-11 as CT finished Stage 3. Linked to UID_410041 Study on IMS Evolution (TR 23.812). Solutions from IETF SOC WG and existing 3GPP procedures to be re-used if possible & backward compatibility ensured / WI rapporteur e-mail: Antoine MOUQUET, YU Qing
- 1688: SP#57 completed. Moved Rel-12=>Rel-11 as CT finished Stage 3. / WI rapporteur e-mail: antoine.mouquet@orange-ftgroup.com, YU Qing
- 1689: - / WI rapporteur e-mail: Keith Drage
- 1690: CP#58 completed / WI rapporteur e-mail: Keith Drage
- 1691: CP#58 completed / WI rapporteur e-mail: Keith Drage
- 1692: in RFC Ed-queue. Dec.14: 75->100. Mar15: impacted spec updated (was draft-ietf-soc-overload-control). / WI rapporteur e-mail: Keith Drage
- 1693: Submitted to IESG for publication. Dec14: 50->90%. Mar15: 100%. Impacted RFC updated (was draft-ietf-soc-overload-rate-control) / WI rapporteur e-mail: Keith Drage
- 1694: CP#64 completed / WI rapporteur e-mail: Keith Drage
- 1695: SEC11 is an umbrella Feature for Security related TEI11 type of changes that are not part of any other dedicated feature
- 1696: Stage 1/2/3. SP#56 completed / WI rapporteur e-mail: Koen Jaspers (k.b.jaspers@minjus.nl), terry.jacobson@alcatel-lucent.com

| ID | WBS | Task | Duration | Start | Finish | Complete | Baseline start | Baseline finish | Baseline duration | Constraint | Resources | Work | Actual work | Acronym | PCG approved | WI rapporteur name | Release | TSG approved | MCC resp | Acronym_3GU_Export | Status Report | Special Focus Doc |
| --- | --- | --- | --- | --- | --- | --- | --- | --- | --- | --- | --- | --- | --- | --- | --- | --- | --- | --- | --- | --- | --- | --- |
| 1697 | 390 | **ZUC EEA3 and EIA3 (new Encryption & Integrity EPS security Algorithms)** | 857d? | 2009-06-04 A | 2012-09-07 A | 100% | 2009-06-04 | 2012-09-07 | 857d? |  | S3; R5 | 19488h | 19488h | EEA3_EIA3 | PCG-23 | CATR | Rel-11 | SP-44 | Mirko | EEA3_EIA3 |  |  |
| 1698 | 390.1 | ZUC EEA3 and EIA3 | 663d? | 2009-06-04 A | 2011-12-14 A | 100% | 2009-06-04 | 2011-12-14 | 663d? | finish no earlier than 2011-09-21 | S3 | 5288h | 5288h | EEA3_EIA3 | PCG-23 | CATR | Rel-11 | SP-44 | Mirko |  |  |  |
| 1699 | 390.2 | Conformance Test Aspects – ZUC (EEA3 and EIA3 Encryption & Integrity EPS security Algorithms) | 61d? | 2012-06-18 A | 2012-09-07 A | 100% | 2012-06-18 | 2012-09-07 | 61d? | finish no earlier than 2013-03-01 | R5 | 488h | 488h | EEA3_EIA3_UEConTest | PCG-29 | CATR | Rel-11 | RP-56 | Ingbert | EEA3_EIA3_UEConTest | RP-120968 |  |
| 1700 | 391 | Specification of Protection against Unsolicited Communication for IMS (produced TR-only) | 456d? | 2010-06-10 A | 2012-03-07 A | 100% | 2010-06-10 | 2012-03-07 | 456d? | finish no earlier than 2012-03-07 | S3 | 3640h | 3640h | SPUCI | PCG-25 | NEC | Rel-11 | SP-48 | Mirko | SPUCI |  |  |
| 1701 | 392 | H(e)NB security features for UE mobility scenarios (Stage 2) | 252d? | 2011-03-23 A | 2012-03-07 A | 100% | 2011-03-23 | 2012-03-07 | 252d? | finish no earlier than 2012-03-07 | S3 | 2008h | 2008h | HNB_mob_Sec | PCG-26 | Huawei | Rel-11 | SP-51 | Mirko | HNB_mob_Sec |  | HNB |
| 1702 | 393 | **Generic Bootstrapping Architecture (GBA) extensions for re-use of SIP Digest credentials** | 203d? | 2011-12-02 A | 2012-09-07 A | 100% | 2011-12-02 | 2012-09-07 | 203d? |  | S3; C4; C1 | 11824h | 11824h | GBA-ext | PCG-28 | Nokia | Rel-11 | SP-54 | Mirko | GBA-ext |  |  |
| 1703 | 393.1 | Stage 2 for GBA extensions for re-use of SIP Digest credentials | 61d? | 2011-12-14 A | 2012-03-07 A | 100% | 2011-12-14 | 2012-03-07 | 61d? | finish no earlier than 2012-02-28 | S3 | 488h | 488h | GBA-ext | PCG-28 | Nokia | Rel-11 | SP-54 | Mirko |  |  |  |
| 1704 | 393.2 | **Stage 3 for GBA extensions for re-use of SIP Digest credentials** | 203d? | 2011-12-02 A | 2012-09-07 A | 100% | 2011-12-02 | 2012-09-07 | 203d? |  | C4; C1 | 6464h | 6464h | GBA-ext-St3 | PCG-28 | Alcatel-Lucent | Rel-11 | CP-54 | Kimmo | GBA-ext-St3 |  |  |
| 1705 | 393.2.1 | CT4 part of Stage 3 for GBA extensions for re-use of SIP Digest credentials | 203d? | 2011-12-02 A | 2012-09-07 A | 100% | 2011-12-02 | 2012-09-07 | 203d? | finish no earlier than 2012-09-07 | C4 | 1608h | 1608h | GBA-ext-St3 | PCG-28 | Alcatel-Lucent | Rel-11 | CP-54 | Kimmo |  |  |  |
| 1706 | 393.2.2 | CT1 part of Stage 3 for GBA extensions for re-use of SIP Digest credentials | 202d? | 2011-12-05 A | 2012-09-07 A | 100% | 2011-12-05 | 2012-09-07 | 202d? | finish no earlier than 2012-09-07 | C1 | 1608h | 1608h | GBA-ext-St3 | PCG-28 | Alcatel-Lucent | Rel-11 | CP-54 | Frederic |  |  |  |
| 1707 | 394 | Extensions of Acoustic Test Specifications in TS 26.131 and TS 26.132 | 332d? | 2011-06-08 A | 2012-09-12 A | 100% | 2011-06-08 | 2012-09-12 | 332d? | finish no earlier than 2012-09-12 | S4 | 2648h | 2648h | Ext_ATS | PCG-27 | Orange, Qualcomm | Rel-11 | SP-52 | Paolo | Ext_ATS |  |  |
| 1708 | 395 | **Enhancements to Multimedia: PSS, MMS, and MBMS Enhancements and Performance Improvements** | 397d? | 2011-09-07 A | 2013-03-06 A | 100% | 2011-09-07 | 2013-03-06 | 397d? |  | S4 | 10928.6h | 10928.6h | EMM | PCG-27 | Qualcomm | Rel-11 | SP-53 | Paolo | EMM |  |  |
| 1709 | 395.1 | Enhancement to FEC for MBMS | 386d? | 2011-09-21 A | 2013-03-06 A | 100% | 2011-09-21 | 2013-03-06 | 386d? | finish no earlier than 2013-03-06 | S4 | 3048h | 3048h | EMM-EFEC | PCG-27 | Qualcomm | Rel-11 | SP-53 | Paolo | EMM-EFEC |  |  |
| 1710 | 395.2 | Download Delivery Enhancements for MBMS | 325d? | 2011-09-21 A | 2012-12-12 A | 100% | 2011-09-21 | 2012-12-12 | 325d? | finish no earlier than 2012-12-12 | S4 | 2576.59h | 2576.59h | EMM-DDE | PCG-27 | Qualcomm | Rel-11 | SP-53 | Paolo | EMM-DDE |  |  |
| 1711 | 395.3 | IMS-based PSS and MBMS Streaming Synchronization Enhancements | 268d? | 2011-09-07 A | 2012-09-12 A | 100% | 2011-09-07 | 2012-09-12 | 268d? | finish no earlier than 2012-09-12 | S4 | 2128h | 2128h | EMM-IPME | PCG-27 | InterDigital Communications | Rel-11 | SP-53 | Paolo | EMM-IPME |  |  |
| 1712 | 396 | Mobile 3D Video Coding | 71d? | 2012-06-07 A | 2012-09-12 A | 100% | 2012-06-07 | 2012-09-12 | 71d? | finish no earlier than 2012-09-12 | S4 | 560h | 560h | M3DV | PCG-29 | Orange | Rel-11 | SP-56 | Paolo | M3DV |  |  |
| 1713 | 397 | **Rel-11 Operations, Administration, Maintenance and Provisioning (OAM&P)** | 519d? | 2011-03-23 A | 2013-03-07 A | 100% | 2011-03-23 | 2013-03-06 | 519d? |  | S5 | 39394.5h | 39394.5h | OAM11 | PCG-26 |  | Rel-11 | SP-51 | Mirko | OAM11 |  |  |
| 1714 | 397.1 | **Rel-11 Network Infrastructure Management** | 519d? | 2011-03-23 A | 2013-03-07 A | 100% | 2011-03-23 | 2013-03-06 | 519d? |  | S5 | 8256h | 8256h | OAM11-NIM | PCG-26 |  | Rel-11 | SP-51 | Mirko | OAM11-NIM |  |  |
| 1715 | 397.1.1 | IRP framework enhancements to support Management of Converged Networks | 515d? | 2011-03-23 A | 2013-03-07 A | 100% | 2011-03-23 | 2013-03-06 | 515d? | finish no earlier than 2013-03-06 | S5 | 4104h | 4104h | OAM-FMC-IRP | PCG-26 | Nokia Siemens Networks, Ericsson | Rel-11 | SP-51 | Mirko | OAM-FMC-IRP |  |  |
| 1716 | 397.2 | **Rel-11 Performance Management** | 458d? | 2011-03-23 A | 2012-12-12 A | 100% | 2011-03-23 | 2012-12-12 | 458d? |  | S5 | 14530.5h | 14530.5h | OAM11-PM | PCG-26 |  | Rel-11 | SP-51 | Mirko | OAM11-PM |  |  |
| 1717 | 397.2.1 | IMS Performance Management enhancements | 252d? | 2011-03-23 A | 2012-03-07 A | 100% | 2011-03-23 | 2012-03-07 | 252d? | finish no earlier than 2012-09-12 | S5 | 2010.52h | 2010.52h | OAM-ePM-IMS | PCG-26 | ZTE | Rel-11 | SP-51 | Mirko | OAM-ePM-IMS |  |  |
| 1718 | 397.2.2 | Enhanced Management of UE based network performance measurements | 455d? | 2011-03-23 A | 2012-12-12 A | 100% | 2011-03-23 | 2012-12-12 | 455d? | finish no earlier than 2012-12-12 | S5 | 3624h | 3624h | OAM-ePM-UE | PCG-26 | Huawei, Ericsson, Nokia Siemens Networks | Rel-11 | SP-51 | Mirko | OAM-ePM-UE |  |  |
| 1719 | 397.2.3 | CN performance measurements enhancement | 334d? | 2011-06-08 A | 2012-09-12 A | 100% | 2011-06-08 | 2012-09-12 | 334d? | finish no earlier than 2012-09-12 | S5 | 2648h | 2648h | OAM-ePM-CN | PCG-27 | China Mobile | Rel-11 | SP-52 | Mirko | OAM-ePM-CN |  |  |
| 1720 | 397.2.4 | Management of Carrier Aggregation for LTE | 325d? | 2011-09-21 A | 2012-12-12 A | 100% | 2011-09-21 | 2012-12-12 | 325d? | finish no earlier than 2012-12-12 | S5 | 2584h | 2584h | OAM-CA | PCG-27 | Nokia Siemens Networks, Ericsson | Rel-11 | SP-53 | Mirko | OAM-CA |  | CA |

Notes:
- 1697: RP#57 completed testing / WI rapporteur e-mail: Yuan Qi (yuanqi@catr.cn)
- 1698: SP#53 completed new EPS algorithms e.g. for China / Impacted TSs and TRs: 33.401, New (35.221, 35.222, 35.223, 35.924) / WI rapporteur e-mail: Yuan Qi (yuanqi@catr.cn)
- 1699: RP#57 completed. Testing for SA3 TSs 33.401, new (35.221, 35.222, 35.223) / Impacted TSs and TRs: 36.523-1, 36.523-2, 36.523-3 / WI rapporteur e-mail: Ms Jun Chen (chenjun@catr.cn)
- 1700: SP#55 completed (No normative work). TR 33.838v200 for Approval & abandoned new TS 33.237. Continuation of Rel-9 UID_410027/410029. Builds on TR 33.937 Study of Mechanisms for PUCI / Impacted TSs and TRs: New TR 33.838, abandoned New TS 33.237 / WI rapporteur e-mail: Anand R. Prasad (anand@bq.jp.nec.com)
- 1701: SP#55 completed. Add HeNB Security extensions to Extended H(e)NB Features (EHNBF) UID_450053 / Impacted TSs and TRs: 33.320 / WI rapporteur e-mail: Marcus Wong (mwong@huawei.com)
- 1702: Stage 2/3. CP#57 completed / WI rapporteur e-mail: Silke.Holtmanns@nokia.com
- 1703: SP#55 completed / Impacted TSs and TRs: 33.220 / WI rapporteur e-mail: Silke.Holtmanns@nokia.com
- 1704: CP#57 completed / Impacted TSs and TRs: Stage 3 / WI rapporteur e-mail: jean-jacques.trottin@alcatel-lucent.com
- 1705: CP#57 completed / Impacted TSs and TRs: 29.109 / WI rapporteur e-mail: jean-jacques.trottin@alcatel-lucent.com
- 1706: CP#57 completed / Impacted TSs and TRs: 24.109 / WI rapporteur e-mail: jean-jacques.trottin@alcatel-lucent.com
- 1707: SP#57 completed / Impacted TSs and TRs: 26.131, 26.132 / WI rapporteur e-mail: stephane.ragot@orange-ftgroup.com, Andre Schevciw (aschevci@qualcomm.com)
- 1708: Stage 3. SP#59 completed / Impacted TSs and TRs: 26.140, 26.234, 26.247, New TR 26.951=>26.851 / WI rapporteur e-mail: Nikolai Leung (nleung@qualcomm.com)
- 1709: SP#59 completed / Impacted TSs and TRs: 26.346, new TR 26.947 / WI rapporteur e-mail: Thomas Stockhammer (c_tstock@qualcomm.com)
- 1710: SP#58 completed / Impacted TSs and TRs: 26.346, new TR 26.951=>26.851 / WI rapporteur e-mail: Nikolai Leung (nleung@qualcomm.com)
- 1711: SP#58 completed / Impacted TSs and TRs: 26.237, new TR 26.951=>26.851 / WI rapporteur e-mail: hang.liu@interdigital.com
- 1712: SP#57 completed. Triggered by UID_520036 Rel-11 Study on Mobile 3D Video Coding (FS_M3DVC) TR 26.905. / Impacted TSs and TRs: 26.140, 26.234, 26.244, 26.245, 26.247, 26.346, 26.430, 26.905 / WI rapporteur e-mail: gilles.teniou@orange.com
- 1713: OAM11 is an umbrella Feature also for OAM&P related TEI11 type of changes that are not part of any other dedicated feature/WI
- 1714: -
- 1715: SP#59 completed. Triggered by SA5 Studies TR 32.833, 32.828, 32.831 / Impacted TSs and TRs: 32.101/103/150, new (28.620/621/622/623/624/625/626/627/628/629/631/632/633/651/652/653/654/655/656/657/658/659/661/662/663/671/672/673/674/675/676/701/702/703/704/705/706/707/708/709/731/732/733/734/735/736/751/752/753, 32.107/156/157/853/854 / WI rapporteur e-mail: thomas.tovinger@ericsson.com, olaf.pollakowski@nsn.com
- 1716: -
- 1717: SP#55 completed / Impacted TSs and TRs: 32.409 / WI rapporteur e-mail: guo.wenjie1@zte.com.cn
- 1718: SP#58 completed / Impacted TSs and TRs: 32.421, 32.422, 32.423, 32.441, 32.442, 32.446 / WI rapporteur e-mail: Zou Lan (zlan@huawei.com), ulf.hubinette@ericsson.com, gyula.bodog@nsn.com
- 1719: SP#57 completed / Impacted TSs and TRs: 32.406, 32.407, 32.426 / WI rapporteur e-mail: Liang Shuangchun (liangshuangchun@cmdi.chinamobile.com), Li Jian (lijian@chinamobile.com)
- 1720: SP#58 completed. Updated WID SP-110636=>SP-120776. Stage 2 in Rel-10 RAN Feature UID_460007 Carrier Aggregation for LTE (LTE_CA) / Impacted TSs and TRs: 32.425 / WI rapporteur e-mail: yizhi.yao@nsn.com, per.elmdahl@ericsson.com

| ID | WBS | Task | Type | Duration | Start | Finish | Complete | Baseline start | Baseline finish | Baseline duration | Constraint | Resources | Work | Actual work | Acronym | PCG approved | Release | TSG approved | MCC resp | Special Focus Doc | Acronym_3GU_Export | WI rapporteur name | WI rapporteur e-mail |
| --- | --- | --- | --- | --- | --- | --- | --- | --- | --- | --- | --- | --- | --- | --- | --- | --- | --- | --- | --- | --- | --- | --- | --- |
| 1721 | 397.3 | **Rel-11 Self-Organizing Networks (SON) - OAM aspects** |  | 519d? | 2011-03-23 A | 2013-03-06 A | 100% | 2011-03-23 | 2013-03-06 | 519d? |  | S5 | 12456h | 12456h | OAM11-SON | PCG-26 | Rel-11 | SP-51 | Mirko | SON | OAM11-SON |  |  |
| 1722 | 397.3.1 | UTRAN Self-Organizing Networks (SON) management |  | 388d? | 2011-03-23 A | 2012-09-12 A | 100% | 2011-03-23 | 2012-09-12 | 388d? | finish no earlier than 2012-09-12 | S5 | 3088h | 3088h | OAM-SON-UTRAN | PCG-26 | Rel-11 | SP-51 | Mirko | SON | OAM-SON-UTRAN | Huawei | kai.zhangkai@huawei.com |
| 1723 | 397.3.2 | LTE Self-Organizing Networks (SON) coordination management |  | 387d? | 2011-09-21 A | 2013-03-06 A | 100% | 2011-09-21 | 2013-03-06 | 387d? | finish no earlier than 2013-03-06 | S5 | 3072h | 3072h | OAM-SON-LTE_COORD | PCG-27 | Rel-11 | SP-53 | Mirko | SON | OAM-SON-LTE_COORD | Huawei, Nokia Siemens Networks | kai.zhangkai@huawei.com, clemens.suerbaum@nsn.com |
| 1724 | 397.3.3 | Inter-RAT Energy Saving Management |  | 269d? | 2011-12-07 A | 2012-12-12 A | 100% | 2011-12-07 | 2012-12-12 | 269d? | finish no earlier than 2012-12-12 | S5 | 2144h | 2144h | OAM-IRAT-ESM | PCG-28 | Rel-11 | SP-54 | Mirko | SON | OAM-IRAT-ESM | Nokia Siemens Networks, Huawei | clemens.suerbaum@nsn.com, xiahaitao@huawei.com |
| 1725 | 398 | **Rel-11 Charging Management small Enhancements** |  | 717d? | 2010-03-25 A | 2012-12-12 A | 100% | 2010-03-25 | 2012-12-12 | 717d? |  | S5 | 11528h | 11528h | CH11 | PCG-26 | Rel-11 | SP-51 | Mirko |  | CH11 |  |  |
| 1726 | 398.1 | Add solutions for Rc - reference point within the Online Charging System (OCS) |  | 392d? | 2010-03-25 A | 2011-09-21 A | 100% | 2010-03-25 | 2011-09-21 | 392d? | finish no earlier than 2011-08-26 | S5 | 3120h | 3120h | CH-Rc | PCG-24 | Rel-11 | SP-47 | Mirko |  | CH-Rc | Huawei | shan.mingjun@huawei.com |
| 1727 | 398.2 | Charging for Policy Enhancements for Sponsored Connectivity and Coherent Access to Policy related Data Bases |  | 135d? | 2011-03-21 A | 2011-09-21 A | 100% | 2011-03-21 | 2011-09-21 | 135d? | finish no earlier than 2011-09-21 | S5 | 1064h | 1064h | PEST-CH | PCG-26 | Rel-11 | SP-51 | Mirko |  | PEST-CH | Ericsson | patrik.teppo@@ericsson.com |
| 1728 | 398.3 | Unification of Charging session from SIP AS and SRVCC functions in IMS |  | 203d? | 2012-03-07 A | 2012-12-12 A | 100% | 2012-03-07 | 2012-12-12 | 203d? | finish no earlier than 2012-12-12 | S5 | 1608h | 1608h | UCHIMS_AS-SRVCC | PCG-28 | Rel-11 | SP-55 | Mirko |  | UCHIMS_AS-SRVCC | Alcatel-Lucent | maryse.gardella@alcatel-lucent.com |
| 1729 | 399 | **Transit Inter Operator Identifier for IMS Interconnection Charging in multi operator environment** |  | 432d? | 2010-10-27 A | 2012-06-15 A | 100% | 2010-10-27 | 2012-06-15 | 432d? |  | S5; S1; C1 | 15921.1h | 15921.1h | IOI_IMS_CH | PCG-26 | Rel-11 | SP-51 | Mirko |  | IOI_IMS_CH | Deutsche Telekom | matthias.seibel@telekom.de |
| 1730 | 399.1 | Stage 1 for Transit Inter Operator Identifier for IMS Interconnection Charging in multi operator environment |  | 237d? | 2010-10-27 A | 2011-09-21 A | 100% | 2010-10-27 | 2011-09-21 | 237d? |  | S1 | 1896h | 1896h | IOI_IMS_CH | PCG-26 | Rel-11 | SP-51 | Dionisio |  |  | Deutsche Telekom | matthias.seibel@telekom.de |
| 1731 | 399.2 | Stage 2/3 SA5 part of Transit Inter Operator Identifier for IMS Interconnection Charging in multi operator environment |  | 187d? | 2010-10-27 A | 2011-12-07 A | 100% | 2010-10-27 | 2011-12-07 | 187d? | finish no earlier than 2012-03-21 | S5 | 1488h | 1488h | IOI_IMS_CH | PCG-26 | Rel-11 | SP-51 | Mirko |  |  | Deutsche Telekom | matthias.seibel@telekom.de |
| 1732 | 399.3 | Stage 3 for Transit Inter Operator Identifier for IMS Interconnection Charging in multi operator environment |  | 273d? | 2011-06-07 A | 2012-06-15 A | 100% | 2011-06-07 | 2012-06-15 | 273d? | finish no earlier than 2012-06-01 | C1 | 2169.09h | 2169.09h | IOI_IMS_CH | PCG-27 | Rel-11 | CP-52 | Frederic |  |  | Deutsche Telekom | martin.huelsemann@telekom.de] |
| 1733 | 400 | **User Data Convergence - Data Model** |  | 647d? | 2010-03-25 A | 2012-09-07 A | 100% | 2010-03-25 | 2012-09-07 | 647d? |  | C4; S1 | 22984h | 22984h | UDC_DM | PCG-25 | Rel-11 | CP-48 | Kimmo |  | UDC_DM | Telecom Italia | mauro.ficaccio@telecomitalia.it |
| 1734 | 400.1 | Stage 1 for UDC Data Model |  | 392d? | 2010-03-25 A | 2011-09-21 A | 100% | 2010-03-25 | 2011-09-21 | 392d? | finish no earlier than 2010-06-10 | S1 | 3136h | 3136h | UDC_DM | PCG-25 | Rel-11 | CP-48 | Alain |  |  | Telecom Italia | mauro.ficaccio@telecomitalia.it |
| 1735 | 400.2 | TR on User Data Convergence (UDC) Data Model |  | 593d? | 2010-06-04 A | 2012-09-07 A | 100% | 2010-06-04 | 2012-09-07 | 593d? | finish no earlier than 2012-09-07 | C4 | 4736h | 4736h | UDC_DM | PCG-25 | Rel-11 | CP-48 | Kimmo |  |  | Telecom Italia | mauro.ficaccio@telecomitalia.it |
| 1736 | 400.3 | User Data Convergence (UDC) Data Model |  | 596d? | 2010-06-04 A | 2012-09-07 A | 100% | 2010-06-04 | 2012-09-07 | 596d? | finish no earlier than 2012-09-07 | C4 | 4760h | 4760h | UDC_DM | PCG-25 | Rel-11 | CP-48 | Kimmo |  |  | Telecom Italia | mauro.ficaccio@telecomitalia.it |
| 1737 | 401 | Definition of the UICC Application for Hosting Party Module |  | 327d? | 2011-03-18 A | 2012-06-15 A | 100% | 2011-03-18 | 2012-06-15 | 327d? | finish no earlier than 2012-06-15 | C6 | 2608h | 2608h | HPM_UICC | PCG-26 | Rel-11 | CP-51 | Xavier |  | HPM_UICC | Gemalto | Denis.Lheriteau@gemalto.com |
| 1738 | 402 | Usability improvement of Inter-IMS Network to Network Interface (II-NNI) specification for inter-connection by means of Option Item list |  | 273d? | 2011-06-07 A | 2012-06-15 A | 100% | 2011-06-07 | 2012-06-15 | 273d? | finish no earlier than 2012-06-01 | C3 | 2169.56h | 2169.56h | NNI_OI | PCG-27 | Rel-11 | CP-52 | Adrian |  | NNI_OI | NTT | arai.kenjiro@lab.ntt.co.jp |
| 1739 | 403 | **enhanced Nodes Restoration for EPC (Stage 2/3)** |  | 668d? | 2011-06-03 A | 2013-12-06 A | 100% | 2011-06-03 | 2013-12-06 | 668d? |  | C4; C1; C3; IETF | 27728h | 27728h | eNR_EPC | PCG-27 | Rel-11 | CP-52 | Kimmo |  | eNR_EPC | ZTE | lu.fei1@zte.com.cn |
| 1740 | 403.1 | CT4 part of enhanced Nodes Restoration for EPC |  | 402d? | 2011-06-03 A | 2012-12-07 A | 100% | 2011-06-03 | 2012-12-07 | 402d? | finish no earlier than 2012-12-07 | C4 | 3192h | 3192h | eNR_EPC | PCG-27 | Rel-11 | CP-52 | Kimmo |  |  | ZTE | lu.fei1@zte.com.cn |
| 1741 | 403.2 | (IETF) CT4 part of enhanced Nodes Restoration for EPC (RFC 7077) |  | 266d? | 2012-12-07 A | 2013-12-06 A | 100% | 2012-12-07 | 2013-12-06 | 266d? | finish no earlier than 2013-12-06 | C4-IETF | 2104h | 2104h | eNR_EPC | PCG-30 | Rel-11 | CP-58 | Kimmo |  |  | Lionel Morand | Lionel Morand |
| 1742 | 403.3 | CT1 part of enhanced Nodes Restoration for EPC |  | 66d? | 2011-12-02 A | 2012-03-02 A | 100% | 2011-12-02 | 2012-03-02 | 66d? | finish no earlier than 2012-06-15 | C1 | 528h | 528h | eNR_EPC | PCG-28 | Rel-11 | CP-54 | Frederic |  |  | ZTE | lu.fei1@zte.com.cn |
| 1743 | 403.4 | CT3 part of enhanced Nodes Restoration for EPC |  | 67d? | 2012-09-10 A | 2012-12-07 A | 100% | 2012-09-10 | 2012-12-07 | 67d? | finish no earlier than 2012-12-07 | C3 | 528h | 528h | eNR_EPC | PCG-29 | Rel-11 | CP-57 | Adrian |  |  | ZTE | lu.fei1@zte.com.cn |
| 1744 | 404 | **Reference Location Information (Stage 3)** |  | 78d? | 2011-06-03 A | 2011-09-16 A | 100% | 2011-06-03 | 2011-09-16 | 78d? |  | C4; C1 | 1860.74h | 1860.74h | RLI | PCG-27 | Rel-11 | CP-52 | Kimmo |  | RLI | Huawei | susan.shishufeng@Huawei.com |
| 1745 | 404.1 | CT4 part of Reference Location Information (Stage 3) | milestone | 0d? | 2011-06-03 A | 2011-06-03 A | 100% | 2011-06-03 | 2011-06-03 | 0d? | finish no earlier than 2011-06-03 | C4 |  |  | RLI | PCG-27 | Rel-11 | CP-52 | Kimmo |  |  | Huawei | susan.shishufeng@Huawei.com |
| 1746 | 404.2 | CT1 part of Reference Location Information (Stage 3) |  | 78d? | 2011-06-03 A | 2011-09-16 A | 100% | 2011-06-03 | 2011-09-16 | 78d? | finish no earlier than 2011-08-30 | C1 | 612.74h | 612.74h | RLI | PCG-27 | Rel-11 | CP-52 | Frederic |  |  | Huawei | susan.shishufeng@Huawei.com |

Notes:
- 1721: -
- 1722: SP#57 completed. Updated WID SP-110518=>SP-120552 / Impacted TSs and TRs: UTRA 32.405, 32.500, 32.511, 32.521, 32.522, 32.526, 32.642, 32.646
- 1723: SP#59 completed / Impacted TSs and TRs: LTE 32.425, 32.500, 32.521, 32.522, 32.526, 32.762, 32.766
- 1724: SP#58 completed. Triggered by Rel-11 TR 32.834 (Study on OAM aspects of inter-RAT Energy Saving) UID_510045. Needs coordination with RAN WGs / Impacted TSs and TRs: 32.405, 32.551, 32.522, 32.526, 32.642, 32.646, 32.762, 32.766
- 1725: CH11 is an umbrella Feature also for OAM&P related TEI11 type of changes that are not part of any other dedicated feature/WI / Impacted TSs and TRs: TR 30.821
- 1726: SP#53 completed. Stage 3 (Stage 1 in 22.115). Triggered by Rel-10 TR 32.825 SA5 Study on Rc Reference Point Functionalities and Message Flows (UID_410044) / Impacted TSs and TRs: 32.296, 32.299
- 1727: SP#53 completed. Stage 3 / Impacted TSs and TRs: 32.251, 32.298, 32.299
- 1728: Stage 2/3. SP#58 completed / Impacted TSs and TRs: 32.260, 32.275, 32.298, 32.299
- 1729: Stage 2/3. CP#56 completed. Stage 1 in SA1 22.115
- 1730: SP#53 completed under IPXS / Impacted TSs and TRs: 22.115
- 1731: SP#54 completed / Impacted TSs and TRs: 32.240, 32.260, 32.298, 32.299
- 1732: CP#56 completed / Impacted TSs and TRs: 24.229
- 1733: CP#57 completed. SP#48 Stage 1 completed as Rel-10
- 1734: SP#53 completed under Rel-10 UDC / Impacted TSs and TRs: 22.101
- 1735: CP#57 completed / Impacted TSs and TRs: new TR 29.935
- 1736: CP#57 completed / Impacted TSs and TRs: 29.335
- 1737: CP#56 completed / Impacted TSs and TRs: 31.102, New TS 31.104
- 1738: CP#56 completed. Stage 3 (No architectural change, specify the list of selectable items related to control plane signalling directly for the same architecture) / Impacted TSs and TRs: 29.165
- 1739: Triggered by DRAFT TR 23.857 Study on EPC Nodes Restoration UID_490014
- 1740: CP#58 completed / Impacted TSs and TRs: 23.007, 23.008, 23.018, 29.274, 29.275
- 1741: CP#62 completed / Impacted TSs and TRs: RFC 7077 (was draft-ietf-netext-update-notifications)
- 1742: CP#55 completed / Impacted TSs and TRs: 29.118
- 1743: CP#58 completed / Impacted TSs and TRs: 29.212
- 1744: CP#53 completed. Stage 2 clause C.1.1 of SA2 TS 23.167 CR#0182 (WI code: TEI11)
- 1745: CP#52 completed / Impacted TSs and TRs: 23.008, 29.228, 29.328, 29.329
- 1746: CP#53 completed / Impacted TSs and TRs: 24.229

| ID | WBS | Task | Duration | Start | Finish | Complete | Baseline start | Baseline finish | Baseline duration | Constraint | Resources | Work | Actual work | Acronym | PCG approved | WI rapporteur name | WI rapporteur e-mail | Release | TSG approved | MCC resp | Acronym_3GU_Export | PCG stopped | TSG stopped | Special Focus Doc |
| --- | --- | --- | --- | --- | --- | --- | --- | --- | --- | --- | --- | --- | --- | --- | --- | --- | --- | --- | --- | --- | --- | --- | --- | --- |
| 1747 | 405 | **IMS Stage 3 IETF Protocol Alignment - phase 5** | 868d? | 2011-06-07 A | 2014-09-12 A | 100% | 2011-06-07 | 2014-12-05 | 927d? |  | C1; C3; IETF | 34260h | 34260h | IMSProtoc5 | PCG-27 | Alcatel-Lucent | keith.drage@alcatel-lucent.com | Rel-11 | CP-52 | Frederic | IMSProtoc5 |  |  |  |
| 1748 | 405.1 | CT1 part of IMS Stage 3 IETF Protocol Alignment - phase 5 | 333d? | 2011-06-07 A | 2012-09-07 A | 100% | 2011-06-07 | 2012-09-07 | 333d? | finish no earlier than 2012-09-07 | C1 | 2648h | 2648h | IMSProtoc5 | PCG-27 | Alcatel-Lucent | keith.drage@alcatel-lucent.com | Rel-11 | CP-52 | Frederic |  |  |  |  |
| 1749 | 405.2 | (IETF) CT1 part of IMS Stage 3 IETF Protocol Alignment - phase 5 (RFC 7315) | 356.5d? | 2013-03-01 A | 2014-09-12 A | 100% | 2013-03-01 | 2014-12-05 | 416.5d? | finish no earlier than 2014-09-12 | C1-IETF | 2812h | 2812h | IMSProtoc5 | PCG-30 | Roland Jesske | Roland Jesske | Rel-11 | CP-59 | Frederic |  |  |  |  |
| 1750 | 405.3 | (IETF) CT1 part of IMS Stage 3 IETF Protocol Alignment - phase 5 (RFC 7135) | 203d? | 2013-09-06 A | 2014-06-13 A | 100% | 2013-09-06 | 2014-06-13 | 203d? | finish no earlier than 2014-06-13 | C1-IETF | 1608h | 1608h | IMSProtoc5 | PCG-31 | Roland Jesske | Roland Jesske | Rel-11 | CP-61 |  |  |  |  |  |
| 1751 | 405.4 | CT3 part of IMS Stage 3 IETF Protocol Alignment - phase 5 | 333d? | 2011-06-07 A | 2012-09-07 A | 100% | 2011-06-07 | 2012-09-07 | 333d? | finish no earlier than 2012-09-07 | C3 | 2648h | 2648h | IMSProtoc5 | PCG-27 | Alcatel-Lucent | keith.drage@alcatel-lucent.com | Rel-11 | CP-52 | Adrian |  |  |  |  |
| 1752 | 405.5 | Deleted - (IETF) CT3 part of IMS Stage 3 IETF Protocol Alignment - phase 5 (avasarala-dispatch-comm-div-notification) | 466d? | 2012-12-07 A | 2014-09-12 A | 100% | 2012-12-07 | 2014-12-05 | 526d? | finish no earlier than 2014-09-12 | C3-IETF | 3712h | 3712h | IMSProtoc5 | PCG-30 | Andrew Allen | Andrew Allen | Rel-11 | CP-58 | Adrian |  | PCG-33 | CP-65 |  |
| 1753 | 406 | **Service Identification for RRC Improvements in GERAN (Stage 2/3)** | 258d? | 2011-09-19 A | 2012-09-07 A | 100% | 2011-09-19 | 2012-09-07 | 258d? |  | S2; C4; C3; G2 | 16216h | 16216h | SIRIG | PCG-27 | China Mobile | zhanghao@chinamobile.com | Rel-11 | GP-51 | Maurice | SIRIG |  |  |  |
| 1754 | 406.1 | Stage 2 for Service Identification for RRC Improvements in GERAN | 61d? | 2012-06-18 A | 2012-09-07 A | 100% | 2012-06-18 | 2012-09-07 | 61d? | finish no earlier than 2012-09-07 | S2 | 480h | 480h | SIRIG | PCG-29 |  |  | Rel-11 | SP-56 | Maurice |  |  |  |  |
| 1755 | 406.2 | **CN aspects of Service Identification for RRC Improvements in GERAN** | 203d? | 2011-12-02 A | 2012-09-07 A | 100% | 2011-12-02 | 2012-09-07 | 203d? |  | C4; C3 | 5464h | 5464h | SIRIG | PCG-28 | China Mobile | zhanghao@chinamobile.com | Rel-11 | CP-54 | Kimmo |  |  |  |  |
| 1756 | 406.2.1 | CT4 part of CN aspects of Service Identification for RRC Improvements in GERAN | 203d? | 2011-12-02 A | 2012-09-07 A | 100% | 2011-12-02 | 2012-09-07 | 203d? | finish no earlier than 2012-09-07 | C4 | 1608h | 1608h | SIRIG | PCG-28 | China Mobile | zhanghao@chinamobile.com | Rel-11 | CP-54 | Kimmo |  |  |  |  |
| 1757 | 406.2.2 | Deleted - CT3 part of CN aspects of Service Identification for RRC Improvements in GERAN | 77d? | 2012-03-02 A | 2012-06-15 A | 100% | 2012-03-02 | 2012-06-15 | 77d? | finish no earlier than 2012-06-01 | C3 | 608h | 608h | SIRIG | PCG-28 | China Mobile | zhanghao@chinamobile.com | Rel-11 | CP-55 | Adrian |  | PCG-29 | CP-56 |  |
| 1758 | 406.3 | GERAN2 part of Service Identification for RRC Improvements in GERAN | 252d? | 2011-09-19 A | 2012-08-31 A | 100% | 2011-09-19 | 2012-08-31 | 252d? | finish no earlier than 2012-08-31 | G2 | 2016h | 2016h | SIRIG | PCG-27 | China Mobile, Huawei | Juan Deng, Yang Zhao | Rel-11 | GP-51 | Gert |  |  |  |  |
| 1759 | 407 | **SAE Protocol Development - Phase 2** | 259d? | 2011-09-16 A | 2012-09-07 A | 100% | 2011-09-16 | 2012-09-07 | 259d? |  | C1 | 6168h | 6168h | SAES2 | PCG-27 | Nokia Siemens Networks | robert.zaus@nsn.com | Rel-11 | CP-53 | Frederic | SAES2 |  |  |  |
| 1760 | 407.1 | SAE Protocol Development (Stage 3) - Phase 2 | 259d? | 2011-09-16 A | 2012-09-07 A | 100% | 2011-09-16 | 2012-09-07 | 259d? | finish no earlier than 2012-09-07 | C1 | 2048h | 2048h | SAES2 | PCG-27 | Nokia Siemens Networks | robert.zaus@nsn.com | Rel-11 | CP-53 | Frederic |  |  |  |  |
| 1761 | 407.2 | CS Fallback in EPS - Phase 2 | 259d? | 2011-09-16 A | 2012-09-07 A | 100% | 2011-09-16 | 2012-09-07 | 259d? | finish no earlier than 2012-09-07 | C1 | 2048h | 2048h | SAES2-CSFB | PCG-27 | Nokia Siemens Networks | robert.zaus@nsn.com | Rel-11 | CP-53 | Frederic | SAES2-CSFB |  |  |  |
| 1762 | 408 | **GCSMSC and GCR Redundancy for VGCS/VBS (Stage 2/3)** | 258d? | 2011-09-19 A | 2012-09-07 A | 100% | 2011-09-19 | 2012-09-07 | 258d? |  | C1 | 5680h | 5680h | RT_VGCS_Red | PCG-27 | Nokia Siemens Networks | robert.zaus@nsn.com | Rel-11 | CP-53 | Frederic | RT_VGCS_Red |  |  |  |
| 1763 | 408.1 | CT1 part of GCSMSC and GCR Redundancy for VGCS/VBS | 258d? | 2011-09-19 A | 2012-09-07 A | 100% | 2011-09-19 | 2012-09-07 | 258d? | finish no earlier than 2012-09-07 | C1 | 2048h | 2048h | RT_VGCS_Red | PCG-27 | Nokia Siemens Networks | robert.zaus@nsn.com | Rel-11 | CP-53 | Frederic |  |  |  |  |
| 1764 | 408.2 | Deleted - CT4 part of GCSMSC and GCR Redundancy for VGCS/VBS | 197d? | 2011-09-19 A | 2012-06-15 A | 100% | 2011-09-19 | 2012-06-15 | 197d? | finish no earlier than 2012-06-15 | C4 | 1568h | 1568h | RT_VGCS_Red | PCG-27 | Nokia Siemens Networks | robert.zaus@nsn.com | Rel-11 | CP-53 | Kimmo |  | PCG-29 | CP-56 |  |
| 1765 | 409 | Support of RFC 6140 in IMS | 203d? | 2011-12-02 A | 2012-09-07 A | 100% | 2011-12-02 | 2012-09-07 | 203d? | finish no earlier than 2012-09-07 | C1 | 1608h | 1608h | GINI | PCG-28 | Deutsche Telekom | martin.huelsemann@telekom.de | Rel-11 | CP-54 | Frederic | GINI |  |  |  |
| 1766 | 410 | **Enhancements for Multimedia Priority Service (MPS) – Gateway Control Priority** | 203d? | 2011-12-02 A | 2012-09-07 A | 100% | 2011-12-02 | 2012-09-07 | 203d? |  | C4; C3 | 6464h | 6464h | eMPS_Gateway | PCG-28 | Telcordia | Viqar Shaikh | Rel-11 | CP-54 | Kimmo | eMPS_Gateway |  |  | Public Safety (I-A) |
| 1767 | 410.1 | CT4 part of Enhancements for Multimedia Priority Service (MPS) – Gateway Control Priority | 202d? | 2011-12-02 A | 2012-09-07 A | 100% | 2011-12-02 | 2012-09-07 | 202d? | finish no earlier than 2012-09-07 | C4 | 1608h | 1608h | eMPS_Gateway | PCG-28 | Telcordia | Viqar Shaikh | Rel-11 | CP-54 | Kimmo |  |  |  | Public Safety (I-A) |
| 1768 | 410.2 | CT3 part of Enhancements for Multimedia Priority Service (MPS) – Gateway Control Priority | 202d? | 2011-12-02 A | 2012-09-07 A | 100% | 2011-12-02 | 2012-09-07 | 202d? | finish no earlier than 2012-09-07 | C3 | 1608h | 1608h | eMPS_Gateway | PCG-28 | Telcordia | Viqar Shaikh | Rel-11 | CP-54 | Adrian |  |  |  | Public Safety (I-A) |
| 1769 | 411 | Inter-IMS Network to Network Interface (II-NNI) enhancements: SIP timers applicability (Stage 3) | 138d? | 2012-03-02 A | 2012-09-07 A | 100% | 2012-03-02 | 2012-09-07 | 138d? | start no earlier than 2012-03-02 | C3 | 1088h | 1088h | NNI_timers | PCG-28 | Telecom Italia | antonio.ascolese@telecomitalia.it | Rel-11 | CP-55 | Adrian | NNI_timers |  |  |  |
| 1770 | 412 | AT commands for Universal Resource Identifier (URI) support | 188d? | 2012-06-15 A | 2013-03-01 A | 100% | 2012-06-15 | 2013-03-01 | 188d? | finish no earlier than 2013-03-01 | C1 | 1496h | 1496h | ATURI | PCG-29 | Intel | frank.kowalewski@intel.com | Rel-11 | CP-56 | Frederic | ATURI |  |  |  |
| 1771 | 413 | PS Additional Number (Stage 3) | 62d? | 2012-06-15 A | 2012-09-07 A | 100% | 2012-06-15 | 2012-09-07 | 62d? | finish no earlier than 2012-09-07 | C4 | 488h | 488h | PSAN | PCG-29 | Deutsche Telekom | Yvette.koza@t-mobile.at | Rel-11 | CP-56 | Kimmo | PSAN |  |  |  |
| 1772 | 414 | Generic IMS User Group Over Sh | 62d? | 2012-06-15 A | 2012-09-07 A | 100% | 2012-06-15 | 2012-09-07 | 62d? | finish no earlier than 2012-09-07 | C4 | 488h | 488h | GenUG_Sh | PCG-29 | Alcatel-Lucent | jean-jacques.trottin@alcatel-lucent.com | Rel-11 | CP-56 | Kimmo | GenUG_Sh |  |  |  |

Notes:
- 1747: CP#57 completed
- 1748: CP#57 completed / Impacted TSs and TRs: 23.218, 24.229, 24.930
- 1749: CP#65 completed / Impacted TSs and TRs: RFC 7315 (was draft-drage-sipping-rfc3455bis)
- 1750: CP#64 completed / Impacted TSs and TRs: RFC 7135 (was draft-polk-local-emergency-rph-namespace)
- 1751: CP#57 completed / Impacted TSs and TRs: 29.163, 29.165
- 1752: CP#64 Draft removed from 3GPP documentation / Impacted TSs and TRs: draft-avasarala-dispatch-comm-div-notification
- 1753: TSG#57, GP#55 completed. CT defined a generic solution (not only for GERAN) / Impacted TSs and TRs: GERAN
- 1754: SP#57 completed / Impacted TSs and TRs: 23.060, 23.251
- 1755: CP#57 completed
- 1756: CP#57 completed / Impacted TSs and TRs: 29.281
- 1757: CP#56 stopped (SA2 decided NO CT3 impact) / Impacted TSs and TRs: 29.212
- 1758: GP#55 completed. GP#51 approved WID / Impacted TSs and TRs: 48.018
- 1759: CP#57 completed. Stage 3 continuation of Rel-8 Feature SAES (3GPP System Architecture Evolution Specification - Evolved Packet System) UID_320005
- 1760: CP#57 completed / Impacted TSs and TRs: 23.122, 24.008, 24.167, 24.229, 24.301, 24.302, 24.303, 24.304, 24.305, 24.312, 29.018, 29.118
- 1761: CP#57 completed / Impacted TSs and TRs: 23.122, 24.008, 24.167, 24.229, 24.301, 24.302, 24.303, 24.304, 24.305, 24.312, 29.018, 29.118
- 1762: CP#57 completed. Stage 2/3 adding a CN internal functionality, not affecting Voice Group Call Service (VGCS)/VBS as perceived by service subscriber. Hence, no Stage 1 impact for VGCS/VBS (42.068, 42.069) / Impacted TSs and TRs: Stage 2/3
- 1763: CP#57 completed / Impacted TSs and TRs: 43.068, 43.069
- 1764: CP#56 stopped (no CT4 impact) / Impacted TSs and TRs: 29.002
- 1765: CP#57 completed. Stage 3. Support procedures and protocol extensions in RFC6140 "Registration for Multiple Phone Numbers in SIP" to IMS for complex UEs. Ensure co-existence with NGCN IP-PBX registration procedures already defined in IMS. / Impacted TSs and TRs: 24.229
- 1766: CP#57 completed. Stage 3. Stage 1 for MPS in 22.153. Details of any MGW actions for priority needs to be further studied within the scope of this WI. / Impacted TSs and TRs: Stage 3
- 1767: CP#57 completed / Impacted TSs and TRs: 23.333, 23.334, 29.232, 29.238, 29.332, 29.333, 29.334
- 1768: CP#57 completed / Impacted TSs and TRs: 29.162, 29.163, 29.292
- 1769: CP#57 completed / Impacted TSs and TRs: 29.165
- 1770: CP#59 completed. Define new AT cmd for URI addresses for IMS services (eg VoLTE). 27.007(AT cmd to control MT functions and GSM/UMTS/LTE network services from TE), 27.005(AT commands for SMS). Currently address types for AT cmd based on dialling# / Impacted TSs and TRs: 27.005, 27.007
- 1771: CP#57 completed. Stage 1 in Rel-11 SA1 TS 22.101 clause 17.7.3 (No Stage 2 needed since no architecture impact) / Impacted TSs and TRs: 23.003, 23.008, 29.002, 29.272, 29.230
- 1772: CP#57 completed / Impacted TSs and TRs: 29.364

| ID | WBS | Task | Duration | Start | Finish | Complete | Baseline start | Baseline finish | Baseline duration | Constraint | Resources | Work | Actual work | Acronym | PCG approved | WI rapporteur name | WI rapporteur e-mail | Release | TSG approved | MCC resp | Acronym_3GU_Export | PCG stopped | TSG stopped | Status Report |
| --- | --- | --- | --- | --- | --- | --- | --- | --- | --- | --- | --- | --- | --- | --- | --- | --- | --- | --- | --- | --- | --- | --- | --- | --- |
| 1773 | 415 | **IMS Operator Determined Call Barring** | 205d? | 2012-09-07 A | 2013-06-14 A | 100% | 2012-09-07 | 2013-06-14 | 205d? |  | C1; C4 | 5411.54h | 5411.54h | IODB | PCG-29 | Orange | Youssef.Chadli@Orange.com | Rel-11 | CP-57 | Frederic | IODB |  |  |  |
| 1774 | 415.1 | CT1 part of IMS Operator Determined Call Barring | 203d? | 2012-09-10 A | 2013-06-14 A | 100% | 2012-09-10 | 2013-06-14 | 203d? | finish no earlier than 2013-06-14 | C1 | 1616h | 1616h | IODB | PCG-29 | Orange | Youssef.Chadli@Orange.com | Rel-11 | CP-57 | Frederic |  |  |  |  |
| 1775 | 415.2 | CT4 part of IMS Operator Determined Call Barring | 69d? | 2012-09-07 A | 2013-03-12 A | 100% | 2012-09-07 | 2013-03-12 | 69d? | finish no earlier than 2012-12-07 | C4 | 515.54h | 515.54h | IODB | PCG-29 | Orange | Youssef.Chadli@Orange.com | Rel-11 | CP-57 | Kimmo |  |  |  |  |
| 1776 | 416 | **Enhanced T.38 FAX support (Stage 3)** | 69d? | 2012-09-06 A | 2012-12-07 A | 100% | 2012-09-06 | 2012-12-07 | 69d? |  | C3; C1; C4 | 2728h | 2728h | MMTel_T.38_FAX | PCG-29 | NEC | Naoaki Suzuki (n-suzuki@en.jp.nec.com) | Rel-11 | CP-57 | Adrian | MMTel_T.38_FAX |  |  |  |
| 1777 | 416.1 | CT3 part of Enhanced T.38 FAX support | 68d? | 2012-09-07 A | 2012-12-07 A | 100% | 2012-09-07 | 2012-12-07 | 68d? | finish no earlier than 2012-12-07 | C3 | 528h | 528h | MMTel_T.38_FAX | PCG-29 | NEC | Naoaki Suzuki (n-suzuki@en.jp.nec.com) | Rel-11 | CP-57 | Adrian |  |  |  |  |
| 1778 | 416.2 | CT1 part of Enhanced T.38 FAX support | 67d? | 2012-09-07 A | 2012-12-07 A | 100% | 2012-09-07 | 2012-12-07 | 67d? | finish no earlier than 2012-12-07 | C1 | 528h | 528h | MMTel_T.38_FAX | PCG-29 | NEC | Naoaki Suzuki (n-suzuki@en.jp.nec.com) | Rel-11 | CP-57 | Frederic |  |  |  |  |
| 1779 | 416.3 | CT4 part of Enhanced T.38 FAX support | 2d? | 2012-09-06 A | 2012-09-07 A | 100% | 2012-09-06 | 2012-09-07 | 2d? | finish no earlier than 2012-12-07 | C4 | 16h | 16h | MMTel_T.38_FAX | PCG-29 | NEC | Naoaki Suzuki (n-suzuki@en.jp.nec.com) | Rel-11 | CP-57 | Kimmo |  |  |  |  |
| 1780 | 417 | **Deleted - Enhancement of the Protocols for SMS over SGs (Stage 3)** | 142d? | 2011-12-02 A | 2012-06-15 A | 100% | 2011-12-02 | 2012-06-15 | 142d? |  | C4; C1 | 5664h | 5664h | PROTOC_SMS_SGs | PCG-28 | Alcatel-Lucent | jean-jacques.trottin@alcatel-lucent.com | Rel-11 | CP-54 | Kimmo | PROTOC_SMS_SGs | PCG-29 | CP-56 |  |
| 1781 | 417.1 | Deleted - TR Study on enhancement of protocols for SMS service over SGs | 142d? | 2011-12-02 A | 2012-06-15 A | 100% | 2011-12-02 | 2012-06-15 | 142d? | finish no earlier than 2012-06-15 | C4 | 1128h | 1128h | PROTOC_SMS_SGs | PCG-28 | Alcatel-Lucent | jean-jacques.trottin@alcatel-lucent.com | Rel-11 | CP-54 | Kimmo |  | PCG-29 | CP-56 |  |
| 1782 | 417.2 | Deleted - CT4 part of Enhancement of the Protocols for SMS over SGs | 142d? | 2011-12-02 A | 2012-06-15 A | 100% | 2011-12-02 | 2012-06-15 | 142d? | finish no earlier than 2012-06-15 | C4 | 1128h | 1128h | PROTOC_SMS_SGs | PCG-28 | Alcatel-Lucent | jean-jacques.trottin@alcatel-lucent.com | Rel-11 | CP-54 | Kimmo |  | PCG-29 | CP-56 |  |
| 1783 | 417.3 | Deleted - CT1 part of Enhancement of the Protocols for SMS over SGs | 142d? | 2011-12-02 A | 2012-06-15 A | 100% | 2011-12-02 | 2012-06-15 | 142d? | finish no earlier than 2012-06-15 | C1 | 1136h | 1136h | PROTOC_SMS_SGs | PCG-28 | Alcatel-Lucent | jean-jacques.trottin@alcatel-lucent.com | Rel-11 | CP-54 | Frederic |  | PCG-29 | CP-56 |  |
| 1784 | 418 | **Full Support of Multi-Operator Core Network by GERAN** | 584d? | 2011-03-04 A | 2013-05-17 A | 100% | 2011-03-04 | 2013-05-17 | 584d? |  | G2; S2; C1 | 31293.3h | 31293.3h | Full_MOCN-GERAN | PCG-26 | Alcatel-Lucent | michel.robert@alcatel-lucent.com | Rel-11 | GP-49 | Paolo | Full_MOCN-GERAN |  |  |  |
| 1785 | 418.1 | GERAN part of Full Support of Multi-Operator Core Network by GERAN | 584d? | 2011-03-04 A | 2013-05-17 A | 100% | 2011-03-04 | 2013-05-17 | 584d? | finish no earlier than 2013-06-07 | G2 | 4656.4h | 4656.4h | Full_MOCN-GERAN | PCG-26 | Alcatel-Lucent | michel.robert@alcatel-lucent.com | Rel-11 | GP-49 | Gert |  |  |  |  |
| 1786 | 418.2 | Stage 2 for Full Support of Multi-Operator Core Network by GERAN | 160.8d? | 2011-06-08 A | 2012-03-07 A | 100% | 2011-06-08 | 2012-03-07 | 160.8d? | finish no earlier than 2012-03-07 | S2 | 1278.4h | 1278.4h | Full_MOCN-GERAN | PCG-26 | Alcatel-Lucent | nicolas.drevon@alcatel-lucent.com | Rel-11 | GP-49 | Maurice |  |  |  |  |
| 1787 | 418.3 | **CN Stage 3 for Full Support of Multi-Operator Core Network by GERAN** | 403d? | 2011-06-03 A | 2012-12-07 A | 100% | 2011-06-03 | 2012-12-07 | 403d? |  | C1; C4 | 9838.51h | 9838.51h | Full_MOCN-GERAN | PCG-26 | Alcatel-Lucent | jennifer.liu@alcatel-lucent.com | Rel-11 | GP-49 | Frederic |  |  |  |  |
| 1788 | 418.3.1 | CT1 part of CN Stage 3 for Full Support of Multi-Operator Core Network by GERAN | 362.8d? | 2011-06-03 A | 2012-12-07 A | 100% | 2011-06-03 | 2012-12-07 | 362.8d? | finish no earlier than 2012-12-07 | C1 | 2886.51h | 2886.51h | Full_MOCN-GERAN | PCG-26 | Alcatel-Lucent | jennifer.liu@alcatel-lucent.com | Rel-11 | GP-49 | Frederic |  |  |  |  |
| 1789 | 418.3.2 | CT4 part of CN Stage 3 for Full Support of Multi-Operator Core Network by GERAN | 64d? | 2012-06-13 A | 2012-09-07 A | 100% | 2012-06-13 | 2012-09-07 | 64d? | finish no earlier than 2012-09-07 | C4 | 504h | 504h | Full_MOCN-GERAN | PCG-29 | Alcatel-Lucent | michel.robert@alcatel-lucent.com | Rel-11 | GP-54 | Kimmo |  |  |  |  |
| 1790 | 418.4 | Stage 2 for Gateway Core Network Sharing for GERAN | 192d? | 2012-06-18 A | 2013-03-06 A | 100% | 2012-06-18 | 2013-03-06 | 192d? | finish no earlier than 2013-03-06 | S2 | 1504h | 1504h | Full_MOCN-GERAN-GWCN | PCG-29 | Vodafone | chris.pudney@vodafone.com | Rel-11 | SP-56 | Maurice | Full_MOCN-GERAN-GWCN |  |  |  |
| 1791 | 419 | **Medium range/local area requirements for multicarrier BTS** | 264d? | 2011-11-25 A | 2012-11-23 A | 100% | 2011-11-25 | 2012-11-23 | 264d? |  | G1 | 6296h | 6296h | MRLA | PCG-28 | Ericsson | Eric Nordström | Rel-11 | GP-52 | Paolo | MRLA |  |  |  |
| 1792 | 419.1 | Core part: Medium range/local area requirements for multicarrier BTS | 263d? | 2011-11-25 A | 2012-11-23 A | 100% | 2011-11-25 | 2012-11-23 | 263d? | finish no earlier than 2012-11-23 | G1 | 2096h | 2096h | MRLA-Core | PCG-28 | Ericsson | Eric Nordström | Rel-11 | GP-52 | Paolo | MRLA-Core |  |  |  |
| 1793 | 419.2 | Perf. part: Medium range/local area requirements for multicarrier BTS | 262d? | 2011-11-28 A | 2012-11-23 A | 100% | 2011-11-28 | 2012-11-23 | 262d? | finish no earlier than 2012-11-23 | G1 | 2088h | 2088h | MRLA-Perf | PCG-28 | Ericsson | Eric Nordström | Rel-11 | GP-52 | Paolo | MRLA-Perf |  |  |  |
| 1794 | 420 | Domain Specific Access Control in GERAN | 131d? | 2012-03-05 A | 2012-08-31 A | 100% | 2012-03-05 | 2012-08-31 | 131d? | finish no earlier than 2012-08-31 | G2 | 1048h | 1048h | GDSAC | PCG-28 | Vodafone | chris.pudney@vodafone.com | Rel-11 | GP-53 | Gert | GDSAC |  |  |  |
| 1795 | 421 | **Extending 850 MHz Upper Band (814 – 849 MHz)** | 589d? | 2010-12-10 A | 2013-03-01 A | 100% | 2010-12-10 | 2013-03-01 | 589d? |  | R4; R2; R3; R5 | 33352h | 33352h | e850_UB | PCG-26 | Sprint | John.J.Humbert@Sprint.com | Rel-11 | RP-50 | Issam | e850_UB |  |  |  |
| 1796 | 421.1 | Core part: Extending 850 MHz Upper Band (814 – 849 MHz) | 324d? | 2010-12-10 A | 2012-03-02 A | 100% | 2010-12-10 | 2012-03-02 | 324d? | finish no earlier than 2012-03-02 | R4; R2; R3 | 7776h | 7776h | e850_UB-Core | PCG-26 | Sprint | John.J.Humbert@Sprint.com | Rel-11 | RP-50 | Issam | e850_UB-Core |  |  | RP-120075 |
| 1797 | 421.2 | Perf. part: Extending 850 MHz Upper Band (814 – 849 MHz) | 324d? | 2010-12-10 A | 2012-03-02 A | 100% | 2010-12-10 | 2012-03-02 | 324d? | finish no earlier than 2012-03-02 | R4 | 2592h | 2592h | e850_UB-Perf | PCG-26 | Sprint | John.J.Humbert@Sprint.com | Rel-11 | RP-50 | Issam | e850_UB-Perf |  |  | RP-120076 |
| 1798 | 421.3 | Test part: Extending 850 MHz Upper Band (814 – 849 MHz) | 517d? | 2011-03-18 A | 2013-03-01 A | 100% | 2011-03-18 | 2013-03-01 | 517d? | finish no earlier than 2013-03-01 | R5 | 4136h | 4136h | e850_UB-UEConTest | PCG-26 | Sprint | John.J.Humbert@Sprint.com | Rel-11 | RP-51 | Ingbert | e850_UB-UEConTest |  |  | RP-130043 |

Notes:
- 1773: LS_in C4-121615 GSMA IREG RILTE concluded that TS 22.041 clause 5.4 Stage 1 requirements are not covered by stage 3 specifications
- 1774: CP#60 completed. Handling of premium rate numbers remained OPEN in Rel-11 (shifted to Rel-12). CP-130384 LS_out sent to SA1 / GSMA informing this TSG CT decision. / Impacted TSs and TRs: New TS 24.315
- 1775: CP#58 completed / Impacted TSs and TRs: 23.008 , 23.015 , 29.328 , 29.329 , 29.364
- 1776: CP#58 completed. Linked to Rel-8 Feature: IMS Multimedia Telephony Service (IMS-MMTel) UID_7038. SA1 added FAX stage 1 requirement only in Rel-10 under TEI10 to TS 22.173 (CR#0064)
- 1777: CP#58 completed / Impacted TSs and TRs: 29.163
- 1778: CP#58 completed / Impacted TSs and TRs: 24.229
- 1779: CP#57 completed / Impacted TSs and TRs: 29.332
- 1780: CP#56 stopped. Reason: Protocols for SMS over SGs is replaced by the SIMTC SMS in MME solution (as solution not only for MTC user but for general subscribers) / Impacted TSs and TRs: Stage 3
- 1781: CP#56 stopped (abandonned new TR 29.818) / Impacted TSs and TRs: new TR 29.818
- 1782: CP#56 stopped (abandonned new TS 29.218 Diameter based protocols for SMS service over SGs) / Impacted TSs and TRs: 29.305, new TS 29.218
- 1783: CP#56 stopped / Impacted TSs and TRs: 23.040, 24.011, 43.068
- 1784: GP#58 completed. GP#49 approved WID. Standardization of management of MOCN supporting MSs/UEs in GERAN. Continuation of Rel-10 MOCN-GERAN UID_490001 / Impacted TSs and TRs: GERAN
- 1785: GP#58 completed. GP#49 approved WID / Impacted TSs and TRs: 44.018, 44.060, 45.002, 45.008, 48.008, 48.018
- 1786: SP#55 completed / Impacted TSs and TRs: 23.251, 23.272
- 1787: CP#58 completed
- 1788: CP#58 completed / Impacted TSs and TRs: 24.008
- 1789: CP#57 completed / Impacted TSs and TRs: 23.003
- 1790: SP#59 completed. (23.251CR0062R2 as TEI11. TS 23.251 specifies both MOCN and GWCN for E-UTRAN and UTRAN, but GWCN is not yet supported on GERAN. Extend Full_MOCN-GERAN to also cover GWCN GERAN / Impacted TSs and TRs: 23.251
- 1791: GP#56 completed. GP#52 approved WID / Impacted TSs and TRs: GERAN
- 1792: Stage 3. GP#56 completed. GP#52 approved WID / Impacted TSs and TRs: 45.005
- 1793: Test spec. GP#56 completed. GP#52 approved WID / Impacted TSs and TRs: 51.021
- 1794: GP#55 completed. GP#53 approved WID. Work is dependent upon Full_MOCN-GERAN (UID_510001) / Impacted TSs and TRs: GERAN 44.018
- 1795: Stage 3. Triggered by R4 Rel-10 LTE TR 37.806 Study on Extending 850 MHz (UID_440016) / Impacted TSs and TRs: UTRA, LTE
- 1796: RP#55 completed / Impacted TSs and TRs: 25.101, 25.104, 25.113, 25.133, 25.141, 25.461, 25.466, 36.101, 36.104, 36.113, 36.124, 36.133, 36.141, 36.307, 36.331, 37.104, 37.113, 37.141
- 1797: RP#55 completed / Impacted TSs and TRs: 25.101, 25.104, 25.113, 25.133, 25.141, 25.461, 25.466, 36.101, 36.104, 36.124, 36.133, 36.141, 36.307, 36.331, 37.104, 37.113, 37.141
- 1798: RP#59 completed / Impacted TSs and TRs: 34.108, 34.121-1, 34.121-2, 34.123-1, 34.123-2, 34.123-3, 36.508, 36.521-1, 36.521-2, 36.521-3, 36.523-1, 36.523-2, 36.523-3

| ID | WBS | Task | Duration | Start | Finish | Complete | Baseline start | Baseline finish | Baseline duration | Constraint | Resources | Work | Actual work | Acronym | PCG approved | WI rapporteur name | WI rapporteur e-mail | Release | TSG approved | MCC resp | Special Focus Doc | Acronym_3GU_Export | Status Report |
| --- | --- | --- | --- | --- | --- | --- | --- | --- | --- | --- | --- | --- | --- | --- | --- | --- | --- | --- | --- | --- | --- | --- | --- |
| 1799 | 422 | **Further Self Optimizing Networks (SON) enhancements** | 325d? | 2011-09-19 A | 2012-12-07 A | 100% | 2011-09-19 | 2012-12-07 | 325d? |  | R3; R2 | 10400h | 10400h | SONenh2_LTE_UTRA | PCG-27 | Nokia Siemens Networks | krzysztof.kordybach@nsn.com | Rel-11 | RP-53 | Juha | SON | SONenh2_LTE_UTRA |  |
| 1800 | 422.1 | Core part: Further Self Optimizing Networks (SON) enhancements | 325d? | 2011-09-19 A | 2012-12-07 A | 100% | 2011-09-19 | 2012-12-07 | 325d? | finish no earlier than 2012-12-07 | R3; R2 | 5200h | 5200h | SONenh2_LTE_UTRA-Core | PCG-27 | Nokia Siemens Networks | krzysztof.kordybach@nsn.com | Rel-11 | RP-53 | Juha | SON | SONenh2_LTE_UTRA-Core | RP-121557 |
| 1801 | 423 | **Enhancement of Minimization of Drive Tests for E-UTRAN and UTRAN** | 590d? | 2011-09-19 A | 2013-12-06 A | 100% | 2011-09-19 | 2013-12-06 | 590d? |  | R2; R1; R3; R4; R5 | 35608h | 35608h | eMDT_UMTSLTE | PCG-27 | MediaTek | Johan Johansson | Rel-11 | RP-53 | Yong-Jun |  | eMDT_UMTSLTE |  |
| 1802 | 423.1 | Core part: Enhancement of Minimization of Drive Tests for E-UTRAN and UTRAN | 325d? | 2011-09-19 A | 2012-12-07 A | 100% | 2011-09-19 | 2012-12-07 | 325d? | finish no earlier than 2012-12-07 | R2; R1; R3; R4 | 10400h | 10400h | eMDT_UMTSLTE-Core | PCG-27 | MediaTek | Johan Johansson | Rel-11 | RP-53 | Yong-Jun |  | eMDT_UMTSLTE-Core | RP-121556 |
| 1803 | 423.2 | Test part: Enhancement of Minimization of Drive Tests for E-UTRAN and UTRAN | 202d? | 2013-03-04 A | 2013-12-06 A | 100% | 2013-03-04 | 2013-12-06 | 202d? | finish no earlier than 2013-12-06 | R5 | 1608h | 1608h | eMDT_UMTSLTE-UEConTest | PCG-30 | NTT DoCoMo | masahiro.tamaoki.eu@nttdocomo.com | Rel-11 | RP-59 | Ingbert |  | eMDT_UMTSLTE-UEConTest | RP-131447 |
| 1804 | 424 | **Network Energy Saving for E-UTRAN** | 258d? | 2011-09-19 A | 2012-09-07 A | 100% | 2011-09-19 | 2012-09-07 | 258d? |  | R3; GP | 6224h | 6224h | Netw_Energy_LTE | PCG-27 | China Mobile | yangning@chinamobile.com | Rel-11 | RP-53 | Juha |  | Netw_Energy_LTE |  |
| 1805 | 424.1 | Core part: Network Energy Saving for E-UTRAN | 257d? | 2011-09-19 A | 2012-09-07 A | 100% | 2011-09-19 | 2012-09-07 | 257d? | finish no earlier than 2012-09-07 | R3 | 2056h | 2056h | Netw_Energy_LTE-Core | PCG-27 | China Mobile | yangning@chinamobile.com | Rel-11 | RP-53 | Juha |  | Netw_Energy_LTE-Core | RP-121016 |
| 1806 | 424.2 | GERAN part: Network Energy Saving for E-UTRAN | 5d? | 2012-08-27 A | 2012-08-31 A | 100% | 2012-08-27 | 2012-08-31 | 5d? | finish no earlier than 2012-08-31 | GP | 40h | 40h |  | PCG-29 | Alcatel-Lucent | marguerite.woch@alcatel-lucent.com | Rel-11 | GP-55 | Paolo |  |  |  |
| 1807 | 425 | **E-UTRA medium range and MSR medium range/local area BS class requirements** | 325d? | 2011-09-19 A | 2012-12-07 A | 100% | 2011-09-19 | 2012-12-07 | 325d? |  | R4; G1 | 12432h | 12432h | medBS_class_LTE_MSR | PCG-27 | Ericsson | johan.skold@ericsson.com | Rel-11 | RP-53 | Issam |  | medBS_class_LTE_MSR |  |
| 1808 | 425.1 | Core part: E-UTRA medium range and MSR medium range/local area BS class requirements | 323d? | 2011-09-19 A | 2012-12-07 A | 100% | 2011-09-19 | 2012-12-07 | 323d? | finish no earlier than 2012-12-07 | R4 | 2576h | 2576h | medBS_class_LTE_MSR-Core | PCG-27 | Ericsson | johan.skold@ericsson.com | Rel-11 | RP-53 | Issam |  | medBS_class_LTE_MSR-Core | RP-121558 |
| 1809 | 425.2 | Perf. part: E-UTRA medium range and MSR medium range/local area BS class requirements | 321d? | 2011-09-23 A | 2012-12-07 A | 100% | 2011-09-23 | 2012-12-07 | 321d? | finish no earlier than 2012-12-07 | R4 | 2568h | 2568h | medBS_class_LTE_MSR-Perf | PCG-27 | Ericsson | johan.skold@ericsson.com | Rel-11 | RP-53 | Issam |  | medBS_class_LTE_MSR-Perf | RP-121559 |
| 1810 | 425.3 | GERAN part: E-UTRA medium range and MSR medium range/local area BS class requirements | 261d? | 2011-11-28 A | 2012-11-23 A | 100% | 2011-11-28 | 2012-11-23 | 261d? | finish no earlier than 2012-11-23 | G1 | 2088h | 2088h | medBS_class_LTE_MSR-GERAN | PCG-28 | Ericsson | Eric Nordström | Rel-11 | GP-52 | Paolo |  | medBS_class_LTE_MSR-GERAN |  |
| 1811 | 426 | **RF Requirements for Multi-Band and Multi-Standard Radio (MB-MSR) Base Station** | 553.1d? | 2012-02-06 A | 2014-03-06 A | 100% | 2012-02-06 | 2014-03-06 | 553.1d? |  | R4; G1 | 20915.2h | 20915.2h | MB_MSR_RF | PCG-28 | Huawei | Liu Ye (leo.liuye@huawei.com) | Rel-11 | RP-55 | Issam |  | MB_MSR_RF |  |
| 1812 | 426.1 | Core part: RF Requirements for Multi-Band and Multi-Standard Radio (MB-MSR) Base Station | 223.1d? | 2012-02-06 A | 2012-12-07 A | 100% | 2012-02-06 | 2012-12-07 | 223.1d? | finish no earlier than 2012-12-07 | R4; G1 | 3569.6h | 3569.6h | MB_MSR_RF-Core | PCG-28 | Huawei | Liu Ye (leo.liuye@huawei.com) | Rel-11 | RP-55 | Issam |  | MB_MSR_RF-Core | RP-121985 |
| 1813 | 426.2 | Perf. part: RF Requirements for Multi-Band and Multi-Standard Radio (MB-MSR) Base Station | 531d? | 2012-03-08 A | 2014-03-06 A | 100% | 2012-03-08 | 2014-03-06 | 531d? | finish no earlier than 2014-03-06 | R4; G1 | 8496h | 8496h | MB_MSR_RF-Perf | PCG-28 | Huawei | Liu Ye (leo.liuye@huawei.com) | Rel-11 | RP-55 | Issam |  | MB_MSR_RF-Perf | RP-140064 |
| 1814 | 427 | **Further enhancements to H(e)NB mobility - Part 1** | 129d? | 2012-06-15 A | 2012-12-07 A | 100% | 2012-06-15 | 2012-12-07 | 129d? |  | R3; R2 | 4128h | 4128h | EHNB_enh1 | PCG-29 | Alcatel-Lucent | Martin.Warner@alcatel-lucent.com | Rel-11 | RP-56 | Juha | HNB | EHNB_enh1 |  |
| 1815 | 427.1 | Core part: Further enhancements to H(e)NB mobility - Part 1 | 129d? | 2012-06-15 A | 2012-12-07 A | 100% | 2012-06-15 | 2012-12-07 | 129d? | finish no earlier than 2012-12-07 | R3; R2 | 2064h | 2064h | EHNB_enh1-Core | PCG-29 | Alcatel-Lucent | Martin.Warner@alcatel-lucent.com | Rel-11 | RP-56 | Juha | HNB | EHNB_enh1-Core | RP-121563 |
| 1816 | 428 | **Further enhancements to H(e)NB mobility - Part 2** | 127d? | 2012-06-19 A | 2012-12-07 A | 100% | 2012-06-19 | 2012-12-07 | 127d? |  | R3; R2 | 4064h | 4064h | EHNB_enh2 | PCG-29 | Alcatel-Lucent | Martin.Warner@alcatel-lucent.com | Rel-11 | RP-56 | Juha | HNB | EHNB_enh2 |  |
| 1817 | 428.1 | Core part: Further enhancements to H(e)NB mobility - Part 2 | 127d? | 2012-06-19 A | 2012-12-07 A | 100% | 2012-06-19 | 2012-12-07 | 127d? | finish no earlier than 2012-12-07 | R3; R2 | 2032h | 2032h | EHNB_enh2-Core | PCG-29 | Alcatel-Lucent | Martin.Warner@alcatel-lucent.com | Rel-11 | RP-56 | Juha | HNB | EHNB_enh2-Core | RP-121564 |
| 1818 | 429 | **Network-Based Positioning Support for LTE** | 1391d? | 2009-03-05 A | 2014-06-13 A | 100% | 2009-03-05 | 2014-06-13 | 1391d? |  | R2; R1; R3; R4 | 91464h | 91464h | LCS_LTE-NBPS | PCG-22 | TruePosition | terri.brooks@trueposition.com | Rel-11 | RP-43 | Yong-Jun |  | LCS_LTE-NBPS |  |
| 1819 | 429.1 | Core part: Network-Based Positioning Support for LTE | 1125d? | 2009-03-05 A | 2013-06-12 A | 100% | 2009-03-05 | 2013-06-12 | 1125d? | finish no earlier than 2013-06-12 | R2; R1; R3; R4 | 36000h | 36000h | LCS_LTE-NBPS-Core | PCG-22 | TruePosition | terri.brooks@trueposition.com | Rel-11 | RP-43 | Yong-Jun |  | LCS_LTE-NBPS-Core | RP-130483 |
| 1820 | 429.2 | Perf. part: Network-Based Positioning Support for LTE | 1377d? | 2009-03-24 A | 2014-06-13 A | 100% | 2009-03-24 | 2014-06-13 | 1377d? | finish no earlier than 2014-06-13 | R4 | 11016h | 11016h | LCS_LTE-NBPS-Perf | PCG-22 | TruePosition | terri.brooks@trueposition.com | Rel-11 | RP-43 | Yong-Jun |  | LCS_LTE-NBPS-Perf | RP-140626 |
| 1821 | 430 | **Service continuity improvements for MBMS for LTE** | 993d? | 2010-06-04 A | 2014-03-06 A | 100% | 2010-06-04 | 2014-03-06 | 993d? |  | R2; R3; R5 | 35496h | 35496h | MBMS_LTE_SC | PCG-25 | Huawei | David.Lecompte@huawei.com | Rel-11 | RP-48 | Yong-Jun |  | MBMS_LTE_SC |  |
| 1822 | 430.1 | Core part: Service continuity improvements for MBMS for LTE | 596d? | 2010-06-04 A | 2012-09-07 A | 100% | 2010-06-04 | 2012-09-07 | 596d? | finish no earlier than 2012-09-07 | R2; R3 | 9536h | 9536h | MBMS_LTE_SC-Core | PCG-25 | Huawei | David.Lecompte@huawei.com | Rel-11 | RP-48 | Yong-Jun |  | MBMS_LTE_SC-Core | RP-121001 |
| 1823 | 430.2 | Test part: Service continuity improvements for MBMS for LTE | 266d? | 2013-03-04 A | 2014-03-06 A | 100% | 2013-03-04 | 2014-03-06 | 266d? | finish no earlier than 2014-03-06 | R5 | 2128h | 2128h | MBMS_LTE_SC-UEConTest | PCG-30 | Ericsson | leif.mattisson@ericsson.com | Rel-11 | RP-59 | Ingbert |  | MBMS_LTE_SC-UEConTest | RP-140074 |

Notes:
- 1799: Stage 1/2/3 / Impacted TSs and TRs: UTRA, LTE
- 1800: RP#58 completed / Impacted TSs and TRs: 25.331, 25.401, 25.410, 25.413, 25.423, 25.433, 36.300, 36.331, 36.413, 36.423
- 1801: Stage 2/3 / Impacted TSs and TRs: UTRA, LTE
- 1802: RP#58 completed / Impacted TSs and TRs: 25.133, 25.123, 25.304, 25.331, 25.413, 25.423, 36.133, 36.304, 36.306, 36.331, 36.413, 36.423, 37.320, 36.300
- 1803: RP#62 completed / Impacted TSs and TRs: 34.108, 34.109, 34.123-1, 34.123-2, 34.123-3, 36.508, 36.509, 36.523-1, 36.523-2, 36.523-3
- 1804: Stage 2/3 / Impacted TSs and TRs: LTE, GERAN
- 1805: RP#57 completed. Inter-RAT aspect can affect UTRA and GERAN as well / Impacted TSs and TRs: 25.413, 36.300, 36.413, 36.423
- 1806: GP#55 approved WID and completed. Stage 3. Changes in RIM protocol and in SON Transfer RIM application to provide support for Energy Savings Indication feature / Impacted TSs and TRs: 48.018 [Serving GPRS Support Node (SGSN); BSS GPRS protocol (BSSGP)]
- 1807: Stage 3. GERAN BS RF requirements specs need aligned with RAN4 ongoing Rel-11 Feature UID_530037 E-UTRA medium range and MSR medium range/local area BS class requirements (medBS_class_LTE_MSR) / Impacted TSs and TRs: UTRA, LTE, GERAN
- 1808: RP#58 completed. TR 37.809 v200 for Approval / Impacted TSs and TRs: 25.104, 36.104, 37.104, new TR 37.809
- 1809: RP#58 completed / Impacted TSs and TRs: 25.141, 36.141, 37.141
- 1810: GP#56 completed. GP#52 approved WID / Impacted TSs and TRs: 45.005, 51.021
- 1811: - / Impacted TSs and TRs: UTRA, LTE, GERAN
- 1812: RP#58 completed / Impacted TSs and TRs: 25.104, 25.105, 36.104, 37.104, new TR 37.812
- 1813: RP#63 completed / Impacted TSs and TRs: 25.141, 25.142, 36.141, 37.141
- 1814: Stage 2/3. Triggered by FS_EHNB_enh (UTRA, LTE TR 37.803 under AI 12.3.2). Compare also Rel-10 WI HNB_HENB_mob_enh RP-110183 / Impacted TSs and TRs: UTRA, LTE
- 1815: RP#58 completed / Impacted TSs and TRs: 25.413, 25.467, 25.469, 36.300, 36.413, 36.423
- 1816: Stage 2/3. Legacy UE Handling (X2-GW, 20% complete, moved to Rel-12 UID_580030). Triggered by FS_EHNB_enh (UTRA, LTE TR 37.803 under AI 12.3.2) / Impacted TSs and TRs: UTRA, LTE
- 1817: RP#58 completed Legacy UE Handling (X2-GW, 20% complete, moved to Rel-12 UID_580030). Updated WID RP-121147=>RP-121712 / Impacted TSs and TRs: 25.413, 25.467, 25.469, 25.471
- 1818: - / Impacted TSs and TRs: LTE
- 1819: RP#60 completed / Impacted TSs and TRs: 36.214, 36.300, 36.305, 36.401, 36.413, 36.455, new TS (36.111, 36.456, 36.457, 36.458, 36.459)
- 1820: RP#64 completed. TS 36.112v100 for 1-step Approval / Impacted TSs and TRs: 36.111, new TS 36.112
- 1821: - / Impacted TSs and TRs: LTE
- 1822: RP#57 completed / Impacted TSs and TRs: 25.446, 36.300, 36.304, 36.321, 36.322, 36.323, 36.331, 36.440, 36.441, 36.442, 36.443, 36.444, 36.445
- 1823: RP#63 completed / Impacted TSs and TRs: 36.508, 36.523-1, 36.523-2, 36.523-3

| ID | WBS | Task | Duration | Start | Finish | Complete | Remaining | Baseline start | Baseline finish | Baseline duration | Total slack | Constraint | Resources | Work | Actual work | Acronym | PCG approved | WI rapporteur name | WI rapporteur e-mail | Release | TSG approved | MCC resp | Acronym_3GU_Export | Status Report | Special Focus Doc |
| --- | --- | --- | --- | --- | --- | --- | --- | --- | --- | --- | --- | --- | --- | --- | --- | --- | --- | --- | --- | --- | --- | --- | --- | --- | --- |
| 1824 | 431 | **Further Enhanced Non CA-based ICIC for LTE** | 991d? | 2011-03-22 A | 2014-12-15 | 99% | 0d? | 2011-03-22 | 2014-09-12 | 922d? | 0d |  | R1; R2; R3; R4; R5 | 63112h | 63086.7h | eICIC_enh_LTE | PCG-26 | China Mobile | ShenXiaodong@chinamobile.com | Rel-11 | RP-51 | Patrick | eICIC_enh_LTE |  |  |
| 1825 | 431.1 | Core part: Further Enhanced Non CA-based ICIC for LTE | 456d? | 2011-03-22 A | 2012-12-07 A | 100% |  | 2011-03-22 | 2012-12-07 | 456d? |  | finish no earlier than 2012-12-07 | R1; R2; R3; R4 | 14592h | 14592h | eICIC_enh_LTE-Core | PCG-26 | China Mobile | ShenXiaodong@chinamobile.com | Rel-11 | RP-51 | Patrick | eICIC_enh_LTE-Core | RP-121986 |  |
| 1826 | 431.2 | Perf. part: Further Enhanced Non CA-based ICIC for LTE | 715d? | 2011-03-23 A | 2013-12-06 A | 100% |  | 2011-03-23 | 2013-12-06 | 715d? |  | finish no earlier than 2013-12-06 | R4 | 5720h | 5720h | eICIC_enh_LTE-Perf | PCG-26 | China Mobile | ShenXiaodong@chinamobile.com | Rel-11 | RP-51 | Issam | eICIC_enh_LTE-Perf | RP-131463 |  |
| 1827 | 431.3 | Test part: Further Enhanced Non CA-based ICIC for LTE | 395d? | 2013-06-15 A | 2014-12-15 A | 100% |  | 2013-06-18 | 2014-09-12 | 326d? |  | finish no earlier than 2014-12-15 | R5 | 3160h | 3160h | eICIC_enh_LTE-UEConTest | PCG-31 | ZTE | Carolyn Taylor (carolyn.tayl@zte.com.cn) | Rel-11 | RP-60 | Ingbert | eICIC_enh_LTE-UEConTest | RP-141847 |  |
| 1828 | 432 | **New Band LTE Downlink FDD 716-728 MHz (Band 29, Carrier Aggregation of Band 2 and Band 29 and of Band 4 and Band 29)** | 456d? | 2011-03-22 A | 2012-12-07 A | 100% |  | 2011-03-22 | 2012-12-07 | 456d? |  |  | R4 | 10880h | 10880h | LTE_DL_FDD700 | PCG-26 | AT&T | marc.grant@att.com | Rel-11 | RP-51 | Issam | LTE_DL_FDD700 |  | CA |
| 1829 | 432.1 | Core part: New Band LTE Downlink FDD 716-728 MHz (Band 29), Carrier Aggregation of Band 2 and Band 29 and of Band 4 and Band 29 | 453d? | 2011-03-22 A | 2012-12-07 A | 100% |  | 2011-03-22 | 2012-12-07 | 453d? |  | finish no earlier than 2012-12-07 | R4 | 3624h | 3624h | LTE_DL_FDD700-Core | PCG-26 | AT&T | marc.grant@att.com | Rel-11 | RP-51 | Issam | LTE_DL_FDD700-Core | RP-121604 |  |
| 1830 | 432.2 | Perf. part: New Band LTE Downlink FDD 716-728 MHz (Band 29), Carrier Aggregation of Band 2 and Band 29 and of Band 4 and Band 29 | 451d? | 2011-03-29 A | 2012-12-07 A | 100% |  | 2011-03-29 | 2012-12-07 | 451d? |  | finish no earlier than 2012-12-07 | R4 | 3608h | 3608h | LTE_DL_FDD700-Perf | PCG-26 | AT&T | marc.grant@att.com | Rel-11 | RP-51 | Issam | LTE_DL_FDD700-Perf | RP-121605 |  |
| 1831 | 433 | **LTE RAN Enhancements for Diverse Data Applications** | 657d? | 2011-03-18 A | 2013-09-06 A | 100% |  | 2011-03-18 | 2013-09-06 | 657d? |  |  | R2; R5 | 15248h | 15248h | LTE_eDDA | PCG-26 | BlackBerry | Gordon Young (gyoung@rim.com) | Rel-11 | RP-51 | Yong-Jun | LTE_eDDA |  |  |
| 1832 | 433.1 | Core part: LTE RAN Enhancements for Diverse Data Applications | 456d? | 2011-03-18 A | 2012-12-07 A | 100% |  | 2011-03-18 | 2012-12-07 | 456d? |  | finish no earlier than 2012-12-07 | R2 | 3648h | 3648h | LTE_eDDA-Core | PCG-26 | BlackBerry | Gordon Young (gyoung@rim.com) | Rel-11 | RP-51 | Yong-Jun | LTE_eDDA-Core | RP-121571 |  |
| 1833 | 433.2 | Test part: LTE RAN Enhancements for Diverse Data Applications | 136d? | 2013-03-04 A | 2013-09-06 A | 100% |  | 2013-03-04 | 2013-09-06 | 136d? |  | finish no earlier than 2013-09-06 | R5 | 1088h | 1088h | LTE_eDDA-UEConTest | PCG-30 | BlackBerry | Enikő Sokondár (esokondar@rim.com) | Rel-11 | RP-59 | Ingbert | LTE_eDDA-UEConTest | RP-130946 |  |
| 1834 | 434 | **LTE E850 - Lower Band for Region 2 (non-US), Band 27** | 516d? | 2011-03-23 A | 2013-03-01 A | 100% |  | 2011-03-23 | 2013-03-01 | 516d? |  |  | R1; R2; R4; R5 | 28496h | 28496h | LTE_e850_LB | PCG-26 | NII Holdings | bill.shvodian@nii.com | Rel-11 | RP-51 | Patrick | LTE_e850_LB |  |  |
| 1835 | 434.1 | Core part: LTE E850 - Lower Band for Region 2 (non-US), Band 27 | 328d? | 2011-06-15 A | 2012-09-07 A | 100% |  | 2011-06-15 | 2012-09-07 | 328d? |  | finish no earlier than 2012-09-07 | R1; R2; R4 | 7872h | 7872h | LTE_e850_LB-Core | PCG-26 | NII Holdings | bill.shvodian@nii.com | Rel-11 | RP-51 | Patrick | LTE_e850_LB-Core | RP-120570 |  |
| 1836 | 434.2 | Perf. part: LTE E850 - Lower Band for Region 2 (non-US), Band 27 | 326d? | 2011-03-23 A | 2012-06-15 A | 100% |  | 2011-03-23 | 2012-06-15 | 326d? |  | finish no earlier than 2012-12-07 | R4 | 2608h | 2608h | LTE_e850_LB-Perf | PCG-26 | NII Holdings | bill.shvodian@nii.com | Rel-11 | RP-51 | Issam | LTE_e850_LB-Perf | RP-120571 |  |
| 1837 | 434.3 | Test part: LTE E850 - Lower Band for Region 2 (non-US), Band 27 | 189d? | 2012-06-18 A | 2013-03-01 A | 100% |  | 2012-06-18 | 2013-03-01 | 189d? |  | finish no earlier than 2013-03-01 | R5 | 1504h | 1504h | LTE_e850_LB-UEConTest | PCG-29 | NII Holdings | bill.shvodian@nii.com | Rel-11 | RP-56 | Ingbert | LTE_e850_LB-UEConTest | RP-130045 |  |
| 1838 | 435 | **LTE for 700 MHz Digital Dividend** | 538d? | 2011-06-07 A | 2013-06-14 A | 100% |  | 2011-06-07 | 2013-06-14 | 538d? |  |  | R4; R2; R3; R5 | 28032h | 28032h | LTE_APAC700 | PCG-27 | Ericsson | olav.queseth@ericsson.com | Rel-11 | RP-52 | Issam | LTE_APAC700 |  |  |
| 1839 | 435.1 | Core part: LTE for 700 MHz Digital Dividend | 273d? | 2011-06-07 A | 2012-06-15 A | 100% |  | 2011-06-07 | 2012-06-15 | 273d? |  | finish no earlier than 2012-06-15 | R4; R2; R3 | 6552h | 6552h | LTE_APAC700-Core | PCG-27 | Ericsson | olav.queseth@ericsson.com | Rel-11 | RP-52 | Issam | LTE_APAC700-Core | RP-120572 |  |
| 1840 | 435.2 | Perf. part: LTE for 700 MHz Digital Dividend | 271d? | 2011-06-09 A | 2012-06-15 A | 100% |  | 2011-06-09 | 2012-06-15 | 271d? |  | finish no earlier than 2012-06-15 | R4 | 2168h | 2168h | LTE_APAC700-Perf | PCG-27 | Ericsson | olav.queseth@ericsson.com | Rel-11 | RP-52 | Issam | LTE_APAC700-Perf | RP-120573 |  |
| 1841 | 435.3 | Test part: LTE for 700 MHz Digital Dividend | 262d? | 2012-06-18 A | 2013-06-14 A | 100% |  | 2012-06-18 | 2013-06-14 | 262d? |  | finish no earlier than 2013-06-14 | R5 | 2096h | 2096h | LTE_APAC700-UEConTest | PCG-29 | Ericsson | fredrik.sundstrom@ericsson.com | Rel-11 | RP-56 | Ingbert | LTE_APAC700-UEConTest | RP-130467 |  |
| 1842 | 436 | **Relays for LTE (part 2)** | 930d? | 2009-12-04 A | 2013-06-14 A | 100% |  | 2009-12-04 | 2013-06-14 | 930d? |  |  | R4 | 17496.4h | 17496.4h | LTE_Relay2 | PCG-24 | Ericsson | christian.hoymann@ericsson.com | Rel-11 | RP-46 | Patrick | LTE_Relay2 |  |  |
| 1843 | 436.1 | Core part: Relays for LTE (part 2) | 333d? | 2011-06-07 A | 2012-09-07 A | 100% |  | 2011-06-07 | 2012-09-07 | 333d? |  | finish no earlier than 2012-09-07 | R4 | 2656.39h | 2656.39h | LTE_Relay2-Core | PCG-27 | Ericsson | christian.hoymann@ericsson.com | Rel-11 | RP-52 | Issam | LTE_Relay2-Core | RP-121008 |  |
| 1844 | 436.2 | Perf. part: Relays for LTE (part 2) | 925d? | 2009-12-04 A | 2013-06-14 A | 100% |  | 2009-12-04 | 2013-06-14 | 925d? |  | finish no earlier than 2013-06-14 | R4 | 7400h | 7400h | LTE_Relay2-Perf | PCG-24 | Ericsson | christian.hoymann@ericsson.com | Rel-11 | RP-46 | Issam | LTE_Relay2-Perf | RP-130487 |  |
| 1845 | 437 | **Signalling and Procedure for Interference Avoidance for in-device coexistence** | 325d? | 2011-09-19 A | 2012-12-07 A | 100% |  | 2011-09-19 | 2012-12-07 | 325d? |  |  | R2; R4 | 12976h | 12976h | SPIA_IDC_LTE | PCG-27 | China Mobile | Zhenping HU | Rel-11 | RP-53 | Yong-Jun | SPIA_IDC_LTE |  |  |
| 1846 | 437.1 | Core part: Signalling and Procedure for Interference Avoidance for in-device coexistence | 325d? | 2011-09-19 A | 2012-12-07 A | 100% |  | 2011-09-19 | 2012-12-07 | 325d? |  | finish no earlier than 2012-12-07 | R2; R4 | 5200h | 5200h | SPIA_IDC_LTE-Core | PCG-27 | China Mobile | Zhenping HU | Rel-11 | RP-53 | Yong-Jun | SPIA_IDC_LTE-Core | RP-121573 |  |
| 1847 | 437.2 | Perf. part: Signalling and Procedure for Interference Avoidance for in-device coexistence | 322d? | 2011-09-20 A | 2012-12-07 A | 100% |  | 2011-09-20 | 2012-12-07 | 322d? |  | finish no earlier than 2012-12-07 | R4 | 2576h | 2576h | SPIA_IDC_LTE-Perf | PCG-27 | China Mobile | Zhenping HU | Rel-11 | RP-53 | Issam | SPIA_IDC_LTE-Perf | RP-121574 |  |

Notes:
- 1824: - / Impacted TSs and TRs: LTE
- 1825: RP#58 completed / Impacted TSs and TRs: 36.101, 36.133, 36.201, 36.211, 36.212, 36.213, 36.214, 36.300, 36.304, 36.321, 36.331, 36.413, 36.423
- 1826: RP#62 completed / Impacted TSs and TRs: 36.101, 36.104, 36.133, 36.141
- 1827: ; Stat Rep: RP-141131->RP-141847 / Impacted TSs and TRs: 36.508, 36.521-1, 36.521-2, 36.521-3, 36.523-1, 36.523-2, 36.523-3
- 1828: Stage 3 / Impacted TSs and TRs: LTE
- 1829: RP#58 completed / Impacted TSs and TRs: 36.101, 36.104, 36.141, 36.307
- 1830: RP#58 completed / Impacted TSs and TRs: 36.101, 36.104, 36.133, 36.141, 36.307
- 1831: Stage 2/3 / Impacted TSs and TRs: LTE
- 1832: RP#58 completed / Impacted TSs and TRs: 36.300, 36.321, 36.331, new TR 36.822
- 1833: RP#61 completed / Impacted TSs and TRs: 36.523-1, 36.523-2, 36.523-3
- 1834: Stage 3 / Impacted TSs and TRs: LTE
- 1835: RP#56 completed / Impacted TSs and TRs: 25.101, 25.104, 25.461, 25.466, 36.101, 36.104, 36.113, 36.124, 36.307, 37.104, 37.113
- 1836: RP#56 completed / Impacted TSs and TRs: 25.123, 25.133, 25.141, 36.133, 36.141, 37.141
- 1837: RP#59 completed / Impacted TSs and TRs: 36.508, 36.521-1, 36.521-2, 36.521-3, 36.523-2, 36.523-3, 37.571-1
- 1838: Stage 3. Asian Pacific American Caucus (APAC) Asia-Pacific Telecommunity (APT) Wireless Forum / Impacted TSs and TRs: LTE
- 1839: RP#56 completed. TR 36.820 v100 for Information and Approval / Impacted TSs and TRs: 25.461, 25.466, 36.101, 36.104, 36.113, 36.124, 36.133, 36.307, 37.104, 37.113, new TR 36.820
- 1840: RP#56 completed / Impacted TSs and TRs: 36.133, 36.141, 37.141
- 1841: RP#60 completed / Impacted TSs and TRs: 36.508, 36.521-1, 36.521-2, 36.521-3, 36.523-2, 36.523-3, 37.571-1
- 1842: Continuation of Rel-10 (open RAN4 Core & Perf parts) / Impacted TSs and TRs: LTE
- 1843: RP#57 completed. TS 36.116, TR 36.826 v100 for Information & Approval. RP#52 Core part not completed in Rel-10 / Impacted TSs and TRs: 36.133, new RAN4 (36.116, 36.826)
- 1844: RP#60 completed. New TS 36.117 v100 for 1-step Approval. RP#52 transferred completely from Rel-10 UID_460213 / Impacted TSs and TRs: 36.133, new TS 36.117 (E-UTRA Relay conformance testing)
- 1845: Stage 2/3 / Impacted TSs and TRs: LTE
- 1846: RP#58 completed / Impacted TSs and TRs: 36.133, 36.300, 36.306, 36.321, 36.331
- 1847: RP#58 completed / Impacted TSs and TRs: 36.133

| ID | WBS | Task | Duration | Start | Finish | Complete | Remaining | Baseline start | Baseline finish | Baseline duration | Total slack | Constraint | Resources | Work | Actual work | Acronym | PCG approved | WI rapporteur name | Release | TSG approved | MCC resp | Acronym_3GU_Export | Status Report | Special Focus Doc |
| --- | --- | --- | --- | --- | --- | --- | --- | --- | --- | --- | --- | --- | --- | --- | --- | --- | --- | --- | --- | --- | --- | --- | --- | --- |
| 1848 | 438 | **Coordinated Multi-Point Operation for LTE** | 860d? | 2011-09-19 A | 2014-12-15 A | 100% |  | 2011-09-19 | 2014-09-12 | 791d? |  |  | R1; R2; R3; R4; R5 | 66128h | 66128h | COMP_LTE | PCG-27 | Huawei, Samsung | Rel-11 | RP-53 | Patrick | COMP_LTE |  |  |
| 1849 | 438.1 | Core part: Coordinated Multi-Point Operation for LTE – Uplink | 325d? | 2011-09-19 A | 2012-12-07 A | 100% |  | 2011-09-19 | 2012-12-07 | 325d? |  | finish no earlier than 2012-12-07 | R1; R2; R3; R4 | 10400h | 10400h | COMP_LTE_UL-Core | PCG-27 | Huawei | Rel-11 | RP-53 | Patrick | COMP_LTE_UL-Core | RP-121575 |  |
| 1850 | 438.2 | Perf. part: Coordinated Multi-Point Operation for LTE – Uplink | 321d? | 2011-09-23 A | 2012-12-07 A | 100% |  | 2011-09-23 | 2012-12-07 | 321d? |  | finish no earlier than 2012-12-07 | R4 | 2568h | 2568h | COMP_LTE_UL-Perf | PCG-27 | Huawei | Rel-11 | RP-53 | Issam | COMP_LTE_UL-Perf | RP-121576 |  |
| 1851 | 438.3 | Core part: Coordinated Multi-Point Operation for LTE – Downlink | 325d? | 2011-09-19 A | 2012-12-07 A | 100% |  | 2011-09-19 | 2012-12-07 | 325d? |  | finish no earlier than 2012-12-07 | R1; R2; R3; R4 | 10400h | 10400h | COMP_LTE_DL-Core | PCG-27 | Samsung | Rel-11 | RP-53 | Patrick | COMP_LTE_DL-Core | RP-121577 |  |
| 1852 | 438.4 | Perf. part: Coordinated Multi-Point Operation for LTE – Downlink | 582d? | 2011-09-23 A | 2013-12-06 A | 100% |  | 2011-09-23 | 2013-12-06 | 582d? |  | finish no earlier than 2013-12-06 | R4 | 4656h | 4656h | COMP_LTE_DL-Perf | PCG-27 | Samsung | Rel-11 | RP-53 | Issam | COMP_LTE_DL-Perf | RP-131465 |  |
| 1853 | 438.5 | Test part: Coordinated Multi-Point Operation for LTE | 463d? | 2013-03-15 A | 2014-12-15 A | 100% |  | 2013-03-04 | 2014-09-12 | 404d? |  | finish no earlier than 2014-12-15 | R5 | 3704h | 3704h | COMP_LTE-UEConTest | PCG-30 | Samsung | Rel-11 | RP-59 | Ingbert | COMP_LTE-UEConTest | RP-141782 |  |
| 1854 | 439 | **Enhanced downlink control channel(s) for LTE Advanced** | 732d? | 2011-12-09 A | 2014-09-12 A | 100% |  | 2011-12-09 | 2014-09-12 | 731d? |  |  | R1; R2; R4; R5 | 38272h | 38272h | LTE_enh_dl_ctrl | PCG-28 | Alcatel-Lucent | Rel-11 | RP-54 | Patrick | LTE_enh_dl_ctrl |  |  |
| 1855 | 439.1 | Core part: Enhanced downlink control channel(s) for LTE Advanced | 265d? | 2011-12-09 A | 2012-12-07 A | 100% |  | 2011-12-09 | 2012-12-07 | 265d? |  | finish no earlier than 2012-12-07 | R1; R2; R4 | 6360h | 6360h | LTE_enh_dl_ctrl-Core | PCG-28 | Alcatel-Lucent | Rel-11 | RP-54 | Patrick | LTE_enh_dl_ctrl-Core | RP-121579 |  |
| 1856 | 439.2 | Perf. part: Enhanced downlink control channel(s) for LTE Advanced | 659d? | 2011-12-16 A | 2014-06-13 A | 100% |  | 2011-12-16 | 2014-06-13 | 659d? |  | finish no earlier than 2014-06-13 | R4 | 5272h | 5272h | LTE_enh_dl_ctrl-Perf | PCG-28 | Alcatel-Lucent | Rel-11 | RP-54 | Issam | LTE_enh_dl_ctrl-Perf | RP-140651 |  |
| 1857 | 439.3 | Test part: Enhanced downlink control channel(s) for LTE Advanced | 402d? | 2013-03-04 A | 2014-09-12 A | 100% |  | 2013-03-04 | 2014-09-12 | 402d? |  | finish no earlier than 2014-09-12 | R5 | 3216h | 3216h | LTE_enh_dl_ctrl-UEConTest | PCG-30 | Huawei | Rel-11 | RP-59 | Ingbert | LTE_enh_dl_ctrl-UEConTest | RP-141256 |  |
| 1858 | 440 | **Public Safety Broadband High Power UE for Band 14 for Region 2** | 403d? | 2012-03-05 A | 2013-09-06 A | 100% |  | 2012-03-05 | 2013-09-06 | 403d? |  |  | R4; R5 | 9144h | 9144h | LTE_B14_PSBB_HPUE | PCG-28 | Motorola Solutions | Rel-11 | RP-55 | Issam | LTE_B14_PSBB_HPUE |  | Public Safety (A-A) |
| 1859 | 440.1 | Core part: Public Safety Broadband High Power UE for Band 14 for Region 2 | 201d? | 2012-03-05 A | 2012-12-07 A | 100% |  | 2012-03-05 | 2012-12-07 | 201d? |  | finish no earlier than 2012-12-07 | R4 | 1608h | 1608h | LTE_B14_PSBB_HPUE-Core | PCG-28 | Motorola Solutions | Rel-11 | RP-55 | Issam | LTE_B14_PSBB_HPUE-Core | RP-121581 | Public Safety (A-A) |
| 1860 | 440.2 | Test part: Public Safety Broadband High Power UE for Band 14 for Region 2 | 138d? | 2013-03-04 A | 2013-09-06 A | 100% |  | 2013-03-04 | 2013-09-06 | 138d? |  | finish no earlier than 2013-09-06 | R5 | 1088h | 1088h | LTE_B14_PSBB_HPUE-UEConTest | PCG-30 | Motorola Solutions | Rel-11 | RP-59 | Ingbert | LTE_B14_PSBB_HPUE-UEConTest | RP-130949 | Public Safety (A-A) |
| 1861 | 441 | **Improved Minimum Performance Requirements for E-UTRA: Interference Rejection** | 671d? | 2012-03-05 A | 2014-09-12 A | 100% |  | 2012-03-05 | 2014-09-12 | 670d? |  |  | R4; R5 | 14952h | 14952h | LTE_Interf_Rej | PCG-28 | Renesas Mobile | Rel-11 | RP-55 | Issam | LTE_Interf_Rej |  |  |
| 1862 | 441.1 | Perf. part: Improved Minimum Performance Requirements for E-UTRA: Interference Rejection | 201d? | 2012-03-05 A | 2012-12-07 A | 100% |  | 2012-03-05 | 2012-12-07 | 201d? |  | finish no earlier than 2012-12-07 | R4 | 1608h | 1608h | LTE_Interf_Rej-Perf | PCG-28 | Renesas Mobile | Rel-11 | RP-55 | Issam | LTE_Interf_Rej-Perf | RP-121582 |  |
| 1863 | 441.2 | Test part: Improved Minimum Performance Requirements for E-UTRA: Interference Rejection | 327d? | 2013-06-18 A | 2014-09-12 A | 100% |  | 2013-06-18 | 2014-09-12 | 327d? |  | finish no earlier than 2014-09-12 | R5 | 2608h | 2608h | LTE_Interf_Rej-UEConTest | PCG-31 | Broadcom | Rel-11 | RP-60 | Ingbert | LTE_Interf_Rej-UEConTest | RP-141602 |  |
| 1864 | 442 | **Additional special subframe configuration for LTE TDD** | 341d? | 2012-03-05 A | 2013-06-14 A | 100% |  | 2012-03-05 | 2013-06-14 | 341d? |  |  | R4; R2; R3; R5 | 14808h | 14808h | LTE_TDD_add_subframe | PCG-28 | China Mobile | Rel-11 | RP-55 | Issam | LTE_TDD_add_subframe |  |  |
| 1865 | 442.1 | Core part: Additional special subframe configuration for LTE TDD | 137d? | 2012-03-05 A | 2012-09-07 A | 100% |  | 2012-03-05 | 2012-09-07 | 137d? |  | finish no earlier than 2012-09-07 | R4; R2; R3 | 3288h | 3288h | LTE_TDD_add_subframe-Core | PCG-28 | China Mobile | Rel-11 | RP-55 | Issam | LTE_TDD_add_subframe-Core | RP-121019 |  |
| 1866 | 442.2 | Test part: Additional special subframe configuration for LTE TDD | 76d? | 2013-03-04 A | 2013-06-14 A | 100% |  | 2013-03-04 | 2013-06-14 | 76d? |  | finish no earlier than 2013-09-13 | R5 | 608h | 608h | LTE_TDD_add_subframe-UEConTest | PCG-30 | Huawei | Rel-11 | RP-59 | Ingbert | LTE_TDD_add_subframe-UEConTest | RP-130475 |  |
| 1867 | 443 | **Rel-11 LTE Carrier Aggregation** | 1062d? | 2010-12-10 A | 2014-12-15 | 99% | 8.37d? | 2010-12-10 | 2014-12-05 | 1054d? | 654d |  | R1; R2; R3; R4; R5 | 315760h | 263184h | LTE_CA_Rel-11 | PCG-30 |  | Rel-11 | RP-58 | Patrick | LTE_CA_Rel-11 |  | CA |
| 1868 | 443.1 | **LTE Carrier Aggregation Enhancements** | 995d? | 2011-03-15 A | 2014-12-15 | 93% | 65.41d? | 2011-03-22 | 2014-12-05 | 982d? | 654d |  | R1; R2; R3; R4; R5 | 70824h | 47768h | LTE_CA_enh | PCG-26 | Nokia | Rel-11 | RP-51 | Patrick | LTE_CA_enh |  | CA |
| 1869 | 443.1.1 | Core part: LTE Carrier Aggregation Enhancements | 646.25d? | 2011-03-22 A | 2013-08-27 | 80% | 129.25d? | 2011-03-22 | 2013-03-01 | 517d? | 997.75d | finish no earlier than 2013-03-01 | R1; R2; R4; R3 | 20680h | 16544h | LTE_CA_enh-Core | PCG-26 | Nokia | Rel-11 | RP-51 | Patrick | LTE_CA_enh-Core | RP-130059 | CA |
| 1870 | 443.1.2 | Perf. part: LTE Carrier Aggregation Enhancements | 994d? | 2011-03-15 A | 2014-12-15 A | 100% |  | 2011-03-29 | 2014-12-05 | 977d? |  | finish no earlier than 2014-12-15 | R4 | 7936h | 7936h | LTE_CA_enh-Perf | PCG-26 | Nokia | Rel-11 | RP-51 | Issam | LTE_CA_enh-Perf | RP-141969 | CA |
| 1871 | 443.1.3 | Test part: LTE Carrier Aggregation Enhancements | 326d? | 2013-06-18 A | 2014-09-12 A | 100% |  | 2013-06-18 | 2014-09-12 | 326d? |  | finish no earlier than 2014-09-12 | R5 | 2608h | 2608h | LTE_CA_enh-UEConTest | PCG-31 | Microsoft | Rel-11 | RP-60 | Ingbert | LTE_CA_enh-UEConTest | RP-141443 | CA |
| 1872 | 443.2 | UE Conformance Test Aspects – LTE Advanced Carrier Aggregation of Intra-band contiguous and Inter-band configurations | 329d? | 2012-09-11 A | 2013-12-06 A | 100% |  | 2012-09-11 | 2013-12-06 | 329d? |  | finish no earlier than 2013-12-06 | R5 | 2624h | 2624h | LTE_CA_intraC_inter_UEConTest | PCG-29 | Nokia | Rel-11 | RP-57 | Ingbert | LTE_CA_intraC_inter_UEConTest | RP-131446 | CA |

Notes:
- 1848: Stage 3. Triggered by Rel-11 TR 36.819 Study on Coordinated Multi-Point Operation for LTE (FS_CoMP_LTE) / Impacted TSs and TRs: LTE / WI rapporteur e-mail: Juho Lee (juho95.lee@samsung.com), david.mazzarese@huawei.com
- 1849: RP#58 completed / Impacted TSs and TRs: 36.101, 36.104, 36.133, 36.201, 36.211, 36.212, 36.213, 36.214, 36.300, 36.306, 36.321, 36.331, 36.423 / WI rapporteur e-mail: david.mazzarese@huawei.com
- 1850: RP#58 completed / Impacted TSs and TRs: 36.101, 36.104, 36.133, 36.141 / WI rapporteur e-mail: Xinwei Zhi (zhixinwei@huawei.com)
- 1851: RP#58 completed / Impacted TSs and TRs: 36.101, 36.104, 36.133, 36.201, 36.211, 36.212, 36.213, 36.214, 36.300, 36.306, 36.321, 36.331, 36.423 / WI rapporteur e-mail: Juho Lee (juho95.lee@samsung.com)
- 1852: RP#62 completed / Impacted TSs and TRs: 36.101, 36.104, 36.133, 36.141, 36.307 / WI rapporteur e-mail: xutao.zhou@samsung.com
- 1853: Impacted TSs and TRs: 36.508, 36.521-1, 36.521-2, 36.523-1, 36.523-2, 36.523-3 / WI rapporteur e-mail: Stoyan.Baev@partner.samsung.com
- 1854: Stage 3. RP#58 Core completed. Triggered by UID_510037 Rel-11 TR 36.871 Study on further Downlink MIMO enhancements for LTE-Advanced (FS_LTE_eDL_MIMO_enh) / Impacted TSs and TRs: LTE / WI rapporteur e-mail: sigen.ye@alcatel-lucent.com
- 1855: RP#58 completed / Impacted TSs and TRs: 36.101, 36.211, 36.212, 36.213, 36.331 / WI rapporteur e-mail: sigen.ye@alcatel-lucent.com
- 1856: RP#64 completed / Impacted TSs and TRs: 36.101, 36.104, 36.133, 36.141 / WI rapporteur e-mail: teck.hu@alcatel-lucent.com
- 1857: RP#65 completed / Impacted TSs and TRs: 36.508, 36.521-1, 36.521-2, 36.523-1, 36.523-2, 36.523-3 / WI rapporteur e-mail: Xu Kai (xk.xukai@huawei.com)
- 1858: Stage 3 / Impacted TSs and TRs: LTE / WI rapporteur e-mail: xiaowei.jin@motorolasolutions.com
- 1859: RP#58 completed. TR 36.837 v100 for Information and Approval / Impacted TSs and TRs: 36.101, new TR 36.837 / WI rapporteur e-mail: xiaowei.jin@motorolasolutions.com
- 1860: RP#61 completed / Impacted TSs and TRs: 36.521-1, 36.521-2 / WI rapporteur e-mail: xiaowei.jin@motorolasolutions.com
- 1861: RP#58 completed. Triggered by FS_enh_perf_UE_LTE. Adds Perf. requirements for demodulation of the already specified PDSCH with the transmission modes defined in Rel-8 to Rel-10 / Impacted TSs and TRs: LTE / WI rapporteur e-mail: Timo Roman
- 1862: RP#58 completed / Impacted TSs and TRs: 36.101 / WI rapporteur e-mail: Timo Roman
- 1863: RP#65 completed. TR 36.904 for 1-step Approval. Testing for 36.101 / Impacted TSs and TRs: 36.508, 36.521-1, 36.521-2, New TR 36.904 / WI rapporteur e-mail: jarkko.hellsten@kolumbus.fi
- 1864: Stage 3. Exists already for 1UL a WI LTE_CA_B3_B5 / Impacted TSs and TRs: LTE / WI rapporteur e-mail: Xiaodong Shen
- 1865: RP#57 completed / Impacted TSs and TRs: 36.211, 36.213, 36.331, 36.423 / WI rapporteur e-mail: Xiaodong Shen
- 1866: RP#60 completed / Impacted TSs and TRs: 36.508, 36.523-1, 36.523-2, 36.523-3 / WI rapporteur e-mail: Li Xiang (tricia.li@huawei.com)
- 1867: LTE_CA_Rel-11 / Impacted TSs and TRs: LTE
- 1868: Stage 3 / Impacted TSs and TRs: LTE / WI rapporteur e-mail: lars.e.lindh@nokia.com
- 1869: RP#59 completed. New TR 36.823 v100 for Information and Approval / Impacted TSs and TRs: 36.101, 36.104, 36.133, 36.201, 36.211, 36.212, 36.213, 36.300, 36.302, 36.306, 36.321, 36.331, 36.413, 36.423, new TR 36.823 / WI rapporteur e-mail: lars.e.lindh@nokia.com
- 1870: ; Stat Rep: RP-141377->RP-141969 / Impacted TSs and TRs: 36.101, 36.104, 36.133, 36.141 / WI rapporteur e-mail: lars.e.lindh@nokia.com
- 1871: SP#65 completed / Impacted TSs and TRs: 36.508, 36.521-1, 36.521-2, 36.521-3, 36.523-1, 36.523-2, 36.523-3 / WI rapporteur e-mail: jussi.kuusisto@microsoft.com
- 1872: RP#62 completed / Impacted TSs and TRs: 36.508, 36.521-1, 36.521-2, 36.521-3, 36.523-1, 36.523-2, 36.523-3, 37.571-1 / WI rapporteur e-mail: jussi.kuusisto@nokia.com

| ID | WBS | Task | Duration | Start | Finish | Complete | Baseline start | Baseline finish | Baseline duration | Constraint | Resources | Work | Actual work | PCG approved | Release | TSG approved | MCC resp | Special Focus Doc | Acronym | WI rapporteur name | WI rapporteur e-mail | Acronym_3GU_Export | Status Report |
| --- | --- | --- | --- | --- | --- | --- | --- | --- | --- | --- | --- | --- | --- | --- | --- | --- | --- | --- | --- | --- | --- | --- | --- |
| 1873 | 443.3 | **Rel-11 inter-band Carrier Aggregation** | 528d? | 2010-12-10 A | 2012-12-07 A | 100% | 2010-12-10 | 2012-12-07 | 528d? |  | R4 | 180968h | 180968h | PCG-30 | Rel-11 | RP-58 | Issam | CA |  |  |  |  |  |
| 1874 | 443.3.1 | **LTE Advanced Carrier Aggregation of Band 3 and Band 7** | 528d? | 2010-12-10 A | 2012-12-07 A | 100% | 2010-12-10 | 2012-12-07 | 528d? |  | R4 | 12040h | 12040h | PCG-25 | Rel-11 | RP-48 | Issam | CA | LTE_CA_B3_B7 | TeliaSonera | Ralf.Schuh@TeliaSonera.com | LTE_CA_B3_B7 |  |
| 1875 | 443.3.1.1 | Core part: LTE Advanced Carrier Aggregation of Band 3 and Band 7 | 456d? | 2010-12-10 A | 2012-09-07 A | 100% | 2010-12-10 | 2012-09-07 | 456d? | finish no earlier than 2012-09-07 | R4 | 3648h | 3648h | PCG-25 | Rel-11 | RP-48 | Issam | CA | LTE_CA_B3_B7-Core | TeliaSonera | Ralf.Schuh@TeliaSonera.com | LTE_CA_B3_B7-Core | RP-121022 |
| 1876 | 443.3.1.2 | Perf. part: LTE Advanced Carrier Aggregation of Band 3 and Band 7 | 523d? | 2010-12-17 A | 2012-12-07 A | 100% | 2010-12-17 | 2012-12-07 | 523d? | finish no earlier than 2012-12-07 | R4 | 4168h | 4168h | PCG-25 | Rel-11 | RP-48 | Issam | CA | LTE_CA_B3_B7-Perf | TeliaSonera | Ralf.Schuh@TeliaSonera.com | LTE_CA_B3_B7-Perf | RP-121023 |
| 1877 | 443.3.2 | **LTE Advanced Carrier Aggregation of Band 4 and Band 17** | 528d? | 2010-12-10 A | 2012-12-07 A | 100% | 2010-12-10 | 2012-12-07 | 528d? |  | R4 | 12064h | 12064h | PCG-26 | Rel-11 | RP-50 | Issam | CA | LTE_CA_B4_B17 | AT&T | marc.grant@att.com | LTE_CA_B4_B17 |  |
| 1878 | 443.3.2.1 | Core part: LTE Advanced Carrier Aggregation of Band 4 and Band 17 | 459d? | 2010-12-10 A | 2012-09-07 A | 100% | 2010-12-10 | 2012-09-07 | 459d? | finish no earlier than 2012-09-07 | R4 | 3672h | 3672h | PCG-26 | Rel-11 | RP-50 | Issam | CA | LTE_CA_B4_B17-Core | AT&T | marc.grant@att.com | LTE_CA_B4_B17-Core | RP-121024 |
| 1879 | 443.3.2.2 | Perf. part: LTE Advanced Carrier Aggregation of Band 4 and Band 17 | 521d? | 2010-12-17 A | 2012-12-07 A | 100% | 2010-12-17 | 2012-12-07 | 521d? | finish no earlier than 2012-12-07 | R4 | 4168h | 4168h | PCG-26 | Rel-11 | RP-50 | Issam | CA | LTE_CA_B4_B17-Perf | AT&T | marc.grant@att.com | LTE_CA_B4_B17-Perf | RP-121595 |
| 1880 | 443.3.3 | **LTE Advanced Carrier Aggregation of Band 4 and Band 13** | 528d? | 2010-12-10 A | 2012-12-07 A | 100% | 2010-12-10 | 2012-12-07 | 528d? |  | R4 | 12040h | 12040h | PCG-26 | Rel-11 | RP-50 | Issam | CA | LTE_CA_B4_B13 | Ericsson | christian.bergljung@ericsson.com | LTE_CA_B4_B13 |  |
| 1881 | 443.3.3.1 | Core part: LTE Advanced Carrier Aggregation of Band 4 and Band 13 | 456d? | 2010-12-10 A | 2012-09-07 A | 100% | 2010-12-10 | 2012-09-07 | 456d? | finish no earlier than 2012-09-07 | R4 | 3648h | 3648h | PCG-26 | Rel-11 | RP-50 | Issam | CA | LTE_CA_B4_B13-Core | Ericsson | christian.bergljung@ericsson.com | LTE_CA_B4_B13-Core | RP-121026 |
| 1882 | 443.3.3.2 | Perf. part: LTE Advanced Carrier Aggregation of Band 4 and Band 13 | 521d? | 2010-12-21 A | 2012-12-07 A | 100% | 2010-12-21 | 2012-12-07 | 521d? | finish no earlier than 2012-12-07 | R4 | 4168h | 4168h | PCG-26 | Rel-11 | RP-50 | Issam | CA | LTE_CA_B4_B13-Perf | Ericsson | christian.bergljung@ericsson.com | LTE_CA_B4_B13-Perf | RP-121594 |
| 1883 | 443.3.4 | **LTE Advanced Carrier Aggregation of Band 4 and Band 12** | 456d? | 2011-03-22 A | 2012-12-07 A | 100% | 2011-03-22 | 2012-12-07 | 456d? |  | R4; R2 | 18200h | 18200h | PCG-26 | Rel-11 | RP-51 | Issam | CA | LTE_CA_B4_B12 | Leap Wireless | Bill Chandler (bchandler@cricketcommunications.com) | LTE_CA_B4_B12 |  |
| 1884 | 443.3.4.1 | Core part: LTE Advanced Carrier Aggregation of Band 4 and Band 12 | 456d? | 2011-03-22 A | 2012-12-07 A | 100% | 2011-03-22 | 2012-12-07 | 456d? | finish no earlier than 2012-12-07 | R4; R2 | 7296h | 7296h | PCG-26 | Rel-11 | RP-51 | Issam | CA | LTE_CA_B4_B12-Core | Leap Wireless | Bill Chandler (bchandler@cricketcommunications.com) | LTE_CA_B4_B12-Core | RP-121592 |
| 1885 | 443.3.4.2 | Perf. part: LTE Advanced Carrier Aggregation of Band 4 and Band 12 | 451d? | 2011-03-29 A | 2012-12-07 A | 100% | 2011-03-29 | 2012-12-07 | 451d? | finish no earlier than 2012-12-07 | R4 | 3608h | 3608h | PCG-26 | Rel-11 | RP-51 | Issam | CA | LTE_CA_B4_B12-Perf | Leap Wireless | Bill Chandler (bchandler@cricketcommunications.com) | LTE_CA_B4_B12-Perf | RP-121593 |
| 1886 | 443.3.5 | **LTE Advanced Carrier Aggregation of Band 5 and Band 12** | 456d? | 2011-03-22 A | 2012-12-07 A | 100% | 2011-03-22 | 2012-12-07 | 456d? |  | R4; R2 | 18200h | 18200h | PCG-26 | Rel-11 | RP-51 | Issam | CA | LTE_CA_B5_B12 | US Cellular | sebastian.thalanany@uscellular.com | LTE_CA_B5_B12 |  |
| 1887 | 443.3.5.1 | Core part: LTE Advanced Carrier Aggregation of Band 5 and Band 12 | 456d? | 2011-03-22 A | 2012-12-07 A | 100% | 2011-03-22 | 2012-12-07 | 456d? | finish no earlier than 2012-12-07 | R4; R2 | 7296h | 7296h | PCG-26 | Rel-11 | RP-51 | Issam | CA | LTE_CA_B5_B12-Core | US Cellular | sebastian.thalanany@uscellular.com | LTE_CA_B5_B12-Core | RP-121596 |
| 1888 | 443.3.5.2 | Perf. part: LTE Advanced Carrier Aggregation of Band 5 and Band 12 | 451d? | 2011-03-25 A | 2012-12-07 A | 100% | 2011-03-25 | 2012-12-07 | 451d? | finish no earlier than 2012-12-07 | R4 | 3608h | 3608h | PCG-26 | Rel-11 | RP-51 | Issam | CA | LTE_CA_B5_B12-Perf | US Cellular | sebastian.thalanany@uscellular.com | LTE_CA_B5_B12-Perf | RP-121597 |
| 1889 | 443.3.6 | **LTE Advanced Carrier Aggregation of Band 7 and Band 20** | 389d? | 2011-03-22 A | 2012-09-07 A | 100% | 2011-03-22 | 2012-09-07 | 389d? |  | R4 | 9288h | 9288h | PCG-26 | Rel-11 | RP-51 | Issam | CA | LTE_CA_B7_B20 | Huawei | Steven Chen | LTE_CA_B7_B20 |  |
| 1890 | 443.3.6.1 | Core part: LTE Advanced Carrier Aggregation of Band 7 and Band 20 | 386d? | 2011-03-22 A | 2012-09-07 A | 100% | 2011-03-22 | 2012-09-07 | 386d? | finish no earlier than 2012-09-07 | R4 | 3088h | 3088h | PCG-26 | Rel-11 | RP-51 | Issam | CA | LTE_CA_B7_B20-Core | Huawei | Steven Chen | LTE_CA_B7_B20-Core | RP-121032 |
| 1891 | 443.3.6.2 | Perf. part: LTE Advanced Carrier Aggregation of Band 7 and Band 20 | 386d? | 2011-03-25 A | 2012-09-07 A | 100% | 2011-03-25 | 2012-09-07 | 386d? | finish no earlier than 2012-09-07 | R4 | 3088h | 3088h | PCG-26 | Rel-11 | RP-51 | Issam | CA | LTE_CA_B7_B20-Perf | Huawei | Steven Chen | LTE_CA_B7_B20-Perf | RP-121033 |
| 1892 | 443.3.7 | **LTE Advanced Carrier Aggregation of Band 2 and Band 17** | 455d? | 2011-03-23 A | 2012-12-07 A | 100% | 2011-03-23 | 2012-12-07 | 455d? |  | R4 | 10336h | 10336h | PCG-26 | Rel-11 | RP-51 | Issam | CA | LTE_CA_B2_B17 | AT&T | marc.grant@att.com | LTE_CA_B2_B17 |  |
| 1893 | 443.3.7.1 | Core part: LTE Advanced Carrier Aggregation of Band 2 and Band 17 | 386d? | 2011-03-23 A | 2012-09-07 A | 100% | 2011-03-23 | 2012-09-07 | 386d? | finish no earlier than 2012-09-07 | R4 | 3088h | 3088h | PCG-26 | Rel-11 | RP-51 | Issam | CA | LTE_CA_B2_B17-Core | AT&T | marc.grant@att.com | LTE_CA_B2_B17-Core | RP-121034 |
| 1894 | 443.3.7.2 | Perf. part: LTE Advanced Carrier Aggregation of Band 2 and Band 17 | 451d? | 2011-03-25 A | 2012-12-07 A | 100% | 2011-03-25 | 2012-12-07 | 451d? | finish no earlier than 2012-12-07 | R4 | 3608h | 3608h | PCG-26 | Rel-11 | RP-51 | Issam | CA | LTE_CA_B2_B17-Perf | AT&T | marc.grant@att.com | LTE_CA_B2_B17-Perf | RP-121585 |
| 1895 | 443.3.8 | **LTE Advanced Carrier Aggregation of Band 4 and Band 5** | 455d? | 2011-03-23 A | 2012-12-07 A | 100% | 2011-03-23 | 2012-12-07 | 455d? |  | R4 | 10856h | 10856h | PCG-26 | Rel-11 | RP-51 | Issam | CA | LTE_CA_B4_B5 | AT&T | marc.grant@att.com | LTE_CA_B4_B5 |  |
| 1896 | 443.3.8.1 | Core part: LTE Advanced Carrier Aggregation of Band 4 and Band 5 | 451d? | 2011-03-23 A | 2012-12-07 A | 100% | 2011-03-23 | 2012-12-07 | 451d? | finish no earlier than 2012-12-07 | R4 | 3608h | 3608h | PCG-26 | Rel-11 | RP-51 | Issam | CA | LTE_CA_B4_B5-Core | AT&T | marc.grant@att.com | LTE_CA_B4_B5-Core | RP-121757 |
| 1897 | 443.3.8.2 | Perf. part: LTE Advanced Carrier Aggregation of Band 4 and Band 5 | 451d? | 2011-03-25 A | 2012-12-07 A | 100% | 2011-03-25 | 2012-12-07 | 451d? | finish no earlier than 2012-12-07 | R4 | 3608h | 3608h | PCG-26 | Rel-11 | RP-51 | Issam | CA | LTE_CA_B4_B5-Perf | AT&T | marc.grant@att.com | LTE_CA_B4_B5-Perf | RP-121589 |

Notes:
- 1873: LTE_CA_Rel-11 / Impacted TSs and TRs: LTE
- 1874: RP#57 completed. In Europe Band 3,7,20 are interesting for LTE and LTE-Advanced deployment. Different CA combinations for these bands are of high priority for Region 1 / Impacted TSs and TRs: LTE
- 1875: RP#57 completed. RP#59 new generic TR 36.850v100 for Information and Approval / Impacted TSs and TRs: 36.101, 36.104, 36.307, new generic TR 36.850
- 1876: RP#57 completed / Impacted TSs and TRs: 36.133, 36.141
- 1877: Stage 3. RP#57 Core completed. RP#58 Perf completed / Impacted TSs and TRs: LTE
- 1878: RP#57 completed. RP#59 new generic TR 36.850v100 for Information and Approval / Impacted TSs and TRs: 36.101, 36.104, 36.133, 36.141, 36.307, new generic TR 36.850
- 1879: RP#58 completed / Impacted TSs and TRs: 36.101, 36.104, 36.133, 36.307
- 1880: Stage 3. RP#57 Core completed. RP#58 Perf completed / Impacted TSs and TRs: LTE
- 1881: RP#57 completed / Impacted TSs and TRs: 36.101, 36.104, 36.133, 36.307, new generic TR 36.850
- 1882: RP#58 completed / Impacted TSs and TRs: 36.101, 36.133, 36.141
- 1883: Stage 3. RP#58 completed / Impacted TSs and TRs: LTE
- 1884: RP#58 completed. RP#59 new generic TR 36.850v100 for Information and Approval / Impacted TSs and TRs: 36.101, 36.104, 36.307, new generic TR 36.850
- 1885: RP#58 completed / Impacted TSs and TRs: 36.133, 36.141
- 1886: Stage 3. RP#58 completed / Impacted TSs and TRs: LTE
- 1887: RP#58 completed. RP#59 new generic TR 36.850v100 for Information and Approval / Impacted TSs and TRs: 36.101, 36.104, 36.133, 36.141, 36.307, new generic TR 36.850
- 1888: RP#58 completed / Impacted TSs and TRs: 36.101, 36.104, 36.133, 36.307
- 1889: Stage 3. RP#57 completed / Impacted TSs and TRs: LTE
- 1890: RP#57 completed. RP#59 new generic TR 36.850v100 for Information and Approval / Impacted TSs and TRs: 36.101, 36.104, 36.307, new generic TR 36.850
- 1891: RP#57 completed / Impacted TSs and TRs: 36.133, 36.141
- 1892: Stage 3. RP#57 Core completed. RP#58 Perf completed / Impacted TSs and TRs: LTE
- 1893: RP#57 completed. RP#59 new generic TR 36.850v100 for Information and Approval / Impacted TSs and TRs: 36.101, 36.104, 36.133, 36.141, 36.307, new generic TR 36.850
- 1894: RP#58 completed / Impacted TSs and TRs: 36.101, 36.104, 36.133, 36.307
- 1895: Stage 3. RP#58 completed / Impacted TSs and TRs: LTE
- 1896: RP#58 completed. RP#59 new generic TR 36.850v100 for Information and Approval / Impacted TSs and TRs: 36.101, 36.104, 36.133, 36.141, 36.307, new generic TR 36.850
- 1897: RP#58 completed / Impacted TSs and TRs: 36.101, 36.104, 36.133, 36.307

| ID | WBS | Task | Duration | Start | Finish | Complete | Baseline start | Baseline finish | Baseline duration | Constraint | Resources | Work | Actual work | Acronym | PCG approved | WI rapporteur name | WI rapporteur e-mail | Release | TSG approved | MCC resp | Special Focus Doc | Acronym_3GU_Export | Status Report |
| --- | --- | --- | --- | --- | --- | --- | --- | --- | --- | --- | --- | --- | --- | --- | --- | --- | --- | --- | --- | --- | --- | --- | --- |
| 1898 | 443.3.9 | **LTE Advanced Carrier Aggregation of Band 5 and Band 17** | 455d? | 2011-03-23 A | 2012-12-07 A | 100% | 2011-03-23 | 2012-12-07 | 455d? |  | R4 | 10856h | 10856h | LTE_CA_B5_B17 | PCG-26 | AT&T | marc.grant@att.com | Rel-11 | RP-51 | Issam | CA | LTE_CA_B5_B17 |  |
| 1899 | 443.3.9.1 | Core part: LTE Advanced Carrier Aggregation of Band 5 and Band 17 | 451d? | 2011-03-23 A | 2012-12-07 A | 100% | 2011-03-23 | 2012-12-07 | 451d? | finish no earlier than 2012-12-07 | R4 | 3608h | 3608h | LTE_CA_B5_B17-Core | PCG-26 | AT&T | marc.grant@att.com | Rel-11 | RP-51 | Issam | CA | LTE_CA_B5_B17-Core | RP-121598 |
| 1900 | 443.3.9.2 | Perf. part: LTE Advanced Carrier Aggregation of Band 5 and Band 17 | 451d? | 2011-03-25 A | 2012-12-07 A | 100% | 2011-03-25 | 2012-12-07 | 451d? | finish no earlier than 2012-12-07 | R4 | 3608h | 3608h | LTE_CA_B5_B17-Perf | PCG-26 | AT&T | marc.grant@att.com | Rel-11 | RP-51 | Issam | CA | LTE_CA_B5_B17-Perf | RP-121599 |
| 1901 | 443.3.10 | **LTE Advanced Carrier Aggregation of Band 3 and Band 20** | 258d? | 2011-09-19 A | 2012-09-07 A | 100% | 2011-09-19 | 2012-09-07 | 258d? |  | R4 | 6168h | 6168h | LTE_CA_B3_B20 | PCG-27 | Vodafone | tim.frost@vodafone.com | Rel-11 | RP-53 | Issam | CA | LTE_CA_B3_B20 |  |
| 1902 | 443.3.10.1 | Core part: LTE Advanced Carrier Aggregation of Band 3 and Band 20 | 256d? | 2011-09-19 A | 2012-09-07 A | 100% | 2011-09-19 | 2012-09-07 | 256d? | finish no earlier than 2012-09-07 | R4 | 2048h | 2048h | LTE_CA_B3_B20-Core | PCG-27 | Vodafone | tim.frost@vodafone.com | Rel-11 | RP-53 | Issam | CA | LTE_CA_B3_B20-Core | RP-121046 |
| 1903 | 443.3.10.2 | Perf. part: LTE Advanced Carrier Aggregation of Band 3 and Band 20 | 257d? | 2011-09-20 A | 2012-09-07 A | 100% | 2011-09-20 | 2012-09-07 | 257d? | finish no earlier than 2012-09-07 | R4 | 2056h | 2056h | LTE_CA_B3_B20-Perf | PCG-27 | Vodafone | tim.frost@vodafone.com | Rel-11 | RP-53 | Issam | CA | LTE_CA_B3_B20-Perf | RP-121047 |
| 1904 | 443.3.11 | **LTE Advanced Carrier Aggregation of Band 8 and Band 20** | 325d? | 2011-09-19 A | 2012-12-07 A | 100% | 2011-09-19 | 2012-12-07 | 325d? |  | R4 | 7752h | 7752h | LTE_CA_B8_B20 | PCG-27 | Vodafone | Luis.Anaya@vodafone.com | Rel-11 | RP-53 | Issam | CA | LTE_CA_B8_B20 |  |
| 1905 | 443.3.11.1 | Core part: LTE Advanced Carrier Aggregation of Band 8 and Band 20 | 323d? | 2011-09-19 A | 2012-12-07 A | 100% | 2011-09-19 | 2012-12-07 | 323d? | finish no earlier than 2012-12-07 | R4 | 2584h | 2584h | LTE_CA_B8_B20-Core | PCG-27 | Vodafone | Luis.Anaya@vodafone.com | Rel-11 | RP-53 | Issam | CA | LTE_CA_B8_B20-Core | RP-121600 |
| 1906 | 443.3.11.2 | Perf. part: LTE Advanced Carrier Aggregation of Band 8 and Band 20 | 321d? | 2011-09-23 A | 2012-12-07 A | 100% | 2011-09-23 | 2012-12-07 | 321d? | finish no earlier than 2012-12-07 | R4 | 2568h | 2568h | LTE_CA_B8_B20-Perf | PCG-27 | Vodafone | Luis.Anaya@vodafone.com | Rel-11 | RP-53 | Issam | CA | LTE_CA_B8_B20-Perf | RP-121601 |
| 1907 | 443.3.12 | **LTE Advanced Carrier Aggregation of Band 3 and Band 5** | 258d? | 2011-09-19 A | 2012-09-07 A | 100% | 2011-09-19 | 2012-09-07 | 258d? |  | R4 | 6160h | 6160h | LTE_CA_B3_B5 | PCG-27 | SK Telecom | Haesung Park | Rel-11 | RP-53 | Issam | CA | LTE_CA_B3_B5 |  |
| 1908 | 443.3.12.1 | Core part: LTE Advanced Carrier Aggregation of Band 3 and Band 5 | 256d? | 2011-09-19 A | 2012-09-07 A | 100% | 2011-09-19 | 2012-09-07 | 256d? | finish no earlier than 2012-09-07 | R4 | 2048h | 2048h | LTE_CA_B3_B5-Core | PCG-27 | SK Telecom | Haesung Park | Rel-11 | RP-53 | Issam | CA | LTE_CA_B3_B5-Core | RP-121042 |
| 1909 | 443.3.12.2 | Perf. part: LTE Advanced Carrier Aggregation of Band 3 and Band 5 | 256d? | 2011-09-21 A | 2012-09-07 A | 100% | 2011-09-21 | 2012-09-07 | 256d? | finish no earlier than 2012-09-07 | R4 | 2048h | 2048h | LTE_CA_B3_B5-Perf | PCG-27 | SK Telecom | Haesung Park | Rel-11 | RP-53 | Issam | CA | LTE_CA_B3_B5-Perf | RP-121043 |
| 1910 | 443.3.13 | **LTE Advanced Carrier Aggregation of Band 4 and Band 7** | 325d? | 2011-09-19 A | 2012-12-07 A | 100% | 2011-09-19 | 2012-12-07 | 325d? |  | R4 | 7744h | 7744h | LTE_CA_B4_B7 | PCG-27 | Rogers Wireless | takwing.wan@rci.rogers.com | Rel-11 | RP-53 | Issam | CA | LTE_CA_B4_B7 |  |
| 1911 | 443.3.13.1 | Core part: LTE Advanced Carrier Aggregation of Band 4 and Band 7 | 322d? | 2011-09-19 A | 2012-12-07 A | 100% | 2011-09-19 | 2012-12-07 | 322d? | finish no earlier than 2012-12-07 | R4 | 2576h | 2576h | LTE_CA_B4_B7-Core | PCG-27 | Rogers Wireless | takwing.wan@rci.rogers.com | Rel-11 | RP-53 | Issam | CA | LTE_CA_B4_B7-Core | RP-121590 |
| 1912 | 443.3.13.2 | Perf. part: LTE Advanced Carrier Aggregation of Band 4 and Band 7 | 321d? | 2011-09-23 A | 2012-12-07 A | 100% | 2011-09-23 | 2012-12-07 | 321d? | finish no earlier than 2012-12-07 | R4 | 2568h | 2568h | LTE_CA_B4_B7-Perf | PCG-27 | Rogers Wireless | takwing.wan@rci.rogers.com | Rel-11 | RP-53 | Issam | CA | LTE_CA_B4_B7-Perf | RP-121591 |
| 1913 | 443.3.14 | **LTE Advanced Carrier Aggregation of Band 11 and Band 18** | 265d? | 2011-12-09 A | 2012-12-07 A | 100% | 2011-12-09 | 2012-12-07 | 265d? |  | R4; R2 | 10568h | 10568h | LTE_CA_B11_B18 | PCG-28 | KDDI | Masaaki Obara (ms-obara@kddi.com) | Rel-11 | RP-54 | Issam | CA | LTE_CA_B11_B18 |  |
| 1914 | 443.3.14.1 | Core part: LTE Advanced Carrier Aggregation of Band 11 and Band 18 | 265d? | 2011-12-09 A | 2012-12-07 A | 100% | 2011-12-09 | 2012-12-07 | 265d? | finish no earlier than 2012-12-07 | R4; R2 | 4240h | 4240h | LTE_CA_B11_B18-Core | PCG-28 | KDDI | Masaaki Obara (ms-obara@kddi.com) | Rel-11 | RP-54 | Issam | CA | LTE_CA_B11_B18-Core | RP-121602 |
| 1915 | 443.3.14.2 | Perf. part: LTE Advanced Carrier Aggregation of Band 11 and Band 18 | 261d? | 2011-12-15 A | 2012-12-07 A | 100% | 2011-12-15 | 2012-12-07 | 261d? | finish no earlier than 2012-12-07 | R4 | 2088h | 2088h | LTE_CA_B11_B18-Perf | PCG-28 | KDDI | Masaaki Obara (ms-obara@kddi.com) | Rel-11 | RP-54 | Issam | CA | LTE_CA_B11_B18-Perf | RP-121603 |
| 1916 | 443.3.15 | **LTE Advanced Carrier Aggregation of Band 1 and Band 18** | 198d? | 2011-12-09 A | 2012-09-07 A | 100% | 2011-12-09 | 2012-09-07 | 198d? |  | R4; R2 | 7904h | 7904h | LTE_CA_B1_B18 | PCG-28 | KDDI | Masaaki Obara (ms-obara@kddi.com) | Rel-11 | RP-54 | Issam | CA | LTE_CA_B1_B18 |  |
| 1917 | 443.3.15.1 | Core part: LTE Advanced Carrier Aggregation of Band 1 and Band 18 | 198d? | 2011-12-09 A | 2012-09-07 A | 100% | 2011-12-09 | 2012-09-07 | 198d? | finish no earlier than 2012-09-07 | R4; R2 | 3168h | 3168h | LTE_CA_B1_B18-Core | PCG-28 | KDDI | Masaaki Obara (ms-obara@kddi.com) | Rel-11 | RP-54 | Issam | CA | LTE_CA_B1_B18-Core | RP-121052 |
| 1918 | 443.3.15.2 | Perf. part: LTE Advanced Carrier Aggregation of Band 1 and Band 18 | 196d? | 2011-12-13 A | 2012-09-07 A | 100% | 2011-12-13 | 2012-09-07 | 196d? | finish no earlier than 2012-12-07 | R4 | 1568h | 1568h | LTE_CA_B1_B18-Perf | PCG-28 | KDDI | Masaaki Obara (ms-obara@kddi.com) | Rel-11 | RP-54 | Issam | CA | LTE_CA_B1_B18-Perf | RP-121053 |
| 1919 | 443.3.16 | **LTE Advanced Carrier Aggregation of Band 1 and Band 19** | 197d? | 2011-12-12 A | 2012-09-07 A | 100% | 2011-12-12 | 2012-09-07 | 197d? |  | R4; R2 | 6432h | 6432h | LTE_CA_B1_B19 | PCG-28 | NTT DoCoMo | Hiromasa Umeda (umedah@nttdocomo.co.jp) | Rel-11 | RP-54 | Issam | CA | LTE_CA_B1_B19 |  |
| 1920 | 443.3.16.1 | Core part: LTE Advanced Carrier Aggregation of Band 1 and Band 19 | 137d? | 2012-03-05 A | 2012-09-07 A | 100% | 2012-03-05 | 2012-09-07 | 137d? | finish no earlier than 2012-09-07 | R4; R2 | 2192h | 2192h | LTE_CA_B1_B19-Core | PCG-28 | NTT DoCoMo | Hiromasa Umeda (umedah@nttdocomo.co.jp) | Rel-11 | RP-54 | Issam | CA | LTE_CA_B1_B19-Core | RP-120552 |
| 1921 | 443.3.16.2 | Perf. part: LTE Advanced Carrier Aggregation of Band 1 and Band 19 | 136d? | 2011-12-12 A | 2012-06-15 A | 100% | 2011-12-12 | 2012-06-15 | 136d? | finish no earlier than 2012-12-07 | R4 | 1088h | 1088h | LTE_CA_B1_B19-Perf | PCG-28 | NTT DoCoMo | Hiromasa Umeda (umedah@nttdocomo.co.jp) | Rel-11 | RP-54 | Issam | CA | LTE_CA_B1_B19-Perf | RP-120553 |

Notes:
- 1898: Stage 3. RP#58 completed / Impacted TSs and TRs: LTE
- 1899: RP#58 completed. RP#59 new generic TR 36.850v100 for Information and Approval / Impacted TSs and TRs: 36.101, 36.104, 36.133, 36.141, 36.307, new generic TR 36.850
- 1900: RP#58 completed / Impacted TSs and TRs: 36.101, 36.104, 36.133, 36.141, 36.307
- 1901: Stage 3. RP#57 completed / Impacted TSs and TRs: LTE
- 1902: RP#57 completed. RP#59 new generic TR 36.850v100 for Information and Approval / Impacted TSs and TRs: 36.101, 36.104, 36.133, 36.307, new generic TR 36.850
- 1903: RP#57 completed / Impacted TSs and TRs: 36.101, 36.104, 36.133, 36.141, 36.307
- 1904: Stage 3. RP#58 completed / Impacted TSs and TRs: LTE
- 1905: RP#58 completed. RP#59 new generic TR 36.850v100 for Information and Approval / Impacted TSs and TRs: 36.101, 36.104, 36.307, new generic TR 36.850
- 1906: RP#58 completed / Impacted TSs and TRs: 36.101, 36.104, 36.133, 36.141
- 1907: Stage 3. RP#57 completed / Impacted TSs and TRs: LTE
- 1908: RP#57 completed. RP#59 new generic TR 36.850v100 for Information and Approval / Impacted TSs and TRs: 36.101, 36.104, 36.133, 36.307, new generic TR 36.850
- 1909: RP#57 completed / Impacted TSs and TRs: 36.133, 36.141
- 1910: Stage 3. RP#58 completed / Impacted TSs and TRs: LTE
- 1911: RP#58 completed. RP#59 new generic TR 36.850v100 for Information and Approval / Impacted TSs and TRs: 36.101, 36.104, 36.133, 36.141, 36.307, 37.104, new generic TR 36.850
- 1912: RP#58 completed / Impacted TSs and TRs: 36.101, 36.104, 36.133, 36.141, 36.307
- 1913: Stage 3. RP#58 completed / Impacted TSs and TRs: LTE
- 1914: RP#58 completed. RP#59 new generic TR 36.850v100 for Information and Approval / Impacted TSs and TRs: 36.101, 36.104, 36.307, new generic TR 36.850
- 1915: RP#58 completed / Impacted TSs and TRs: 36.133
- 1916: Stage 3. RP#57 completed / Impacted TSs and TRs: LTE
- 1917: RP#57 completed. RP#59 new generic TR 36.850v100 for Information and Approval / Impacted TSs and TRs: 36.101, 36.104, 36.307, new generic TR 36.850
- 1918: RP#57 completed / Impacted TSs and TRs: 36.133, 36.141
- 1919: Stage 3. RP#56 completed. Updated WID RP-111765=>RP-120866 / Impacted TSs and TRs: LTE
- 1920: RP#56 completed. RP#59 new generic TR 36.850v100 for Information and Approval / Impacted TSs and TRs: 36.101, 36.104, 36.133, 36.307, new generic TR 36.850
- 1921: RP#56 completed / Impacted TSs and TRs: 36.133, 36.141

| ID | WBS | Task | Duration | Start | Finish | Complete | Remaining | Baseline start | Baseline finish | Baseline duration | Total slack | Constraint | Resources | Work | Actual work | Acronym | PCG approved | WI rapporteur name | Release | TSG approved | MCC resp | Special Focus Doc | Acronym_3GU_Export | Status Report |
| --- | --- | --- | --- | --- | --- | --- | --- | --- | --- | --- | --- | --- | --- | --- | --- | --- | --- | --- | --- | --- | --- | --- | --- | --- |
| 1922 | 443.3.17 | **LTE Advanced Carrier Aggregation of Band 1 and Band 21** | 265d? | 2011-12-09 A | 2012-12-07 A | 100% |  | 2011-12-09 | 2012-12-07 | 265d? |  |  | R4; R2 | 9496h | 9496h | LTE_CA_B1_B21 | PCG-28 | NTT DoCoMo | Rel-11 | RP-54 | Issam | CA | LTE_CA_B1_B21 |  |
| 1923 | 443.3.17.1 | Core part: LTE Advanced Carrier Aggregation of Band 1 and Band 21 | 198d? | 2011-12-09 A | 2012-09-07 A | 100% |  | 2011-12-09 | 2012-09-07 | 198d? |  | finish no earlier than 2012-09-07 | R4; R2 | 3168h | 3168h | LTE_CA_B1_B21-Core | PCG-28 | NTT DoCoMo | Rel-11 | RP-54 | Issam | CA | LTE_CA_B1_B21-Core | RP-121054 |
| 1924 | 443.3.17.2 | Perf. part: LTE Advanced Carrier Aggregation of Band 1 and Band 21 | 263d? | 2011-12-13 A | 2012-12-07 A | 100% |  | 2011-12-13 | 2012-12-07 | 263d? |  | finish no earlier than 2012-12-07 | R4 | 2088h | 2088h | LTE_CA_B1_B21-Perf | PCG-28 | NTT DoCoMo | Rel-11 | RP-54 | Issam | CA | LTE_CA_B1_B21-Perf | RP-121055 |
| 1925 | 443.3.18 | **LTE Advanced Carrier Aggregation of Band 3 and Band 8** | 204d? | 2012-03-05 A | 2012-12-07 A | 100% |  | 2012-03-05 | 2012-12-07 | 204d? |  |  | R4 | 4864h | 4864h | LTE_CA_B3_B8 | PCG-28 | KT | Rel-11 | RP-55 | Issam | CA | LTE_CA_B3_B8 |  |
| 1926 | 443.3.18.1 | Core part: LTE Advanced Carrier Aggregation of Band 3 and Band 8 | 201d? | 2012-03-05 A | 2012-12-07 A | 100% |  | 2012-03-05 | 2012-12-07 | 201d? |  | finish no earlier than 2012-12-07 | R4 | 1608h | 1608h | LTE_CA_B3_B8-Core | PCG-28 | KT | Rel-11 | RP-55 | Issam | CA | LTE_CA_B3_B8-Core | RP-121586 |
| 1927 | 443.3.18.2 | Perf. part: LTE Advanced Carrier Aggregation of Band 3 and Band 8 | 203d? | 2012-03-06 A | 2012-12-07 A | 100% |  | 2012-03-06 | 2012-12-07 | 203d? |  | finish no earlier than 2012-12-07 | R4 | 1624h | 1624h | LTE_CA_B3_B8-Perf | PCG-28 | KT | Rel-11 | RP-55 | Issam | CA | LTE_CA_B3_B8-Perf | RP-121587 |
| 1928 | 443.4 | **Rel-11 intra-band Carrier Aggregation** | 334d? | 2011-06-07 A | 2012-09-07 A | 100% |  | 2011-06-07 | 2012-09-07 | 334d? |  |  | RP | 18864h | 18864h |  | PCG-30 |  | Rel-11 | RP-58 |  | CA |  |  |
| 1929 | 443.4.1 | **LTE Advanced Carrier Aggregation in Band 38** | 334d? | 2011-06-07 A | 2012-09-07 A | 100% |  | 2011-06-07 | 2012-09-07 | 334d? |  |  | R4 | 7976h | 7976h | LTE_CA_B38 | PCG-27 | Huawei | Rel-11 | RP-52 | Issam | CA | LTE_CA_B38 |  |
| 1930 | 443.4.1.1 | Core part: LTE Advanced Carrier Aggregation in Band 38 | 331d? | 2011-06-07 A | 2012-09-07 A | 100% |  | 2011-06-07 | 2012-09-07 | 331d? |  | finish no earlier than 2012-09-07 | R4 | 2648h | 2648h | LTE_CA_B38-Core | PCG-27 | Huawei | Rel-11 | RP-52 | Issam | CA | LTE_CA_B38-Core | RP-121060 |
| 1931 | 443.4.1.2 | Perf. part: LTE Advanced Carrier Aggregation in Band 38 | 333d? | 2011-06-08 A | 2012-09-07 A | 100% |  | 2011-06-08 | 2012-09-07 | 333d? |  | finish no earlier than 2012-09-07 | R4 | 2656h | 2656h | LTE_CA_B38-Perf | PCG-27 | Huawei | Rel-11 | RP-52 | Issam | CA | LTE_CA_B38-Perf | RP-121061 |
| 1932 | 443.4.2 | **LTE Advanced Carrier Aggregation in Band 41** | 197d? | 2011-06-07 A | 2012-03-02 A | 100% |  | 2011-06-07 | 2012-03-02 | 197d? |  |  | R4 | 4720h | 4720h | LTE_CA_B41 | PCG-27 | Clearwire | Rel-11 | RP-52 | Issam | CA | LTE_CA_B41 |  |
| 1933 | 443.4.2.1 | Core part: LTE Advanced Carrier Aggregation in Band 41 | 196d? | 2011-06-07 A | 2012-03-02 A | 100% |  | 2011-06-07 | 2012-03-02 | 196d? |  | finish no earlier than 2012-02-23 | R4 | 1568h | 1568h | LTE_CA_B41-Core | PCG-27 | Clearwire | Rel-11 | RP-52 | Issam | CA | LTE_CA_B41-Core | RP-120126 |
| 1934 | 443.4.2.2 | Perf. part: LTE Advanced Carrier Aggregation in Band 41 | 197d? | 2011-06-07 A | 2012-03-02 A | 100% |  | 2011-06-07 | 2012-03-02 | 197d? |  | finish no earlier than 2012-03-02 | R4 | 1576h | 1576h | LTE_CA_B41-Perf | PCG-27 | Clearwire | Rel-11 | RP-52 | Issam | CA | LTE_CA_B41-Perf | RP-120127 |
| 1935 | 443.4.3 | **LTE Advanced Carrier Aggregation in Band 7** | 258d? | 2011-09-19 A | 2012-09-07 A | 100% |  | 2011-09-19 | 2012-09-07 | 258d? |  |  | R4 | 6168h | 6168h | LTE_CA_B7 | PCG-27 | China Unicom | Rel-11 | RP-53 | Issam | CA | LTE_CA_B7 |  |
| 1936 | 443.4.3.1 | Core part: LTE Advanced Carrier Aggregation in Band 7 | 256d? | 2011-09-19 A | 2012-09-07 A | 100% |  | 2011-09-19 | 2012-09-07 | 256d? |  | finish no earlier than 2012-09-07 | R4 | 2048h | 2048h | LTE_CA_B7-Core | PCG-27 | China Unicom | Rel-11 | RP-53 | Issam | CA | LTE_CA_B7-Core | RP-121062 |
| 1937 | 443.4.3.2 | Perf. part: LTE Advanced Carrier Aggregation in Band 7 | 257d? | 2011-09-20 A | 2012-09-07 A | 100% |  | 2011-09-20 | 2012-09-07 | 257d? |  | finish no earlier than 2012-09-07 | R4 | 2056h | 2056h | LTE_CA_B7-Perf | PCG-27 | China Unicom | Rel-11 | RP-53 | Issam | CA | LTE_CA_B7-Perf | RP-121063 |
| 1938 | 444 | **UE Over The Air (Antenna) conformance testing methodology - Laptop mounted equipment Free Space test** | 1775d? | 2009-09-18 A | 2016-06-15 | 97% | 61.57d? | 2009-09-18 | 2014-12-05 | 1374d? | 261d |  | R4; R5 | 43584h | 23999.6h | UEAnt_FSTest | PCG-23 | CATR | Rel-11 | RP-45 | Issam |  | UEAnt_FSTest |  |
| 1939 | 444.1 | Core part: UE Over The Air (Antenna) conformance testing methodology - Laptop mounted equipment Free Space test | 583d? | 2009-09-18 A | 2011-12-09 A | 100% |  | 2009-09-18 | 2011-12-09 | 583d? |  | finish no earlier than 2011-12-09 | R4 | 4664h | 4664h | UEAnt_FSTest-Core | PCG-23 | CATR | Rel-11 | RP-45 | Issam |  | UEAnt_FSTest-Core | RP-111456 |
| 1940 | 444.2 | Test part: UE Over The Air (Antenna) conformance testing methodology - Laptop mounted equipment Free Space test | 1321d? | 2011-06-15 A | 2016-06-15 | 95% | 66.05d? | 2011-06-07 | 2014-12-05 | 926d? | 261d | finish no earlier than 2016-06-15 | R5 | 10520h | 9991.6h | UEAnt_FSTest-UEConTest | PCG-27 | ZTE | Rel-11 | RP-52 | Ingbert |  | UEAnt_FSTest-UEConTest | RP-150068 |
| 1941 | 445 | **Eight carrier HSDPA** | 589d? | 2010-09-15 A | 2012-12-07 A | 100% |  | 2010-09-15 | 2012-12-07 | 589d? |  |  | R1; R2; R3; R4 | 37768h | 37768h | 8C_HSDPA | PCG-26 | Ericsson | Rel-11 | RP-50 | Patrick |  | 8C_HSDPA |  |
| 1942 | 445.1 | Core part: Eight carrier HSDPA | 461d? | 2010-09-15 A | 2012-06-15 A | 100% |  | 2010-09-15 | 2012-06-15 | 461d? |  | finish no earlier than 2012-06-15 | R1; R2; R3; R4 | 14752h | 14752h | 8C_HSDPA-Core | PCG-26 | Ericsson | Rel-11 | RP-50 | Patrick |  | 8C_HSDPA-Core | RP-120971 |
| 1943 | 445.2 | Perf. part: Eight carrier HSDPA | 523d? | 2010-12-15 A | 2012-12-07 A | 100% |  | 2010-12-15 | 2012-12-07 | 523d? |  | finish no earlier than 2012-12-07 | R4 | 4168h | 4168h | 8C_HSDPA-Perf | PCG-26 | Ericsson | Rel-11 | RP-50 | Issam |  | 8C_HSDPA-Perf | RP-120972 |
| 1944 | 446 | **UE demodulation performance requirements under multiple-cell scenario for 1.28Mcps TDD** | 324d? | 2010-12-10 A | 2012-03-02 A | 100% |  | 2010-12-10 | 2012-03-02 | 324d? |  |  | R4; R5 | 7760h | 7760h | LCR_TDD_UE_demod_mc | PCG-26 | China Mobile | Rel-11 | RP-50 | Issam |  | LCR_TDD_UE_demod_mc |  |
| 1945 | 446.1 | Perf. part: UE demodulation performance requirements under multiple-cell scenario for 1.28Mcps TDD | 201d? | 2010-12-10 A | 2011-09-16 A | 100% |  | 2010-12-10 | 2011-09-16 | 201d? |  | finish no earlier than 2011-09-16 | R4 | 1608h | 1608h | LCR_TDD_UE_demod_mc-Perf | PCG-26 | China Mobile | Rel-11 | RP-50 | Issam |  | LCR_TDD_UE_demod_mc-Perf | RP-110996 |
| 1946 | 446.2 | Test part: UE demodulation performance requirements under multiple-cell scenario for 1.28Mcps TDD | 121d? | 2011-09-19 A | 2012-03-02 A | 100% |  | 2011-09-19 | 2012-03-02 | 121d? |  | finish no earlier than 2012-02-23 | R5 | 968h | 968h | LCR_TDD_UE_demod_mc-UEConTest | PCG-27 | China Mobile | Rel-11 | RP-53 | Ingbert |  | LCR_TDD_UE_demod_mc-UEConTest | RP-120052 |

Notes:
- 1922: Stage 3. RP#57 completed. Updated WID RP-111764=>RP-121173 / Impacted TSs and TRs: LTE / WI rapporteur e-mail: Hiromasa Umeda (umedah@nttdocomo.co.jp)
- 1923: RP#57 completed. RP#59 new generic TR 36.850v100 for Information and Approval / Impacted TSs and TRs: 36.101, 36.104, 36.133, 36.307, new generic TR 36.850 / WI rapporteur e-mail: Hiromasa Umeda (umedah@nttdocomo.co.jp)
- 1924: RP#57 completed / Impacted TSs and TRs: 36.133, 36.141 / WI rapporteur e-mail: Hiromasa Umeda (umedah@nttdocomo.co.jp)
- 1925: Stage 3. RP#58 completed / Impacted TSs and TRs: LTE / WI rapporteur e-mail: Chungwoo HWANG (cwhwang@kt.com)
- 1926: RP#58 completed. RP#59 new generic TR 36.850v100 for Information and Approval / Impacted TSs and TRs: 36.101, 36.104, 36.133, 36.307, new generic TR 36.850 / WI rapporteur e-mail: Chungwoo HWANG (cwhwang@kt.com)
- 1927: RP#58 completed / Impacted TSs and TRs: 36.133, 36.141 / WI rapporteur e-mail: Chungwoo HWANG (cwhwang@kt.com)
- 1928: LTE_CA_Rel-11 / Impacted TSs and TRs: LTE
- 1929: Stage 3. RP#57 completed. WI only covers intra-band contiguous and not non-contiguous aspects / Impacted TSs and TRs: LTE / WI rapporteur e-mail: ronnie.zhang@huawei.com
- 1930: RP#57 completed. TR 36.830 v100 for Information & Approval / Impacted TSs and TRs: 36.101, 36.104, 36.133, 36.141, 36.307, 37.104, 37.141, new TR 36.833-1-38 [instead of 36.830] / WI rapporteur e-mail: ronnie.zhang@huawei.com
- 1931: RP#57 completed / Impacted TSs and TRs: 36.101, 36.104, 36.133, 36.141, 36.307, 37.104, 37.141 / WI rapporteur e-mail: ronnie.zhang@huawei.com
- 1932: RP#55 completed. WI only covers intra-band contiguous and not non-contiguous aspects. / Impacted TSs and TRs: LTE / WI rapporteur e-mail: michael.hart@clearwire.com
- 1933: RP#55 completed. Updated WID RP-110673=>RP-120249. TR 36.827 v100 for Information + Approval / Impacted TSs and TRs: 36.101, 36.104, 36.133, 36.141, 36.307, 37.104, new TR 36.833-1-41 [instead of 36.827] / WI rapporteur e-mail: michael.hart@clearwire.com
- 1934: RP#55 completed / Impacted TSs and TRs: 36.101, 36.104, 36.133, 36.141, 36.307 / WI rapporteur e-mail: michael.hart@clearwire.com
- 1935: Stage 3. RP#57 completed. Updated WID RP-111356=>RP-121193. WI only covers intra-band contiguous and not non-contiguous aspects / Impacted TSs and TRs: LTE / WI rapporteur e-mail: Zhangchao Ma (mazc@chinaunicom.cn), Zhonghao Zhang (zhangzh306@chinaunicom.cn)
- 1936: RP#57 completed. TR 36.831 v100 for Information & Approval / Impacted TSs and TRs: 36.101, 36.104, 36.133, 36.141, 36.307, 37.104, 37.141, new TR 36.833-1-07 [instead of 36.831] / WI rapporteur e-mail: Zhangchao Ma (mazc@chinaunicom.cn), Zhonghao Zhang (zhangzh306@chinaunicom.cn)
- 1937: RP#57 completed / Impacted TSs and TRs: 36.101, 36.104, 36.133, 36.141, 36.307, 37.104, 37.141 / WI rapporteur e-mail: Zhangchao Ma (mazc@chinaunicom.cn), Zhonghao Zhang (zhangzh306@chinaunicom.cn)
- 1938: - / Impacted TSs and TRs: UTRA / WI rapporteur e-mail: Guo Lin (guolin@emcite.com)
- 1939: RP#54 completed / Impacted TSs and TRs: 25.144, 25.914, 34.114 / WI rapporteur e-mail: Guo Lin (guolin@emcite.com)
- 1940: 1st Apr 15: CD:Mon 15/06/15->Wed 15/06/16 1st Apr 15: Stat Rep: RP-141846->RP-150068 / Impacted TSs and TRs: 34.114 / WI rapporteur e-mail: carolyn.tayl@zte.com.cn
- 1941: Stage 3 / Impacted TSs and TRs: UTRA / WI rapporteur e-mail: johan.hultell@ericsson.com
- 1942: RP#57 completed / Impacted TSs and TRs: 25.101, 25.104, 25.133, 25.211, 25.212, 25.213, 25.214, 25.215, 25.308, 25.331, 25.423, 25.433, 26.306 / WI rapporteur e-mail: johan.hultell@ericsson.com
- 1943: RP#57 completed / Impacted TSs and TRs: 25.101, 25.104, 25.133, 25.141 / WI rapporteur e-mail: johan.hultell@ericsson.com
- 1944: Stage 3 / Impacted TSs and TRs: UTRA / WI rapporteur e-mail: Li Nan (linan@chinamobile.com)
- 1945: RP#53 completed. TR 25.873v100 for Approval / Impacted TSs and TRs: 25.102, new TR 25.873 / WI rapporteur e-mail: Li Nan (linan@chinamobile.com)
- 1946: RP#55 completed / Impacted TSs and TRs: 34.108, 34.122 / WI rapporteur e-mail: Ma Shuai (mashuai@chinamobile.com)

| ID | WBS | Task | Duration | Start | Finish | Complete | Remaining | Baseline start | Baseline finish | Baseline duration | Total slack | Constraint | Resources | Work | Actual work | Acronym | PCG approved | WI rapporteur name | WI rapporteur e-mail | Release | TSG approved | MCC resp | Acronym_3GU_Export | Status Report |
| --- | --- | --- | --- | --- | --- | --- | --- | --- | --- | --- | --- | --- | --- | --- | --- | --- | --- | --- | --- | --- | --- | --- | --- | --- |
| 1947 | 447 | **Uplink Transmit Diversity for HSPA** | 929d? | 2010-12-10 A | 2014-06-13 A | 100% |  | 2010-12-10 | 2014-06-13 | 929d? |  |  | R1; R4; R2; R3; R5 | 83568.3h | 83568.3h | HSPA_UL_TxDiv | PCG-26 | Huawei | zongjie.wang@huawei.com | Rel-11 | RP-50 | Patrick | HSPA_UL_TxDiv |  |
| 1948 | 447.1 | Core part: Uplink Transmit Diversity for HSPA - Closed Loop | 528d? | 2010-12-10 A | 2012-12-07 A | 100% |  | 2010-12-10 | 2012-12-07 | 528d? |  | finish no earlier than 2012-12-07 | R1; R4; R2; R3 | 16896h | 16896h | HSPA_UL_TxDiv-CL-Core | PCG-26 | Huawei | zongjie.wang@huawei.com | Rel-11 | RP-50 | Patrick | HSPA_UL_TxDiv-CL-Core | RP-121542 |
| 1949 | 447.2 | Perf. part: Uplink Transmit Diversity for HSPA - Closed Loop | 721d? | 2010-12-14 A | 2013-09-06 A | 100% |  | 2010-12-14 | 2013-09-06 | 721d? |  | finish no earlier than 2013-09-06 | R4 | 5760.31h | 5760.31h | HSPA_UL_TxDiv-CL-Perf | PCG-26 | Huawei | zongjie.wang@huawei.com | Rel-11 | RP-50 | Issam | HSPA_UL_TxDiv-CL-Perf | RP-130477 |
| 1950 | 447.3 | Core part: Uplink Transmit Diversity for HSPA - Open Loop | 528d? | 2010-12-10 A | 2012-12-07 A | 100% |  | 2010-12-10 | 2012-12-07 | 528d? |  | finish no earlier than 2012-12-07 | R4; R1; R2; R3 | 16896h | 16896h | HSPA_UL_TxDiv-OL-Core | PCG-26 | Huawei | zongjie.wang@huawei.com | Rel-11 | RP-50 | Patrick | HSPA_UL_TxDiv-OL-Core | RP-121544 |
| 1951 | 447.4 | Perf. part: Uplink Transmit Diversity for HSPA - Open Loop | 521d? | 2010-12-14 A | 2012-12-07 A | 100% |  | 2010-12-14 | 2012-12-07 | 521d? |  | finish no earlier than 2012-12-07 | R4 | 4168h | 4168h | HSPA_UL_TxDiv-OL-Perf | PCG-26 | Huawei | zongjie.wang@huawei.com | Rel-11 | RP-50 | Issam | HSPA_UL_TxDiv-OL-Perf | RP-121545 |
| 1952 | 447.5 | Test part: Uplink Transmit Diversity for HSPA | 336d? | 2013-03-04 A | 2014-06-13 A | 100% |  | 2013-03-04 | 2014-06-13 | 336d? |  | finish no earlier than 2014-06-13 | R5 | 2688h | 2688h | HSPA_UL_TxDiv-UEConTest | PCG-30 | Qualcomm | Shubhang Vora (svora@qti.qualcomm.com) | Rel-11 | RP-59 | Ingbert | HSPA_UL_TxDiv-UEConTest | RP-140767 |
| 1953 | 448 | **Introduction of New Configuration for 4C-HSDPA** | 328d? | 2011-03-22 A | 2012-06-15 A | 100% |  | 2011-03-22 | 2012-06-15 | 328d? |  |  | R4; R2 | 10928h | 10928h | 4C_HSDPA_Config | PCG-26 | Telus Communications | jorge.delrio@telus.com | Rel-11 | RP-51 | Issam | 4C_HSDPA_Config |  |
| 1954 | 448.1 | Core part: Introduction of New Configuration for 4C-HSDPA | 192d? | 2011-03-22 A | 2011-12-09 A | 100% |  | 2011-03-22 | 2011-12-09 | 192d? |  | finish no earlier than 2011-12-09 | R4; R2 | 3072h | 3072h | 4C_HSDPA_Config-Core | PCG-26 | Telus Communications | jorge.delrio@telus.com | Rel-11 | RP-51 | Issam | 4C_HSDPA_Config-Core | RP-111463 |
| 1955 | 448.2 | Perf. part: Introduction of New Configuration for 4C-HSDPA | 326d? | 2011-03-24 A | 2012-06-15 A | 100% |  | 2011-03-24 | 2012-06-15 | 326d? |  | finish no earlier than 2012-06-15 | R4 | 2608h | 2608h | 4C_HSDPA_Config-Perf | PCG-26 | Telus Communications | jorge.delrio@telus.com | Rel-11 | RP-51 | Issam | 4C_HSDPA_Config-Perf | RP-120475 |
| 1956 | 449 | **Non-contiguous 4C-HSDPA operation** | 516d? | 2011-03-23 A | 2013-03-01 A | 100% |  | 2011-03-23 | 2013-03-01 | 516d? |  |  | R4; R2; R3 | 24360h | 24360h | NC_4C_HSDPA | PCG-26 | Ericsson | muhammad.kazmi@ericsson.com | Rel-11 | RP-51 | Issam | NC_4C_HSDPA |  |
| 1957 | 449.1 | Core part: Non-contiguous 4C-HSDPA operation | 328d? | 2011-06-15 A | 2012-09-07 A | 100% |  | 2011-06-15 | 2012-09-07 | 328d? |  | finish no earlier than 2012-09-07 | R4; R2; R3 | 7872h | 7872h | NC_4C_HSDPA-Core | PCG-26 | Ericsson | muhammad.kazmi@ericsson.com | Rel-11 | RP-51 | Issam | NC_4C_HSDPA-Core | RP-120842 |
| 1958 | 449.2 | Perf. part: Non-contiguous 4C-HSDPA operation | 513d? | 2011-03-23 A | 2013-03-01 A | 100% |  | 2011-03-23 | 2013-03-01 | 513d? |  | finish no earlier than 2013-03-01 | R4 | 4104h | 4104h | NC_4C_HSDPA-Perf | PCG-26 | Ericsson | muhammad.kazmi@ericsson.com | Rel-11 | RP-51 | Issam | NC_4C_HSDPA-Perf | RP-130049 |
| 1959 | 450 | **Further Enhancements to CELL_FACH** | 1057d? | 2011-03-18 A | 2015-03-15 | 99% | 0d? | 2011-03-18 | 2014-09-12 | 924d? | 0d |  | R1; R2; R3; R4; R5 | 66320h | 42360h | Cell_FACH_enh | PCG-26 | Qualcomm | Ravi Agarwal | Rel-11 | RP-51 | Patrick | Cell_FACH_enh |  |
| 1960 | 450.1 | Core part: Further Enhancements to CELL_FACH | 458d? | 2011-03-18 A | 2012-12-07 A | 100% |  | 2011-03-18 | 2012-12-07 | 458d? |  | finish no earlier than 2012-12-07 | R2; R1; R3; R4 | 14656h | 14656h | Cell_FACH_enh-Core | PCG-26 | Qualcomm | Ravi Agarwal | Rel-11 | RP-51 | Yong-Jun | Cell_FACH_enh-Core | RP-121547 |
| 1961 | 450.2 | Perf. part: Further Enhancements to CELL_FACH | 717d? | 2011-03-24 A | 2013-12-06 A | 100% |  | 2011-03-24 | 2013-12-06 | 717d? |  | finish no earlier than 2013-12-06 | R4 | 5728h | 5728h | Cell_FACH_enh-Perf | PCG-26 | Qualcomm | Heechoon Lee (heechoon@qti.qualcomm.com) | Rel-11 | RP-51 | Issam | Cell_FACH_enh-Perf | RP-131459 |
| 1962 | 450.3 | Test part: Further Enhancements to CELL_FACH | 457d? | 2013-06-15 A | 2015-03-15 A | 100% |  | 2013-06-18 | 2014-09-12 | 327d? |  | finish no earlier than 2015-03-15 | R5 | 3656h | 3656h | Cell_FACH_enh-UEConTest | PCG-31 | Ericsson | leif.mattisson@ericsson.com | Rel-11 | RP-60 | Ingbert | Cell_FACH_enh-UEConTest | RP-150132 |
| 1963 | 451 | **HSDPA Multiflow Data Transmission** | 924d? | 2011-09-19 A | 2015-03-15 | 99% | 0d? | 2011-09-19 | 2014-12-05 | 851d? | 0d |  | R2; R1; R3; R4; R5 | 54136h | 30176h | HSDPA_MFTX | PCG-27 | Nokia Siemens Networks | Alexander Sayenko | Rel-11 | RP-53 | Yong-Jun | HSDPA_MFTX |  |
| 1964 | 451.1 | Core part: HSDPA Multiflow Data Transmission | 325d? | 2011-09-19 A | 2012-12-07 A | 100% |  | 2011-09-19 | 2012-12-07 | 325d? |  | finish no earlier than 2012-12-07 | R2; R1; R3; R4 | 10400h | 10400h | HSDPA_MFTX-Core | PCG-27 | Nokia Siemens Networks | Alexander Sayenko | Rel-11 | RP-53 | Yong-Jun | HSDPA_MFTX-Core | RP-121551 |
| 1965 | 451.2 | Perf. part: HSDPA Multiflow Data Transmission | 519d? | 2011-09-20 A | 2013-09-06 A | 100% |  | 2011-09-20 | 2013-09-06 | 519d? |  | finish no earlier than 2013-09-06 | R4 | 4152h | 4152h | HSDPA_MFTX-Perf | PCG-27 | Nokia Siemens Networks | kamil.bechta@nsn.com | Rel-11 | RP-53 | Issam | HSDPA_MFTX-Perf | RP-130959 |
| 1966 | 451.3 | Test part: HSDPA Multiflow Data Transmission | 328d? | 2013-12-15 A | 2015-03-15 A | 100% |  | 2013-12-06 | 2014-12-05 | 262d? |  | finish no earlier than 2015-03-15 | R5 | 2624h | 2624h | HSDPA_MFTX-UEConTest | PCG-32 | Qualcomm | Shubhang Vora (svora@qti.qualcomm.com) | Rel-11 | RP-62 | Ingbert | HSDPA_MFTX-UEConTest | RP-150126 |
| 1967 | 452 | **Four Branch MIMO transmission for HSDPA** | 590d? | 2011-09-19 A | 2013-12-06 A | 100% |  | 2011-09-19 | 2013-12-06 | 590d? |  |  | R1; R2; R3; R4 | 33968h | 33968h | 4Tx_HSDPA | PCG-27 | Ericsson | johan.hultell@ericsson.com | Rel-11 | RP-53 | Patrick | 4Tx_HSDPA |  |
| 1968 | 452.1 | Core part: Four Branch MIMO transmission for HSDPA | 325d? | 2011-09-19 A | 2012-12-07 A | 100% |  | 2011-09-19 | 2012-12-07 | 325d? |  | finish no earlier than 2012-12-07 | R1; R2; R3; R4 | 10400h | 10400h | 4Tx_HSDPA-Core | PCG-27 | Ericsson | johan.hultell@ericsson.com | Rel-11 | RP-53 | Patrick | 4Tx_HSDPA-Core | RP-121549 |
| 1969 | 452.2 | Perf. part: Four Branch MIMO transmission for HSDPA | 586d? | 2011-09-21 A | 2013-12-06 A | 100% |  | 2011-09-21 | 2013-12-06 | 586d? |  | finish no earlier than 2013-12-06 | R4 | 4688h | 4688h | 4Tx_HSDPA-Perf | PCG-27 | Ericsson | johan.hultell@ericsson.com | Rel-11 | RP-53 | Issam | 4Tx_HSDPA-Perf | RP-131460 |
| 1970 | 453 | **MIMO with 64QAM for HSUPA** | 464d? | 2011-12-09 A | 2013-09-06 A | 100% |  | 2011-12-09 | 2013-09-06 | 464d? |  |  | R1; R2; R3; R4 | 26984h | 26984h | MIMO_64QAM_HSUPA | PCG-28 | Nokia Siemens Networks | Karri Ranta-aho | Rel-11 | RP-54 | Patrick | MIMO_64QAM_HSUPA |  |
| 1971 | 453.1 | Core part: MIMO with 64QAM for HSUPA | 265d? | 2011-12-09 A | 2012-12-07 A | 100% |  | 2011-12-09 | 2012-12-07 | 265d? |  | finish no earlier than 2012-12-07 | R1; R2; R3; R4 | 8480h | 8480h | MIMO_64QAM_HSUPA-Core | PCG-28 | Nokia Siemens Networks | Karri Ranta-aho | Rel-11 | RP-54 | Patrick | MIMO_64QAM_HSUPA-Core | RP-121554 |
| 1972 | 453.2 | Perf. part: MIMO with 64QAM for HSUPA | 457d? | 2011-12-13 A | 2013-09-06 A | 100% |  | 2011-12-13 | 2013-09-06 | 457d? |  | finish no earlier than 2013-09-06 | R4 | 3656h | 3656h | MIMO_64QAM_HSUPA-Perf | PCG-28 | Nokia Siemens Networks | kamil.bechta@nsn.com | Rel-11 | RP-54 | Issam | MIMO_64QAM_HSUPA-Perf | RP-130960 |

Notes:
- 1947: Stage 2/3 / Impacted TSs and TRs: UTRA
- 1948: RP#58 completed / Impacted TSs and TRs: 25.101, 25.104, 25.133, 25.211, 25.212, 25.213, 25.214, 25.215, 25.306, 25.319, 25.321, 25.331, 25.423, 25.433
- 1949: RP#61 completed / Impacted TSs and TRs: 25.101, 25.104, 25.133, 25.141
- 1950: RP#58 completed / Impacted TSs and TRs: 25.101, 25.133, 25.306, 25.319, 25.321, 25.331, 25.423, 25.433
- 1951: RP#58 completed / Impacted TSs and TRs: 25.101, 25.133
- 1952: RP#64 completed / Impacted TSs and TRs: 34.121-1, 34.121-2, 34.123-1, 34.123-2, 34.123-3
- 1953: - / Impacted TSs and TRs: UTRA
- 1954: RP#54 completed. RP#62 existing TS 25.317 replaced by new TS 25.327 / Impacted TSs and TRs: 25.101, 25.104, 25.141, 25.317 replaced by new TS 25.327
- 1955: RP#56 completed. RP#62 existing TS 25.317 replaced by new TS 25.327 / Impacted TSs and TRs: 25.101, 25.104, 25.141, 25.317 replaced by new TS 25.327
- 1956: - / Impacted TSs and TRs: UTRA
- 1957: RP#56 completed / Impacted TSs and TRs: 25.101, 25.104, 25.133, 25.331, 25.423, 25.433
- 1958: RP#59 completed / Impacted TSs and TRs: 25.101, 25.104, 25.133, 25.141
- 1959: - / Impacted TSs and TRs: UTRA
- 1960: RP#58 completed / Impacted TSs and TRs: 25.101, 25.104, 25.133, 25.211, 25.212, 25.213, 25.214, 25.306, 25.308, 25.319, 25.321, 25.331, 25.423, 25.433
- 1961: RP#62 completed / Impacted TSs and TRs: 25.101, 25.104, 25.133, 25.141
- 1962: ; Stat Rep: RP-141164->RP-141770 1st Apr 15: Compl:92%->100% 1st Apr 15: Stat Rep: RP-141770->RP-150132 / Impacted TSs and TRs: 34.108, 34.121-1, 34.121-2, 34.123-1, 34.123-2, 34.123-3, 36.508, 36.523-1, 36.523-2, 36.523-3
- 1963: Stage 2,3 / Impacted TSs and TRs: UTRA
- 1964: RP#58 completed / Impacted TSs and TRs: 25.101, 25.104, 25.133, 25.211, 25.212, 25.214, 25.306, 25.308, 25.321, 25.331, 25.423, 25.433
- 1965: RP#61 completed / Impacted TSs and TRs: 25.101, 25.104, 25.133, 25.141
- 1966: ; Stat Rep: RP-141136->RP-141961 1st Apr 15: Compl:90%->100% 1st Apr 15: Stat Rep: RP-141961->RP-150126 / Impacted TSs and TRs: 34.108, 34.121-1, 34.121-2, 34.123-1, 34.123-2, 34.123-3
- 1967: Stage 3 / Impacted TSs and TRs: UTRA
- 1968: RP#58 completed / Impacted TSs and TRs: 25.101, 25.104, 25.133, 25.211, 25.212, 25.213, 25.214, 25.215, 25.308, 25.331, 25.423, 25.433, 26.306
- 1969: RP#62 completed / Impacted TSs and TRs: 25.101, 25.104, 25.133, 25.141
- 1970: Specified UE and BS performance requirements for uplink MIMO together with QPSK and 16QAM modulations for E-DCH/HSUPA. 64QAM is for future releases / Impacted TSs and TRs: UTRA
- 1971: RP#58 completed / Impacted TSs and TRs: 25.101, 25.104, 25.133, 25.211, 25.212, 25.213, 25.214, 25.215, 25.308, 25.321, 25.331, 25.423, 25.433, 26.306
- 1972: RP#61 completed / Impacted TSs and TRs: 25.101, 25.104, 25.133, 25.141

| ID | WBS | Task | Type | Duration | Start | Finish | Complete | Baseline start | Baseline finish | Baseline duration | Constraint | Resources | Work | Actual work | Acronym | PCG approved | Impacted TSs and TRs | WI rapporteur name | Release | TSG approved | MCC resp | Acronym_3GU_Export | Status Report | Special Focus Doc | PCG stopped | TSG stopped |
| --- | --- | --- | --- | --- | --- | --- | --- | --- | --- | --- | --- | --- | --- | --- | --- | --- | --- | --- | --- | --- | --- | --- | --- | --- | --- | --- |
| 1973 | 454 | **HSDPA Dual-Band Multi-Carrier combinations** |  | 198d? | 2011-12-09 A | 2012-09-07 A | 100% | 2011-12-09 | 2012-09-07 | 198d? |  | R4; R2 | 7920h | 7920h | HSDPA_DB_MC | PCG-28 | UTRA | Ericsson | Rel-11 | RP-54 | Issam | HSDPA_DB_MC |  |  |  |  |
| 1974 | 454.1 | Core part: HSDPA Dual-Band Multi-Carrier combinations |  | 198d? | 2011-12-09 A | 2012-09-07 A | 100% | 2011-12-09 | 2012-09-07 | 198d? | finish no earlier than 2012-09-07 | R4; R2 | 3168h | 3168h | HSDPA_DB_MC-Core | PCG-28 | 25.101, 25.104, 25.141, 25.317 replaced by new TS 25.327 | Ericsson | Rel-11 | RP-54 | Issam | HSDPA_DB_MC-Core | RP-120987 |  |  |  |
| 1975 | 454.2 | Perf. part: HSDPA Dual-Band Multi-Carrier combinations |  | 198d? | 2011-12-09 A | 2012-09-07 A | 100% | 2011-12-09 | 2012-09-07 | 198d? | finish no earlier than 2012-09-07 | R4 | 1584h | 1584h | HSDPA_DB_MC-Perf | PCG-28 | 25.101, 25.104, 25.141 | Ericsson | Rel-11 | RP-54 | Issam | HSDPA_DB_MC-Perf | RP-120988 |  |  |  |
| 1976 | 455 | Split TTCN Test Models for IMS testing in TS 34.229-3 |  | 201d? | 2013-12-09 A | 2014-09-12 A | 100% | 2013-12-09 | 2014-09-12 | 201d? | finish no earlier than 2014-09-12 | R5 | 1608h | 1608h | IMS-CCR_Test2 | PCG-32 | 34.229-3, New TS 34.229-4 | Spirent | Rel-11 | RP-62 | Ingbert | IMS-CCR_Test2 | RP-141155 |  |  |  |
| 1977 | 456 | (Small) Technical Enhancements and Improvements for Rel-11 |  | 595d? | 2010-06-18 A | 2012-09-20 A | 100% | 2010-06-18 | 2012-09-20 | 595d? | finish no earlier than 2012-09-20 | SP; CP; RP; GP | 19040h | 19040h | TEI11 | PCG-25 |  |  | Rel-11 | SP-48 | All | TEI11 |  |  |  |  |
| 1978 | 457 | Test - (Small) Technical Enhancements and Improvements for Rel-11 |  | 397d? | 2012-06-15 A | 2013-12-11 A | 100% | 2012-06-15 | 2013-12-11 | 397d? | finish no earlier than 2013-12-11 | R5; G3new | 6352h | 6352h | TEI11_Test | PCG-29 |  |  | Rel-11 | RP-56 | Ingbert | TEI11_Test |  |  |  |  |
| 1979 | 458 | (IETF) (Small) Technical Enhancements and Improvements for Rel-11 (RFC 7077) |  | 333d? | 2012-09-07 A | 2013-12-06 A | 100% | 2012-09-07 | 2013-12-06 | 333d? | finish no earlier than 2013-11-28 | C4-IETF | 2632.95h | 2632.95h | TEI11_IETF | PCG-29 | RFC 7077 (was draft-ietf-netext-update-notifications) | Lionel Morand | Rel-11 | CP-57 | Kimmo | TEI11_IETF |  |  |  |  |
| 1980 | 459 | Release 11 Studies | milestone | 0d? | 2009-12-10 A | 2009-12-10 A | 100% | 2009-12-10 | 2012-09-14 | 727d? | finish no earlier than 2012-12-07 | SP; CP; GP; RP |  |  |  |  |  |  | Rel-11 |  | All |  |  |  |  |  |
| 1981 | 460 | Study on IMS based Peer-to-Peer Content Distribution Services |  | 195d? | 2009-09-11 A | 2010-06-10 A | 100% | 2009-05-12 | 2010-06-10 | 284d? | finish no earlier than 2010-06-10 | S1; S2 | 3120h | 3120h | FS_IMS_P2P | PCG-23 | 22.906 | China Mobile | Rel-11 | SP-45 | Alain | FS_IMS_P2P |  |  |  |  |
| 1982 | 461 | Study on Non Voice Emergency Services |  | 467d? | 2009-12-10 A | 2011-09-21 A | 100% | 2009-12-10 | 2011-09-21 | 467d? | finish no earlier than 2011-09-21 | S1 | 3720h | 3720h | FS_NOVES | PCG-24 | 22.871 | Qualcomm | Rel-11 | SP-46 | Alain | FS_NOVES |  |  |  |  |
| 1983 | 462 | Study on Support for 3GPP Voice Interworking with Enterprise IP-PBX |  | 130d? | 2010-09-23 A | 2011-03-23 A | 100% | 2010-09-23 | 2011-03-23 | 130d? | finish no earlier than 2011-02-21 | S1; S2 | 2080h | 2080h | FS_VINE | PCG-25 | 22.809 | Tatara Systems | Rel-11 | SP-48 | Alain | FS_VINE |  |  |  |  |
| 1984 | 463 | Study on IMS Network-Independent Public User Identities |  | 185d? | 2010-09-23 A | 2011-06-08 A | 100% | 2010-09-23 | 2011-06-08 | 185d? | finish no earlier than 2011-06-08 | S1 | 1480h | 1480h | FS_INIPUI | PCG-25 | 22.894 | Vodafone | Rel-11 | SP-49 | Alain | FS_INIPUI |  |  |  |  |
| 1985 | 464 | Study on IMS Evolution |  | 849d? | 2008-09-18 A | 2011-12-14 A | 100% | 2008-09-18 | 2011-12-14 | 849d? | finish no earlier than 2011-12-07 | S2 | 6784h | 6784h | FS_eIMS | PCG-21 | 23.812 | China Mobile | Rel-11 | SP-41 | Maurice | FS_eIMS |  |  |  |  |
| 1986 | 465 | Study on Policy solutions and enhancements |  | 521d? | 2009-06-12 A | 2011-06-10 A | 100% | 2000-01-03 | 2002-01-03 | 525d? | finish no earlier than 2011-06-10 | S2; S1 | 8336h | 8336h | FS_PP | PCG-23 | 23.813 | AT&T | Rel-11 | SP-44 | Maurice | FS_PP |  |  |  |  |
| 1987 | 466 | Study on IPv6 Migration |  | 525d? | 2009-06-04 A | 2011-06-08 A | 100% | 2009-06-04 | 2011-06-08 | 525d? | finish no earlier than 2011-06-08 | S2 | 4200h | 4200h | FS_IP6M | PCG-23 | 23.975 | China Mobile | Rel-11 | SP-44 | Maurice | FS_IP6M |  |  |  |  |
| 1988 | 467 | Study on Single Radio Voice Call Continuity from UTRAN/GERAN to E-UTRAN/HSPA |  | 528d? | 2009-12-10 A | 2011-12-14 A | 100% | 2009-12-10 | 2011-12-14 | 528d? | finish no earlier than 2011-09-21 | S2 | 4208h | 4208h | FS_rSRVCC | PCG-24 | 23.885 | Orange | Rel-11 | SP-46 | Maurice | FS_rSRVCC |  |  |  |  |
| 1989 | 468 | Study on Roaming Architecture for Voice over IMS with Local Breakout |  | 194d? | 2011-03-23 A | 2011-12-14 A | 100% | 2011-03-23 | 2011-12-14 | 194d? | finish no earlier than 2011-12-07 | S2 | 1535.79h | 1535.79h | FS_RAVEL | PCG-26 | 23.850 | Deutsche Telekom | Rel-11 | SP-51 | Maurice | FS_RAVEL |  |  |  |  |
| 1990 | 469 | Study on UTRAN key management enhancements |  | 1102d? | 2007-12-20 A | 2012-03-07 A | 100% | 2007-12-20 | 2012-03-07 | 1102d? | finish no earlier than 2012-02-20 | S3 | 8808.12h | 8808.12h | FS_UKM | PCG-21 | 33.859 | Ericsson | Rel-11 | SP-38 | Mirko | FS_UKM |  |  |  |  |
| 1991 | 470 | Study on Single Sign On (SSO) Application Security for IMS - based on SIP Digest |  | 532d? | 2010-06-10 A | 2012-06-20 A | 100% | 2010-06-10 | 2012-06-20 | 532d? | finish no earlier than 2012-06-20 | S3 | 4247.09h | 4247.09h | FS_SSO_APS | PCG-25 | 33.914 converted to 33.804 | Nokia | Rel-11 | SP-48 | Mirko | FS_SSO_APS |  |  |  |  |
| 1992 | 471 | Study on Mobile 3D Video Coding |  | 273d? | 2011-06-08 A | 2012-06-20 A | 100% | 2011-06-08 | 2012-06-20 | 273d? | finish no earlier than 2012-06-20 | S4 | 2168h | 2168h | FS_M3DVC | PCG-27 | 26.905 | Orange | Rel-11 | SP-52 | Paolo | FS_M3DVC |  |  |  |  |
| 1993 | 472 | Study on Management of Converged Networks |  | 591d? | 2010-06-10 A | 2012-09-12 A | 100% | 2010-06-10 | 2012-09-12 | 591d? | finish no earlier than 2012-09-12 | S5 | 4720h | 4720h | FS_ManCon | PCG-25 | 32.833 | Nokia Siemens Networks | Rel-11 | SP-48 | Mirko | FS_ManCon |  |  |  |  |
| 1994 | 473 | Study on User Data Convergence (UDC) information model handling and provisioning: Example Use Cases |  | 321d? | 2010-09-23 A | 2011-12-14 A | 100% | 2010-09-23 | 2011-12-14 | 321d? | finish no earlier than 2011-12-14 | S5 | 2560h | 2560h | FS_UDC_AppUseCase | PCG-25 | 32.901 | Alcatel-Lucent | Rel-11 | SP-49 | Mirko | FS_UDC_AppUseCase |  |  |  |  |
| 1995 | 474 | Study on OAM aspects of inter-RAT Energy Saving |  | 194d? | 2011-03-23 A | 2011-12-14 A | 100% | 2011-03-23 | 2011-12-14 | 194d? | start no earlier than 2011-03-23 | S5 | 1528h | 1528h | FS_OAM_ES_iRAT | PCG-26 | 32.834 | Nokia Siemens Networks | Rel-11 | SP-51 | Mirko | FS_OAM_ES_iRAT |  | SON |  |  |
| 1996 | 475 | Study on impacts on UE-Core Network signalling from Energy Saving |  | 261d? | 2010-06-04 A | 2011-06-03 A | 100% | 2010-06-04 | 2011-06-03 | 261d? | finish no earlier than 2011-06-03 | C1 | 2088h | 2088h | FS_UE-CN_ES | PCG-25 | 24.826 | NEC | Rel-11 | CP-48 | Frederic | FS_UE-CN_ES |  |  |  |  |
| 1997 | 476 | Study on EPC Nodes Restoration |  | 588d? | 2010-09-17 A | 2012-12-07 A | 100% | 2010-09-17 | 2012-12-07 | 588d? | finish no earlier than 2012-12-07 | C4 | 4664h | 4664h | FS_EPC_NR | PCG-25 | 23.857 | ZTE | Rel-11 | CP-49 | Kimmo | FS_EPC_NR |  |  |  |  |
| 1998 | 477 | Study on Signal Precoding enhancements for EGPRS2 DL |  | 394d? | 2010-09-03 A | 2012-03-02 A | 100% | 2010-09-03 | 2012-03-02 | 394d? | finish no earlier than 2012-03-02 | G1; G2 | 6304h | 6304h | FS_SPEED | PCG-25 | GERAN 45.860 | Ericsson | Rel-11 | GP-46 | Paolo | FS_SPEED |  |  |  |  |
| 1999 | 478 | Study on Coordinated Multi-Point operation for LTE |  | 203d? | 2010-12-10 A | 2011-09-16 A | 100% | 2010-12-10 | 2011-09-16 | 203d? | finish no earlier than 2011-09-16 | R1; R2; R3 | 4872h | 4872h | FS_CoMP_LTE | PCG-24 | LTE 36.819 | Samsung | Rel-11 | RP-47 | Patrick | FS_CoMP_LTE | RP-111343 |  |  |  |
| 2000 | 479 | Study on Signalling and procedure for interference avoidance for in-device coexistence |  | 338d? | 2010-06-04 A | 2011-09-16 A | 100% | 2010-06-04 | 2011-09-16 | 338d? | finish no earlier than 2011-09-16 | R2; R4 | 5408h | 5408h | FS_SPIA_IDC | PCG-25 | LTE 36.816 | China Mobile | Rel-11 | RP-48 | Yong-Jun | FS_SPIA_IDC | RP-111057 |  |  |  |
| 2001 | 480 | Study on HetNet mobility enhancements for LTE |  | 391d? | 2011-03-18 A | 2012-09-07 A | 100% | 2011-03-18 | 2012-09-07 | 391d? | finish no earlier than 2012-09-07 | R2; R1; R3; R4 | 12512h | 12512h | FS_HetNet_eMOB_LTE | PCG-26 | LTE 36.839 | Alcatel-Lucent | Rel-11 | RP-51 | Yong-Jun | FS_HetNet_eMOB_LTE | RP-121085 |  |  |  |
| 2002 | 481 | Study on further Downlink MIMO enhancements for LTE-Advanced |  | 193d? | 2011-03-18 A | 2011-12-09 A | 100% | 2011-03-18 | 2011-12-09 | 193d? | finish no earlier than 2011-12-09 | R1 | 1544h | 1544h | FS_LTE_eDL_MIMO_enh | PCG-26 | LTE 36.871 | Alcatel-Lucent | Rel-11 | RP-51 | Patrick | FS_LTE_eDL_MIMO_enh | RP-111550 |  |  |  |
| 2003 | 482 | Study on Further Enhancements to LTE TDD for DL-UL Interference Management and Traffic Adaptation |  | 328d? | 2011-03-22 A | 2012-06-15 A | 100% | 2011-03-22 | 2012-06-15 | 328d? | finish no earlier than 2012-06-15 | R1; R4 | 5248h | 5248h | FS_LTE_TDD_eIMTA | PCG-26 | LTE 36.828 | CATT | Rel-11 | RP-51 | Patrick | FS_LTE_TDD_eIMTA | RP-120587 | Small cell |  |  |
| 2004 | 483 | Study on LTE Coverage Enhancements |  | 197d? | 2011-09-19 A | 2012-06-15 A | 100% | 2011-09-19 | 2012-06-15 | 197d? | finish no earlier than 2012-06-15 | R1; R2 | 3152h | 3152h | FS_Cov_Enh_LTE | PCG-27 | LTE 36.824 | China Telecom | Rel-11 | RP-53 | Patrick | FS_Cov_Enh_LTE | RP-120589 |  |  |  |
| 2005 | 484 | Study on Enhanced performance requirement for LTE UE |  | 121d? | 2011-09-19 A | 2012-03-02 A | 100% | 2011-09-19 | 2012-03-02 | 121d? | finish no earlier than 2012-03-02 | R4; R1 | 1936h | 1936h | FS_enh_perf_UE_LTE | PCG-27 | LTE 36.829 | NTT DoCoMo | Rel-11 | RP-53 | Issam | FS_enh_perf_UE_LTE | RP-120167 |  |  |  |
| 2006 | 485 | Study on Measurements of radio performances for LTE terminals - Total Radiated Power (TRP) and Total Radiated Sensitivity (TRS) test methodology |  | 136d? | 2012-03-05 A | 2012-09-07 A | 100% | 2012-03-05 | 2012-09-07 | 136d? | finish no earlier than 2012-09-07 | R4 | 1088h | 1088h | FS_LTE_OTA | PCG-28 | LTE 25.914, New TR 37.902 | CATR | Rel-11 | RP-55 | Issam | FS_LTE_OTA | RP-121083 |  |  |  |
| 2007 | 486 | Study on Measurement of Radiated Performance for MIMO and multi-antenna reception for HSPA and LTE terminals |  | 712.8d? | 2009-03-06 A | 2012-03-02 A | 100% | 2009-03-06 | 2012-03-02 | 712.8d? | finish no earlier than 2012-03-02 | R4 | 5702.4h | 5702.4h | FS_HSPA_LTE_measRP_MIMO_multi-antenna | PCG-22 | UTRA, LTE 37.976 | Vodafone | Rel-11 | RP-43 | Issam | FS_HSPA_LTE_measRP_MIMO_multi-antenna | RP-120154 |  |  |  |
| 2008 | 487 | Study on Extending 850 MHz |  | 860d? | 2009-05-30 A | 2012-09-07 A | 100% | 2009-05-30 | 2012-09-07 | 860d? | finish no earlier than 2012-09-07 | R4 | 6880h | 6880h | FS_e850 | PCG-23 | UTRA, LTE 37.806 | Ericsson | Rel-11 | RP-44 | Issam | FS_e850 | RP-121080 |  |  |  |
| 2009 | 488 | Study on RAN improvements for Machine-Type Communications |  | 523d? | 2009-09-18 A | 2011-09-16 A | 100% | 2009-09-18 | 2011-09-16 | 523d? | finish no earlier than 2011-09-16 | R2; R1; R3; R4 | 16736h | 16736h | FS_NIMTC_RAN | PCG-23 | UTRA, LTE 37.868 | Huawei | Rel-11 | RP-45 | Yong-Jun | FS_NIMTC_RAN | RP-111052 | MTC, M2M |  |  |
| 2010 | 489 | Study on UE Application Layer Data Throughput Performance |  | 264d? | 2010-09-16 A | 2011-09-16 A | 100% | 2010-09-16 | 2011-09-16 | 264d? | finish no earlier than 2011-09-16 | R5; R4 | 4224h | 4224h | FS_UE_App_Data_Perf | PCG-26 | UTRA, LTE 37.901 | Spirent | Rel-11 | RP-50 | Ingbert | FS_UE_App_Data_Perf | RP-111543 |  |  |  |
| 2011 | 490 | Study on further enhancements for HNB and HeNB |  | 330d? | 2011-03-18 A | 2012-06-15 A | 100% | 2011-03-18 | 2012-06-15 | 330d? | finish no earlier than 2012-06-15 | R3; R2 | 5280h | 5280h | FS_EHNB_enh | PCG-26 | UTRA, LTE 37.803 | Alcatel-Lucent | Rel-11 | RP-51 | Juha | FS_EHNB_enh | RP-120579 | HNB |  |  |
| 2012 | 491 | Study on Interference analysis between 800~900 MHz bands |  | 326d? | 2011-03-23 A | 2012-06-15 A | 100% | 2011-03-23 | 2012-06-15 | 326d? | finish no earlier than 2012-06-15 | R4 | 2608h | 2608h | FS_B800_B900_Interf_LTE | PCG-26 | UTRA, LTE impacts TR 37.804 | LG Uplus | Rel-11 | RP-51 | Issam | FS_B800_B900_Interf_LTE | RP-120586 |  |  |  |
| 2013 | 492 | Study on UMTS/LTE in 900 MHz band (Japan, Korea) |  | 272d? | 2011-06-07 A | 2012-06-15 A | 100% | 2011-06-07 | 2012-06-15 | 272d? | finish no earlier than 2012-06-15 | R4 | 2176h | 2176h | FS_UTRA_LTE_900MHz | PCG-27 | UTRA, LTE 37.804 | NTT DoCoMo | Rel-11 | SP-52 | Issam | FS_UTRA_LTE_900MHz | RP-120580 |  |  |  |
| 2014 | 493 | Study on Uplink MIMO |  | 203d? | 2010-12-10 A | 2011-09-16 A | 100% | 2010-12-10 | 2011-09-16 | 203d? | finish no earlier than 2011-09-16 | R1 | 1624h | 1624h | FS_UTRA_UL_MIMO | PCG-26 | UTRA 25.871 | Qualcomm | Rel-11 | RP-50 | Patrick | FS_UTRA_UL_MIMO | RP-111048 |  |  |  |
| 2015 | 494 | Study on HSDPA Multipoint Transmission |  | 203d? | 2010-12-10 A | 2011-09-16 A | 100% | 2010-12-10 | 2011-09-16 | 203d? | finish no earlier than 2011-09-16 | R1; R2; R3 | 4872h | 4872h | FS_HSDPA_MP_TX | PCG-26 | UTRA 25.872 | Nokia Siemens Networks | Rel-11 | RP-50 | Patrick | FS_HSDPA_MP_TX | RP-111049 |  |  |  |
| 2016 | 495 | Study on UE Over The Air (OTA) test method with Head and Hand Phantoms |  | 258d? | 2011-09-19 A | 2012-09-07 A | 100% | 2011-09-19 | 2012-09-07 | 258d? | finish no earlier than 2012-09-07 | R4; R5 | 4128h | 4128h | FS_OTA_phantoms_UTRA | PCG-27 | UTRA 25.914 | Nokia | Rel-11 | RP-53 | Issam | FS_OTA_phantoms_UTRA | RP-121078 |  |  |  |
| 2017 | 496 | Study on HSPA feedback and signalling efficiency enhancements for LCR TDD |  | 199d? | 2011-12-07 A | 2012-09-07 A | 100% | 2011-12-07 | 2012-09-07 | 199d? | finish no earlier than 2012-09-07 | R1 | 1584h | 1584h | FS_LCRTDD_HSPAenh | PCG-28 | UTRA 25.874 | TD Tech | Rel-11 | RP-54 | Patrick | FS_LCRTDD_HSPAenh | RP-121079 |  |  |  |
| 2018 | 497 | Deleted - Study on Enhanced Uplink Transmission for LTE |  | 328d? | 2011-03-22 A | 2012-06-15 A | 100% | 2011-03-22 | 2012-06-15 | 328d? | finish no earlier than 2012-06-15 | R1 | 2624h | 2624h | FS_eUL_TX_LTE | PCG-26 | LTE 36.8xy | Huawei | Rel-11 | RP-51 | Patrick | FS_eUL_TX_LTE | RP-120585 |  | PCG-29 | RP-56 |
| 2019 | 498 | Release 10 Features |  | 728d? | 2008-12-11 A | 2011-09-21 A | 100% | 2008-12-11 | 2011-09-21 | 728d? | finish no earlier than 2011-09-21 | CP; GP; RP; SP | 23296h | 23296h |  |  |  |  | Rel-10 |  |  |  |  |  |  |  |

Notes:
- 1973: Stage 3 / WI rapporteur e-mail: muhammad.kazmi@ericsson.com
- 1974: RP#57 completed. RP#62 existing TS 25.317 replaced by new TS 25.327 / WI rapporteur e-mail: muhammad.kazmi@ericsson.com
- 1975: RP#57 completed / WI rapporteur e-mail: muhammad.kazmi@ericsson.com
- 1976: SP#65 completed. TS 34.229-4 for Approval. Split out of old TS 34.229-3 a new TS 34.229-4 / WI rapporteur e-mail: richard.catmur@spirent.com
- 1977: SP#50 EU-Alert is introduced under Public Warning System in parallel with the already existing ETWS and CMAS. SA1 22.268 CR#9r1 adds EU-ALERT specific requirements & CT1 23.041 CRs#
- 1978: -
- 1979: CP#62 completed / WI rapporteur e-mail: Lionel Morand
- 1980: -
- 1981: SP#48 completed. 3/3/15: start date corrected (was 05/09) / WI rapporteur e-mail: Li Gang (ligangyf@chinamobile.com)
- 1982: SP#53 completed. Spin-off Feature UID_500030 Non Voice Emergency Services (NOVES) / WI rapporteur e-mail: dwilliams@qualcomm.com
- 1983: SP#51 completed. Support Interworking between 3GPP networks and Enterprise environments to provide enterprise voice services via 3GPP mobile devices / WI rapporteur e-mail: Phillip Brown (pbrown@tatarasystems.com)
- 1984: SP#52 completed / WI rapporteur e-mail: mona.mustapha@vodafone.com
- 1985: SP#54 completed / WI rapporteur e-mail: Li Gang (ligangyf@chinamobile.com), Yu Qing (yuqing@chinamobile.com)
- 1986: SP#52 completed. 3/3/15: start and finish dates corrected (was start on Jan-00, ends on Jan-02) / WI rapporteur e-mail: farooq.bari@att.com
- 1987: SP#52 completed / WI rapporteur e-mail: Li Lianyuan (lilianyuan@chinamobile.com), Liu Hong (liuhongyfw@chinamobile.com)
- 1988: SP#54 completed. Study on "reverse direction" from UTRAN/GERAN to E-UTRAN/HSPA (Rel-8 SRVCC was in the other direction E-UTRAN/HSPA to GERAN/UTRAN) / WI rapporteur e-mail: delphin.barankanira@orange-ftgroup.com
- 1989: SP#54 completed. Linked to Rel-11 OSCAR (Optimized Service Charging and Allocation of Resources in IMS whilst Roaming) UID_490032. Related to LBO/home routing decision / WI rapporteur e-mail: michele.zarri@telekom.com
- 1990: SP#55 completed / WI rapporteur e-mail: karl.norrman@ericsson.com
- 1991: SP#56 completed. SP#55 TR 33.914v200 approved (converted 33.804). Study reuse of non-UICC credentials (in particular SIP Digest) to provide security for access to applications. Provide reference material for IMS based non-UICC based SSO to applications / WI rapporteur e-mail: Silke.Holtmanns@nokia.com
- 1992: SP#56 completed. Extends Rel-10 work on 3D video formats UID_480044 Improved Video Coding Support for PSS and MBMS / WI rapporteur e-mail: gilles.teniou@orange-ftgroup.com
- 1993: SP#57 completed. TR 32.833v200 for Approval / WI rapporteur e-mail: Jörg Schmidt (J.Schmidt@nsn.com)
- 1994: SP#54 completed / WI rapporteur e-mail: Nick Mazzarella (njmazzarella@alcatel-lucent.com)
- 1995: SP#54 completed. Triggered by Rel-10 UID_430044 TR 32.826 Study on Energy Savings Management (FS_OAM_ESM) and UID_470037 OAM aspects of Energy Saving in Radio Networks (OAM-ES) / WI rapporteur e-mail: clemens.suerbaum@nsn.com
- 1996: CP#52 completed. Linked to SA5 UID_430044 (FS_OAM-ESM) & UID_470037 (OAM-ES), RAN3 UID_470015 (FS_Energy_LTE), RAN1 UID_460016 (FS_Energy_UMTS) / WI rapporteur e-mail: gottfried.punz@nw.neclab.eu
- 1997: CP#58 completed. Continue work in Rel-11 especially to cover handling of Idle mode Signalling Reduction (ISR). Linked to SA2 UID_490036 Study on Core Network Overload solutions / WI rapporteur e-mail: lu.fei1@zte.com.cn
- 1998: GP#53 completed (03/12). GP#46 approved WID. / WI rapporteur e-mail: marten.sundberg@ericsson.com
- 1999: RP#53 completed / WI rapporteur e-mail: bruno.clerckx@samsung.com
- 2000: RP#53 completed. Studied coexistence scenario of LTE and Industrial, Scientific and Medical (ISM) Radio within the same device working in adjacent frequencies / WI rapporteur e-mail: Zhenping Hu (huzhenping@chinamobile.com)
- 2001: RP#57 completed. TR 36.839 v100 for Information & Approval / WI rapporteur e-mail: sudeep.palat@alcatel-lucent.com
- 2002: RP#54 completed / WI rapporteur e-mail: federico.boccardi@alcatel-lucent.com
- 2003: RP#56 completed. TR 36.828 for Information and Approval / WI rapporteur e-mail: Zukang Shen (shenzukang@catt.cn)
- 2004: RP#56 completed. TR 36.824 v200 for Approval / WI rapporteur e-mail: Peng Chen (chenpeng@ctbri.com.cn)
- 2005: RP#55 completed. TR 36.829 v100 for Information + Approval / WI rapporteur e-mail: Yuta Sagae
- 2006: RP#57 completed / WI rapporteur e-mail: Xudong An (anxudong@emcite.com)
- 2007: RP#55 completed. TR 37.976 v200 for Approval / WI rapporteur e-mail: Tim.frost@vodafone.com
- 2008: RP#57 completed. TR 37.806 v200 for Approval / WI rapporteur e-mail: christian.bergljung@ericsson.com
- 2009: RP#53 completed. TR 37.868v100 for Approval (No WID change: RAN overload only). Triggered by TR 22.868 Study on Facilitating Machine to Machine Communication in GSM and UMTS (M2M) UID_7027 and Rel-10 NIMTC UID_410030 / WI rapporteur e-mail: Jeff Gao (gaoyq@huawei.com)
- 2010: RP#54 completed / WI rapporteur e-mail: ron.borsato@spirent.com
- 2011: RP#56 completed. TR 37.803 v200 for Approval / WI rapporteur e-mail: Martin.Warner@alcatel-lucent.com
- 2012: RP#56 completed. Impacts TR 37.804 Study on UMTS/LTE in 900 MHz band (Japan, Korea) UID_520018 / WI rapporteur e-mail: Koo Yeon Sang (yskoo@lguplus.co.kr)
- 2013: RP#56 completed. Updated WID RP-111751=>RP-120617. TR 37.804 v100 for Information and Approval. Linked to Study on Interference analysis between 800~900 MHz bands UID_510038 / WI rapporteur e-mail: Masahiro Fujii (fujiima@nttdocomo.co.jp)
- 2014: RP#53 completed (1-step Approval) / WI rapporteur e-mail: Sharad Sambhwani
- 2015: RP#53 completed / WI rapporteur e-mail: karri.ranta-aho@nsn.com
- 2016: RP#57 completed / WI rapporteur e-mail: petri.j.vasenkari@nokia.com
- 2017: RP#57 completed. TR 25.874 v100 for Information & Approval / WI rapporteur e-mail: limei.wei@td-tech.com
- 2018: RP#56 stopped. RP-120856 discussion: most content moved to Rel-11 Coordinated Multi-Point Operation for LTE Uplink (COMP_LTE_UL) and RAN1 has no time to look at it / WI rapporteur e-mail: Yongxing Zhou
- 2019: -

| ID | WBS | Task | Duration | Start | Finish | Complete | Baseline start | Baseline finish | Baseline duration | Constraint | Resources | Work | Actual work | Acronym | PCG approved | WI rapporteur name | WI rapporteur e-mail | Release | TSG approved | MCC resp | Special Focus Doc | Acronym_3GU_Export | PCG stopped | TSG stopped | Status Report |
| --- | --- | --- | --- | --- | --- | --- | --- | --- | --- | --- | --- | --- | --- | --- | --- | --- | --- | --- | --- | --- | --- | --- | --- | --- | --- |
| 2020 | 499 | **Enhancements for Multimedia Priority Service** | 1311d? | 2006-03-13 A | 2011-03-18 A | 100% | 2006-03-13 | 2011-03-18 | 1311d? |  | S1; S2; C4; C3; C1 | 72120h | 72120h | eMPS | PCG-21 | Telcordia | jgarraha@telcordia.com | Rel-10 | SP-39 | Alain | Public Safety (I-A) | eMPS |  |  |  |
| 2021 | 499.1 | Stage 1 on enhancements for Multimedia Priority Service | 584d? | 2006-03-13 A | 2008-06-05 A | 100% | 2006-03-13 | 2008-06-05 | 584d? | start no earlier than 2006-03-12 | S1 | 4672h | 4672h | ePRIOR-St1 | PCG-21 | Telcordia | jgarraha@telcordia.com | Rel-10 | SP-39 | Alain | Public Safety (I-A) | ePRIOR |  |  |  |
| 2022 | 499.2 | **Stage 2 on enhancements for Multimedia Priority Service** | 206d? | 2009-12-10 A | 2010-09-23 A | 100% | 2009-12-10 | 2010-09-23 | 206d? |  | S2 | 6592h | 6592h | ePRIOR-St2 | PCG-24 | Telcordia, NTT DoCoMo | Vijay Varma, Katsutoshi Nishida | Rel-10 | SP-46 | Maurice | Public Safety (I-A) |  |  |  |  |
| 2023 | 499.2.1 | Stage 2 on eMPS for CSFB | 206d? | 2009-12-10 A | 2010-09-23 A | 100% | 2009-12-10 | 2010-09-23 | 206d? | finish no earlier than 2010-09-24 | S2 | 1648h | 1648h | ePRIOR-St2 | PCG-24 | Telcordia, NTT DoCoMo | Vijay Varma, Katsutoshi Nishida | Rel-10 | SP-46 | Maurice | Public Safety (I-A) |  |  |  |  |
| 2024 | 499.2.2 | Stage 2 on eMPS for EPS Bearer Service | 206d? | 2009-12-10 A | 2010-09-23 A | 100% | 2009-12-10 | 2010-09-23 | 206d? | finish no earlier than 2010-12-09 | S2 | 1648h | 1648h | ePRIOR-St2 | PCG-24 | Telcordia, NTT DoCoMo | Vijay Varma, Katsutoshi Nishida | Rel-10 | SP-46 | Maurice | Public Safety (I-A) |  |  |  |  |
| 2025 | 499.2.3 | Stage 2 on eMPS for IMS Aspects | 206d? | 2009-12-10 A | 2010-09-23 A | 100% | 2009-12-10 | 2010-09-23 | 206d? | finish no earlier than 2010-12-09 | S2 | 1648h | 1648h | ePRIOR-St2 | PCG-24 | Telcordia, NTT DoCoMo | Vijay Varma, Katsutoshi Nishida | Rel-10 | SP-46 | Maurice | Public Safety (I-A) |  |  |  |  |
| 2026 | 499.3 | Deleted - TR 23.854 on Stage 2 on enhancements for Multimedia Priority Service | 266d? | 2009-12-10 A | 2010-12-16 A | 100% | 2009-12-10 | 2010-12-16 | 266d? | finish no earlier than 2011-03-17 | S2 | 2128h | 2128h |  | PCG-24 | Telcordia, NTT DoCoMo | Vijay Varma, Katsutoshi Nishida | Rel-10 | SP-46 | Maurice | Public Safety (I-A) |  | PCG-27 | SP-50 |  |
| 2027 | 499.4 | **Stage 3 on enhancements for Multimedia Priority Service** | 131d? | 2010-09-17 A | 2011-03-18 A | 100% | 2010-09-17 | 2011-03-18 | 131d? |  | C4; C3; C1 | 6288h | 6288h | eMPS-CN | PCG-25 | Ericsson | Philip.hodges@ericsson.com | Rel-10 | CP-49 | Kimmo | Public Safety (I-A) | eMPS-CN |  |  |  |
| 2028 | 499.4.1 | CT4 part on Stage 3 on enhancements for Multimedia Priority Service | 131d? | 2010-09-17 A | 2011-03-18 A | 100% | 2010-09-17 | 2011-03-18 | 131d? | start no earlier than 2010-09-17 | C4 | 1048h | 1048h | eMPS-CN | PCG-25 | Ericsson | Philip.hodges@ericsson.com | Rel-10 | CP-49 | Kimmo | Public Safety (I-A) |  |  |  |  |
| 2029 | 499.4.2 | CT3 part on Stage 3 on enhancements for Multimedia Priority Service | 131d? | 2010-09-17 A | 2011-03-18 A | 100% | 2010-09-17 | 2011-03-18 | 131d? | start no earlier than 2010-09-17 | C3 | 1048h | 1048h | eMPS-CN | PCG-25 | Ericsson | Philip.hodges@ericsson.com | Rel-10 | CP-49 | Adrian | Public Safety (I-A) |  |  |  |  |
| 2030 | 499.4.3 | CT1 part on Stage 3 on enhancements for Multimedia Priority Service | 131d? | 2010-09-17 A | 2011-03-18 A | 100% | 2010-09-17 | 2011-03-18 | 131d? | start no earlier than 2010-09-17 | C1 | 1048h | 1048h | eMPS-CN | PCG-25 | Ericsson | Philip.hodges@ericsson.com | Rel-10 | CP-49 | Frederic | Public Safety (I-A) |  |  |  |  |
| 2031 | 500 | **Network Improvements for Machine-Type Communications** | 1365d? | 2008-09-18 A | 2013-11-22 A | 100% | 2008-09-18 | 2013-11-22 | 1365d? |  | S1; S2; S5; C1; C4; C6; G2; R2; R3; R5; G3new | 149017h | 149017h | NIMTC | PCG-21 | KPN | toon.norp@tno.nl | Rel-10 | SP-41 | Alain | MTC, M2M | NIMTC |  |  |  |
| 2032 | 500.1 | Stage 1 for Network Improvements for Machine-Type Communications | 397d? | 2008-09-18 A | 2010-03-25 A | 100% | 2008-09-18 | 2010-03-25 | 397d? | finish no earlier than 2009-12-10 | S1 | 3176h | 3176h | NIMTC | PCG-21 | KPN | toon.norp@tno.nl | Rel-10 | SP-41 | Alain | MTC, M2M |  |  |  |  |
| 2033 | 500.2 | Deleted - TR on Stage 2 for Network Improvements for Machine-Type Communications | 321d? | 2009-09-24 A | 2010-12-16 A | 100% | 2009-09-24 | 2010-12-16 | 321d? | finish no earlier than 2010-11-30 | S2 | 2568h | 2568h | NIMTC | PCG-23 | Samsung | erik.guttman@partner.samsung.com | Rel-10 | SP-45 | Maurice | MTC, M2M |  | PCG-26 | SP-50 |  |
| 2034 | 500.3 | Stage 2 for Network Improvements for Machine-Type Communications | 19d? | 2010-08-30 A | 2010-09-23 A | 100% | 2010-08-30 | 2010-09-23 | 19d? | finish no earlier than 2010-09-17 | S2 | 152h | 152h | NIMTC | PCG-23 | Samsung | erik.guttman@partner.samsung.com | Rel-10 | SP-45 | Maurice | MTC, M2M |  |  |  |  |
| 2035 | 500.4 | Deleted - Security for Network Improvements for Machine-Type Communications | 193.15d? | 2009-12-10 A | 2010-09-23 A | 100% | 2009-12-10 | 2010-09-23 | 193.15d? | finish no earlier than 2010-09-23 | S3 | 1545.2h | 1545.2h | NIMTC | PCG-24 | Samsung | Rajavelsamy R (rajvel@samsung.com) | Rel-10 | SP-46 | Mirko | MTC, M2M |  | PCG-25 | SP-49 |  |
| 2036 | 500.5 | Charging for Network Improvements for Machine-Type Communication | 3d? | 2011-03-21 A | 2011-03-23 A | 100% | 2011-03-21 | 2011-03-23 | 3d? | start no earlier than 2011-03-21 | S5 | 24h | 24h | NIMTC-CH | PCG-26 | Ericsson | patrik.teppo@@ericsson.com | Rel-10 | SP-51 | Mirko | MTC, M2M | NIMTC-CH |  |  |  |
| 2037 | 500.6 | **CN part of Stage 3 for Network Improvements for Machine-Type Communications** | 261d? | 2010-06-04 A | 2011-06-03 A | 100% | 2010-06-04 | 2011-06-03 | 261d? |  | C1; C4; C6 | 12976h | 12976h | NIMTC-CN | PCG-25 | Ericsson | mikael.wass@ericsson.com | Rel-10 | CP-48 | Frederic | MTC, M2M | NIMTC-CN |  |  |  |
| 2038 | 500.6.1 | CT1 part of Stage 3 for Network Improvements for Machine-Type Communications | 261d? | 2010-06-04 A | 2011-06-03 A | 100% | 2010-06-04 | 2011-06-03 | 261d? | finish no earlier than 2011-06-03 | C1 | 2088h | 2088h | NIMTC-CN | PCG-25 | Ericsson | mikael.wass@ericsson.com | Rel-10 | CP-48 | Frederic | MTC, M2M |  |  |  |  |
| 2039 | 500.6.2 | Deleted - CT3 part of Stage 3 for Network Improvements for Machine-Type Communications | 261d? | 2010-06-04 A | 2011-06-03 A | 100% | 2010-06-04 | 2011-06-03 | 261d? | finish no earlier than 2010-12-10 | C3 | 2088h | 2088h | NIMTC-CN | PCG-25 | Ericsson | mikael.wass@ericsson.com | Rel-10 | CP-48 | Adrian | MTC, M2M |  | PCG-27 | CP-52 |  |
| 2040 | 500.6.3 | CT4 part of Stage 3 for Network Improvements for Machine-Type Communications | 261d? | 2010-06-04 A | 2011-06-03 A | 100% | 2010-06-04 | 2011-06-03 | 261d? | finish no earlier than 2011-03-18 | C4 | 2088h | 2088h | NIMTC-CN | PCG-25 | Ericsson | mikael.wass@ericsson.com | Rel-10 | CP-48 | Kimmo | MTC, M2M |  |  |  |  |
| 2041 | 500.6.4 | CT6 part of Stage 3 for Network Improvements for Machine-Type Communications | 56d? | 2011-03-18 A | 2011-06-03 A | 100% | 2011-03-18 | 2011-06-03 | 56d? | finish no earlier than 2011-06-03 | C6 | 448h | 448h | NIMTC-CN | PCG-26 | Sagem-Orga | heiko.kruse@sagem-orga.com | Rel-10 | CP-51 | Xavier | MTC, M2M |  |  |  |  |
| 2042 | 500.7 | GERAN part of Network Improvements for Machine-Type Communications (Stage 3) | 261d? | 2010-09-03 A | 2011-09-02 A | 100% | 2010-09-03 | 2011-09-02 | 261d? | finish no earlier than 2011-09-02 | G2 | 2088h | 2088h | NIMTC | PCG-25 | Vodafone, Ericsson | leo.patanapongpibul@vodafone.com, john.diachina@ericsson.com | Rel-10 | GP-47 | Gert | MTC, M2M |  |  |  |  |
| 2043 | 500.8 | MS Conformance Test Aspects for GERAN - Network Improvements for Machine-Type Communications | 333d? | 2012-08-27 A | 2013-11-22 A | 100% | 2012-08-27 | 2013-11-22 | 333d? | finish no earlier than 2013-11-22 | G3new | 2656h | 2656h | NIMTC_GERAN-MSTest | PCG-29 | ST-Ericsson | hakan.e.grunditz@stericsson.com | Rel-10 | GP-55 | Ingbert | MTC, M2M | NIMTC_GERAN-MSTest |  |  |  |
| 2044 | 500.9 | RAN mechanisms to avoid CN overload due to Machine-Type Communications | 131d? | 2010-09-17 A | 2011-03-18 A | 100% | 2010-09-17 | 2011-03-18 | 131d? | finish no earlier than 2011-03-18 | R2; R3 | 2096h | 2096h | NIMTC-RAN_overload | PCG-25 | Huawei | Jeff Gao (gaoyq@huawei.com) | Rel-10 | RP-49 | Yong-Jun | MTC, M2M | NIMTC-RAN_overload |  |  | RP-110063 |
| 2045 | 500.10 | UE Conformance Test Aspects - Network Improvements for Machine-Type Communications | 202d? | 2012-09-11 A | 2013-06-14 A | 100% | 2012-09-11 | 2013-06-14 | 202d? | finish no earlier than 2013-06-14 | R5 | 1616h | 1616h | NIMTC-UEConTest | PCG-29 | Ericsson | calle.hagenfeldt@ericsson.com | Rel-10 | RP-57 | Ingbert | MTC, M2M | NIMTC-UEConTest |  |  | RP-130465 |

Notes:
- 2020: CP#51 completed. SP#49 moved Stage 1 from Rel-9 & Completed Stage 2. SP#40 Stage 1 completed. Continuation of Rel-8 Feature PRIOR (UID_340044)
- 2021: 22/01: acronym modified / Impacted TSs and TRs: 22.153, 22.278
- 2022: 22/01: acronym modified
- 2023: 22/01: acronym modified / Impacted TSs and TRs: 23.002, 23.203, 23.221, 23.228, 23.272, 23.401
- 2024: 22/01: acronym modified / Impacted TSs and TRs: 23.002, 23.203, 23.221, 23.228, 23.272, 23.401
- 2025: 22/01: acronym modified / Impacted TSs and TRs: 23.002, 23.203, 23.221, 23.228, 23.272, 23.401
- 2026: SP#49 TR 23.854 v100 for Information. SP#50 moved to Rel-11 SRVCC aspect of enhancements for Multimedia Priority Service UID_480135 (place holder for solution alternatives and agreed functions to be reflected in affected existing TS) / Impacted TSs and TRs: new TR 23.854
- 2027: CP#51 completed / Impacted TSs and TRs: Stage 3
- 2028: CP#51 completed / Impacted TSs and TRs: 23.008, 29.002, 29.228, 29.229, 29.272, 29.274, 29.277, 29.328, 29.329
- 2029: CP#51 completed / Impacted TSs and TRs: 29.212, 29.213, 29.214
- 2030: CP#51 completed / Impacted TSs and TRs: 24.008, 24.229, 24.301
- 2031: Triggered by Rel-8 UID_7027 Study on Facilitating Machine to Machine Communication in GSM and UMTS (FS_M2M) TR 22.868
- 2032: SP#47 completed / Impacted TSs and TRs: 22.011, New 22.368
- 2033: SP#50 updated WID SP-090832=>SP-100863 (TR 23.888 not submitted for approval to conclude Rel-10 NIMTC as it will continue to serve as basis for Rel-11 SIMTC work item) / Impacted TSs and TRs: New TR 23.888
- 2034: SP#49 completed / Impacted TSs and TRs: 23.060, 23.236, 23.401
- 2035: SP#49 stopped (activity transferred to Rel-11 Feature SIMTC under UID_490028 "TR on Security aspects of Machine-Type Communications". / Impacted TSs and TRs: New TR 33.868
- 2036: SP#51 completed / Impacted TSs and TRs: 32.251, 32.298, 32.299
- 2037: CP#52 completed / Impacted TSs and TRs: Stage 3
- 2038: CP#52 completed / Impacted TSs and TRs: 23.122, 24.008, 24.301, New 24.368
- 2039: CP#52 stopped (SA2 decided to move impact from CT3 to CT4). Updated WID CP-110147=>CP-110442 (no CT3 impact) / Impacted TSs and TRs: 29.212, 29.213, 29.215
- 2040: CP#52 completed / Impacted TSs and TRs: 23.003, 23.008, 29.002, 29.060, 29.230, 29.272, 29.274, 29.275, 29.282
- 2041: CP#52 completed / Impacted TSs and TRs: 31.102
- 2042: GP#51 completed. GP#47 approved WID / Impacted TSs and TRs: 44.018, 44.060
- 2043: GP#60 completed. GP#55 approved WID. Testing for CT1 part of Stage 3 for NIMTC UID_480105, GERAN part of NIMTC (Stage 3) UID_490003 / Impacted TSs and TRs: 51.010-1, 51.010-2
- 2044: RP#51 completed / Impacted TSs and TRs: UTRA, LTE 25.331, 25.413, 36.331, 36.413
- 2045: RP#60 completed. Testing for CT1 part of Stage 3 UID_480105, RAN mechanisms to avoid CN overload due to MTC UID_490024 / Impacted TSs and TRs: 34.123-1, 34.123-2, 34.123-3, 36.523-1, 36.523-2, 36.523-3

| ID | WBS | Task | Duration | Start | Finish | Complete | Baseline start | Baseline finish | Baseline duration | Constraint | Resources | Work | Actual work | Acronym | PCG approved | WI rapporteur name | Release | TSG approved | MCC resp | Acronym_3GU_Export | Special Focus Doc |
| --- | --- | --- | --- | --- | --- | --- | --- | --- | --- | --- | --- | --- | --- | --- | --- | --- | --- | --- | --- | --- | --- |
| 2046 | 501 | **Multi Access PDN Connectivity** | 527d? | 2009-03-13 A | 2011-03-18 A | 100% | 2009-03-13 | 2011-03-18 | 527d? |  | S2; C4; C1; C3 | 23680h | 23680h | MAPCON | PCG-22 | Telecom Italia | Rel-10 | SP-43 | Maurice | MAPCON |  |
| 2047 | 501.1 | Stage 2 for Multi Access PDN Connectivity | 401d? | 2009-03-13 A | 2010-09-23 A | 100% | 2009-03-13 | 2010-09-23 | 401d? |  | S2 | 3208h | 3208h | MAPCON |  | Telecom Italia | Rel-10 |  | Maurice |  |  |
| 2048 | 501.2 | **CT aspects of Multi Access PDN Connectivity** | 90d? | 2010-11-15 A | 2011-03-18 A | 100% | 2010-11-15 | 2011-03-18 | 90d? |  | C4; C1; C3 | 3608h | 3608h | MAPCON-St3 | PCG-26 | ZTE | Rel-10 | CP-50 | Kimmo | MAPCON-St3 |  |
| 2049 | 501.2.1 | CT4 aspects of Multi Access PDN Connectivity | 20d? | 2010-11-15 A | 2010-12-10 A | 100% | 2010-11-15 | 2010-12-10 | 20d? | start no earlier than 2010-12-10 | C4 | 160h | 160h | MAPCON-St3 | PCG-26 | ZTE | Rel-10 | CP-50 | Kimmo |  |  |
| 2050 | 501.2.2 | CT1 aspects of Multi Access PDN Connectivity | 71d? | 2010-12-10 A | 2011-03-18 A | 100% | 2010-12-10 | 2011-03-18 | 71d? | start no earlier than 2010-12-10 | C1 | 568h | 568h | MAPCON-St3 | PCG-26 | ZTE | Rel-10 | CP-50 | Frederic |  |  |
| 2051 | 501.2.3 | CT3 aspects of Multi Access PDN Connectivity | 90d? | 2010-11-15 A | 2011-03-18 A | 100% | 2010-11-15 | 2011-03-18 | 90d? | finish no earlier than 2011-03-18 | C3 | 720h | 720h | MAPCON-St3 | PCG-26 | ZTE | Rel-10 | CP-50 | Adrian |  |  |
| 2052 | 502 | **IMS Service Continuity – Inter Device Transfer enhancements** | 924d? | 2009-06-04 A | 2012-12-07 A | 100% | 2009-06-04 | 2012-12-07 | 924d? |  | S1; S2; C1; IETF | 41168h | 41168h | IMS_SC_eIDT | PCG-23 | Huawei | Rel-10 | SP-44 | Alain | IMS_SC_eIDT |  |
| 2053 | 502.1 | Stage 1 - IMS Service Continuity – Inter Device Transfer enhancements | 211d? | 2009-06-04 A | 2010-03-25 A | 100% | 2009-06-04 | 2010-03-25 | 211d? | finish no earlier than 2010-03-25 | S1 | 1688h | 1688h | IMS_SC_eIDT | PCG-23 | Huawei | Rel-10 | SP-44 | Alain |  |  |
| 2054 | 502.2 | Stage 2 - IMS Inter-UE Transfer enhancements | 261d? | 2009-09-24 A | 2010-09-23 A | 100% | 2009-09-24 | 2010-09-23 | 261d? | finish no earlier than 2010-09-23 | S2 | 2088h | 2088h | IMS_SC_eIDT | PCG-23 | Huawei | Rel-10 | SP-45 | Maurice |  |  |
| 2055 | 502.3 | Stage 3 - IMS Inter-UE Transfer enhancements | 261d? | 2010-03-19 A | 2011-03-18 A | 100% | 2010-03-19 | 2011-03-18 | 261d? | start no earlier than 2010-03-19 | C1 | 2088h | 2088h | IMS_SC_eIDT | PCG-24 | Huawei | Rel-10 | CP-47 | Frederic |  |  |
| 2056 | 502.4 | (IETF) Stage 3 - IMS Inter-UE Transfer enhancements | 717d? | 2010-03-19 A | 2012-12-07 A | 100% | 2010-03-19 | 2012-12-07 | 717d? | finish no earlier than 2012-12-04 | C1-IETF | 5736h | 5736h | IMS_SC_eIDT | PCG-27 | christer.holmberg@ericsson.com | Rel-10 | CP-52 | Frederic |  |  |
| 2057 | 503 | **IP-Short-Message-Gateway enhancements for CPM-SMS Interworking** | 257d? | 2009-09-24 A | 2010-09-17 A | 100% | 2009-09-24 | 2010-09-17 | 257d? |  | S1; S2; C3 | 9904.8h | 9904.8h | CPM-SMS | PCG-23 | China Mobile | Rel-10 | SP-45 | Alain | CPM-SMS |  |
| 2058 | 503.1 | Stage 1 for CPM-SMS | 131d? | 2009-09-24 A | 2010-03-25 A | 100% | 2009-09-24 | 2010-03-25 | 131d? | finish no earlier than 2010-03-25 | S1 | 1048h | 1048h | CPM-SMS | PCG-23 | China Mobile | Rel-10 | SP-45 | Alain |  |  |
| 2059 | 503.2 | Stage 2 for CPM-SMS | 130.1d? | 2009-09-24 A | 2010-03-25 A | 100% | 2009-09-24 | 2010-03-25 | 130.1d? | finish no earlier than 2010-03-25 | S2 | 1040.8h | 1040.8h | CPM-SMS | PCG-23 | Orange | Rel-10 | SP-45 | Maurice |  |  |
| 2060 | 503.3 | Stage 3 for IP-Short-Message-Gateway enhancements for CPM-SMS Interworking | 206d? | 2009-12-04 A | 2010-09-17 A | 100% | 2009-12-04 | 2010-09-17 | 206d? | finish no earlier than 2010-09-17 | C3 | 1648h | 1648h | CPM-SMS | PCG-24 | Ericsson | Rel-10 | CP-46 | Adrian |  |  |
| 2061 | 504 | **Completion of Communications on Not Logged-in** | 387d? | 2009-09-24 A | 2011-03-18 A | 100% | 2009-09-24 | 2011-03-18 | 387d? |  | S1; C1; C3 | 11992h | 11992h | CCNL | PCG-23 | Deutsche Telekom | Rel-10 | SP-45 | Alain | CCNL |  |
| 2062 | 504.1 | Stage 1 for Completion of Communications on Not Logged-in | 1d? | 2009-09-24 A | 2009-09-24 A | 100% | 2009-09-24 | 2009-09-24 | 1d? | start no earlier than 2009-09-24 | S1 | 8h | 8h | CCNL | PCG-23 | Deutsche Telekom | Rel-10 | SP-45 | Alain |  |  |
| 2063 | 504.2 | CT1 part of Stage 3 for Completion of Communications on Not Logged-in | 261d? | 2010-03-19 A | 2011-03-18 A | 100% | 2010-03-19 | 2011-03-18 | 261d? | finish no earlier than 2011-03-18 | C1 | 2088h | 2088h | CCNL | PCG-24 | Deutsche Telekom | Rel-10 | CP-47 | Frederic |  |  |
| 2064 | 504.3 | CT3 part of Stage 3 for Completion of Communications on Not Logged-in | 76d? | 2010-06-04 A | 2010-09-17 A | 100% | 2010-06-04 | 2010-09-17 | 76d? | finish no earlier than 2010-09-17 | C3 | 608h | 608h | CCNL | PCG-25 | Deutsche Telekom | Rel-10 | CP-48 | Adrian |  |  |
| 2065 | 505 | **Local IP Access and Selected Internet IP Traffic Offload** | 390d? | 2009-09-24 A | 2011-03-23 A | 100% | 2009-09-24 | 2011-03-23 | 390d? |  | S2; S1; S3; S5; C4; C1 | 66128h | 66128h | LIPA_SIPTO | PCG-23 | Huawei, China Mobile | Rel-10 | SP-45 | Maurice | LIPA_SIPTO | HNB |
| 2066 | 505.1 | Stage 1 for Local IP Access and Selected Internet IP Traffic Offload | 131d? | 2009-09-24 A | 2010-03-25 A | 100% | 2009-09-24 | 2010-03-25 | 131d? | finish no earlier than 2010-03-25 | S1 | 1048h | 1048h | LIPA_SIPTO | PCG-23 | Huawei, China Mobile | Rel-10 | SP-45 | Alain |  | HNB |
| 2067 | 505.2 | TR on Local IP Access and Selected Internet IP Traffic Offload | 387d? | 2009-09-24 A | 2011-03-18 A | 100% | 2009-09-24 | 2011-03-18 | 387d? | finish no earlier than 2011-03-18 | S2 | 3096h | 3096h | LIPA_SIPTO | PCG-23 | Huawei, China Mobile | Rel-10 | SP-45 | Maurice |  | HNB |
| 2068 | 505.3 | Security for Local IP Access and Selected Internet IP Traffic Offload | 261d? | 2009-09-24 A | 2010-09-23 A | 100% | 2009-09-24 | 2010-09-23 | 261d? | finish no earlier than 2010-09-23 | S3 | 2088h | 2088h | LIPA_SIPTO | PCG-23 | Huawei, Qualcomm | Rel-10 | SP-45 | Mirko |  | HNB |
| 2069 | 505.4 | OAM&P for Local IP Access and Selected Internet IP Traffic Offload | 390d? | 2009-09-24 A | 2011-03-23 A | 100% | 2009-09-24 | 2011-03-23 | 390d? | finish no earlier than 2011-03-23 | S5 | 3120h | 3120h | LIPA_SIPTO | PCG-23 | Huawei, China Mobile | Rel-10 | SP-45 | Mirko |  | HNB |
| 2070 | 505.5 | Charging for Local IP Access and Selected Internet IP Traffic Offload | 335d? | 2009-12-10 A | 2011-03-23 A | 100% | 2009-12-10 | 2011-03-23 | 335d? | finish no earlier than 2011-03-23 | S5 | 2680h | 2680h | LIPA_SIPTO | PCG-24 | Huawei, China Mobile | Rel-10 | SP-46 | Mirko |  | HNB |

Notes:
- 2046: CP#51 completed. SP#49 Stage 2 completed. Triggered by TR 23.861 UID_410043 FS_MAPIM. Stage 1 in Rel-9 22.278 (6.2 - IP session control) / WI rapporteur e-mail: ivano.guardini@telecomitalia.it
- 2047: SP#49 completed. Triggered by TR 23.861 UID_410043 FS_MAPIM. Stage 1 in Rel-9 22.278 (6.2 - IP session control) / Impacted TSs and TRs: 23.237, 23.401, 23.402 / WI rapporteur e-mail: ivano.guardini@telecomitalia.it
- 2048: CP#51 completed / WI rapporteur e-mail: Xingyue (Joy) Zhou (zhou.xingyue@zte.com.cn)
- 2049: CP#50 completed / Impacted TSs and TRs: 29.273, 29.272, 29.002, 23.008 / WI rapporteur e-mail: Xingyue (Joy) Zhou (zhou.xingyue@zte.com.cn)
- 2050: CP#51 completed / Impacted TSs and TRs: 24.302, 24.312 / WI rapporteur e-mail: Xingyue (Joy) Zhou (zhou.xingyue@zte.com.cn)
- 2051: CP#51 completed / Impacted TSs and TRs: 29.215 / WI rapporteur e-mail: Xingyue (Joy) Zhou (zhou.xingyue@zte.com.cn)
- 2052: CP#51 completed. SP#47 Stage 1 completed. Rel-9 set Inter-Device Transfer requirements UID_410033 (IMS_SCC-IDT). Adds IDT scenarios and requirements / WI rapporteur e-mail: Amar Deol (adeol@huawei.com)
- 2053: SP#47 completed / Impacted TSs and TRs: 22.228 / WI rapporteur e-mail: Amar Deol (adeol@huawei.com)
- 2054: SP#49 completed / Impacted TSs and TRs: 23.237, 23.292, new 23.831 / WI rapporteur e-mail: Lee Valerius (lvalerius@huawei.com)
- 2055: CP#51 completed. WID updated CP-100334=>CP-110285 / Impacted TSs and TRs: 24.216, 24.229, 24.237, new (24.837, 24.337) / WI rapporteur e-mail: georg.mayer@huawei.com
- 2056: CP#58 completed / Impacted TSs and TRs: RFC 6809 (was draft-ietf-sipcore-proxy-feature) / WI rapporteur e-mail: christer.holmberg@ericsson.com
- 2057: CP#49 completed. SP#47 Stage 1 completed. IP-SM-GW enhancements for interworking with OMA CPM / WI rapporteur e-mail: Qing Huang (huangqing@chinamobile.com)
- 2058: SP#47 completed. External requirements (Stage 1 in OMA-RD-CPM-V1_0-20090310-C) / Impacted TSs and TRs: 22.340 / WI rapporteur e-mail: Qing Huang
- 2059: SP#47 completed / Impacted TSs and TRs: 23.204, new TR 23.824 / WI rapporteur e-mail: antoine.mouquet@orange-ftgroup.com
- 2060: CP#49 completed. Linked to Rel-8 UID_340031 Service-Level Interworking for Messaging Services (MESSIW) 23.204 / Impacted TSs and TRs: 29.311 / WI rapporteur e-mail: Jan Holm
- 2061: CP#51 completed. SP#45 Stage 1 completed / WI rapporteur e-mail: Kurt Bischinger
- 2062: SP#45 completed / Impacted TSs and TRs: 22.173 CR#0056r1 / WI rapporteur e-mail: Kurt Bischinger
- 2063: CP#51 completed / Impacted TSs and TRs: 24.173, 24.642 / WI rapporteur e-mail: martin.huelsemann@telekom.de
- 2064: CP#49 completed / Impacted TSs and TRs: 29.165 / WI rapporteur e-mail: martin.huelsemann@telekom.de
- 2065: TSG#51 completed. Updated WID SP-100696=>SP-110131. SP#49 Stage 2 & Security completed. UID_400035 Enhanced Home NodeB/eNodeB (EHNB) formerly covered Local IP Access to Internet and Local access to Home Network from the Home NodeB/eNodeB / WI rapporteur e-mail: patrice.hede@huawei.com, Tao Sun (suntao@chinamobile.com)
- 2066: SP#47 completed / Impacted TSs and TRs: 22.101, 22.220 / WI rapporteur e-mail: Amar Deol (adeolf@huawei.com), Gang Li (ligangyf@chinamobile.com)
- 2067: SP#51 completed. TR 23.829 for Approval / Impacted TSs and TRs: New TR 23.829 / WI rapporteur e-mail: patrice.hede@huawei.com, Tao Sun (suntao@chinamobile.com)
- 2068: SP#49 completed / Impacted TSs and TRs: 33.102, 33.107, 33.108, 33.320, 33.401 / WI rapporteur e-mail: Marcus Wong (mwong@huawei.com), Brian Rosenberg (bmr@qualcomm.com)
- 2069: SP#51 completed. Updated WID SP-100696=>SP-110131 / Impacted TSs and TRs: 32.581, 32.582, 32.584, 32.591, 32.592, 32.642, 32.646, 32.772, 32.782 / WI rapporteur e-mail: Zou Lan (zlan@huawei.com), Chen Gang (chengang@chinamobile.com)
- 2070: SP#51 completed. Updated WID SP-100696=>SP-110131 / Impacted TSs and TRs: 32.251 / WI rapporteur e-mail: shan.mingjun@huawei.com, Ai Chen (chenai@chinamobile.com)

| ID | WBS | Task | Duration | Start | Finish | Complete | Baseline start | Baseline finish | Baseline duration | Constraint | Resources | Work | Actual work | Acronym | PCG approved | WI rapporteur name | WI rapporteur e-mail | Release | TSG approved | MCC resp | Special Focus Doc | Acronym_3GU_Export |
| --- | --- | --- | --- | --- | --- | --- | --- | --- | --- | --- | --- | --- | --- | --- | --- | --- | --- | --- | --- | --- | --- | --- |
| 2071 | 505.6 | **Stage 2/3 for Local IP Access** | 387d? | 2009-09-24 A | 2011-03-18 A | 100% | 2009-09-24 | 2011-03-18 | 387d? |  | S2; C4; C1 | 17968h | 17968h | LIPA | PCG-23 | Huawei, China Mobile | patrice.hede@huawei.com, Tao Sun (suntao@chinamobile.com) | Rel-10 | SP-45 | Maurice | HNB | LIPA |
| 2072 | 505.6.1 | Stage 2 for Local IP Access | 261d? | 2009-09-24 A | 2010-09-23 A | 100% | 2009-09-24 | 2010-09-23 | 261d? | finish no earlier than 2010-08-10 | S2 | 2088h | 2088h | LIPA | PCG-23 | Huawei, China Mobile | patrice.hede@huawei.com, Tao Sun (suntao@chinamobile.com) | Rel-10 | SP-45 | Maurice | HNB |  |
| 2073 | 505.6.2 | **Stage 3 for Local IP Access** | 206d? | 2010-06-04 A | 2011-03-18 A | 100% | 2010-06-04 | 2011-03-18 | 206d? |  | C4; C1 | 6592h | 6592h | LIPA | PCG-25 | China Mobile | Zhang Hao (zhanghao@chinamobile.com) | Rel-10 | CP-48 | Kimmo | HNB |  |
| 2074 | 505.6.2.1 | CT4 part of Stage 3 for Local IP Access | 206d? | 2010-06-04 A | 2011-03-18 A | 100% | 2010-06-04 | 2011-03-18 | 206d? | finish no earlier than 2011-03-18 | C4 | 1648h | 1648h | LIPA | PCG-25 | China Mobile | Zhang Hao (zhanghao@chinamobile.com) | Rel-10 | CP-48 | Kimmo | HNB |  |
| 2075 | 505.6.2.2 | CT1 part of Stage 3 for Local IP Access | 206d? | 2010-06-04 A | 2011-03-18 A | 100% | 2010-06-04 | 2011-03-18 | 206d? | finish no earlier than 2011-03-18 | C1 | 1648h | 1648h | LIPA | PCG-25 | China Mobile | Zhang Hao (zhanghao@chinamobile.com) | Rel-10 | CP-48 | Frederic | HNB |  |
| 2076 | 505.7 | **Stage 2/3 for SIPTO for macro networks** | 387d? | 2009-09-24 A | 2011-03-18 A | 100% | 2009-09-24 | 2011-03-18 | 387d? |  | S2; C4; C1 | 17408h | 17408h | SIPTO | PCG-23 | Huawei, China Mobile | patrice.hede@huawei.com, Tao Sun (suntao@chinamobile.com) | Rel-10 | SP-45 | Maurice | HNB | SIPTO |
| 2077 | 505.7.1 | Stage 2 for SIPTO for macro networks | 261d? | 2009-09-24 A | 2010-09-23 A | 100% | 2009-09-24 | 2010-09-23 | 261d? | finish no earlier than 2010-09-23 | S2 | 2088h | 2088h | SIPTO | PCG-23 | Huawei, China Mobile | patrice.hede@huawei.com, Tao Sun (suntao@chinamobile.com) | Rel-10 | SP-45 | Maurice | HNB |  |
| 2078 | 505.7.2 | **Stage 3 for SIPTO for macro networks** | 206d? | 2010-06-04 A | 2011-03-18 A | 100% | 2010-06-04 | 2011-03-18 | 206d? |  | C4; C1 | 6032h | 6032h | SIPTO | PCG-25 | Huawei | Caixia Qi (qcxmay@huawei.com) | Rel-10 | CP-48 | Kimmo | HNB |  |
| 2079 | 505.7.2.1 | CT4 part of Stage 3 for SIPTO for macro networks | 206d? | 2010-06-04 A | 2011-03-18 A | 100% | 2010-06-04 | 2011-03-18 | 206d? | finish no earlier than 2011-03-18 | C4 | 1648h | 1648h | SIPTO | PCG-25 | Huawei | Caixia Qi (qcxmay@huawei.com) | Rel-10 | CP-48 | Kimmo | HNB |  |
| 2080 | 505.7.2.2 | CT1 part of Stage 3 for SIPTO for macro networks | 136d? | 2010-06-04 A | 2010-12-10 A | 100% | 2010-06-04 | 2010-12-10 | 136d? | finish no earlier than 2011-03-18 | C1 | 1088h | 1088h | SIPTO | PCG-25 | Huawei | Caixia Qi (qcxmay@huawei.com) | Rel-10 | CP-48 | Frederic | HNB |  |
| 2081 | 506 | **IP Flow Mobility and seamless WLAN offload** | 390d? | 2009-09-24 A | 2011-03-23 A | 100% | 2009-09-24 | 2011-03-23 | 390d? |  | S2; S1; S5; C1; C3 | 26808h | 26808h | IFOM | PCG-23 | Qualcomm | Gerardo Giaretta (gerardo@qualcomm.com) | Rel-10 | SP-45 | Maurice | WLAN | IFOM |
| 2082 | 506.1 | Stage 1 for IP Flow Mobility and seamless WLAN offload | 56d? | 2009-09-24 A | 2009-12-10 A | 100% | 2009-09-24 | 2009-12-10 | 56d? | finish no earlier than 2009-12-10 | S1 | 448h | 448h | IFOM | PCG-23 | Qualcomm | David Williams (dwilliam@qualcomm.com) | Rel-10 | SP-45 | Alain | WLAN |  |
| 2083 | 506.2 | Stage 2 for IP Flow Mobility and seamless WLAN offload | 261d? | 2009-09-24 A | 2010-09-23 A | 100% | 2009-09-24 | 2010-09-23 | 261d? | finish no earlier than 2010-09-23 | S2 | 2088h | 2088h | IFOM | PCG-23 | Qualcomm | Gerardo Giaretta (gerardo@qualcomm.com) | Rel-10 | SP-45 | Maurice | WLAN |  |
| 2084 | 506.3 | Charging for IP Flow Mobility and seamless WLAN offload | 260d? | 2010-03-25 A | 2011-03-23 A | 100% | 2010-03-25 | 2011-03-23 | 260d? | finish no earlier than 2011-03-23 | S5 | 2080h | 2080h | IFOM | PCG-24 | Alcatel-Lucent | maryse.gardella@alcatel-lucent.com | Rel-10 | SP-47 | Mirko | WLAN |  |
| 2085 | 506.4 | **Stage 3 for IP Flow Mobility and seamless WLAN offload** | 206d? | 2010-06-04 A | 2011-03-18 A | 100% | 2010-06-04 | 2011-03-18 | 206d? |  | C1; C3 | 6592h | 6592h | IFOM-CT | PCG-25 | Qualcomm | Patrick Stupar (pstupar@qualcomm.com) | Rel-10 | CP-48 | Frederic | WLAN | IFOM-CT |
| 2086 | 506.4.1 | CT1 part of Stage 3 for IP Flow Mobility and seamless WLAN offload | 206d? | 2010-06-04 A | 2011-03-18 A | 100% | 2010-06-04 | 2011-03-18 | 206d? | finish no earlier than 2011-03-18 | C1 | 1648h | 1648h | IFOM-CT | PCG-25 | Qualcomm | Patrick Stupar (pstupar@qualcomm.com) | Rel-10 | CP-48 | Frederic | WLAN |  |
| 2087 | 506.4.2 | CT3 part of Stage 3 for IP Flow Mobility and seamless WLAN offload | 206d? | 2010-06-04 A | 2011-03-18 A | 100% | 2010-06-04 | 2011-03-18 | 206d? | finish no earlier than 2011-03-18 | C3 | 1648h | 1648h | IFOM-CT | PCG-25 | Qualcomm | Patrick Stupar (pstupar@qualcomm.com) | Rel-10 | CP-48 | Adrian | WLAN |  |
| 2088 | 507 | **Enabling Coder Selection and Rate Adaptation for UTRAN and E-UTRAN for Load Adaptive Applications** | 827.4d? | 2009-07-15 A | 2012-09-07 A | 100% | 2009-07-15 | 2012-09-07 | 827.4d? |  | S2; S4; C4; C3; C1; IETF | 85939.2h | 85939.2h | ECSRA_LAA | PCG-23 | Qualcomm | AC Mahendran (ac@qualcomm.com) | Rel-10 | SP-45 | Maurice |  | ECSRA_LAA |
| 2089 | 507.1 | TR on Enabling Coder Selection and Rate Adaptation for UTRAN and E-UTRAN for Load Adaptive Applications | 186d? | 2010-01-07 A | 2010-09-23 A | 100% | 2010-01-07 | 2010-09-23 | 186d? | finish no earlier than 2010-09-23 | S2; S4 | 2976h | 2976h | ECSRA_LAA | PCG-23 | Qualcomm | AC Mahendran (ac@qualcomm.com) | Rel-10 | SP-45 | Maurice |  |  |
| 2090 | 507.2 | SA4 review of TR on Enabling Coder Selection and Rate Adaptation for UTRAN and E-UTRAN for Load Adaptive Applications | 320d? | 2009-09-24 A | 2010-12-15 A | 100% | 2009-09-24 | 2010-12-15 | 320d? | finish no earlier than 2010-12-15 | S4 | 2560h | 2560h | ECSRA_LAA | PCG-23 | Qualcomm | AC Mahendran (ac@qualcomm.com) | Rel-10 | SP-45 | Paolo |  |  |
| 2091 | 507.3 | Stage 2 for Enabling Coder Selection and Rate Adaptation for UTRAN and E-UTRAN for Load Adaptive Applications | 261d? | 2009-09-24 A | 2010-09-23 A | 100% | 2009-09-24 | 2010-09-23 | 261d? | finish no earlier than 2010-09-23 | S2 | 2088h | 2088h | ECSRA_LAA | PCG-23 | Qualcomm | AC Mahendran (ac@qualcomm.com) | Rel-10 | SP-45 | Maurice |  |  |
| 2092 | 507.4 | SA4 aspects of Enabling Coder Selection and Rate Adaptation for UTRAN and E-UTRAN for Load Adaptive Applications | 130d? | 2010-09-23 A | 2011-03-23 A | 100% | 2010-09-23 | 2011-03-23 | 130d? | finish no earlier than 2011-03-23 | S4 | 1040h | 1040h | ECSRA_LAA | PCG-25 | Qualcomm | AC Mahendran (ac@qualcomm.com) | Rel-10 | SP-49 | Paolo |  |  |
| 2093 | 507.5 | **CN aspects of Enabling Coder Selection and Rate Adaptation for UTRAN and E-UTRAN for Load Adaptive Applications** | 827.4d? | 2009-07-15 A | 2012-09-07 A | 100% | 2009-07-15 | 2012-09-07 | 827.4d? |  | C4; C3; C1 | 37560h | 37560h | ECSRA_LAA-CN | PCG-25 | Ericsson | philip.hodges@ericsson.com | Rel-10 | CP-49 | Kimmo |  | ECSRA_LAA-CN |
| 2094 | 507.5.1 | CT4 part of CN aspects of Enabling Coder Selection and Rate Adaptation for UTRAN and E-UTRAN for Load Adaptive Applications | 186d? | 2010-09-17 A | 2011-06-03 A | 100% | 2010-09-17 | 2011-06-03 | 186d? | start no earlier than 2010-09-17 | C4 | 1488h | 1488h | ECSRA_LAA-CN | PCG-25 | Ericsson | philip.hodges@ericsson.com | Rel-10 | CP-49 | Kimmo |  |  |
| 2095 | 507.5.2 | (IETF) CT3, CT4 part of CN aspects of Enabling Coder Selection and Rate Adaptation for UTRAN and E-UTRAN for Load Adaptive Applications | 827.4d? | 2009-07-15 A | 2012-09-07 A | 100% | 2009-07-15 | 2012-09-07 | 827.4d? | finish no earlier than 2012-09-07 | C3-IETF; C4-IETF | 13238.4h | 13238.4h | ECSRA_LAA-CN | PCG-27 | Lionel Morand |  | Rel-10 | CP-53 | Adrian |  |  |
| 2096 | 507.5.3 | CT3 part of CN aspects of Enabling Coder Selection and Rate Adaptation for UTRAN and E-UTRAN for Load Adaptive Applications | 186d? | 2010-09-17 A | 2011-06-03 A | 100% | 2010-09-17 | 2011-06-03 | 186d? | finish no earlier than 2011-06-03 | C3 | 1488h | 1488h | ECSRA_LAA-CN | PCG-25 | Ericsson | philip.hodges@ericsson.com | Rel-10 | CP-49 | Adrian |  |  |
| 2097 | 507.5.4 | CT1 part of CN aspects of Enabling Coder Selection and Rate Adaptation for UTRAN and E-UTRAN for Load Adaptive Applications | 186d? | 2010-09-17 A | 2011-06-03 A | 100% | 2010-09-17 | 2011-06-03 | 186d? | start no earlier than 2010-09-17 | C1 | 1488h | 1488h | ECSRA_LAA-CN | PCG-25 | Ericsson | philip.hodges@ericsson.com | Rel-10 | CP-49 | Frederic |  |  |

Notes:
- 2071: -
- 2072: SP#49 completed (has impacts to RAN) / Impacted TSs and TRs: 23.060, 23.401
- 2073: CP#51 completed
- 2074: CP#51 completed / Impacted TSs and TRs: 23.008, 23.015, 29.002, 29.060, 29.272, 29.274, 29.281, 29.303
- 2075: CP#51 completed / Impacted TSs and TRs: 24.008, 24.301
- 2076: -
- 2077: SP#49 completed (SIPTO GW selection for wild card APN and for GERAN. Serving-GW selection for SIPTO. Corrections and Clarifications of the SIPTO procedure) / Impacted TSs and TRs: 23.060, 23.401
- 2078: CP#51 completed. Updated WID CP-100419=>CP-110091
- 2079: CP#51 completed. Updated WID CP-100419=>CP-110091 / Impacted TSs and TRs: 23.003, 23.008, 29.002, 29.272, 29.303
- 2080: CP#50 completed / Impacted TSs and TRs: 24.008, 24.301
- 2081: SP#51 completed. Triggered by Rel-10 TR 23.861 (UID_410043 Study on Multi Access PDN connectivity and IP flow mobility - MAPIM)
- 2082: SP#46 completed / Impacted TSs and TRs: 22.278
- 2083: SP#49 completed / Impacted TSs and TRs: 23.203, 23.402, new 23.261
- 2084: SP#51 completed / Impacted TSs and TRs: 32.240, 32.251, 32.252, 32.298, 32.299
- 2085: CP#51 completed / Impacted TSs and TRs: Stage 3
- 2086: CP#51 completed / Impacted TSs and TRs: 24.008, 24.301, 24.302, 24.303, 24.312, 24.327
- 2087: CP#51 completed / Impacted TSs and TRs: 29.212, 29.213, 29.214, 29.215
- 2088: CP#52 completed. Triggered by Rel-9 UID_440013 Vocoder rate adaptation for LTE / Impacted TSs and TRs: UTRA, LTE
- 2089: SP#48 completed / Impacted TSs and TRs: new 23.860
- 2090: SP#50 completed / Impacted TSs and TRs: new 23.860
- 2091: SP#49 completed / Impacted TSs and TRs: 23.060, 23.203, 23.228, 23.401
- 2092: SP#51 completed / Impacted TSs and TRs: 26.114
- 2093: CP#52 completed / Impacted TSs and TRs: Stage 2/3
- 2094: CP#52 completed / Impacted TSs and TRs: 23.334, 29.334, 29.238, 23.333, 29.333, 29.232, 29.332
- 2095: CP#57 completed / Impacted TSs and TRs: RFC 6679 (was draft-ietf-avtcore-ecn-for-rtp)
- 2096: CP#52 completed / Impacted TSs and TRs: 29.162, 29.163, 29.213, 29.235, 29.292
- 2097: CP#52 completed / Impacted TSs and TRs: 24.229

| ID | WBS | Task | Type | Duration | Start | Finish | Complete | Baseline start | Baseline finish | Baseline duration | Constraint | Resources | Work | Actual work | Acronym | PCG approved | Impacted TSs and TRs | WI rapporteur name | WI rapporteur e-mail | Release | TSG approved | MCC resp | Special Focus Doc | Acronym_3GU_Export | PCG stopped | TSG stopped |
| --- | --- | --- | --- | --- | --- | --- | --- | --- | --- | --- | --- | --- | --- | --- | --- | --- | --- | --- | --- | --- | --- | --- | --- | --- | --- | --- |
| 2098 | 508 | **Extended H(e)NB features** |  | 467d? | 2008-12-11 A | 2010-09-23 A | 100% | 2008-12-11 | 2010-09-23 | 467d? |  | S1; S2; S3 | 15552h | 15552h | EHNBF | PCG-23 | UTRA, LTE | NEC | joerg.swetina@neclab.eu | Rel-10 | SP-45 | Alain | HNB | EHNBF |  |  |
| 2099 | 508.1 | Stage 1 of Extended H(e)NB features |  | 131d? | 2009-09-24 A | 2010-03-25 A | 100% | 2009-09-24 | 2010-03-25 | 131d? | finish no earlier than 2010-03-25 | S1 | 1048h | 1048h | EHNBF | PCG-23 | 22.220 | NEC | joerg.swetina@neclab.eu | Rel-10 | SP-45 | Alain | HNB |  |  |  |
| 2100 | 508.2 | IMS aspects of Architecture for Home NodeB |  | 336d? | 2008-12-11 A | 2010-03-25 A | 100% | 2008-12-11 | 2010-03-25 | 336d? | finish no earlier than 2010-03-25 | S2 | 2688h | 2688h | EHNB-IMS | PCG-22 | New 23.832 | Alcatel-Lucent | Nicolas Drevon | Rel-10 | SP-42 | Maurice | HNB | EHNB-IMS |  |  |
| 2101 | 508.3 | Extended H(e)NB Security features (Stage 2) |  | 76d? | 2010-06-10 A | 2010-09-23 A | 100% | 2010-06-10 | 2010-09-23 | 76d? | finish no earlier than 2010-09-23 | S3 | 608h | 608h | EHNBF-Sec | PCG-25 | 33.320 | Huawei | Marcus Wong (mwong@huawei.com) | Rel-10 | SP-48 | Mirko | HNB | EHNBF-Sec |  |  |
| 2102 | 509 | **Optimal Media Routing** |  | 314d? | 2010-03-25 A | 2011-06-08 A | 100% | 2010-03-25 | 2011-06-08 | 314d? |  | S2; S5; C3; C1 | 22696h | 22696h | OMR | PCG-24 |  | Alcatel-Lucent | andy.bennett@alcatel-lucent.com | Rel-10 | SP-46 | Maurice |  | OMR |  |  |
| 2103 | 509.1 | Stage 2 for Optimal Media Routing | milestone | 0d? | 2010-03-25 A | 2010-03-25 A | 100% | 2010-03-25 | 2010-03-25 | 0d? |  | S2 |  |  | OMR | PCG-24 | 23.228 | Alcatel-Lucent | andy.bennett@alcatel-lucent.com | Rel-10 | SP-46 | Maurice |  |  |  |  |
| 2104 | 509.2 | **Stage 3 for Optimal Media Routing** |  | 261d? | 2010-06-04 A | 2011-06-03 A | 100% | 2010-06-04 | 2011-06-03 | 261d? |  | C3; C1; C4 | 11648h | 11648h | OMR | PCG-25 |  | Alcatel-Lucent | jim.calme@alcatel-lucent.com | Rel-10 | CP-48 | Adrian |  |  |  |  |
| 2105 | 509.2.1 | CT3 part of Stage 3 for Optimal Media Routeing |  | 261d? | 2010-06-04 A | 2011-06-03 A | 100% | 2010-06-04 | 2011-06-03 | 261d? | finish no earlier than 2011-06-03 | C3 | 2088h | 2088h | OMR | PCG-25 | 29.162, 29.163, 29.165, 29.235, new TS 29.079 | Alcatel-Lucent | jim.calme@alcatel-lucent.com | Rel-10 | CP-48 | Adrian |  |  |  |  |
| 2106 | 509.2.2 | CT1 part of Stage 3 for Optimal Media Routeing |  | 206d? | 2010-06-04 A | 2011-03-18 A | 100% | 2010-06-04 | 2011-03-18 | 206d? | finish no earlier than 2011-03-18 | C1 | 1648h | 1648h | OMR | PCG-25 | 24.229 | Alcatel-Lucent | jim.calme@alcatel-lucent.com | Rel-10 | CP-48 | Frederic |  |  |  |  |
| 2107 | 509.2.3 | Deleted - CT4 part of Stage 3 for Optimal Media Routeing |  | 206d? | 2010-06-04 A | 2011-03-18 A | 100% | 2010-06-04 | 2011-03-18 | 206d? | finish no earlier than 2011-03-18 | C4 | 1648h | 1648h | OMR | PCG-25 |  | Alcatel-Lucent | jim.calme@alcatel-lucent.com | Rel-10 | CP-48 | Kimmo |  |  | PCG-26 | CP-51 |
| 2108 | 509.3 | Charging for Optimal Media Routing |  | 125d? | 2010-12-16 A | 2011-06-08 A | 100% | 2010-12-16 | 2011-06-08 | 125d? | finish no earlier than 2011-06-08 | S5 | 1000h | 1000h | OMR | PCG-26 | 32.260, 32.298, 32.299 | Alcatel-Lucent | maryse.gardella@alcatel-lucent.com | Rel-10 | SP-50 | Mirko |  |  |  |  |
| 2109 | 510 | **IMS Emergency Session Enhancements** |  | 312d? | 2010-03-25 A | 2011-06-03 A | 100% | 2010-03-25 | 2011-06-03 | 312d? |  | S1; S2; C1 | 9552h | 9552h | IESE | PCG-24 |  | Deutsche Telekom, T-Mobile | michele.zarri@t-mobile.co.uk | Rel-10 | SP-47 | Maurice | Public Safety (I-A) | IESE |  |  |
| 2110 | 510.1 | Stage 1 for IMS Emergency Session Enhancements |  | 1d? | 2010-03-25 A | 2010-03-25 A | 100% | 2010-03-25 | 2010-03-25 | 1d? | start no earlier than 2010-03-25 | S1 | 8h | 8h | IESE | PCG-24 | 22.101 CR#0343 | Deutsche Telekom, T-Mobile | Kurt Bischinger | Rel-10 | SP-47 | Alain | Public Safety (I-A) |  |  |  |
| 2111 | 510.2 | Stage 2 for IMS Emergency Session Enhancements |  | 131d? | 2010-03-25 A | 2010-09-23 A | 100% | 2010-03-25 | 2010-09-23 | 131d? | finish no earlier than 2010-09-23 | S2 | 1048h | 1048h | IESE | PCG-24 | 23.167 | Deutsche Telekom, T-Mobile | michele.zarri@t-mobile.co.uk | Rel-10 | SP-47 | Maurice | Public Safety (I-A) |  |  |  |
| 2112 | 510.3 | Stage 3 for IMS Emergency Session Enhancements |  | 126d? | 2010-12-10 A | 2011-06-03 A | 100% | 2010-12-10 | 2011-06-03 | 126d? | finish no earlier than 2011-06-03 | C1 | 1008h | 1008h | IESE | PCG-26 | 24.229 | Deutsche Telekom | reinhard.lauster@t-mobile.at | Rel-10 | CP-50 | Frederic | Public Safety (I-A) |  |  |  |
| 2113 | 511 | **S2b Mobility based on GTP** |  | 202d? | 2010-06-10 A | 2011-03-18 A | 100% | 2010-06-10 | 2011-03-18 | 202d? |  | S2; C4; C3; C1 | 12800h | 12800h | SMOG | PCG-25 |  | Alcatel-Lucent | bruno.landais@alcatel-lucent.com | Rel-10 | SP-48 | Maurice | WLAN | SMOG |  |  |
| 2114 | 511.1 | Stage 2 for S2b Mobility based on GTP |  | 76d? | 2010-06-10 A | 2010-09-23 A | 100% | 2010-06-10 | 2010-09-23 | 76d? | finish no earlier than 2010-09-23 | S2 | 608h | 608h | SMOG | PCG-25 | 23.002, 23.203, 23.402 | Alcatel-Lucent | bruno.landais@alcatel-lucent.com | Rel-10 | SP-48 | Maurice | WLAN |  |  |  |
| 2115 | 511.2 | **Stage 3 for S2b Mobility based on GTP** |  | 131d? | 2010-09-17 A | 2011-03-18 A | 100% | 2010-09-17 | 2011-03-18 | 131d? |  | C4; C3; C1 | 5728h | 5728h | SMOG-St3 | PCG-25 |  | Alcatel-Lucent | bruno.landais@alcatel-lucent.com | Rel-10 | CP-49 | Kimmo | WLAN | SMOG-St3 |  |  |
| 2116 | 511.2.1 | CT4 part of Stage 3 for S2b Mobility based on GTP |  | 131d? | 2010-09-17 A | 2011-03-18 A | 100% | 2010-09-17 | 2011-03-18 | 131d? | finish no earlier than 2011-03-18 | C4 | 1048h | 1048h | SMOG-St3 | PCG-25 | 23.003, 23.007, 23.008, 29.273, 29.274, 29.281, 29.303 | Alcatel-Lucent | bruno.landais@alcatel-lucent.com | Rel-10 | CP-49 | Kimmo | WLAN |  |  |  |
| 2117 | 511.2.2 | CT3 part of Stage 3 for S2b Mobility based on GTP |  | 131d? | 2010-09-17 A | 2011-03-18 A | 100% | 2010-09-17 | 2011-03-18 | 131d? | finish no earlier than 2011-03-18 | C3 | 1048h | 1048h | SMOG-St3 | PCG-25 | 29.212, 29.213, 29.215 | Alcatel-Lucent | bruno.landais@alcatel-lucent.com | Rel-10 | CP-49 | Adrian | WLAN |  |  |  |
| 2118 | 511.2.3 | CT1 part of Stage 3 for S2b Mobility based on GTP |  | 61d? | 2010-09-17 A | 2010-12-10 A | 100% | 2010-09-17 | 2010-12-10 | 61d? | finish no earlier than 2010-12-10 | C1 | 488h | 488h | SMOG-St3 | PCG-25 | 24.302 | Alcatel-Lucent | bruno.landais@alcatel-lucent.com | Rel-10 | CP-49 | Frederic | WLAN |  |  |  |
| 2119 | 512 | **Policy Enhancements for Sponsored Connectivity and Coherent Access to Policy related Databases** |  | 113.15d? | 2010-10-12 A | 2011-03-18 A | 100% | 2010-10-12 | 2011-03-18 | 113.15d? |  | S2; C3 | 2378.4h | 2378.4h | PEST | PCG-26 |  | Qualcomm | AC Mahendran (ac@qualcomm.com) | Rel-10 | SP-50 | Maurice |  | PEST |  |  |
| 2120 | 512.1 | Stage 2 for Policy Enhancements for Sponsored Connectivity and Coherent Access to Policy related Databases | milestone | 0d? | 2010-10-12 A | 2010-12-15 A | 100% | 2010-10-12 | 2010-12-15 | 0d? | finish no earlier than 2010-12-15 | S2 |  |  | PEST | PCG-26 | 23.002, 23.203 | Qualcomm | AC Mahendran (ac@qualcomm.com) | Rel-10 | SP-50 | Maurice |  |  |  |  |
| 2121 | 512.2 | CT3 aspects of Policy Enhancements for Sponsored Connectivity and Coherent Access to Policy related Databases |  | 71d? | 2010-12-10 A | 2011-03-18 A | 100% | 2010-12-10 | 2011-03-18 | 71d? | finish no earlier than 2011-03-18 | C3 | 568h | 568h | PEST-CT3 | PCG-26 | 29.212, 29.213, 29.214, 29.215 | ZTE | zhou.xiaoyun@zte.com.cn | Rel-10 | CP-50 | Adrian |  | PEST-CT3 |  |  |

Notes:
- 2098: SP#49 completed. Adds extensions to Rel-9 functionality in UID_400035 Enhanced Home NodeB / eNodeB (EHNB)
- 2099: SP#47 completed
- 2100: SP#47 completed. Chosen solution has no normative impacts
- 2101: SP#49 completed
- 2102: CP#52 completed. SP#47 Stage 2 completed. Triggered by TR 23.894 (UID_370050 Study on System enhancements for the use of IMS services in local breakout)
- 2103: SP#47 completed
- 2104: CP#51 completion 03/11=>06/11. WID updated CP-100327=>CP-110134
- 2105: CP#52 completed
- 2106: CP#51 completed. WID updated CP-100327=>CP-110134
- 2107: CP#51 stopped (CT4 specs not impacted). WID updated CP-100327=>CP-110134
- 2108: SP#52 completed. Stage 3: Linked to CT3 TS 29.079 OMR within the IMS; Stage 3 (UID_480110)
- 2109: CP#52 completed. SP#49 completed. Source of external requirements: ETSI TISPAN TS 181.019 (Business Communication Requirements)
- 2110: SP#47 completed
- 2111: SP#49 completed
- 2112: CP#52 completed
- 2113: CP#51 completed. SP#49 Stage 2 completed. Related to Rel-10 UID_470049 Study on S2b mobility based on GTP (TR23.834), UID_350027 SAE for support for non-3GPP accesses. Stage1 in Rel-8 UID_320022 Reqs for evolution of 3GPP system architecture (AIPN-SAE)
- 2114: SP#49 completed
- 2115: CP#51 Stage 3 completed
- 2116: CP#51 completed
- 2117: CP#51 completed
- 2118: CP#50 completed
- 2119: CP#51 completed. SP#50 Stage 2 completed. Triggered by the SA1,SA2 Rel-10 TR 23.813 Study on Policy solutions and enhancements (FS_PP) UID_440047. Provides Video Call seamless service continuity for 3G/LTE terminal user
- 2120: SP#51 updated WID SP-100702=>SP-110196. SP#49 work completed as SA2 CRs approved under TEI10 (SP-10557)
- 2121: CP#51 completed

| ID | WBS | Task | Duration | Start | Finish | Complete | Baseline start | Baseline finish | Baseline duration | Constraint | Resources | Work | Actual work | Acronym | PCG approved | WI rapporteur name | WI rapporteur e-mail | Release | TSG approved | MCC resp | Acronym_3GU_Export | PCG stopped | TSG stopped |
| --- | --- | --- | --- | --- | --- | --- | --- | --- | --- | --- | --- | --- | --- | --- | --- | --- | --- | --- | --- | --- | --- | --- | --- |
| 2122 | 513 | **Lawful Interception in the 3GPP Rel-10** | 315d? | 2010-03-25 A | 2011-06-08 A | 100% | 2010-03-25 | 2011-06-08 | 315d? |  | S3 | 20480h | 20480h | LI10 | PCG-24 | PIDS, BT | Koen Jaspers (k.b.jaspers@minjus.nl), alex.leadbeater@bt.com | Rel-10 | SP-47 | Mirko | LI10 |  |  |
| 2123 | 513.1 | LI for CAT (Customer Alerting Tones) | 315d? | 2010-03-25 A | 2011-06-08 A | 100% | 2010-03-25 | 2011-06-08 | 315d? | finish no earlier than 2011-03-23 | S3 | 2520h | 2520h | LI10 | PCG-24 | PIDS, BT | Koen Jaspers (k.b.jaspers@minjus.nl), alex.leadbeater@bt.com | Rel-10 | SP-47 | Mirko |  |  |  |
| 2124 | 513.2 | LI for CRS (Customized Ringing Signal) | 315d? | 2010-03-25 A | 2011-06-08 A | 100% | 2010-03-25 | 2011-06-08 | 315d? | finish no earlier than 2011-03-23 | S3 | 2520h | 2520h | LI10 | PCG-24 | PIDS, BT | Koen Jaspers (k.b.jaspers@minjus.nl), alex.leadbeater@bt.com | Rel-10 | SP-47 | Mirko |  |  |  |
| 2125 | 513.3 | LI for EPS enhancements | 315d? | 2010-03-25 A | 2011-06-08 A | 100% | 2010-03-25 | 2011-06-08 | 315d? | finish no earlier than 2011-03-23 | S3 | 2520h | 2520h | LI10 | PCG-24 | PIDS, BT | Koen Jaspers (k.b.jaspers@minjus.nl), alex.leadbeater@bt.com | Rel-10 | SP-47 | Mirko |  |  |  |
| 2126 | 513.4 | LI for VCC (Voice Call Continuity) | 260d? | 2010-03-25 A | 2011-03-23 A | 100% | 2010-03-25 | 2011-03-23 | 260d? | finish no earlier than 2011-03-23 | S3 | 2080h | 2080h | LI10 | PCG-24 | PIDS, BT | Koen Jaspers (k.b.jaspers@minjus.nl), alex.leadbeater@bt.com | Rel-10 | SP-47 | Mirko |  |  |  |
| 2127 | 513.5 | LI for MEDIASEC (IMS Media security) | 260d? | 2010-03-25 A | 2011-03-23 A | 100% | 2010-03-25 | 2011-03-23 | 260d? | finish no earlier than 2011-03-23 | S3 | 2080h | 2080h | LI10 | PCG-24 | PIDS, BT | Koen Jaspers (k.b.jaspers@minjus.nl), alex.leadbeater@bt.com | Rel-10 | SP-47 | Mirko |  |  |  |
| 2128 | 513.6 | LI for H(e)NB also with Local IP Access and Selected IP Traffic Offload (LIPA, SIPTO) | 260d? | 2010-03-25 A | 2011-03-23 A | 100% | 2010-03-25 | 2011-03-23 | 260d? | finish no earlier than 2011-03-23 | S3 | 2080h | 2080h | LI10 | PCG-24 | PIDS, BT | Koen Jaspers (k.b.jaspers@minjus.nl), alex.leadbeater@bt.com | Rel-10 | SP-47 | Mirko |  |  |  |
| 2129 | 513.7 | LI for MBMS enhancements | 260d? | 2010-03-25 A | 2011-03-23 A | 100% | 2010-03-25 | 2011-03-23 | 260d? | finish no earlier than 2011-03-23 | S3 | 2080h | 2080h | LI10 | PCG-24 | PIDS, BT | Koen Jaspers (k.b.jaspers@minjus.nl), alex.leadbeater@bt.com | Rel-10 | SP-47 | Mirko |  |  |  |
| 2130 | 513.8 | LI for LCLS (Local Call Local Switch) | 260d? | 2010-03-25 A | 2011-03-23 A | 100% | 2010-03-25 | 2011-03-23 | 260d? | finish no earlier than 2011-03-23 | S3 | 2080h | 2080h | LI10 | PCG-24 | PIDS, BT | Koen Jaspers (k.b.jaspers@minjus.nl), alex.leadbeater@bt.com | Rel-10 | SP-47 | Mirko |  |  |  |
| 2131 | 514 | Optimization of IMS based PSS and MBMS User Service | 260d? | 2010-03-25 A | 2011-03-23 A | 100% | 2010-03-25 | 2011-03-23 | 260d? | finish no earlier than 2011-03-23 | S4 | 2080h | 2080h | OPT_IMS_PSS_MBMS_US | PCG-24 | Ericsson | markus.kampmann@ericsson.com | Rel-10 | SP-47 | Paolo | OPT_IMS_PSS_MBMS_US |  |  |
| 2132 | 515 | **HTTP-based Streaming and Download Services** | 392d? | 2010-03-25 A | 2011-09-21 A | 100% | 2010-03-25 | 2011-09-21 | 392d? |  | S4; IETF | 10468.8h | 10468.8h | HTTP_SDS | PCG-24 | Qualcomm | Thomas Stockhammer (c_tstock@qualcomm.com) | Rel-10 | SP-47 | Paolo | HTTP_SDS |  |  |
| 2133 | 515.1 | HTTP-based Streaming and Download Services in 3GPP | 315d? | 2010-03-25 A | 2011-06-08 A | 100% | 2010-03-25 | 2011-06-08 | 315d? | finish no earlier than 2011-05-26 | S4 | 2520h | 2520h | HTTP_SDS | PCG-24 | Qualcomm | Thomas Stockhammer (c_tstock@qualcomm.com) | Rel-10 | SP-47 | Paolo |  |  |  |
| 2134 | 515.2 | (IETF) HTTP-based Streaming and Download Services in 3GPP | 211.6d? | 2010-03-25 A | 2011-09-21 A | 100% | 2010-03-25 | 2011-09-21 | 211.6d? | start no earlier than 2010-03-25 | S4-IETF | 1676.8h | 1676.8h | HTTP_SDS | PCG-27 |  |  | Rel-10 | CP-52 | Paolo |  |  |  |
| 2135 | 516 | PSS and MBMS enhancements | 205d? | 2010-06-10 A | 2011-03-23 A | 100% | 2010-06-10 | 2011-03-23 | 205d? | finish no earlier than 2011-03-23 | S4 | 1640h | 1640h | MBS_Enh | PCG-25 | Ericsson | Markus.Kampmann@ericsson.com | Rel-10 | SP-48 | Paolo | MBS_Enh |  |  |
| 2136 | 517 | Enhancements and Addition of Audio Tests to 26.131 and 26.132 | 260d? | 2010-06-10 A | 2011-06-08 A | 100% | 2010-06-10 | 2011-06-08 | 260d? | finish no earlier than 2011-06-08 | S4 | 2080h | 2080h | EAAT | PCG-25 | Vodafone | ramin.afchar@vodafone.com | Rel-10 | SP-48 | Paolo | EAAT |  |  |
| 2137 | 518 | Video Coding Enhancements in MTSI | 3d? | 2011-03-21 A | 2011-03-23 A | 100% | 2011-03-21 | 2011-03-23 | 3d? | start no earlier than 2011-03-21 | S4 | 24h | 24h | VCEM | PCG-26 | Ericsson | frederic.gabin@ericsson.com | Rel-10 | SP-51 | Paolo | VCEM |  |  |
| 2138 | 519 | **Rel-10 Operations, Administration, Maintenance and Provisioning (OAM&P)** | 467d? | 2009-12-10 A | 2011-09-21 A | 100% | 2009-12-10 | 2011-09-21 | 467d? |  | S5; C4 | 54144h | 54144h | OAM10 | PCG-24 |  |  | Rel-10 | SP-46 | Mirko | OAM10 |  |  |
| 2139 | 519.1 | **Rel-10 Network Infrastructure Management** | 467d? | 2009-12-10 A | 2011-09-21 A | 100% | 2009-12-10 | 2011-09-21 | 467d? |  | S5 | 14592h | 14592h | OAM10-NIM | PCG-24 |  |  | Rel-10 | SP-46 | Mirko | OAM10-NIM |  |  |
| 2140 | 519.1.1 | Common RAT Network Resource Model (NRM) | 390d? | 2009-12-10 A | 2011-06-08 A | 100% | 2009-12-10 | 2011-06-08 | 390d? | finish no earlier than 2011-06-08 | S5 | 3120h | 3120h | RAT_NRM_common | PCG-24 | Ericsson | robert.petersen@ericsson.com | Rel-10 | SP-46 | Mirko | RAT_NRM_common |  |  |
| 2141 | 519.1.2 | IRP Solution Set specification organisation improvements | 260d? | 2010-03-25 A | 2011-03-23 A | 100% | 2010-03-25 | 2011-03-23 | 260d? | finish no earlier than 2011-03-23 | S5 | 2080h | 2080h | OAM-IRP-SS | PCG-24 | Nokia Siemens Networks, Huawei | Jörg Schmidt (J.Schmidt@nsn.com), Lan Zou (zlan@huawei.com) | Rel-10 | SP-47 | Mirko | OAM-IRP-SS |  |  |
| 2142 | 519.1.3 | Deleted - Service Oriented Architecture (SOA) for IRP continuation from Rel-9 | 260d? | 2010-03-25 A | 2011-03-23 A | 100% | 2010-03-25 | 2011-03-23 | 260d? | finish no earlier than 2011-06-08 | S5 | 2080h | 2080h | OAM-SOA-IRP | PCG-24 | Nokia Siemens Networks, Ericsson | Jörg Schmidt (J.Schmidt@NSN.com), edwin.tse@ericsson.com | Rel-10 | SP-47 | Mirko | OAM-SOA-IRP | PCG-26 | SP-51 |
| 2143 | 519.1.4 | IRP Overview, Profiles & Usage Guide | 260d? | 2010-06-10 A | 2011-06-08 A | 100% | 2010-06-10 | 2011-06-08 | 260d? | finish no earlier than 2011-06-08 | S5 | 2080h | 2080h | OAM-NIM-IRP_OPU | PCG-25 | Nokia Siemens Networks | Jörg Schmidt (J.Schmidt@NSN.com) | Rel-10 | SP-48 | Mirko | OAM-NIM-IRP_OPU |  |  |
| 2144 | 519.1.5 | Alarm Correlation and Root Cause Analysis | 133d? | 2011-03-23 A | 2011-09-21 A | 100% | 2011-03-23 | 2011-09-21 | 133d? | finish no earlier than 2011-09-21 | S5 | 1048h | 1048h | OAM-AC-RCA | PCG-26 | Ericsson | brendan.hassett@ericsson.com | Rel-10 | SP-51 | Mirko | OAM-AC-RCA |  |  |
| 2145 | 519.1.6 | Inventory Management Network Resource Model enhancements | 56d? | 2011-03-23 A | 2011-06-08 A | 100% | 2011-03-23 | 2011-06-08 | 56d? | start no earlier than 2011-03-23 | S5 | 448h | 448h | OAM-IM-NMR | PCG-26 | Nokia Siemens Networks | olaf.pollakowski@nsn.com | Rel-10 | SP-51 | Mirko | OAM-IM-NMR |  |  |

Notes:
- 2122: SP#52 completed / Impacted TSs and TRs: 33.106 (LI requirements), 33.107 (LI architecture and functions), 33.108 (Handover interface for LI)
- 2123: SP#52 completed / Impacted TSs and TRs: 33.106, 33.107, 33.108
- 2124: SP#52 completed / Impacted TSs and TRs: 33.106, 33.107, 33.108
- 2125: SP#52 completed / Impacted TSs and TRs: 33.106, 33.107, 33.108
- 2126: SP#51 completed / Impacted TSs and TRs: 33.106, 33.107, 33.108
- 2127: SP#51 completed / Impacted TSs and TRs: 33.106, 33.107, 33.108
- 2128: SP#51 completed / Impacted TSs and TRs: 33.106, 33.107, 33.108
- 2129: SP#51 completed / Impacted TSs and TRs: 33.106, 33.107, 33.108
- 2130: SP#51 completed / Impacted TSs and TRs: 33.106, 33.107, 33.108
- 2131: SP#51 completed. Work to enhance UID_430046 Rel-9 IMS_PSS_MBMS_US_EXT / Impacted TSs and TRs: 26.237
- 2132: SP#52 completed. Work to enhance UID_430038 Rel-9 PSS and MBMS extensions
- 2133: SP#52 completed / Impacted TSs and TRs: 26.234, 26.244, 26.346, new TS 26.247
- 2134: SP#53/IETF#81: Draft not included in 3GPP documentation. Dec.14: IETF RFC added / Impacted TSs and TRs: RFC 6381 (was draft-gellens-mime-bucket-bis)
- 2135: SP#51 completed. Linked to Rel-9 Feature UID_430038 PSS and MBMS extensions (PMA-MBS_Ext). / Impacted TSs and TRs: 26.234, 26.346
- 2136: SP#52 completed. Reduce fragmentation in acoustic testing (3GPP SA4, ETSI STQ, GCF CAG, CTIA) & Review existing acoustic tests to determine need for new spec / Impacted TSs and TRs: 26.131, 26.132
- 2137: SP#51 completed. Linked to Rel-7 UID_7040 Multimedia Telephony Service for IMS - Media handling and interaction in MTSI (MTSI-MHI) / Impacted TSs and TRs: 26.114
- 2138: OAM10 is an umbrella Feature also for OAM&P related TEI10 type of changes that are not part of any other dedicated feature/WI / Impacted TSs and TRs: TR 30.820
- 2139: umbrella BB
- 2140: SP#52 completed. Share equipment btw several RATs (RET,TMA,repeaters) to reduce costs. With existing modelling is difficult to see that several cells are affected when an antenna tilt is changed etc / Impacted TSs and TRs: 32.616, 32.642, 32.646, 32.652, 32.656, 32.762, 32.766 new (32.791, 32.792, 32.796)
- 2141: SP#51 completed / Impacted TSs and TRs: 32.153, new (32.111-6,32.126,32.176,32.306,32.316,32.326,32.336,32.346,32.356,32.366,32.376,32.386,32.396,32.416,32.446,32.506/26/36,32.606,32.616,32.626,32.636,32.646,32.656,32.666,32.676,32.696,32.716,32.726,32.736,32.746,32.756,32.766,32.776,32.786)
- 2142: SP#51 work stopped (Reason: lack of progress). Continuation of Rel-9 UID_440065 SOA for IRP (covering SOA Architecture & SOA-supporting Solution Set) to address SOA conforming Registration & Discovery capabilities / Impacted TSs and TRs: 32.101, 32.150
- 2143: SP#52 completed. Updated WID SP-100777=>SP-110277 / Impacted TSs and TRs: new TS 32.103
- 2144: SP#53 completed. Triggered by Rel-10 TR 32.832 Study on Alarm Correlation and Alarm Root Cause Analysis UID_480045 & TR 32.829 Study on Harmonization of 3GPP Alarm IRP and TMF Interface Program Fault Management UID_460038 / Impacted TSs and TRs: 32.111-1, 32.111-2, 32.111-6
- 2145: SP#52 completed. Inventory NRM specified in Rel-6 is mainly hardware related. Rel-10 TR 32.828 recommends extending the scope of inventory NRM. Additionally, NGMN Top OPE Recs, v1.0 sets inventory enhancements as one of top 10 priority items / Impacted TSs and TRs: 32.690, 32.691, 32.692, 32.696

| ID | WBS | Task | Duration | Start | Finish | Complete | Baseline start | Baseline finish | Baseline duration | Constraint | Resources | Work | Actual work | Acronym | PCG approved | Release | TSG approved | MCC resp | Special Focus Doc | Acronym_3GU_Export | WI rapporteur name |
| --- | --- | --- | --- | --- | --- | --- | --- | --- | --- | --- | --- | --- | --- | --- | --- | --- | --- | --- | --- | --- | --- |
| 2146 | 519.2 | **Rel-10 Self-Organizing Networks (SON) - OAM aspects** | 390d? | 2009-12-10 A | 2011-06-08 A | 100% | 2009-12-10 | 2011-06-08 | 390d? |  | S5 | 11000h | 11000h | OAM10-SON | PCG-24 | Rel-10 | SP-46 | Mirko | SON | OAM10-SON |  |
| 2147 | 519.2.1 | SON Self-optimization management continuation | 390d? | 2009-12-10 A | 2011-06-08 A | 100% | 2009-12-10 | 2011-06-08 | 390d? | finish no earlier than 2011-03-23 | S5 | 3120h | 3120h | LTE-SON-OAM_SO | PCG-24 | Rel-10 | SP-46 | Mirko | SON | LTE-SON-OAM_SO | Huawei |
| 2148 | 519.2.2 | SON Self-healing management | 335d? | 2009-12-10 A | 2011-03-23 A | 100% | 2009-12-10 | 2011-03-23 | 335d? | finish no earlier than 2011-03-23 | S5 | 2680h | 2680h | LTE-SON-OAM_SH | PCG-24 | Rel-10 | SP-46 | Mirko | SON | LTE-SON-OAM_SH | ZTE |
| 2149 | 519.2.3 | OAM aspects of Energy Saving in Radio Networks | 260d? | 2010-03-25 A | 2011-03-23 A | 100% | 2010-03-25 | 2011-03-23 | 260d? | finish no earlier than 2011-03-23 | S5 | 2080h | 2080h | OAM-ES | PCG-24 | Rel-10 | SP-47 | Mirko | SON | OAM-ES | Nokia Siemens Networks |
| 2150 | 519.3 | Rel-10 Subscription Management (SuM) evolution | 260d? | 2010-03-25 A | 2011-03-23 A | 100% | 2010-03-25 | 2011-03-23 | 260d? | finish no earlier than 2011-03-23 | S5 | 2080h | 2080h | OAM10-SuM | PCG-24 | Rel-10 | SP-47 | Mirko |  | OAM10-SuM | Ericsson |
| 2151 | 519.4 | **Rel-10 Performance Management** | 315d? | 2010-03-25 A | 2011-06-08 A | 100% | 2010-03-25 | 2011-06-08 | 315d? |  | S5; C4 | 19000h | 19000h |  | PCG-24 | Rel-10 | SP-47 | Mirko |  |  |  |
| 2152 | 519.4.1 | Key Performance Indicators (KPIs) for IMS | 260d? | 2010-03-25 A | 2011-03-23 A | 100% | 2010-03-25 | 2011-03-23 | 260d? | finish no earlier than 2011-03-23 | S5 | 2080h | 2080h | OAM-PM-KPI_IMS | PCG-24 | Rel-10 | SP-47 | Mirko |  | OAM-PM-KPI_IMS | China Mobile |
| 2153 | 519.4.2 | Key Performance Indicators (KPIs) for EPC | 260d? | 2010-03-25 A | 2011-03-23 A | 100% | 2010-03-25 | 2011-03-23 | 260d? | finish no earlier than 2011-03-23 | S5 | 2080h | 2080h | OAM-PM-KPI_EPC | PCG-24 | Rel-10 | SP-47 | Mirko |  | OAM-PM-KPI_EPC | China Mobile |
| 2154 | 519.4.3 | **Management of UE based network performance measurements** | 315d? | 2010-03-25 A | 2011-06-08 A | 100% | 2010-03-25 | 2011-06-08 | 315d? |  | S5; C4 | 7720h | 7720h | OAM-PM-UE | PCG-24 | Rel-10 | SP-47 | Mirko |  | OAM-PM-UE | Huawei, Nokia Siemens Networks, Ericsson |
| 2155 | 519.4.3.1 | SA5 aspects of Management of UE based network performance measurements | 315d? | 2010-03-25 A | 2011-06-08 A | 100% | 2010-03-25 | 2011-06-08 | 315d? | finish no earlier than 2011-06-08 | S5 | 2520h | 2520h |  | PCG-24 | Rel-10 | SP-47 | Mirko |  |  | Huawei, Nokia Siemens Networks, Ericsson |
| 2156 | 519.4.3.2 | CN aspects of Management of UE based network performance measurements | 20d? | 2011-02-21 A | 2011-03-18 A | 100% | 2011-02-21 | 2011-03-18 | 20d? | start no earlier than 2011-02-21 | C4 | 160h | 160h |  | PCG-26 | Rel-10 | CP-51 | Kimmo |  |  | Nokia Siemens Networks |
| 2157 | 519.4.4 | 3G HNB and LTE HeNB Subsystem performance measurements | 260d? | 2010-03-25 A | 2011-03-23 A | 100% | 2010-03-25 | 2011-03-23 | 260d? | finish no earlier than 2011-03-23 | S5 | 2080h | 2080h | OAM-PM-HeNS | PCG-24 | Rel-10 | SP-47 | Mirko | HNB | OAM-PM-HeNS | China Mobile |
| 2158 | 520 | **Rel-10 Charging Management small Enhancements** | 470d? | 2009-06-04 A | 2011-03-23 A | 100% | 2009-06-04 | 2011-03-23 | 470d? |  | S5 | 7520h | 7520h | CH10 | PCG-24 | Rel-10 | SP-47 | Mirko | WLAN | CH10 |  |
| 2159 | 520.1 | IWLAN mobility charging | 470d? | 2009-06-04 A | 2011-03-23 A | 100% | 2009-06-04 | 2011-03-23 | 470d? | finish no earlier than 2011-03-23 | S5 | 3760h | 3760h | eIWLAN_Mob | PCG-23 | Rel-10 | SP-44 | Mirko | WLAN | eIWLAN_Mob | Orange |
| 2160 | 521 | **Advice of Charge (AoC) service support enhancements** | 312d? | 2010-03-25 A | 2011-06-03 A | 100% | 2010-03-25 | 2011-06-03 | 312d? |  | S5; C1 | 8560h | 8560h | eAoC | PCG-24 | Rel-10 | SP-47 | Mirko |  | eAoC | Deutsche Telekom |
| 2161 | 521.1 | SA5 part - AoC enhancements | 260d? | 2010-03-25 A | 2011-03-23 A | 100% | 2010-03-25 | 2011-03-23 | 260d? | finish no earlier than 2011-03-23 | S5 | 2080h | 2080h | eAoC | PCG-24 | Rel-10 | SP-47 | Mirko |  |  | Deutsche Telekom |
| 2162 | 521.2 | CT1 part - AoC enhancements (Stage 3) | 186d? | 2010-09-17 A | 2011-06-03 A | 100% | 2010-09-17 | 2011-06-03 | 186d? | finish no earlier than 2011-06-03 | C1 | 1488h | 1488h | eAoC | PCG-25 | Rel-10 | CP-49 | Frederic |  |  | Deutsche Telekom |
| 2163 | 522 | IMS Stage 3 IETF Protocol Alignment - phase 4 | 261d? | 2010-03-19 A | 2011-03-18 A | 100% | 2010-03-19 | 2011-03-18 | 261d? | finish no earlier than 2011-03-18 | C1 | 2088h | 2088h | IMSProtoc4 | PCG-24 | Rel-10 | CP-47 | Frederic |  | IMSProtoc4 | Alcatel-Lucent |
| 2164 | 523 | Enhanced User Data Convergence (UDC) Model | 206d? | 2010-06-04 A | 2011-03-18 A | 100% | 2010-06-04 | 2011-03-18 | 206d? | finish no earlier than 2011-03-18 | C4 | 1648h | 1648h | eUDC | PCG-25 | Rel-10 | CP-48 | Kimmo |  | eUDC | China Mobile |
| 2165 | 524 | **Further improvements of II-NNI Stage 3 based on operational feedback and evolution of other specifications** | 724d? | 2010-06-04 A | 2013-03-01 A | 100% | 2010-06-04 | 2013-03-01 | 724d? |  | C3 | 10625.9h | 10625.9h | II-NNI2 | PCG-25 | Rel-10 | CP-48 | Adrian |  | II-NNI2 | Orange |
| 2166 | 524.1 | Further improvements of II-NNI Stage 3 | 206d? | 2010-06-04 A | 2011-03-18 A | 100% | 2010-06-04 | 2011-03-18 | 206d? | start no earlier than 2010-06-04 | C3 | 1648h | 1648h | II-NNI2 | PCG-25 | Rel-10 | CP-48 | Adrian |  |  | Orange |
| 2167 | 524.2 | (IETF) Further improvements of II-NNI Stage 3 (RFC 6794) | 230d? | 2012-04-20 A | 2013-03-01 A | 100% | 2012-04-20 | 2013-03-01 | 230d? | finish no earlier than 2013-03-01 | C3-IETF | 1832h | 1832h | II-NNI2 | PCG-29 | Rel-10 | CP-56 | Adrian |  |  | Lionel Morand |
| 2168 | 524.3 | (IETF) Further improvements of II-NNI Stage 3 (RFC 6809) | 170d? | 2012-04-20 A | 2012-12-07 A | 100% | 2012-04-20 | 2012-12-07 | 170d? | finish no earlier than 2012-12-04 | C3-IETF | 1353.89h | 1353.89h | II-NNI2 | PCG-29 | Rel-10 | CP-56 | Adrian |  |  | christer.holmberg@ericsson.com |
| 2169 | 525 | AT Commands for IMS-configuration | 206d? | 2010-06-04 A | 2011-03-18 A | 100% | 2010-06-04 | 2011-03-18 | 206d? |  | C1 | 1648h | 1648h | AT_IMS | PCG-25 | Rel-10 | CP-48 | Frederic |  | AT_IMS | Ericsson |
| 2170 | 526 | AT Commands for USIM Application Toolkit (USAT) | 131d? | 2010-09-17 A | 2011-03-18 A | 100% | 2010-09-17 | 2011-03-18 | 131d? |  | C1 | 52.4h | 52.4h | AT_UICC | PCG-25 | Rel-10 | CP-49 | Frederic |  | AT_UICC | ST-Ericsson |
| 2171 | 527 | Communication Control for IMS by USIM (Stage 3) | 131d? | 2010-09-17 A | 2011-03-18 A | 100% | 2010-09-17 | 2011-03-18 | 131d? | start no earlier than 2010-09-17 | C6 | 1048h | 1048h | CC_IMS_USIM | PCG-25 | Rel-10 | CP-49 | Xavier |  | CC_IMS_USIM | Gemalto |
| 2172 | 528 | Dynamic view of SIP message for Inter-IMS Network to Network Interface (II-NNI) (Stage 3) | 126d? | 2010-12-10 A | 2011-06-03 A | 100% | 2010-12-10 | 2011-06-03 | 126d? | finish no earlier than 2011-06-03 | C3 | 1008h | 1008h | NNI_DV | PCG-26 | Rel-10 | CP-50 | Adrian |  | NNI_DV | NTT |
| 2173 | 529 | Introduction of Smart Card Web Server launch functionality | 71d? | 2010-12-10 A | 2011-03-18 A | 100% | 2010-12-10 | 2011-03-18 | 71d? | finish no earlier than 2011-03-18 | C6 | 568h | 568h | SCWS_L | PCG-26 | Rel-10 | CP-50 | Xavier |  | SCWS_L | Telecom Italia |
| 2174 | 530 | USAT using AT Commands | 71d? | 2010-12-10 A | 2011-03-18 A | 100% | 2010-12-10 | 2011-03-18 | 71d? | finish no earlier than 2011-03-18 | C6 | 568h | 568h | USAT_AT | PCG-26 | Rel-10 | CP-50 | Xavier |  | USAT_AT | Giesecke & Devrient |

Notes:
- 2146: umbrella BB
- 2147: SP#52 completed. Cont'd Rel-9 SON self-optimization management UID_390007 / Impacted TSs and TRs: 32.425, 32.521, 32.522, 32.526, 32.762, 32.766 / WI rapporteur e-mail: Lan Zou (zlan@huawei.com)
- 2148: SP#51 completed. WID updated SP-100776=>SP-110150. Work moved to Rel-10 after split of the Rel-9 UID_390007 SON self-optimization (removed Self-Healing handling) / Impacted TSs and TRs: 32.522, 32.526, 32.762, 32.766, new TS 32.541 / WI rapporteur e-mail: zhu.weihong@zte.com.cn
- 2149: SP#51 completed. WID updated SP-100226=>SP-110128. Triggered by Rel-10 TR 32.826 Study on Telecommunication Management; Energy Savings Management (FS_OAM_ESM) UID_430044 / Impacted TSs and TRs: 32.425, 32.522, 32.526, 32.626, 32.762, 32.766, new TS 32.551 / WI rapporteur e-mail: clemens.suerbaum@nsn.com
- 2150: SP#51 completed / Impacted TSs and TRs: 32.172, 32.175, 32.176 / WI rapporteur e-mail: leo.yang@ericsson.com
- 2151: umbrella BB
- 2152: SP#51 completed / Impacted TSs and TRs: new 32.454 / WI rapporteur e-mail: Li Jian (lijian@chinamobile.com), Liang Shuangchun (liangshuangchun@cmdi.chinamobile.com)
- 2153: SP#51 completed / Impacted TSs and TRs: new 32.455 / WI rapporteur e-mail: Li Jian (lijian@chinamobile.com), Liang Shuangchun (liangshuangchun@cmdi.chinamobile.com)
- 2154: SP#52 completed. Stage 2/3. Linked to UID_460003 Minimization of drive tests for E-UTRAN and UTRAN (MDT_UMTSLTE) / WI rapporteur e-mail: Zou Lan (zlan@huawei.com), gyula.bodog@nsn.com, ulf.hubinette@ericsson.com
- 2155: SP#52 completed / Impacted TSs and TRs: 32.421, 32.422, 32.423, 32.441, 32.442, 32.446 / WI rapporteur e-mail: Zou Lan (zlan@huawei.com), gyula.bodog@nsn.com, ulf.hubinette@ericsson.com
- 2156: CP#51 completed under the SA5 WI code / Impacted TSs and TRs: 23.008 (CR#0330), 29.002 (CR#1007), 29.230 (CR#0207), 29.272 (CR#0329) / WI rapporteur e-mail: ulrich.wiehe@nsn.com
- 2157: SP#51 completed / Impacted TSs and TRs: 32.582, 32.592, new (32.452, 32.453) / WI rapporteur e-mail: Chen Gang (chengang@chinamobile.com)
- 2158: CH10 is an umbrella Feature also for OAM&P related TEI10 type of changes that are not part of any other dedicated feature/WI / Impacted TSs and TRs: TR 30.820
- 2159: SP#51 completed. RAT differentiation for charging. Completes Rel-8 Feature IWLAN_Mob UID_370049 Mobility between 3GPP-WLAN Interworking and 3GPP Systems. Cooperation with CT1,CT3 on affected protocols / Impacted TSs and TRs: 32.240, 32.252, 32.298, 32.299 / WI rapporteur e-mail: Jean-Luc Garcia (jl.garcia@orange-ftgroup.com)
- 2160: CP#52 completed. SP#51 completed SA5. Continuation of Rel-8 BB UID_80042: Advice of Charge (AoC) support in IMS Charging (IMSTSS). Stage 2/3 work / WI rapporteur e-mail: matthias.seibel@telekom.de
- 2161: SP#51 completed. SA1 Stage 1 in 22.115 / Impacted TSs and TRs: 32.275, 32.280, 32.298, 32.299 / WI rapporteur e-mail: matthias.seibel@telekom.de
- 2162: CP#52 completed. SA1 Stage 1 in 22.115, 22.173, 22.024. Add mobile-specific CAI format and volume charging elements. Extensions to existing AoC XML / Impacted TSs and TRs: 24.647 / WI rapporteur e-mail: reinhard.lauster@t-mobile.at
- 2163: CP#51 completed. Ensure protocol alignment between 3GPP Stage 3 IMS work and IETF. Review capabilities provided in SIP by IETF and document whether these capabilities are supported in the IM CN Subsystem or not / Impacted TSs and TRs: 23.218, 24.229, 24.930 / WI rapporteur e-mail: keith.drage@alcatel-lucent.com
- 2164: CP#51 completed. Specify CRUD (Create/Read/Update/Delete) operations based on SOAP protocol, which may be used by the applications having no high real-time requirement to the data access operations / Impacted TSs and TRs: 29.335 / WI rapporteur e-mail: Lan Sizhong (lansizhong@chinamobile.com)
- 2165: Improvements of Rel-9 Feature UID_440027 Operational description of the Inter-IMS Network to Network Interface (II-NNI) / WI rapporteur e-mail: beata.dobrowolska@orange-ftgroup.com
- 2166: CP#51 completed / Impacted TSs and TRs: 29.165 / WI rapporteur e-mail: beata.dobrowolska@orange-ftgroup.com
- 2167: CP#59 completed AUTH 48 RFC-to-be-6794 / Impacted TSs and TRs: RFC 6794 (was draft-ietf-sip-session-policy-framework) / WI rapporteur e-mail: Lionel Morand
- 2168: CP#58 completed / Impacted TSs and TRs: RFC 6809 (was draft-ietf-sipcore-proxy-feature) / WI rapporteur e-mail: Christer Holmberg
- 2169: CP#51 completed. Specify 1) IMS-related AT-commands to configure MT and 2) IMS-related unsolicited response codes from MT to present to end-user / Impacted TSs and TRs: 27.007 / WI rapporteur e-mail: atle.monrad@ericsson.com
- 2170: CP#51 completed / Impacted TSs and TRs: 27.007 / WI rapporteur e-mail: magnus.mk.karlsson@stericsson.com
- 2171: CP#51 completed. Stage 1 in TS 22.038 USAT service description. Linked to CT6's UID_1273 Rel-5 BB Provisioning of IP-based multimedia services (24.229, 31.103) and UID_390021 Rel-8 BB CT6 aspects of SAE (31.102, 31.111) / Impacted TSs and TRs: 31.102, 31.103, 31.111 / WI rapporteur e-mail: Denis.Lheriteau@gemalto.com
- 2172: CP#52 completed. Linked to CT3 Rel-10 Feature UID_480014 Further improvements of II-NNI Stage 3 based on operational feedback and evolution of other specifications (II-NNI2) / Impacted TSs and TRs: 29.165 / WI rapporteur e-mail: arai.kenjiro@lab.ntt.co.jp
- 2173: CP#51 completed. Define a solution which allows enabling to launch Smart Card Web Server services in an easy and simple manner / Impacted TSs and TRs: 31.102 / WI rapporteur e-mail: davide.pratone@telecomitalia.it
- 2174: CP#51 completed. Stage 3 based on SA1 22.038CR#37r1 (Make USAT proactive capability reqs applicable to ME as a whole without regard to any particular configuration; e.g. a modem connected to an external display) / Impacted TSs and TRs: Stage 3 31.102, 31.111 / WI rapporteur e-mail: enric.fort@gi-de.com

| ID | WBS | Task | Type | Duration | Start | Finish | Complete | Baseline start | Baseline finish | Baseline duration | Constraint | Resources | Work | Actual work | Acronym | PCG approved | WI rapporteur name | WI rapporteur e-mail | Release | TSG approved | MCC resp | Acronym_3GU_Export | Status Report | Special Focus Doc | PCG stopped | TSG stopped |
| --- | --- | --- | --- | --- | --- | --- | --- | --- | --- | --- | --- | --- | --- | --- | --- | --- | --- | --- | --- | --- | --- | --- | --- | --- | --- | --- |
| 2175 | 531 | **Single Radio Voice Call Continuity (SRVCC) enhancements (Stage 3)** |  | 528d? | 2010-12-10 A | 2012-12-07 A | 100% | 2010-12-10 | 2012-12-07 | 528d? |  | C1; C4; IETF | 17295.4h | 17295.4h | eSRVCC | PCG-26 | China Mobile | Jiang Y (jiangyi@chinamobile.com) | Rel-10 | CP-50 | Frederic | eSRVCC |  |  |  |  |
| 2176 | 531.1 | CT1 part of Stage 3 for SRVCC enhancements |  | 71d? | 2010-12-10 A | 2011-03-18 A | 100% | 2010-12-10 | 2011-03-18 | 71d? | finish no earlier than 2011-03-18 | C1 | 568h | 568h | eSRVCC | PCG-26 | China Mobile | Jiang Y (jiangyi@chinamobile.com) | Rel-10 | CP-50 | Frederic |  |  |  |  |  |
| 2177 | 531.2 | CT4 part of Stage 3 for SRVCC enhancements |  | 71d? | 2010-12-10 A | 2011-03-18 A | 100% | 2010-12-10 | 2011-03-18 | 71d? | finish no earlier than 2011-03-18 | C4 | 568h | 568h | eSRVCC | PCG-26 | China Mobile | Jiang Y (jiangyi@chinamobile.com) | Rel-10 | CP-50 | Kimmo |  |  |  |  |  |
| 2178 | 531.3 | (IETF) CT1 part of Stage 3 for SRVCC enhancements (RFC 6809) |  | 436.8d? | 2010-12-10 A | 2012-12-07 A | 100% | 2010-12-10 | 2012-12-07 | 436.8d? | finish no earlier than 2013-03-01 | C1-IETF | 3487.38h | 3487.38h | eSRVCC | PCG-27 | christer.holmberg@ericsson.com | christer.holmberg@ericsson.com | Rel-10 | CP-52 | Frederic |  |  |  |  |  |
| 2179 | 532 | **Single Radio Voice Call Continuity (SRVCC) in alerting phase (Stage 3)** |  | 589d? | 2010-12-10 A | 2013-03-01 A | 100% | 2010-12-10 | 2013-03-01 | 589d? |  | C1; R5 | 11440h | 11440h | aSRVCC | PCG-26 | ZTE | li.shitao@zte.com.cn | Rel-10 | CP-50 | Frederic | aSRVCC |  |  |  |  |
| 2180 | 532.1 | CT aspects of Single Radio Voice Call Continuity (SRVCC) in alerting phase (Stage 3) |  | 126d? | 2010-12-10 A | 2011-06-03 A | 100% | 2010-12-10 | 2011-06-03 | 126d? | finish no earlier than 2011-06-03 | C1 | 1008h | 1008h | aSRVCC | PCG-26 | ZTE | li.shitao@zte.com.cn | Rel-10 | CP-50 | Frederic |  |  |  |  |  |
| 2181 | 532.2 | Conformance test aspects SRVCC in alerting phase |  | 126d? | 2012-09-11 A | 2013-03-01 A | 100% | 2012-09-11 | 2013-03-01 | 126d? | finish no earlier than 2013-03-01 | R5 | 1008h | 1008h | aSRVCC-UEConTest | PCG-29 | NTT DoCoMo | Takao.Shimizu.rp@nttdocomo.com | Rel-10 | RP-57 | Ingbert | aSRVCC-UEConTest | RP-130042 |  |  |  |
| 2182 | 533 | **PCRF failure and restoration** |  | 71d? | 2010-12-10 A | 2011-03-18 A | 100% | 2010-12-10 | 2011-03-18 | 71d? |  | C4; C3 | 2130h | 2130h | PCRF_FR | PCG-26 | NEC | Toshiyuki Tamura (tamurato@aj.jp.nec.com) | Rel-10 | CP-50 | Kimmo | PCRF_FR |  |  |  |  |
| 2183 | 533.1 | CT4 part of PCRF failure and restoration |  | 71d? | 2010-12-10 A | 2011-03-18 A | 100% | 2010-12-10 | 2011-03-18 | 71d? | finish no earlier than 2011-03-18 | C4 | 568h | 568h | PCRF_FR | PCG-26 | NEC | Toshiyuki Tamura (tamurato@aj.jp.nec.com) | Rel-10 | CP-50 | Kimmo |  |  |  |  |  |
| 2184 | 533.2 | CT3 part of PCRF failure and restoration |  | 53.25d? | 2010-12-10 A | 2011-03-18 A | 100% | 2010-12-10 | 2011-03-18 | 53.25d? | start no earlier than 2010-12-10 | C3 | 426h | 426h | PCRF_FR | PCG-26 | NEC | Toshiyuki Tamura (tamurato@aj.jp.nec.com) | Rel-10 | CP-50 | Adrian |  |  |  |  |  |
| 2185 | 534 | Formalization of WLAN Files | milestone | 0d? | 2011-02-23 A | 2011-03-18 A | 100% | 2011-02-23 | 2011-03-18 | 0d? | start no earlier than 2011-03-16 | C1 |  |  | FoWF | PCG-26 | Deutsche Telekom | dieter.jacobsohn@telekom.de | Rel-10 | CP-51 | Frederic | FoWF |  | WLAN |  |  |
| 2186 | 535 | CS and IMS Interworking for CAT service - Early Session model |  | 58d? | 2011-03-16 A | 2011-06-03 A | 100% | 2011-03-16 | 2011-06-03 | 58d? |  | C3 | 464h | 464h | CIIC_ES | PCG-26 | ZTE | li.shitao@zte.com.cn | Rel-10 | CP-51 | Adrian | CIIC_ES |  |  |  |  |
| 2187 | 536 | EPC Node Restoration without Idle mode Signalling Reduction (ISR) activated |  | 3d? | 2011-03-16 A | 2011-03-18 A | 100% | 2011-03-16 | 2011-03-18 | 3d? | finish no earlier than 2011-03-18 | C4 | 24h | 24h | EPC_NR | PCG-26 | Alcatel-Lucent | bruno.landais@alcatel-lucent.com | Rel-10 | CP-51 | Kimmo | EPC_NR |  |  |  |  |
| 2188 | 537 | EPC Node Restoration with Idle mode Signalling Reduction (ISR) activated |  | 58d? | 2011-03-16 A | 2011-06-03 A | 100% | 2011-03-16 | 2011-06-03 | 58d? | finish no earlier than 2011-03-18 | C4 | 464h | 464h | EPC_NR_ISR | PCG-26 | NEC | Toshiyuki Tamura (tamurato@aj.jp.nec.com) | Rel-10 | CP-51 | Kimmo | EPC_NR_ISR |  |  |  |  |
| 2189 | 538 | Mobile Terminating Roaming Forwarding with pre-paging |  | 58d? | 2011-03-16 A | 2011-06-03 A | 100% | 2011-03-16 | 2011-06-03 | 58d? | finish no earlier than 2011-03-18 | C4 | 464h | 464h | MTRF | PCG-26 | Ericsson | philip.hodges@ericsson.com | Rel-10 | CP-51 | Kimmo | MTRF |  |  |  |  |
| 2190 | 539 | **UICC access to IMS Specification** |  | 58d? | 2011-03-16 A | 2011-06-03 A | 100% | 2011-03-16 | 2011-06-03 | 58d? |  | C6; C1 | 1416h | 1416h | IMS-UICC-S | PCG-26 | Gemalto | Denis.Lheriteau@gemalto.com | Rel-10 | CP-51 | Xavier | IMS-UICC-S |  |  |  |  |
| 2191 | 539.1 | CT6 part of UICC access to IMS Specification |  | 3d? | 2011-03-16 A | 2011-03-18 A | 100% | 2011-03-16 | 2011-03-18 | 3d? | start no earlier than 2011-03-16 | C6 | 24h | 24h | IMS-UICC-S | PCG-26 | Gemalto | Denis.Lheriteau@gemalto.com | Rel-10 | CP-51 | Xavier |  |  |  |  |  |
| 2192 | 539.2 | CT1 part of UICC access to IMS Specification |  | 58d? | 2011-03-16 A | 2011-06-03 A | 100% | 2011-03-16 | 2011-06-03 | 58d? | start no earlier than 2011-03-16 | C1 | 464h | 464h | IMS-UICC-S | PCG-26 | Gemalto | Denis.Lheriteau@gemalto.com | Rel-10 | CP-51 | Frederic |  |  |  |  |  |
| 2193 | 540 | Deleted - Testing for Terminal support of Rel-10 USIM, ISIM and USAT features |  | 463d? | 2012-03-05 A | 2013-12-03 A | 100% | 2012-03-05 | 2013-12-03 | 463d? | finish no earlier than 2013-06-14 | C6 | 3704h | 3704h | USIM_R10_Test | PCG-28 | Gemalto | Denis.Praca@gemalto.com | Rel-10 | CP-55 | Xavier | USIM_R10_Test |  |  | PCG-32 | CP-62 |
| 2194 | 541 | **CN aspects of Local Call Local Switch** |  | 472d? | 2009-05-29 A | 2011-03-18 A | 100% | 2009-05-29 | 2011-03-18 | 472d? |  | C4 | 13008h | 13008h | LCLS-CN | PCG-23 | Vodafone | David.Hutton@vodafone.com | Rel-10 | CP-44 | Kimmo | LCLS-CN |  |  |  |  |
| 2195 | 541.1 | TR on CN aspects of Local Call Local Switch |  | 341d? | 2009-05-29 A | 2010-09-16 A | 100% | 2009-05-29 | 2010-09-16 | 341d? | finish no earlier than 2010-09-17 | C4 | 2728h | 2728h | LCLS-CN | PCG-23 | Vodafone | David.Hutton@vodafone.com | Rel-10 | CP-44 | Kimmo |  |  |  |  |  |
| 2196 | 541.2 | Stage 2/3 for CN aspects of Local Call Local Switch |  | 131d? | 2010-09-17 A | 2011-03-18 A | 100% | 2010-09-17 | 2011-03-18 | 131d? | finish no earlier than 2011-03-18 | C4 | 1048h | 1048h | LCLS-CN | PCG-25 | Vodafone | David.Hutton@vodafone.com | Rel-10 | CP-49 | Kimmo |  |  |  |  |  |
| 2197 | 541.3 | Deleted - CT3 aspects of Local Call Local Switch |  | 341d? | 2009-05-29 A | 2010-09-16 A | 100% | 2009-05-29 | 2010-09-16 | 341d? | finish no earlier than 2010-09-17 | C3 | 2728h | 2728h | LCLS-CN | PCG-23 | Vodafone | David.Hutton@vodafone.com | Rel-10 | CP-44 | Adrian |  |  |  | PCG-25 | CP-49 |
| 2198 | 541.4 | Deleted - CT1 aspects of Local Call Local Switch |  | 341d? | 2009-05-29 A | 2010-09-16 A | 100% | 2009-05-29 | 2010-09-16 | 341d? | finish no earlier than 2010-09-17 | C1 | 2728h | 2728h | LCLS-CN | PCG-23 | Vodafone | David.Hutton@vodafone.com | Rel-10 | CP-44 | Frederic |  |  |  | PCG-25 | CP-49 |
| 2199 | 542 | Local Call Local Switch | milestone | 0d? | 2007-05-07 A | 2007-05-07 A | 100% | 2007-05-07 | 2011-05-20 | 1055.8d? |  | GP; G2 |  |  | LCLS | PCG-22 | Huawei | wang_zhixi@huawei.com | Rel-10 | GP-41 | Paolo | LCLS |  |  |  |  |

Notes:
- 2175: Triggered by SA2 TR 23.856 Study on Single Radio Voice Call Continuity enhancements (FS_eSRVCC) UID_440049
- 2176: CP#51 completed / Impacted TSs and TRs: 24.229, 24.237
- 2177: CP#51 completed / Impacted TSs and TRs: 23.003, 23.008, 29.002, 29.230, 29.272, 29.305, 29.328, 29.329
- 2178: CP#58 completed / Impacted TSs and TRs: RFC 6809 (was draft-ietf-sipcore-proxy-feature)
- 2179: Builds on Rel-8 UID_390057 (IMS-Cont) TS 23.216 Stage 2. Provide Stage 3 for SRVCC PS-CS transfer of a call in alerting phase. Stage 2 TEI10 in TS 23.237 (6.3.2.1.4c/d, 6.3.2.1.7a/b)
- 2180: CP#52 completed / Impacted TSs and TRs: 24.008, 24.237
- 2181: RP#59 completed / Impacted TSs and TRs: 36.523-1, 36.523-2, 36.523-3, 34.229-1, 34.229-2, 34.229-3
- 2182: CP#51 completed. Triggered by CT3 TR 29.816 Study on Policy and Charging Rules Function (PCRF) failure and restoration (FS_PCRF-FR) UID_450013 / Impacted TSs and TRs: Stage 2/3 work
- 2183: CP#51 completed / Impacted TSs and TRs: Stage 2 23.007, Stage 3 29.230
- 2184: CP#51 completed / Impacted TSs and TRs: Stage 3 29.212, 29.213, 29.214, 29.215
- 2185: CP#51 completed. TS 24.235 for Info+Approval. Define the ME files as specified in 24.234 in OMA Device Management structure / Impacted TSs and TRs: Stage 3: 24.234, New 24.235
- 2186: CP#52 completed. Stage 1 in Rel-8 TS 22.182 Customized Alerting Tones (CAT) service. Stage 3 TS 24.182 defines 3 impl models: Gateway, Forking, Early Session. Specify missing CAT service interworking procedures btw CS & IMS networks / Impacted TSs and TRs: Stage 3 29.163, 29.235, 29.292
- 2187: CP#51 completed. Triggered by DRAFT TR 23.857 Study on EPC Nodes Restoration (FS_EPC_NR) UID_490014 / Impacted TSs and TRs: Stage 2/3: 23.007, 29.274
- 2188: CP#52 completed. Triggered by DRAFT TR 23.857 Study on EPC Nodes Restoration (FS_EPC_NR) UID_490014 / Impacted TSs and TRs: Stage 2/3: 23.007, 29.274
- 2189: CP#52 completed. Provides Stage 2/3 alternative solution to Mobile Terminating Roaming Retry to solve roaming events during paging, in particular to support CSFB. Hence, no new Stage 1 requirements exist / Impacted TSs and TRs: Stage 2/3: 23.012, 23.018, 23.116, 29.002
- 2190: CP#52 completed. Triggered by Rel-10 TR 31.828 Study on UICC access to IMS (FS_IMS-UICC) UID_480017. Specify mechanism in UICC and ME to make use of IMS functionality implemented in ME for case a) an ISIM is present b) no ISIM is present in UICC
- 2191: CP#51 completed / Impacted TSs and TRs: 31.102, 31.103, 31.111
- 2192: CP#52 completed / Impacted TSs and TRs: 24.229
- 2193: CP#62 stopped (at 70% completion 06/13). Testing for New features in Rel-10 specifications for USIM, ISIM applications and USIM Application Toolkit (USAT) in TS 31.102, 31.103, 31.111 / Impacted TSs and TRs: 31.121, 31.124, New TS 31.ABC (Conformance Testing of specific features)
- 2194: CP#51 completed / Impacted TSs and TRs: GERAN Stage 2/3
- 2195: CP#49 completed / Impacted TSs and TRs: new TR 23.889
- 2196: CP#51 completed / Impacted TSs and TRs: 23.003, 23.009, 23.205, 23.231, 29.002, 29.205, 29.232, new TS 23.284
- 2197: CP#49 stopped. Result of study TR 23.889: no CT3 specification impact
- 2198: CP#49 stopped. Result of study TR 23.889: no CT1 specification impact
- 2199: GP#50 completed. GP#41 WID approved / Impacted TSs and TRs: GERAN Stage 3: 48.008, 48.103

| ID | WBS | Task | Duration | Start | Finish | Complete | Baseline start | Baseline finish | Baseline duration | Constraint | Resources | Work | Actual work | Acronym | PCG approved | WI rapporteur name | Release | TSG approved | MCC resp | Acronym_3GU_Export | Status Report | Special Focus Doc |
| --- | --- | --- | --- | --- | --- | --- | --- | --- | --- | --- | --- | --- | --- | --- | --- | --- | --- | --- | --- | --- | --- | --- |
| 2200 | 543 | **Tightened Link Level Performance Requirements for Single Antenna MS** | 659d? | 2010-09-03 A | 2013-03-01 A | 100% | 2010-09-03 | 2013-03-01 | 659d? |  | G1; G2; C1; G3new | 30856h | 30856h | TIGHTER | PCG-25 | Renesas Mobile | Rel-10 | GP-46 | Paolo | TIGHTER |  |  |
| 2201 | 543.1 | CT1 part for TIGHTER | 196d? | 2010-09-03 A | 2011-06-03 A | 100% | 2010-09-03 | 2011-06-03 | 196d? | finish no earlier than 2011-06-03 | C1 | 1568h | 1568h | TIGHTER | PCG-25 | Renesas Mobile | Rel-10 | GP-46 | Frederic |  |  |  |
| 2202 | 543.2 | TIGHTER Performance Requirements | 186d? | 2010-09-03 A | 2011-05-20 A | 100% | 2010-09-03 | 2011-05-20 | 186d? | finish no earlier than 2011-05-20 | G1; G2 | 2976h | 2976h | TIGHTER | PCG-25 | Renesas Mobile | Rel-10 | GP-46 | Paolo |  |  |  |
| 2203 | 543.3 | TIGHTER Testing | 654d? | 2010-09-08 A | 2013-03-01 A | 100% | 2010-09-08 | 2013-03-01 | 654d? | finish no earlier than 2013-03-01 | G3new | 5224h | 5224h | TIGHTER | PCG-25 | Renesas Mobile | Rel-10 | GP-46 | Ingbert |  |  |  |
| 2204 | 544 | **Support of Multi-Operator Core Network by GERAN** | 206d? | 2010-05-21 A | 2011-03-04 A | 100% | 2010-05-21 | 2011-03-04 | 206d? |  | G2; S2; C1 | 8392h | 8392h | MOCN-GERAN | PCG-25 | Alcatel-Lucent | Rel-10 | GP-47 | Gert | MOCN-GERAN |  |  |
| 2205 | 544.1 | Stage 2 for Support of Multi-Operator Core Network by GERAN | 150d? | 2010-05-21 A | 2010-12-16 A | 100% | 2010-05-21 | 2010-12-16 | 150d? | finish no earlier than 2010-12-15 | S2 | 1200h | 1200h | MOCN-GERAN | PCG-25 | Alcatel-Lucent | Rel-10 | GP-47 | Maurice |  |  |  |
| 2206 | 544.2 | CT1 part of Stage 3 for Support of Multi-Operator Core Network by GERAN | 146d? | 2010-05-21 A | 2010-12-10 A | 100% | 2010-05-21 | 2010-12-10 | 146d? | finish no earlier than 2010-12-10 | C1 | 1168h | 1168h | MOCN-GERAN | PCG-25 | Alcatel-Lucent | Rel-10 | GP-47 | Frederic |  |  |  |
| 2207 | 544.3 | GERAN2 part of Stage 3 for Support of Multi-Operator Core Network by GERAN | 135d? | 2010-08-30 A | 2011-03-04 A | 100% | 2010-08-30 | 2011-03-04 | 135d? | finish no earlier than 2011-03-04 | G2 | 1080h | 1080h | MOCN-GERAN | PCG-25 | Alcatel-Lucent | Rel-10 | GP-47 | Gert |  |  |  |
| 2208 | 545 | **Enhancements of Iur-g interface** | 196d? | 2010-09-03 A | 2011-06-03 A | 100% | 2010-09-03 | 2011-06-03 | 196d? |  | G2; R3 | 5752h | 5752h | eIurg | PCG-25 | China Mobile, ZTE | Rel-10 | GP-47 | Gert | eIurg |  |  |
| 2209 | 545.1 | GERAN part for Enhancements of Iur-g interface (Stage 2/3) | 131d? | 2010-09-03 A | 2011-03-04 A | 100% | 2010-09-03 | 2011-03-04 | 131d? | finish no earlier than 2011-03-04 | G2 | 1048h | 1048h | eIurg-GERAN | PCG-25 | China Mobile, ZTE | Rel-10 | GP-47 | Gert | eIurg-GERAN |  |  |
| 2210 | 545.2 | Core part: Enhancements of Iur-g interface (Stage 2/3) | 196d? | 2010-09-03 A | 2011-06-03 A | 100% | 2010-09-03 | 2011-06-03 | 196d? | finish no earlier than 2011-06-03 | R3 | 1568h | 1568h | eIurg-RAN | PCG-25 | ZTE | Rel-10 | RP-49 | Juha | eIurg-RAN | RP-110526 |  |
| 2211 | 546 | 1.28 Mcps TDD Repeater | 599d? | 2007-12-04 A | 2010-03-19 A | 100% | 2007-12-04 | 2010-03-19 | 599d? | finish no earlier than 2010-03-19 | R4 | 4792h | 4792h | RANimp-Repeaters1.28TDD | PCG-21 | RITT | Rel-10 | RP-38 | Issam | RANimp-Repeaters1.28TDD | RP-100039 |  |
| 2212 | 547 | 1.28 Mcps TDD Multi-carrier HSUPA | 321d? | 2009-09-18 A | 2010-12-10 A | 100% | 2009-09-18 | 2010-12-10 | 321d? | finish no earlier than 2010-12-10 | R1; R2; R3; R4 | 10272h | 10272h | TDD_MC_HSUPA | PCG-23 | CATR | Rel-10 | RP-45 | Patrick | TDD_MC_HSUPA | RP-101079 |  |
| 2213 | 548 | **1.28 Mcps TDD Home NodeB RF requirements** | 266d? | 2009-12-04 A | 2010-12-10 A | 100% | 2009-12-04 | 2010-12-10 | 266d? |  | R4 | 5304h | 5304h | HNB_LCRTDD_RF | PCG-24 | TD Tech | Rel-10 | RP-46 | Issam | HNB_LCRTDD_RF |  | HNB |
| 2214 | 548.1 | Core part: 1.28Mcps TDD Home NodeB RF requirements | 131d? | 2009-12-04 A | 2010-06-04 A | 100% | 2009-12-04 | 2010-06-04 | 131d? | finish no earlier than 2010-12-10 | R4 | 1048h | 1048h | HNB_LCRTDD_RF-Core | PCG-24 | TD Tech | Rel-10 | RP-46 | Issam | HNB_LCRTDD_RF-Core | RP-100446 | HNB |
| 2215 | 548.2 | Perf. part: 1.28Mcps TDD Home NodeB RF requirements | 266d? | 2009-12-04 A | 2010-12-10 A | 100% | 2009-12-04 | 2010-12-10 | 266d? | finish no earlier than 2010-12-10 | R4 | 2128h | 2128h | HNB_LCRTDD_RF-Perf | PCG-24 | TD Tech | Rel-10 | RP-46 | Issam | HNB_LCRTDD_RF-Perf | RP-101081 | HNB |
| 2216 | 549 | **Multi-User Multiple-Input and Multiple-Output (MU-MIMO) for 1.28Mcps TDD** | 316d? | 2010-03-19 A | 2011-06-03 A | 100% | 2010-03-19 | 2011-06-03 | 316d? |  | R1; R2; R3; R4 | 17224h | 17224h | MUMIMO_LCR_TDD | PCG-24 | CATT | Rel-10 | RP-47 | Patrick | MUMIMO_LCR_TDD |  |  |
| 2217 | 549.1 | Core part: MU-MIMO for 1.28Mcps TDD | 191d? | 2010-03-19 A | 2010-12-10 A | 100% | 2010-03-19 | 2010-12-10 | 191d? | finish no earlier than 2010-12-10 | R1; R2; R3 | 4584h | 4584h | MUMIMO_LCR_TDD-Core | PCG-24 | CATT | Rel-10 | RP-47 | Patrick | MUMIMO_LCR_TDD-Core | RP-101085 |  |
| 2218 | 549.2 | Perf. part: MU-MIMO for 1.28Mcps TDD | 316d? | 2010-03-19 A | 2011-06-03 A | 100% | 2010-03-19 | 2011-06-03 | 316d? | finish no earlier than 2011-06-03 | R4 | 2528h | 2528h | MUMIMO_LCR_TDD-Perf | PCG-24 | CATT | Rel-10 | RP-47 | Issam | MUMIMO_LCR_TDD-Perf | RP-110520 |  |
| 2219 | 550 | **AGNSS Minimum Performance for UTRAN** | 523d? | 2009-09-18 A | 2011-09-16 A | 100% | 2009-09-18 | 2011-09-16 | 523d? |  | R4; R5 | 13624h | 13624h | AGNSSPerf_UTRAN | PCG-23 | Thales | Rel-10 | RP-45 | Issam | AGNSSPerf_UTRAN |  |  |
| 2220 | 550.1 | AGNSS Minimum Performance Specification Development | 321d? | 2009-09-18 A | 2010-12-10 A | 100% | 2009-09-18 | 2010-12-10 | 321d? | finish no earlier than 2010-12-10 | R4 | 2568h | 2568h | AGNSSPerf_UTRAN | PCG-23 | Thales | Rel-10 | RP-45 | Issam | AGNSSPerf_UTRAN | RP-101078 |  |
| 2221 | 550.2 | AGNSS test case development for UMTS | 336d? | 2010-06-04 A | 2011-09-16 A | 100% | 2010-06-04 | 2011-09-16 | 336d? | finish no earlier than 2011-09-16 | R5 | 2688h | 2688h | AGNSSPerf_UTRAN | PCG-25 | Thales | Rel-10 | RP-48 | Ingbert | AGNSSPerf_UTRAN | RP-110979 |  |
| 2222 | 551 | **Inclusion of RF Pattern Matching Technologies as positioning method in the UTRAN** | 336d? | 2009-12-04 A | 2011-03-18 A | 100% | 2009-12-04 | 2011-03-18 | 336d? |  | R2; R3 | 10752h | 10752h | LCS_UMTS_RFPMT | PCG-24 | Polaris Wireless | Rel-10 | RP-46 | Yong-Jun | LCS_UMTS_RFPMT | RP-110048 |  |
| 2223 | 551.1 | Core part: Inclusion of RF Pattern Matching Technologies as positioning method in the UTRAN | 336d? | 2009-12-04 A | 2011-03-18 A | 100% | 2009-12-04 | 2011-03-18 | 336d? | finish no earlier than 2011-03-18 | R2; R3 | 5376h | 5376h | LCS_UMTS_RFPMT-Core | PCG-24 | Polaris Wireless | Rel-10 | RP-46 | Yong-Jun | LCS_UMTS_RFPMT-Core | RP-110048 |  |

Notes:
- 2200: GP#46 approved WID / Impacted TSs and TRs: GERAN / WI rapporteur e-mail: carsten.juncker@renesasmobile.com
- 2201: CP#52 completed / Impacted TSs and TRs: 24.008 / WI rapporteur e-mail: marko.niemi@renesasmobile.com
- 2202: GP#50 completed / Impacted TSs and TRs: 45.005, 45.015 / WI rapporteur e-mail: carsten.juncker@renesasmobile.com
- 2203: GP#57 completed / Impacted TSs and TRs: 51.010 / WI rapporteur e-mail: carsten.juncker@renesasmobile.com
- 2204: GP#47 approved WID. 900 MHz spectrum re-farming to other RATs lead operators to reduce GSM capacity and therefore share their GSM networks. Hence the need for the most suitable (GE)RAN sharing method / Impacted TSs and TRs: GERAN / WI rapporteur e-mail: michel.robert@alcatel-lucent.com
- 2205: SP#50 completed / Impacted TSs and TRs: 23.251 / WI rapporteur e-mail: michel.robert@alcatel-lucent.com
- 2206: CP#50 completed / Impacted TSs and TRs: 24.008 CR#1644 / WI rapporteur e-mail: michel.robert@alcatel-lucent.com
- 2207: GP#49 completed / Impacted TSs and TRs: 48.008 CR#0325, 48.018 CR#0303 / WI rapporteur e-mail: michel.robert@alcatel-lucent.com
- 2208: GP#47 approved WID / Impacted TSs and TRs: GERAN,UTRA / WI rapporteur e-mail: Ms Juan Deng (dengjuan@chinamobile.com), Xinhui Wang (wangxinhui@zte.com.cn)
- 2209: GP#49 completed. GP#48 updated WID GP-101659=>GP-101758 (restricting the scope to GERAN BSC and TD-SCDMA RNC only). GP#47 approved WID / Impacted TSs and TRs: 43.130, 48.008 / WI rapporteur e-mail: Ms Juan Deng (dengjuan@chinamobile.com), Xinhui Wang (wangxinhui@zte.com.cn)
- 2210: RP#52 completed / Impacted TSs and TRs: UTRA Stage 2 (25.401, 25.420), Stage 3 (25.423) / WI rapporteur e-mail: Liu Junqiang (liu.junqiang@zte.com.cn)
- 2211: RP#47 completed / Impacted TSs and TRs: UTRA 25.113, New 25.116, 25.153 (testing) / WI rapporteur e-mail: qinyan@chinattl.com
- 2212: RP#50 completed / Impacted TSs and TRs: UTRA 25.102, 25.105, 25.123, 25.221, 25.222, 25.223, 25.224, 25.225, 25.306, 25.319, 25.321, 25.331, 25.423, 25.427, 25.433 / WI rapporteur e-mail: Aihui Song (songaihui@mail.ritt.com.cn)
- 2213: RP#50 completed. Triggered by FS_RAN-HNBLCRTDD UID_410016 Study on 1.28 Mcps TDD Home NodeB (TR 25.866) / Impacted TSs and TRs: UTRA / WI rapporteur e-mail: Li Rong (lirong@td-tech.com)
- 2214: RP#48 completed / Impacted TSs and TRs: 25.105 / WI rapporteur e-mail: Li Rong (lirong@td-tech.com)
- 2215: RP#50 completed. TR 25.968 v100 for Approval / Impacted TSs and TRs: 25.142, new TR 25.968 / WI rapporteur e-mail: Li Rong (lirong@td-tech.com)
- 2216: RP#52 completed / Impacted TSs and TRs: UTRA / WI rapporteur e-mail: Yanping Xing (xingyanping@datangmobile.cn)
- 2217: RP#50 completed / Impacted TSs and TRs: 25.221, 25.222, 25.224, 25.306, 25.308, 25.319, 25.331, 25.423, 25.425, 25.433, 25.435 / WI rapporteur e-mail: Yanping Xing (xingyanping@datangmobile.cn)
- 2218: RP#52 completed / Impacted TSs and TRs: 25.102, 25.105, 25.142 / WI rapporteur e-mail: Sanjun Feng (fengsanjun@datangmobile.cn)
- 2219: RP#53 completed. Triggered by Rel-7 UID_20050 (GNSS in UTRAN) and Rel-8 UID_400051 (Support for Additional NSS). Linked to GERAN Rel-9 UID_38002 (AGNSS Performances and Testing Procedures) / Impacted TSs and TRs: UTRA / WI rapporteur e-mail: Michel.monnerat@thalesaleniaspace.com
- 2220: RP#50 completed / Impacted TSs and TRs: new 25.172 / WI rapporteur e-mail: Michel.monnerat@thalesaleniaspace.com
- 2221: RP#53 completed / Impacted TSs and TRs: 34.108, 34.109, 34.123-1, 34.123-2, 34.123-3, 36.37.571-5, new 34.172 / WI rapporteur e-mail: Michel.monnerat@thalesaleniaspace.com
- 2222: RP#51 completed. Triggered by Study UID_380079 Evaluation of the inclusion of Path Loss Based Technology in the UTRAN (25.907) / Impacted TSs and TRs: UTRA / WI rapporteur e-mail: Norman Shaw (nshaw@polariswireless.com)
- 2223: RP#51 completed / Impacted TSs and TRs: 25.305, 25.453 / WI rapporteur e-mail: Norman Shaw (nshaw@polariswireless.com)

| ID | WBS | Task | Duration | Start | Finish | Complete | Baseline start | Baseline finish | Baseline duration | Constraint | Resources | Work | Actual work | Acronym | PCG approved | WI rapporteur name | WI rapporteur e-mail | Release | TSG approved | MCC resp | Acronym_3GU_Export | Status Report | PCG stopped | TSG stopped | Special Focus Doc |
| --- | --- | --- | --- | --- | --- | --- | --- | --- | --- | --- | --- | --- | --- | --- | --- | --- | --- | --- | --- | --- | --- | --- | --- | --- | --- |
| 2224 | 552 | **Four carrier HSDPA** | 992d? | 2009-12-04 A | 2013-09-06 A | 100% | 2009-12-04 | 2013-09-06 | 992d? |  | R1; R2; R3; R4; R5 | 57872h | 57872h | 4C_HSDPA | PCG-24 | Qualcomm | Arjun Bharadwaj (arjunb@qualcomm.com) | Rel-10 | RP-46 | Patrick | 4C_HSDPA |  |  |  |  |
| 2225 | 552.1 | Core part: Four carrier HSDPA | 336d? | 2009-12-04 A | 2011-03-18 A | 100% | 2009-12-04 | 2011-03-18 | 336d? | finish no earlier than 2011-03-18 | R1; R2; R3; R4 | 10752h | 10752h | 4C_HSDPA-Core | PCG-24 | Qualcomm | Arjun Bharadwaj (arjunb@qualcomm.com) | Rel-10 | RP-46 | Patrick | 4C_HSDPA-Core | RP-110046 |  |  |  |
| 2226 | 552.2 | Perf. part: Four carrier HSDPA | 466d? | 2009-12-04 A | 2011-09-16 A | 100% | 2009-12-04 | 2011-09-16 | 466d? | finish no earlier than 2011-09-16 | R4 | 3728h | 3728h | 4C_HSDPA-Perf | PCG-24 | Qualcomm | Arjun Bharadwaj (arjunb@qualcomm.com) | Rel-10 | RP-46 | Issam | 4C_HSDPA-Perf | RP-110986 |  |  |  |
| 2227 | 552.3 | Test part: Four carrier HSDPA | 464d? | 2011-12-02 A | 2013-09-06 A | 100% | 2011-12-02 | 2013-09-06 | 464d? | finish no earlier than 2013-09-06 | R5 | 3712h | 3712h | 4C_HSDPA-UEConTest | PCG-28 | Qualcomm | Shubhang Vora (svora@qualcomm.com) | Rel-10 | RP-54 | Ingbert | 4C_HSDPA-UEConTest | RP-130940 |  |  |  |
| 2228 | 553 | **Performance Requirements for two-antenna 1.28Mcps TDD Type 1 and Type 2 UE receiver** | 316d? | 2010-03-19 A | 2011-06-03 A | 100% | 2010-03-19 | 2011-06-03 | 316d? |  | R4 | 5504h | 5504h | 2ant_UE_LCR_TDD | PCG-24 | TD Tech | dafei.wang@td-tech.com | Rel-10 | RP-47 | Issam | 2ant_UE_LCR_TDD |  |  |  |  |
| 2229 | 553.1 | Core part: Performance Requirements for two-antenna 1.28Mcps TDD Type 1 and Type 2 UE receiver | 56d? | 2010-03-19 A | 2010-06-04 A | 100% | 2010-03-19 | 2010-06-04 | 56d? | finish no earlier than 2010-06-04 | R4 | 448h | 448h | 2ant_UE_LCR_TDD-Core | PCG-24 | TD Tech | dafei.wang@td-tech.com | Rel-10 | RP-47 | Issam | 2ant_UE_LCR_TDD-Core | RP-100454 |  |  |  |
| 2230 | 553.2 | Perf. part: Performance Requirements for two-antenna 1.28Mcps TDD Type 1 and Type 2 UE receiver | 316d? | 2010-03-19 A | 2011-06-03 A | 100% | 2010-03-19 | 2011-06-03 | 316d? | finish no earlier than 2011-06-03 | R4 | 2528h | 2528h | 2ant_UE_LCR_TDD-Perf | PCG-24 | TD Tech | dafei.wang@td-tech.com | Rel-10 | RP-47 | Issam | 2ant_UE_LCR_TDD-Perf | RP-110521 |  |  |  |
| 2231 | 554 | **Automatic Neighbour Relation (ANR) for UTRAN** | 663d? | 2010-06-04 A | 2012-12-07 A | 100% | 2010-06-04 | 2012-12-07 | 663d? |  | R3; R2; R5 | 22672h | 22672h | ANR_UTRAN | PCG-25 | ZTE | Zhai.hengxing@zte.com.cn | Rel-10 | RP-48 | Juha | ANR_UTRAN |  |  |  |  |
| 2232 | 554.1 | Core part: Automatic Neighbour Relation (ANR) for UTRAN | 261d? | 2010-06-04 A | 2011-06-03 A | 100% | 2010-06-04 | 2011-06-03 | 261d? | finish no earlier than 2011-06-03 | R3; R2 | 4176h | 4176h | ANR_UTRAN-Core | PCG-25 | ZTE | Zhai.hengxing@zte.com.cn | Rel-10 | RP-48 | Juha | ANR_UTRAN-Core | RP-110522 |  |  |  |
| 2233 | 554.2 | Test part: Automatic Neighbour Relation (ANR) for UTRAN | 323d? | 2011-09-19 A | 2012-12-07 A | 100% | 2011-09-19 | 2012-12-07 | 323d? | finish no earlier than 2012-12-07 | R5 | 2584h | 2584h | ANR_UTRAN-UEConTest | PCG-27 | Ericsson | leif.mattisson@ericsson.com | Rel-10 | RP-53 | Ingbert | ANR_UTRAN-UEConTest | RP-121529 |  |  |  |
| 2234 | 555 | **Support of New Band Combinations for Dual-Band Dual Cell HSDPA** | 261d? | 2010-06-04 A | 2011-06-03 A | 100% | 2010-06-04 | 2011-06-03 | 261d? |  | R4; R2 | 9568h | 9568h | DB_DC_HSDPA | PCG-25 | AT&T | Vince Spatafora (vs5785@att.com) | Rel-10 | RP-48 | Issam | DB_DC_HSDPA |  |  |  |  |
| 2235 | 555.1 | Core part: Support of New Band Combinations for Dual-Band Dual Cell HSDPA | 261d? | 2010-06-04 A | 2011-06-03 A | 100% | 2010-06-04 | 2011-06-03 | 261d? | finish no earlier than 2011-06-03 | R4; R2 | 4176h | 4176h | DB_DC_HSDPA-Core | PCG-25 | AT&T | Vince Spatafora (vs5785@att.com) | Rel-10 | RP-48 | Issam | DB_DC_HSDPA-Core | RP-110523 |  |  |  |
| 2236 | 555.2 | Deleted - Perf. part: Support of New Band Combinations for Dual-Band Dual Cell HSDPA | 76d? | 2010-06-04 A | 2010-09-17 A | 100% | 2010-06-04 | 2010-09-17 | 76d? | finish no earlier than 2010-09-17 | R4; R2 | 1216h | 1216h | DB_DC_HSDPA-Perf | PCG-25 | AT&T | Vince Spatafora (vs5785@att.com) | Rel-10 | RP-48 | Issam | DB_DC_HSDPA-Perf | RP-100759 | PCG-25 | RP-49 |  |
| 2237 | 556 | **MIMO operation with non-MIMO coexistence in HSDPA** | 459d? | 2010-06-04 A | 2012-03-02 A | 100% | 2010-06-04 | 2012-03-02 | 459d? |  | R4; R5 | 12936h | 12936h | MIMO_HSDPA | PCG-25 | Qualcomm | Heechoon Lee | Rel-10 | RP-48 | Issam | MIMO_HSDPA |  |  |  |  |
| 2238 | 556.1 | Core part: MIMO operation with non-MIMO coexistence in HSDPA | 186d? | 2010-09-17 A | 2011-06-03 A | 100% | 2010-09-17 | 2011-06-03 | 186d? | finish no earlier than 2011-06-03 | R4 | 1488h | 1488h | MIMO_HSDPA-Core | PCG-25 | Qualcomm | Heechoon Lee | Rel-10 | RP-49 | Issam | MIMO_HSDPA-Core | RP-110524 |  |  |  |
| 2239 | 556.2 | Perf. part: MIMO operation with non-MIMO coexistence in HSDPA | 261d? | 2010-06-04 A | 2011-06-03 A | 100% | 2010-06-04 | 2011-06-03 | 261d? | finish no earlier than 2011-06-03 | R4 | 2088h | 2088h | MIMO_HSDPA-Perf | PCG-25 | Qualcomm | Heechoon Lee | Rel-10 | RP-48 | Issam | MIMO_HSDPA-Perf | RP-110525 |  |  |  |
| 2240 | 556.3 | Test part: MIMO operation with non-MIMO coexistence in HSDPA | 252d? | 2011-03-18 A | 2012-03-02 A | 100% | 2011-03-18 | 2012-03-02 | 252d? | finish no earlier than 2012-03-02 | R5 | 2016h | 2016h | MIMO_HSDPA-UEConTest | PCG-26 | Qualcomm | Shubhang Vora (svora@qualcomm.com) | Rel-10 | RP-51 | Ingbert | MIMO_HSDPA-UEConTest | RP-120042 |  |  |  |
| 2241 | 557 | Interfrequency detected set measurements for UMTS | 61d? | 2010-09-17 A | 2010-12-10 A | 100% | 2010-09-17 | 2010-12-10 | 61d? | finish no earlier than 2010-12-10 | R2; R4 | 976h | 976h | Interf_dset_meas_UMTS | PCG-25 | Nokia | Chris.callender@nokia.com | Rel-10 | RP-49 | Yong-Jun | Interf_dset_meas_UMTS | RP-101093 |  |  |  |
| 2242 | 558 | **Carrier Aggregation for LTE** | 793d? | 2009-12-04 A | 2012-12-07 A | 100% | 2009-12-04 | 2012-12-07 | 793d? |  | R1; R2; R3; R4; R5 | 51024h | 51024h | LTE_CA | PCG-24 | Nokia | Asbjorn.grovlen@nokia.com | Rel-10 | RP-46 | Patrick | LTE_CA |  |  |  | CA |
| 2243 | 558.1 | Core part: Carrier Aggregation for LTE | 391d? | 2009-12-04 A | 2011-06-03 A | 100% | 2009-12-04 | 2011-06-03 | 391d? | finish no earlier than 2011-06-03 | R1; R2; R3; R4 | 12512h | 12512h | LTE_CA-Core | PCG-24 | Nokia | lars.e.lindh@nokia.com | Rel-10 | RP-46 | Patrick | LTE_CA-Core | RP-110535 |  |  | CA |
| 2244 | 558.2 | Perf. part: Carrier Aggregation for LTE | 528d? | 2009-12-04 A | 2011-12-09 A | 100% | 2009-12-04 | 2011-12-09 | 528d? | finish no earlier than 2011-12-09 | R4 | 4224h | 4224h | LTE_CA-Perf | PCG-24 | Nokia | lars.e.lindh@nokia.com | Rel-10 | RP-46 | Issam | LTE_CA-Perf | RP-111452 |  |  | CA |
| 2245 | 558.3 | Test part: Carrier Aggregation for LTE | 321d? | 2011-09-19 A | 2012-12-07 A | 100% | 2011-09-19 | 2012-12-07 | 321d? | finish no earlier than 2012-12-07 | R5 | 2568h | 2568h | LTE_CA-UEConTest | PCG-27 | Nokia | jussi.kuusisto@nokia.com | Rel-10 | RP-53 | Ingbert | LTE_CA-UEConTest | RP-121528 |  |  | CA |
| 2246 | 559 | **Enhanced Downlink Multiple Antenna Transmission for LTE** | 930d? | 2009-12-04 A | 2013-06-14 A | 100% | 2009-12-04 | 2013-06-14 | 930d? |  | R1; R2; R4; R5 | 44624h | 44624h | LTE_eDL_MIMO | PCG-24 | NTT DoCoMo | Hidekazu Taoka (taoka@nttdocomo.com) | Rel-10 | RP-46 | Patrick | LTE_eDL_MIMO |  |  |  |  |
| 2247 | 559.1 | Core part: Enhanced Downlink Multiple Antenna Transmission for LTE | 336d? | 2009-12-04 A | 2011-03-18 A | 100% | 2009-12-04 | 2011-03-18 | 336d? | finish no earlier than 2011-03-18 | R1; R2; R4 | 8064h | 8064h | LTE_eDL_MIMO-Core | PCG-24 | NTT DoCoMo | Hidekazu Taoka (taoka@nttdocomo.com) | Rel-10 | RP-46 | Patrick | LTE_eDL_MIMO-Core | RP-110067 |  |  |  |
| 2248 | 559.2 | Perf. part: Enhanced Downlink Multiple Antenna Transmission for LTE | 589d? | 2009-12-04 A | 2012-03-02 A | 100% | 2009-12-04 | 2012-03-02 | 589d? | finish no earlier than 2012-03-02 | R4 | 4712h | 4712h | LTE_eDL_MIMO-Perf | PCG-24 | NTT DoCoMo | Hidekazu Taoka (taoka@nttdocomo.com) | Rel-10 | RP-46 | Issam | LTE_eDL_MIMO-Perf | RP-120053 |  |  |  |
| 2249 | 559.3 | Test part: Enhanced Downlink Multiple Antenna Transmission for LTE | 261d? | 2012-06-18 A | 2013-06-14 A | 100% | 2012-06-18 | 2013-06-14 | 261d? | finish no earlier than 2013-06-14 | R5 | 2088h | 2088h | LTE_eDL_MIMO-UEConTest | PCG-29 | ZTE | Carolyn Taylor (carolyn.tayl@zte.com.cn) | Rel-10 | RP-56 | Ingbert | LTE_eDL_MIMO-UEConTest | RP-130464 |  |  |  |

Notes:
- 2224: RP#53 completed / Impacted TSs and TRs: UTRA
- 2225: RP#51 completed. RP#52 TR 25.864 v200 for Approval / Impacted TSs and TRs: 25.101, 25.104, 25.133, 25.211, 25.212, 25.213, 25.214, 25.215, 25.308, 25.331, 25.423, 25.433, 26.306, new TR 25.864
- 2226: RP#53 completed / Impacted TSs and TRs: 25.101, 25.104, 25.133, 25.141
- 2227: RP#61 completed / Impacted TSs and TRs: 34.108, 34.121-1, 34.121-2, 34.123-1, 34.123-2, 34.123-3
- 2228: Stage 3. RP#52 completed / Impacted TSs and TRs: UTRA
- 2229: RP#48 completed / Impacted TSs and TRs: 25.102
- 2230: RP#52 completed / Impacted TSs and TRs: 25.102
- 2231: RP#52 Core completed. Automatic Neighbour Relation (ANR) function for UTRAN relieves operators from the burden of manually managing the Neighbour cell Relations (NRs) / Impacted TSs and TRs: UTRA
- 2232: RP#52 completed / Impacted TSs and TRs: 25.331, 25.413, 25.423, new TS 25.484 (Stage 2)
- 2233: RP#58 completed / Impacted TSs and TRs: 34.108, 34.123-1, 34.123-2, 34.123-3
- 2234: RP#52 completed. Rel-9 Dual-Band Dual-Cell HSDPA (UID_430015 Support for different bands for Dual-Cell HSDPA) has one combination per region in principle. This work adds additional combinations: Band I and XI (Region 3) and Band II and V (Region 2) / Impacted TSs and TRs: UTRA
- 2235: RP#52 completed. RP#62 existing TS 25.317 replaced by new TS 25.327 / Impacted TSs and TRs: 25.101, 25.104, 25.141, 25.317 replaced by new TS 25.327
- 2236: RP#49 stopped (Reason: no need for Performance work) / Impacted TSs and TRs: 25.101, 25.104, 25.141, 25.317
- 2237: RP#52 completed. RP#49 updated WID RP-100687=>RP-100993 (changed Title: MIMO Testing in HSDPA => MIMO operation with non-MIMO coexistence in HSDPA) / Impacted TSs and TRs: UTRA
- 2238: RP#52 completed / Impacted TSs and TRs: 25.104
- 2239: RP#52 completed / Impacted TSs and TRs: 25.101, 25.141
- 2240: RP#55 completed / Impacted TSs and TRs: 34.108, 34.121-1, 34.121-2, 34.123-1, 34.123-2, 34.123-3
- 2241: RP#50 completed / Impacted TSs and TRs: UTRA 25.133, 25.331
- 2242: - / Impacted TSs and TRs: LTE
- 2243: RP#52 completed. RP#56 new RAN4 TR (36.807, 36.808) v200 for Approval / Impacted TSs and TRs: 36.101, 36.104, 36.133, 36.211, 36.212, 36.213, 36.300, 36.302, 36.306, 36.321, 36.331, 36.413, 36.423, 37.104, new RAN4 TR (36.807, 36.808)
- 2244: RP#54 completed / Impacted TSs and TRs: 36.101, 36.104, 36.133, 36.141, 37.141
- 2245: RP#58 completed / Impacted TSs and TRs: 36.508, 36.521-1, 36.521-2, 36.521-3, 36.523-1, 36.523-2, 36.523-3, 37.571-1, 37.571-3, 37.571-5
- 2246: - / Impacted TSs and TRs: LTE
- 2247: RP#51 completed. RP#56 new RAN4 TR 36.807 v200 for Approval / Impacted TSs and TRs: 36.101, 36.104, 36.133, 36.201, 36.211, 36.212, 36.213, 36.300, 36.306, 36.321, 36.331, new RAN4 TR 36.807
- 2248: RP#55 completed / Impacted TSs and TRs: 36.101, 36.104, 36.133, 36.141
- 2249: RP#60 completed. Testing for 36.101, 36.133 / Impacted TSs and TRs: 36.508, 36.521-1, 36.521-2

| ID | WBS | Task | Duration | Start | Finish | Complete | Baseline start | Baseline finish | Baseline duration | Constraint | Resources | Work | Actual work | Acronym | PCG approved | WI rapporteur name | WI rapporteur e-mail | Release | TSG approved | MCC resp | Acronym_3GU_Export | Status Report | PCG stopped | TSG stopped |
| --- | --- | --- | --- | --- | --- | --- | --- | --- | --- | --- | --- | --- | --- | --- | --- | --- | --- | --- | --- | --- | --- | --- | --- | --- |
| 2250 | 560 | **Uplink Multiple Antenna Transmission for LTE** | 3445d? | 2000-01-03 A | 2013-03-01 A | 100% | 2000-01-03 | 2013-03-01 | 3445d? |  | R1; R2; R4; R5 | 125976h | 125976h | LTE_UL_MIMO | PCG-24 | Huawei | Mattias.wennstrom@huawei.com | Rel-10 | RP-46 | Patrick | LTE_UL_MIMO |  |  |  |
| 2251 | 560.1 | Core part: UL multiple antenna transmission for LTE | 391d? | 2000-01-03 A | 2001-06-29 A | 100% | 2000-01-03 | 2001-06-29 | 391d? |  | R1; R2; R4 | 9384h | 9384h | LTE_UL_MIMO-Core | PCG-24 | Huawei | Mattias.wennstrom@huawei.com | Rel-10 | RP-46 | Patrick | LTE_UL_MIMO-Core | RP-110537 |  |  |
| 2252 | 560.2 | Perf. part: UL multiple antenna transmission for LTE | 466d? | 2009-12-04 A | 2011-09-16 A | 100% | 2009-12-04 | 2011-09-16 | 466d? | finish no earlier than 2011-09-16 | R4 | 3728h | 3728h | LTE_UL_MIMO-Perf | PCG-24 | Huawei | Mattias.wennstrom@huawei.com | Rel-10 | RP-46 | Issam | LTE_UL_MIMO-Perf | RP-110992 |  |  |
| 2253 | 560.3 | Test part: UL multiple antenna transmission for LTE | 328d? | 2011-12-02 A | 2013-03-01 A | 100% | 2011-12-02 | 2013-03-01 | 328d? | finish no earlier than 2013-03-01 | R5 | 2624h | 2624h | LTE_UL_MIMO-UEConTest | PCG-28 | Huawei | Zhang Xin (suzanna.zhang@huawei.com) | Rel-10 | RP-54 | Ingbert | LTE_UL_MIMO-UEConTest | RP-130038 |  |  |
| 2254 | 561 | **Relays for LTE** | 394d? | 2009-12-04 A | 2011-06-08 A | 100% | 2009-12-04 | 2011-06-08 | 394d? |  | R1; R2; R4; S2; S3; C4; C6 | 36856h | 36856h | LTE_Relay | PCG-24 | Ericsson | christian.hoymann@ericsson.com | Rel-10 | RP-46 | Patrick | LTE_Relay |  |  |  |
| 2255 | 561.1 | Core part: Relays for LTE | 391d? | 2009-12-04 A | 2011-06-03 A | 100% | 2009-12-04 | 2011-06-03 | 391d? | finish no earlier than 2011-06-03 | R1; R2; R4 | 9384h | 9384h | LTE_Relay-Core | PCG-24 | Ericsson | christian.hoymann@ericsson.com | Rel-10 | RP-46 | Patrick | LTE_Relay-Core | RP-110540 |  |  |
| 2256 | 561.2 | Deleted - Perf. part: Relays for LTE | 391d? | 2009-12-04 A | 2011-06-03 A | 100% | 2009-12-04 | 2011-06-03 | 391d? | finish no earlier than 2011-09-16 | R4 | 3128h | 3128h | LTE_Relay-Perf | PCG-24 | Ericsson | christian.hoymann@ericsson.com | Rel-10 | RP-46 | Issam | LTE_Relay-Perf | RP-110541 | PCG-27 | RP-52 |
| 2257 | 561.3 | Stage 2 for Relays for LTE | 3d? | 2011-06-06 A | 2011-06-08 A | 100% | 2011-06-06 | 2011-06-08 | 3d? | start no earlier than 2011-06-06 | S2 | 24h | 24h | LTE_Relay | PCG-27 | Vodafone | chris.pudney@vodafone.com | Rel-10 | SP-52 | Maurice | LTE_Relay |  |  |  |
| 2258 | 561.4 | **LTE Relay Nodes Security** | 69d? | 2010-12-16 A | 2011-03-22 A | 100% | 2010-12-16 | 2011-03-22 | 69d? |  | S3; C6 | 2232h | 2232h | LTE_Relay-Sec | PCG-26 | Qualcomm | Adrian Escott (aescott@qualcomm.com) | Rel-10 | SP-50 | Mirko | LTE_Relay-Sec |  |  |  |
| 2259 | 561.4.1 | TR on LTE Relay Nodes Security | 69d? | 2010-12-16 A | 2011-03-22 A | 100% | 2010-12-16 | 2011-03-22 | 69d? | finish no earlier than 2011-03-23 | S3 | 552h | 552h | LTE_Relay-Sec | PCG-26 | Qualcomm | Adrian Escott (aescott@qualcomm.com) | Rel-10 | SP-50 | Mirko |  |  |  |  |
| 2260 | 561.4.2 | Security for LTE Relay Nodes (Stage 2) | 69d? | 2010-12-16 A | 2011-03-22 A | 100% | 2010-12-16 | 2011-03-22 | 69d? | finish no earlier than 2011-03-23 | S3 | 552h | 552h | LTE_Relay-Sec | PCG-26 | Qualcomm | Adrian Escott (aescott@qualcomm.com) | Rel-10 | SP-50 | Mirko |  |  |  |  |
| 2261 | 561.4.3 | CT6 aspects of LTE Relay Node Security | 3d? | 2011-03-16 A | 2011-03-18 A | 100% | 2011-03-16 | 2011-03-18 | 3d? | start no earlier than 2011-03-16 | C6 | 24h | 24h | LTE_Relay-Sec | PCG-26 | n/a | n/a | Rel-10 | CP-51 | Xavier |  |  |  |  |
| 2262 | 561.5 | Core Network Impacts for Relay Nodes | 3d? | 2011-03-16 A | 2011-03-18 A | 100% | 2011-03-16 | 2011-03-18 | 3d? | finish no earlier than 2011-03-18 | C4 | 24h | 24h | LTE_Relay-CN | PCG-26 | Vodafone | David.Hutton@vodafone.com | Rel-10 | CP-51 | Kimmo | LTE_Relay-CN |  |  |  |
| 2263 | 562 | **Enhanced Inter-Cell Interference Control (ICIC) for non-Carrier Aggregation (CA) based deployments of heterogeneous networks for LTE** | 1119d? | 2010-03-19 A | 2014-06-13 A | 100% | 2010-03-19 | 2014-06-13 | 1119d? |  | R1; R2; R3; R4; R5 | 64384h | 64384h | eICIC_LTE | PCG-24 | China Mobile | Xiaodong XU (xuxiaodong@chinamobile.com) | Rel-10 | RP-47 | Patrick | eICIC_LTE |  |  |  |
| 2264 | 562.1 | Core part: Enhanced Inter-Cell Interference Control (ICIC) for non-Carrier Aggregation (CA) based deployments of heterogeneous networks for LTE | 316d? | 2010-03-19 A | 2011-06-03 A | 100% | 2010-03-19 | 2011-06-03 | 316d? | finish no earlier than 2011-06-03 | R1; R2; R3; R4 | 10112h | 10112h | eICIC_LTE-Core | PCG-24 | China Mobile | Xiaodong XU (xuxiaodong@chinamobile.com) | Rel-10 | RP-47 | Patrick | eICIC_LTE-Core | RP-110543 |  |  |
| 2265 | 562.2 | Perf. part: Enhanced Inter-Cell Interference Control (ICIC) for non-Carrier Aggregation (CA) based deployments of heterogeneous networks for LTE | 589d? | 2010-03-19 A | 2012-06-15 A | 100% | 2010-03-19 | 2012-06-15 | 589d? | finish no earlier than 2012-06-15 | R4 | 4712h | 4712h | eICIC_LTE-Perf | PCG-24 | China Mobile | Xiaodong XU (xuxiaodong@chinamobile.com) | Rel-10 | RP-47 | Issam | eICIC_LTE-Perf | RP-120461 |  |  |
| 2266 | 562.3 | Test part: Enhanced Inter-Cell Interference Control (ICIC) for non-Carrier Aggregation (CA) based deployments of heterogeneous networks for LTE | 600d? | 2012-03-05 A | 2014-06-13 A | 100% | 2012-03-05 | 2014-06-13 | 600d? | finish no earlier than 2014-06-13 | R5 | 4800h | 4800h | eICIC_LTE-UEConTest | PCG-28 | Qualcomm | Anjali Mishra (ajha@qualcomm.com) | Rel-10 | RP-55 | Ingbert | eICIC_LTE-UEConTest | RP-140766 |  |  |
| 2267 | 563 | **LTE TDD in 2600MHz for US** | 191d? | 2010-03-19 A | 2010-12-10 A | 100% | 2010-03-19 | 2010-12-10 | 191d? |  | R4; R2; R3; R5 | 11392h | 11392h | LTE_TDD_2600_US | PCG-24 | Clearwire | michael.hart@clearwire.com | Rel-10 | RP-47 | Issam | LTE_TDD_2600_US |  |  |  |
| 2268 | 563.1 | Core part: LTE TDD in 2600MHz for US | 131d? | 2010-03-19 A | 2010-09-17 A | 100% | 2010-03-19 | 2010-09-17 | 131d? | finish no earlier than 2010-09-17 | R4; R2; R3 | 3144h | 3144h | LTE_TDD_2600_US-Core | PCG-24 | Clearwire | michael.hart@clearwire.com | Rel-10 | RP-47 | Issam | LTE_TDD_2600_US-Core | RP-100782 |  |  |
| 2269 | 563.2 | Perf. part: LTE TDD in 2600MHz for US | 131d? | 2010-03-19 A | 2010-09-17 A | 100% | 2010-03-19 | 2010-09-17 | 131d? | finish no earlier than 2010-09-17 | R4 | 1048h | 1048h | LTE_TDD_2600_US-Perf | PCG-24 | Clearwire | michael.hart@clearwire.com | Rel-10 | RP-47 | Issam | LTE_TDD_2600_US-Perf | RP-100783 |  |  |
| 2270 | 563.3 | UE conformance test part: LTE TDD in 2600MHz for US | 136d? | 2010-06-04 A | 2010-12-10 A | 100% | 2010-06-04 | 2010-12-10 | 136d? | finish no earlier than 2010-12-10 | R5 | 1088h | 1088h | LTE_TDD_2600_US-UEConTest | PCG-25 | Clearwire | michael.hart@clearwire.com | Rel-10 | RP-48 | Ingbert | LTE_TDD_2600_US-UEConTest | RP-101071 |  |  |
| 2271 | 564 | **Adding 2 GHz band LTE FDD (Band 23) for Ancillary Terrestrial Component (ATC) of Mobile Satellite Service (MSS) in North America** | 454d? | 2010-03-19 A | 2011-12-09 A | 100% | 2010-03-19 | 2011-12-09 | 454d? |  | R2; R4; R5 | 19568h | 19568h | S_Band_LTE_ATC_MSS | PCG-24 | DBSD | Mariam.Sorond@ico.com | Rel-10 | RP-47 | Yong-Jun | S_Band_LTE_ATC_MSS |  |  |  |
| 2272 | 564.1 | Core part: Adding 2 GHz band LTE FDD (Band 23) for ATC of MSS in North America | 316d? | 2010-03-19 A | 2011-06-03 A | 100% | 2010-03-19 | 2011-06-03 | 316d? | finish no earlier than 2011-06-03 | R4; R2 | 5056h | 5056h | S_Band_LTE_ATC_MSS-Core | PCG-24 | DBSD | Mariam.Sorond@ico.com | Rel-10 | RP-47 | Issam | S_Band_LTE_ATC_MSS-Core | RP-110545 |  |  |
| 2273 | 564.2 | Perf. part: Adding 2 GHz band LTE FDD (Band 23) for ATC of MSS in North America | 316d? | 2010-03-19 A | 2011-06-03 A | 100% | 2010-03-19 | 2011-06-03 | 316d? | finish no earlier than 2011-06-03 | R4 | 2528h | 2528h | S_Band_LTE_ATC_MSS-Perf | PCG-24 | DBSD | Mariam.Sorond@ico.com | Rel-10 | RP-47 | Issam | S_Band_LTE_ATC_MSS-Perf | RP-110546 |  |  |
| 2274 | 564.3 | Test part: Adding 2 GHz band LTE FDD (Band 23) for ATC of MSS in North America | 137d? | 2011-06-07 A | 2011-12-09 A | 100% | 2011-06-07 | 2011-12-09 | 137d? | finish no earlier than 2011-12-09 | R5 | 1088h | 1088h | S_Band_LTE_ATC_MSS-UEConTest | PCG-27 | DBSD | Mariam.Sorond@ico.com | Rel-10 | RP-52 | Ingbert | S_Band_LTE_ATC_MSS-UEConTest | RP-111444 |  |  |

Notes:
- 2250: - / Impacted TSs and TRs: LTE
- 2251: RP#52 completed. TR 36.817 v110 for Approval. RP#56 new TR 36.807 v200 for Approval / Impacted TSs and TRs: 36.101, 36.104, 36.133, 36.201, 36.211, 36.212, 36.213, 36.300, 36.306, 36.321, 36.331, new RAN4 (TR 36.807, 36.817)
- 2252: RP#53 completed / Impacted TSs and TRs: 36.101, 36.104, 36.133, 36.141, 36.817
- 2253: RP#59 completed / Impacted TSs and TRs: 36.508, 36.521-1, 36.521-2, 36.521-3, 36.523-1, 36.523-2, 36.523-3
- 2254: RP#52 completed (open RAN4 Core & Perf parts moved to new Rel-11) / Impacted TSs and TRs: LTE
- 2255: RP#52 completed. Updated WID RP-101417=>RP-101911 (contains only Core part completed in Rel-10). Open RAN4 Core & Perf parts moved to new Rel-11 / Impacted TSs and TRs: 36.201, 36.211, 36.212, 36.213, 36.300, 36.321, 36.323, 36.331, New RAN1 TS 36.216
- 2256: RP#52 stopped at 30% (no CRs so far) . Transferred completely to Rel-11 together with remaining core part / Impacted TSs and TRs: 36.133, New TS 36.117 (E-UTRA Relay conformance testing)
- 2257: SP#52 SP-110338 (S2-85/S2-112851) 23.401 Cat F CR#2128 Completion of Relay procedure overview / Impacted TSs and TRs: 23.401
- 2258: -
- 2259: SP#51 completed / Impacted TSs and TRs: 33.816
- 2260: SP#51 completed (impacting Stage 3 in CT and RAN) / Impacted TSs and TRs: 33.401 (CR#0437,0438), CT1 24.301, CT4 (29.272, 29.274), CT6 31.102, RAN2 (36.331, 36.323), RAN3 36.413
- 2261: CP#51 completed / Impacted TSs and TRs: 31.101, 31.102
- 2262: CP#51 completed / Impacted TSs and TRs: 23.003, 23.008, 29.303, 29.230, 29.272
- 2263: RP#56 completed / Impacted TSs and TRs: LTE
- 2264: RP#52 completed / Impacted TSs and TRs: 36.101, 36.133, 36.201, 36.211, 36.212, 36.213, 36.214, 36.300, 36.321, 36.331, 36.413, 36.423
- 2265: RP#56 completed / Impacted TSs and TRs: 36.101, 36.133
- 2266: RP#64 completed / Impacted TSs and TRs: 36.508, 36.521-1, 36.521-2, 36.521-3, 36.523-1, 36.523-2, 36.523-3
- 2267: RP#50 Testing completed. RP#49 Core+Perf completed / Impacted TSs and TRs: LTE
- 2268: RP#49 completed / Impacted TSs and TRs: 25.461, 25.466, 36.101, 36.104, 36.113, 36.124, 36.133, 36.141, 36.307, 36.331, 37.104, 37.113, 37.141, new TR 36.812
- 2269: RP#49 completed / Impacted TSs and TRs: 36.101, 36.104, 36.133, 36.141, 36.307, 37.104, 37.141, new TR 36.812
- 2270: RP#50 completed / Impacted TSs and TRs: 36.508, 36.521-1, 36.521-2, 36.521-3, 36.523-1, 36.523-2, 36.523-3
- 2271: RP#52 completed. Updated WID RP-101401=>RP-110775 (changed in Title "LTE" to "LTE FDD (Band 23)" / Impacted TSs and TRs: LTE
- 2272: RP#52 completed / Impacted TSs and TRs: 25.101, 25.104, 25.141, 25.461, 25.466, 36.101, 36.104, 36.113, 36.124, 36.133, 36.307, 37.104, 37.141, new TR 36.811
- 2273: RP#52 completed / Impacted TSs and TRs: 36.101, 36.104, 36.113, 36.124, 36.133, 36.141, 36.307, 36.811
- 2274: RP#54 completed / Impacted TSs and TRs: 36.508, 36.521-1, 36.521-2, 36.521-3, 36.523-1, 36.523-2, 36.523-3

| ID | WBS | Task | Duration | Start | Finish | Complete | Baseline start | Baseline finish | Baseline duration | Constraint | Resources | Work | Actual work | Acronym | PCG approved | WI rapporteur name | WI rapporteur e-mail | Release | TSG approved | MCC resp | Acronym_3GU_Export | Status Report | Special Focus Doc |
| --- | --- | --- | --- | --- | --- | --- | --- | --- | --- | --- | --- | --- | --- | --- | --- | --- | --- | --- | --- | --- | --- | --- | --- |
| 2275 | 565 | **Adding L-Band (Band 24) LTE for Ancillary Terrestrial Component (ATC) of Mobile Satellite Service (MSS) in North America** | 463d? | 2009-12-11 A | 2011-09-16 A | 100% | 2009-12-11 | 2011-09-16 | 463d? |  | R4; R2; R5 | 18864h | 18864h | L_Band_LTE_ATC_MSS | PCG-24 | LightSquared | Eric.Jacks@lightsquared.com, Maqbool.Aliani@lightsquared.com | Rel-10 | RP-47 | Issam | L_Band_LTE_ATC_MSS |  |  |
| 2276 | 565.1 | Core part: Adding L-Band (Band 24) LTE for ATC of MSS in North America | 261d? | 2009-12-11 A | 2010-12-10 A | 100% | 2009-12-11 | 2010-12-10 | 261d? | finish no earlier than 2010-12-10 | R4; R2 | 4176h | 4176h | L_Band_LTE_ATC_MSS-Core | PCG-24 | LightSquared | Eric.Jacks@lightsquared.com, Maqbool.Aliani@lightsquared.com | Rel-10 | RP-47 | Issam | L_Band_LTE_ATC_MSS-Core | RP-101117 |  |
| 2277 | 565.2 | Perf. part: Adding L-Band (Band 24) LTE for ATC of MSS in North America | 316d? | 2010-03-19 A | 2011-06-03 A | 100% | 2010-03-19 | 2011-06-03 | 316d? | finish no earlier than 2011-06-03 | R4 | 2528h | 2528h | L_Band_LTE_ATC_MSS-Perf | PCG-24 | LightSquared | Eric.Jacks@lightsquared.com, Maqbool.Aliani@lightsquared.com | Rel-10 | RP-47 | Issam | L_Band_LTE_ATC_MSS-Perf | RP-110548 |  |
| 2278 | 565.3 | Test part: Adding L-Band (Band 24) LTE for ATC of MSS in North America | 131d? | 2011-03-18 A | 2011-09-16 A | 100% | 2011-03-18 | 2011-09-16 | 131d? | finish no earlier than 2011-09-16 | R5 | 1048h | 1048h | L_Band_LTE_ATC_MSS-UEConTest | PCG-26 | LightSquared | masoud.olfat@lightsquared.com | Rel-10 | RP-51 | Ingbert | L_Band_LTE_ATC_MSS-UEConTest | RP-110980 |  |
| 2279 | 566 | **LTE Self Optimizing Networks (SON) enhancements** | 316d? | 2010-03-19 A | 2011-06-03 A | 100% | 2010-03-19 | 2011-06-03 | 316d? |  | R3; R2; R4 | 15168h | 15168h | SONenh_LTE | PCG-24 | Nokia Siemens Networks | krzysztof.kordybach@nsn.com | Rel-10 | RP-47 | Juha | SONenh_LTE |  | SON |
| 2280 | 566.1 | Core part: LTE Self Optimizing Networks (SON) enhancements | 316d? | 2010-03-19 A | 2011-06-03 A | 100% | 2010-03-19 | 2011-06-03 | 316d? | finish no earlier than 2011-06-03 | R3; R2; R4 | 7584h | 7584h | SONenh_LTE-Core | PCG-24 | Nokia Siemens Networks | krzysztof.kordybach@nsn.com | Rel-10 | RP-47 | Juha | SONenh_LTE-Core | RP-110547 | SON |
| 2281 | 567 | **Further enhancements to MBMS for LTE** | 459d? | 2010-06-04 A | 2012-03-02 A | 100% | 2010-06-04 | 2012-03-02 | 459d? |  | R2; R3; R5 | 14840h | 14840h | MBMS_LTE_enh | PCG-25 | Huawei | Ms Zhao Junhui (zhaojh@huawei.com) | Rel-10 | RP-48 | Yong-Jun | MBMS_LTE_enh |  |  |
| 2282 | 567.1 | Core part: Further enhancements to MBMS for LTE | 206d? | 2010-06-04 A | 2011-03-18 A | 100% | 2010-06-04 | 2011-03-18 | 206d? | finish no earlier than 2011-03-18 | R2; R3 | 3296h | 3296h | MBMS_LTE_enh-Core | PCG-25 | Huawei | Ms Zhao Junhui (zhaojh@huawei.com) | Rel-10 | RP-48 | Yong-Jun | MBMS_LTE_enh-Core | RP-110083 |  |
| 2283 | 567.2 | Test part: Further enhancements to MBMS for LTE | 66d? | 2011-12-02 A | 2012-03-02 A | 100% | 2011-12-02 | 2012-03-02 | 66d? | finish no earlier than 2012-03-02 | R5 | 528h | 528h | MBMS_LTE_enh-UEConTest | PCG-28 | Huawei | Zhang Xin (suzanna.zhang@huawei.com) | Rel-10 | RP-54 | Ingbert | MBMS_LTE_enh-UEConTest | RP-120049 |  |
| 2284 | 568 | **UMTS/LTE 3500 MHz** | 1456d? | 2007-11-30 A | 2013-06-14 A | 100% | 2007-11-30 | 2013-06-14 | 1456d? |  | R4; R2; R3; R5 | 87360h | 87360h | RInImp8-UMTSLTE3500 | PCG-21 | Ericsson | johan.skold@ericsson.com | Rel-10 | RP-38 | Issam | RInImp8-UMTSLTE3500 |  |  |
| 2285 | 568.1 | Core part: UMTS/LTE 3500 MHz | 994d? | 2007-11-30 A | 2011-09-16 A | 100% | 2007-11-30 | 2011-09-16 | 994d? | finish no earlier than 2011-09-16 | R4; R2; R3 | 23856h | 23856h | RInImp8-UMTSLTE3500 | PCG-21 | Ericsson | johan.skold@ericsson.com | Rel-10 | RP-38 | Issam | RInImp8-UMTSLTE3500 | RP-110987 |  |
| 2286 | 568.2 | Conformance Test Aspects – LTE 3500 | 1189d? | 2008-12-05 A | 2013-06-14 A | 100% | 2008-12-05 | 2013-06-14 | 1189d? | finish no earlier than 2013-06-14 | R5 | 9512h | 9512h | LTE-UEConTest_LTE3500 | PCG-22 | Ericsson | fredrik.sundstrom@ericsson.com | Rel-10 | RP-42 | Ingbert | LTE-UEConTest_LTE3500 | RP-130461 |  |
| 2287 | 568.3 | Conformance Test Aspects – UMTS 3500 | 925d? | 2008-12-05 A | 2012-06-15 A | 100% | 2008-12-05 | 2012-06-15 | 925d? | finish no earlier than 2012-06-15 | R5 | 7400h | 7400h | RInImp-UEConTest_UMTS3500 | PCG-22 | Ericsson | fredrik.sundstrom@ericsson.com | Rel-10 | RP-42 | Ingbert | RInImp-UEConTest_UMTS3500 | RP-120450 |  |
| 2288 | 569 | **Minimization of Drive Tests for E-UTRAN and UTRAN** | 854d? | 2009-12-04 A | 2013-03-01 A | 100% | 2009-12-04 | 2013-03-01 | 854d? |  | R2; R4; R3; R5 | 39784h | 39784h | MDT_UMTSLTE | PCG-24 | Nokia Siemens Networks | malgorzata.tomala@nsn.com | Rel-10 | RP-46 | Yong-Jun | MDT_UMTSLTE |  |  |
| 2289 | 569.1 | Core part: Minimization of Drive Tests for E-UTRAN and UTRAN | 391d? | 2009-12-04 A | 2011-06-03 A | 100% | 2009-12-04 | 2011-06-03 | 391d? | finish no earlier than 2011-06-03 | R2; R4; R3 | 9384h | 9384h | MDT_UMTSLTE-Core | PCG-24 | Nokia Siemens Networks | malgorzata.tomala@nsn.com | Rel-10 | RP-46 | Yong-Jun | MDT_UMTSLTE-Core | RP-110528 |  |
| 2290 | 569.2 | Test part: Minimization of Drive Tests for E-UTRAN | 384d? | 2011-09-19 A | 2013-03-01 A | 100% | 2011-09-19 | 2013-03-01 | 384d? | finish no earlier than 2013-03-01 | R5 | 3072h | 3072h | MDT_UMTSLTE-UEConTest | PCG-27 | Ericsson | leif.mattisson@ericsson.com | Rel-10 | RP-53 | Ingbert | MDT_UMTSLTE-UEConTest | RP-130036 |  |
| 2291 | 570 | **HNB and HeNB Mobility Enhancements** | 718d? | 2010-03-19 A | 2012-12-07 A | 100% | 2010-03-19 | 2012-12-07 | 718d? |  | R3; R2; R5 | 23016h | 23016h | HNB_HENB_mob_enh | PCG-24 | Alcatel-Lucent | Martin,Warner@alcatel-lucent.com | Rel-10 | RP-47 | Juha | HNB_HENB_mob_enh |  | HNB |
| 2292 | 570.1 | Core part: HNB and HeNB Mobility Enhancements | 261d? | 2010-03-19 A | 2011-03-18 A | 100% | 2010-03-19 | 2011-03-18 | 261d? | start no earlier than 2010-03-19 | R3; R2 | 4176h | 4176h | HNB_HENB_mob_enh-Core | PCG-24 | Alcatel-Lucent | Martin.Warner@alcatel-lucent.com | Rel-10 | RP-47 | Juha | HNB_HENB_mob_enh-Core | RP-110058 | HNB |
| 2293 | 570.2 | Test part: HeNB Mobility Enhancements | 201d? | 2012-03-05 A | 2012-12-07 A | 100% | 2012-03-05 | 2012-12-07 | 201d? | finish no earlier than 2012-12-07 | R5 | 1608h | 1608h | HNB_HENB_mob_enh-UEConTest_LTE | PCG-28 | Qualcomm | Anjali Mishra (ajha@qualcom.com) | Rel-10 | RP-55 | Ingbert | HNB_HENB_mob_enh-UEConTest_LTE | RP-121533 | HNB |
| 2294 | 571 | **Expanded 1900 MHz Band for UTRA and LTE** | 596d? | 2010-06-04 A | 2012-09-07 A | 100% | 2010-06-04 | 2012-09-07 | 596d? |  | R4; R2; R5 | 25312h | 25312h | E1900 | PCG-25 | Sprint | nick.j.baustert@sprint.com | Rel-10 | RP-48 | Issam | E1900 |  |  |
| 2295 | 571.1 | Core part: Expanded 1900 MHz Band for UTRA and LTE | 261d? | 2010-06-04 A | 2011-06-03 A | 100% | 2010-06-04 | 2011-06-03 | 261d? | finish no earlier than 2011-06-03 | R4; R2 | 4176h | 4176h | E1900-Core | PCG-25 | Sprint | nick.j.baustert@sprint.com | Rel-10 | RP-48 | Issam | E1900-Core | RP-110529 |  |
| 2296 | 571.2 | Perf. part: Expanded 1900 MHz Band for UTRA and LTE | 261d? | 2010-06-04 A | 2011-06-03 A | 100% | 2010-06-04 | 2011-06-03 | 261d? | finish no earlier than 2011-06-03 | R4; R2 | 4176h | 4176h | E1900-Perf | PCG-25 | Sprint | nick.j.baustert@sprint.com | Rel-10 | RP-48 | Issam | E1900-Perf | RP-110530 |  |
| 2297 | 571.3 | Test part: Expanded 1900 MHz Band for UTRA and LTE | 333d? | 2011-06-07 A | 2012-09-07 A | 100% | 2011-06-07 | 2012-09-07 | 333d? | finish no earlier than 2012-09-07 | R5 | 2656h | 2656h | E1900-UEConTest | PCG-27 | Sprint | nick.j.baustert@sprint.com | Rel-10 | RP-52 | Ingbert | E1900-UEConTest | RP-120957 |  |
| 2298 | 572 | **Multi-Standard Radio Base Station RF requirements for non-contiguous spectrum deployments** | 389d? | 2010-06-04 A | 2011-11-25 A | 100% | 2010-06-04 | 2011-11-25 | 389d? |  | R4; G1 | 16160h | 16160h | MSR_NC | PCG-25 | Ericsson | johan.skold@ericsson.com | Rel-10 | RP-48 | Issam | MSR_NC |  |  |
| 2299 | 572.1 | Core part: Multi-Standard Radio BS RF requirements for non-contiguous spectrum deployments | 261d? | 2010-06-04 A | 2011-06-03 A | 100% | 2010-06-04 | 2011-06-03 | 261d? | finish no earlier than 2011-06-03 | R4 | 2088h | 2088h | MSR_NC-Core | PCG-25 | Ericsson | johan.skold@ericsson.com | Rel-10 | RP-48 | Issam | MSR_NC-Core | RP-110531 |  |
| 2300 | 572.2 | Perf. part: Multi-Standard Radio BS RF requirements for non-contiguous spectrum deployments | 336d? | 2010-06-04 A | 2011-09-16 A | 100% | 2010-06-04 | 2011-09-16 | 336d? | finish no earlier than 2011-09-16 | R4 | 2688h | 2688h | MSR_NC-Perf | PCG-25 | Ericsson | johan.skold@ericsson.com | Rel-10 | RP-48 | Issam | MSR_NC-Perf | RP-110988 |  |

Notes:
- 2275: RP#53 completed / Impacted TSs and TRs: LTE
- 2276: RP#51 completed / Impacted TSs and TRs: 25.101, 25.104, 25.141, 25.461, 25.466, 34.124, 36.101, 36.104, 36.113, 36.124, 36.133, 36.307, 37.104, 37.141, new RAN4 TR 36.813
- 2277: RP#52 completed / Impacted TSs and TRs: 34.121-1, 36.101, 36.104, 36.113, 36.124, 36.133, 36.141, 36.307, 36.521-1, 36.813
- 2278: RP#53 completed / Impacted TSs and TRs: 36.508, 36.521-1, 36.521-2, 36.521-3, 36.523-2
- 2279: RP#52 completed / Impacted TSs and TRs: LTE
- 2280: RP#52 completed (Stage 1,2,3) / Impacted TSs and TRs: 36.300, 36.331, 36.413, 36.423
- 2281: RP#51 completed. SA2 decided not to support MBR>GBR in Rel-10 MBMS. For SA2, MBR=GBR in Rel-10 MBMS. Hence RAN removed enabling statistical multiplexing gains for variable bit rate services in Objectives / Impacted TSs and TRs: LTE
- 2282: RP#51 completed / Impacted TSs and TRs: 25.446, 36.300, 36.321, 36.322, 36.323, 36.331, 36.440, 36.441, 36.442, 36.443, 36.444, 36.445
- 2283: RP#55 completed / Impacted TSs and TRs: 36.508, 36.523-1, 36.523-2, 36.523-3
- 2284: - / Impacted TSs and TRs: UTRA, LTE
- 2285: RP#53 completed. TR 37.801v200 for Approval / Impacted TSs and TRs: 25.101, 25.104, 25.113, 25.133, 25.141, 25.307, 25.307, 25.331, 25.461, 25.463, 34.124, 36.101, 36.104, 36.113, 36.141, 36.331, new 37.801
- 2286: RP#60 completed / Impacted TSs and TRs: 36.508, 36.521-1, 36.521-2, 36.521-3
- 2287: RP#56 completed / Impacted TSs and TRs: 34.108, 34.121-1, 34.121-2
- 2288: Triggered by UID_430021 TR 36.805 (Study on Minimization of drive-tests in NGN) / Impacted TSs and TRs: UTRA, LTE
- 2289: RP#52 completed / Impacted TSs and TRs: 25.133, 25.215, 25.304, 25.331, 25.423, 36.133, 36.214, 36.300, 36.304, 36.331, 36.413, 36.423, new 37.320 (Stage 2)
- 2290: RP#59 completed. Testing for LTE only / Impacted TSs and TRs: LTE 34.108, 34.109, 34.123-1, 34.123-2, 34.123-3, 36.508, 36.509, 36.523-1, 36.523-2, 36.523-3
- 2291: - / Impacted TSs and TRs: UTRA, LTE
- 2292: RP#51 completed / Impacted TSs and TRs: 25.413, 25.467, 25.469, 36.300, 36.413, 36.423, new 25.471
- 2293: RP#58 completed / Impacted TSs and TRs: 34.108, 34.123-1, 34.123-2, 34.123-3, 36.508, 36.523-1, 36.523-2, 36.523-3
- 2294: Expand UTRA and E-UTRA band 2 to include frequencies between 1910 1915 MHz and 1990-1995 MHz (US FCC allocation) / Impacted TSs and TRs: UTRA, LTE
- 2295: RP#52 completed / Impacted TSs and TRs: 25.101, 25.104, 25.113, 25.133, 25.141, 25.461, 25.466, 36.101, 36.104, 36.113, 36.124, 36.133, 36.141, 36.307, 36.331, new TR 36.818
- 2296: RP#52 completed / Impacted TSs and TRs: 25.101, 25.104, 25.113, 25.133, 25.141, 25.461, 25.466, 36.101, 36.104, 36.113, 36.124, 36.133, 36.141, 36.307, 36.331, new TR 36.818
- 2297: RP#57 completed / Impacted TSs and TRs: 34.108, 34.121-1, 34.121-2, 34.123-1, 34.123-2, 34.123-3, 36.508, 36.521-1, 36.521-2, 36.521-3, 36.523-1, 36.523-2, 36.523-3
- 2298: - / Impacted TSs and TRs: UTRA, LTE, GERAN
- 2299: RP#52 completed / Impacted TSs and TRs: 25.104, 36.104, 37.104, new TR 37.802
- 2300: RP#53 completed / Impacted TSs and TRs: 25.141, 36.141, 37.141, 37.802

| ID | WBS | Task | Type | Duration | Start | Finish | Complete | Remaining | Baseline start | Baseline finish | Baseline duration | Total slack | Constraint | Resources | Work | Actual work | Acronym | PCG approved | WI rapporteur name | WI rapporteur e-mail | Release | TSG approved | MCC resp | Acronym_3GU_Export | Impacted TSs and TRs | PCG stopped | TSG stopped | Status Report | Special Focus Doc |
| --- | --- | --- | --- | --- | --- | --- | --- | --- | --- | --- | --- | --- | --- | --- | --- | --- | --- | --- | --- | --- | --- | --- | --- | --- | --- | --- | --- | --- | --- |
| 2301 | 572.3 | **GERAN part: Multi-Standard Radio BS RF requirements for non-contiguous spectrum deployments** |  | 324d? | 2010-09-03 A | 2011-11-25 A | 100% |  | 2010-09-03 | 2011-11-25 | 324d? |  |  | G1 | 5160h | 5160h | MSR_NC-GERAN | PCG-25 | Ericsson | mats.y.samuelsson@ericsson.com | Rel-10 | GP-47 | Paolo | MSR_NC-GERAN |  |  |  |  |  |
| 2302 | 572.3.1 | GERAN Core part: Multi-Standard Radio BS RF requirements for non-contiguous spectrum deployments |  | 261d? | 2010-09-03 A | 2011-09-02 A | 100% |  | 2010-09-03 | 2011-09-02 | 261d? |  | finish no earlier than 2011-09-02 | G1 | 2088h | 2088h | MSR_NC-GERAN | PCG-25 | Ericsson | mats.y.samuelsson@ericsson.com | Rel-10 | GP-47 | Paolo |  | 45.005 |  |  |  |  |
| 2303 | 572.3.2 | GERAN BS Test part: Multi-Standard Radio BS RF requirements for non-contiguous spectrum deployments |  | 62d? | 2011-09-02 A | 2011-11-25 A | 100% |  | 2011-09-02 | 2011-11-25 | 62d? |  | finish no earlier than 2011-11-25 | G1 | 496h | 496h | MSR_NC-GERAN | PCG-28 | Ericsson | mats.y.samuelsson@ericsson.com | Rel-10 | GP-52 | Paolo |  | 51.021 |  |  |  |  |
| 2304 | 573 | (Small) Technical Enhancements and Improvements for Rel-10 |  | 470d? | 2009-06-04 A | 2011-03-23 A | 100% |  | 2009-06-04 | 2011-03-23 | 470d? |  | finish no earlier than 2011-03-23 | SP; CP; RP; GP | 15040h | 15040h | TEI10 | PCG-23 |  |  | Rel-10 | SP-44 |  | TEI10 |  |  |  |  |  |
| 2305 | 574 | (IETF) (Small) Technical Enhancements and Improvements for Rel-10 (draft-atarius) |  | 1244d? | 2009-06-04 A | 2014-12-09 | 75% | 312.5d? | 2009-06-04 | 2014-12-05 | 1242d? | 657d | finish no earlier than 2014-12-09 | C1-IETF | 9952h | 7452h | TEI10_IETF | PCG-27 | Andrew Allen | Andrew Allen | Rel-10 | CP-52 | Frederic | TEI10_IETF | draft-atarius-dispatch-meid-urn |  |  |  |  |
| 2306 | 575 | (IETF) (Small) Technical Enhancements and Improvements for Rel-10 (RFC6275) |  | 562d? | 2009-06-04 A | 2011-07-29 A | 100% |  | 2009-06-04 | 2011-07-29 | 562d? |  | finish no earlier than 2011-07-29 | C1-IETF | 4496h | 4496h | TEI10_IETF1 | PCG-27 |  |  | Rel-10 | CP-53 | Frederic | TEI10_IETF1 | RFC 6275 (was draft-ietf-mext-rfc3775bis) |  |  |  |  |
| 2307 | 576 | Test - (Small) Technical Enhancements and Improvements for Rel-10 |  | 271d? | 2011-12-01 A | 2012-12-07 A | 100% |  | 2011-12-01 | 2012-12-07 | 271d? |  | finish no earlier than 2012-12-07 | R5; G3new | 4336h | 4336h | TEI10_Test | PCG-28 | n/a |  | Rel-10 | RP-54 | Ingbert | TEI10_Test |  |  |  |  |  |
| 2308 | 577 | **Deleted - Registration in Densely-populated area (RED)** |  | 665d? | 2007-03-12 A | 2009-09-24 A | 100% |  | 2007-03-12 | 2009-09-24 | 665d? |  |  | S1 | 9544h | 9544h | RED |  | NTT DoCoMo | tanakai@nttdocomo.co.jp | Rel-10 | SP-35 | Alain | RED |  | PCG-24 | SP-46 |  |  |
| 2309 | 577.1 | Deleted - Stage 1 for RED |  | 4d? | 2007-03-12 A | 2007-03-15 A | 100% |  | 2007-03-12 | 2007-03-15 | 4d? |  | start no earlier than 2007-03-12 | S1 | 32h | 32h | RED |  | NTT DoCoMo | takakurat@s1.nttdocomo.co.jp | Rel-10 | SP-35 | Alain |  | 22.101 CR#0207 | PCG-24 | SP-46 |  |  |
| 2310 | 577.2 | Deleted - Stage 2 for RED |  | 524d? | 2007-09-25 A | 2009-09-24 A | 100% |  | 2007-09-25 | 2009-09-24 | 524d? |  | finish no earlier than 2009-09-24 | S2 | 4192h | 4192h | RED |  | NTT DoCoMo | tanakai@nttdocomo.co.jp | Rel-10 | SP-37 | Maurice |  | draft TR 23.880 withdrawn, 23.002, 23.060, 23.221, 23.236 | PCG-23 | SP-45 |  |  |
| 2311 | 578 | **Deleted - Network Selection for non-3GPP Access** |  | 471d? | 2007-12-07 A | 2009-09-24 A | 100% |  | 2007-12-07 | 2009-09-24 | 471d? |  |  | S1; C6 | 15072h | 15072h | N3GtoNSP | PCG-21 | Telefónica O2 | chris.friel@O2.com | Rel-10 | SP-38 | Alain | N3GtoNSP |  | PCG-23 | SP-45 |  |  |
| 2312 | 578.1 | Deleted - Stage 1 for N3GtoNSP |  | 471d? | 2007-12-07 A | 2009-09-24 A | 100% |  | 2007-12-07 | 2009-09-24 | 471d? |  | finish no earlier than 2009-12-10 | S1 | 3768h | 3768h | N3GtoNSP | PCG-21 | Telefónica O2 | chris.friel@O2.com | Rel-10 | SP-38 | Alain |  | 22.011 | PCG-23 | SP-45 |  |  |
| 2313 | 578.2 | Deleted - CT6 issues for N3GtoNSP |  | 471d? | 2007-12-07 A | 2009-09-24 A | 100% |  | 2007-12-07 | 2009-09-24 | 471d? |  | finish no earlier than 2009-12-04 | C6 | 3768h | 3768h | N3GtoNSP | PCG-21 | Telefónica O2 | chris.friel@O2.com | Rel-10 | CP-38 | Xavier |  | 36.300 | PCG-23 | CP-45 |  |  |
| 2314 | 579 | **Deleted - GTP-based S8 chaining** |  | 337d? | 2008-12-11 A | 2010-03-25 A | 100% |  | 2008-12-11 | 2010-03-25 | 337d? |  |  | S2 | 5392h | 5392h | GTPchaining | PCG-22 | Huawei | Haining Wang (wanghaining@huawei.com) | Rel-10 | SP-42 | Maurice | GTPchaining |  | PCG-24 | SP-47 |  |  |
| 2315 | 579.1 | Deleted - Stage 2 for GTPchaining |  | 337d? | 2008-12-11 A | 2010-03-25 A | 100% |  | 2008-12-11 | 2010-03-25 | 337d? |  | finish no earlier than 2010-03-25 | S2 | 2696h | 2696h | GTPchaining | PCG-22 | Huawei | Haining Wang (wanghaining@huawei.com) | Rel-10 | SP-42 | Maurice |  | 23.402 | PCG-24 | SP-47 |  |  |
| 2316 | 580 | Deleted - UTRAN 2 ms TTI uplink range improvement |  | 272d? | 2009-03-06 A | 2010-03-19 A | 100% |  | 2009-03-06 | 2010-03-19 | 272d? |  | finish no earlier than 2010-03-19 | R1; R2; R3; R4 | 8704h | 8704h | RANimp-2mTTI_ULimp | PCG-22 | Nokia Siemens Networks | Karri Ranta-aho (karri.ranta-aho@nsn.com) | Rel-10 | RP-43 | Patrick | RANimp-2mTTI_ULimp | 25.133, 25.212, 25.214, 25.321, 25.331 | PCG-24 | RP-47 | RP-100040 |  |
| 2317 | 581 | Deleted - Enhanced Home NodeB / eNodeB continuation of Rel-9 |  | 337d? | 2008-12-11 A | 2010-03-25 A | 100% |  | 2008-12-11 | 2010-03-25 | 337d? |  |  | S2 | 2696h | 2696h | eEHNB | PCG-23 | Alcatel-Lucent | Nicolas Drevon | Rel-10 | SP-44 | Maurice | eEHNB |  | PCG-24 | SP-47 |  | HNB |
| 2318 | 582 | **Deleted - Fixed Wireless Customer-Premises Equipment (CPE) RF Requirements** |  | 391d? | 2009-12-04 A | 2011-06-03 A | 100% |  | 2009-12-04 | 2011-06-03 | 391d? |  |  | R4; R5 | 12512h | 12512h | FW_CPE_RF | PCG-24 | Verizon Wireless | zheng.zhao@verizonwireless.com | Rel-10 | RP-46 | Issam | FW_CPE_RF | LTE | PCG-27 | RP-52 |  |  |
| 2319 | 582.1 | Deleted - Core part: Fixed Wireless Customer-Premises Equipment (CPE) RF Requirements |  | 391d? | 2009-12-04 A | 2011-06-03 A | 100% |  | 2009-12-04 | 2011-06-03 | 391d? |  | finish no earlier than 2011-06-03 | R4 | 3128h | 3128h | FW_CPE_RF-Core | PCG-24 | Verizon Wireless | zheng.zhao@verizonwireless.com | Rel-10 | RP-46 | Issam | FW_CPE_RF-Core | 36.101 | PCG-27 | RP-52 | RP-110539 |  |
| 2320 | 582.2 | Deleted - Test part: Fixed Wireless Customer-Premises Equipment (CPE) RF Requirements |  | 391d? | 2009-12-04 A | 2011-06-03 A | 100% |  | 2009-12-04 | 2011-06-03 | 391d? |  | finish no earlier than 2011-06-03 | R5 | 3128h | 3128h | FW_CPE_RF-UEConTest | PCG-24 | Verizon Wireless | zheng.zhao@verizonwireless.com | Rel-10 | RP-46 | Ingbert | FW_CPE_RF-UEConTest | 36.521-1 | PCG-27 | RP-52 | RP-110504 |  |
| 2321 | 583 | **Deleted - Latency reductions for LTE** |  | 266d? | 2009-12-04 A | 2010-12-10 A | 100% |  | 2009-12-04 | 2010-12-10 | 266d? |  |  | R2; R1 | 8512h | 8512h | LTE_LATRED | PCG-24 | Ericsson | henrik.enbuske@ericsson.com | Rel-10 | RP-46 | Yong-Jun | LTE_LATRED | LTE | PCG-26 | RP-50 |  |  |
| 2322 | 583.1 | Deleted - Core part: Latency reductions for LTE |  | 266d? | 2009-12-04 A | 2010-12-10 A | 100% |  | 2009-12-04 | 2010-12-10 | 266d? |  | finish no earlier than 2010-12-10 | R2; R1 | 4256h | 4256h | LTE_LATRED-Core | PCG-24 | Ericsson | henrik.enbuske@ericsson.com | Rel-10 | RP-46 | Yong-Jun | LTE_LATRED-Core | 36.213, 36.300, 36.306, 36.321, 36.331 | PCG-26 | RP-50 | RP-101112 |  |
| 2323 | 584 | **Deleted - Enhanced Interference Management for Home NodeBs** |  | 131d? | 2010-03-19 A | 2010-09-17 A | 100% |  | 2010-03-19 | 2010-09-17 | 131d? |  |  | R3 | 2096h | 2096h | HNB_IM | PCG-24 | Qualcomm | Andrei Radulescu (aradules@qualcomm.com) | Rel-10 | RP-47 | Juha | HNB_IM | UTRA | PCG-25 | RP-49 | RP-100754 | HNB |
| 2324 | 584.1 | Deleted - Core part: Enhanced Interference Management for Home NodeBs |  | 131d? | 2010-03-19 A | 2010-09-17 A | 100% |  | 2010-03-19 | 2010-09-17 | 131d? |  | finish no earlier than 2010-09-17 | R3 | 1048h | 1048h | HNB_IM-Core | PCG-24 | Qualcomm | Andrei Radulescu (aradules@qualcomm.com) | Rel-10 | RP-47 | Juha | HNB_IM-Core | 25.413, 25.467, 25.469 | PCG-25 | RP-49 | RP-100754 | HNB |
| 2325 | 585 | Release 10 Studies | milestone | 0d? | 2009-03-12 A | 2009-03-12 A | 100% |  | 2009-03-12 | 2011-03-23 | 531d? |  | finish no earlier than 2011-03-23 | CP; GP; RP; SP |  |  |  |  |  |  | Rel-10 |  |  |  |  |  |  |  |  |

Notes:
- 2301: -
- 2302: GP#51 completed. GP#47 approved WID
- 2303: GP#52 completed
- 2304: -
- 2305: Not completed internet-draft, waiting for draft-montemurro to complete
- 2306: SP#53/IETF#81: RFC 6275 completed
- 2307: -
- 2308: SP#35 Stage 1 completed. SP#45 Stage 2 work stopped. SP#46 work stopped/abandoned
- 2309: SP#35 completed. SP#46 work stopped/abandoned
- 2310: SP#45 Stage 2 work stopped
- 2311: SP#45 work stopped/abandoned
- 2312: SP#45 work stopped/abandoned
- 2313: SP#45 work stopped/abandoned
- 2314: SP#47 work stopped (depending on ongoing related CT4 work). Stage 1 in UID_320022 Rel-8 Requirements for evolution of the 3GPP system architecture (AIPN-SAE): 22.278, 22.011, 22.246
- 2315: SP#47 work stopped
- 2316: RP#47 work stopped/abandoned (no CR approved). Cell sets the TTI (Transmission Time Interval) to 2 ms
- 2317: SP#47 deleted (SA2 work moved under SA1 UID_450053). SP#44 Umbrella Feature created to host WIs moved out of Rel-9 (SA2 UID_420034 on IMS aspects of Architecture for Home NodeB)
- 2318: RP#52 work stopped (lack of contributions). Add new power classes in E-UTRAN UL to allow CPE type applications to be operated at higher max output power
- 2319: RP#52 work stopped at 55% (lack of contributions)
- 2320: RP#52 work stopped (lack of contributions)
- 2321: RP#50 work stopped (RP-101266)
- 2322: RP#50 work stopped (RP-101266)
- 2323: RP#49 stopped (no further standardization needed). Ensure that Enhanced Interference Management methods identified in Rel-9 for HNBs do not fail in deployments with a large penetration of CSG-aware UEs
- 2324: RP#49 stopped (no further standardization needed)
- 2325: -

| ID | WBS | Task | Type | Duration | Start | Finish | Complete | Baseline start | Baseline finish | Baseline duration | Constraint | Resources | Work | Actual work | Acronym | Impacted TSs and TRs | WI rapporteur name | Release | TSG approved | MCC resp | Acronym_3GU_Export | PCG approved | Status Report | PCG stopped | TSG stopped |
| --- | --- | --- | --- | --- | --- | --- | --- | --- | --- | --- | --- | --- | --- | --- | --- | --- | --- | --- | --- | --- | --- | --- | --- | --- | --- |
| 2326 | 586 | **Study on enhanced voice service requirements for the Evolved Packet System (EPS)** |  | 670d? | 2007-09-03 A | 2010-03-25 A | 100% | 2007-09-03 | 2010-03-25 | 670d? |  | S1; S4 | 18744h | 18744h | FS_EV_EPS | 22.813 | France Telecom | Rel-10 | SP-37 | Alain | FS_EV_EPS |  |  |  |  |
| 2327 | 586.1 | Use cases definition and service and system requirements |  | 334d? | 2007-09-03 A | 2008-12-11 A | 100% | 2007-09-03 | 2008-12-11 | 334d? | finish no earlier than 2008-12-11 | S1 | 2672h | 2672h | FS_EV_EPS-S1 | 22.813 | France Telecom | Rel-10 | SP-37 | Alain | FS_EV_EPS-S1 |  |  |  |  |
| 2328 | 586.2 | Codec specific part of FS_EV_EPS |  | 669d? | 2007-09-03 A | 2010-03-25 A | 100% | 2007-09-03 | 2010-03-25 | 669d? | finish no earlier than 2010-03-25 | S4 | 5352h | 5352h | FS_EV_EPS-S4 | 22.813 | Ericsson | Rel-10 | SP-37 | Paolo | FS_EV_EPS-S4 |  |  |  |  |
| 2329 | 587 | Study on advanced requirements for IP interconnect |  | 528d? | 2007-12-04 A | 2009-12-10 A | 100% | 2007-12-04 | 2009-12-10 | 528d? | finish no earlier than 2009-12-10 | S1 | 4224h | 4224h | FS_IPXS | 22.893 | Telefónica O2 | Rel-10 | SP-38 | Alain | FS_IPXS | PCG-21 |  |  |  |
| 2330 | 588 | Study on Personal Broadcast Service |  | 397d? | 2008-09-18 A | 2010-03-25 A | 100% | 2008-09-18 | 2010-03-25 | 397d? | finish no earlier than 2010-03-25 | S1 | 3168h | 3168h | FS_PBS | 22.947 | ETRI | Rel-10 | SP-41 | Alain | FS_PBS | PCG-21 |  |  |  |
| 2331 | 589 | Study on LCS support in SAE for non-3GPP accesses |  | 397d? | 2008-09-18 A | 2010-03-25 A | 100% | 2008-09-18 | 2010-03-25 | 397d? | finish no earlier than 2010-03-25 | S1 | 3168h | 3168h | FS_LCS_n3GPP | 22.814 | SK Telecom | Rel-10 | SP-41 | Alain | FS_LCS_n3GPP | PCG-21 |  |  |  |
| 2332 | 590 | Study on Haptic Services |  | 272d? | 2009-03-12 A | 2010-03-25 A | 100% | 2009-03-12 | 2010-03-25 | 272d? | finish no earlier than 2010-03-25 | S1 | 2168h | 2168h | FS_Haptics | 22.987 | SK Telecom | Rel-10 | SP-43 | Alain | FS_Haptics | PCG-22 |  |  |  |
| 2333 | 591 | Study on System enhancements for the use of IMS services in Local BreakOut and Optimal Routing of Media |  | 575d? | 2007-10-01 A | 2009-12-10 A | 100% | 2007-10-01 | 2009-12-10 | 575d? | finish no earlier than 2009-12-10 | S2 | 4600h | 4600h | FS_IMS_LBO_ORM | 23.894 | Telecom Italia, BT | Rel-10 | SP-37 | Maurice | FS_IMS_LBO_ORM |  |  |  |  |
| 2334 | 592 | Study on Intra Domain Connection of RAN Nodes to Multiple CN Nodes |  | 533d? | 2008-03-12 A | 2010-03-25 A | 100% | 2008-03-12 | 2010-03-25 | 533d? | finish no earlier than 2010-03-25 | S2 | 4264h | 4264h | FS_IDC | 23.924 (was 23.823) | China Mobile | Rel-10 | SP-39 | Maurice | FS_IDC | PCG-21 |  |  |  |
| 2335 | 593 | Study on Single Radio Voice Call Continuity enhancements |  | 341d? | 2009-06-04 A | 2010-09-23 A | 100% | 2009-06-04 | 2010-09-23 | 341d? | finish no earlier than 2010-09-23 | S2 | 2728h | 2728h | FS_eSRVCC | 23.856 | China Mobile | Rel-10 | SP-44 | Maurice | FS_eSRVCC | PCG-23 |  |  |  |
| 2336 | 594 | Study on Single Radio Video Call Continuity for 3G-CS |  | 131d? | 2010-03-25 A | 2010-09-23 A | 100% | 2010-03-25 | 2010-09-23 | 131d? | finish no earlier than 2010-09-23 | S2 | 1048h | 1048h | FS_vSRVCC | 23.886 | Samsung | Rel-10 | SP-47 | Maurice | FS_vSRVCC | PCG-24 |  |  |  |
| 2337 | 595 | Study on S2b Mobility based on GTP |  | 56d? | 2010-03-25 A | 2010-06-10 A | 100% | 2010-03-25 | 2010-06-10 | 56d? | finish no earlier than 2010-06-07 | S2 | 448h | 448h | FS_SMOG | 23.834 | Alcatel-Lucent | Rel-10 | SP-47 | Maurice | FS_SMOG | PCG-24 |  |  |  |
| 2338 | 596 | Study on Surround Sound codec extension for PSS and MBMS |  | 530d? | 2009-03-12 A | 2011-03-23 A | 100% | 2009-03-12 | 2011-03-23 | 530d? | finish no earlier than 2011-03-23 | S4 | 4240h | 4240h | FS_SS_PSS_MBMS | 26.950 | Fraunhofer Gesellschaft | Rel-10 | SP-43 | Paolo | FS_SS_PSS_MBMS | PCG-22 |  |  |  |
| 2339 | 597 | Study on Improved Video Coding Support |  | 205d? | 2010-06-10 A | 2011-03-23 A | 100% | 2010-06-10 | 2011-03-23 | 205d? | finish no earlier than 2011-03-23 | S4 | 1640h | 1640h | FS_IVCS | 26.904 | Nokia, ETRI | Rel-10 | SP-48 | Paolo | FS_IVCS | PCG-25 |  |  |  |
| 2340 | 598 | Study on Rc Reference Point Functionalities and Message Flows |  | 397d? | 2008-09-18 A | 2010-03-25 A | 100% | 2008-09-18 | 2010-03-25 | 397d? | finish no earlier than 2010-03-23 | S5 | 3170.08h | 3170.08h | FS_OAM_Rc | 32.825 | Huawei | Rel-10 | SP-41 | Mirko | FS_OAM_Rc | PCG-21 |  |  |  |
| 2341 | 599 | Study on Telecommunication Management; Energy Savings Management |  | 271d? | 2009-03-12 A | 2010-03-25 A | 100% | 2009-03-12 | 2010-03-25 | 271d? | finish no earlier than 2010-03-25 | S5 | 2168h | 2168h | FS_OAM_ESM | 32.826 | Orange, Vodafone | Rel-10 | SP-43 | Mirko | FS_OAM_ESM | PCG-22 |  |  |  |
| 2342 | 600 | Study on Integration of Device Management Information with Itf-N |  | 211d? | 2009-06-04 A | 2010-03-25 A | 100% | 2009-06-04 | 2010-03-25 | 211d? | finish no earlier than 2010-03-25 | S5 | 1688h | 1688h | FS_IDMI_Itf-N | 32.827 | Motorola | Rel-10 | SP-44 | Mirko | FS_IDMI_Itf-N | PCG-23 |  |  |  |
| 2343 | 601 | Study on Alignment of 3GPP Generic NRM IRP and TMF Shared Information Data (SID) model |  | 335d? | 2009-12-10 A | 2011-03-23 A | 100% | 2009-12-10 | 2011-03-23 | 335d? | finish no earlier than 2011-03-23 | S5 | 2680h | 2680h | FS_3GNRM_TMFSID | 32.828 | Nokia Siemens Networks | Rel-10 | SP-46 | Mirko | FS_3GNRM_TMFSID | PCG-24 |  |  |  |
| 2344 | 602 | Study on Harmonization of 3GPP Alarm IRP and TMF Interface Program (TIP) Fault Management |  | 335d? | 2009-12-10 A | 2011-03-23 A | 100% | 2009-12-10 | 2011-03-23 | 335d? | finish no earlier than 2011-03-23 | S5 | 2680h | 2680h | FS_3G_TMF_FM | 32.829 | Nokia Siemens Networks, Alcatel-Lucent | Rel-10 | SP-46 | Mirko | FS_3G_TMF_FM | PCG-24 |  |  |  |
| 2345 | 603 | Study on Alarm Correlation and Alarm Root Cause Analysis |  | 205d? | 2010-06-10 A | 2011-03-23 A | 100% | 2010-06-10 | 2011-03-23 | 205d? | finish no earlier than 2011-03-23 | S5 | 1640h | 1640h | FS_AC_ARCA | 32.832 | Ericsson | Rel-10 | SP-48 | Mirko | FS_AC_ARCA | PCG-25 |  |  |  |
| 2346 | 604 | Study on Alignment of 3GPP PM IRP and TMF Interface Program (TIP) PM |  | 205d? | 2010-06-10 A | 2011-03-23 A | 100% | 2010-06-10 | 2011-03-23 | 205d? | finish no earlier than 2011-03-23 | S5 | 1640h | 1640h | FS_3G_TMF_PM | 32.831 | Alcatel-Lucent | Rel-10 | SP-48 | Mirko | FS_3G_TMF_PM | PCG-25 |  |  |  |
| 2347 | 605 | Study on Policy and Charging Rules Function (PCRF) failure and restoration |  | 261d? | 2009-08-18 A | 2010-09-17 A | 100% | 2009-08-18 | 2010-09-17 | 261d? | finish no earlier than 2010-09-17 | C3 | 2088h | 2088h | FS_PCRF-FR | 29.816 | NEC | Rel-10 | CP-45 | Adrian | FS_PCRF-FR | PCG-23 |  |  |  |
| 2348 | 606 | Study on User Data Convergence (UDC) evolution |  | 206d? | 2010-06-04 A | 2011-03-18 A | 100% | 2010-06-04 | 2011-03-18 | 206d? | finish no earlier than 2011-03-18 | C4 | 1648h | 1648h | FS_UDCe | 23.845 | Alcatel-Lucent | Rel-10 | CP-48 | Kimmo | FS_UDCe | PCG-25 |  |  |  |
| 2349 | 607 | Study on UICC access to IMS |  | 206d? | 2010-06-04 A | 2011-03-18 A | 100% | 2010-06-04 | 2011-03-18 | 206d? | finish no earlier than 2011-03-18 | C6 | 1648h | 1648h | FS_IMS-UICC | 31.828 | Gemalto | Rel-10 | CP-48 | Xavier | FS_IMS-UICC | PCG-25 |  |  |  |
| 2350 | 608 | Study on Uplink Tx Diversity for HSPA |  | 208.4d? | 2009-08-18 A | 2010-06-04 A | 100% | 2009-08-18 | 2010-06-04 | 208.4d? | finish no earlier than 2010-06-04 | R4 | 1667.2h | 1667.2h | FS_UL-TxDiv-HSPA | UTRA 25.863 | Qualcomm | Rel-10 | RP-45 | Issam | FS_UL-TxDiv-HSPA | PCG-23 | RP-100499 |  |  |
| 2351 | 609 | Study on Solutions for Energy Saving within UTRA Node B |  | 206d? | 2009-12-04 A | 2010-09-17 A | 100% | 2009-12-04 | 2010-09-17 | 206d? | finish no earlier than 2010-09-17 | R1; R3 | 3296h | 3296h | FS_Energy_UMTS | UTRA 25.927 | Vodafone | Rel-10 | RP-46 | Patrick | FS_Energy_UMTS | PCG-24 | RP-100796 |  |  |
| 2352 | 610 | Study on Potential solutions for energy saving for E-UTRAN |  | 348.75d? | 2010-02-02 A | 2011-06-03 A | 100% | 2010-02-02 | 2011-06-03 | 348.75d? | finish no earlier than 2011-06-03 | R3; R2 | 5580h | 5580h | FS_Energy_LTE | LTE 36.927 | China Mobile | Rel-10 | RP-47 | Juha | FS_Energy_LTE | PCG-24 | RP-110597 |  |  |
| 2353 | 611 | Study on Improvements of distributed antenna for 1.28Mcps TDD |  | 200.55d? | 2010-03-05 A | 2010-12-10 A | 100% | 2010-03-05 | 2010-12-10 | 200.55d? | finish no earlier than 2010-12-10 | R1; R2; R3 | 4813.2h | 4813.2h | FS_distr_ant_LCR_TDD | UTRA 25.865 | ZTE | Rel-10 | RP-47 | Patrick | FS_distr_ant_LCR_TDD | PCG-24 | RP-101287 |  |  |
| 2354 | 612 | Deleted - Study on Unauthenticated PS Emergency Calls |  | 471d? | 2008-06-05 A | 2010-03-25 A | 100% | 2008-06-05 | 2010-03-25 | 471d? | finish no earlier than 2010-03-25 | S1 | 3768h | 3768h | FS_UAPSEC | 22.984 | Nokia Siemens Networks | Rel-10 | SP-40 | Alain | FS_UAPSEC | PCG-21 |  | PCG-24 | SP-47 |
| 2355 | 613 | Deleted - Study on enhancements to IMS border functions for IMS Interconnection of services |  | 586d? | 2008-09-18 A | 2010-12-15 A | 100% | 2008-09-18 | 2010-12-15 | 586d? | finish no earlier than 2010-12-15 | S2 | 4688h | 4688h | FS_eIMS_IBCF | 23.848 | Starent Networks | Rel-10 | SP-41 | Maurice | FS_eIMS_IBCF | PCG-21 |  | PCG-26 | SP-50 |
| 2356 | 614 | Deleted - Study on EPC Charging enhancement |  | 211d? | 2009-06-04 A | 2010-03-25 A | 100% | 2009-06-04 | 2010-03-25 | 211d? | finish no earlier than 2010-03-25 | S5 | 1688h | 1688h | FS_EPCcharg |  | Nokia Siemens Networks | Rel-10 | SP-44 | Mirko | FS_EPCcharg | PCG-23 |  | PCG-24 | SP-47 |
| 2357 | 615 | Deleted - Study on Interworking Proxy between GTP based and PMIP based interfaces |  | 186d? | 2009-09-18 A | 2010-06-04 A | 100% | 2009-09-18 | 2010-06-04 | 186d? | finish no earlier than 2010-06-04 | C4 | 1488h | 1488h | FS_GTP-MIP-IW | 29.875 | NTT DoCoMo | Rel-10 | CP-45 | Kimmo | FS_GTP-MIP-IW | PCG-23 |  | PCG-25 | CP-48 |
| 2358 | 616 | Release 9 Features | milestone | 0d? | 2000-01-01 A | 2000-01-01 A | 100% | 2000-01-01 | 2000-01-01 | 0d? |  | CP; GP; RP; SP |  |  |  |  |  | Rel-9 |  |  |  |  |  |  |  |

Notes:
- 2326: SP#47 completed. TR 22.813-100 for Approval. Spin-off Feature UID_470030 Codec for Enhanced Voice Services / WI rapporteur e-mail: philippe.lottin@orange.com
- 2327: SP#47 completed. TR 22.813-100 for Approval / WI rapporteur e-mail: philippe.lottin@orange.com
- 2328: SP#47 completed. TR 22.813-100 for Approval / WI rapporteur e-mail: stefan.bruhn@ericson.com
- 2329: SP#46 completed. Linked to Rel-8 Feature UID_380060 IP Interconnection of Services (IPinterc). Spin-off Feature Rel-11 UID_470051 Advanced IP Interconnection of Services / WI rapporteur e-mail: chris.friel@O2.com
- 2330: SP#47 completed / WI rapporteur e-mail: Jaihyung Cho
- 2331: SP#47 completed / WI rapporteur e-mail: jinhan.song@sktelecom.com
- 2332: SP#47 completed. Covers Mobile/Fixed/Cordless/etc terminals. Haptic (human-machine tactile communication) extend service offering & richness of user experience beyond current visual & auditory senses / WI rapporteur e-mail: jinhan.song@sktelecom.com
- 2333: SP#46 completed. Spin-off Feature UID_460028 Optimal Media Routeing (OMR). Linked to Study on Multimedia Session Continuity UID_350051, Study on Centralized IMS Service Control UID_330012, IMS inter-operator service interconnection interface UID_360011 / WI rapporteur e-mail: mario.madella@telecomitalia.it, victor.kueh@bt.com
- 2334: SP#47 completed. Concluded no further normative work expected. Linked to 23.236 / WI rapporteur e-mail: LIU HONG (liuhongyfw@chinamobile.com)
- 2335: SP#49 completed (Conclusion: select the SIP anchoring based solution for normative work CR (TEI10) introducing and completing stage-2). Analyzed performance of Rel-8 SRVCC solution from E-UTRAN/HSPA to UTRAN/GERAN / WI rapporteur e-mail: Hou zhiqiang (houzhiqiang@chinamobile.com), Jiang Yi (jiangyi@chinamobile.com)
- 2336: SP#49 completed. TR 23.886v100 for Approval. Related to Rel-8 UID_350030 Single Radio Voice Call Continuity for 3GPP (SAES-SRVCC). Study how to provide Video Call seamless service continuity for 3G/LTE terminal user / WI rapporteur e-mail: Haris Zisimopoulos (haris.z@samsung.com)
- 2337: SP#48 completed. Triggered by Rel-8 UID_350027 SAE for support for non-3GPP accesses. Nature of relationship: S2b one of the interfaces defined for non-3GPP accesses support in EPS. Stage 1 in Rel-8 UID_320022 (AIPN-SAE) 22.278,22.101 / WI rapporteur e-mail: bruno.landais@alcatel-lucent.com
- 2338: SP#51 completed. Extend Rel-8 UID_34043 (Extending PSS and MBMS User Services for optimized Mobile TV) / WI rapporteur e-mail: jan.plogsties@iis.franhofer.de
- 2339: SP#51 completed. Extends Rel-9 Improved Video Support for PSS and MBMS (UID_430039) / WI rapporteur e-mail: imed.bouazizi@nokia.com, jaihyung@etri.re.kr
- 2340: SP#47 completed / WI rapporteur e-mail: shan.mingjun@huawei.com
- 2341: SP#47 completed. Study result might impact Feature UID_420011 Self Organising Networks (SON) / WI rapporteur e-mail: Jean-Michel Cornilly (Orange)
- 2342: SP#47 completed / WI rapporteur e-mail: Yizhi Yao (yzyao@motorola.com)
- 2343: SP#51 completed / WI rapporteur e-mail: olaf.pollakowski@nsn.com
- 2344: SP#51 completed / WI rapporteur e-mail: olaf.pollakowski@nsn.com, Padma.Sudarsan@alcatel-lucent.com
- 2345: SP#51 completed / WI rapporteur e-mail: edwin.tse@ericsson.com
- 2346: SP#51 completed / WI rapporteur e-mail: Padma.Sudarsan@alcatel-lucent.com
- 2347: CP#49 completed / WI rapporteur e-mail: gottfried.punz@nw.neclab.eu
- 2348: CP#51 completed. Study UDC evolution from Features in Rel-9 UID_400034 and Rel-10 UID_480011 UDC Data Model / WI rapporteur e-mail: jean-jacques.trottin@alcatel-lucent.com
- 2349: CP#51 completed / WI rapporteur e-mail: Denis.Lheriteau@gemalto.com
- 2350: RP#48 completed / WI rapporteur e-mail: Heechoon Lee (heechoon@qualcomm.com)
- 2351: RP#49 completed. Based on ETSI EE TS 102 706. / WI rapporteur e-mail: Prakash.bhat@vodafone.com
- 2352: RP#52 completed / WI rapporteur e-mail: Yang Ning (yangning@chinamobile.com)
- 2353: RP#50 completed. TR 25.865 v101 for Approval / WI rapporteur e-mail: huang.he4@zte.com.cn
- 2354: SP#47 work stopped/abandoned / WI rapporteur e-mail: Juergen.Merkel@nsn.com
- 2355: SP#50 work stopped. Additional work may be addressed as part of the Rel-11 Feature UID_470051 Advanced IP Interconnection of Services (IPXS) / WI rapporteur e-mail: Rajat Ghai (rghai@starentnetworks.com)
- 2356: SP#47 work stopped. Issue covered by Rel-10 UID_460039 Charging for LIPA_SIPTO and UID_4700xy Charging for IFOM / WI rapporteur e-mail: Gerald.Goermer@nsn.com
- 2357: CP#48 work stopped/abandoned / WI rapporteur e-mail: takaaki.matsuura.sp@s1.nttdocomo.com
- 2358: -

| ID | WBS | Task | Duration | Start | Finish | Complete | Baseline start | Baseline finish | Baseline duration | Constraint | Resources | Work | Actual work | Acronym | PCG approved | WI rapporteur name | WI rapporteur e-mail | Release | TSG approved | MCC resp | Special Focus Doc | Acronym_3GU_Export | Status Report |
| --- | --- | --- | --- | --- | --- | --- | --- | --- | --- | --- | --- | --- | --- | --- | --- | --- | --- | --- | --- | --- | --- | --- | --- |
| 2359 | 617 | **Enhanced Home NodeB / eNodeB** | 921d? | 2008-06-05 A | 2011-12-09 A | 100% | 2008-06-05 | 2011-12-09 | 921d? |  | S1; S2; S3; S5; C1; C6; R2; R3; R4; R5; GP | 113136h | 113136h | EHNB | PCG-21 | T-Mobile | michael.kurz@t-mobile.at | Rel-9 | SP-40 | Alain | HNB | EHNB |  |
| 2360 | 617.1 | Stage 1 for EHNB | 261d? | 2008-06-05 A | 2009-06-04 A | 100% | 2008-06-05 | 2009-06-04 | 261d? | finish no earlier than 2009-06-04 | S1 | 2088h | 2088h | EHNB | PCG-21 | T-Mobile | michael.kurz@t-mobile.at | Rel-9 | SP-40 | Alain | HNB |  |  |
| 2361 | 617.2 | Architecture aspects of EHNB | 266d? | 2008-09-18 A | 2009-09-24 A | 100% | 2008-09-18 | 2009-09-24 | 266d? | finish no earlier than 2009-09-22 | S2 | 2128h | 2128h | EHNB | PCG-21 | T-Mobile | sebastian.speicher@telekom.de | Rel-9 | SP-41 | Maurice | HNB |  |  |
| 2362 | 617.3 | Security aspects of Enhanced Home NodeB / eNodeB | 262d? | 2008-12-11 A | 2009-12-10 A | 100% | 2008-12-11 | 2009-12-10 | 262d? | finish no earlier than 2009-12-10 | S3 | 2096h | 2096h | EHNB-Sec | PCG-22 | Huawei | Marcus Wong (mwong@huawei.com) | Rel-9 | SP-42 | Mirko | HNB | EHNB-Sec |  |
| 2363 | 617.4 | CT1 aspects - Support of Home NB and Home eNB enhancements | 321d? | 2009-09-18 A | 2010-12-10 A | 100% | 2009-09-18 | 2010-12-10 | 321d? | finish no earlier than 2010-12-10 | C1 | 2568h | 2568h | EHNB-CT1 | PCG-23 | Qualcomm | Ramachandran Subramanian (rsubrama@qualcomm.com) | Rel-9 | CP-45 | Frederic | HNB | EHNB-CT1 |  |
| 2364 | 617.5 | CT6 aspects - Support of Home NB and Home eNB enhancements | 131d? | 2009-09-18 A | 2010-03-19 A | 100% | 2009-09-18 | 2010-03-19 | 131d? | finish no earlier than 2010-03-19 | C6 | 1048h | 1048h | EHNB-CT6 | PCG-23 | Qualcomm | Ramachandran Subramanian (rsubrama@qualcomm.com) | Rel-9 | CP-45 | Xavier | HNB | EHNB-CT6 |  |
| 2365 | 617.6 | 3G HNB Gateway and LTE HeNB Gateway OAM&P | 336d? | 2008-12-11 A | 2010-03-25 A | 100% | 2008-12-11 | 2010-03-25 | 336d? | finish no earlier than 2010-03-25 | S5 | 2688h | 2688h | HNB-OAM_GW | PCG-22 | China Mobile | GangChen (chengang@chinamobile.com) | Rel-9 | SP-42 | Mirko | HNB | HNB-OAM_GW |  |
| 2366 | 617.7 | 3G HNB and LTE HeNB OAM&P Type 1 Interface | 272d? | 2009-03-12 A | 2010-03-25 A | 100% | 2009-03-12 | 2010-03-25 | 272d? | finish no earlier than 2010-03-25 | S5 | 2168h | 2168h | HNB_eHNB-OAM_Type1 | PCG-22 | Huawei | Zou Lan (zlan@huawei.com) | Rel-9 | SP-43 | Mirko | HNB | HNB_eHNB-OAM_Type1 |  |
| 2367 | 617.8 | 3G HNB and LTE HeNB OAM&P Type 2 Interface | 225d? | 2009-05-15 A | 2010-03-25 A | 100% | 2009-05-15 | 2010-03-25 | 225d? | finish no earlier than 2010-03-25 | S5 | 1800h | 1800h | HNB_eHNB-OAM_Type2 | PCG-23 | Ericsson | edwin.tse@ericsson.com | Rel-9 | SP-44 | Mirko | HNB | HNB_eHNB-OAM_Type2 |  |
| 2368 | 617.9 | LTE FDD Home eNodeB RF Requirements | 336d? | 2008-12-05 A | 2010-03-19 A | 100% | 2008-12-05 | 2010-03-19 | 336d? | finish no earlier than 2010-03-19 | R4 | 2688h | 2688h | HeNB-RF_FDD | PCG-22 | Motorola | Ying Cai (yingcai@motorola.com) | Rel-9 | RP-42 | Issam | HNB | HeNB-RF_FDD | RP-100035 |
| 2369 | 617.10 | LTE TDD Home eNodeB RF Requirements | 271d? | 2009-03-06 A | 2010-03-19 A | 100% | 2009-03-06 | 2010-03-19 | 271d? | finish no earlier than 2010-03-19 | R4 | 2168h | 2168h | HeNB-RF_TDD | PCG-22 | China Mobile | Nan Li (linan@chinamobile.com) | Rel-9 | RP-43 | Issam | HNB | HeNB-RF_TDD | RP-100036 |
| 2370 | 617.11 | Home NB and Home eNB enhancements - RAN3 aspects | 197d? | 2009-03-06 A | 2009-12-04 A | 100% | 2009-03-06 | 2009-12-04 | 197d? | finish no earlier than 2009-12-04 | R3 | 1576h | 1576h | EHNB-RAN3 | PCG-22 | Alcatel-Lucent | Martin Warner (mw15@alcatel-lucent.com) | Rel-9 | RP-43 | Juha | HNB | EHNB-RAN3 | RP-091050 |
| 2371 | 617.12 | Home NB and Home eNB enhancements - RAN2 aspects | 271d? | 2009-03-06 A | 2010-03-19 A | 100% | 2009-03-06 | 2010-03-19 | 271d? | finish no earlier than 2010-03-19 | R2 | 2168h | 2168h | EHNB-RAN2 | PCG-22 | Huawei | Yang Xudong (yangxudong@huawei.com) | Rel-9 | RP-43 | Yong-Jun | HNB | EHNB-RAN2 | RP-100037 |
| 2372 | 617.13 | Conformance Test Aspects – Home NB enhancements for FDD | 322d? | 2010-09-17 A | 2011-12-09 A | 100% | 2010-09-17 | 2011-12-09 | 322d? | finish no earlier than 2011-12-09 | R5 | 2568h | 2568h | EHNB-UTRA_FDD_UEConTest | PCG-25 | Huawei | trica_li@huawei.com | Rel-9 | RP-49 | Ingbert | HNB | EHNB-UTRA_FDD_UEConTest | RP-111679 |
| 2373 | 617.14 | Conformance Test Aspects – Home eNB enhancements | 201d? | 2010-12-10 A | 2011-09-16 A | 100% | 2010-12-10 | 2011-09-16 | 201d? | finish no earlier than 2011-09-16 | R5 | 1608h | 1608h | EHNB-LTE_UEConTest | PCG-26 | Qualcomm | Mrs Lena Chaponniere (lchaponn@qualcomm.com) | Rel-9 | RP-50 | Ingbert | HNB | EHNB-LTE_UEConTest | RP-110972 |
| 2374 | 617.15 | Home NB and Home eNB enhancements - GERAN aspects | 341d? | 2009-05-18 A | 2010-09-03 A | 100% | 2009-05-18 | 2010-09-03 | 341d? | finish no earlier than 2010-09-03 | GP | 2728h | 2728h | EHNB-GERAN | PCG-23 | Nokia Siemens Networks | leonardo.provvedi@roke.co.uk | Rel-9 | GP-42 | Paolo | HNB | EHNB-GERAN |  |
| 2375 | 618 | **Value-Added Services for Short Message Service** | 586d? | 2007-09-10 A | 2009-12-04 A | 100% | 2007-09-10 | 2009-12-04 | 586d? |  | S1; C4; C1 | 20264h | 20264h | VAS4SMS |  | China Mobile | Wu Bin (wubin@chinamobile.com) | Rel-9 | SP-37 | Alain |  | VAS4SMS |  |
| 2376 | 618.1 | Stage 1 for VAS4SMS | 133d? | 2007-09-10 A | 2008-03-12 A | 100% | 2007-09-10 | 2008-03-12 | 133d? | finish no earlier than 2008-03-21 | S1 | 1064h | 1064h | VAS4SMS |  | China Mobile | Wu Bin (wubin@chinamobile.com) | Rel-9 | SP-37 | Alain |  |  |  |
| 2377 | 618.2 | CT4 aspects of VAS4SMS Interface and Signalling Flow | 322d? | 2008-09-12 A | 2009-12-04 A | 100% | 2008-09-12 | 2009-12-04 | 322d? | finish no earlier than 2009-12-04 | C4 | 2568h | 2568h | VAS4SMS | PCG-21 | China Mobile | Wu Bin (wubin@chinamobile.com) | Rel-9 | CP-41 | Kimmo |  |  |  |
| 2378 | 618.3 | CT1 aspects of VAS4SMS Interface and Signalling Flow | 321d? | 2008-09-09 A | 2009-12-04 A | 100% | 2008-09-09 | 2009-12-04 | 321d? | finish no earlier than 2009-12-04 | C1 | 2568h | 2568h | VAS4SMS | PCG-21 | China Mobile | Wu Bin (wubin@chinamobile.com) | Rel-9 | CP-41 | Frederic |  |  |  |
| 2379 | 619 | **Definition of End-User Identity** | 334d? | 2007-09-03 A | 2008-12-11 A | 100% | 2007-09-03 | 2008-12-11 | 334d? |  | S1 | 5344h | 5344h | EUI |  | Nokia Siemens Networks | Juergen.Merkel@nsn.com | Rel-9 | SP-38 | Alain |  | EUI |  |
| 2380 | 619.1 | Stage 1 for Definition of End-User Identity | 334d? | 2007-09-03 A | 2008-12-11 A | 100% | 2007-09-03 | 2008-12-11 | 334d? | finish no earlier than 2008-12-11 | S1 | 2672h | 2672h | EUI | PCG-21 | Nokia Siemens Networks | Juergen.Merkel@nsn.com | Rel-9 | SP-38 | Alain |  |  |  |
| 2381 | 620 | **Customized Ringing Signal** | 522d? | 2007-12-06 A | 2009-12-03 A | 100% | 2007-12-06 | 2009-12-03 | 522d? |  | S1; C1 | 11296h | 11296h | CRS | PCG-21 | SK Telecom, China Mobile | Donghee Shim (SK Telecom), Jianping Zheng (China Mobile) | Rel-9 | SP-38 | Alain |  | CRS |  |
| 2382 | 620.1 | Stage 1 for Customized Ringing Signal | 266d? | 2007-12-06 A | 2008-12-11 A | 100% | 2007-12-06 | 2008-12-11 | 266d? | finish no earlier than 2008-12-11 | S1 | 2128h | 2128h | CRS | PCG-21 | SK Telecom, China Mobile | Donghee Shim (SK Telecom), Jianping Zheng (China Mobile) | Rel-9 | SP-38 | Alain |  |  |  |
| 2383 | 620.2 | Stage 3 for IMS Customized Ringing Signal (CRS) Service | 136d? | 2009-05-29 A | 2009-12-03 A | 100% | 2009-05-29 | 2009-12-03 | 136d? | finish no earlier than 2010-06-04 | C1 | 816h | 816h | CRS | PCG-23 | China Mobile | wangzhao | Rel-9 | CP-44 | Frederic |  |  |  |

Notes:
- 2359: RP#54 Testing completed / Impacted TSs and TRs: UTRA, LTE
- 2360: CP#49 the SA1-reqs are moving. CT1 will align when the work in SA1 is clear. (was SP#44 completed.) / Impacted TSs and TRs: 22.220, 22.011
- 2361: SP#45 completed / Impacted TSs and TRs: 23.401, 23.402, 23.060, New 23.830
- 2362: SP#46 completed / Impacted TSs and TRs: New 33.320
- 2363: CP#50 completed (Roaming aspects for manual CSG selection, Support of temporary users and CSG membership changes, Support of user controlled and operator controlled lists) / Impacted TSs and TRs: 23.122, 24.008, 24.285, 24.301
- 2364: CP#47 completed. Storing of CSG related data items on the USIM / Impacted TSs and TRs: 31.102
- 2365: SP#47 completed / Impacted TSs and TRs: 32.632, 32.633, 32.635, New (32.771, 32.772, 32.773, 32.775, 32.781, 32.782, 32.783, 32.785)
- 2366: SP#47 completed / Impacted TSs and TRs: 32.581, 32.582, 32.583, 32.584, New (32.591, 32.592, 32.593, 32.594)
- 2367: SP#47 completed / Impacted TSs and TRs: New (32.571, 32.572)
- 2368: RP#47 completed / Impacted TSs and TRs: 36.104, 36.141, New TR 36.921
- 2369: RP#47 completed / Impacted TSs and TRs: 36.104, 36.141, 36.300, 36.331, 36.413, New TR 36.922
- 2370: RP#46 completed (based on high priority items specified in RP-090995) / Impacted TSs and TRs: 25.413, 25.467, 25.467, 25.468, 25.469, 25.469, 36.401, 36.413, New 25.444
- 2371: RP#47 completed / Impacted TSs and TRs: 25.304, 25.331, 25.367, 36.300, 36.304, 36.331
- 2372: UTRA. RP#54 completed. Testing for UID_430026 Support of Home NB and Home eNB enhancements RAN2 aspects (25.304, 25.331, 25.367) / Impacted TSs and TRs: 34.108, 34.121-1, 34.121-2, 34.123-1, 34.123-2, 34.123-3
- 2373: RP#53 completed / Impacted TSs and TRs: 36.508, 36.523-1, 36.523-2, 36.523-3
- 2374: GP#47 completed. GP#42 WID approved / Impacted TSs and TRs: 43.055, 43.129, 44.018, 44.060, 45.008, 48.008, 48.018
- 2375: CP#46 completed
- 2376: SP#39 completed. SP#43 Feature moved to Rel-9 / Impacted TSs and TRs: new 22.142
- 2377: CP#46 completed / Impacted TSs and TRs: new 23.142
- 2378: CP#46 completed / Impacted TSs and TRs: 23.040
- 2379: SP#42 closed. Stage 1 work closed at 5% completion due to lack of input (added only the EUI definition in 21.905)
- 2380: SP#42 closed. Stage 1 work closed at 5% completion due to lack of input (added only the EUI definition in 21.905) / Impacted TSs and TRs: 21.905
- 2381: CP#48 completed
- 2382: SP#42 completed. / Impacted TSs and TRs: 22.173, new 22.183
- 2383: CP#48 completed / Impacted TSs and TRs: 24.173, new 24.183

| ID | WBS | Task | Type | Duration | Start | Finish | Complete | Baseline start | Baseline finish | Baseline duration | Constraint | Resources | Work | Actual work | Acronym | PCG approved | Impacted TSs and TRs | WI rapporteur name | Release | TSG approved | MCC resp | Special Focus Doc | Acronym_3GU_Export | Status Report |
| --- | --- | --- | --- | --- | --- | --- | --- | --- | --- | --- | --- | --- | --- | --- | --- | --- | --- | --- | --- | --- | --- | --- | --- | --- |
| 2384 | 621 | **Public Warning System** |  | 1315d? | 2007-12-06 A | 2012-12-07 A | 100% | 2007-12-06 | 2012-12-07 | 1315d? |  | S1; C1; C4; R2; R3; R5 | 73920h | 73920h | PWS | PCG-21 | LTE | T-Mobile | Rel-9 | SP-38 | Alain | Public Safety (I-A) | PWS |  |
| 2385 | 621.1 | Stage 1 for Public Warning System |  | 266d? | 2007-12-06 A | 2008-12-11 A | 100% | 2007-12-06 | 2008-12-11 | 266d? | finish no earlier than 2008-12-11 | S1 | 2128h | 2128h | PWS | PCG-21 | 22.268 | T-Mobile | Rel-9 | SP-38 | Alain | Public Safety (I-A) |  |  |
| 2386 | 621.2 | **Stage 3 for Public Warning System** |  | 137d? | 2009-05-29 A | 2009-12-04 A | 100% | 2009-05-29 | 2009-12-04 | 137d? |  | C1; C4 | 4368h | 4368h | PWS-St3 | PCG-23 |  | Qualcomm | Rel-9 | CP-44 | Frederic | Public Safety (I-A) | PWS-St3 |  |
| 2387 | 621.2.1 | CT1 aspects of Stage 3 for Public Warning System |  | 137d? | 2009-05-29 A | 2009-12-04 A | 100% | 2009-05-29 | 2009-12-04 | 137d? | finish no earlier than 2009-12-04 | C1 | 1088h | 1088h | PWS-St3 | PCG-23 | 23.041 | Qualcomm | Rel-9 | CP-44 | Frederic | Public Safety (I-A) |  |  |
| 2388 | 621.2.2 | CT4 aspects of Stage 3 for Public Warning System |  | 136d? | 2009-05-30 A | 2009-12-04 A | 100% | 2009-05-30 | 2009-12-04 | 136d? | finish no earlier than 2009-12-04 | C4 | 1088h | 1088h | PWS-St3 | PCG-23 | 29.168 | Qualcomm | Rel-9 | CP-44 | Kimmo | Public Safety (I-A) |  |  |
| 2389 | 621.3 | Public Warning System (PWS) – RAN aspects |  | 136d? | 2009-05-30 A | 2009-12-04 A | 100% | 2009-05-30 | 2009-12-04 | 136d? | finish no earlier than 2009-12-04 | R2; R3 | 2176h | 2176h | PWS-RAN | PCG-23 | LTE 36.300, 36.302, 36.331, 36.413 | AT&T | Rel-9 | RP-44 | Yong-Jun | Public Safety (I-A) | PWS-RAN | RP-091052 |
| 2390 | 621.4 | Conformance Test Aspects – Public Warning System (PWS) – RAN aspects for LTE |  | 267d? | 2011-12-02 A | 2012-12-07 A | 100% | 2011-12-02 | 2012-12-07 | 267d? | finish no earlier than 2012-12-07 | R5 | 2128h | 2128h | PWS-RAN_UEConTest | PCG-28 | 36.508, 36.523-1, 36.523-2, 36.523-3 | Qualcomm | Rel-9 | RP-54 | Ingbert | Public Safety (I-A) | PWS-RAN_UEConTest | RP-121525 |
| 2391 | 622 | **Support of Personal Area Networks and Enhancements to Personal Network Management** |  | 523d? | 2008-06-05 A | 2010-06-04 A | 100% | 2008-06-05 | 2010-06-04 | 523d? |  | S1; C1 | 12544h | 12544h | PAN_EPNM | PCG-21 |  | Vodafone | Rel-9 | SP-40 | Alain |  | PAN_EPNM |  |
| 2392 | 622.1 | Stage 1 for Support of Personal Area Networks and Enhancements to Personal Network Management | milestone | 0d? | 2008-06-05 A | 2008-06-05 A | 100% | 2008-06-05 | 2008-06-05 | 0d? | finish no earlier than 2008-06-05 | S1 |  |  | PAN_EPNM | PCG-21 | 22.259 | Vodafone | Rel-9 | SP-40 | Alain |  |  |  |
| 2393 | 622.2 | Stage 2 for Support of Personal Area Networks and Enhancements to Personal Network Management |  | 196d? | 2009-03-06 A | 2009-12-04 A | 100% | 2009-03-06 | 2009-12-04 | 196d? | finish no earlier than 2009-12-04 | C1 | 1568h | 1568h | PAN_EPNM | PCG-22 | 23.259 | Huawei | Rel-9 | CP-43 | Frederic |  |  |  |
| 2394 | 622.3 | Stage 3 for Support of Personal Area Networks and Enhancements to Personal Network Management |  | 326d? | 2009-03-09 A | 2010-06-04 A | 100% | 2009-03-09 | 2010-06-04 | 326d? | finish no earlier than 2010-06-04 | C1 | 2608h | 2608h | PAN_EPNM | PCG-22 | 24.259 | Huawei | Rel-9 | CP-43 | Frederic |  |  |  |
| 2395 | 623 | **Multi-Media Telephony Service enhancements** |  | 472d? | 2008-06-05 A | 2010-03-25 A | 100% | 2008-06-05 | 2010-03-25 | 472d? |  | S1; S5; C1 | 17840h | 17840h | eMMTel | PCG-21 |  | France Telecom | Rel-9 | SP-40 | Alain |  | eMMTel |  |
| 2396 | 623.1 | Stage 1 for eMMTel |  | 136d? | 2008-06-05 A | 2008-12-11 A | 100% | 2008-06-05 | 2008-12-11 | 136d? | start no earlier than 2008-06-05 | S1 | 1088h | 1088h | eMMTel | PCG-21 | 22.173 | France Telecom | Rel-9 | SP-40 | Alain |  |  |  |
| 2397 | 623.2 | Multimedia Telephony (MMTel) Service and Supplementary Services - Online Charging and completion for Offline Charging (all supplementary services) |  | 272d? | 2009-03-12 A | 2010-03-25 A | 100% | 2009-03-12 | 2010-03-25 | 272d? | finish no earlier than 2010-03-25 | S5 | 2168h | 2168h | eMMTel-SS-CH | PCG-22 | 32.275, 32.298, 32.299 | Alcatel-Lucent | Rel-9 | SP-43 | Mirko |  | eMMTel-SS-CH |  |
| 2398 | 623.3 | Support of Real-time Transfer of Tariff Information (RTTI) in IMS charging |  | 271d? | 2009-03-12 A | 2010-03-25 A | 100% | 2009-03-12 | 2010-03-25 | 271d? | finish no earlier than 2010-03-25 | S5 | 2168h | 2168h | IMSTSS-RTTI-CH | PCG-22 | 32.240, 32.280, 32.298, 32.299 | Orange | Rel-9 | SP-43 | Mirko |  | IMSTSS-RTTI-CH |  |
| 2399 | 623.4 | Stage 3 - Enhancements for Completion of Communications Supplementary service |  | 136d? | 2009-05-30 A | 2009-12-04 A | 100% | 2009-05-30 | 2009-12-04 | 136d? | finish no earlier than 2009-12-04 | C1 | 1088h | 1088h | eMMTel-CC | PCG-23 | 24.642 | France Telecom | Rel-9 | CP-44 | Frederic |  | eMMTel-CC |  |
| 2400 | 624 | **User Data Convergence (UDC)** |  | 527d? | 2008-06-05 A | 2010-06-10 A | 100% | 2008-06-05 | 2010-06-10 | 527d? |  | S1; S5; C4 | 25056h | 25056h | UDC | PCG-21 |  | Nokia Siemens Networks | Rel-9 | SP-40 | Alain |  | UDC |  |
| 2401 | 624.1 | Stage 1 for User Data Convergence (UDC) |  | 136d? | 2008-06-05 A | 2008-12-11 A | 100% | 2008-06-05 | 2008-12-11 | 136d? | start no earlier than 2008-06-05 | S1 | 1088h | 1088h | UDC | PCG-21 | 22.101, new 22.985 | Nokia Siemens Networks | Rel-9 | SP-40 | Alain |  |  |  |
| 2402 | 624.2 | **Stage 2/3 for User Data Convergence (UDC) Technical Realization** |  | 272d? | 2009-03-06 A | 2010-03-19 A | 100% | 2009-03-06 | 2010-03-19 | 272d? |  | C4 | 5376h | 5376h | UDC-CN | PCG-22 |  | Ericsson | Rel-9 | CP-43 | Kimmo |  | UDC-CN |  |
| 2403 | 624.2.1 | User Data Convergence (UDC) Technical Realization (Stage 2) |  | 271d? | 2009-03-06 A | 2010-03-19 A | 100% | 2009-03-06 | 2010-03-19 | 271d? | finish no earlier than 2010-03-19 | C4 | 2168h | 2168h | UDC-CN | PCG-22 | new 23.335 | Ericsson | Rel-9 | CP-43 | Kimmo |  |  |  |
| 2404 | 624.2.2 | User Data Convergence (UDC) Protocol Description |  | 130d? | 2009-09-18 A | 2010-03-19 A | 100% | 2009-09-18 | 2010-03-19 | 130d? | finish no earlier than 2010-03-19 | C4 | 1040h | 1040h | UDC-CN | PCG-23 | new 29.335 | China Mobile, Ericsson | Rel-9 | CP-45 | Kimmo |  |  |  |
| 2405 | 624.3 | **User Data Convergence (UDC) Modelling and Management** |  | 266d? | 2009-06-04 A | 2010-06-10 A | 100% | 2009-06-04 | 2010-06-10 | 266d? |  | S5 | 5944h | 5944h | UDC-MMAN | PCG-23 |  | T-Mobile, China Mobile, Ericsson | Rel-9 | SP-44 | Mirko |  | UDC-MMAN |  |
| 2406 | 624.3.1 | UDC – Framework for Model Handling and Management |  | 266d? | 2009-06-04 A | 2010-06-10 A | 100% | 2009-06-04 | 2010-06-10 | 266d? | finish no earlier than 2010-06-10 | S5 | 2128h | 2128h | UDC-MMAN-MFRM | PCG-23 | 32.172, new 32.181 | T-Mobile | Rel-9 | SP-44 | Mirko |  | UDC-MMAN-MFRM |  |
| 2407 | 624.3.2 | UDC – Common Baseline Information Model |  | 211d? | 2009-06-04 A | 2010-03-25 A | 100% | 2009-06-04 | 2010-03-25 | 211d? | finish no earlier than 2010-03-25 | S5 | 1688h | 1688h | UDC-MMAN-CBIM | PCG-23 | 32.172, new 32.182 | China Mobile, Ericsson | Rel-9 | SP-44 | Mirko |  | UDC-MMAN-CBIM |  |

Notes:
- 2384: TSG#46 completed. Larger scope than Rel-8 Feature UID_370051 (ETWS). Triggered by TR 22.968 Study UID_320025 (FS_PWS) / WI rapporteur e-mail: Mark.Younge@t-mobile.com
- 2385: SP#42 completed / WI rapporteur e-mail: Mark.Younge@t-mobile.com
- 2386: RP#46 completed / WI rapporteur e-mail: Ramachandran Subramanian (rsubrama@qualcomm.com)
- 2387: CP#46 completed / WI rapporteur e-mail: Ramachandran Subramanian (rsubrama@qualcomm.com)
- 2388: CP#46 completed / WI rapporteur e-mail: Ramachandran Subramanian (rsubrama@qualcomm.com)
- 2389: RP#46 completed / WI rapporteur e-mail: don.zelmer@att.com
- 2390: RP#58 completed / WI rapporteur e-mail: Shubhang Vora (svora@qualcomm.com)
- 2391: CP#48 completed / WI rapporteur e-mail: armin.toepfer@vodafone.com
- 2392: SP#40 completed / WI rapporteur e-mail: armin.toepfer@vodafone.com
- 2393: CP#46 completed / WI rapporteur e-mail: Lili Yang (kadyyang@huawei.com)
- 2394: CP#48 completed / WI rapporteur e-mail: Lili Yang (kadyyang@huawei.com)
- 2395: SP#47 completed / WI rapporteur e-mail: philippe.lottin@orange.com
- 2396: SP#42 completed / WI rapporteur e-mail: philippe.lottin@orange.com
- 2397: SP#47 completed / WI rapporteur e-mail: maryse.gardella@alcatel-lucent.com
- 2398: SP#47 completed. Linked to SA5 Rel-8 UID_380042 AoC support in IMS Charging (IMSTSS) / WI rapporteur e-mail: Jean-Luc Garcia (jl.garcia@orange-ftgroup.com)
- 2399: CP#46 completed / WI rapporteur e-mail: Youssef.chadli@orange-ftgroup.com
- 2400: SP#48 completed. Triggered by Rel-8 SA5 Study of Common Profile Storage Framework of User Data for network services and management (UID_320006) TR 32.808 / WI rapporteur e-mail: juergen.merkel@nsn.com
- 2401: SP#42 completed / WI rapporteur e-mail: juergen.merkel@nsn.com
- 2402: - / WI rapporteur e-mail: emiliano.merino@ericsson.com
- 2403: CP#47 completed / WI rapporteur e-mail: emiliano.merino@ericsson.com
- 2404: CP#47 completed / WI rapporteur e-mail: Lan Si Zhong (lansizhong@chinamobile.com), emiliano.merino@ericsson.com
- 2405: SP#48 completed / WI rapporteur e-mail: istvan.aba@t-mobile.at, lansizhong@chinamobile.com, miguel.a.garcia@ericsson.com
- 2406: SP#48 completed / WI rapporteur e-mail: istvan.aba@t-mobile.at
- 2407: SP#47 completed / WI rapporteur e-mail: Lan Si Zhong, Miguel Garcia

| ID | WBS | Task | Duration | Start | Finish | Complete | Baseline start | Baseline finish | Baseline duration | Constraint | Resources | Work | Actual work | Acronym | PCG approved | WI rapporteur name | WI rapporteur e-mail | Release | TSG approved | MCC resp | Acronym_3GU_Export | Status Report | Special Focus Doc |
| --- | --- | --- | --- | --- | --- | --- | --- | --- | --- | --- | --- | --- | --- | --- | --- | --- | --- | --- | --- | --- | --- | --- | --- |
| 2408 | 625 | **IMS Services Centralization and Continuity** | 393d? | 2008-09-18 A | 2010-03-19 A | 100% | 2008-09-18 | 2010-03-19 | 393d? |  | S1; S2; C1 | 30992h | 30992h | IMS_SCC | PCG-21 | NEC | joerg.swetina@neclab.eu | Rel-9 | SP-41 | Alain | IMS_SCC |  |  |
| 2409 | 625.1 | Stage 1 - Inter-Device Transfer – Requirements | 61d? | 2008-09-18 A | 2008-12-11 A | 100% | 2008-09-18 | 2008-12-11 | 61d? | finish no earlier than 2009-06-18 | S1 | 488h | 488h | IMS_SCC-IDT | PCG-21 | NEC | joerg.swetina@neclab.eu | Rel-9 | SP-41 | Alain | IMS_SCC-IDT |  |  |
| 2410 | 625.2 | **Stage 2/3 for IMS Service Continuity Enhancements: Service, Policy and Interactions** | 393d? | 2008-09-18 A | 2010-03-19 A | 100% | 2008-09-18 | 2010-03-19 | 393d? |  | S2; C1 | 9456h | 9456h | IMS_SCC-SPI | PCG-21 | Huawei | HengLiang Zhang (hl_zhang@huawei.com) | Rel-9 | SP-41 | Maurice | IMS_SCC-SPI |  |  |
| 2411 | 625.2.1 | Stage 2 for IMS Service Continuity Enhancements: Service, Policy and Interactions | 186d? | 2008-09-18 A | 2009-06-04 A | 100% | 2008-09-18 | 2009-06-04 | 186d? | finish no earlier than 2009-06-04 | S2 | 1488h | 1488h | IMS_SCC-SPI | PCG-21 | Huawei | HengLiang Zhang (hl_zhang@huawei.com) | Rel-9 | SP-41 | Maurice |  |  |  |
| 2412 | 625.2.2 | Stage 3 for IMS Service Continuity Enhancements: Service, Policy, Interactions and Inter UE Transfer | 212d? | 2009-05-29 A | 2010-03-19 A | 100% | 2009-05-29 | 2010-03-19 | 212d? | finish no earlier than 2010-03-19 | C1 | 1696h | 1696h | IMS_SCC-SPI | PCG-23 | Qualcomm | Roozbeh Atarius (ratarius@qualcomm.com) | Rel-9 | CP-44 | Frederic |  |  |  |
| 2413 | 625.3 | **Stage 2/3 for IMS Centralized Services** | 393d? | 2008-09-18 A | 2010-03-19 A | 100% | 2008-09-18 | 2010-03-19 | 393d? |  | S2; C1 | 9448h | 9448h | IMS_SCC-ICS | PCG-21 | Alcatel-Lucent | andy.bennett@alcatel-lucent.com | Rel-9 | SP-41 | Maurice | IMS_SCC-ICS |  |  |
| 2414 | 625.3.1 | Stage 2 for IMS Centralized Services | 186d? | 2008-09-18 A | 2009-06-04 A | 100% | 2008-09-18 | 2009-06-04 | 186d? | finish no earlier than 2009-06-04 | S2 | 1488h | 1488h | IMS_SCC-ICS | PCG-21 | Alcatel-Lucent | andy.bennett@alcatel-lucent.com | Rel-9 | SP-41 | Maurice |  |  |  |
| 2415 | 625.3.2 | Stage 3 for Enhancements to IMS Centralized Services | 212d? | 2009-05-29 A | 2010-03-19 A | 100% | 2009-05-29 | 2010-03-19 | 212d? | finish no earlier than 2010-03-19 | C1 | 1688h | 1688h | IMS_SCC-ICS | PCG-23 | Nokia Siemens Networks | Peter.Leis@nsn.com | Rel-9 | CP-44 | Frederic |  |  |  |
| 2416 | 625.4 | Stage 3 - IMS Centralized Services support via I1 interface | 271d? | 2009-03-06 A | 2010-03-19 A | 100% | 2009-03-06 | 2010-03-19 | 271d? | finish no earlier than 2010-03-19 | C1 | 2168h | 2168h | IMS_SCC-ICS_I1 | PCG-22 | Huawei | Lili Yang(kadyyang@huawei.com) | Rel-9 | CP-43 | Frederic | IMS_SCC-ICS_I1 |  |  |
| 2417 | 626 | **Service Specific Access Control in EPS** | 922d? | 2008-12-11 A | 2012-06-15 A | 100% | 2008-12-11 | 2012-06-15 | 922d? |  | S1; C1; R5 | 26000h | 26000h | SSAC | PCG-22 | NTT DoCoMo | Frederic Thepot (thepot@docomolab-euro.com) | Rel-9 | SP-42 | Alain | SSAC |  |  |
| 2418 | 626.1 | Stage 1 for Service Specific Access Control in EPS | 1d? | 2008-12-11 A | 2008-12-11 A | 100% | 2008-12-11 | 2008-12-11 | 1d? | start no earlier than 2008-12-11 | S1 | 8h | 8h | SSAC | PCG-22 | NTT DoCoMo | Frederic Thepot (thepot@docomolab-euro.com) | Rel-9 | SP-42 | Alain |  |  |  |
| 2419 | 626.2 | Stage 3 for Service Specific Access Control in EPS | 212d? | 2009-05-29 A | 2010-03-19 A | 100% | 2009-05-29 | 2010-03-19 | 212d? | finish no earlier than 2010-03-19 | C1 | 1696h | 1696h | SSAC | PCG-23 | NTT DoCoMo | Hideyuki Yamashita (yamashitahi@s1.nttdocomo.co.jp) | Rel-9 | CP-44 | Frederic |  |  |  |
| 2420 | 626.3 | Conformance Test Aspects - Service Specific Access Control | 272d? | 2011-06-07 A | 2012-06-15 A | 100% | 2011-06-07 | 2012-06-15 | 272d? | finish no earlier than 2012-06-15 | R5 | 2168h | 2168h | SSAC_UEConTest | PCG-27 | NTT DoCoMo | Takao.Shimizu.rp@nttdocomo.com | Rel-9 | RP-52 | Ingbert | SSAC_UEConTest | RP-120447 |  |
| 2421 | 627 | **Support for IMS Emergency Calls over GPRS and EPS** | 3785d? | 2000-01-03 A | 2014-06-13 A | 100% | 2000-01-03 | 2014-06-13 | 3785d? |  | S1; S2; S3; C1; C3; C4; R2; R3; R5; IETF | 293512h | 293512h | IMS_EMER_GPRS_EPS | PCG-21 | Alcatel-Lucent | Deborah Barclay | Rel-9 | SP-38 | Maurice | IMS_EMER_GPRS_EPS |  | Public Safety (I-A) |
| 2422 | 627.1 | Stage 1 for IMS Emergency Calls over GPRS and EPS | 239d? | 2008-01-14 A | 2008-12-11 A | 100% | 2008-01-14 | 2008-12-11 | 239d? | finish no earlier than 2008-12-11 | S1 | 1912h | 1912h | IMS_EMER_GPRS_EPS | PCG-21 | Alcatel-Lucent | Deborah Barclay | Rel-9 | SP-38 | Alain |  |  | Public Safety (I-A) |
| 2423 | 627.2 | Stage 2 for IMS Emergency Calls over GPRS and EPS | 364d? | 2008-01-14 A | 2009-06-04 A | 100% | 2008-01-14 | 2009-06-04 | 364d? | finish no earlier than 2009-06-04 | S2 | 2912h | 2912h | IMS_EMER_GPRS_EPS | PCG-21 | Alcatel-Lucent | Deborah Barclay | Rel-9 | SP-38 | Maurice |  |  | Public Safety (I-A) |
| 2424 | 627.3 | Security aspects for IMS Emergency Calls over GPRS and EPS | 391d? | 2008-12-12 A | 2010-06-10 A | 100% | 2008-12-12 | 2010-06-10 | 391d? | finish no earlier than 2010-03-25 | S3 | 3128h | 3128h | IMS_EMER_GPRS_EPS-Sec | PCG-22 | Alcatel-Lucent | Deborah Barclay | Rel-9 | SP-42 | Mirko | IMS_EMER_GPRS_EPS-Sec |  | Public Safety (I-A) |
| 2425 | 627.4 | **Stage 3 for IMS Emergency Calls over GPRS and EPS** | 801d? | 2009-05-29 A | 2012-06-15 A | 100% | 2009-05-29 | 2012-06-15 | 801d? |  | C1; C3; C4; R5 | 33331.7h | 33331.7h | IMS_EMER_GPRS_EPS | PCG-23 | Alcatel-Lucent | Frank Alfano (falfano@alcatel-lucent.com) | Rel-9 | CP-44 | Frederic |  |  | Public Safety (I-A) |
| 2426 | 627.4.1 | CT1 aspects - Stage 3 for IMS Emergency Calls over GPRS and EPS | 212d? | 2009-05-29 A | 2010-03-19 A | 100% | 2009-05-29 | 2010-03-19 | 212d? | finish no earlier than 2010-03-19 | C1 | 1696h | 1696h | IMS_EMER_GPRS_EPSC1 | PCG-23 | Alcatel-Lucent | Frank Alfano (falfano@alcatel-lucent.com) | Rel-9 | CP-44 | Frederic |  |  | Public Safety (I-A) |
| 2427 | 627.4.2 | Conformance Test Aspects - CT1 aspects for IMS Emergency Calls over GPRS and EPS | 532d? | 2010-06-04 A | 2012-06-15 A | 100% | 2010-06-04 | 2012-06-15 | 532d? | finish no earlier than 2012-06-15 | R5 | 4256h | 4256h | IMS_EMER_GPRS_EPS_UEConTest | PCG-25 | Samsung | stoyan.baev@partner.samsung.com | Rel-9 | RP-48 | Ingbert | IMS_EMER_GPRS_EPS_UEConTest | RP-120445 | Public Safety (I-A) |
| 2428 | 627.4.3 | CT3 aspects - Stage 3 for IMS Emergency Calls over GPRS and EPS | 82d? | 2009-05-29 A | 2009-09-18 A | 100% | 2009-05-29 | 2009-09-18 | 82d? | start no earlier than 2009-05-29 | C3 | 651.68h | 651.68h | IMS_EMER_GPRS_EPSC3 | PCG-23 | Alcatel-Lucent | Frank Alfano (falfano@alcatel-lucent.com) | Rel-9 | CP-44 | Adrian |  |  | Public Safety (I-A) |
| 2429 | 627.4.4 | CT4 aspects - Stage 3 for IMS Emergency Calls over GPRS and EPS | 137d? | 2009-05-29 A | 2009-12-04 A | 100% | 2009-05-29 | 2009-12-04 | 137d? | finish no earlier than 2009-12-04 | C4 | 1096h | 1096h | IMS_EMER_GPRS_EPSC4 | PCG-23 | Alcatel-Lucent | Frank Alfano (falfano@alcatel-lucent.com) | Rel-9 | CP-44 | Kimmo |  |  | Public Safety (I-A) |
| 2430 | 627.5 | Support for IMS Emergency Calls over LTE | 207d? | 2000-01-03 A | 2000-10-16 A | 100% | 2000-01-03 | 2000-10-16 | 207d? |  | R2; R3 | 3312h | 3312h | IMS_EMER_LTE | PCG-22 | Alcatel-Lucent | Sudeep Palat (spalat@alcatel-lucent.com) | Rel-9 | RP-42 | Yong-Jun | IMS_EMER_LTE | RP-090698 | Public Safety (I-A) |
| 2431 | 627.6 | Conformance Test Aspects – Support for IMS Emergency Calls over LTE | 187d? | 2010-03-25 A | 2010-12-10 A | 100% | 2010-03-25 | 2010-12-10 | 187d? | finish no earlier than 2010-12-10 | R5 | 1496h | 1496h | IMS_EMER_LTE_UEConTest | PCG-24 | Ericsson | leif.mattisson@ericsson.com | Rel-9 | RP-47 | Ingbert | IMS_EMER_LTE_UEConTest | RP-101068 | Public Safety (I-A) |

Notes:
- 2408: CP#47 completed
- 2409: SP#42 completed / Impacted TSs and TRs: 22.101, 22.228
- 2410: -
- 2411: SP#57 Removal of the MSC server assisted mid-call feature from Rel-9 by 23.237CR#0433 (CT1 proposed moving this feature to Rel-10). SP#44 completed. TR 23.838 for Approval / Impacted TSs and TRs: 23.237, 23.292, 23.216, new 23.838
- 2412: CP#47 completed / Impacted TSs and TRs: 24.216, 24.229, 24.237
- 2413: -
- 2414: SP#44 completed. TR 23.883 for Information + Approval / Impacted TSs and TRs: 23.292, new 23.883
- 2415: CP#47 completed / Impacted TSs and TRs: 24.292, 24.604, 24.607, 24.608, 24.611, 24.623
- 2416: CP#47 completed / Impacted TSs and TRs: 24.237, 24.292, new 24.294
- 2417: CP#47 completed. Triggered by TR 22.986 Study on Service Specific Access Control in EPS. As EPS is a PS-Domain only system, Domain Specific Access Control (DSAC) doesn't apply, hence SSAC allows restriction of voice and non-voice calls separately
- 2418: SP#42 completed. If UE supports E-UTRA and IMS, SSAC is a mandatory Rel-9 function (during congestion in emergency case earthquake/tsunami improves mobile communications). / Impacted TSs and TRs: 22.011 CR0136
- 2419: CP#47 completed / Impacted TSs and TRs: 24.173, 27.007
- 2420: RP#56 completed. Testing for Stage 3 for Service Specific Access Control in EPS (24.173, 27.007) UID_440040 / Impacted TSs and TRs: 34.229-1, 34.229-2, 34.229-3
- 2421: RP#56 completed testing. CP#47 completed. SP#48 completed / Impacted TSs and TRs: GERAN, LTE
- 2422: SP#42 completed / Impacted TSs and TRs: 22.101
- 2423: SP#44 completed / Impacted TSs and TRs: 23.869, 23.060, 23.167, 23.203, 23.221, 23.228, 23.271, 23.401, 23.402
- 2424: SP#48 completed / Impacted TSs and TRs: 33.401, 33.402
- 2425: RP#56 completed testing. CP#47 completed / Impacted TSs and TRs: GERAN, LTE
- 2426: CP#47 completed / Impacted TSs and TRs: 23.122, 24.008, 24.229, 24.301, 24.302
- 2427: RP#56 completed / Impacted TSs and TRs: 34.108, 34.123-1, 34.123-2, 34.123-3, 34.229-1, 34.229-2, 34.229-3, 36.508, 36.523-1, 36.523-2, 36.523-3
- 2428: CP#45 completed / Impacted TSs and TRs: 29.212, 29.213, 29.214, 29.215
- 2429: CP#46 completed / Impacted TSs and TRs: 23.003, 23.008, 29.060, 29.272, 29.273, 29.274, 29.275, 29.276
- 2430: RP#45 completed / Impacted TSs and TRs: 36.331, 36.413
- 2431: RP#50 completed / Impacted TSs and TRs: 36.508, 36.523-1, 36.523-2, 36.523-3

| ID | WBS | Task | Type | Duration | Start | Finish | Complete | Baseline start | Baseline finish | Baseline duration | Constraint | Resources | Work | Actual work | Acronym | PCG approved | WI rapporteur name | WI rapporteur e-mail | Release | TSG approved | MCC resp | Special Focus Doc | Acronym_3GU_Export | Status Report |
| --- | --- | --- | --- | --- | --- | --- | --- | --- | --- | --- | --- | --- | --- | --- | --- | --- | --- | --- | --- | --- | --- | --- | --- | --- |
| 2432 | 627.7 | **Single Radio Voice Call Continuity (SRVCC) support for IMS Emergency Calls** |  | 1511d? | 2008-09-18 A | 2014-06-13 A | 100% | 2008-09-18 | 2014-06-13 | 1511d? |  | S2; C1; C4; C3; IETF | 112300h | 112300h | IMS_EMER_GPRS_EPS-SRVCC | PCG-21 | China Mobile | Yu Qing (Yuqing@chinamobile.com) | Rel-9 | SP-41 | Maurice | Public Safety (I-A) | IMS_EMER_GPRS_EPS-SRVCC |  |
| 2433 | 627.7.1 | SRVCC support for IMS Emergency Calls |  | 322d? | 2008-09-18 A | 2009-12-10 A | 100% | 2008-09-18 | 2009-12-10 | 322d? | finish no earlier than 2009-12-10 | S2 | 2576h | 2576h | IMS_EMER_GPRS_EPS-SRVCC | PCG-21 | China Mobile | Yu Qing (Yuqing@chinamobile.com) | Rel-9 | SP-41 | Maurice | Public Safety (I-A) |  |  |
| 2434 | 627.7.2 | **CT aspects of SRVCC support for IMS Emergency Calls** |  | 1330d? | 2009-05-29 A | 2014-06-13 A | 100% | 2009-05-29 | 2014-06-13 | 1330d? |  | C1; C4; C3; IETF | 49284h | 49284h | IMS_EMER_GPRS_EPS-SRVCC | PCG-24 | China Mobile | jiangyi@chinamobile.com | Rel-9 | CP-46 | Frederic | Public Safety (I-A) |  |  |
| 2435 | 627.7.2.1 | CT1 aspects of SRVCC support for IMS Emergency Calls |  | 137d? | 2009-05-29 A | 2009-12-04 A | 100% | 2009-05-29 | 2009-12-04 | 137d? | finish no earlier than 2009-12-04 | C1 | 1096h | 1096h | IMS_EMER_GPRS_EPS-SRVCC | PCG-23 | China Mobile | jiangyi@chinamobile.com | Rel-9 | CP-44 | Frederic | Public Safety (I-A) |  |  |
| 2436 | 627.7.2.2 | CT4 aspects of SRVCC support for IMS Emergency Calls |  | 137d? | 2009-05-29 A | 2009-12-04 A | 100% | 2009-05-29 | 2009-12-04 | 137d? | finish no earlier than 2009-12-04 | C4 | 1096h | 1096h | IMS_EMER_GPRS_EPS-SRVCC | PCG-23 | China Mobile | jiangyi@chinamobile.com | Rel-9 | CP-44 | Kimmo | Public Safety (I-A) |  |  |
| 2437 | 627.7.2.3 | CT3 aspects of SRVCC support for IMS Emergency Calls |  | 1d? | 2009-12-04 A | 2009-12-04 A | 100% | 2009-12-04 | 2009-12-04 | 1d? | finish no earlier than 2009-12-04 | C3 | 8h | 8h | IMS_EMER_GPRS_EPS-SRVCC | PCG-24 | China Mobile | jiangyi@chinamobile.com | Rel-9 | CP-46 | Kimmo | Public Safety (I-A) |  |  |
| 2438 | 627.7.2.4 | (IETF) CT3 aspects of SRVCC support for IMS Emergency Calls (RFC 7254) |  | 568d? | 2012-04-20 A | 2014-06-13 A | 100% | 2012-04-20 | 2014-06-13 | 568d? | finish no earlier than 2014-06-13 | C3-IETF | 4524h | 4524h | IMS_EMER_GPRS_EPS-SRVCC | PCG-29 | Andrew Allen | Andrew Allen | Rel-9 | CP-56 | Adrian | Public Safety (I-A) |  |  |
| 2439 | 628 | **LCS for LTE and EPS** |  | 981d? | 2008-06-05 A | 2012-03-02 A | 100% | 2008-06-05 | 2012-03-02 | 981d? |  | S2; C1; C4; R2; R1; R3; R4; R5 | 83592h | 83592h | LCS_LTE_EPS | PCG-22 |  |  | Rel-9 | SP-43 | Maurice | Public Safety (I-A) | LCS_LTE_EPS |  |
| 2440 | 628.1 | **LCS Control Plane Solution for EPS** |  | 468d? | 2008-06-05 A | 2010-03-19 A | 100% | 2008-06-05 | 2010-03-19 | 468d? |  | S2; C4; C1 | 16712h | 16712h | LCS_EPS-CPS | PCG-21 | Polaris Wireless | Robert Gross (rgross@polariswireless.com) | Rel-9 | SP-40 | Maurice | Public Safety (I-A) | LCS_EPS-CPS |  |
| 2441 | 628.1.1 | Stage 2 for LCS Control Plane Solution for EPS |  | 261d? | 2008-06-05 A | 2009-06-04 A | 100% | 2008-06-05 | 2009-06-04 | 261d? | finish no earlier than 2009-06-04 | S2 | 2088h | 2088h | LCS_EPS-CPS | PCG-21 | Polaris Wireless | Robert Gross (rgross@polariswireless.com) | Rel-9 | SP-40 | Maurice | Public Safety (I-A) |  |  |
| 2442 | 628.1.2 | CT4 aspects of Control Plane LCS in the EPC |  | 212d? | 2009-05-29 A | 2010-03-19 A | 100% | 2009-05-29 | 2010-03-19 | 212d? | finish no earlier than 2010-03-19 | C4 | 1696h | 1696h | LCS_EPS-CPS | PCG-23 | Polaris Wireless | Robert Gross (rgross@polariswireless.com) | Rel-9 | CP-44 | Kimmo | Public Safety (I-A) |  |  |
| 2443 | 628.1.3 | CT1 aspects of Control Plane LCS in the EPC |  | 212d? | 2009-05-29 A | 2010-03-19 A | 100% | 2009-05-29 | 2010-03-19 | 212d? | finish no earlier than 2010-03-19 | C1 | 1696h | 1696h | LCS_EPS-CPS | PCG-23 | Polaris Wireless | Robert Gross (rgross@polariswireless.com) | Rel-9 | CP-44 | Frederic | Public Safety (I-A) |  |  |
| 2444 | 628.2 | Positioning Support for LTE | milestone | 0d? | 2008-12-05 A | 2008-12-05 A | 100% | 2008-12-05 | 2010-06-04 | 392d? | finish no earlier than 2010-06-04 | R2; R1; R3; R4 |  |  | LCS_LTE | PCG-22 | Qualcomm | Nathan Tenny (ntenny@qualcomm.com) | Rel-9 | RP-42 | Yong-Jun | Public Safety (I-A) | LCS_LTE | RP-100442 |
| 2445 | 628.3 | Conformance Test Aspects – Positioning Support for LTE |  | 512d? | 2010-03-19 A | 2012-03-02 A | 100% | 2010-03-19 | 2012-03-02 | 512d? | finish no earlier than 2012-03-02 | R5 | 4096h | 4096h | LCS_LTE_UEConTest | PCG-24 | Qualcomm | Shubhang Vora (svoral@qualcomm.com) | Rel-9 | RP-47 | Ingbert | Public Safety (I-A) | LCS_LTE_UEConTest | RP-120034 |
| 2446 | 629 | **MBMS support in EPS** |  | 921d? | 2008-06-05 A | 2011-12-09 A | 100% | 2008-06-05 | 2011-12-09 | 921d? |  | S2; S3; S5; C3; C4; R2; R3; R4; R5 | 82896h | 82896h | MBMS_EPS | PCG-21 | China Mobile | Liu Hong (liuhongyfw@chinamobile.com) | Rel-9 | SP-40 | Maurice |  | MBMS_EPS |  |
| 2447 | 629.1 | Stage 2 for MBMS support in EPS |  | 261d? | 2008-06-05 A | 2009-06-04 A | 100% | 2008-06-05 | 2009-06-04 | 261d? | finish no earlier than 2009-06-04 | S2 | 2088h | 2088h | MBMS_EPS | PCG-21 | China Mobile | Liu Hong (liuhongyfw@chinamobile.com) | Rel-9 | SP-40 | Maurice |  |  |  |
| 2448 | 629.2 | Security for MBMS support in EPS |  | 261d? | 2008-12-11 A | 2009-12-10 A | 100% | 2008-12-11 | 2009-12-10 | 261d? | finish no earlier than 2009-12-10 | S3 | 2088h | 2088h | MBMS_EPS | PCG-22 | China Mobile | Liu Hong (liuhongyfw@chinamobile.com) | Rel-9 | SP-42 | Mirko |  |  |  |
| 2449 | 629.3 | MBMS Charging in EPS |  | 201d? | 2009-03-06 A | 2009-12-10 A | 100% | 2009-03-06 | 2009-12-10 | 201d? | finish no earlier than 2009-12-10 | S5 | 1600h | 1600h | MBMS_EPS | PCG-22 | ZTE | guo.wenjie1@zte.com.cn | Rel-9 | SP-43 | Mirko |  |  |  |
| 2450 | 629.4 | CT4 aspects of MBMS support in EPS (Stage 3) |  | 137d? | 2009-05-29 A | 2009-12-04 A | 100% | 2009-05-29 | 2009-12-04 | 137d? | finish no earlier than 2009-12-04 | C4 | 1096h | 1096h | MBMS_EPS | PCG-23 | China Mobile, ZTE | wangjingyf@chinamobile.com, lu.fei1@zte.com.cn | Rel-9 | CP-44 | Kimmo |  |  |  |
| 2451 | 629.5 | CT3 aspects of MBMS support in EPS (Stage 3) |  | 137d? | 2009-05-29 A | 2009-12-04 A | 100% | 2009-05-29 | 2009-12-04 | 137d? | start no earlier than 2009-05-29 | C3 | 1096h | 1096h | MBMS_EPS | PCG-23 | ZTE, China Mobile | zhou.xiaoyun@zte.com.cn, wangjingyf@chinamobile.com | Rel-9 | CP-44 | Adrian |  |  |  |
| 2452 | 629.6 | MBMS support in LTE |  | 272d? | 2009-03-06 A | 2010-03-19 A | 100% | 2009-03-06 | 2010-03-19 | 272d? | finish no earlier than 2010-03-19 | R2; R3; R4 | 6528h | 6528h | MBMS_LTE | PCG-22 | Huawei | arnaud.meylan@huawei.com | Rel-9 | RP-43 | Yong-Jun |  | MBMS_LTE | RP-100033 |
| 2453 | 629.7 | Conformance Test Aspects – MBMS support in LTE |  | 262d? | 2010-12-10 A | 2011-12-09 A | 100% | 2010-12-10 | 2011-12-09 | 262d? | finish no earlier than 2011-12-09 | R5 | 2088h | 2088h | MBMS_LTE-UEConTest | PCG-26 | Huawei | Zhang Xin (zhangxin0208@huawei.com) | Rel-9 | RP-50 | Ingbert |  | MBMS_LTE-UEConTest | RP-111437 |
| 2454 | 630 | **Access Network Discovery and Selection Function enhancements** |  | 333d? | 2008-12-11 A | 2010-03-19 A | 100% | 2008-12-11 | 2010-03-19 | 333d? |  | S2; C1 | 7384h | 7384h | eANDSF | PCG-22 | Motorola | Apostolis Salkintzis (salki@motorola.com) | Rel-9 | SP-42 | Maurice |  | eANDSF |  |
| 2455 | 630.1 | Stage 2 for Access Network Discovery and Selection Function enhancements |  | 126d? | 2008-12-11 A | 2009-06-04 A | 100% | 2008-12-11 | 2009-06-04 | 126d? | finish no earlier than 2009-06-04 | S2 | 1008h | 1008h | eANDSF | PCG-22 | Motorola | Apostolis Salkintzis (salki@motorola.com) | Rel-9 | SP-42 | Maurice |  |  |  |
| 2456 | 630.2 | CT1 aspects of Access Network Discovery and Selection Function enhancements |  | 131d? | 2009-09-18 A | 2010-03-19 A | 100% | 2009-09-18 | 2010-03-19 | 131d? | finish no earlier than 2010-03-19 | C1 | 1048h | 1048h | eANDSF | PCG-23 | Panasonic | benjamin.limck@sg.panasonic.com | Rel-9 | CP-45 | Frederic |  |  |  |

Notes:
- 2432: CP#56 added IETF dependency
- 2433: SP#46 completed / Impacted TSs and TRs: 23.870, 23.216, 23.237
- 2434: CP#46 completed
- 2435: CP#46 completed / Impacted TSs and TRs: 24.229, 24.237
- 2436: CP#46 completed / Impacted TSs and TRs: 29.205, 29.280
- 2437: CP#46 completed / Impacted TSs and TRs: 29.163
- 2438: CP#64 completed / Impacted TSs and TRs: RFC 7254 (was draft-montemurro-gsma-imei-urn)
- 2439: - / Impacted TSs and TRs: LTE
- 2440: Triggered by abandoned Study UID_380068 (FS_LCS_EPS). Linked to Feature UID_380064 Support for IMS Emergency Calls over GPRS and EPS
- 2441: SP#44 completed / Impacted TSs and TRs: 23.891, 23.271, 23.401, 23.402
- 2442: CP#47 completed (IANA registrations outstanding). Stage 3 SLs and SLg interfaces & transport of positioning messages between E-SMLC and MME in the scope of UID_420006 (Positioning Support for LTE) / Impacted TSs and TRs: 24.080, 29.002, 29.272, 29.230, new 24.171, 29.171, 29.172, 29.173
- 2443: CP#47 completed / Impacted TSs and TRs: 24.301
- 2444: RP#48 completed. UID_400038 (LCS Control Plane Solution for EPS) depends on this WI / Impacted TSs and TRs: 34.213, 36.133, 36.211, 36.214, 36.300, 36.305, 36.331, 36.355, 36.410, 36.413, 36.455, new 36.171
- 2445: RP#55 completed. RP#56 TS 37.571-4 v200 for Approval / Impacted TSs and TRs: 36.508, 36.509, new (37.571-1, 37.571-2, 37.571-3, 37.571-4, 37.571-5)
- 2446: RP#47 completed. SP#46, CP#46 completed / Impacted TSs and TRs: LTE
- 2447: SP#44 completed / Impacted TSs and TRs: 23.246
- 2448: SP#46 completed / Impacted TSs and TRs: 33.246
- 2449: SP#46 completed / Impacted TSs and TRs: 32.273, 32.251, 32.298, 32.299
- 2450: CP#46 completed / Impacted TSs and TRs: 29.274, 29.281, 23.007, 23.008
- 2451: CP#46 completed / Impacted TSs and TRs: 29.061
- 2452: RP#47 completed / Impacted TSs and TRs: 25.446, 36.101, 36.104, 36.141, 36.300, 36.304, 36.321, 36.322, 36.323, 36.331, 36.440, 36.441, 36.442, 36.444, 36.445
- 2453: RP#54 completed / Impacted TSs and TRs: 36.508, 36.521-1, 36.521-2, 36.523-1, 36.523-2, 36.523-3
- 2454: CP#47 completed. No new Rel-9 use cases defined. Implement service requirements not covered in Rel-8 / Impacted TSs and TRs: 22.278, SA3 33.402 CR#0055
- 2455: SP#44 completed / Impacted TSs and TRs: 23.402, 23.002
- 2456: CP#47 completed / Impacted TSs and TRs: 24.302, 24.312

| ID | WBS | Task | Duration | Start | Finish | Complete | Baseline start | Baseline finish | Baseline duration | Constraint | Resources | Work | Actual work | Acronym | PCG approved | WI rapporteur name | WI rapporteur e-mail | Release | TSG approved | MCC resp | Acronym_3GU_Export | Impacted TSs and TRs | Status Report |
| --- | --- | --- | --- | --- | --- | --- | --- | --- | --- | --- | --- | --- | --- | --- | --- | --- | --- | --- | --- | --- | --- | --- | --- |
| 2457 | 631 | **Multiple PDN Connection to the Same APN for PMIP-based Interfaces** | 267d? | 2009-03-13 A | 2010-03-19 A | 100% | 2009-03-13 | 2010-03-19 | 267d? |  | S2; C4; C1 | 8392h | 8392h | MUPSAP | PCG-22 | Samsung | erik.guttman@partner.samsung.com | Rel-9 | SP-43 | Maurice | MUPSAP |  |  |
| 2458 | 631.1 | Stage 2 for Multiple PDN Connection to the Same APN for PMIP-based Interfaces | 61d? | 2009-03-13 A | 2009-06-04 A | 100% | 2009-03-13 | 2009-06-04 | 61d? | finish no earlier than 2009-06-04 | S2 | 488h | 488h | MUPSAP | PCG-22 | Samsung | erik.guttman@partner.samsung.com | Rel-9 | SP-43 | Maurice |  | 23.060, 23.203, 23.401, 23.402 |  |
| 2459 | 631.2 | CT4 aspects of Multiple PDN Connection to the Same APN for PMIP-based Interfaces | 56d? | 2009-09-18 A | 2009-12-04 A | 100% | 2009-09-18 | 2009-12-04 | 56d? | finish no earlier than 2009-12-04 | C4 | 448h | 448h | MUPSAP | PCG-23 | Samsung | Surjyakanta Mohapatra (surjya.kanta@samsung.com) | Rel-9 | CP-45 | Kimmo |  | 29.275, 23.008, 29.282 |  |
| 2460 | 631.3 | CT1 aspects of Multiple PDN Connection to the Same APN for PMIP-based Interfaces | 131d? | 2009-09-18 A | 2010-03-19 A | 100% | 2009-09-18 | 2010-03-19 | 131d? | finish no earlier than 2010-03-19 | C1 | 1048h | 1048h | MUPSAP | PCG-23 | Samsung | Surjyakanta Mohapatra (surjya.kanta@samsung.com) | Rel-9 | CP-45 | Frederic |  | 24.302 |  |
| 2461 | 632 | **System aspects of vocoder rate adaptation for LTE** | 1403.68d? | 2007-05-07 A | 2012-09-12 A | 100% | 2007-05-07 | 2012-09-12 | 1403.68d? |  | S2; S4; C1; C3; R2; IETF | 108798h | 108798h | LTEimp-Vocoder | PCG-23 | Qualcomm | AC Mahendran (ac@qualcomm.com) | Rel-9 | SP-45 | Maurice | LTEimp-Vocoder | LTE |  |
| 2462 | 632.1 | SA2 system aspects of vocoder rate adaptation for LTE | 81d? | 2009-06-04 A | 2009-09-24 A | 100% | 2009-06-04 | 2009-09-24 | 81d? | start no earlier than 2009-06-04 | S2 | 648h | 648h | LTEimp-Vocoder | PCG-23 | Qualcomm | AC Mahendran (ac@qualcomm.com) | Rel-9 | SP-45 | Maurice |  | 23.401 CR#1103r3 |  |
| 2463 | 632.2 | SA4 system aspects of vocoder rate adaptation for LTE | 136d? | 2009-06-04 A | 2009-12-10 A | 100% | 2009-06-04 | 2009-12-10 | 136d? | finish no earlier than 2009-12-07 | S4 | 1088h | 1088h | LTEimp-Vocoder | PCG-23 | Qualcomm | Nikolai Leung | Rel-9 | SP-45 | Paolo |  | 26.114 |  |
| 2464 | 632.3 | Vocoder rate adaptation for LTE | 81d? | 2009-05-30 A | 2009-09-18 A | 100% | 2009-05-30 | 2009-09-18 | 81d? | finish no earlier than 2009-09-18 | R2 | 648h | 648h | LTEimp-Vocoder | PCG-23 | Alcatel-Lucent | Sudeep Palat (spalat@alcatel-lucent.com) | Rel-9 | RP-44 | Yong-Jun |  | 36.300 CR#0114 | RP-090704 |
| 2465 | 632.4 | (IETF) SA4 system aspects of vocoder rate adaptation for LTE | 677.6d? | 2009-06-04 A | 2012-09-12 A | 100% | 2009-06-04 | 2012-09-12 | 677.6d? | finish no earlier than 2012-09-14 | S4-IETF | 5420.8h | 5420.8h | LTEimp-Vocoder | PCG-27 | Lionel Morand |  | Rel-9 | SP-52 | Paolo |  | RFC 6679 (was draft-ietf-avtcore-ecn-for-rtp) |  |
| 2466 | 632.5 | (IETF) CT aspects of vocoder rate adaptation for LTE | 1400.68d? | 2007-05-07 A | 2012-09-07 A | 100% | 2007-05-07 | 2012-09-07 | 1400.68d? | finish no earlier than 2012-09-07 | C1-IETF; C3-IETF; C4-IETF | 33616.3h | 33616.3h | LTEimp-Vocoder | PCG-27 | Lionel Morand |  | Rel-9 | CP-52 | Frederic |  | RFC 6679 (was draft-ietf-avtcore-ecn-for-rtp) |  |
| 2467 | 633 | Access Security Enhancements | 505d? | 2007-07-02 A | 2009-06-04 A | 100% | 2007-07-02 | 2009-06-04 | 505d? | finish no earlier than 2009-06-03 | S3 | 4040h | 4040h | ACCSEC2 |  | Ericsson | Bengt.Sahlin@ericsson.com | Rel-9 | SP-26 | Mirko | ACCSEC2 | 33.102, 43.020 |  |
| 2468 | 634 | **Protection against Unsolicited Communication for IMS (PUCI)** | 322d? | 2008-09-18 A | 2009-12-10 A | 100% | 2008-09-18 | 2009-12-10 | 322d? |  | S3; S1 | 8216h | 8216h | PUCI | PCG-21 | NEC | Anand R. Prasad (anand@bq.jp.nec.com) | Rel-9 | SP-41 | Alain | PUCI |  |  |
| 2469 | 634.1 | Stage 1 for PUCI | 61d? | 2008-09-18 A | 2008-12-11 A | 100% | 2008-09-18 | 2008-12-11 | 61d? | finish no earlier than 2009-06-18 | S1 | 488h | 488h | PUCI | PCG-21 | NEC | Anand R. Prasad (anand@bq.jp.nec.com) | Rel-9 | SP-41 | Alain |  | 22.228 |  |
| 2470 | 634.2 | SA3 work on PUCI | 322d? | 2008-09-18 A | 2009-12-10 A | 100% | 2008-09-18 | 2009-12-10 | 322d? | finish no earlier than 2009-12-10 | S3 | 2576h | 2576h | PUCI | PCG-21 | NEC | Anand R. Prasad (anand@bq.jp.nec.com) | Rel-9 | SP-41 | Mirko |  | New 33.937 |  |
| 2471 | 635 | **IMS Media Plane Security** | 922d? | 2009-03-13 A | 2012-09-14 A | 100% | 2009-03-13 | 2012-09-14 | 922d? |  | S3; C1; C4; C3; IETF | 67928h | 67928h | MEDIASEC | PCG-22 | Vodafone | Peter.Howard@vodafone.com | Rel-9 | SP-43 | Mirko | MEDIASEC |  |  |
| 2472 | 635.1 | SA3 aspects of IMS Media Plane Security | 271d? | 2009-03-13 A | 2010-03-25 A | 100% | 2009-03-13 | 2010-03-25 | 271d? | finish no earlier than 2010-03-25 | S3 | 2168h | 2168h | MEDIASEC | PCG-22 | Vodafone | Peter.Howard@vodafone.com | Rel-9 | SP-43 | Mirko |  | New 33.828, 33.328 |  |
| 2473 | 635.2 | (IETF) SA3, CT1, CT3 aspects of IMS Media Plane Security | 919d? | 2009-03-18 A | 2012-09-14 A | 100% | 2009-03-18 | 2012-09-14 | 919d? | finish no earlier than 2012-09-14 | S3-IETF; C1-IETF; C3-IETF | 22056h | 22056h | MEDIASEC | PCG-27 | Peter Dawes |  | Rel-9 | SP-52 | Mirko |  | draft-dawes-dispatch-mediasec-parameter |  |
| 2474 | 635.3 | **CN aspects of IMS Media Plane Security** | 186d? | 2009-09-18 A | 2010-06-04 A | 100% | 2009-09-18 | 2010-06-04 | 186d? |  | C1; C4; C3 | 6824h | 6824h | MEDIASEC_CORE | PCG-23 | Vodafone | peter.dawes@vodafone.com | Rel-9 | CP-45 | Frederic | MEDIASEC_CORE |  |  |
| 2475 | 635.3.1 | CT1 aspects of IMS Media Plane Security | 33d? | 2009-09-18 A | 2010-03-19 A | 100% | 2009-09-18 | 2010-03-19 | 33d? | finish no earlier than 2010-03-19 | C1 | 264h | 264h | MEDIASEC_CORE | PCG-23 | Vodafone | peter.dawes@vodafone.com | Rel-9 | CP-45 | Frederic |  | 23.218, 24.229 |  |
| 2476 | 635.3.2 | CT4 aspects of IMS Media Plane Security | 131d? | 2009-09-18 A | 2010-03-19 A | 100% | 2009-09-18 | 2010-03-19 | 131d? | finish no earlier than 2010-03-19 | C4 | 1048h | 1048h | MEDIASEC_CORE | PCG-23 | Vodafone | peter.dawes@vodafone.com | Rel-9 | CP-45 | Kimmo |  | 29.238, 23.334, 29.334 |  |
| 2477 | 635.3.3 | CT3 aspects of IMS Media Plane Security | 131d? | 2009-12-04 A | 2010-06-04 A | 100% | 2009-12-04 | 2010-06-04 | 131d? | finish no earlier than 2010-06-04 | C3 | 1048h | 1048h | MEDIASEC_CORE | PCG-24 | Vodafone | peter.dawes@vodafone.com | Rel-9 | CP-46 | Adrian |  | 29.162 |  |
| 2478 | 636 | **GBAPush enhancements (Generic push layer)** | 533d? | 2008-03-12 A | 2010-03-25 A | 100% | 2008-03-12 | 2010-03-25 | 533d? |  | S3 | 8528h | 8528h | eGBAPush | PCG-23 | Ericsson | Rolf Blom | Rel-9 | SP-44 | Mirko | eGBAPush | New 33.224 |  |
| 2479 | 636.1 | SA3 part of eGBAPush (Generic push layer) | 533d? | 2008-03-12 A | 2010-03-25 A | 100% | 2008-03-12 | 2010-03-25 | 533d? | finish no earlier than 2010-03-25 | S3 | 4264h | 4264h | eGBAPush | PCG-21 | Ericsson | Rolf Blom | Rel-9 | SP-39 | Mirko |  | New 33.224 |  |
| 2480 | 637 | Extended Identity Management | 136d? | 2009-06-04 A | 2009-12-10 A | 100% | 2009-06-04 | 2009-12-10 | 136d? | finish no earlier than 2009-12-10 | S3 | 1088h | 1088h | GBA-IdM | PCG-23 | Nokia | Silke.Holtmanns@nokia.com | Rel-9 | SP-44 | Mirko | GBA-IdM | New 33.924, CT4 29.109 (added service code) |  |

Notes:
- 2457: CP#47 completed. Continues Rel-8 SAES Stage 2 UID_320005. Stage 1 in 22.278 (EPS Service requirements)
- 2458: SP#44 completed
- 2459: CP#46 completed
- 2460: CP#47 completed
- 2461: Triggered by RAN2 UID_440013 Vocoder rate adaptation for LTE
- 2462: SP#45 completed (CR adding support for Explicit Congestion Notification)
- 2463: SP#46 completed
- 2464: RP#45 completed
- 2465: SP#57 completed
- 2466: CP#57 completed
- 2467: SP#44 completed. Stopped TR 33.801. CRs 33.102,43.020 on A5/2 removal done long time ago. A5/4 introduction CRs will be done under UID_440057 128 bit encryption for GSM and GPRS. SP#26 approved WID (improved GERAN security)
- 2468: SP#46 TR 33.937 completed but no specification work done in Rel-9. Related work in OMA Categorization Based Content Screening
- 2469: SP#42 completed
- 2470: SP#46 completed. No normative work done in Rel-9
- 2471: -
- 2472: SP#47 completed
- 2473: CP#57 completed, ietf-draft discontinued, documented within 3GPP
- 2474: CP#48 completed
- 2475: CP#47 completed
- 2476: CP#47 completed
- 2477: CP#48 completed
- 2478: SP#43 umbrella to host 33.224, moved from Rel-8 to Rel-9. SP#47 completed
- 2479: SP#47 completed
- 2480: SP#46 completed. Stage 1 not identified (GBA Liberty Interworking has been outlined and GBAOpenID interworking is analogous)

| ID | WBS | Task | Duration | Start | Finish | Complete | Baseline start | Baseline finish | Baseline duration | Constraint | Resources | Work | Actual work | Acronym | PCG approved | WI rapporteur name | Release | TSG approved | MCC resp | Acronym_3GU_Export | PCG stopped | TSG stopped |
| --- | --- | --- | --- | --- | --- | --- | --- | --- | --- | --- | --- | --- | --- | --- | --- | --- | --- | --- | --- | --- | --- | --- |
| 2481 | 638 | **Network Domain Security (NDS) enhancements to support backhaul security** | 924d? | 2009-06-04 A | 2012-12-07 A | 100% | 2009-06-04 | 2012-12-07 | 924d? |  | S3; IETF | 23452.8h | 23452.8h | NDS_Backhaul | PCG-23 | Vodafone | Rel-9 | SP-44 | Mirko | NDS_Backhaul |  |  |
| 2482 | 638.1 | SA3 part of Network Domain Security (NDS) enhancements to support backhaul security | 211d? | 2009-06-04 A | 2010-03-25 A | 100% | 2009-06-04 | 2010-03-25 | 211d? | finish no earlier than 2010-03-25 | S3 | 1688h | 1688h | NDS_Backhaul | PCG-23 | Vodafone | Rel-9 | SP-44 | Mirko |  |  |  |
| 2483 | 638.2 | (IETF) SA3 part of Network Domain Security (NDS) enhancements to support backhaul security | 740.6d? | 2009-06-04 A | 2012-12-07 A | 100% | 2009-06-04 | 2012-12-07 | 740.6d? | finish no earlier than 2012-12-07 | S3-IETF | 5924.8h | 5924.8h | NDS_Backhaul | PCG-27 | Bengt Sahlin | Rel-9 | SP-52 | Mirko |  |  |  |
| 2484 | 638.3 | Deleted - CT4 part of Network Domain Security (NDS) enhancements to support backhaul security | 132d? | 2009-06-04 A | 2009-12-04 A | 100% | 2009-06-04 | 2009-12-04 | 132d? | finish no earlier than 2009-12-04 | C4 | 1056h | 1056h | NDS_Backhaul | PCG-23 | Vodafone | Rel-9 | SP-44 | Kimmo |  | PCG-24 | CP-46 |
| 2485 | 639 | **128 bit encryption for GSM and GPRS** | 136d? | 2009-06-04 A | 2009-12-10 A | 100% | 2009-06-04 | 2009-12-10 | 136d? |  | S3; C1; C4; G2; G3new | 10392h | 10392h | A5/4-GEA4 | PCG-23 | Ericsson | Rel-9 | SP-44 | Mirko | A5/4-GEA4 |  |  |
| 2486 | 639.1 | SA3 part of 128 bit encryption for GSM and GPRS | 136d? | 2009-06-04 A | 2009-12-10 A | 100% | 2009-06-04 | 2009-12-10 | 136d? | finish no earlier than 2010-01-06 | S3 | 1088h | 1088h | A5/4-GEA4 | PCG-23 | Ericsson | Rel-9 | SP-44 | Mirko |  |  |  |
| 2487 | 639.2 | CT1 part of 128 bit encryption for GSM and GPRS | 77d? | 2009-06-04 A | 2009-09-18 A | 100% | 2009-06-04 | 2009-09-18 | 77d? | start no earlier than 2009-06-04 | C1 | 616h | 616h | A5/4-GEA4 | PCG-23 | Ericsson | Rel-9 | SP-44 | Frederic |  |  |  |
| 2488 | 639.3 | CT4 part of 128 bit encryption for GSM and GPRS | 136d? | 2009-06-04 A | 2009-12-10 A | 100% | 2009-06-04 | 2009-12-10 | 136d? | start no earlier than 2009-06-04 | C4 | 1088h | 1088h | A5/4-GEA4 | PCG-23 | Ericsson | Rel-9 | SP-44 | Kimmo |  |  |  |
| 2489 | 639.4 | GERAN2 part of 128 bit encryption for GSM and GPRS | 67d? | 2009-06-04 A | 2009-09-04 A | 100% | 2009-06-04 | 2009-09-04 | 67d? | finish no earlier than 2009-09-04 | G2 | 536h | 536h | A5/4-GEA4 | PCG-23 | Ericsson | Rel-9 | SP-44 | Gert |  |  |  |
| 2490 | 639.5 | GERAN3new (testing) part of 128 bit encryption for GSM and GPRS | 122d? | 2009-06-04 A | 2009-11-20 A | 100% | 2009-06-04 | 2009-11-20 | 122d? | finish no earlier than 2009-11-20 | G3new | 976h | 976h | A5/4-GEA4 | PCG-23 | Ericsson | Rel-9 | SP-44 | Ingbert |  |  |  |
| 2491 | 639.6 | Deleted - SA2 part of 128 bit encryption for GSM and GPRS | 81d? | 2009-06-04 A | 2009-09-24 A | 100% | 2009-06-04 | 2009-09-24 | 81d? | finish no earlier than 2009-09-24 | S2 | 648h | 648h | A5/4-GEA4 | PCG-23 | Ericsson | Rel-9 | SP-44 | Maurice |  | PCG-23 | SP-45 |
| 2492 | 640 | Timed Graphics | 337d? | 2008-12-11 A | 2010-03-25 A | 100% | 2008-12-11 | 2010-03-25 | 337d? | finish no earlier than 2010-03-25 | S4 | 2696h | 2696h | TG | PCG-22 | Ericsson | Rel-9 | SP-42 | Paolo | TG |  |  |
| 2493 | 641 | Managing MTSI Media Adaptation | 197d? | 2009-03-12 A | 2009-12-10 A | 100% | 2009-03-12 | 2009-12-10 | 197d? | finish no earlier than 2009-12-10 | S4 | 1568h | 1568h | M3A | PCG-22 | Samsung | Rel-9 | SP-43 | Paolo | M3A |  |  |
| 2494 | 642 | **PSS and MBMS Aspects** | 272d? | 2009-03-12 A | 2010-03-25 A | 100% | 2009-03-12 | 2010-03-25 | 272d? |  | S4 | 6512h | 6512h | PMA | PCG-23 | Ericsson, Nokia | Rel-9 | SP-44 | Paolo | PMA |  |  |
| 2495 | 642.1 | PSS and MBMS extensions | 271d? | 2009-03-12 A | 2010-03-25 A | 100% | 2009-03-12 | 2010-03-25 | 271d? | finish no earlier than 2010-03-25 | S4 | 2168h | 2168h | PMA-MBS_Ext | PCG-22 | Ericsson | Rel-9 | SP-43 | Paolo | PMA-MBS_Ext |  |  |
| 2496 | 642.2 | Improved Video Support for PSS and MBMS | 271d? | 2009-03-12 A | 2010-03-25 A | 100% | 2009-03-12 | 2010-03-25 | 271d? | finish no earlier than 2010-03-25 | S4 | 2168h | 2168h | PMA-IVS | PCG-22 | Nokia | Rel-9 | SP-43 | Paolo | PMA-IVS |  |  |
| 2497 | 643 | IMS based PSS and MBMS User Service extensions | 197d? | 2009-03-12 A | 2009-12-10 A | 100% | 2009-03-12 | 2009-12-10 | 197d? | finish no earlier than 2009-12-10 | S4 | 1576h | 1576h | IMS_PSS_MBMS_US_EXT | PCG-22 | Ericsson | Rel-9 | SP-43 | Paolo | IMS_PSS_MBMS_US_EXT |  |  |
| 2498 | 644 | Syndicated Feed Reception within 3GPP environments | 136d? | 2009-06-04 A | 2009-12-10 A | 100% | 2009-06-04 | 2009-12-10 | 136d? | start no earlier than 2009-06-04 | S4 | 1088h | 1088h | SFR | PCG-23 | Ericsson | Rel-9 | SP-44 | Paolo | SFR |  |  |
| 2499 | 645 | Distortion Measurement Test Methods and Requirements | 131d? | 2009-09-24 A | 2010-03-25 A | 100% | 2009-09-24 | 2010-03-25 | 131d? | finish no earlier than 2010-03-25 | S4 | 1048h | 1048h | DTMR | PCG-23 | Motorola | Rel-9 | SP-45 | Paolo | DTMR |  |  |
| 2500 | 646 | **Rel-9 Operations, Administration, Maintenance and Provisioning (OAM&P)** | 601d? | 2008-02-22 A | 2010-06-10 A | 100% | 2008-02-22 | 2010-06-10 | 601d? |  | S5 | 36890.4h | 36890.4h | OAM9 | PCG-22 |  | Rel-9 | SP-42 | Mirko | OAM9 |  |  |
| 2501 | 646.1 | **Rel-9 Network Infrastructure Management** | 337d? | 2008-12-11 A | 2010-03-25 A | 100% | 2008-12-11 | 2010-03-25 | 337d? |  | S5 | 8760h | 8760h | OAM9-NIM | PCG-22 |  | Rel-9 | SP-42 | Mirko | OAM9-NIM |  |  |
| 2502 | 646.1.1 | Software Management for Network Elements | 336d? | 2008-12-11 A | 2010-03-25 A | 100% | 2008-12-11 | 2010-03-25 | 336d? | finish no earlier than 2010-03-25 | S5 | 2688h | 2688h | OAM9-NE_SWM | PCG-22 | Huawei, Nokia Siemens Networks | Rel-9 | SP-42 | Mirko | OAM9-NE_SWM |  |  |
| 2503 | 646.1.2 | Service Oriented Architecture (SOA) for IRP | 211d? | 2009-06-04 A | 2010-03-25 A | 100% | 2009-06-04 | 2010-03-25 | 211d? | finish no earlier than 2010-03-25 | S5 | 1688h | 1688h |  | PCG-23 | Ericsson, Nokia Siemens Networks | Rel-9 | SP-44 | Mirko |  |  |  |
| 2504 | 646.1.3 | IRP SOAP Solution Sets continuation from Rel-8 | 211d? | 2009-06-04 A | 2010-03-25 A | 100% | 2009-06-04 | 2010-03-25 | 211d? | finish no earlier than 2010-03-25 | S5 | 1688h | 1688h |  | PCG-23 | Ericsson | Rel-9 | SP-44 | Mirko |  |  |  |

Notes:
- 2481: Continuation of Rel-8 UID_390044 SAE security architecture. Covers gaps in backhaul security in SAE (also applicable to UTRAN and GERAN backhaul) / WI rapporteur e-mail: Peter.Howard@vodafone.com
- 2482: SP#47 completed / Impacted TSs and TRs: 33.102, 33.210, 33.310, 33.401, 33.402 / WI rapporteur e-mail: Peter.Howard@vodafone.com
- 2483: CP#58 completed / Impacted TSs and TRs: RFC 6712 (was draft-ietf-pkix-cmp-transport-protocols)
- 2484: CP#46 completed. No impact on CT4 specs / WI rapporteur e-mail: Peter.Howard@vodafone.com
- 2485: Allow 128 as an alternative to 64 bit keys (Stage 2/3 + Test spec) / WI rapporteur e-mail: Karl Norrman
- 2486: SP#46 completed / Impacted TSs and TRs: 33.102,43.020, New 55.226 / WI rapporteur e-mail: Karl Norrman
- 2487: CP#45 completed / Impacted TSs and TRs: 24.008,44.064 / WI rapporteur e-mail: Karl Norrman
- 2488: CP#46 completed. Kc128 enhancements are carried as UMTS keys => no impact on CT4 29.002, 29.060 / WI rapporteur e-mail: Karl Norrman
- 2489: GP#43 WID approved + completed / Impacted TSs and TRs: 44.018,48.008,48.018,48.058 / WI rapporteur e-mail: Karl Norrman
- 2490: GP#44 completed. GP#43 WID approved / Impacted TSs and TRs: 51.010 / WI rapporteur e-mail: Karl Norrman
- 2491: SP#45 work stopped/abandoned / Impacted TSs and TRs: 23.060 / WI rapporteur e-mail: Karl Norrman
- 2492: SP#47 completed. Provide graphics in parallel to a video stream (without requiring an umbrella scene descriptor such as 3GPP DIMS in TS 26.142) / Impacted TSs and TRs: 26.114, 26.140, 26.234, 26.244, 26.245, 26.346, New 26.430 / WI rapporteur e-mail: clinton.priddle@ericsson.com
- 2493: SP#46 completed. Work extending Rel-8 UID_34041 MTSI Video - Dynamic Rate Adaptation/Signalling of Image Size. Update speech/video adaptation algorithms used by network to control MTSI client terminal in congestion or poor transmission conditions. / Impacted TSs and TRs: 26.114 / WI rapporteur e-mail: kyunghun.jung@samsung.com
- 2494: Umbrella WI / WI rapporteur e-mail: Clinton.Priddle@ericsson.com, imed.bouazizi@nokia.com
- 2495: SP#47 completed. Extends Rel-8 UID_34043 (PSS_MBMS_OMTV) & ensures compatibility with UID_34046 (IMS_PSS_MBMS_US) / Impacted TSs and TRs: 26.234, 26.346 / WI rapporteur e-mail: Clinton.Priddle@ericsson.com
- 2496: SP#47 completed / Impacted TSs and TRs: 26.234, 26.244, 26.346, new 26.903 / WI rapporteur e-mail: imed.bouazizi@nokia.com
- 2497: SP#46 completed. Work extending Rel-8 UID_34046 (IMS_PSS_MBMS_US), SA2 UID_410034 IMSSCC-SPI (IMS Service Continuity Enhancements: Service, Policy and Interactions) / Impacted TSs and TRs: 26.237 / WI rapporteur e-mail: Markus Kampmann
- 2498: SP#46 completed. TS 26.150v100 for Approval. RSS optimized for mobile use. Reuse/reference OMA's enabler DCD. / Impacted TSs and TRs: New 26.150 / WI rapporteur e-mail: Thorsten.Lohmar@ericsson.com
- 2499: SP#47 completed / Impacted TSs and TRs: 26.131, 26.132 / WI rapporteur e-mail: Stephen Kendall (wcsk01@motorola.com)
- 2500: OAM9 is an umbrella Feature also for OAM&P related TEI9 type of changes that are not part of any other dedicated feature/WI / Impacted TSs and TRs: TR 30.819
- 2501: SP#42 umbrella BB created to host OAM WIs
- 2502: SP#47 completed / Impacted TSs and TRs: 32.531, 32.532, 32.533, new 32.537 / WI rapporteur e-mail: Bidipta Das (bidipta@huawei.com), Clemens Suerbaum (clemens.suerbaum@nsn.com)
- 2503: SP#47 completed (covering SOA Architecture & SOA-supporting Solution Set). Triggered by UID_400029 Study on Service Oriented Architecture (SOA) for IRP (TR 32.824) / Impacted TSs and TRs: 32.101, 32.102, 32.150 / WI rapporteur e-mail: edwin.tse@ericsson.com, Jörg Schmidt (joerg@cox.net)
- 2504: SP#47 completed. Continuation of Rel-8 UID_400030 IRP SOAP Solution Sets / Impacted TSs and TRs: New (32.127/ 327/ 337/ 357/ 387/ 397/ 447/ 397/ 447/ 507/ 537), 32.121,32.122,32.123,32,32.321,32.322,32.323,32.325,32.331,32.332,32.333,32.335,32.351,32.352,32.353,32.381,32.382,32.383,32.385,32.391,32.392,32.393,32.395,32.441,32.442,32.443 / WI rapporteur e-mail: John Power

| ID | WBS | Task | Duration | Start | Finish | Complete | Baseline start | Baseline finish | Baseline duration | Constraint | Resources | Work | Actual work | Acronym | PCG approved | Release | TSG approved | MCC resp | Acronym_3GU_Export | Impacted TSs and TRs | WI rapporteur name | Special Focus Doc | PCG stopped | TSG stopped |
| --- | --- | --- | --- | --- | --- | --- | --- | --- | --- | --- | --- | --- | --- | --- | --- | --- | --- | --- | --- | --- | --- | --- | --- | --- |
| 2505 | 646.2 | **Rel-9 Performance Management** | 327d? | 2009-03-12 A | 2010-06-10 A | 100% | 2009-03-12 | 2010-06-10 | 327d? |  | S5 | 7890.41h | 7890.41h | OAM9-PM | PCG-22 | Rel-9 | SP-42 | Mirko | OAM9-PM |  |  |  |  |  |
| 2506 | 646.2.1 | Enhancement of UTRAN Performance Measurements | 136d? | 2009-06-04 A | 2009-12-10 A | 100% | 2009-06-04 | 2009-12-10 | 136d? | start no earlier than 2009-06-04 | S5 | 1088h | 1088h |  | PCG-23 | Rel-9 | SP-44 | Mirko |  | 32.405 | China Mobile |  |  |  |
| 2507 | 646.2.2 | Enhancement of E-UTRAN Performance Measurements | 327d? | 2009-03-12 A | 2010-06-10 A | 100% | 2009-03-12 | 2010-06-10 | 327d? | finish no earlier than 2010-06-10 | S5 | 2616h | 2616h |  | PCG-22 | Rel-9 | SP-43 | Mirko |  | 32.425 | Motorola, Huawei |  |  |  |
| 2508 | 646.2.3 | Enhancement of EPC Performance Measurements | 197d? | 2009-03-12 A | 2009-12-10 A | 100% | 2009-03-12 | 2009-12-10 | 197d? | finish no earlier than 2010-03-25 | S5 | 1570.41h | 1570.41h |  | PCG-22 | Rel-9 | SP-43 | Mirko |  | 32.426 | China Mobile |  |  |  |
| 2509 | 646.3 | **Rel-9 Self-Organizing Networks (SON) - OAM aspects** | 601d? | 2008-02-22 A | 2010-06-10 A | 100% | 2008-02-22 | 2010-06-10 | 601d? |  | S5 | 11736h | 11736h | OAM9-SON | PCG-22 | Rel-9 | SP-43 | Mirko | OAM9-SON |  |  | SON |  |  |
| 2510 | 646.3.1 | SON self-optimization management (moved from Rel-8 LTE_SON-OAM) | 600d? | 2008-02-22 A | 2010-06-10 A | 100% | 2008-02-22 | 2010-06-10 | 600d? | finish no earlier than 2010-06-10 | S5 | 4800h | 4800h |  | PCG-21 | Rel-9 | SP-39 | Mirko |  | 32.425, new (32.521, 32.522, 32.523, 32.525) | Huawei | SON |  |  |
| 2511 | 646.3.2 | Automatic Radio Network Configuration Data Preparation | 266d? | 2009-06-04 A | 2010-06-10 A | 100% | 2009-06-04 | 2010-06-10 | 266d? | finish no earlier than 2010-06-10 | S5 | 2128h | 2128h |  | PCG-23 | Rel-9 | SP-44 | Mirko |  | 32.501, 32.502, 32.503, 32.505, new 32.507 | Nokia Siemens Networks | SON |  |  |
| 2512 | 646.4 | Rel-9 Subscription Management (SuM) evolution | 266d? | 2009-06-04 A | 2010-06-10 A | 100% | 2009-06-04 | 2010-06-10 | 266d? | finish no earlier than 2010-06-10 | S5 | 2128h | 2128h | OAM9-SuM | PCG-23 | Rel-9 | SP-44 | Mirko | OAM9-SuM | 32.140, 32.141, 32.152, 32.172, 32.175 | Ericsson |  |  |  |
| 2513 | 646.5 | Deleted - Rel-9 Trace | 196d? | 2009-03-13 A | 2009-12-10 A | 100% | 2009-03-13 | 2009-12-10 | 196d? | finish no earlier than 2009-12-10 | S5 | 1568h | 1568h | OAM9-Trace | PCG-22 | Rel-9 | SP-42 | Mirko | OAM9-Trace |  |  |  | PCG-24 | SP-46 |
| 2514 | 647 | Rel-9 Charging Management small Enhancements | 211d? | 2009-06-04 A | 2010-03-25 A | 100% | 2009-06-04 | 2010-03-25 | 211d? |  | S5 | 1688h | 1688h | CH9 | PCG-23 | Rel-9 | SP-44 | Mirko | CH9 | TR 30.819 |  |  |  |  |
| 2515 | 648 | **CS-IBCF and CS-TrGW definition in 3GPP specifications** | 472d? | 2008-05-30 A | 2010-03-19 A | 100% | 2008-05-30 | 2010-03-19 | 472d? |  | C3; C4 | 14490.3h | 14490.3h | CS-IBCF | PCG-21 | Rel-9 | CP-40 | Adrian | CS-IBCF |  | Telecom Italia |  |  |  |
| 2516 | 648.1 | CT3 aspects of CS-IBCF and CS-TrGW definition in 3GPP specifications | 472d? | 2008-05-30 A | 2010-03-19 A | 100% | 2008-05-30 | 2010-03-19 | 472d? | finish no earlier than 2009-12-04 | C3 | 3770.34h | 3770.34h | CS-IBCF | PCG-21 | Rel-9 | CP-40 | Adrian |  | 29.235 | Telecom Italia |  |  |  |
| 2517 | 648.2 | CT4 aspects of CS-IBCF and CS-TrGW definition in 3GPP specifications | 396d? | 2008-05-30 A | 2009-12-04 A | 100% | 2008-05-30 | 2009-12-04 | 396d? | finish no earlier than 2009-12-04 | C4 | 3168h | 3168h | CS-IBCF | PCG-21 | Rel-9 | CP-40 | Kimmo |  | 23.231, 29.232, new 29.238 | Telecom Italia |  |  |  |
| 2518 | 649 | **IMS – Interconnection Border Control Function (IBCF) – Transition Gateway (TrGW); Ix Interface; Stage 3** | 322d? | 2008-09-12 A | 2009-12-04 A | 100% | 2008-09-12 | 2009-12-04 | 322d? |  | C4; C3 | 10086.4h | 10086.4h | IMS_IBCF | PCG-21 | Rel-9 | CP-41 | Kimmo | IMS_IBCF |  | Alcatel-Lucent |  |  |  |
| 2519 | 649.1 | CT4 part of IMS – Interconnection Border Control Function (IBCF) – Transition Gateway (TrGW); Ix Interface; Stage 3 | 321d? | 2008-09-12 A | 2009-12-04 A | 100% | 2008-09-12 | 2009-12-04 | 321d? | finish no earlier than 2009-12-04 | C4 | 2568h | 2568h | IMS_IBCF | PCG-21 | Rel-9 | CP-41 | Kimmo |  | new 29.238 | Alcatel-Lucent |  |  |  |
| 2520 | 649.2 | CT3 part of IMS – Interconnection Border Control Function (IBCF) – Transition Gateway (TrGW); Ix Interface; Stage 3 | 295.8d? | 2008-09-12 A | 2009-12-04 A | 100% | 2008-09-12 | 2009-12-04 | 295.8d? | finish no earlier than 2010-03-19 | C3 | 2366.4h | 2366.4h | IMS_IBCF | PCG-21 | Rel-9 | CP-41 | Adrian |  | 29.162, 29.235 | Alcatel-Lucent |  |  |  |
| 2521 | 650 | IMS Application Level Gateway Control Function (ALGCF) – IMS Access Media Gateway (IMA-MGW); Iq Interface; Stage 2 and Stage 3 | 321d? | 2008-09-12 A | 2009-12-04 A | 100% | 2008-09-12 | 2009-12-04 | 321d? | finish no earlier than 2009-12-04 | C4 | 2568h | 2568h | IMS_AGCF | PCG-21 | Rel-9 | CP-41 | Kimmo | IMS_AGCF | New 23.334, 29.334 | Alcatel-Lucent |  |  |  |
| 2522 | 651 | **Enhancements of IMS Customized Alerting Tone (CAT) Service** | 392d? | 2008-12-05 A | 2010-06-04 A | 100% | 2008-12-05 | 2010-06-04 | 392d? |  | C1 | 5846.4h | 5846.4h | eCAT | PCG-22 | Rel-9 | CP-42 | Frederic | eCAT |  | China Mobile |  |  |  |
| 2523 | 651.1 | Stage 3 for Enhancements of IMS Customized Alerting Tone (CAT) Service | 391d? | 2008-12-05 A | 2010-06-04 A | 100% | 2008-12-05 | 2010-06-04 | 391d? | finish no earlier than 2010-06-04 | C1 | 3128h | 3128h | eCAT-SS | PCG-22 | Rel-9 | CP-42 | Frederic | eCAT-SS | 24.182 | China Mobile |  |  |  |
| 2524 | 652 | **Completion of IMS Restoration Procedures** | 212d? | 2009-05-29 A | 2010-03-19 A | 100% | 2009-05-29 | 2010-03-19 | 212d? |  | C3; C4; C1 | 10176h | 10176h | eIMS_RP | PCG-23 | Rel-9 | CP-44 | Kimmo | eIMS_RP |  | Ericsson |  |  |  |
| 2525 | 652.1 | CT4 aspects of Completion of IMS Restoration Procedures | 212d? | 2009-05-29 A | 2010-03-19 A | 100% | 2009-05-29 | 2010-03-19 | 212d? | finish no earlier than 2010-03-19 | C4 | 1696h | 1696h | eIMS_RP | PCG-23 | Rel-9 | CP-44 | Kimmo |  | 23.380, 23.820 | Ericsson |  |  |  |
| 2526 | 652.2 | CT1 aspects of Completion of IMS Restoration Procedures | 212d? | 2009-05-29 A | 2010-03-19 A | 100% | 2009-05-29 | 2010-03-19 | 212d? | finish no earlier than 2010-03-19 | C1 | 1696h | 1696h | eIMS_RP | PCG-23 | Rel-9 | CP-44 | Kimmo |  | 24.229 | Ericsson |  |  |  |
| 2527 | 652.3 | CT3 aspects of Completion of IMS Restoration Procedures | 212d? | 2009-05-29 A | 2010-03-19 A | 100% | 2009-05-29 | 2010-03-19 | 212d? | finish no earlier than 2010-03-19 | C3 | 1696h | 1696h | eIMS_RP | PCG-24 | Rel-9 | CP-46 | Kimmo |  | 29.061, 29.212, 29.213, 29.214, 29.215 | Ericsson |  |  |  |
| 2528 | 653 | **IMS Stage 3 IETF Protocol Alignment - phase 3** | 1458d? | 2009-05-29 A | 2014-12-05 A | 100% | 2009-05-29 | 2014-12-05 | 1455d? |  | C1; IETF | 40216h | 40216h | IMSProtoc3 | PCG-23 | Rel-9 | CP-44 | Frederic | IMSProtoc3 |  | Alcatel-Lucent |  |  |  |
| 2529 | 653.1 | CT1 aspects of IMS Stage 3 - IETF Protocol Alignment - phase 3 | 212d? | 2009-05-29 A | 2010-03-19 A | 100% | 2009-05-29 | 2010-03-19 | 212d? | finish no earlier than 2010-03-19 | C1 | 1696h | 1696h | IMSProtoc3 | PCG-23 | Rel-9 | CP-44 | Frederic |  | 23.218, 24.229, 24.930 | Alcatel-Lucent |  |  |  |
| 2530 | 653.2 | (IETF) CT1 IMS Stage 3 - IETF Protocol Alignment (RFC 7329) | 1242d? | 2009-05-29 A | 2014-12-05 A | 100% | 2009-05-29 | 2014-12-05 | 1240d? | finish no earlier than 2014-12-09 | C1-IETF | 9936h | 9936h | IMSProtoc3 | PCG-27 | Rel-9 | CP-52 | Frederic |  | RFC 7329 (was draft-kaplan-insipid-session-id) | christer.holmberg@ericsson.com |  |  |  |
| 2531 | 653.3 | (IETF) CT1 IMS Stage 3 - IETF Protocol Alignment (RFC 7044) | 659d? | 2011-09-13 A | 2014-03-07 A | 100% | 2011-09-13 | 2014-03-07 | 659d? | finish no earlier than 2014-02-10 | C1-IETF | 5256h | 5256h | IMSProtoc3 | PCG-27 | Rel-9 | CP-53 | Frederic |  | RFC 7044 (was draft-ietf-sipcore-rfc4244bis) | christer.holmberg@ericsson.com |  |  |  |

Notes:
- 2505: SP#42 umbrella BB created to host OAM WIs
- 2506: SP#46 completed / WI rapporteur e-mail: liangshuangchun@cmdi.chinamobile.com, lijian@chinamobile.com, Bao Haitao
- 2507: SP#48 completed / WI rapporteur e-mail: Yizhi Yao (yzyao@motorola.com),Lan Zou (zlan@huawei.com)
- 2508: SP#46 completed / WI rapporteur e-mail: Li Jian (lijian@chinamobile.com), Liang Shuangchun (liangshuangchun@cmdi.chinamobile.com)
- 2509: SP#43 umbrella BB created to host OAM WIs
- 2510: SP#48 completed / WI rapporteur e-mail: Lan Zou (zlan@huawei.com)
- 2511: SP#48 completed / WI rapporteur e-mail: clemens.suerbaum@nsn.com
- 2512: SP#48 completed / WI rapporteur e-mail: frode.nergard@ericsson.com
- 2513: SP#46 stopped (no work in Rel-9)
- 2514: CH9 is an umbrella Feature also for OAM&P related TEI9 type of changes that are not part of any other dedicated feature/WI
- 2515: CP#47 completed. Rel-8 UID_380061 (Ipinterc) covers Stage 1 in SA1 22.101, 22.228 / WI rapporteur e-mail: mauro.ficaccio@telecomitalia.it
- 2516: CP#47 completed / WI rapporteur e-mail: mauro.ficaccio@telecomitalia.it
- 2517: CP#46 completed / WI rapporteur e-mail: mauro.ficaccio@telecomitalia.it
- 2518: CP#46 completed / WI rapporteur e-mail: bruno.landais@alcatel-lucent.fr
- 2519: CP#46 completed / WI rapporteur e-mail: bruno.landais@alcatel-lucent.fr
- 2520: CP#46 completed / WI rapporteur e-mail: bruno.landais@alcatel-lucent.fr
- 2521: CP#46 completed / WI rapporteur e-mail: bruno.landais@alcatel-lucent.fr
- 2522: CP#48 completed. Stage 1 in 22.182 / WI rapporteur e-mail: Jiang Yi
- 2523: CP#48 completed / WI rapporteur e-mail: Jiang Yi
- 2524: CP#47 completed. Continuation of Rel-8 Feature UID_400012 IMS Restoration Procedures / WI rapporteur e-mail: Emiliano Merino (emiliano.merino@ericsson.com)
- 2525: CP#47 completed / WI rapporteur e-mail: Emiliano Merino (emiliano.merino@ericsson.com)
- 2526: CP#47 completed / WI rapporteur e-mail: Emiliano Merino (emiliano.merino@ericsson.com)
- 2527: CP#47 completed / WI rapporteur e-mail: Emiliano Merino (emiliano.merino@ericsson.com)
- 2528: CP#47 completed / WI rapporteur e-mail: Keith Drage (drage@alcatel-lucent.com)
- 2529: CP#47 completed / WI rapporteur e-mail: Keith Drage (drage@alcatel-lucent.com)
- 2530: CP#65 completed / WI rapporteur e-mail: christer.holmberg@ericsson.com
- 2531: CP#63 completed / WI rapporteur e-mail: christer.holmberg@ericsson.com

| ID | WBS | Task | Type | Duration | Start | Finish | Complete | Remaining | Baseline start | Baseline finish | Baseline duration | Total slack | Constraint | Resources | Work | Actual work | Acronym | PCG approved | WI rapporteur name | WI rapporteur e-mail | Release | TSG approved | MCC resp | Acronym_3GU_Export | Special Focus Doc | Status Report |
| --- | --- | --- | --- | --- | --- | --- | --- | --- | --- | --- | --- | --- | --- | --- | --- | --- | --- | --- | --- | --- | --- | --- | --- | --- | --- | --- |
| 2532 | 654 | **Operational description of the Inter-IMS Network to Network Interface (II-NNI)** |  | 1460d? | 2009-05-29 A | 2014-12-09 | 98% | 23.12d? | 2009-05-29 | 2014-12-05 | 1455d? | 657d |  | C3; IETF | 58408h | 38763.2h | II-NNI | PCG-23 | Orange | sebastien.daudet@orange-ftgroup.com | Rel-9 | CP-44 | Adrian | II-NNI |  |  |
| 2533 | 654.1 | Operational description of the Inter-IMS Network to Network Interface |  | 267d? | 2009-05-29 A | 2010-06-04 A | 100% |  | 2009-05-29 | 2010-06-04 | 267d? |  | start no earlier than 2009-05-29 | C3 | 2136h | 2136h | II-NNI | PCG-23 | Orange |  | Rel-9 | CP-44 | Adrian |  |  |  |
| 2534 | 654.2 | (IETF) Operational description of the Inter-IMS Network to Network Interface (RFC 7329) |  | 633d? | 2012-04-20 A | 2014-09-12 A | 100% |  | 2012-04-20 | 2014-12-05 | 693d? |  | finish no earlier than 2014-09-12 | C3-IETF | 5040h | 5040h | II-NNI | PCG-29 | christer.holmberg@ericsson.com | christer.holmberg@ericsson.com | Rel-9 | CP-56 | Adrian |  |  |  |
| 2535 | 654.3 | (IETF) Operational description of the Inter-IMS Network to Network Interface (RFC 7316) |  | 634d? | 2012-04-20 A | 2014-09-12 A | 100% |  | 2012-04-20 | 2014-12-05 | 694d? |  | finish no earlier than 2014-12-09 | C3-IETF | 5064h | 5064h | II-NNI | PCG-29 | Keith Drage | Keith Drage | Rel-9 | CP-56 | Adrian |  |  |  |
| 2536 | 654.4 | (IETF) Operational description of the Inter-IMS Network to Network Interface |  | 696d? | 2012-04-20 A | 2014-12-09 | 90% | 69.6d? | 2012-04-20 | 2014-12-05 | 694d? | 657d | finish no earlier than 2014-12-09 | C3-IETF | 5560h | 5003.2h | II-NNI | PCG-29 | Roland Jesske | Roland Jesske | Rel-9 | CP-56 | Adrian |  |  |  |
| 2537 | 654.5 | (IETF) Operational description of the Inter-IMS Network to Network Interface |  | 696d? | 2012-04-20 A | 2014-12-09 A | 100% |  | 2012-04-20 | 2014-12-05 | 694d? |  | finish no earlier than 2014-12-09 | C3-IETF | 5536h | 5536h | II-NNI | PCG-29 | Roland Jesske | Roland Jesske | Rel-9 | CP-56 | Adrian |  |  |  |
| 2538 | 654.6 | (IETF) Operational description of the Inter-IMS Network to Network Interface |  | 697d? | 2012-04-20 A | 2014-12-09 A | 100% |  | 2012-04-20 | 2014-12-05 | 695d? |  | finish no earlier than 2014-12-09 | C3-IETF | 5560h | 5560h | II-NNI | PCG-29 | Keith Drage | Keith Drage | Rel-9 | CP-56 | Adrian |  |  |  |
| 2539 | 654.7 | Deleted - (IETF) Operational description of the Inter-IMS Network to Network Interface |  | 433d? | 2012-04-20 A | 2013-12-06 A | 100% |  | 2012-04-20 | 2014-12-05 | 694d? |  | finish no earlier than 2013-12-06 | C3-IETF | 3456h | 3456h | II-NNI | PCG-29 | Peter Dawes | peter.dawes@vodafone.com | Rel-9 | CP-56 | Adrian |  |  |  |
| 2540 | 654.8 | Deleted - (IETF) Operational description of the Inter-IMS Network to Network Interface (avasarala-dispatch-comm-div-notification) |  | 340d? | 2013-03-01 A | 2014-06-13 A | 100% |  | 2013-03-01 | 2014-06-13 | 340d? |  | finish no earlier than 2014-06-13 | C3-IETF | 2696h | 2696h | II-NNI | PCG-30 | Andrew Allen | Andrew Allen | Rel-9 | CP-59 | Adrian |  |  |  |
| 2541 | 655 | Definition of Ml interface for Control Plane LCS (Stage 3) |  | 131d? | 2009-09-18 A | 2010-03-19 A | 100% |  | 2009-09-18 | 2010-03-19 | 131d? |  | finish no earlier than 2010-03-19 | C1 | 1048h | 1048h | EMC2 | PCG-23 | Alcatel-Lucent | Keith Drage (drage@alcatel-lucent.com) | Rel-9 | CP-45 | Frederic | EMC2 | Public Safety (I-A) |  |
| 2542 | 656 | PCC enhancements |  | 56d? | 2009-09-18 A | 2009-12-04 A | 100% |  | 2009-09-18 | 2009-12-04 | 56d? |  | finish no earlier than 2009-12-04 | C3 | 448h | 448h | PCC-Enh | PCG-23 | Huawei | Wei Weihua (weiwh@huawei.com) | Rel-9 | CP-45 | Adrian | PCC-Enh |  |  |
| 2543 | 657 | 3GPP IMS Conferencing Management Object (MO) |  | 2d? | 2009-12-03 A | 2009-12-04 A | 100% |  | 2009-12-03 | 2009-12-04 | 2d? |  | start no earlier than 2009-12-03 | C1 | 16h | 16h | IMS_ConfMO | PCG-24 |  |  | Rel-9 | CP-46 | Frederic | IMS_ConfMO |  |  |
| 2544 | 658 | In Case of Emergency (ICE) Graphics |  | 3d? | 2010-03-17 A | 2010-03-19 A | 100% |  | 2010-03-17 | 2010-03-19 | 3d? |  | finish no earlier than 2010-03-19 | C6 | 24h | 24h | ICE_Graphics | PCG-24 | Sagem-Orga | heiko.kruse@sagem-orga.com | Rel-9 | CP-47 | Xavier | ICE_Graphics |  |  |
| 2545 | 659 | **Rel-9 Improvements of the Radio Interface** |  | 397d? | 2008-09-12 A | 2010-03-19 A | 100% |  | 2008-09-12 | 2010-03-19 | 397d? |  |  | RP; GP | 19744h | 19744h | RInImp9 | PCG-21 |  |  | Rel-9 | RP-41 | Issam | RInImp9 |  |  |
| 2546 | 659.1 | LCR TDD UE OTA Performance Requirements |  | 186d? | 2008-09-12 A | 2009-05-29 A | 100% |  | 2008-09-12 | 2009-05-29 | 186d? |  | finish no earlier than 2009-05-29 | R4 | 1488h | 1488h | RInImp9-RFLCROTA | PCG-21 | RITT | Wu Xiang (wuxiang@chinattl.com) | Rel-9 | RP-41 | Issam | RInImp9-RFLCROTA |  | RP-090389 |
| 2547 | 659.2 | **RF requirements for Multicarrier and Multi-RAT BS** |  | 347d? | 2008-11-21 A | 2010-03-19 A | 100% |  | 2008-11-21 | 2010-03-19 | 347d? |  |  | R4; G1 | 10336h | 10336h | RInImp9-RFmulti | PCG-21 | Ericsson | Johan.skold@ericsson.com | Rel-9 | RP-41 | Issam | RInImp9-RFmulti |  |  |
| 2548 | 659.2.1 | RAN4 part of RF requirements for Multicarrier and Multi RAT BS |  | 337d? | 2008-12-05 A | 2010-03-19 A | 100% |  | 2008-12-05 | 2010-03-19 | 337d? |  | finish no earlier than 2010-03-19 | R4 | 2696h | 2696h | RInImp9-Rfmulti | PCG-22 | Ericsson | johan.skold@ericsson.com | Rel-9 | RP-42 | Issam |  |  | RP-100027 |
| 2549 | 659.2.2 | GERAN part of RF requirements for Multicarrier and Multi RAT BS |  | 261d? | 2008-11-21 A | 2009-11-20 A | 100% |  | 2008-11-21 | 2009-11-20 | 261d? |  | finish no earlier than 2009-11-20 | G1 | 2088h | 2088h | RInImp9-RFmulti-GERAN | PCG-22 | Ericsson | mats.y.samuelsson@ericsson.com | Rel-9 | GP-40 | Paolo | RInImp9-RFmulti-GERAN |  |  |
| 2550 | 659.3 | Extended UMTS/LTE 800 MHz | milestone | 0d? | 2008-12-05 A | 2008-12-05 A | 100% |  | 2008-12-05 | 2009-09-18 | 207d? |  |  | R4; R2; R3 |  |  | RInImp9-UMTSLTE800 | PCG-22 | NTT DoCoMo | Shingo Suwa (suwas@nttdocomo.co.jp) | Rel-9 | RP-42 | Issam | RInImp9-UMTSLTE800 |  | RP-090687 |
| 2551 | 659.4 | UMTS/LTE 800 MHz for Europe | milestone | 0d? | 2009-03-06 A | 2009-03-06 A | 100% |  | 2009-03-06 | 2010-03-19 | 272d? |  | finish no earlier than 2010-03-19 | R4; R2; R3 |  |  | RInImp9-UMTSLTE800EU | PCG-22 | Ericsson | olav.queseth@ericsson.com | Rel-9 | RP-43 | Issam | RInImp9-UMTSLTE800EU |  | RP-100028 |
| 2552 | 659.5 | Performance requirement for LCR TDD with UE speeds up to 350 km/h |  | 196d? | 2009-03-06 A | 2009-12-04 A | 100% |  | 2009-03-06 | 2009-12-04 | 196d? |  | finish no earlier than 2009-12-04 | R4 | 1568h | 1568h | RInImp9-LCRTDD350 | PCG-22 | CATT | Yuexia Song (songyuexia@catt.cn) | Rel-9 | RP-43 | Issam | RInImp9-LCRTDD350 |  | RP-091035 |
| 2553 | 659.6 | Extended UMTS/LTE 1500 MHz | milestone | 0d? | 2009-05-30 A | 2009-05-30 A | 100% |  | 2009-05-30 | 2010-03-19 | 211d? |  | finish no earlier than 2010-03-19 | R4; R2; R3 |  |  | UMTSLTE1500 | PCG-23 | NTT DoCoMo | Shingo Suwa (suwas@nttdocomo.co.jp) | Rel-9 | RP-44 | Issam | UMTSLTE1500 |  | RP-100029 |
| 2554 | 660 | **Rel-9 Improvements of the Radio Interface - UE Conformance Testing** |  | 350d? | 2009-05-19 A | 2010-09-17 A | 100% |  | 2009-05-19 | 2010-09-17 | 350d? |  |  | R5 | 8184h | 8184h |  | PCG-23 |  |  | Rel-9 | RP-44 | Ingbert |  |  |  |
| 2555 | 660.1 | Conformance Test Aspects – UMTS/LTE in 800 MHz for Europe |  | 350d? | 2009-05-19 A | 2010-09-17 A | 100% |  | 2009-05-19 | 2010-09-17 | 350d? |  | finish no earlier than 2010-09-17 | R5 | 2800h | 2800h | RInImp-UEConTest-UMTSLTE800EU | PCG-23 | Ericsson | fredrik.sundstrom@ericsson.com | Rel-9 | RP-44 | Ingbert | RInImp-UEConTest-UMTSLTE800EU |  | RP-100736 |
| 2556 | 660.2 | Conformance Test Aspects – Extended UMTS/LTE 1500 MHz |  | 186d? | 2009-09-18 A | 2010-06-04 A | 100% |  | 2009-09-18 | 2010-06-04 | 186d? |  | finish no earlier than 2010-06-04 | R5 | 1488h | 1488h | UMTSLTE1500_UEConTest | PCG-23 | NTT DoCoMo | Nguyen Dung Dao (dao@nttdocomo.co.jp) | Rel-9 | RP-45 | Ingbert | UMTSLTE1500_UEConTest |  | RP-100487 |
| 2557 | 660.3 | TDD UE Over The Air (Antenna) conformance testing methodology |  | 81d? | 2009-05-30 A | 2009-09-18 A | 100% |  | 2009-05-30 | 2009-09-18 | 81d? |  | finish no earlier than 2009-09-18 | R5 | 648h | 648h | UEAnt_TDDTest | PCG-23 | CATR | Qu Yan (quyan@emcite.com) | Rel-9 | RP-44 | Ingbert | UEAnt_TDDTest |  | RP-090727 |
| 2558 | 660.4 | Conformance Test Aspects – Performance requirement for LCR TDD with UE speeds up to 350 km/h |  | 56d? | 2010-03-19 A | 2010-06-04 A | 100% |  | 2010-03-19 | 2010-06-04 | 56d? |  | finish no earlier than 2010-06-04 | R5 | 448h | 448h | RInImp9-LCRTDD350_UEConTest | PCG-24 | CATT | Xiaozhong Chen (chexiaozhong@datangmobile.cn) | Rel-9 | RP-47 | Ingbert | RInImp9-LCRTDD350_UEConTest |  | RP-100496 |
| 2559 | 661 | Conformance Test Aspects – SMS over IMS in E-UTRAN |  | 131d? | 2009-09-18 A | 2010-03-19 A | 100% |  | 2009-09-18 | 2010-03-19 | 131d? |  | finish no earlier than 2010-06-18 | R5 | 1048h | 1048h | SMSoverIMS_UEConTest | PCG-23 | Alcatel-Lucent | Nidal Khrais (khrais@alcatel-lucent.com) | Rel-9 | RP-45 | Ingbert | SMSoverIMS_UEConTest |  | RP-100072 |

Notes:
- 2532: -
- 2533: CP#48 completed / Impacted TSs and TRs: 29.165
- 2534: CP#65 complete / Impacted TSs and TRs: RFC 7329 (was draft-kaplan-insipid-session-id)
- 2535: CP#65 complete / Impacted TSs and TRs: RFC 7316 (was draft-vanelburg-dispatch-private-network-ind)
- 2536: In RFC Editors Queue. Dec.14: 75->90 / Impacted TSs and TRs: draft-ietf-salud-alert-info-urns
- 2537: In RFC Editors Queue. Mar15: 90->100%. RFC updated (was draft-ietf-cuss-sip-uui) / Impacted TSs and TRs: RFC 7433
- 2538: In RFC Editors Queue. Dec.14: 75->90. Mar15: 90->100%. RFC updated (was draft-ietf-cuss-sip-uui-isdni) / Impacted TSs and TRs: RFC 7434
- 2539: CP#62 removed from Rel-8 to Rel-11. Not completed internet-draft / Impacted TSs and TRs: Rel-12 remains draft-dawes-sipping-debug
- 2540: CP#64 Draft removed from 3GPP documentation / Impacted TSs and TRs: draft-avasarala-dispatch-comm-div-notification
- 2541: CP#47 completed [Stage 3 for Rel-7 Emergency Calls (EMC1)]. Related to Rel-9 UID_400038 LCS Control Plane Solution for EPS. Stage 2 in Rel-9 UID_400038 (23.271), UID_410037 (23.167) / Impacted TSs and TRs: 24.229
- 2542: CP#46 completed / Impacted TSs and TRs: 29.212, 29.213, 29.215
- 2543: CP#46 completed. Linked to Rel-6 UID_11051 (IMS Management objects) under the Feature UID_32021 (IMS Phase 2). MO compatible with OMA DM v1.2 & upwards and defined using OMA DM Device Description Framework (OMA-ERELD _DM-V1_2) / Impacted TSs and TRs: New 24.166
- 2544: CP#47 approved WID and completed. Added capability to store ICE graphical information (picture). Linked to CT6 Rel-8 ICE Feature UID_380059 In Case of Emergency numbers storage and easy access on UICC / Impacted TSs and TRs: 31.102 CR#0433
- 2545: RP#41 umbrella Feature created to host Rel-9 WIs / Impacted TSs and TRs: GERAN, UTRA, LTE
- 2546: RP#44 completed technical work (RAN4 internal TR abandoned) / Impacted TSs and TRs: UTRA (no TR 25.8xy produced)
- 2547: RP#47 completed. RF requirements specification applicable to Multi-Standard Radio (MSR) Base Station with multiple carriers and/or multiple 3GPP Radio Access Technologies (RAT) / Impacted TSs and TRs: GERAN, UTRA, LTE
- 2548: RP#48 completed / Impacted TSs and TRs: UTRA, LTE 25.104, 25.105, 36.104, new 37.104, 37.113, 37.141, 37.900
- 2549: GP#44 Core spec completed. GP#40 WID approved / Impacted TSs and TRs: GERAN 45.005, 51.021
- 2550: RP#45 completed / Impacted TSs and TRs: UTRA, LTE 25.101, 25.104, 25.113, 25.133, 34.124, 36.101, 36.104, 36.113, 36.124, 36.133, 36.141, 25.306, 25.307, 25.331, 36.331, 25.461, 25.466, new 36.800
- 2551: RP#47 completed / Impacted TSs and TRs: UTRA, LTE 25.101, 25.104, 25.113, 25.133, 25.141, 34.124, 36.101, 36.104, 36.113, 36.124, 36.133, 36.141, new 36.810, 25.306, 25.307, 25.331, 36.331, 25.461, 25.466
- 2552: RP#46 completed / Impacted TSs and TRs: UTRA 25.102, 25.105, 25.142
- 2553: RP#47 completed. For potential deployment in Japan / Impacted TSs and TRs: UTRA, LTE 25.101, 25.104, 25.113, 25.133, 25.141, 25.306, 25.307, 25.331, 25.461, 25.466, 34.124, 36.101, 36.104, 36.113, 36.124, 36.133, 36.141, 36.331, new (36.821, 36.307)
- 2554: - / Impacted TSs and TRs: UTRA, LTE
- 2555: RP#49 completed. Testing for UID_430009 UMTS/LTE 800 MHz for Europe / Impacted TSs and TRs: UTRA, LTE 34.108, 34.121-1, 34.121-2, 36.508, 36.521-1, 36.521-2, 36.521-3
- 2556: RP#48 completed / Impacted TSs and TRs: UTRA, LTE 34.108, 34.121-1, 34.121-2, 34.123-1, 34.123-2, 36.508, 36.521-1, 36.521-2, 36.521-3, 36.523-1, 36.523-2, 36.523-3
- 2557: RP#45 completed. Finalized TDD UE test methodology based on R4 TR 25.914 (UE and MS antenna performance evaluation method) and TS 25.144 Over the Air (Antenna) minimum performance requirements for the speech mode (terminal close to head) / Impacted TSs and TRs: UTRA 34.114
- 2558: RP#48 completed. Testing for UID_430010 Performance requirement for LCR TDD with UE speeds up to 350 km/h / Impacted TSs and TRs: UTRA 34.122
- 2559: RP#47 completed / Impacted TSs and TRs: LTE 34.229-1, 34.229-2, 34.229-3

| ID | WBS | Task | Type | Duration | Start | Finish | Complete | Remaining | Baseline start | Baseline finish | Baseline duration | Total slack | Constraint | Resources | Work | Actual work | PCG approved | Release | TSG approved | MCC resp | Acronym | WI rapporteur name | WI rapporteur e-mail | Status Report | Acronym_3GU_Export | Special Focus Doc |
| --- | --- | --- | --- | --- | --- | --- | --- | --- | --- | --- | --- | --- | --- | --- | --- | --- | --- | --- | --- | --- | --- | --- | --- | --- | --- | --- |
| 2560 | 662 | **Rel-9 RAN improvements** |  | 2395d? | 2000-01-03 A | 2009-03-06 | 99% | 0d? | 2000-01-03 | 2010-03-19 | 2667d? | 0d |  | RP | 3264h | 3264h | PCG-22 | Rel-9 | RP-43 | Issam |  |  |  |  |  |  |
| 2561 | 662.1 | Dual-Cell HSUPA | milestone | 0d? | 2009-03-06 A | 2009-03-06 A | 100% |  | 2009-03-06 | 2010-03-19 | 272d? |  | finish no earlier than 2010-03-19 | R1; R2; R3; R4 |  |  | PCG-22 | Rel-9 | RP-43 | Patrick | RANimp-DC_HSUPA | Nokia Siemens Networks | Karri Ranta-aho (karri.ranta-aho@nsn.com) | RP-100030 | RANimp-DC_HSUPA |  |
| 2562 | 662.2 | Support for different bands for Dual-Cell HSDPA | milestone | 0d? | 2009-03-06 A | 2009-03-06 A | 100% |  | 2009-03-06 | 2009-12-04 | 197d? |  |  | R4; R2; R3 |  |  | PCG-22 | Rel-9 | RP-43 | Issam | RANimp-MultiBand_DC_HSDPA | Nokia Siemens Networks | Tuomo Säynäjäkangas (tuomo.saynajakangas@nsn.com) | RP-091038 | RANimp-MultiBand_DC_HSDPA |  |
| 2563 | 662.3 | Combination of DC-HSDPA with MIMO | milestone | 0d? | 2009-03-06 A | 2009-03-06 A | 100% |  | 2009-03-06 | 2009-12-04 | 197d? |  |  | R1; R2; R3; R4 |  |  | PCG-22 | Rel-9 | RP-43 | Patrick | RANimp-DC_MIMO | Ericsson | johan.bergman@ericsson.com | RP-091039 | RANimp-DC_MIMO |  |
| 2564 | 662.4 | Transmit Antenna Array (TxAA) extension for non-MIMO UEs | milestone | 0d? | 2009-03-06 A | 2009-03-06 A | 100% |  | 2009-03-06 | 2009-12-04 | 197d? |  |  | R1; R2; R3; R4 |  |  | PCG-22 | Rel-9 | RP-43 | Patrick | RANimp-TxAA_nonMIMO | Nokia | Arto Lehti (arto.lehti@nokia.com) | RP-091040 | RANimp-TxAA_nonMIMO |  |
| 2565 | 662.5 | Cell Portion for 1.28 Mcps TDD |  | 136d? | 2000-01-03 A | 2000-07-07 A | 100% |  | 2000-01-03 | 2000-07-07 | 136d? |  |  | R3; R1; R4 | 3264h | 3264h | PCG-23 | Rel-9 | RP-44 | Juha | CP_LCRTDD | CATT | Ying Zhang (zhangying2@datangmobile.cn) | RP-091041 | CP_LCRTDD |  |
| 2566 | 663 | **Rel-9 RAN improvements - UE Conformance Testing** |  | 588d? | 2010-09-17 A | 2012-12-07 A | 100% |  | 2010-09-17 | 2012-12-07 | 588d? |  |  | R5 | 11848h | 11848h | PCG-25 | Rel-9 | RP-49 | Ingbert |  |  |  |  |  |  |
| 2567 | 663.1 | Conformance Test Aspects – Combination of DC-HSDPA with MIMO |  | 186d? | 2010-09-17 A | 2011-06-03 A | 100% |  | 2010-09-17 | 2011-06-03 | 186d? |  | finish no earlier than 2011-06-03 | R5 | 1488h | 1488h | PCG-25 | Rel-9 | RP-49 | Ingbert | RANimp-DC_MIMO_UEConTest | Ericsson | leif.mattisson@ericsson.com | RP-110510 | RANimp-DC_MIMO_UEConTest |  |
| 2568 | 663.2 | Conformance Test Aspects – Dual-Cell HSUPA |  | 453d? | 2011-03-18 A | 2012-12-07 A | 100% |  | 2011-03-18 | 2012-12-07 | 453d? |  | finish no earlier than 2012-12-07 | R5 | 3624h | 3624h | PCG-26 | Rel-9 | RP-51 | Ingbert | RANimp-DC_HSUPA_UEConTest | Ericsson | leif.mattisson@ericsson.com | RP-121524 | RANimp-DC_HSUPA_UEConTest |  |
| 2569 | 663.3 | Conformance Test Aspects – Support for different bands for Dual-Cell HSDPA |  | 254d? | 2011-03-18 A | 2012-03-02 A | 100% |  | 2011-03-18 | 2012-03-02 | 254d? |  | finish no earlier than 2012-03-02 | R5 | 2032h | 2032h | PCG-26 | Rel-9 | RP-51 | Ingbert | RANimp-MultiBand_DC_HSDPA_UEConTest | Ericsson | leif.mattisson@ericsson.com | RP-120036 | RANimp-MultiBand_DC_HSDPA_UEConTest |  |
| 2570 | 664 | **LTE improvements** |  | 587d? | 2009-03-06 A | 2011-06-03 A | 100% |  | 2009-03-06 | 2011-06-03 | 587d? |  |  | R1; R2; R4; R5 | 21840h | 21840h | PCG-22 | Rel-9 | RP-42 | Patrick | LTEimp |  |  |  | LTEimp |  |
| 2571 | 664.1 | LTE Pico NodeB RF Requirements |  | 196d? | 2009-03-06 A | 2009-12-04 A | 100% |  | 2009-03-06 | 2009-12-04 | 196d? |  | finish no earlier than 2010-03-05 | R4 | 1568h | 1568h | PCG-22 | Rel-9 | RP-43 | Issam | LTEimp-Pico_eNB-RF | Huawei | Liyan Yin (yinliyan@huawei.com) | RP-091045 | LTEimp-Pico_eNB-RF |  |
| 2572 | 664.2 | Enhanced Dual-Layer transmission for LTE | milestone | 0d? | 2009-03-06 A | 2009-03-06 A | 100% |  | 2009-03-06 | 2010-03-19 | 272d? |  | finish no earlier than 2010-03-18 | R1; R2; R4 |  |  | PCG-22 | Rel-9 | RP-43 | Patrick | LTEimp-eDL | China Mobile | Xu Xiaodong (xuxiaodong@chinamobile.com) | RP-100034 | LTEimp-eDL |  |
| 2573 | 664.3 | UE Conformance Test Aspects – Enhanced Dual-layer transmission for LTE TDD |  | 186d? | 2010-09-17 A | 2011-06-03 A | 100% |  | 2010-09-17 | 2011-06-03 | 186d? |  | finish no earlier than 2011-06-03 | R5 | 1488h | 1488h | PCG-25 | Rel-9 | RP-49 | Ingbert | LTEimp-eDL_UEConTest | China Mobile | Shanpeng Xiao (xiaoshanpeng@chinamobile.com) | RP-110509 | LTEimp-eDL_UEConTest |  |
| 2574 | 665 | Rel-9 Self-Organizing Networks (SON) | milestone | 0d? | 2009-03-06 A | 2009-03-06 A | 100% |  | 2009-03-06 | 2010-03-19 | 272d? |  | finish no earlier than 2010-03-19 | R3; R2 |  |  | PCG-22 | Rel-9 | SP-42 | Juha | SON | Nokia Siemens Networks | krzysztof.kordybach@nsn.com | RP-100038 | SON | SON |
| 2575 | 666 | **AGNSS Performances and Testing Procedures** |  | 787d? | 2008-05-16 A | 2011-05-20 A | 100% |  | 2008-05-16 | 2011-05-20 | 787d? |  |  | G1; G3new | 22664h | 22664h |  | Rel-9 |  | Paolo | AGNSSPTP | Thales | Michel.monnerat@thalesaleniaspace.com |  | AGNSSPTP |  |
| 2576 | 666.1 | AGNSS Minimum Performances |  | 472d? | 2008-05-16 A | 2010-03-05 A | 100% |  | 2008-05-16 | 2010-03-05 | 472d? |  | finish no earlier than 2010-03-05 | G1 | 3776h | 3776h |  | Rel-9 |  | Paolo | AGNSSPTP-Perfreq | Thales | Michel.monnerat@thalesaleniaspace.com |  | AGNSSPTP-Perfreq |  |
| 2577 | 666.2 | AGNSS Testing Procedures |  | 787d? | 2008-05-16 A | 2011-05-20 A | 100% |  | 2008-05-16 | 2011-05-20 | 787d? |  | finish no earlier than 2011-05-20 | G3new | 6296h | 6296h |  | Rel-9 |  | Ingbert | AGNSSPTP-MStest | Thales | Michel.monnerat@thalesaleniaspace.com |  | AGNSSPTP-MStest |  |
| 2578 | 667 | **Voice services over Adaptive Multi-user channels on One Slot** |  | 860d? | 2008-11-21 A | 2012-03-02 A | 100% |  | 2008-11-21 | 2012-03-02 | 860d? |  |  | GP; G1; G2; G3new | 71592h | 71592h | PCG-22 | Rel-9 | SP-42 | Paolo | VAMOS | Nokia Siemens Networks, China Mobile | juergen.hofmann@nsn.com, liuxiaoyu@chinamobile.com |  | VAMOS |  |
| 2579 | 667.1 | Stage 2 for Voice services over Adaptive Multi-user channels on One Slot |  | 392d? | 2008-11-21 A | 2010-05-21 A | 100% |  | 2008-11-21 | 2010-05-21 | 392d? |  | finish no earlier than 2010-05-21 | GP; G1; G2 | 9408h | 9408h | PCG-22 | Rel-9 | GP-40 | Paolo | VAMOS | Nokia Siemens Networks, China Mobile | juergen.hofmann@nsn.com, liuxiaoyu@chinamobile.com |  |  |  |
| 2580 | 667.2 | Stage 3 for Voice services over Adaptive Multi-user channels on One Slot |  | 596d? | 2008-11-24 A | 2011-03-04 A | 100% |  | 2008-11-24 | 2011-03-04 | 596d? |  | finish no earlier than 2011-03-04 | GP; G1; G2 | 14304h | 14304h | PCG-22 | Rel-9 | GP-40 | Paolo | VAMOS | Nokia Siemens Networks, China Mobile | juergen.hofmann@nsn.com, liuxiaoyu@chinamobile.com |  |  |  |
| 2581 | 667.3 | VAMOS Radio Performance Requirements |  | 651d? | 2008-11-24 A | 2011-05-20 A | 100% |  | 2008-11-24 | 2011-05-20 | 651d? |  | finish no earlier than 2011-05-20 | GP; G1; G2 | 15624h | 15624h | PCG-22 | Rel-9 | GP-40 | Paolo | VAMOS | Nokia Siemens Networks, China Mobile | juergen.hofmann@nsn.com, liuxiaoyu@chinamobile.com |  |  |  |
| 2582 | 667.4 | VAMOS - MS conformance testing |  | 392d? | 2010-09-03 A | 2012-03-02 A | 100% |  | 2010-09-03 | 2012-03-02 | 392d? |  | finish no earlier than 2012-03-02 | G3new | 3128h | 3128h | PCG-25 | Rel-9 | GP-47 | Ingbert | VAMOS_MStest | BlackBerry | Raveendra Seetharam (rseetharam@rim.com) |  | VAMOS_MStest |  |
| 2583 | 667.5 | VAMOS - BTS conformance testing |  | 201d? | 2010-11-26 A | 2011-09-02 A | 100% |  | 2010-11-26 | 2011-09-02 | 201d? |  | finish no earlier than 2011-09-02 | G1 | 1608h | 1608h | PCG-26 | Rel-9 | GP-48 | Paolo | VAMOS_BTStest | Nokia Siemens Networks | eddie.riddington@nsn.com |  | VAMOS_BTStest |  |

Notes:
- 2560: RP#47 completed / Impacted TSs and TRs: UTRA
- 2561: RP#47 completed / Impacted TSs and TRs: 25.101, 25.104, 25.133, 25.211, 25.212, 25.213, 25.214, 25.215, 25.319, 25.306, 25.321, 25.331, 25.423, 25.433
- 2562: RP#46 completed. RP#62 existing TS 25.317 replaced by new TS 25.327 / Impacted TSs and TRs: 25.101, 25.104, 25.133, 25.306, 25.308, 25.331, 25.423, 25.433, new 25.317 replaced by new TS 25.327
- 2563: RP#46 completed / Impacted TSs and TRs: 25.101, 25.104, 25.133, 25.211, 25.212, 25.213, 25.214, 25.215, 25.308, 25.321, 25.331, 26.306, 25.423, 25.433
- 2564: RP#46 completed / Impacted TSs and TRs: 25.101, 25.104, 25.211, 25.212, 25.213, 25.214, 25.215, 25.308, 25.306, 25.321, 25.331, 25.423, 25.433
- 2565: RP#46 completed / Impacted TSs and TRs: 25.102, 25.105, 25.123, 25.225, 25.423, 25.433
- 2566: -
- 2567: UTRA. RP#52 completed. Testing for Rel-9 UID_430016 Combination of DC-HSDPA with MIMO / Impacted TSs and TRs: UTRA 34.108, 34.121-1, 34.121-2, 34.123-1, 34.123-2, 34.123-3
- 2568: RP#58 completed. Testing for Rel-9 UID_430014 Dual-Cell HSUPA / Impacted TSs and TRs: UTRA 34.108, 34.121-1, 34.121-2, 34.123-1, 34.123-2, 34.123-3
- 2569: RP#55 completed. Testing for Rel-9 UID_430015 Support for different bands for Dual-Cell HSDPA / Impacted TSs and TRs: UTRA 34.108, 34.121-1, 34.121-2, 34.123-1, 34.123-2, 34.123-3
- 2570: - / Impacted TSs and TRs: LTE
- 2571: RP#46 completed / Impacted TSs and TRs: 36.104, 36.141, new 36.931
- 2572: RP#47 completed / Impacted TSs and TRs: 36.101, 36.211, 36.212, 36.213, 36.331
- 2573: RP#52 completed. Testing for UID_430029 (Enhanced Dual-Layer transmission for LTE) / Impacted TSs and TRs: 36.508, 36.521-1, 36.521-2
- 2574: RP#47 completed / Impacted TSs and TRs: LTE 25.413, 36.300, 36.413, 36.423, 48.018, New 36.902
- 2575: GP#46 still ongoing MS testing. Linked to Rel-10 RAN4 UID_450027 (AGNSS Minimum Performance for UTRAN)
- 2576: GP#45 completed (open performance requirements alignment GPS/Galileo) / Impacted TSs and TRs: 45.005
- 2577: GP#50 completed / Impacted TSs and TRs: 51.010-1, new 51.010-7
- 2578: Triggered by UID_50590 (MUROS) Study on Multi-User Reusing-One-Slot
- 2579: GP#46 completed. GP#40 WID approved / Impacted TSs and TRs: 45.001
- 2580: GP#49 completed. GP#40 WID approved / Impacted TSs and TRs: 24.008, 44.018, 45.002, 45.003, 45.004, 45.008, 48.008, 48.058
- 2581: GP#50 completed. GP#40 WID approved / Impacted TSs and TRs: 45.005
- 2582: GP#53 completed. GP#47 WID approved / Impacted TSs and TRs: 51.010-1, 51.010-2
- 2583: GP#51 completed. GP#48 WID approved / Impacted TSs and TRs: 51.021

| ID | WBS | Task | Type | Duration | Start | Finish | Complete | Baseline start | Baseline finish | Baseline duration | Constraint | Resources | Work | Actual work | Acronym | PCG approved | WI rapporteur name | WI rapporteur e-mail | Release | TSG approved | MCC resp | Acronym_3GU_Export | PCG stopped | TSG stopped | Special Focus Doc | Status Report |
| --- | --- | --- | --- | --- | --- | --- | --- | --- | --- | --- | --- | --- | --- | --- | --- | --- | --- | --- | --- | --- | --- | --- | --- | --- | --- | --- |
| 2584 | 668 | **Cell Broadcast protocol Base Station Controller – Cell Broadcast Centre (BSC-CBC)** |  | 222d? | 2009-05-15 A | 2010-03-19 A | 100% | 2009-05-15 | 2010-03-19 | 222d? |  | GP; C1 | 7024h | 7024h | CEBRO | PCG-23 | Ericsson | claes-goran.persson@ericsson.com | Rel-9 | GP-42 | Paolo | CEBRO |  |  |  |  |
| 2585 | 668.1 | GERAN part of Cell Broadcast protocol Base Station Controller – Cell Broadcast Centre |  | 212d? | 2009-05-15 A | 2010-03-05 A | 100% | 2009-05-15 | 2010-03-05 | 212d? | finish no earlier than 2010-03-05 | GP | 1696h | 1696h | CEBRO | PCG-23 | Ericsson | claes-goran.persson@ericsson.com | Rel-9 | GP-42 | Paolo |  |  |  |  |  |
| 2586 | 668.2 | CT1 part of Cell Broadcast protocol Base Station Controller – Cell Broadcast Centre |  | 222d? | 2009-05-15 A | 2010-03-19 A | 100% | 2009-05-15 | 2010-03-19 | 222d? | finish no earlier than 2010-03-19 | C1 | 1776h | 1776h | CEBRO | PCG-23 | Ericsson | claes-goran.persson@ericsson.com | Rel-9 | GP-42 | Frederic |  |  |  |  |  |
| 2587 | 669 | Hybrid Location |  | 136d? | 2009-05-18 A | 2009-11-20 A | 100% | 2009-05-18 | 2009-11-20 | 136d? | finish no earlier than 2009-11-20 | GP | 1088h | 1088h | HILT | PCG-23 | TruePosition | Matt Ward (mward@trueposition.com) | Rel-9 | GP-42 | Paolo | HILT |  |  |  |  |
| 2588 | 670 | (Small) Technical Enhancements and Improvements for Rel-9 |  | 325d? | 2008-09-15 A | 2009-12-10 A | 100% | 2008-09-15 | 2009-12-10 | 325d? | finish no earlier than 2009-12-10 | SP; CP; RP; GP | 10400h | 10400h | TEI9 | PCG-22 |  |  | Rel-9 | SP-42 | All | TEI9 |  |  |  |  |
| 2589 | 671 | Test - (Small) Technical Enhancements and Improvements for Rel-9 |  | 286d? | 2009-11-20 A | 2010-12-24 A | 100% | 2009-11-20 | 2010-12-24 | 286d? | finish no earlier than 2010-12-24 | R5; G3new | 4576h | 4576h | TEI9_Test | PCG-24 |  |  | Rel-9 | GP-44 | Ingbert | TEI9_Test |  |  |  |  |
| 2590 | 672 | **Deleted - Services Alignment and Migration** |  | 467d? | 2006-12-06 A | 2008-09-18 A | 100% | 2006-12-06 | 2008-09-18 | 467d? |  | S1 | 7472h | 7472h | ServAl |  | Telefónica O2 | chris.friel@O2.com | Rel-9 | SP-33 | Alain | ServAl | PCG-21 | SP-41 |  |  |
| 2591 | 672.1 | Deleted - Stage 1 for ServAl |  | 467d? | 2006-12-06 A | 2008-09-18 A | 100% | 2006-12-06 | 2008-09-18 | 467d? | finish no earlier than 2008-12-11 | S1 | 3736h | 3736h |  | PCG-21 | Telefónica O2 | chris.friel@O2.com | Rel-9 | SP-33 | Alain |  | PCG-21 | SP-41 |  |  |
| 2592 | 673 | Deleted - Harmonization of Gq'/Rx for Common IMS |  | 304d? | 2008-01-14 A | 2009-03-12 A | 100% | 2008-01-14 | 2009-03-12 | 304d? | finish no earlier than 2009-03-12 | S2 | 2432h | 2432h | IMS_Comm_GqRx_Harm | PCG-21 | Alcatel-Lucent | geoffrey.cristallo@alcatel-lucent.be | Rel-9 | SP-38 | Maurice | IMS_Comm_GqRx_Harm | PCG-22 | SP-43 |  |  |
| 2593 | 674 | Deleted - Support of WiMAX - LTE Mobility |  | 407d? | 2008-06-06 A | 2009-12-25 A | 100% | 2008-06-06 | 2009-12-25 | 407d? | start no earlier than 2008-06-06 | R2 | 3248h | 3248h | WiMAX_LTE_Mobility | PCG-21 | Samsung |  | Rel-9 | RP-38 | Yong-Jun | WiMAX_LTE_Mobility | PCG-21 | SP-39 |  |  |
| 2594 | 675 | Deleted - Support of WiMAX - UMTS Mobility |  | 407d? | 2008-06-06 A | 2009-12-25 A | 100% | 2008-06-06 | 2009-12-25 | 407d? | start no earlier than 2008-06-06 | R2 | 3248h | 3248h | WiMAX_UMTS_Mobility | PCG-21 | Intel |  | Rel-9 | RP-38 | Yong-Jun | WiMAX_UMTS_Mobility | PCG-21 | SP-39 |  |  |
| 2595 | 676 | Deleted - Definition of 3GPP UICC services over the new high-speed interface | milestone | 0d? | 2010-03-19 A | 2010-03-19 A | 100% | 2010-03-19 | 2010-03-19 | 0d? |  | C6 |  |  | UICCHS | PCG-21 | Gemalto | Denis.Lheriteau@gemalto.com | Rel-9 | CP-38 | Xavier | UICCHS | PCG-24 | CP-47 |  |  |
| 2596 | 677 | **Deleted - SAES Enhancements (non RAN aspects)** |  | 381d? | 2007-06-25 A | 2008-12-08 A | 100% | 2007-06-25 | 2008-12-08 | 381d? |  | S2 | 11664h | 11664h | SAES_Ph2 | PCG-21 | Nokia Siemens Networks |  | Rel-9 | SP-39 | Maurice | SAES_Ph2 | PCG-21 | SP-39 |  |  |
| 2597 | 677.1 | Deleted - Functions and procedures for SAE to support LTE MBMS |  | 381d? | 2007-06-25 A | 2008-12-08 A | 100% | 2007-06-25 | 2008-12-08 | 381d? | finish no earlier than 2008-12-08 | S2 | 3048h | 3048h | SAES_Ph2 |  |  |  | Rel-9 | SP-35 | Maurice |  | PCG-21 | SP-39 |  |  |
| 2598 | 677.2 | Deleted - CS over EPS |  | 194d? | 2008-03-12 A | 2008-12-08 A | 100% | 2008-03-12 | 2008-12-08 | 194d? | finish no earlier than 2008-12-08 | S2 | 1552h | 1552h | SAES_Ph2 | PCG-21 |  |  | Rel-9 | SP-39 | Maurice |  | PCG-21 | SP-39 |  |  |
| 2599 | 677.3 | **Deleted - SAE for generic support for non-3GPP accesses** |  | 251d? | 2007-06-25 A | 2008-06-09 A | 100% | 2007-06-25 | 2008-06-09 | 251d? |  | S2 | 4016h | 4016h | SAES_Ph2 | PCG-21 |  |  | Rel-9 | SP-39 | Maurice |  | PCG-21 | SP-39 |  |  |
| 2600 | 677.3.1 | Deleted - Single Radio Aspects of SAE for Optimized Handover with WiMAX |  | 251d? | 2007-06-25 A | 2008-06-09 A | 100% | 2007-06-25 | 2008-06-09 | 251d? | finish no earlier than 2008-06-09 | S2 | 2008h | 2008h | SAES_Ph2 | PCG-21 |  |  | Rel-9 | SP-39 | Maurice |  | PCG-21 | SP-39 |  |  |
| 2601 | 678 | Deleted - Lawful Interception in the 3GPP Rel-9 |  | 211d? | 2009-06-04 A | 2010-03-25 A | 100% | 2009-06-04 | 2010-03-25 | 211d? | finish no earlier than 2010-03-25 | S3 | 1688h | 1688h | LI9 | PCG-23 | PIDS, Nortel | Koen Jaspers, Ronald Ryan | Rel-9 | SP-44 | Mirko | LI9 | PCG-24 | SP-47 |  |  |
| 2602 | 679 | Release 9 Studies | milestone | 0d? | 2008-06-05 A | 2008-06-05 A | 100% | 2008-06-05 | 2010-03-19 | 468d? |  | CP; RP; SP |  |  |  |  |  |  | Rel-9 |  |  |  |  |  |  |  |
| 2603 | 680 | Study on Service Specific Access Control in EPS |  | 136d? | 2008-06-05 A | 2008-12-11 A | 100% | 2008-06-05 | 2008-12-11 | 136d? | start no earlier than 2008-06-05 | S1 | 1088h | 1088h | FS_SSAC | PCG-21 | NTT DoCoMo | Shin-ichi Isobe (isobes@nttdocomo.co.jp) | Rel-9 | SP-40 | Alain | FS_SSAC |  |  |  |  |
| 2604 | 681 | Study on CS Domain Services over EPS access |  | 492d? | 2007-04-25 A | 2009-03-12 A | 100% | 2007-04-25 | 2009-03-12 | 492d? | finish no earlier than 2009-03-12 | S2 | 3936h | 3936h | FS_CSoPS |  | T-Mobile | Karl-Heinz.Nenner@T-Mobile.net | Rel-9 | SP-35 | Maurice | FS_CSoPS |  |  |  |  |
| 2605 | 682 | Study on Extended Support of IMS Emergency Calls |  | 319d? | 2007-09-24 A | 2008-12-11 A | 100% | 2007-09-24 | 2008-12-11 | 319d? | finish no earlier than 2009-06-18 | S2 | 2552h | 2552h | FS_IMS-eCall |  | Qualcomm | Stephen Edge | Rel-9 | SP-37 | Maurice | FS_IMS-eCall |  |  | Public Safety (I-A) |  |
| 2606 | 683 | Study on Service Continuity for Emergency Voice Calls |  | 721d? | 2006-06-08 A | 2009-03-12 A | 100% | 2006-06-08 | 2009-03-12 | 721d? | finish no earlier than 2009-03-12 | S2 | 5768h | 5768h | FS_VCCEm |  | Nortel | Ricky Kaura (rkaura@nortel.com) | Rel-9 | SP-32 | Maurice | FS_VCCEm |  |  | Public Safety (I-A) |  |
| 2607 | 684 | Study on Security Aspects of Remote Provisioning and Change of Subscription for M2M Equipment |  | 1483.15d? | 2004-04-06 A | 2009-12-10 A | 100% | 2004-04-06 | 2009-12-10 | 1483.15d? | finish no earlier than 2009-12-10 | S3; C6 | 23730.4h | 23730.4h | FS_UM2M |  | Ericsson | vesa.lehtovirta@ericsson.com | Rel-9 | SP-37 | Mirko | FS_UM2M |  |  | MTC, M2M |  |
| 2608 | 685 | Study on System Maintenance over Itf-N |  | 602d? | 2007-06-07 A | 2009-09-24 A | 100% | 2007-06-07 | 2009-09-24 | 602d? | finish no earlier than 2009-09-24 | S5 | 4808h | 4808h | FS_OAM-Maint-Itf-N |  | ZTE | Shuqiang Huang (huangsq@zte.com.cn) | Rel-9 | SP-36 | Mirko | FS_OAM-Maint-Itf-N |  |  |  |  |
| 2609 | 686 | Study on Self-Organizing Networks (SON) related OAM interfaces for Home NodeB |  | 522d? | 2007-06-07 A | 2009-06-04 A | 100% | 2007-06-07 | 2009-06-04 | 522d? | finish no earlier than 2009-12-10 | S5 | 4168h | 4168h | FS_OAM-SON-HNB |  | Huawei | Zou Lan (zlan@huawei.com) | Rel-9 | SP-36 | Mirko | FS_OAM-SON-HNB |  |  | HNB, SON |  |
| 2610 | 687 | Study on Self-healing of Self-Organizing Networks (SON) |  | 416d? | 2008-02-22 A | 2009-09-24 A | 100% | 2008-02-22 | 2009-09-24 | 416d? | finish no earlier than 2009-09-24 | S5 | 3320.15h | 3320.15h | FS_OAM-SON-SH | PCG-21 | ZTE | zhu.weihong@zte.com.cn | Rel-9 | SP-39 | Mirko | FS_OAM-SON-SH |  |  | SON |  |
| 2611 | 688 | Study on Service Oriented Architecture (SOA) for IRP |  | 262d? | 2008-06-05 A | 2009-06-04 A | 100% | 2008-06-05 | 2009-06-04 | 262d? | finish no earlier than 2009-05-20 | S5 | 2088h | 2088h | FS_OAM_SOA_IRP | PCG-21 | Ericsson | edwin.tse@ericsson.com | Rel-9 | SP-40 | Mirko | FS_OAM_SOA_IRP |  |  |  |  |
| 2612 | 689 | Study on Evaluation of the inclusion of Path Loss Based Technology in the UTRAN |  | 516d? | 2007-12-17 A | 2009-12-04 A | 100% | 2007-12-17 | 2009-12-04 | 516d? | finish no earlier than 2009-09-18 | R4 | 4120h | 4120h | FS_RAN-Pathloss | PCG-21 | Polaris Wireless | Norman Shaw (nshaw@polariswireless.com) | Rel-9 | RP-38 | Issam | FS_RAN-Pathloss |  |  |  | RP-091080 |
| 2613 | 690 | Study on LTE-Advanced |  | 781.2d? | 2007-03-23 A | 2010-03-19 A | 100% | 2007-03-23 | 2010-03-19 | 781.2d? | finish no earlier than 2010-03-19 | R1; R2; R3; R4 | 24998.4h | 24998.4h | FS_RAN_LTEA | PCG-21 | NTT DoCoMo | Tetsushi Abe | Rel-9 | RP-39 | Patrick | FS_RAN_LTEA |  |  | CA | RP-100080 |
| 2614 | 691 | Study on 1.28 Mcps TDD Home NodeB |  | 387d? | 2008-02-20 A | 2009-12-04 A | 100% | 2008-02-20 | 2009-12-04 | 387d? | finish no earlier than 2009-12-04 | R4 | 3096h | 3096h | FS_RAN-HNBLCRTDD | PCG-21 | TD Tech | Li Rong (lirong@td-tech.com) | Rel-9 | RP-41 | Issam | FS_RAN-HNBLCRTDD |  |  | HNB | RP-091081 |
| 2615 | 692 | Study on E-UTRAN Mobility Evaluation and Enhancement |  | 126d? | 2008-12-05 A | 2009-05-29 A | 100% | 2008-12-05 | 2009-05-29 | 126d? | finish no earlier than 2009-05-29 | R1 | 1008h | 1008h | FS_EUTRAN_mob | PCG-22 | Qualcomm | Rajat Prakash (rprakash@qualcomm.com) | Rel-9 | RP-42 | Patrick | FS_EUTRAN_mob |  |  |  | RP-090426 |
| 2616 | 693 | Study on Minimization of drive-tests in Next Generation Networks |  | 196d? | 2009-03-06 A | 2009-12-04 A | 100% | 2009-03-06 | 2009-12-04 | 196d? | finish no earlier than 2009-12-04 | R2 | 1568h | 1568h | FS_NGN_min_drive-tests | PCG-22 | Qualcomm | Masato Kitazoe (mkitazoe@qualcomm.com) | Rel-9 | RP-43 | Yong-Jun | FS_NGN_min_drive-tests |  |  |  | RP-091084 |
| 2617 | 694 | Study on Enhanced Interference Management for HNBs |  | 61d? | 2009-03-06 A | 2009-05-29 A | 100% | 2009-03-06 | 2009-05-29 | 61d? | start no earlier than 2009-03-06 | R4 | 488h | 488h | FS_eInterfMgmt_HNB | PCG-22 | Qualcomm | Farhad Meshkati (fmeshkat@qualcomm.com) | Rel-9 | RP-43 | Issam | FS_eInterfMgmt_HNB |  |  | HNB | RP-090429 |
| 2618 | 695 | Study on Enhanced Interference Management Mechanisms for HNBs |  | 81d? | 2009-05-30 A | 2009-09-18 A | 100% | 2009-05-30 | 2009-09-18 | 81d? | finish no earlier than 2009-09-18 | R3 | 648h | 648h | FS_eInterfMgmtMchsm_HNB | PCG-23 | Qualcomm | Farhad Meshkati (fmeshkat@qualcomm.com) | Rel-9 | RP-44 | Juha | FS_eInterfMgmtMchsm_HNB |  |  | HNB | RP-090733 |
| 2619 | 696 | Deleted - Study on Protection against SMS and MMS spam |  | 862d? | 2006-06-08 A | 2009-09-24 A | 100% | 2006-06-08 | 2009-09-24 | 862d? | finish no earlier than 2009-09-24 | S3 | 6896h | 6896h | FS_CPSMal |  | Orange | eric.gauthier@orange.ch | Rel-9 | SP-32 | Mirko | FS_CPSMal | PCG-23 | SP-45 |  |  |
| 2620 | 697 | Release 8 Features |  | 914.3d? | 2006-09-19 A | 2010-03-19 A | 100% | 2006-09-19 | 2010-03-19 | 914.3d? | start no earlier than 2000-01-03 | CP; GP; RP; SP | 29257.6h | 29257.6h |  |  |  |  | Rel-8 |  |  |  |  |  |  |  |

Notes:
- 2584: CP#47 completed. GP#45 completed. GP#42 WID approved
- 2585: GP#45 completed. GP#42 WID approved / Impacted TSs and TRs: new 48.049
- 2586: CP#47 completed / Impacted TSs and TRs: 23.041
- 2587: GP#44 completed. GP#42 WID approved (Hybrid Integrated Location Technology=HILT) / Impacted TSs and TRs: 43.059, 48.071
- 2588: SP#46 completed
- 2589: GP#44 created
- 2590: SP#41 closed (no tangible result of this work; no CR against TR 22.983). Triggered by Study UID_370086 (FSServAl)
- 2591: SP#41 closed (no tangible result of this work; no CR against TR 22.983) / Impacted TSs and TRs: 22.983
- 2592: SP#43 stopped. LS_out to TISPAN informs about stopping this activity / Impacted TSs and TRs: 23.822, 23.203
- 2593: RP#39: No agreed WID / Impacted TSs and TRs: 36.306, 36.331, 36.413, 36.300, 36.214, 36.133, 36.304
- 2594: RP#39: No agreed WID / Impacted TSs and TRs: 25.306, 25.331, 25.413
- 2595: CP#47 work stopped/abandoned / Impacted TSs and TRs: 31.xyz
- 2596: SP#39 created to host Rel-9 Wis. BUT no agreed WID
- 2597: SP#39 SAE functionality moved to Rel-9. WID returned to SA2 for re-consideration & remove MBMS for EPS from Rel 8
- 2598: SP#39 SAE functionality moved to Rel-9. BUT no agreed WID
- 2599: SP#39 SAE functionality moved to Rel-9. BUT no agreed WID
- 2600: SP#39 SAE functionality moved to Rel-9. BUT no agreed WID
- 2601: SP#47 stopped. WI + new topics moved to Rel-10 / Impacted TSs and TRs: 33.106, 33.107, 33.108
- 2602: -
- 2603: SP#42 completed. Spin-off Feature UID_420020 (SSAC) / Impacted TSs and TRs: 22.986
- 2604: SP#43 completed. Linked to Combinational Services UID_31064, Services Alignment and Migration (ServAl) UID_330017 and 3GPP System Architecture Evolution (SAES) UID_3208 / Impacted TSs and TRs: 23.879
- 2605: SP#42 completed / Impacted TSs and TRs: 23.868
- 2606: SP#43 completed / Impacted TSs and TRs: 23.826
- 2607: SP#46 completed. Triggered by the SA1 Rel-8 Study on Facilitating Machine to Machine Communication in GSM and UMTS (FS_M2M) UID_7027 in TR 22.868. / Impacted TSs and TRs: 33.812
- 2608: SP#45 completed / Impacted TSs and TRs: 32.822
- 2609: SP#44 completed. Linked to SA5 TR 32.816 Study of Management for LTE and SAE (UID_340036) / Impacted TSs and TRs: 32.821
- 2610: SP#45 completed. Linked to SA5 TR 32.816 Study of Management for LTE and SAE (UID_340036) / Impacted TSs and TRs: 32.823
- 2611: SP#44 completed. Spin-off implementation WI UID_440064 Service Oriented Architecture (SOA) for IRP / Impacted TSs and TRs: 32.824
- 2612: RP#46 completed / Impacted TSs and TRs: 25.907
- 2613: RP#47 completed / Impacted TSs and TRs: 36.913 , New 36.814, 36.912, R2 36.806 (Relay architectures for E-UTRA), R4 36.815 (LTE-Advanced feasibility studies in RAN4)
- 2614: RP#46 completed / Impacted TSs and TRs: 25.866
- 2615: RP#44 closed (RP-090452 R1 LS to RAN on Conclusions for LTE Mobility Study Item - no further Rel-9 action / no TR needed) / Impacted TSs and TRs: none
- 2616: RP#46 completed / Impacted TSs and TRs: 36.805
- 2617: RP#44 completed. Linked to UID_420008 LTE FDD Home eNodeB RF Requirements. Spin-off RAN3 UID_440015 Study on Enhanced Interference Management Mechanisms for HNBs / Impacted TSs and TRs: 25.967
- 2618: RP#45 completed. Triggered by RAN4 UID_430027 Study on Enhanced Interference Management for HNBs / Impacted TSs and TRs: 25.967
- 2619: SP#45 work stopped/abandoned / Impacted TSs and TRs: 33.9xx
- 2620: -

| ID | WBS | Task | Duration | Start | Finish | Complete | Remaining | Baseline start | Baseline finish | Baseline duration | Total slack | Constraint | Resources | Work | Actual work | Acronym | WI rapporteur name | WI rapporteur e-mail | Release | MCC resp | Acronym_3GU_Export | TSG approved | PCG approved |
| --- | --- | --- | --- | --- | --- | --- | --- | --- | --- | --- | --- | --- | --- | --- | --- | --- | --- | --- | --- | --- | --- | --- | --- |
| 2621 | 698 | **3GPP System Architecture Evolution Specification - Evolved Packet System (non RAN aspects)** | 1618d? | 2006-04-12 A | 2012-06-15 | 99% | 0d? | 2006-04-12 | 2012-06-15 | 1618d? | 0d |  | S1; S2; S3; S5; C1; C3; C4; C6; IETF | 512323h | 510115h | SAES | T-Mobile | michael.kurz@t-mobile.at | Rel-8 | Alain | SAES |  |  |
| 2622 | 698.1 | Requirements for evolution of the 3GPP system architecture | 395d? | 2006-06-08 A | 2007-12-12 A | 100% |  | 2006-06-08 | 2007-12-12 | 395d? |  | finish no earlier than 2007-11-30 | S1 | 3160h | 3160h | AIPN-SAE | T-Mobile | michael.kurz@t-mobile.at | Rel-8 | Alain | AIPN-SAE |  |  |
| 2623 | 698.2 | **High level and common (for all accesses) functions** | 629d? | 2007-01-02 A | 2009-05-29 A | 100% |  | 2007-01-02 | 2009-05-29 | 629d? |  |  | S2; S3; C1; C3; C4 | 62664h | 62664h | EPS-ComF | Nokia Siemens Networks | balazs.bertenyi@nsn.com | Rel-8 | Maurice | EPS-ComF | SP-37 |  |
| 2624 | 698.2.1 | Stage 2 for High level functions | 370d? | 2007-01-02 A | 2008-06-02 A | 100% |  | 2007-01-02 | 2008-06-02 | 370d? |  | finish no earlier than 2008-06-02 | S2 | 2960h | 2960h | SAES-SA-HLF | Motorola | Irfan.Ali@motorola.com | Rel-8 | Maurice | SAES-SA-HLF |  |  |
| 2625 | 698.2.2 | Stage 2 Security Architecture | 197d? | 2008-03-12 A | 2008-12-11 A | 100% |  | 2008-03-12 | 2008-12-11 | 197d? |  | finish no earlier than 2008-12-11 | S3 | 1576h | 1576h | SAES | Nokia Siemens Networks | marc.blommaert.ext@nsn.com | Rel-8 | Mirko |  | SP-39 | PCG-21 |
| 2626 | 698.2.3 | Stage 3 (CT1) for SAE impact on services, network functions and capabilities | 545d? | 2007-02-05 A | 2009-03-06 A | 100% |  | 2007-02-05 | 2009-03-06 | 545d? |  | finish no earlier than 2009-03-06 | C1 | 4360h | 4360h | SAES | Nokia Siemens Networks | robert.zaus@nsn.com | Rel-8 | Frederic |  |  |  |
| 2627 | 698.2.4 | Stage 3 SAE impact on existing capabilities | 480d? | 2007-02-05 A | 2008-12-05 A | 100% |  | 2007-02-05 | 2008-12-05 | 480d? |  | finish no earlier than 2008-12-12 | C3 | 3840h | 3840h | SAES | Huawei | Wei Weihua (weiwh@huawei.com) | Rel-8 | Adrian |  |  |  |
| 2628 | 698.2.5 | Stage 3 (CT4) of SAE impact on existing capabilities | 545d? | 2007-02-05 A | 2009-03-06 A | 100% |  | 2007-02-05 | 2009-03-06 | 545d? |  | finish no earlier than 2009-03-06 | C4 | 4360h | 4360h | SAES | Huawei | shahab.lavasani@huawei.com | Rel-8 | Kimmo |  |  |  |
| 2629 | 698.2.6 | Stage 2/3 for Network selection procedures | 480d? | 2007-02-05 A | 2008-12-05 A | 100% |  | 2007-02-05 | 2008-12-05 | 480d? |  | finish no earlier than 2009-03-06 | C1 | 3840h | 3840h | SAES | Nokia Siemens Networks | robert.zaus@nsn.com | Rel-8 | Frederic |  |  |  |
| 2630 | 698.2.7 | Stage 3 EPC interworking with external PDNs (SGi) | 605d? | 2007-02-05 A | 2009-05-29 A | 100% |  | 2007-02-05 | 2009-05-29 | 605d? |  | finish no earlier than 2009-05-29 | C3 | 4840h | 4840h | SAES-St3-intwk | Huawei | Wei Weihua (weiwh@huawei.com) | Rel-8 | Adrian | SAES-St3-intwk |  |  |
| 2631 | 698.2.8 | Stage 3 PCC within SAE | 605d? | 2007-02-05 A | 2009-05-29 A | 100% |  | 2007-02-05 | 2009-05-29 | 605d? |  | finish no earlier than 2009-05-29 | C3 | 4840h | 4840h | SAES-St3-PCC | Ericsson | j.javier.pastor@ericsson.com | Rel-8 | Adrian | SAES-St3-PCC |  |  |
| 2632 | 698.2.9 | Stage 3 for SAE / LTE identities | 545d? | 2007-02-05 A | 2009-03-06 A | 100% |  | 2007-02-05 | 2009-03-06 | 545d? |  | finish no earlier than 2009-03-06 | C4 | 4360h | 4360h | SAES | Huawei | shahab.lavasani@huawei.com | Rel-8 | Kimmo |  |  |  |
| 2633 | 698.2.10 | Unified guidelines for Diameter usage within 3GPP | 316d? | 2007-09-21 A | 2008-12-05 A | 100% |  | 2007-09-21 | 2008-12-05 | 316d? |  | finish no earlier than 2008-12-05 | C3 | 2528h | 2528h | SAES-DIAM | Huawei | Javier Gonzalez Gallego | Rel-8 | Adrian | SAES-DIAM | CP-37 |  |
| 2634 | 698.3 | **SAE for LTE access** | 569d? | 2007-01-02 A | 2009-03-06 A | 100% |  | 2007-01-02 | 2009-03-06 | 569d? |  |  | S2; C1; C3; C4 | 80584h | 80584h | SAES-LTE | Motorola | Irfan.Ali@motorola.com | Rel-8 | Maurice | SAES-LTE |  |  |
| 2635 | 698.3.1 | CT4 Stage 3 for protocol between EPCs | 545d? | 2007-02-05 A | 2009-03-06 A | 100% |  | 2007-02-05 | 2009-03-06 | 545d? |  | finish no earlier than 2009-03-06 | C4 | 4360h | 4360h | SAES-LTE | Huawei | shahab.lavasani@huawei.com | Rel-8 | Kimmo |  |  |  |
| 2636 | 7.2.2.1 | **SAES-SA-FP_LTE with GTP variant** | 569d? | 2007-01-02 A | 2009-03-06 A | 100% |  | 2007-01-02 | 2009-03-06 | 569d? |  |  | S2; C4 | 16448h | 16448h | SAES-SA-FP_LTE-GTP | Nokia Siemens Networks | balazs.bertenyi@nsn.com | Rel-8 | Maurice | SAES-SA-FP_LTE-GTP |  |  |
| 2637 | 698.3.2.1 | Stage 2 for SAES-SA-FP_LTE with GTP variant | 373d? | 2007-01-02 A | 2008-06-05 A | 100% |  | 2007-01-02 | 2008-06-05 | 373d? |  | finish no earlier than 2008-06-02 | S2 | 2984h | 2984h | SAES-SA-FP_LTE-GTP-St2 | Nokia Siemens Networks | balazs.bertenyi@nsn.com | Rel-8 | Maurice | SAES-SA-FP_LTE-GTP-St2 |  |  |
| 2638 | 698.3.2.2 | CT4 Stage 3 for GTP v2 protocol | 545d? | 2007-02-05 A | 2009-03-06 A | 100% |  | 2007-02-05 | 2009-03-06 | 545d? |  | finish no earlier than 2009-03-06 | C4 | 4360h | 4360h | SAES-SA-FP_LTE-GTP | Huawei | shahab.lavasani@huawei.com | Rel-8 | Kimmo | SAES-SA-FP_LTE-GTP |  |  |
| 2639 | 7.2.2.2 | **SAES-SA-FP_LTE with PMIP variant** | 569d? | 2007-01-02 A | 2009-03-06 A | 100% |  | 2007-01-02 | 2009-03-06 | 569d? |  |  | S2; C4 | 20288h | 20288h | SAES-SA-FP_LTE-IETF | Nokia Siemens Networks | balazs.bertenyi@nsn.com | Rel-8 | Maurice | SAES-SA-FP_LTE-IETF |  |  |
| 2640 | 698.3.3.1 | Stage 2 for SAES-SA-FP_LTE with PMIP variant | 373d? | 2007-01-02 A | 2008-06-05 A | 100% |  | 2007-01-02 | 2008-06-05 | 373d? |  | finish no earlier than 2008-06-02 | S2 | 2984h | 2984h | SAES-SA-FP_LTE-IETF-St2 | Nokia Siemens Networks | balazs.bertenyi@nsn.com | Rel-8 | Maurice | SAES-SA-FP_LTE-IETF-St2 |  |  |
| 2641 | 698.3.3.2 | CT4 Stage 3 for PMIP protocol within EPC | 545d? | 2007-02-05 A | 2009-03-06 A | 100% |  | 2007-02-05 | 2009-03-06 | 545d? |  | finish no earlier than 2009-03-06 | C4 | 4360h | 4360h | SAES-SA-FP_LTE-IETF | Huawei | shahab.lavasani@huawei.com | Rel-8 | Kimmo | SAES-SA-FP_LTE-IETF | CP-37 |  |
| 2642 | 698.3.3.3 | Mobile IPv4 (MIPv4) based Mobility protocols | 480d? | 2007-02-05 A | 2008-12-05 A | 100% |  | 2007-02-05 | 2008-12-05 | 480d? |  | finish no earlier than 2008-12-05 | C4 | 3840h | 3840h | SAES-SA-FP_LTE-IETF | Motorola | Lewis Milton | Rel-8 | Kimmo |  | CP-41 |  |
| 2643 | 698.3.4 | Stage 3 for UE Non-Access-Stratum (NAS) mobility procedures in idle and active mode | 545d? | 2007-02-05 A | 2009-03-06 A | 100% |  | 2007-02-05 | 2009-03-06 | 545d? |  | finish no earlier than 2009-03-06 | C1 | 4360h | 4360h | SAES-LTE | Nokia Siemens Networks | robert.zaus@nsn.com | Rel-8 | Frederic |  |  |  |
| 2644 | 698.3.5 | Stage 3 for Session management, bearer control and QoS aspects | 545d? | 2007-02-05 A | 2009-03-06 A | 100% |  | 2007-02-05 | 2009-03-06 | 545d? |  | finish no earlier than 2009-03-06 | C1 | 4360h | 4360h | SAES-LTE | Nokia Siemens Networks | robert.zaus@nsn.com | Rel-8 | Frederic |  |  |  |
| 2645 | 698.3.6 | Stage 3 for security aspects of LTE Access | 545d? | 2007-02-05 A | 2009-03-06 A | 100% |  | 2007-02-05 | 2009-03-06 | 545d? |  | finish no earlier than 2009-03-06 | C1 | 4360h | 4360h | SAES-LTE | Nokia Siemens Networks | robert.zaus@nsn.com | Rel-8 | Frederic |  |  |  |
| 2646 | 698.3.7 | Stage 3 for QoS mechanisms | 480d? | 2007-02-05 A | 2008-12-05 A | 100% |  | 2007-02-05 | 2008-12-05 | 480d? |  | finish no earlier than 2008-12-12 | C3 | 3840h | 3840h | SAES-LTE | Ericsson | j.javier.pastor@ericsson.com | Rel-8 | Adrian |  |  |  |
| 2647 | 698.3.8 | Stage 3 for EPC - HSS interface | 545d? | 2007-02-05 A | 2009-03-06 A | 100% |  | 2007-02-05 | 2009-03-06 | 545d? |  | finish no earlier than 2009-03-06 | C4 | 4360h | 4360h | SAES-LTE | Huawei | shahab.lavasani@huawei.com | Rel-8 | Kimmo |  |  |  |

Notes:
- 2621: Role model for SAE/LTE system wide project management by SA2 in SP-060166
- 2622: SP#38 completed / Impacted TSs and TRs: 22.011, 22.246, New 22.278
- 2623: CP#44 completed
- 2624: SP#40 completed / Impacted TSs and TRs: New 23.402
- 2625: SP#42 completed / Impacted TSs and TRs: 33.210, 33.310, New 33.401
- 2626: CP#43 completed / Impacted TSs and TRs: 24.229, 27.007, New 24.305
- 2627: CP#42 completed / Impacted TSs and TRs: 29.061
- 2628: CP#43 completed / Impacted TSs and TRs: New (29.274, 29.275)
- 2629: CP#42 completed / Impacted TSs and TRs: 23.122, New 24.302
- 2630: CP#44 completed / Impacted TSs and TRs: 29.061
- 2631: CP#44 completed / Impacted TSs and TRs: 29.212, 29.213, 29.214, New 29.215
- 2632: CP#43 completed / Impacted TSs and TRs: 23.003
- 2633: CP#42 completed / Impacted TSs and TRs: New 29.909
- 2634: CP#43 completed
- 2635: CP#43 completed / Impacted TSs and TRs: 29.274, 29.275
- 2636: CP#43 completed
- 2637: SP#40 completed / Impacted TSs and TRs: 23.401, 23.060, 23.002, 23.246, 23.203, 23.107, 23.234, 23.271
- 2638: CP#43 completed / Impacted TSs and TRs: 29.274
- 2639: CP#43 completed
- 2640: SP#40 completed
- 2641: CP#43 completed / Impacted TSs and TRs: 29.275, 29.282
- 2642: CP#42 completed / Impacted TSs and TRs: 29.279
- 2643: CP#43 completed / Impacted TSs and TRs: 24.007, 24.301
- 2644: CP#43 completed / Impacted TSs and TRs: 24.007, 24.301
- 2645: CP#43 completed / Impacted TSs and TRs: 24.008, 24.301
- 2646: CP#42 completed / Impacted TSs and TRs: 29.213
- 2647: CP#43 completed / Impacted TSs and TRs: 29.272

| ID | WBS | Task | Type | Duration | Start | Finish | Complete | Baseline start | Baseline finish | Baseline duration | Constraint | Resources | Work | Actual work | Acronym | WI rapporteur name | WI rapporteur e-mail | Release | MCC resp | Acronym_3GU_Export | Impacted TSs and TRs | TSG approved | PCG approved | TSG stopped |
| --- | --- | --- | --- | --- | --- | --- | --- | --- | --- | --- | --- | --- | --- | --- | --- | --- | --- | --- | --- | --- | --- | --- | --- | --- |
| 2648 | 698.4 | **SAE for Interoperation between LTE and legacy cellular PS accesses** |  | 545d? | 2007-02-05 A | 2009-03-06 A | 100% | 2007-02-05 | 2009-03-06 | 545d? |  | S2; C1; C4 | 48872h | 48872h | SAES-SA-FP_3GPP | Motorola | Irfan.Ali@motorola.com | Rel-8 | Maurice | SAES-SA-FP_3GPP |  |  |  |  |
| 2649 | 698.4.1 | Stage 2 for Interoperation between LTE and 2G/3G |  | 424d? | 2007-02-05 A | 2008-09-18 A | 100% | 2007-02-05 | 2008-09-18 | 424d? | finish no earlier than 2008-09-11 | S2 | 3392h | 3392h | EPSto2_3G | Motorola | Irfan.Ali@motorola.com | Rel-8 | Maurice | EPSto2_3G | 23.401, 23.402 | SP-37 |  |  |
| 2650 | 698.4.2 | Stage 3 for Inter-system mobility between E-UTRAN and 2G/3G |  | 545d? | 2007-02-05 A | 2009-03-06 A | 100% | 2007-02-05 | 2009-03-06 | 545d? | finish no earlier than 2009-03-06 | C1 | 4360h | 4360h | SAES-SA-FP_3GPP | Nokia Siemens Networks | robert.zaus@nsn.com | Rel-8 | Frederic | SAES-SA-FP_3GPP | 24.008, 24.301 | CP-38 | PCG-21 |  |
| 2651 | 698.4.3 | Stage 2 GPRS enhancements for LTE access |  | 272d? | 2007-09-04 A | 2008-09-18 A | 100% | 2007-09-04 | 2008-09-18 | 272d? | start no earlier than 2007-09-04 | S2 | 2176h | 2176h | SAES-GPRS_LTE | Vodafone | chris.pudney@vodafone.com | Rel-8 | Maurice | SAES-GPRS_LTE | 23.401 |  |  |  |
| 2652 | 698.4.4 | Stage 2 GPRS for EPC (23.060, etc.) |  | 179d? | 2008-01-14 A | 2008-09-18 A | 100% | 2008-01-14 | 2008-09-18 | 179d? | finish no earlier than 2008-09-18 | S2 | 1432h | 1432h | SAES-SA-FP_3GPP | Nokia Siemens Networks | balazs.bertenyi@nsn.com | Rel-8 | Maurice |  | 23.060 | SP-39 | PCG-21 |  |
| 2653 | 698.4.5 | Stage 3 for EPC - GPRS |  | 545d? | 2007-02-05 A | 2009-03-06 A | 100% | 2007-02-05 | 2009-03-06 | 545d? | finish no earlier than 2009-03-06 | C4 | 4360h | 4360h | SAES-SA-FP_3GPP | Huawei | shahab.lavasani@huawei.com | Rel-8 | Kimmo |  | 29.274, 29.275, 29.281 |  |  |  |
| 2654 | 698.4.6 | Stage 3 for EPC to UTRAN |  | 545d? | 2007-02-05 A | 2009-03-06 A | 100% | 2007-02-05 | 2009-03-06 | 545d? | finish no earlier than 2009-03-06 | C4 | 4360h | 4360h | SAES-SA-FP_3GPP | Huawei | shahab.lavasani@huawei.com | Rel-8 | Kimmo |  | 29.274, 29.275, 29.281 | CP-38 | PCG-21 |  |
| 2655 | 698.4.7 | Stage 3 for EPC to 3GPP2 |  | 545d? | 2007-02-05 A | 2009-03-06 A | 100% | 2007-02-05 | 2009-03-06 | 545d? | finish no earlier than 2009-03-06 | C4 | 4360h | 4360h | SAES-SA-FP_3GPP | Huawei | shahab.lavasani@huawei.com | Rel-8 | Kimmo |  | 29.277, 29.276 | CP-38 | PCG-21 |  |
| 2656 | 698.4.8 | Stage 2 for Interoperation between LTE and CDMA2000 |  | 329d? | 2007-06-18 A | 2008-09-18 A | 100% | 2007-06-18 | 2008-09-18 | 329d? | finish no earlier than 2008-04-25 | S2 | 2632h | 2632h | EPStoC2k | Motorola, Vodafone | Irfan.Ali@motorola.com, chris.pudney@vodafone.com | Rel-8 | Maurice | EPStoC2k | 23.401, 23.402 | CP-37 |  |  |
| 2657 | 698.4.9 | Stage 3 for Inter-system mobility between E-UTRAN and CDMA2000 |  | 545d? | 2007-02-05 A | 2009-03-06 A | 100% | 2007-02-05 | 2009-03-06 | 545d? | finish no earlier than 2009-03-06 | C1 | 4360h | 4360h | SAES-SA-FP_3GPP | Nokia Siemens Networks | robert.zaus@nsn.com | Rel-8 | Frederic |  | 24.301, 24.302 |  |  |  |
| 2658 | 698.4.10 | Stage 3 for MME - SGSN signalling free protocol |  | 545d? | 2007-02-05 A | 2009-03-06 A | 100% | 2007-02-05 | 2009-03-06 | 545d? | finish no earlier than 2009-03-06 | C4 | 4360h | 4360h | SAES-SA-FP_3GPP | Huawei | shahab.lavasani@huawei.com | Rel-8 | Kimmo |  | 29.272, 29.274 |  |  |  |
| 2659 | 698.5 | **SAE for support for non-3GPP accesses** |  | 1429d? | 2007-01-02 A | 2012-06-15 A | 100% | 2007-01-02 | 2012-06-15 | 1429d? |  | S2; S3; C1; C4; IETF | 123829h | 123829h | SAES-SA-FP_n3GPP | Motorola | Irfan.Ali@motorola.com | Rel-8 | Maurice | SAES-SA-FP_n3GPP |  |  |  |  |
| 2660 | 7.2.4.1 | Stage 2 for Host-based Mobility aspects |  | 373d? | 2007-01-02 A | 2008-06-05 A | 100% | 2007-01-02 | 2008-06-05 | 373d? | finish no earlier than 2008-04-11 | S2 | 2984h | 2984h | SAES-SA-FP_n3GPP-HBMob | Motorola | Irfan.Ali@motorola.com | Rel-8 | Maurice | SAES-SA-FP_n3GPP-HBMob | 23.402 |  |  |  |
| 2661 | 7.2.4.2 | Stage 2 for Network-based Mobility aspects |  | 448d? | 2007-01-02 A | 2008-09-18 A | 100% | 2007-01-02 | 2008-09-18 | 448d? | finish no earlier than 2008-09-18 | S2 | 3584h | 3584h | SAES-SA-FP_n3GPP-NBMob | Motorola | Irfan.Ali@motorola.com | Rel-8 | Maurice | SAES-SA-FP_n3GPP-NBMob | 23.402 |  |  |  |
| 2662 | 698.5.3 | Stage 3 for Mobility management based on DSMIPv6 |  | 480d? | 2007-02-05 A | 2008-12-05 A | 100% | 2007-02-05 | 2008-12-05 | 480d? | finish no earlier than 2008-12-05 | C1 | 3840h | 3840h | SAES-SA-FP_n3GPP | Nokia Siemens Networks | robert.zaus@nsn.com | Rel-8 | Frederic |  | 24.303 |  |  |  |
| 2663 | 698.5.4 | (IETF) Stage 3 for Mobility management based on DSMIPv6 (draft-ietf-mip6-hiopt) |  | 589d? | 2007-02-05 A | 2012-06-15 A | 100% | 2007-02-05 | 2012-06-15 | 589d? | finish no earlier than 2012-09-14 | C1-IETF | 4712h | 4712h | SAES-SA-FP_n3GPP | Mark Jones |  | Rel-8 | Frederic |  | RFC 6610 (was draft-ietf-mip6-hiopt) | CP-52 | PCG-27 |  |
| 2664 | 698.5.5 | (IETF) Stage 3 for Mobility management based on DSMIPv6 (RFC6275) |  | 356d? | 2007-02-05 A | 2011-07-29 A | 100% | 2007-02-05 | 2011-07-29 | 356d? | finish no earlier than 2011-07-29 | C1-IETF | 2848h | 2848h | SAES-SA-FP_n3GPP |  |  | Rel-8 | Frederic |  | RFC 6275 (was draft-ietf-mext-rfc3775bis) | CP-52 | PCG-27 |  |
| 2665 | 698.5.6 | Stage 3 for Mobility management based on MIP v4 |  | 480d? | 2007-02-05 A | 2008-12-05 A | 100% | 2007-02-05 | 2008-12-05 | 480d? | start no earlier than 2007-02-05 | C1 | 3840h | 3840h | SAES-SA-FP_n3GPP | Nokia Siemens Networks | robert.zaus@nsn.com | Rel-8 | Frederic |  | 24.304 | CP-39 | PCG-21 |  |
| 2666 | 698.5.7 | Stage 3 for Inter-system mobility between E-UTRAN and non 3GPP accesses |  | 545d? | 2007-02-05 A | 2009-03-06 A | 100% | 2007-02-05 | 2009-03-06 | 545d? | finish no earlier than 2009-03-06 | C1 | 4360h | 4360h | SAES-SA-FP_n3GPP | Nokia Siemens Networks | robert.zaus@nsn.com | Rel-8 | Frederic |  | 24.008, 24.301 | CP-38 | PCG-21 |  |
| 2667 | 698.5.8 | Stage 2 for Optimized Dual-Radio Handover with WiMAX |  | 249d? | 2007-06-25 A | 2008-06-05 A | 100% | 2007-06-25 | 2008-06-05 | 249d? | finish no earlier than 2008-06-09 | S2 | 1992h | 1992h | SAES-SA-FP_n3GPP-OptWIMAX | Motorola | Irfan.Ali@motorola.com | Rel-8 | Maurice | SAES-SA-FP_n3GPP-OptWIMAX | 23.402 |  |  |  |
| 2668 | 698.5.9 | Stage 2 Security aspects for non-3GPP Access |  | 197d? | 2008-03-12 A | 2008-12-11 A | 100% | 2008-03-12 | 2008-12-11 | 197d? | finish no earlier than 2008-12-11 | S3 | 1576h | 1576h | SAES-SA-FP_n3GPP | Nokia Siemens Networks | marc.blommaert.ext@nsn.com | Rel-8 | Mirko |  | 33.402, 33.210, 33.310 | SP-39 | PCG-21 |  |
| 2669 | 698.5.10 | Stage 3 security aspects for DSMIPv6 Access |  | 480d? | 2007-02-05 A | 2008-12-05 A | 100% | 2007-02-05 | 2008-12-05 | 480d? | finish no earlier than 2008-12-05 | C1 | 3840h | 3840h | SAES-SA-FP_n3GPP | Nokia Siemens Networks | robert.zaus@nsn.com | Rel-8 | Frederic |  | 24.303 | CP-37 |  |  |
| 2670 | 698.5.11 | Stage 3 security aspects for MIPv4 Access |  | 480d? | 2007-02-05 A | 2008-12-05 A | 100% | 2007-02-05 | 2008-12-05 | 480d? | finish no earlier than 2008-12-05 | C1 | 3840h | 3840h | SAES-SA-FP_n3GPP | Nokia Siemens Networks | robert.zaus@nsn.com | Rel-8 | Frederic |  | 24.304 | CP-39 | PCG-21 |  |
| 2671 | 698.5.12 | Stage 3 for Access to the EPC via non-3GPP access networks |  | 545d? | 2007-02-05 A | 2009-03-06 A | 100% | 2007-02-05 | 2009-03-06 | 545d? | finish no earlier than 2009-03-06 | C1 | 4360h | 4360h | SAES-SA-FP_n3GPP | Nokia Siemens Networks | robert.zaus@nsn.com | Rel-8 | Frederic |  | 24.302, 24.312 |  |  |  |
| 2672 | 698.5.13 | Stage 3 for interfaces within EPC |  | 383d? | 2007-09-19 A | 2009-03-06 A | 100% | 2007-09-19 | 2009-03-06 | 383d? | finish no earlier than 2009-03-06 | C4 | 3064h | 3064h | SAES-SA-FP_n3GPP | Huawei | shahab.lavasani@huawei.com | Rel-8 | Kimmo |  | 29.274, 29.281 | CP-37 |  |  |
| 2673 | 698.5.14 | Stage 3 for Interfaces EPC - non-3GPP IP access |  | 545d? | 2007-02-05 A | 2009-03-06 A | 100% | 2007-02-05 | 2009-03-06 | 545d? | finish no earlier than 2009-03-06 | C4 | 4360h | 4360h | SAES-SA-FP_n3GPP | Huawei | shahab.lavasani@huawei.com | Rel-8 | Kimmo |  | 29.273, 29.275 |  |  |  |
| 2674 | 698.5.15 | (IETF) Stage 3 for Interfaces EPC - non-3GPP IP access |  | 1224.6d? | 2007-02-05 A | 2012-06-15 A | 100% | 2007-02-05 | 2012-06-15 | 1224.6d? | finish no earlier than 2012-06-15 | C4-IETF | 9788.8h | 9788.8h | SAES-SA-FP_n3GPP | Lionel Morand |  | Rel-8 | Kimmo |  | RFC 6611 (was draft-ietf-mip6-bootstrapping-integrated) | CP-52 | PCG-27 |  |
| 2675 | 698.5.16 | Stage 3 for AAA/HSS related |  | 480d? | 2007-02-05 A | 2008-12-05 A | 100% | 2007-02-05 | 2008-12-05 | 480d? | finish no earlier than 2008-12-05 | C4 | 3840h | 3840h | SAES-SA-FP_n3GPP | Huawei | shahab.lavasani@huawei.com | Rel-8 | Kimmo |  | 29.273 |  |  |  |
| 2676 | 698.5.17 | Stage 3 for EPC - AAA interface |  | 480d? | 2007-02-05 A | 2008-12-05 A | 100% | 2007-02-05 | 2008-12-05 | 480d? | finish no earlier than 2008-12-05 | C4 | 3840h | 3840h | SAES-SA-FP_n3GPP | Huawei | shahab.lavasani@huawei.com | Rel-8 | Kimmo |  | 29.273 |  |  |  |
| 2677 | 698.5.18 | Deleted (already covered) SAES-SA-FP_n3GPP Optimized Handover with CDMA | milestone | 0d? | 2007-06-25 A | 2007-06-25 A | 100% | 2007-06-25 | 2007-06-25 | 0d? | finish no earlier than 2007-06-25 | S2 |  |  | SAES-SA-FP_n3GPP-OptCDMA | Nokia Siemens Networks |  | Rel-8 | Maurice | SAES-SA-FP_n3GPP-OptCDMA |  |  |  | SP-37 |

Notes:
- 2648: CP#43 completed
- 2649: SP#41 completed
- 2650: CP#43 completed
- 2651: SP#41 completed
- 2652: SP#41 completed
- 2653: CP#43 completed
- 2654: CP#43 completed
- 2655: CP#43 completed
- 2656: SP#41 completed (except: Handover of multiple PDNs=>Rel-9)
- 2657: CP#43 completed
- 2658: CP#43 completed
- 2659: CP#43 completed. SP#39 retained in Rel-8 (in addition to the essential functionality defined in SP-070699). Replaces UID_340037
- 2660: SP#40 completed
- 2661: SP#41 completed
- 2662: CP#42 completed
- 2663: CP#56 completed
- 2664: SP#53/IETF#81 completed
- 2665: CP#42 completed
- 2666: CP#43 completed
- 2667: SP#40 completed
- 2668: SP#42 completed
- 2669: CP#42 completed
- 2670: CP#42 completed
- 2671: CP#43 completed
- 2672: CP#43 completed
- 2673: CP#43 completed
- 2674: CP#56 completed
- 2675: CP#42 completed
- 2676: CP#42 completed
- 2677: SP#37 stopped

| ID | WBS | Task | Type | Duration | Start | Finish | Complete | Baseline start | Baseline finish | Baseline duration | Constraint | Resources | Work | Actual work | Acronym | WI rapporteur name | Release | MCC resp | Acronym_3GU_Export | Impacted TSs and TRs | PCG approved | TSG approved | PCG stopped | TSG stopped | Special Focus Doc |
| --- | --- | --- | --- | --- | --- | --- | --- | --- | --- | --- | --- | --- | --- | --- | --- | --- | --- | --- | --- | --- | --- | --- | --- | --- | --- |
| 2678 | 698.6 | **Single Radio Voice Call Continuity for 3GPP (SRVCC)** |  | 569d? | 2007-01-02 A | 2009-03-06 A | 100% | 2007-01-02 | 2009-03-06 | 569d? |  | S2; C1; C4 | 19856h | 19856h | SAES-SRVCC | Nokia Siemens Networks | Rel-8 | Maurice | SAES-SRVCC |  |  |  |  |  |  |
| 2679 | 698.6.1 | Stage 2 for 2G/3G SRVCC |  | 448d? | 2007-01-02 A | 2008-09-18 A | 100% | 2007-01-02 | 2008-09-18 | 448d? | finish no earlier than 2008-09-15 | S2 | 3584h | 3584h | SAES-SRVCC | Nokia Siemens Networks | Rel-8 | Maurice |  | New 23.216 |  |  |  |  |  |
| 2680 | 698.6.2 | Stage 3 for SRVCC in EPS |  | 201d? | 2008-05-30 A | 2009-03-06 A | 100% | 2008-05-30 | 2009-03-06 | 201d? | finish no earlier than 2009-03-06 | C1 | 1608h | 1608h | SAES-SRVCC | Nokia Siemens Networks | Rel-8 | Frederic |  | 23.009, 24.008, New 24.301 | PCG-21 | CP-41 |  |  |  |
| 2681 | 698.6.3 | MME to MSC interface for SRVCC |  | 126d? | 2008-09-12 A | 2009-03-06 A | 100% | 2008-09-12 | 2009-03-06 | 126d? | finish no earlier than 2009-03-06 | C4 | 1008h | 1008h | SAES-SRVCC | Nokia Siemens Networks | Rel-8 | Kimmo |  | 23.003, 23.008, New (29.274, 29.277, 29.280) | PCG-21 | CP-41 |  |  |  |
| 2682 | 698.7 | Voice Call Continuity for CDMA2000 1X |  | 249d? | 2007-06-25 A | 2008-06-05 A | 100% | 2007-06-25 | 2008-06-05 | 249d? | finish no earlier than 2008-06-13 | S2 | 1992h | 1992h | SAES-VCC_1X | Nokia Siemens Networks | Rel-8 | Maurice | SAES-VCC_1X |  |  |  |  |  |  |
| 2683 | 698.8 | SAE impacts on IMS |  | 373d? | 2007-01-02 A | 2008-06-05 A | 100% | 2007-01-02 | 2008-06-05 | 373d? | finish no earlier than 2008-06-13 | S2 | 2984h | 2984h | SAES-SA_IMS | Nokia Siemens Networks | Rel-8 | Maurice | SAES-SA_IMS |  |  |  |  |  |  |
| 2684 | 698.9 | **CS Fallback in EPS** |  | 258d? | 2008-03-12 A | 2009-03-06 A | 100% | 2008-03-12 | 2009-03-06 | 258d? |  | S2; C1; C4 | 9384h | 9384h | SAES-CSFB | T-Mobile, Vodafone | Rel-8 | Maurice | SAES-CSFB |  | PCG-21 | SP-39 |  |  |  |
| 2685 | 698.9.1 | Stage 2 for CS Fallback in EPS |  | 62d? | 2008-03-12 A | 2008-06-05 A | 100% | 2008-03-12 | 2008-06-05 | 62d? | finish no earlier than 2008-12-05 | S2 | 496h | 496h | SAES-CSFB | T-Mobile, Vodafone | Rel-8 | Maurice |  | New (23.272, 23.401) | PCG-21 | SP-40 |  |  |  |
| 2686 | 698.9.2 | CT1 part of Stage 3 for CS Fallback in EPS |  | 201d? | 2008-05-30 A | 2009-03-06 A | 100% | 2008-05-30 | 2009-03-06 | 201d? | finish no earlier than 2009-03-06 | C1 | 1608h | 1608h | SAES-CSFB | NEC | Rel-8 | Frederic |  | 24.007, 24.008, 24.011, 29.018, New (24.301, 24.801, 29.118) | PCG-21 | CP-40 |  |  |  |
| 2687 | 698.9.3 | CT4 part of Stage 3 for CS Fallback in EPS |  | 136d? | 2008-05-30 A | 2008-12-05 A | 100% | 2008-05-30 | 2008-12-05 | 136d? | finish no earlier than 2008-12-05 | C4 | 1088h | 1088h | SAES-CSFB | NEC | Rel-8 | Kimmo |  | 23.007, 23.008, 29.274, New 29.277 | PCG-21 | CP-40 |  |  |  |
| 2688 | 698.10 | System enhancements for the use of IMS services in local breakout |  | 62d? | 2008-03-12 A | 2008-06-05 A | 100% | 2008-03-12 | 2008-06-05 | 62d? | finish no earlier than 2008-06-05 | S2 | 496h | 496h | SAES-IMS_LBO | Telecom Italia | Rel-8 | Maurice | SAES-IMS_LBO | 23.228, 23.221, 23.203 | PCG-21 | SP-39 |  |  |  |
| 2689 | 698.11 | **EPC Data Definitions** |  | 309d? | 2008-01-07 A | 2009-03-12 A | 100% | 2008-01-07 | 2009-03-12 | 309d? |  | S5 | 7144h | 7144h | EPC-OAM |  | Rel-8 | Mirko | EPC-OAM |  | PCG-21 | SP-39 |  |  |  |
| 2690 | 698.11.1 | EPC Network Resource Model (NRM) Integration Reference Point (IRP) |  | 309d? | 2008-01-07 A | 2009-03-12 A | 100% | 2008-01-07 | 2009-03-12 | 309d? | finish no earlier than 2009-03-12 | S5 | 2472h | 2472h | EPC-OAM | Huawei | Rel-8 | Mirko |  | New (32.751, 32.752, 32.753, 32.755) | PCG-21 | SP-38 |  |  |  |
| 2691 | 698.11.2 | Performance measurements for EPC |  | 275d? | 2008-02-22 A | 2009-03-12 A | 100% | 2008-02-22 | 2009-03-12 | 275d? | finish no earlier than 2009-03-12 | S5 | 2200h | 2200h | EPC-OAM | China Mobile | Rel-8 | Mirko |  | New 32.426 | PCG-21 | SP-39 |  |  |  |
| 2692 | 698.12 | EPC Charging |  | 309d? | 2008-01-07 A | 2009-03-12 A | 100% | 2008-01-07 | 2009-03-12 | 309d? | finish no earlier than 2009-03-12 | S5 | 2472h | 2472h | EPC-CH | Nokia Siemens Networks | Rel-8 | Mirko | EPC-CH | 32.240, 32.296, 32.251, 32.252, 32.298, 32.299 | PCG-21 | SP-38 |  |  |  |
| 2693 | 698.13 | Domain Name System Procedures for Evolved Packet System (DEPS) |  | 179.75d? | 2008-05-30 A | 2009-03-06 A | 100% | 2008-05-30 | 2009-03-06 | 179.75d? | finish no earlier than 2009-03-06 | C4 | 1438h | 1438h | SAES-DEPS | TeliaSonera | Rel-8 | Kimmo | SAES-DEPS | 23.003, New 29.303 | PCG-21 | CP-40 |  |  |  |
| 2694 | 698.14 | InterWorking Function (IWF) between MAP based and Diameter based interfaces |  | 126d? | 2008-09-12 A | 2009-03-06 A | 100% | 2008-09-12 | 2009-03-06 | 126d? | finish no earlier than 2009-03-06 | C4 | 1008h | 1008h | SAES-MAP2Diam | Huawei | Rel-8 | Kimmo | SAES-MAP2Diam | New 29.305 | PCG-21 | CP-41 |  |  |  |
| 2695 | 698.15 | **CT6 aspects of SAE** |  | 847d? | 2008-03-07 A | 2011-06-03 A | 100% | 2008-03-07 | 2011-06-03 | 847d? |  | C6 | 13480h | 13480h | SAES | Nokia | Rel-8 | Xavier |  |  | PCG-21 | SP-39 |  |  |  |
| 2696 | 698.15.1 | Core specification for CT6 aspects of SAE |  | 321d? | 2008-03-07 A | 2009-05-29 A | 100% | 2008-03-07 | 2009-05-29 | 321d? | finish no earlier than 2009-05-29 | C6 | 2568h | 2568h | SAES | Nokia | Rel-8 | Xavier |  | 31.102, 31.111 | PCG-21 | CP-39 |  |  |  |
| 2697 | 698.15.2 | Test interworking of LTE Terminals with the USIM |  | 526d? | 2008-12-05 A | 2010-12-10 A | 100% | 2008-12-05 | 2010-12-10 | 526d? | finish no earlier than 2010-12-10 | C6 | 4208h | 4208h | SAES-USIM_LTE-Test | Comprion | Rel-8 | Xavier | SAES-USIM_LTE-Test | 31.121, 31.124 | PCG-22 | CP-42 |  |  |  |
| 2698 | 698.15.3 | Test interworking of IP Multimedia Services Identity Module (ISIM) terminals with IP Multimedia Subsystem (IMS) |  | 186d? | 2010-09-17 A | 2011-06-03 A | 100% | 2010-09-17 | 2011-06-03 | 186d? | finish no earlier than 2011-06-03 | C6 | 1488h | 1488h | SAES-ISIM_IMS_Test | Comprion | Rel-8 | Xavier | SAES-ISIM_IMS_Test | 31.121, 31.124, New TS 31.134 | PCG-25 | CP-49 |  |  |  |
| 2699 | 698.16 | Issues for CT1 TR 24.801 |  | 420d? | 2007-01-04 A | 2008-12-05 A | 100% | 2007-01-04 | 2008-12-05 | 420d? | finish no earlier than 2008-12-05 | C1 | 3360h | 3360h | SAES | Nokia Siemens Networks | Rel-8 | Frederic |  | 24.801 | PCG-21 | CP-39 |  |  |  |
| 2700 | 698.17 | Issues for CT3 TR 29.804 |  | 420d? | 2007-02-05 A | 2008-09-12 A | 100% | 2007-02-05 | 2008-09-12 | 420d? | finish no earlier than 2008-12-12 | C3 | 3360h | 3360h | SAES | Ericsson | Rel-8 | Adrian |  | 29.804 | PCG-21 | CP-39 |  |  |  |
| 2701 | 698.18 | Deleted - Issues for CT4 TR 29.803 |  | 420d? | 2007-01-04 A | 2008-09-12 A | 100% | 2007-01-04 | 2008-09-12 | 420d? | finish no earlier than 2008-12-11 | C4 | 3360h | 3360h | SAES | Huawei | Rel-8 | Kimmo |  | 29.803 | PCG-21 | CP-39 | PCG-21 | CP-41 |  |
| 2702 | 698.19 | Deleted (covered by 380068): Functions and procedures for SAE to support LCS | milestone | 0d? | 2008-03-03 A | 2008-03-03 A | 100% | 2008-03-03 | 2008-03-03 | 0d? | finish no earlier than 2008-03-03 | S2 |  |  | SAES-SA-FP_LCS | Nokia Siemens Networks | Rel-8 | Maurice | SAES-SA-FP_LCS |  |  |  |  | SP-37 |  |
| 2703 | 698.20 | Deleted (covered by 380064): SAE aspects of Emergency Calls | milestone | 0d? | 2008-03-03 A | 2008-03-03 A | 100% | 2008-03-03 | 2008-03-03 | 0d? | start no earlier than 2008-03-03 | S2 |  |  | SAES-SA-EmCall | Nokia Siemens Networks | Rel-8 | Maurice | SAES-SA-EmCall |  |  |  |  | SP-37 | Public Safety (I-A) |

Notes:
- 2678: CP#43 completed. SP#38 WID approved (extract from SAE WID SP-070817). / WI rapporteur e-mail: curt.c.wong@nokia.com
- 2679: SP#41 completed. SP#38 WID approved / WI rapporteur e-mail: curt.c.wong@nokia.com
- 2680: CP#43 completed / WI rapporteur e-mail: robert.zaus@nsn.com
- 2681: CP#43 completed / WI rapporteur e-mail: Giorgi Gulbani
- 2682: SP#40 completed / WI rapporteur e-mail: balazs.bertenyi@nsn.com
- 2683: SP#40 completed / WI rapporteur e-mail: balazs.bertenyi@nsn.com
- 2684: CP#43 completed / WI rapporteur e-mail: sabine.demel@t-mobile.at, chris.pudney@vodafone.com
- 2685: SP#40 completed / WI rapporteur e-mail: sabine.demel@t-mobile.at, chris.pudney@vodafone.com
- 2686: CP#43 completed / WI rapporteur e-mail: yannick.lair@nectech.fr
- 2687: CP#42 completed / WI rapporteur e-mail: yannick.lair@nectech.fr
- 2688: SP#40 completed / WI rapporteur e-mail: mario.madella@telecomitalia.it
- 2689: SP#43 completed
- 2690: SP#43 completed / WI rapporteur e-mail: WANG, Xuelong
- 2691: SP#43 completed / WI rapporteur e-mail: Li Jian (lijian@chinamobile.com), Liang Shuangchun (liangshuangchun@cmdi.chinamobile.com)
- 2692: SP#43 completed / WI rapporteur e-mail: Gerald.Goermer@nsn.com
- 2693: CP#43 completed / WI rapporteur e-mail: jouni.korhonen@teliasonera.com
- 2694: CP#43 completed. Triggered by UID_380023 (FS_MAP2Diam) / WI rapporteur e-mail: liming49985@huawei.com
- 2695: CP#44 completed core specification / WI rapporteur e-mail: Rune Lindholm
- 2696: CP#44 completed (specified Network Measurement Results collection via USAT) / WI rapporteur e-mail: Rune Lindholm
- 2697: CP#50 completed. Steering of Roaming test cases have been introduced. Remaining issues CSG display testing (Provide Local Information, Call Control for EPS/PDN, Event Download (Access Technology Change - Multiple Access Technologies) / WI rapporteur e-mail: Udo Willenbrink (uwillenbrink@comprion.com )
- 2698: CP#52 completed. Linked to R5 UID_1273 Provisioning of IP-based multimedia services (24.229, 31.103), R8 UID_390021 CT6 aspects of SAE, UID_420018 Test interworking of LTE Terminals with the USIM, R UID_450018 Testing SMS over IMS in E-UTRAN (34.229). / WI rapporteur e-mail: Udo Willenbrink (uwillenbrink@comprion.com )
- 2699: CP#43 completed / WI rapporteur e-mail: robert.zaus@nsn.com
- 2700: CP#41 completed / WI rapporteur e-mail: j.javier.pastor@ericsson.com
- 2701: CP#41 Work stopped and continued in Normative specifications
- 2702: SP#37 stopped
- 2703: SP#37 stopped

| ID | WBS | Task | Type | Duration | Start | Finish | Complete | Remaining | Baseline start | Baseline finish | Baseline duration | Total slack | Constraint | Resources | Work | Actual work | Acronym | Release | MCC resp | TSG stopped | Acronym_3GU_Export | WI rapporteur name | WI rapporteur e-mail | PCG approved | TSG approved | Status Report | PCG stopped |
| --- | --- | --- | --- | --- | --- | --- | --- | --- | --- | --- | --- | --- | --- | --- | --- | --- | --- | --- | --- | --- | --- | --- | --- | --- | --- | --- | --- |
| 2704 | 698.21 | **Deleted - CT aspects of SAES** |  | 138d? | 2007-09-04 A | 2008-03-14 | 100% | 0d? | 2007-09-04 | 2008-03-14 | 138d? | 0d |  | C3; C1; C4 | 3312h | 1104h | SAES-St3 | Rel-8 | Frederic | SP-37 | SAES-St3 |  |  |  |  |  |  |
| 2705 | 698.21.1 | Deleted - CT1 aspects of SAES | milestone | 0d? | 2007-09-04 A | 2007-09-04 A | 100% |  | 2007-09-04 | 2007-09-04 | 0d? |  | start no earlier than 2007-09-04 | C1 |  |  | SAES-St3 | Rel-8 | Frederic | SP-37 |  |  |  |  |  |  |  |
| 2706 | 698.21.2 | Deleted - Interoperability | milestone | 0d? | 2008-03-14 A | 2008-03-14 A | 100% |  | 2008-03-14 | 2008-03-14 | 0d? |  | start no earlier than 2008-03-14 | C1 |  |  | SAES-St3-interop | Rel-8 | Frederic | SP-37 | SAES-St3-interop |  |  |  |  |  |  |
| 2707 | 698.21.3 | Deleted - CT3 aspects of SAES | milestone | 0d? | 2007-09-04 A | 2007-09-04 A | 100% |  | 2007-09-04 | 2007-09-04 | 0d? |  | start no earlier than 2007-09-04 | C3 |  |  | SAES | Rel-8 | Adrian | SP-37 |  |  |  |  |  |  |  |
| 2708 | 698.21.4 | Deleted - CT4 aspects of SAES | milestone | 0d? | 2007-09-04 A | 2007-09-04 A | 100% |  | 2007-09-04 | 2007-09-04 | 0d? |  | start no earlier than 2007-09-04 | C4 |  |  | SAES | Rel-8 | Kimmo | SP-37 |  |  |  |  |  |  |  |
| 2709 | 698.21.5 | Deleted - UE to EPC NAS signalling (incl. MBMS and QoS aspects) | milestone | 0d? | 2008-03-14 A | 2008-03-14 A | 100% |  | 2008-03-14 | 2008-03-14 | 0d? |  | start no earlier than 2008-03-14 | C1 |  |  | SAES-St3-sig | Rel-8 | Frederic | SP-37 | SAES-St3-sig |  |  |  |  |  |  |
| 2710 | 698.21.6 | Deleted - User and Control plane protocols | milestone | 0d? | 2007-09-21 A | 2007-09-21 A | 100% |  | 2007-09-21 | 2007-09-21 | 0d? |  | start no earlier than 2007-09-21 | C4 |  |  | SAES-St3-prot | Rel-8 | Kimmo | SP-37 | SAES-St3-prot |  |  |  |  |  |  |
| 2711 | 698.22 | Deleted - Architecture enhancements for non-3GPP accesses | milestone | 0d? | 2007-09-04 A | 2007-09-04 A | 100% |  | 2007-09-04 | 2007-09-04 | 0d? |  | start no earlier than 2007-09-04 | S2 |  |  | SAES-non_3GPP | Rel-8 | Maurice | SP-34 | SAES-non_3GPP | Motorola | Irfan.Ali@motorola.com |  |  |  |  |
| 2712 | 698.23 | Deleted - Stage 2 of architecture for the 3GPP System Architecture Evolution | milestone | 0d? | 2007-10-02 A | 2007-10-02 A | 100% |  | 2007-10-02 | 2007-10-02 | 0d? |  | start no earlier than 2007-10-02 | S2 |  |  | SAES-St2 | Rel-8 | Maurice | SP-34 | SAES-St2 | Vodafone | chris.pudney@vodafone.com |  |  |  |  |
| 2713 | 698.24 | Deleted - SA aspects of System Architecture Evolution |  | 384d? | 2006-04-12 A | 2007-10-01 A | 100% |  | 2006-04-12 | 2007-10-01 | 384d? |  | finish no earlier than 2007-10-02 | S2 | 3072h | 3072h | SAES-SA | Rel-8 | Maurice | SP-34 | SAES-SA |  |  |  |  |  |  |
| 2714 | 699 | Conformance Test Aspects – Mobility management based on DSMIPv6 (Dual-Stack Mobile IPv6) |  | 261d? | 2009-09-18 A | 2010-09-17 A | 100% |  | 2009-09-18 | 2010-09-17 | 261d? |  | finish no earlier than 2010-09-17 | R5 | 2088h | 2088h | DSMIPv6_UEConTest | Rel-8 | Ingbert |  | DSMIPv6_UEConTest | Qualcomm | Lena Chaponniere (lchaponn@qualcomm.com) | PCG-23 | RP-45 | RP-100738 |  |
| 2715 | 700 | **IMS Centralized Service control** |  | 2392.1d? | 2005-11-01 A | 2014-12-09 | 98% | 49.36d? | 2005-11-01 | 2014-12-05 | 2387.1d? | 657d |  | S1; S2; C1; C3; C4; IETF | 239598h | 100747h | ICSRA | Rel-8 | Alain |  | ICSRA | AT&T | Randolph Wohlert (rwohlert@tri.sbc.com) |  | SP-37 |  |  |
| 2716 | 700.1 | Stage 1 for ICS Requirement and Architecture |  | 138d? | 2007-09-03 A | 2008-03-12 A | 100% |  | 2007-09-03 | 2008-03-12 | 138d? |  | finish no earlier than 2007-12-14 | S1 | 1104h | 1104h | ICSRA | Rel-8 | Alain |  |  | AT&T | Randolph Wohlert (rwohlert@tri.sbc.com) | PCG-21 | SP-38 |  |  |
| 2717 | 700.2 | Stage 2 for ICS Requirement and Architecture |  | 125d? | 2007-12-14 A | 2008-06-05 A | 100% |  | 2007-12-14 | 2008-06-05 | 125d? |  | start no earlier than 2007-12-14 | S2 | 1000h | 1000h | ICSRA-St2 | Rel-8 | Maurice |  | ICSRA-St2 | Alcatel-Lucent |  | PCG-21 | SP-38 |  |  |
| 2718 | 700.3 | **Stage 3 for ICSRA – Protocol, Addressing, Subscriber Data** |  | 2392.1d? | 2005-11-01 A | 2014-12-09 | 98% | 51.61d? | 2005-11-01 | 2014-12-05 | 2387.1d? | 657d |  | C1; C3; C4; IETF | 122674h | 69070.4h | ICSRA | Rel-8 | Frederic |  |  | Ericsson | sean.schneyer@ericsson.com |  |  |  |  |
| 2719 | 700.3.1 | CT1 aspects - Stage 3 for ICSRA |  | 201d? | 2008-05-30 A | 2009-03-06 A | 100% |  | 2008-05-30 | 2009-03-06 | 201d? |  | finish no earlier than 2009-03-06 | C1 | 1608h | 1608h | ICSRA | Rel-8 | Frederic |  |  | Ericsson | Sean Schneyer | PCG-21 | CP-40 |  |  |
| 2720 | 700.3.2 | (IETF) CT1 aspects - Stage 3 for ICSRA (draft-ietf-salud-alert-info-urns) |  | 1244d? | 2008-05-30 A | 2014-12-09 | 90% | 124.4d? | 2008-05-30 | 2014-12-05 | 1242d? | 657d | finish no earlier than 2014-12-09 | C1-IETF | 9952h | 8956.8h | ICSRA | Rel-8 | Frederic |  |  | Roland Jesske | Roland Jesske | PCG-27 | CP-52 |  |  |
| 2721 | 700.3.3 | (IETF) CT1 aspects - Stage 3 for ICSRA (RFC 6871) |  | 779d? | 2008-05-30 A | 2013-03-01 A | 100% |  | 2008-05-30 | 2013-03-01 | 779d? |  | finish no earlier than 2013-02-28 | C1-IETF | 6232h | 6232h | ICSRA | Rel-8 | Frederic |  |  | Andrew Allen |  | PCG-27 | CP-52 |  |  |
| 2722 | 700.3.4 | (IETF) CT1 aspects - Stage 3 for ICSRA (RFC 7195) |  | 1117d? | 2008-05-30 A | 2014-06-13 A | 100% |  | 2008-05-30 | 2014-06-13 | 1117d? |  | finish no earlier than 2014-06-13 | C1-IETF | 8936h | 8936h | ICSRA | Rel-8 | Frederic |  |  | Andrew Allen |  | PCG-27 | CP-52 |  |  |
| 2723 | 700.3.5 | (IETF) CT1 aspects - Stage 3 for ICSRA (RFC 7006) |  | 977d? | 2008-06-03 A | 2013-12-06 A | 100% |  | 2008-06-03 | 2013-12-06 | 977d? |  | finish no earlier than 2013-12-06 | C1-IETF | 7816h | 7816h | ICSRA | Rel-8 | Frederic |  |  | Andrew Allen |  | PCG-27 | CP-52 |  |  |
| 2724 | 700.3.6 | CT3 aspects - Stage 3 for ICSRA |  | 201d? | 2008-05-30 A | 2009-03-06 A | 100% |  | 2008-05-30 | 2009-03-06 | 201d? |  | finish no earlier than 2009-03-06 | C3 | 1608h | 1608h | ICSRA | Rel-8 | Adrian |  |  | Mavenir | Brett Wallis ( brett@mavenir.com) | PCG-21 | CP-40 |  |  |
| 2725 | 700.3.7 | CT4 aspects - Stage 3 for ICSRA |  | 136d? | 2008-05-30 A | 2008-12-05 A | 100% |  | 2008-05-30 | 2008-12-05 | 136d? |  | start no earlier than 2008-05-30 | C4 | 1088h | 1088h | ICSRA | Rel-8 | Kimmo |  |  | Ericsson | Sean Schneyer | PCG-21 | CP-40 |  |  |
| 2726 | 700.3.8 | (IETF) CT4 aspects - Stage 3 for ICSRA (RFC 7254) |  | 1034.8d? | 2005-11-01 A | 2014-06-13 A | 100% |  | 2005-11-01 | 2014-06-13 | 1034.8d? |  | finish no earlier than 2014-06-13 | C4-IETF | 8278.4h | 8278.4h | ICSRA | Rel-8 | Kimmo |  |  | Andrew Allen |  | PCG-27 | CP-52 |  |  |
| 2727 | 700.3.9 | Deleted - Stage 3 for ICSRA – I1 interface |  | 76d? | 2008-05-30 A | 2008-09-12 A | 100% |  | 2008-05-30 | 2008-09-12 | 76d? |  | finish no earlier than 2008-09-12 | C1 | 608h | 608h | ICSRA | Rel-8 | Frederic | CP-41 |  | Huawei | xupeili@huawei.com | PCG-21 | CP-40 |  | PCG-21 |

Notes:
- 2704: SP#37 stopped
- 2705: SP#37 stopped
- 2706: SP#37 stopped
- 2707: SP#37 stopped
- 2708: SP#37 stopped / Impacted TSs and TRs: 29.803
- 2709: SP#37 stopped
- 2710: SP#37 stopped
- 2711: SP#34 stopped. Replaced by UID_350027 and its children / Impacted TSs and TRs: 23.402
- 2712: SP#34 stopped. Replaced by UIDs 340018 and 340037. (SP#34 report discussion of SP-060917.) / Impacted TSs and TRs: 23.002, 23.060, 23.107, 23.203, 23.228, 23.234, 23.246, 23.271, 23.279
- 2713: SP#34 stopped
- 2714: RP#49 completed. Testing for CT1's UID_360022 (24.303) under Rel-8 Feature SAES / Impacted TSs and TRs: 36.508, 36.523-1, 36.523-2, 36.523-3
- 2715: CP#46 completed
- 2716: SP#39 completed / Impacted TSs and TRs: 22.101
- 2717: SP#40 completed / Impacted TSs and TRs: 23.292, 23.206
- 2718: CP#46 completed
- 2719: CP#46 completed / Impacted TSs and TRs: 24.229, new (24.292, 24.286)
- 2720: In RFC Editors Queue. Dec.14: 75->90 / Impacted TSs and TRs: draft-ietf-salud-alert-info-urns
- 2721: CP#59 completed / Impacted TSs and TRs: RFC 6871 (was draft-ietf-mmusic-sdp-media-capabilities)
- 2722: CP#64 complete / Impacted TSs and TRs: RFC 7195 (was draft-ietf-mmusic-sdp-cs)
- 2723: CP#62 completed / Impacted TSs and TRs: RFC7006 (was draft-ietf-mmusic-sdp-miscellaneous-caps)
- 2724: CP#43 completed / Impacted TSs and TRs: new 29.292
- 2725: CP#42 completed / Impacted TSs and TRs: 23.003, 29.232, 23.018, 29.002
- 2726: CP#64 complete / Impacted TSs and TRs: RFC 7254 (was draft-montemurro-gsma-imei-urn)
- 2727: CP#41 work stopped / Impacted TSs and TRs: 24.293

| ID | WBS | Task | Duration | Start | Finish | Complete | Remaining | Baseline start | Baseline finish | Baseline duration | Total slack | Constraint | Resources | Work | Actual work | Acronym | Release | TSG approved | MCC resp | Acronym_3GU_Export | WI rapporteur name | WI rapporteur e-mail | PCG approved |
| --- | --- | --- | --- | --- | --- | --- | --- | --- | --- | --- | --- | --- | --- | --- | --- | --- | --- | --- | --- | --- | --- | --- | --- |
| 2728 | 701 | **IMS Multimedia Telephony and Supplementary Services** | 2002d? | 2007-05-02 A | 2014-12-09 | 98% | 39.13d? | 2007-05-02 | 2014-12-05 | 1997d? | 657d |  | S1; S5; C1; C3; C4; IETF | 272222h | 261799h | IMSTSS | Rel-8 | SP-37 | Alain | IMSTSS |  |  |  |
| 2729 | 701.1 | **General aspects of IMS Sup Services** | 395d? | 2007-09-03 A | 2009-03-06 A | 100% |  | 2007-09-03 | 2009-03-06 | 395d? |  |  | S1; C1; C3; C4 | 19232h | 19232h | IMSSS-Gal | Rel-8 | SP-37 | Alain | IMSSS-Gal | Ericsson | Susana Sabater |  |
| 2730 | 701.1.1 | Service and Capability for Core IMS - inclusion of TISPAN requirements | 75d? | 2007-09-03 A | 2007-12-14 A | 100% |  | 2007-09-03 | 2007-12-14 | 75d? |  | finish no earlier than 2007-12-14 | S1 | 600h | 600h | TISCAPR8 | Rel-8 | SP-37 | Alain | TISCAPR8 | Ericsson | Susana Sabater |  |
| 2731 | 701.1.2 | Documentation of TISPAN R1 and R2 in CT1 | 208d? | 2007-11-28 A | 2008-09-12 A | 100% |  | 2007-11-28 | 2008-09-12 | 208d? |  | finish no earlier than 2008-09-12 | C1 | 1664h | 1664h | REDOC_TIS-C1 | Rel-8 | CP-38 | Frederic | REDOC_TIS-C1 | Nokia Siemens Networks | peter.leis@nsn.com | PCG-21 |
| 2732 | 701.1.3 | Documentation of TISPAN R1 and R2 in CT3 | 333d? | 2007-11-28 A | 2009-03-06 A | 100% |  | 2007-11-28 | 2009-03-06 | 333d? |  | finish no earlier than 2009-03-06 | C3 | 2664h | 2664h | REDOC_TIS-C3 | Rel-8 | CP-38 | Adrian | REDOC_TIS-C3 | Nokia Siemens Networks | peter.leis@nsn.com | PCG-21 |
| 2733 | 701.1.4 | Documentation of TISPAN R1 and R2 in CT4 | 208d? | 2007-11-28 A | 2008-09-12 A | 100% |  | 2007-11-28 | 2008-09-12 | 208d? |  | finish no earlier than 2008-09-12 | C4 | 1664h | 1664h | REDOC_TIS-C4 | Rel-8 | CP-38 | Kimmo | REDOC_TIS-C4 | Nokia Siemens Networks | peter.leis@nsn.com | PCG-21 |
| 2734 | 701.2 | **IMS Multimedia Telephony Service** | 394d? | 2007-09-10 A | 2009-03-12 A | 100% |  | 2007-09-10 | 2009-03-12 | 394d? |  |  | S1; S5 | 9296h | 9296h | IMS-MMTel | Rel-8 | SP-37 | Alain | IMS-MMTel |  |  |  |
| 2735 | 701.2.1 | Merging TISPAN MMTel [requirements] for Common IMS | 65d? | 2007-09-10 A | 2007-12-07 A | 100% |  | 2007-09-10 | 2007-12-07 | 65d? |  | finish no earlier than 2007-12-07 | S1 | 520h | 520h | TMMTEL | Rel-8 | SP-37 | Alain | TMMTEL | Nokia Siemens Networks |  |  |
| 2736 | 701.2.2 | Multimedia Telephony Service and Supplementary Services (MMTel) offline Charging | 309d? | 2008-01-07 A | 2009-03-12 A | 100% |  | 2008-01-07 | 2009-03-12 | 309d? |  | finish no earlier than 2009-03-12 | S5 | 2472h | 2472h | MMTel-CH | Rel-8 | SP-38 | Mirko | MMTel-CH | Alcatel-Lucent | maryse.gardella@alcatel-lucent.com | PCG-21 |
| 2737 | 701.3 | **Call Completion on Busy Subscriber (CCBS)/Call Completion on Non-Reachable (CCNR) on IMS** | 1608d? | 2007-05-02 A | 2013-06-14 A | 100% |  | 2007-05-02 | 2013-06-14 | 1608d? |  |  | C1; C3; IETF | 71528h | 71528h | CCBS_CCNR | Rel-8 | SP-38 | Frederic | CCBS_CCNR | Deutsche Telekom | martin.huelsemann@telekom.de | PCG-21 |
| 2738 | 701.3.1 | CT1 part of Stage 3 CCBS_CCNR | 483d? | 2007-05-02 A | 2009-03-06 A | 100% |  | 2007-05-02 | 2009-03-06 | 483d? |  | finish no earlier than 2009-03-06 | C1 | 3864h | 3864h | CCBS_CCNR | Rel-8 | CP-38 | Frederic |  | Deutsche Telekom | martin.huelsemann@telekom.de | PCG-21 |
| 2739 | 701.3.2 | CT3 part of Stage 3 CCBS_CCNR | 418d? | 2007-05-02 A | 2008-12-05 A | 100% |  | 2007-05-02 | 2008-12-05 | 418d? |  | finish no earlier than 2008-12-05 | C3 | 3344h | 3344h | CCBS_CCNR | Rel-8 | CP-38 | Adrian |  | Deutsche Telekom | martin.huelsemann@telekom.de | PCG-21 |
| 2740 | 701.3.3 | (IETF) Stage 3 CCBS_CCNR [RFC 6910 (was draft-ietf-bliss-call-completion)] | 1608d? | 2007-05-02 A | 2013-06-14 A | 100% |  | 2007-05-02 | 2013-06-14 | 1608d? |  | finish no earlier than 2013-06-10 | C1-IETF; C3-IETF | 25728h | 25728h | CCBS_CCNR | Rel-8 | CP-52 | Frederic |  | Roland Jesske |  | PCG-27 |
| 2741 | 701.4 | **Flexible Alerting** | 288d? | 2008-01-30 A | 2009-03-06 A | 100% |  | 2008-01-30 | 2009-03-06 | 288d? |  |  | S1; C1 | 7582.4h | 7582.4h | FA | Rel-8 | SP-39 | Alain | FA | Nortel | milanpa@nortel.com | PCG-21 |
| 2742 | 701.4.1 | Stage 1 FA | 92d? | 2008-01-30 A | 2008-06-05 A | 100% |  | 2008-01-30 | 2008-06-05 | 92d? |  |  | S1 | 670.4h | 670.4h | FA | Rel-8 | SP-39 | Alain |  | Telecom Italia |  | PCG-21 |
| 2743 | 701.4.2 | Stage 3 FA | 288d? | 2008-01-30 A | 2009-03-06 A | 100% |  | 2008-01-30 | 2009-03-06 | 288d? |  | finish no earlier than 2009-03-06 | C1 | 2304h | 2304h | FA | Rel-8 | CP-39 | Frederic |  | Nortel | milanpa@nortel.com | PCG-21 |
| 2744 | 701.5 | **Communication Wait on IMS** | 1965d? | 2007-06-22 A | 2014-12-09 | 93% | 132.85d? | 2007-06-22 | 2014-12-05 | 1960d? | 657d |  | C1; C3; IETF | 61880h | 57696.4h | CW_IMS | Rel-8 | SP-38 | Frederic | CW_IMS | Deutsche Telekom | martin.huelsemann@telekom.de | PCG-21 |
| 2745 | 701.5.1 | CT1 part of Stage 3 CW-IMS | 331d? | 2007-11-30 A | 2009-03-06 A | 100% |  | 2007-11-30 | 2009-03-06 | 331d? |  | finish no earlier than 2009-03-06 | C1 | 2648h | 2648h | CW_IMS | Rel-8 | CP-38 | Frederic |  | Deutsche Telekom | martin.huelsemann@telekom.de | PCG-21 |
| 2746 | 701.5.2 | (IETF) Stage 3 CW-IMS (salud-alert-info-urns) | 1244d? | 2007-06-22 A | 2014-12-09 | 90% | 124.4d? | 2007-06-22 | 2014-12-05 | 1242d? | 657d | finish no earlier than 2014-12-09 | C1-IETF | 9952h | 8956.8h | CW_IMS | Rel-8 | CP-52 | Frederic |  | Roland Jesske | Roland Jesske | PCG-27 |
| 2747 | 701.5.3 | CT3 part of Stage 3 CW-IMS | 265d? | 2007-11-30 A | 2008-12-04 A | 100% |  | 2007-11-30 | 2008-12-04 | 265d? |  | finish no earlier than 2008-12-05 | C3 | 2120h | 2120h | CW_IMS | Rel-8 | CP-38 | Adrian |  | Deutsche Telekom | martin.huelsemann@telekom.de | PCG-21 |
| 2748 | 701.6 | **IMS Charging** | 389d? | 2007-09-17 A | 2009-03-12 A | 100% |  | 2007-09-17 | 2009-03-12 | 389d? |  |  | S5 | 6608h | 6608h | CH8_IMS | Rel-8 | SP-37 | Mirko | CH8 | Alcatel-Lucent | maryse.gardella@alcatel-lucent.com |  |
| 2749 | 701.6.1 | Add Interconnection Border Control Function (IBCF) to IMS Charging | 128d? | 2007-09-17 A | 2008-03-12 A | 100% |  | 2007-09-17 | 2008-03-12 | 128d? |  | finish no earlier than 2008-03-12 | S5 | 1024h | 1024h | CH8_IMS | Rel-8 | SP-37 | Mirko |  | Alcatel-Lucent | maryse.gardella@alcatel-lucent.com |  |
| 2750 | 701.6.2 | Advice of Charge (AoC) support in IMS Charging | 309d? | 2008-01-07 A | 2009-03-12 A | 100% |  | 2008-01-07 | 2009-03-12 | 309d? |  | finish no earlier than 2009-03-12 | S5 | 2472h | 2472h | CH8_IMS | Rel-8 | SP-38 | Mirko |  | Nokia Siemens Networks | Gerald.Goermer@nsn.com | PCG-21 |
| 2751 | 702 | **3GPP2 Input to Common IMS** | 200d? | 2008-03-07 A | 2008-12-11 A | 100% |  | 2008-03-07 | 2008-12-11 | 200d? |  |  | S1; S2; S3; C1; C3; C4 | 21453.2h | 21453.2h | CIMS_3GPP2 | Rel-8 | SP-39 | Alain | CIMS_3GPP2, IMS_Common | Nortel | Amar Deol (deola@nortelnetworks.com) | PCG-21 |
| 2752 | 702.1 | Stage 1 CIMS_3GPP2 | 30.65d? | 2008-03-12 A | 2008-06-05 A | 100% |  | 2008-03-12 | 2008-06-05 | 30.65d? |  | finish no earlier than 2008-06-12 | S1 | 245.2h | 245.2h | CIMS_3GPP2 | Rel-8 | SP-39 | Alain |  | Nortel | Amar Deol (deola@nortelnetworks.com) | PCG-21 |
| 2753 | 702.2 | Stage 2 CIMS_3GPP2 | 62d? | 2008-03-12 A | 2008-06-05 A | 100% |  | 2008-03-12 | 2008-06-05 | 62d? |  | finish no earlier than 2008-09-11 | S2 | 496h | 496h | CIMS_3GPP2 | Rel-8 | SP-39 | Maurice |  | Nortel | Amar Deol (deola@nortelnetworks.com) | PCG-21 |
| 2754 | 702.3 | Security CIMS_3GPP2 | 197d? | 2008-03-12 A | 2008-12-11 A | 100% |  | 2008-03-12 | 2008-12-11 | 197d? |  | finish no earlier than 2008-12-11 | S3 | 1576h | 1576h | CIMS_3GPP2 | Rel-8 | SP-39 | Mirko |  | Nortel | Amar Deol (deola@nortelnetworks.com) | PCG-21 |

Notes:
- 2728: SP#43 completed
- 2729: CP#43 completed
- 2730: SP#39 completed / Impacted TSs and TRs: 22.228, 22.115, 22.101
- 2731: CP#41 completed / Impacted TSs and TRs: 24.141, 24.147, 24.173, 24.229, 24.247, 24.341, 24.604, 24.605, 24.606, 24.607, 24.608, 24.610, 24.611, 24.616, 24.623, 24.628, 24.629, 24.647, 24.654
- 2732: CP#43 completed / Impacted TSs and TRs: 29.162, 29.163, 29.658
- 2733: CP#41 completed / Impacted TSs and TRs: 29.228, 29.229
- 2734: SP#43 completed
- 2735: SP#38 completed / Impacted TSs and TRs: 22.173
- 2736: CP#43 completed / Impacted TSs and TRs: 32.275, 32.298/299
- 2737: CP#43 completed
- 2738: CP#43 completed / Impacted TSs and TRs: 24.642, 24.229, 24.173
- 2739: CP#42 completed / Impacted TSs and TRs: 29.163
- 2740: CP#60 completed / Impacted TSs and TRs: RFC 6910 (was draft-ietf-bliss-call-completion)
- 2741: CP#43 completed
- 2742: SP#40 completed / Impacted TSs and TRs: 22.173
- 2743: CP#43 completed / Impacted TSs and TRs: 24.239, 24.173
- 2744: CP#43 completed
- 2745: CP#43 completed / Impacted TSs and TRs: 24.615, 24.229, 24.173
- 2746: In RFC Editors Queue. Dec.14: 75->90 / Impacted TSs and TRs: draft-ietf-salud-alert-info-urns
- 2747: CP#42 completed / Impacted TSs and TRs: 29.163
- 2748: SP#39 completed / Impacted TSs and TRs: 32.260, 32.298
- 2749: SP#39 completed / Impacted TSs and TRs: 32.260, 32.298
- 2750: SP#43 completed / Impacted TSs and TRs: 32.240, 32.260, 32.296, 32.298, 32.299, new 32.280
- 2751: TSG#42 completed. Acronym changed from "CIMS_3GPP2, IMS_Common"
- 2752: SP#40 completed. Acronym changed from "CIMS_3GPP2, IMS_Common" / Impacted TSs and TRs: 22.228, 22.173, 22.101, 22.153
- 2753: SP#40 completed. Acronym changed from "CIMS_3GPP2, IMS_Common" / Impacted TSs and TRs: 23.002, 23.141, 23.203, 23.167, 23.228
- 2754: SP#42 completed [issues addressed under UID_370078 (IMS-Sec)]. Acronym changed from "CIMS_3GPP2, IMS_Common" / Impacted TSs and TRs: 33.141, 33.203, 33.210

| ID | WBS | Task | Duration | Start | Finish | Complete | Baseline start | Baseline finish | Baseline duration | Constraint | Resources | Work | Actual work | Acronym | PCG approved | WI rapporteur name | WI rapporteur e-mail | Release | TSG approved | MCC resp | Acronym_3GU_Export |
| --- | --- | --- | --- | --- | --- | --- | --- | --- | --- | --- | --- | --- | --- | --- | --- | --- | --- | --- | --- | --- | --- |
| 2755 | 702.4 | **Stage 3 CIMS_3GPP2** | 200d? | 2008-03-07 A | 2008-12-11 A | 100% | 2008-03-07 | 2008-12-11 | 200d? |  | C1; C3; C4 | 9536h | 9536h | REDOC_3GPP2 | PCG-21 | Alcatel-Lucent | orsic@alcatel-lucent.com | Rel-8 | CP-39 | Frederic | REDOC_3GPP2 |
| 2756 | 702.4.1 | Stage 3 CIMS_3GPP2 (CT1) | 196d? | 2008-03-07 A | 2008-12-05 A | 100% | 2008-03-07 | 2008-12-05 | 196d? | finish no earlier than 2008-12-11 | C1 | 1568h | 1568h | REDOC_3GPP2 | PCG-21 | Alcatel-Lucent | orsic@alcatel-lucent.com | Rel-8 | CP-39 | Frederic |  |
| 2757 | 702.4.2 | Stage 3 CIMS_3GPP2 (CT3) | 196d? | 2008-03-07 A | 2008-12-05 A | 100% | 2008-03-07 | 2008-12-05 | 196d? | finish no earlier than 2008-12-05 | C3 | 1568h | 1568h | REDOC_3GPP2 | PCG-21 | Alcatel-Lucent | orsic@alcatel-lucent.com | Rel-8 | CP-39 | Adrian |  |
| 2758 | 702.4.3 | Stage 3 CIMS_3GPP2 (CT4) | 200d? | 2008-03-07 A | 2008-12-11 A | 100% | 2008-03-07 | 2008-12-11 | 200d? | finish no earlier than 2008-12-11 | C4 | 1600h | 1600h | REDOC_3GPP2 | PCG-21 | Alcatel-Lucent | orsic@alcatel-lucent.com | Rel-8 | CP-39 | Kimmo |  |
| 2759 | 703 | **IMS Enhancements for support of Packet Cable access** | 388d? | 2006-12-06 A | 2008-05-30 A | 100% | 2006-12-06 | 2008-05-30 | 388d? |  | S2; S3; C1; C3; C4 | 58616h | 58616h | PktCbl |  | Cablelabs | Bernie McKibben (b.mckibben@cablelabs.com) | Rel-8 |  | Maurice | PktCbl |
| 2760 | 703.1 | **IMS Enhancements for Cable Client Types and Deployment Models** | 345d? | 2007-02-05 A | 2008-05-30 A | 100% | 2007-02-05 | 2008-05-30 | 345d? |  | S2; C1 | 9752h | 9752h | PktCbl-Deploy |  | Cablelabs | Bernie McKibben (b.mckibben@cablelabs.com) | Rel-8 |  | Maurice | PktCbl-Deploy |
| 2761 | 703.1.1 | Architecture aspects of PktCbl-Deploy | 219d? | 2007-02-05 A | 2007-12-06 A | 100% | 2007-02-05 | 2007-12-06 | 219d? | finish no earlier than 2007-12-03 | S2 | 1752h | 1752h | PktCbl-Deploy |  | Cablelabs | Bernie McKibben (b.mckibben@cablelabs.com) | Rel-8 |  | Maurice |  |
| 2762 | 703.1.2 | CT1 aspects of PktCbl-Deploy | 310d? | 2007-03-26 A | 2008-05-30 A | 100% | 2007-03-26 | 2008-05-30 | 310d? | finish no earlier than 2008-06-15 | C1 | 2480h | 2480h | PktCbl-Deploy |  | Cablelabs | D.Hancock@CableLabs.com | Rel-8 |  | Frederic |  |
| 2763 | 703.2 | **IMS Inter-working aspects in Support of Cable Regulatory requirements** | 290d? | 2007-02-05 A | 2008-03-14 A | 100% | 2007-02-05 | 2008-03-14 | 290d? |  | S2; C1; C3 | 12320h | 12320h | PktCbl-Intw |  | Cablelabs | B.McKibben@CableLabs.com | Rel-8 |  | Maurice | PktCbl-Intw |
| 2764 | 703.2.1 | Architecture aspects of PktCbl-Interwork | 160d? | 2007-02-05 A | 2007-09-14 A | 100% | 2007-02-05 | 2007-09-14 | 160d? | start no earlier than 2007-02-05 | S2 | 1280h | 1280h | PktCbl-Intw |  | Cablelabs | B.McKibben@CableLabs.com | Rel-8 |  | Maurice |  |
| 2765 | 703.2.2 | CT1,CT3 aspects of PktCbl-Interwork | 255d? | 2007-03-26 A | 2008-03-14 A | 100% | 2007-03-26 | 2008-03-14 | 255d? | finish no earlier than 2008-03-15 | C1; C3 | 4080h | 4080h | PktCbl-Intw |  | Cablelabs | D.Hancock@CableLabs.com | Rel-8 |  | Frederic |  |
| 2766 | 703.3 | **IMS Enhancements for Security Requirements in Support of Cable Deployments** | 388d? | 2006-12-06 A | 2008-05-30 A | 100% | 2006-12-06 | 2008-05-30 | 388d? |  | S3; C1; C3; C4 | 21024h | 21024h | PktCbl-Sec |  | Cablelabs | s.dotson@cablelabs.com | Rel-8 |  | Mirko | PktCbl-Sec |
| 2767 | 703.3.1 | SA3 aspects of PktCbl-Sec | 331d? | 2006-12-06 A | 2008-03-12 A | 100% | 2006-12-06 | 2008-03-12 | 331d? | finish no earlier than 2007-12-20 | S3 | 2648h | 2648h | PktCbl-Sec |  | Cablelabs | s.dotson@cablelabs.com | Rel-8 |  | Mirko |  |
| 2768 | 703.3.2 | CT1 aspects of PktCbl-Sec | 310d? | 2007-03-26 A | 2008-05-30 A | 100% | 2007-03-26 | 2008-05-30 | 310d? | finish no earlier than 2008-06-06 | C1 | 2480h | 2480h | PktCbl-Sec |  | Cablelabs | D.Hancock@CableLabs.com | Rel-8 |  | Frederic |  |
| 2769 | 703.3.3 | CT3 aspects of PktCbl-Sec | 180d? | 2007-03-26 A | 2007-11-30 A | 100% | 2007-03-26 | 2007-11-30 | 180d? | finish no earlier than 2008-03-15 | C3 | 1440h | 1440h | PktCbl-Sec | PCG-21 | Cablelabs | D.Hancock@CableLabs.com | Rel-8 | CP-38 | Adrian |  |
| 2770 | 703.3.4 | CT4 aspects of PktCbl-Sec | 255d? | 2007-03-26 A | 2008-03-14 A | 100% | 2007-03-26 | 2008-03-14 | 255d? | finish no earlier than 2008-03-14 | C4 | 2040h | 2040h | PktCbl-Sec |  | Cablelabs | D.Hancock@CableLabs.com | Rel-8 |  | Kimmo |  |
| 2771 | 704 | **IMS System enhancements for corporate network access** | 1901d? | 2007-06-22 A | 2014-09-12 A | 100% | 2007-06-22 | 2014-12-05 | 1960d? |  | S2; S1; C1; C4; IETF | 91240.9h | 91240.9h | IMS_Corp |  | Orange | Delphin Barankanira | Rel-8 |  | Maurice | IMS_Corp |
| 2772 | 704.1 | SA1 aspects of IMS_Corp | 23.6d? | 2008-03-12 A | 2008-06-05 A | 100% | 2008-03-12 | 2008-06-05 | 23.6d? | finish no earlier than 2008-06-05 | S1 | 188.8h | 188.8h | IMS_Corp | PCG-21 | Telecom Italia |  | Rel-8 | SP-39 | Alain |  |
| 2773 | 704.2 | SA2 aspects of IMS_Corp | 325d? | 2007-06-22 A | 2008-09-18 A | 100% | 2007-06-22 | 2008-09-18 | 325d? | finish no earlier than 2008-12-25 | S2 | 2600h | 2600h | IMS_Corp |  | Orange | Delphin Barankanira | Rel-8 |  | Maurice |  |
| 2774 | 704.3 | CT1 aspects of IMS_Corp | 532d? | 2008-03-07 A | 2010-03-19 A | 100% | 2008-03-07 | 2010-03-19 | 532d? | finish no earlier than 2010-03-19 | C1 | 4244.09h | 4244.09h | IMS_Corp | PCG-21 | Alcatel-Lucent | Keith Drage (drage@alcatel-lucent.com) | Rel-8 | CP-39 | Frederic |  |
| 2775 | 704.4 | (IETF) CT1 aspects of IMS_Corp (RFC 7316) | 825d? | 2011-06-29 A | 2014-09-12 A | 100% | 2011-06-29 | 2014-12-05 | 885d? | finish no earlier than 2014-09-12 | C1-IETF | 6600h | 6600h | IMS_Corp | PCG-27 | Keith Drage | Keith Drage (drage@alcatel-lucent.com) | Rel-8 | CP-53 | Frederic |  |
| 2776 | 704.5 | CT4 aspects of IMS_Corp | 196d? | 2008-02-26 A | 2008-12-05 A | 100% | 2008-02-26 | 2008-12-05 | 196d? | finish no earlier than 2008-12-11 | C4 | 1568h | 1568h | IMS_Corp | PCG-21 | Alcatel-Lucent | Keith Drage (drage@alcatel-lucent.com) | Rel-8 | CP-39 | Kimmo |  |
| 2777 | 705 | **Maintenance of TISPAN documentation** | 1829d? | 2007-07-02 A | 2014-06-13 A | 100% | 2007-07-02 | 2014-06-13 | 1829d? |  | S2; C1; C3; C4; IETF | 85904h | 85904h | MAINTISP | PCG-21 |  |  | Rel-8 | SP-38 | Maurice | MAINTISP |
| 2778 | 705.1 | Maintenance of TISPAN R2 | 86d? | 2007-11-09 A | 2008-03-07 A | 100% | 2007-11-09 | 2008-03-07 | 86d? | start no earlier than 2007-11-09 | C1; C3; C4 | 2064h | 2064h | MAINT_R2 | PCG-21 | Alcatel-Lucent | Keith Drage (drage@alcatel-lucent.com) | Rel-8 | CP-38 | Frederic | MAINT_R2 |
| 2779 | 705.2 | Deleted - (IETF) Maintenance of TISPAN R2 (avasarala-dispatch-comm-div-notification) | 1117d? | 2007-11-09 A | 2014-06-13 A | 100% | 2007-11-09 | 2014-06-13 | 1117d? | finish no earlier than 2014-06-13 | C1-IETF | 8936h | 8936h | MAINT_R2_IETF | PCG-27 | Andrew Allen |  | Rel-8 | CP-52 | Frederic | MAINT_R2_IETF |
| 2780 | 705.3 | Documentation of TISPAN NGN R1 and R2 in 3GPP SA2 | 104d? | 2008-01-14 A | 2008-06-05 A | 100% | 2008-01-14 | 2008-06-05 | 104d? | finish no earlier than 2008-06-20 | S2 | 832h | 832h | IMS_Comm_Doc | PCG-21 | Nokia Siemens Networks | jozsef.varga@nsn.com | Rel-8 | SP-38 | Maurice | IMS_Comm_Doc |
| 2781 | 705.4 | Maintenance of TISPAN release 2 common IMS | 114d? | 2007-07-02 A | 2007-12-06 A | 100% | 2007-07-02 | 2007-12-06 | 114d? | finish no earlier than 2007-12-06 | S2 | 912h | 912h | IMS_Comm_Mtce8 | PCG-21 | Telecom Italia | antonio.ascolese@telecomitalia.it | Rel-8 | SP-38 | Maurice | IMS_Comm_Mtce8 |

Notes:
- 2755: -
- 2756: CP#42 completed / Impacted TSs and TRs: 23.218, 24.141, 24.147, 24.173, 24.229, 24.238, 24.247, 24.604, 24.605, 24.606, 24.607, 24.608, 24.610, 24.611, 24.629, 24.930
- 2757: CP#42 completed / Impacted TSs and TRs: 29.163, 29.212, 29.213, 29.214
- 2758: CP#42 completed / Impacted TSs and TRs: 29.228, 29.229, 29.328, 29.329
- 2759: CP#40 completed
- 2760: CP#40 completed
- 2761: SP#38 completed / Impacted TSs and TRs: 23.228
- 2762: CP#40 completed
- 2763: CP#39 completed
- 2764: SP#37 completed / Impacted TSs and TRs: 23.228
- 2765: CP#39 completed / Impacted TSs and TRs: 24.229
- 2766: CP#40 completed
- 2767: SP#39 completed / Impacted TSs and TRs: 33.203, 33.210, 33.220
- 2768: CP#40 completed / Impacted TSs and TRs: 24.229
- 2769: CP#38 completed / Impacted TSs and TRs: 29.163
- 2770: CP#39 completed / Impacted TSs and TRs: 29.228, 29.229, 23.008
- 2771: CP#47 completed
- 2772: SP#40 completed
- 2773: no Stage 2 impacts / Impacted TSs and TRs: 23.228
- 2774: CP#47 completed / Impacted TSs and TRs: 24.229, 24.503
- 2775: CP#65 completed / Impacted TSs and TRs: RFC 7316 (was draft-vanelburg-dispatch-private-network-ind)
- 2776: CP#42 completed / Impacted TSs and TRs: 29.228, 29.229, 23.003, 23.008, 29.433
- 2777: SP#40 completed
- 2778: CP#39 completed / Impacted TSs and TRs: 24.406, 24.407, 24.410, 24.411, 24.423, 24.430, 24.447, 24.451, 24.454, 24.503, 24.505, 24.508, 24.516, 24.528, 24.529, 29.412, 29.421, 29.433, 29.458, 29.527, 29.624
- 2779: CP#64 Draft removed from 3GPP documentation / Impacted TSs and TRs: draft-avasarala-dispatch-comm-div-notification
- 2780: SP#40 completed / Impacted TSs and TRs: 23.228, 23.204, 23.167
- 2781: SP#38 completed / Impacted TSs and TRs: 23.506, 23.507,23.517, 23.521

| ID | WBS | Task | Type | Duration | Start | Finish | Complete | Remaining | Baseline start | Baseline finish | Baseline duration | Total slack | Constraint | Resources | Work | Actual work | Acronym | PCG approved | WI rapporteur name | WI rapporteur e-mail | Release | TSG approved | MCC resp | Acronym_3GU_Export | Impacted TSs and TRs |
| --- | --- | --- | --- | --- | --- | --- | --- | --- | --- | --- | --- | --- | --- | --- | --- | --- | --- | --- | --- | --- | --- | --- | --- | --- | --- |
| 2782 | 706 | **IMS Service Continuity** |  | 318d? | 2008-03-12 A | 2009-05-29 A | 100% |  | 2008-03-12 | 2009-05-29 | 318d? |  |  | S2; S1; C1 | 10712h | 10712h | IMS-Cont | PCG-21 | LG Electronics | JaeSeung SONG (anthonys@lge.com) | Rel-8 | SP-39 | Maurice | IMS-Cont |  |
| 2783 | 706.1 | Stage 1 IMS Service Continuity |  | 62d? | 2008-03-12 A | 2008-06-05 A | 100% |  | 2008-03-12 | 2008-06-05 | 62d? |  | start no earlier than 2008-03-12 | S1 | 496h | 496h | IMS-Cont | PCG-21 | LG Electronics | JaeSeung SONG (anthonys@lge.com) | Rel-8 | SP-39 | Alain |  |  |
| 2784 | 706.2 | Stage 2 IMS Service Continuity |  | 62d? | 2008-03-12 A | 2008-06-05 A | 100% |  | 2008-03-12 | 2008-06-05 | 62d? |  | finish no earlier than 2008-06-05 | S2 | 496h | 496h | IMS-Cont | PCG-21 | LG Electronics | JaeSeung SONG (anthonys@lge.com) | Rel-8 | SP-39 | Maurice |  | 23.237, 23.292 |
| 2785 | 706.3 | Stage 3 IMS Service Continuity |  | 261d? | 2008-05-30 A | 2009-05-29 A | 100% |  | 2008-05-30 | 2009-05-29 | 261d? |  | finish no earlier than 2009-05-29 | C1 | 2088h | 2088h | IMS-Cont | PCG-21 | Huawei | Lili Yang (kadyyang@huawei.com) | Rel-8 | CP-40 | Frederic |  | 24.237, 24.229, 24.216 |
| 2786 | 707 | **Security Enhancements for IMS** |  | 643.3d? | 2006-09-19 A | 2009-03-06 A | 100% |  | 2006-09-19 | 2009-03-06 | 643.3d? |  |  | S3; C1; C4 | 29847.2h | 29847.2h | IMS-Sec |  | Ericsson | Bengt.Sahlin@ericsson.com | Rel-8 | SP-37 | Mirko | IMS-Sec |  |
| 2787 | 707.1 | Stage 2 for IMS-Sec |  | 466d? | 2007-03-01 A | 2008-12-11 A | 100% |  | 2007-03-01 | 2008-12-11 | 466d? |  | finish no earlier than 2008-12-11 | S3 | 3728h | 3728h | IMS-Sec |  | Ericsson | Bengt.Sahlin@ericsson.com | Rel-8 |  | Mirko |  | 33.203, 33.141, 33.803 |
| 2788 | 707.2 | CT1 part of Stage 3 for IMS-Sec |  | 392d? | 2006-09-19 A | 2008-12-05 A | 100% |  | 2006-09-19 | 2008-12-05 | 392d? |  | finish no earlier than 2008-12-05 | C1 | 3136h | 3136h | IMS-Sec | PCG-21 | Ericsson |  | Rel-8 | CP-39 | Frederic |  |  |
| 2789 | 707.3 | CT4 part of Stage 3 for IMS-Sec |  | 457d? | 2007-06-07 A | 2009-03-06 A | 100% |  | 2007-06-07 | 2009-03-06 | 457d? |  | finish no earlier than 2009-03-06 | C4 | 3656h | 3656h | IMS-Sec | PCG-21 | Ericsson |  | Rel-8 | CP-39 | Kimmo |  |  |
| 2790 | 707.4 | CT1 part of Network Attachment Subsystem (NASS) Bundled Authentication |  | 343d? | 2007-11-14 A | 2009-03-06 A | 100% |  | 2007-11-14 | 2009-03-06 | 343d? |  | finish no earlier than 2009-03-06 | C1 | 2744h | 2744h | NBA | PCG-21 | Alcatel-Lucent | Keith Drage (drage@alcatel-lucent.com) | Rel-8 | CP-39 | Frederic | NBA | 24.229 |
| 2791 | 707.5 | CT4 part of Network Attachment Subsystem (NASS) Bundled Authentication |  | 143d? | 2007-11-14 A | 2008-05-30 A | 100% |  | 2007-11-14 | 2008-05-30 | 143d? |  | start no earlier than 2007-11-14 | C4 | 1144h | 1144h | NBA-CT4 | PCG-21 | Alcatel-Lucent |  | Rel-8 | CP-39 | Kimmo | NBA-CT4 | 29.229, 29.228, 23.008 |
| 2792 | 708 | **IMS initiated and controlled PSS and MBMS User Service** |  | 924d? | 2008-03-12 A | 2011-09-21 A | 100% |  | 2008-03-12 | 2011-09-21 | 924d? |  |  | S4; S3; IETF | 28108.8h | 28108.8h | IMS_PSS_MBMS_US |  | FT, Ericsson | olle.franceschi@ericsson.com | Rel-8 |  | Paolo | IMS_PSS_MBMS_US |  |
| 2793 | 708.1 | SA4, SA3 part of IMS initiated and controlled PSS and MBMS User Service | milestone | 0d? | 2008-03-12 A | 2008-03-12 A | 100% |  | 2008-03-12 | 2008-03-12 | 0d? |  | finish no earlier than 2009-03-12 | S4; S3 |  |  | IMS_PSS_MBMS_US |  | FT, Ericsson | olle.franceschi@ericsson.com | Rel-8 |  | Paolo |  | 26.234, 26.346, 33.246, New 26.237 |
| 2794 | 708.2 | (IETF) IMS initiated and controlled PSS and MBMS User Service (RFC 6080) |  | 743.6d? | 2008-03-12 A | 2011-09-21 A | 100% |  | 2008-03-12 | 2011-09-21 | 743.6d? |  | finish no earlier than 2011-09-21 | S4-IETF | 5932.8h | 5932.8h | IMS_PSS_MBMS_US | PCG-27 | Ericsson |  | Rel-8 | SP-52 | Paolo |  | RFC 6080 (was draft-ietf-sipping-config-framework) |
| 2795 | 709 | **Multimedia interworking between IMS and CS networks** |  | 836d? | 2005-09-23 A | 2008-12-05 A | 100% |  | 2005-09-23 | 2008-12-05 | 836d? |  |  | C3; C4 | 22800h | 22800h | MIW-IMS |  | Vodafone | nico.gabriele@vodafone.com | Rel-8 |  | Adrian | MIW-IMS |  |
| 2796 | 709.1 | Stage 1 and 2 defined in earlier Releases |  | 49d? | 2005-09-23 A | 2005-11-30 A | 100% |  | 2005-09-23 | 2005-11-30 | 49d? |  | start no earlier than 2005-09-23 | S2 | 392h | 392h | MIW-IMS |  | Vodafone | nico.gabriele@vodafone.com | Rel-8 |  | Maurice |  |  |
| 2797 | 709.2 | Stage 3 of MW-IMS |  | 571d? | 2005-09-23 A | 2007-11-30 A | 100% |  | 2005-09-23 | 2007-11-30 | 571d? |  | finish no earlier than 2007-09-14 | C3 | 4568h | 4568h | MIW-IMS-St3C3 |  | Vodafone | nico.gabriele@vodafone.com | Rel-8 |  | Adrian | MIW-IMS-St3 | 29.863, 29.163 |
| 2798 | 709.3 | Stage 3 for MW-IMS, MONA extension |  | 285d? | 2007-11-05 A | 2008-12-05 A | 100% |  | 2007-11-05 | 2008-12-05 | 285d? |  | finish no earlier than 2008-12-05 | C3 | 2280h | 2280h | MIW-IMS-St3C3_MONA | PCG-21 | Vodafone | Christer.Holmberg@ericsson.com | Rel-8 | CP-38 | Adrian |  | 29.863, 29.163 |
| 2799 | 709.4 | Mn interface (MGCF – IM MGW) |  | 273d? | 2007-11-21 A | 2008-12-05 A | 100% |  | 2007-11-21 | 2008-12-05 | 273d? |  | finish no earlier than 2008-12-19 | C4 | 2184h | 2184h | MIW-IMS-St3C4 | PCG-21 | Vodafone | Christer.Holmberg@ericsson.com | Rel-8 | CP-38 | Kimmo |  | 29.332 |
| 2800 | 710 | **IMS Stage 3 IETF Protocol Alignment - phase 2** |  | 1965d? | 2007-06-22 A | 2014-12-09 | 96% | 81.7d? | 2007-06-22 | 2014-12-05 | 1960d? | 657d |  | C1; IETF | 55368h | 30068.8h | IMSProtoc2 |  | Alcatel-Lucent | Keith Drage (drage@alcatel-lucent.com) | Rel-8 |  | Frederic | IMSProtoc2 |  |
| 2801 | 710.1 | CT1 aspects of IMS Stage 3 IETF Protocol Alignment - phase 2 |  | 446d? | 2007-06-22 A | 2009-03-06 A | 100% |  | 2007-06-22 | 2009-03-06 | 446d? |  | finish no earlier than 2009-03-06 | C1 | 3568h | 3568h | IMSProtoc2 |  | Alcatel-Lucent | Keith Drage (drage@alcatel-lucent.com) | Rel-8 |  | Frederic |  | 23.218, 24.229, 24.930 |
| 2802 | 710.2 | (IETF) IMS Stage 3 IETF Protocol Alignment (draft-bakker-sipping-3gpp-ims-xml-body-handling) |  | 715d? | 2007-06-22 A | 2012-12-07 A | 100% |  | 2007-06-22 | 2012-12-07 | 715d? |  | finish no earlier than 2012-12-07 | C1-IETF | 5720h | 5720h | IMSProtoc2 | PCG-27 | Andrew Allen |  | Rel-8 | CP-52 | Frederic |  | draft-bakker-sipping-3gpp-ims-xml-body-handling |
| 2803 | 710.3 | (IETF) IMS Stage 3 IETF Protocol Alignment (RFC 6544) |  | 587d? | 2007-06-22 A | 2012-06-15 A | 100% |  | 2007-06-22 | 2012-06-15 | 587d? |  | finish no earlier than 2012-04-20 | C1-IETF | 4688h | 4688h | IMSProtoc2 | PCG-27 | Keith Drage |  | Rel-8 | CP-52 | Frederic |  | RFC 6544 (was draft-ietf-mmusic-ice-tcp) |
| 2804 | 710.4 | (IETF) IMS Stage 3 IETF Protocol Alignment (draft-ietf-salud-alert-info-urns) |  | 1244d? | 2007-06-22 A | 2014-12-09 | 90% | 124.4d? | 2007-06-22 | 2014-12-05 | 1242d? | 657d | finish no earlier than 2014-12-09 | C1-IETF | 9952h | 8956.8h | IMSProtoc2 | PCG-27 | Roland Jesske | Roland Jesske | Rel-8 | CP-52 | Frederic |  | draft-ietf-salud-alert-info-urns |
| 2805 | 711 | **Interworking between User-to-User Signalling (UUS) and SIP** |  | 1850d? | 2007-11-30 A | 2014-12-09 | 99% | 0d? | 2007-11-30 | 2014-12-05 | 1845d? | 0d |  | C1; C3; IETF | 68624.4h | 24248.4h | UUSIW | PCG-21 | Huawei | Lili Yang (kadyyang@huawei.com) | Rel-8 | CP-38 | Kimmo | UUSIW |  |
| 2806 | 711.1 | CT1 part of Stage 3 MGCF UUSIW |  | 266d? | 2007-11-30 A | 2008-12-05 A | 100% |  | 2007-11-30 | 2008-12-05 | 266d? |  | finish no earlier than 2008-12-05 | C1 | 2128h | 2128h | UUSIW | PCG-21 | Huawei | Lili Yang (kadyyang@huawei.com) | Rel-8 | CP-38 | Frederic |  | 24.279, 24.229 |
| 2807 | 711.2 | (IETF) Stage 3 MGCF UUSIW (cuss-sip-uui) |  | 227.03d? | 2007-11-30 A | 2014-12-09 A | 100% |  | 2007-11-30 | 2014-12-05 | 225.03d? |  | finish no earlier than 2014-12-09 | C1-IETF; C3-IETF | 3632.4h | 3632.4h | UUSIW | PCG-27 | Roland Jesske | Roland Jesske | Rel-8 | CP-52 | Frederic |  | RFC 7433 |
| 2808 | 711.3 | (IETF) Stage 3 MGCF UUSIW (cuss-sip-uui-isdn) |  | 986.5d? | 2011-03-17 A | 2014-12-09 A | 100% |  | 2011-03-17 | 2014-12-05 | 984.5d? |  | finish no earlier than 2014-12-09 | C1-IETF; C3-IETF | 15784h | 15784h | UUSIW | PCG-28 | Keith Drage | Keith Drage (drage@alcatel-lucent.com) | Rel-8 | CP-55 | Frederic |  | RFC 7434 |
| 2809 | 711.4 | CT3 part of Stage 3 MGCF UUSIW |  | 335d? | 2007-11-30 A | 2009-03-12 A | 100% |  | 2007-11-30 | 2009-03-12 | 335d? |  | finish no earlier than 2009-03-12 | C3 | 2680h | 2680h | UUSIW | PCG-21 | Huawei | Lili Yang (kadyyang@huawei.com) | Rel-8 | CP-38 | Adrian |  | 29.163 |

Notes:
- 2782: CP#44 completed
- 2783: SP#40 completed
- 2784: SP#40 completed
- 2785: CP#44 completed
- 2786: CP#43 completed
- 2787: SP#42 completed. SP#46 withdrawn draft 33.178-100 and 33.978 from Rel-8 onwards
- 2788: CP#42 completed
- 2789: CP#43 completed
- 2790: CP#43 completed
- 2791: CP#40 completed
- 2792: SP#39 WID approved
- 2793: SP#43 completed
- 2794: SP#53/IETF#81 completed
- 2795: CP#42 completed
- 2796: SP#31 Moved from FS section Feb 2006
- 2797: Moved from Rel-7. Feature extended in Rel-8 by including Stage 3 covering MONA UID_380021
- 2798: CP#42 completed
- 2799: CP#42 completed
- 2800: CP#43 completed
- 2801: CP#43 completed
- 2802: CP#58 completed. ietf-draft discontinued. Documented within 3GPP
- 2803: CP#56 completed
- 2804: In RFC Editors Queue. Dec.14: 75->90
- 2805: CP#43 completed
- 2806: CP#42 completed
- 2807: In RFC Editors Queue. Mar15: 90->100%. RFC updated (was draft-ietf-cuss-sip-uui)
- 2808: In RFC Editors Queue. Dec.14: 75->90. Mar15: 90->100%. RFC updated (was draft-ietf-cuss-sip-uui-isdn)
- 2809: CP#43 completed

| ID | WBS | Task | Type | Duration | Start | Finish | Complete | Baseline start | Baseline finish | Baseline duration | Constraint | Resources | Work | Actual work | Acronym | PCG approved | WI rapporteur name | WI rapporteur e-mail | Release | TSG approved | MCC resp | Acronym_3GU_Export | Impacted TSs and TRs | Special Focus Doc | Status Report |
| --- | --- | --- | --- | --- | --- | --- | --- | --- | --- | --- | --- | --- | --- | --- | --- | --- | --- | --- | --- | --- | --- | --- | --- | --- | --- |
| 2810 | 712 | **Support of Overlap signalling** |  | 331d? | 2007-11-30 A | 2009-03-06 A | 100% | 2007-11-30 | 2009-03-06 | 331d? |  | C3; C1; C4 | 15304.2h | 15304.2h | Overlap | PCG-21 | Deutsche Telekom | r.jesske@telekom.de | Rel-8 | CP-38 | Adrian | Overlap |  |  |  |
| 2811 | 712.1 | Stage 3 Overlap (CT1) |  | 331d? | 2007-11-30 A | 2009-03-06 A | 100% | 2007-11-30 | 2009-03-06 | 331d? | finish no earlier than 2009-03-06 | C1 | 2648h | 2648h | Overlap | PCG-21 | Deutsche Telekom | r.jesske@telekom.de | Rel-8 | CP-38 | Frederic |  | 24.229 |  |  |
| 2812 | 712.2 | Stage 3 Overlap (CT3) |  | 331d? | 2007-11-30 A | 2009-03-06 A | 100% | 2007-11-30 | 2009-03-06 | 331d? | finish no earlier than 2009-03-06 | C3 | 2648h | 2648h | Overlap | PCG-21 | Deutsche Telekom | r.jesske@telekom.de | Rel-8 | CP-38 | Adrian |  | 29.163 |  |  |
| 2813 | 712.3 | Stage 3 Overlap (CT4) |  | 258.02d? | 2007-11-30 A | 2008-12-05 A | 100% | 2007-11-30 | 2008-12-05 | 258.02d? | start no earlier than 2007-11-30 | C4 | 2064.16h | 2064.16h | Overlap | PCG-21 | Deutsche Telekom | r.jesske@telekom.de | Rel-8 | CP-38 | Kimmo |  | 29.228, 29.229 |  |  |
| 2814 | 713 | **AS/MRFC Stage 2 and 3** |  | 1203d? | 2007-11-14 A | 2012-06-15 A | 100% | 2007-11-14 | 2012-06-15 | 1203d? |  | C1; IETF | 28384h | 28384h | MRFC_TS | PCG-21 | Hewlett-Packard | mark.syrett@hp.com | Rel-8 | CP-38 | Frederic | MRFC_TS |  |  |  |
| 2815 | 713.1 | AS/MRFC Stage 2 |  | 278d? | 2007-11-14 A | 2008-12-05 A | 100% | 2007-11-14 | 2008-12-05 | 278d? | finish no earlier than 2008-12-05 | C1 | 2224h | 2224h | MRFC_TS | PCG-21 | Hewlett-Packard | mark.syrett@hp.com | Rel-8 | CP-38 | Frederic |  | 23.218 |  |  |
| 2816 | 713.2 | AS/MRFC Stage 3 |  | 278d? | 2007-11-14 A | 2008-12-05 A | 100% | 2007-11-14 | 2008-12-05 | 278d? | finish no earlier than 2008-12-05 | C1 | 2224h | 2224h | MRFC_TS | PCG-21 | Hewlett-Packard | mark.syrett@hp.com | Rel-8 | CP-38 | Frederic |  | 24.229, 24.147, 24.247 |  |  |
| 2817 | 713.3 | (IETF) AS/MRFC Stage 2 and 3 (RFC 6505) |  | 590d? | 2007-11-14 A | 2012-06-15 A | 100% | 2007-11-14 | 2012-06-15 | 590d? | finish no earlier than 2012-06-15 | C1-IETF | 4688h | 4688h | MRFC_TS | PCG-27 | Keith Drage |  | Rel-8 | CP-52 | Frederic |  | RFC 6505 (was draft-ietf-mediactrl-mixer-control-package) |  |  |
| 2818 | 714 | **IMS Restoration Procedures** |  | 201d? | 2008-05-30 A | 2009-03-06 A | 100% | 2008-05-30 | 2009-03-06 | 201d? |  | C4; C1 | 6432h | 6432h | IMS_RP | PCG-21 | Ericsson | german.blanco@ericsson.com | Rel-8 | SP-40 | Kimmo | IMS_RP |  |  |  |
| 2819 | 714.1 | IMS Restoration Procedures (CT4) |  | 201d? | 2008-05-30 A | 2009-03-06 A | 100% | 2008-05-30 | 2009-03-06 | 201d? | finish no earlier than 2009-03-06 | C4 | 1608h | 1608h | IMS_RP | PCG-21 | Ericsson | german.blanco@ericsson.com | Rel-8 | SP-40 | Kimmo |  | 23.380, 29.228, 29.229, 29.230, 23.008 |  |  |
| 2820 | 714.2 | IMS Restoration Procedures (CT1) |  | 201d? | 2008-05-30 A | 2009-03-06 A | 100% | 2008-05-30 | 2009-03-06 | 201d? | finish no earlier than 2009-03-06 | C1 | 1608h | 1608h | IMS_RP | PCG-21 | Ericsson | german.blanco@ericsson.com | Rel-8 | SP-40 | Frederic |  | 24.229 |  |  |
| 2821 | 715 | IMS Application Server Service Data Descriptions for AS interoperability |  | 125d? | 2008-09-12 A | 2009-03-06 A | 100% | 2008-09-12 | 2009-03-06 | 125d? | finish no earlier than 2009-03-06 | C4 | 1000h | 1000h | IMS_ASIO | PCG-21 | Alcatel-Lucent | nhberry@alcatel-lucent.com | Rel-8 | CP-41 | Kimmo | IMS_ASIO | 29.328, 29.329, 29.364 |  |  |
| 2822 | 716 | **I-WLAN Network Selection Principle (NSP)** |  | 451d? | 2007-06-14 A | 2009-03-06 A | 100% | 2007-06-14 | 2009-03-06 | 451d? |  | S1; C1; C6 | 13859.2h | 13859.2h | IWLANNSP |  | Telefónica O2 | chris.friel@O2.com | Rel-8 |  | Alain | IWLANNSP |  | WLAN |  |
| 2823 | 716.1 | Stage 1 for I-WLAN NSP | milestone | 0d? | 2007-06-14 A | 2007-06-14 A | 100% | 2007-06-14 | 2007-06-14 | 0d? |  | S1 |  |  | IWLANNSP | PCG-21 | Telefónica O2 | chris.friel@O2.com | Rel-8 | SP-39 | Alain |  | 22.234 | WLAN |  |
| 2824 | 716.2 | CT1 part of Stage 3 for I-WLAN NSP |  | 261d? | 2008-03-07 A | 2009-03-06 A | 100% | 2008-03-07 | 2009-03-06 | 261d? | finish no earlier than 2008-12-05 | C1 | 2088h | 2088h | IWLANNSP | PCG-21 | Research In Motion | Adrian Buckley (abuckley@rim.com) | Rel-8 | CP-39 | Frederic |  | 24.234 | WLAN |  |
| 2825 | 716.3 | CT6 part of Stage 3 for I-WLAN NSP |  | 118.4d? | 2008-03-07 A | 2008-12-11 A | 100% | 2008-03-07 | 2008-12-11 | 118.4d? | finish no earlier than 2008-12-11 | C6 | 947.2h | 947.2h | IWLANNSP | PCG-21 | Research In Motion | Adrian Buckley (abuckley@rim.com) | Rel-8 | CP-39 | Xavier |  | 31.102, 31.111 | WLAN |  |
| 2826 | 717 | **Mobility between 3GPP-WLAN Interworking and 3GPP Systems** |  | 386d? | 2007-09-14 A | 2009-03-06 A | 100% | 2007-09-14 | 2009-03-06 | 386d? |  | S2; C1 | 9304h | 9304h | IWLAN_Mob |  | Orange | xiaobao.chen@orange-ftgroup.com | Rel-8 | SP-37 | Maurice | IWLAN_Mob |  | WLAN |  |
| 2827 | 717.1 | Stage 2 for Mobility between 3GPP-WLAN Interworking and 3GPP Systems |  | 190d? | 2007-09-14 A | 2008-06-05 A | 100% | 2007-09-14 | 2008-06-05 | 190d? | finish no earlier than 2008-09-08 | S2 | 1520h | 1520h | IWLAN_Mob | PCG-21 | Orange | xiaobao.chen@orange-ftgroup.com | Rel-8 | SP-38 | Maurice |  | new 23.327 | WLAN |  |
| 2828 | 717.2 | CT1 aspects of Mobility between 3GPP-WLAN Interworking and 3GPP Systems |  | 201d? | 2008-05-30 A | 2009-03-06 A | 100% | 2008-05-30 | 2009-03-06 | 201d? | finish no earlier than 2009-03-06 | C1 | 1608h | 1608h | IWLAN_Mob | PCG-21 | Orange | reina.nader@orange-ftgroup.com | Rel-8 | CP-40 | Frederic |  | 24.303, new 24.327 | WLAN |  |
| 2829 | 718 | Conformance Test Aspects – Mobility between 3GPP WLAN Interworking and 3GPP Systems |  | 206d? | 2009-12-04 A | 2010-09-17 A | 100% | 2009-12-04 | 2010-09-17 | 206d? | finish no earlier than 2010-09-17 | R5 | 1648h | 1648h | IWLAN_Mob_UEConTest | PCG-24 | Qualcomm | Patrick Stupar (pstupar@qualcomm.com) | Rel-8 | RP-46 | Ingbert | IWLAN_Mob_UEConTest | 34.108, 34.123-1, 34.123-2, 34.123-3 | WLAN | RP-100740 |
| 2830 | 719 | **Enhancements for Voice Group Call Service (VGCS) Applications (EVA)** |  | 919d? | 2006-03-15 A | 2009-09-18 A | 100% | 2006-03-15 | 2009-09-18 | 919d? |  | S1; C1; C4; G2 | 45559.5h | 45559.5h | EVA |  | Nortel | Amar Deol (deola@nortelnetworks.com) | Rel-8 |  | Alain | EVA |  |  |  |
| 2831 | 719.1 | SA1 aspects of EVA |  | 191d? | 2006-03-15 A | 2006-12-06 A | 100% | 2006-03-15 | 2006-12-06 | 191d? | finish no earlier than 2006-12-06 | S1 | 1528h | 1528h | EVA |  | Nortel | Amar Deol (deola@nortelnetworks.com) | Rel-8 |  | Alain |  | 42.068 |  |  |
| 2832 | 719.2 | VGCS/VBS and GPRS Interactions |  | 145d? | 2007-09-03 A | 2008-03-21 A | 100% | 2007-09-03 | 2008-03-21 | 145d? | finish no earlier than 2008-03-21 | S1 | 1160h | 1160h | EVA |  | Huawei | Ling Liu | Rel-8 | SP-37 | Alain |  | 42.068, 42.069 |  |  |
| 2833 | 719.3 | CT1 aspects of EVA |  | 862d? | 2006-06-02 A | 2009-09-18 A | 100% | 2006-06-02 | 2009-09-18 | 862d? | finish no earlier than 2009-12-04 | C1 | 6887.53h | 6887.53h | EVA |  | Nortel | milanpa@nortel.com | Rel-8 |  | Frederic |  | 43.068, 44.068 |  |  |
| 2834 | 719.4 | CT4 aspects of EVA |  | 391d? | 2006-06-02 A | 2007-11-30 A | 100% | 2006-06-02 | 2007-11-30 | 391d? | finish no earlier than 2007-06-01 | C4 | 3128h | 3128h | EVA |  | Nortel |  | Rel-8 |  | Kimmo |  | 29.002 |  |  |
| 2835 | 719.5 | GERAN2 aspects of EVA |  | 431d? | 2006-06-30 A | 2008-02-22 A | 100% | 2006-06-30 | 2008-02-22 | 431d? | finish no earlier than 2008-02-22 | G2 | 3448h | 3448h | EVA |  | Nortel | frank.billenkamp@nortel.com | Rel-8 |  | Gert |  | 44.018, 48.008 |  |  |

Notes:
- 2810: CP#43 completed
- 2811: CP#43 completed
- 2812: CP#43 completed
- 2813: CP#42 completed
- 2814: Triggered by Study UID_7048 (MRFC)
- 2815: CP#42 completed
- 2816: CP#42 completed
- 2817: CP#56 completed
- 2818: CP#43 completed. Triggered by Study TR 23.820 (FS_IMS_RP) UID_350018
- 2819: CP#43 completed
- 2820: CP#43 completed
- 2821: CP#43 completed. Triggered by UID_360030 (FS_IMS_ASIO)
- 2822: CP#43 completed
- 2823: SP#36 completed
- 2824: CP#43 completed
- 2825: CP#42 completed
- 2826: CP#43 completed
- 2827: SP#40 completed
- 2828: CP#43 completed
- 2829: RP#49 completed. Testing for Rel-8 UID_400013 CT1 aspects of mobility between 3GPP WLAN Interworking and 3GPP Systems (24.327)
- 2830: CP#45 completed
- 2831: SP#38 completed
- 2832: SP#39 completed
- 2833: CP#45 completed
- 2834: CP#38 completed
- 2835: GP#37 completed

| ID | WBS | Task | Type | Duration | Start | Finish | Complete | Baseline start | Baseline finish | Baseline duration | Constraint | Resources | Work | Actual work | Acronym | WI rapporteur name | WI rapporteur e-mail | Release | MCC resp | Acronym_3GU_Export | Impacted TSs and TRs | TSG stopped | Special Focus Doc | TSG approved | PCG approved | Status Report |
| --- | --- | --- | --- | --- | --- | --- | --- | --- | --- | --- | --- | --- | --- | --- | --- | --- | --- | --- | --- | --- | --- | --- | --- | --- | --- | --- |
| 2836 | 720 | **Personal Network Management** |  | 955d? | 2005-07-11 A | 2009-03-06 A | 100% | 2005-07-11 | 2009-03-06 | 955d? |  | S1; C1; S3 | 46368h | 46368h | PNM | Vodafone | armin.toepfer@vodafone.com | Rel-8 | Alain | PNM |  |  |  |  |  |  |
| 2837 | 720.1 | Stage 1 for PNM |  | 276d? | 2005-07-11 A | 2006-07-31 A | 100% | 2005-07-11 | 2006-07-31 | 276d? | start no earlier than 2005-07-11 | S1 | 2208h | 2208h | PNM | Vodafone | armin.toepfer@vodafone.com | Rel-8 | Alain |  | 22.259 |  |  |  |  |  |
| 2838 | 720.2 | Stage 2 for PNM |  | 445d? | 2007-03-26 A | 2008-12-05 A | 100% | 2007-03-26 | 2008-12-05 | 445d? | finish no earlier than 2008-12-05 | C1 | 3560h | 3560h | PNM | Vodafone | yang.lu@vodafone.com | Rel-8 | Frederic |  | 23.259 |  |  |  |  |  |
| 2839 | 720.3 | **Stage 3 for PNM** |  | 510d? | 2007-03-26 A | 2009-03-06 A | 100% | 2007-03-26 | 2009-03-06 | 510d? |  | C1; C4 | 15800h | 15800h | PNM | Vodafone | yang.lu@vodafone.com | Rel-8 | Frederic |  |  |  |  |  |  |  |
| 2840 | 720.3.1 | CT1 aspects of Stage 3 PNM |  | 510d? | 2007-03-26 A | 2009-03-06 A | 100% | 2007-03-26 | 2009-03-06 | 510d? | finish no earlier than 2008-12-05 | C1 | 4080h | 4080h | PNM | Vodafone | yang.lu@vodafone.com | Rel-8 | Frederic |  | 24.259, 24.229 |  |  |  |  |  |
| 2841 | 720.3.2 | Deleted - CT4 aspects of Stage 3 PNM |  | 445d? | 2007-03-26 A | 2008-12-05 A | 100% | 2007-03-26 | 2008-12-05 | 445d? | finish no earlier than 2008-12-11 | C4 | 3560h | 3560h | PNM | Vodafone | yang.lu@vodafone.com | Rel-8 | Kimmo |  |  | CP-42 |  |  |  |  |
| 2842 | 720.4 | Key establishment between a UICC hosting device and a remote device |  | 235d? | 2006-12-06 A | 2007-10-30 A | 100% | 2006-12-06 | 2007-10-30 | 235d? | finish no earlier than 2007-10-30 | S3 | 1880h | 1880h | PNM | Ericsson | Vesa.Lehtovirta@ericsson.com | Rel-8 | Mirko |  | 33.259 |  |  |  |  |  |
| 2843 | 720.5 | Deleted - Actual Requirements of PNM | milestone | 0d? | 2007-03-26 A | 2007-03-26 A | 100% | 2007-03-26 | 2007-03-26 | 0d? | finish no earlier than 2007-03-26 | C1 |  |  | PNM | Ericsson |  | Rel-8 | Frederic |  |  | SP-37 |  |  |  |  |
| 2844 | 721 | **eCall Data Transfer** |  | 637d? | 2006-09-28 A | 2009-03-06 A | 100% | 2006-09-28 | 2009-03-06 | 637d? |  | S1; C1 | 14840h | 14840h | EData | Airbiquity | rrobinson@airbiquity.com | Rel-8 | Alain | EData |  |  | Public Safety (I-A) |  |  |  |
| 2845 | 721.1 | eData Requirements |  | 380d? | 2006-09-28 A | 2008-03-12 A | 100% | 2006-09-28 | 2008-03-12 | 380d? | finish no earlier than 2006-12-07 | S1 | 3040h | 3040h | EData | Airbiquity | rrobinson@airbiquity.com | Rel-8 | Alain |  | 22.101, 22.105 |  | Public Safety (I-A) | SP-37 |  |  |
| 2846 | 721.2 | Transfer of data during an emergency call |  | 201d? | 2008-05-30 A | 2009-03-06 A | 100% | 2008-05-30 | 2009-03-06 | 201d? | finish no earlier than 2009-03-06 | C1 | 1608h | 1608h | EData | T-Mobile | Dieter Jacobsohn | Rel-8 | Frederic |  | 24.008 |  | Public Safety (I-A) | SP-40 | PCG-21 |  |
| 2847 | 722 | eCall data transfer Phase 2: Comparison of alternative in-band modem solutions and standardization of one in-band modem solution |  | 472d? | 2007-12-06 A | 2009-09-24 A | 100% | 2007-12-06 | 2009-09-24 | 472d? | finish no earlier than 2009-09-24 | S4 | 3768.09h | 3768.09h | eCall_Phase2 | Airbiquity | lhong@airbiquity.com & rrobinson@airbiquity.com | Rel-8 | Paolo | eCall_Phase2 | 26.267, 26.268, 26.269, 26.967, 26.969 |  | Public Safety (I-A) |  |  |  |
| 2848 | 723 | eCall Conformance Testing |  | 261d? | 2009-09-04 A | 2010-09-03 A | 100% | 2009-09-04 | 2010-09-03 | 261d? | finish no earlier than 2010-09-03 | G3new | 2088h | 2088h | eCall_MSTest | Ericsson, Qualcomm | Vikrant Jain (vikrantj@qualcomm.com) | Rel-8 | Ingbert | eCall_MSTest | 51.010-1, 51.010-2 |  | Public Safety (I-A) | GP-45 | PCG-23 |  |
| 2849 | 724 | Conformance Test Aspects – non-modem procedures of eCall sessions in UTRA |  | 186d? | 2009-09-18 A | 2010-06-04 A | 100% | 2009-09-18 | 2010-06-04 | 186d? | finish no earlier than 2010-06-04 | R5 | 1488h | 1488h | UMTS_eCall_UEConTest | Ericsson, Qualcomm | Shubhang Vora (svora@qualcomm.com) | Rel-8 | Ingbert | UMTS_eCall_UEConTest | 34.108, 34.123-1, 34.123-2, 34.123-3 |  | Public Safety (I-A) | RP-45 | PCG-23 | RP-100489 |
| 2850 | 725 | **IP Interconnection of Services** |  | 668d? | 2006-08-16 A | 2009-03-06 A | 100% | 2006-08-16 | 2009-03-06 | 668d? |  | S1; S2; S5; C3 | 44240h | 44240h | IPinterc | Telefónica O2 | chris.friel@O2.com | Rel-8 | Alain | IPinterc |  |  |  | SP-38 | PCG-21 |  |
| 2851 | 725.1 | Stage 1 for IPinterc |  | 70d? | 2007-12-06 A | 2008-03-12 A | 100% | 2007-12-06 | 2008-03-12 | 70d? | start no earlier than 2007-12-06 | S1 | 560h | 560h | IPinterc | Telefónica O2 | chris.friel@O2.com | Rel-8 | Alain |  | 22.101, 22.228 |  |  | SP-38 | PCG-21 |  |
| 2852 | 725.2 | **System enhancements for interconnection interfaces between two IMSs** |  | 668d? | 2006-08-16 A | 2009-03-06 A | 100% | 2006-08-16 | 2009-03-06 | 668d? |  | S2; S5; C3 | 22304h | 22304h | IMS_NNI | Telecom Italia | Mario Madella (mario.madella@telecomitalia.it) | Rel-8 | Maurice | IMS_NNI |  |  |  |  |  |  |
| 2853 | 725.2.1 | Stage 2 for IMS_NNI |  | 120d? | 2007-06-22 A | 2007-12-06 A | 100% | 2007-06-22 | 2007-12-06 | 120d? | finish no earlier than 2007-12-21 | S2 | 960h | 960h | IMS_NNI | Telecom Italia | Mario Madella (mario.madella@telecomitalia.it) | Rel-8 | Maurice |  | 23.002, 23.228 |  |  |  |  |  |
| 2854 | 725.2.2 | IMS inter-operator service interconnection interface |  | 461d? | 2007-06-01 A | 2009-03-06 A | 100% | 2007-06-01 | 2009-03-06 | 461d? | finish no earlier than 2009-03-06 | C3 | 3688h | 3688h | FBI2-IOPSI | Telecom Italia | antonio.ascolese@telecomitalia.it | Rel-8 | Adrian | FBI2-IOPSI | 29.865, 29.165 |  |  |  |  |  |
| 2855 | 725.2.3 | Charging harmonization for NGN between 3GPP and ATIS-TMOC |  | 51d? | 2006-09-28 A | 2006-12-07 A | 100% | 2006-09-28 | 2006-12-07 | 51d? | finish no earlier than 2006-12-07 | S5 | 408h | 408h | FBI2-TISP2-CH | Amdocs | yishai.brown@amdocs.com | Rel-8 | Mirko | FBI2-TISP2-CH | 32.297 |  |  |  |  |  |
| 2856 | 725.2.4 | Deleted - Protocol impact of FBI for TISPAN R2 |  | 152d? | 2006-08-16 A | 2007-03-15 A | 100% | 2006-08-16 | 2007-03-15 | 152d? | finish no earlier than 2007-03-15 | C1 | 1216h | 1216h | FBI2-TISP2-c1 | Ericsson |  | Rel-8 | Frederic | FBI2-TISP2-c1 |  | SP-38 |  |  |  |  |
| 2857 | 725.2.5 | Deleted (never approved) - Stage 2 of FBI for TISPAN R2 - Rel 8 | milestone | 0d? | 2007-11-30 A | 2007-11-30 A | 100% | 2007-11-30 | 2007-11-30 | 0d? | finish no earlier than 2007-11-30 | S2 |  |  | FBI2-TISP2-s2 | Nokia Siemens Networks |  | Rel-8 | Maurice | FBI2-TISP2-s2 |  | SP-36 |  |  |  |  |
| 2858 | 726 | **Support of (G)MSC-S – (G)MSC-S Nc Interface based on the SIP-I protocol** |  | 386d? | 2007-09-14 A | 2009-03-06 A | 100% | 2007-09-14 | 2009-03-06 | 386d? |  | C4; C3 | 14960h | 14960h | SIP_Nc | Vodafone | David.Hutton@vodafone.com | Rel-8 | Kimmo | SIP_Nc |  |  |  |  |  |  |
| 2859 | 726.1 | Stage 1 for SIP_Nc (covered by Feature IPinterc) |  | 70d? | 2007-12-06 A | 2008-03-12 A | 100% | 2007-12-06 | 2008-03-12 | 70d? | start no earlier than 2007-12-06 | S1 | 560h | 560h | SIP_Nc | Telefónica O2 | chris.friel@O2.com | Rel-8 | Alain |  | 22.101, 22.228 |  |  | CP-41 | PCG-21 |  |
| 2860 | 726.2 | SIP-I based circuit-switched core network; Stage 2 |  | 321d? | 2007-09-14 A | 2008-12-05 A | 100% | 2007-09-14 | 2008-12-05 | 321d? | finish no earlier than 2008-12-11 | C4 | 2568h | 2568h | SIP_Nc-St2 | Vodafone | David.Hutton@vodafone.com | Rel-8 | Kimmo | SIP_Nc-St2 | 23.231, 23.153, 23.205 |  |  |  |  |  |
| 2861 | 726.3 | Application of SIP-I Protocols to Circuit Switched (CS) core network architecture; Stage 3 |  | 321d? | 2007-09-14 A | 2008-12-05 A | 100% | 2007-09-14 | 2008-12-05 | 321d? | finish no earlier than 2008-12-11 | C4 | 2568h | 2568h | SIP_Nc-St3C4 | Vodafone | David.Hutton@vodafone.com | Rel-8 | Kimmo | SIP_Nc-St3 | 29.231, 29.232, 29.332 |  |  |  |  |  |
| 2862 | 726.4 | Interworking between the 3GPP CS domain with SIP-I as signalling protocol and other networks |  | 386d? | 2007-09-14 A | 2009-03-06 A | 100% | 2007-09-14 | 2009-03-06 | 386d? | finish no earlier than 2009-03-06 | C3 | 3088h | 3088h | SIP_Nc-St3C3 | Nokia Siemens Networks | Thomas.Belling@nsn.com | Rel-8 | Adrian |  | 29.235, 23.172, 23.202, 29.007, 29.163, 29.414 |  |  |  |  |  |

Notes:
- 2836: CP#43 completed
- 2837: SP#31 completed
- 2838: CP#42 completed
- 2839: CP#43 completed
- 2840: CP#43 completed
- 2841: CP#42 no impact on CT4 specs
- 2842: SP#37 completed
- 2843: SP#37 stopped
- 2844: SP#39 completed. Linked to SA4 Feature UID_34042 (eCall_Phase2)
- 2845: SP#39 completed
- 2846: CP#43 completed
- 2847: SP#45 completed. Triggered by Study UID_360015 (eCALLIBMS). Linked to SA1 Feature UID_330005 (EData)
- 2848: GP#47 completed. GP#43 WID approved. Testing for Rel-8 eCall_Phase2 (UID_34042) and EData (UID_330005)
- 2849: RP#48 completed. Testing for Rel-8 eCall_Phase2 (UID_34042) and Edata (UID_330005)
- 2850: SP#43 completed
- 2851: SP#39 completed.
- 2852: CP#43 completed
- 2853: SP#38 completed
- 2854: CP#43 completed
- 2855: SP#34 completed
- 2856: SP#38 stopped
- 2857: SP#36 stopped
- 2858: CP#43 completed. Stage 1 in Feature UID_380060 (IPinterc). CP#40 updated WID CP-070517=>CP-080282
- 2859: 22/07/08 Created. Stage 1 for SIP_Nc (covered by SA1 Feature UID_380060 Ipinterc)
- 2860: CP#42 completed
- 2861: CP#42 completed
- 2862: CP#43 completed. CP#42 target 12/08=>03/09

| ID | WBS | Task | Type | Duration | Start | Finish | Complete | Baseline start | Baseline finish | Baseline duration | Constraint | Resources | Work | Actual work | Acronym | WI rapporteur name | WI rapporteur e-mail | Release | TSG approved | MCC resp | Special Focus Doc | Acronym_3GU_Export | Impacted TSs and TRs | PCG approved | Status Report |
| --- | --- | --- | --- | --- | --- | --- | --- | --- | --- | --- | --- | --- | --- | --- | --- | --- | --- | --- | --- | --- | --- | --- | --- | --- | --- |
| 2863 | 727 | **Earthquake and Tsunami Warning System** |  | 440d? | 2007-09-10 A | 2009-05-15 A | 100% | 2007-09-10 | 2009-05-15 | 440d? |  | S1; S2; C1; C4; G2 | 21280h | 21280h | ETWS | NTT DoCoMo | kitaharar@nttdocomo.co.jp | Rel-8 | SP-37 | Alain | Public Safety (I-A) | ETWS |  |  |  |
| 2864 | 727.1 | Stage 1 for ETWS |  | 133d? | 2007-09-10 A | 2008-03-12 A | 100% | 2007-09-10 | 2008-03-12 | 133d? | finish no earlier than 2008-03-12 | S1 | 1064h | 1064h | ETWS | NTT DoCoMo | kitaharar@nttdocomo.co.jp | Rel-8 | SP-37 | Alain | Public Safety (I-A) |  | 22.168 |  |  |
| 2865 | 727.2 | SA2 aspects of ETWS |  | 179d? | 2008-01-14 A | 2008-09-18 A | 100% | 2008-01-14 | 2008-09-18 | 179d? | finish no earlier than 2008-09-08 | S2 | 1432h | 1432h | ETWS | NTT DoCoMo | tanakai@nttdocomo.co.jp | Rel-8 | SP-38 | Maurice | Public Safety (I-A) |  | 23.828, 23.401 | PCG-21 |  |
| 2866 | 727.3 | CT1 aspects of ETWS |  | 50.5d? | 2008-05-30 A | 2008-12-05 A | 100% | 2008-05-30 | 2008-12-05 | 50.5d? | finish no earlier than 2008-12-05 | C1 | 404h | 404h | ETWS | NTT DoCoMo | yamashitahi@s1.nttdocomo.co.jp | Rel-8 | CP-40 | Frederic | Public Safety (I-A) |  | 23.041 | PCG-21 |  |
| 2867 | 727.4 | CT4 aspects of ETWS |  | 50.5d? | 2008-09-26 A | 2008-12-05 A | 100% | 2008-09-26 | 2008-12-05 | 50.5d? | finish no earlier than 2008-12-05 | C4 | 404h | 404h | ETWS | NTT DoCoMo | yamashitahi@s1.nttdocomo.co.jp | Rel-8 | CP-40 | Kimmo | Public Safety (I-A) |  | 29.168 | PCG-21 |  |
| 2868 | 727.5 | ETWS primary notification message definition in GERAN |  | 47d? | 2009-03-12 A | 2009-05-15 A | 100% | 2009-03-12 | 2009-05-15 | 47d? | finish no earlier than 2009-05-15 | G2 | 376h | 376h | ETWS | Ericsson | claes-goran.persson@ericsson.com | Rel-8 | SP-43 | Gert | Public Safety (I-A) |  | 44.018, 44.060 | PCG-22 |  |
| 2869 | 728 | Conformance Test Aspects – UMTS Earthquake and Tsunami Warning System (ETWS) FDD |  | 207d? | 2009-05-29 A | 2010-03-12 A | 100% | 2009-05-29 | 2010-03-12 | 207d? | finish no earlier than 2010-03-12 | R5 | 1656h | 1656h | ETWS_UMTS_UEConTestFDD | NTT DoCoMo | Makoto Ito (itohm@nttdocomo.co.jp) | Rel-8 | RP-44 | Ingbert | Public Safety (I-A) | ETWS_UMTS_UEConTestFDD | 34.108, 34.123-1, 34.123-2 | PCG-23 | RP-100068 |
| 2870 | 729 | **In Case of Emergency numbers storage and easy access on UICC** |  | 519d? | 2007-03-13 A | 2009-03-06 A | 100% | 2007-03-13 | 2009-03-06 | 519d? |  | S1; C6 | 14552h | 14552h | ICE | Vodafone | armin.toepfer@vodafone.com | Rel-8 | SP-38 | Alain |  | ICE |  | PCG-21 |  |
| 2871 | 729.1 | Stage 1 for ICE |  | 262d? | 2007-03-13 A | 2008-03-12 A | 100% | 2007-03-13 | 2008-03-12 | 262d? | finish no earlier than 2008-03-12 | S1 | 2096h | 2096h | ICE | Vodafone | armin.toepfer@vodafone.com | Rel-8 | SP-38 | Alain |  |  | 22.030, 22.101 | PCG-21 |  |
| 2872 | 729.2 | CT6 aspects of ICE |  | 519d? | 2007-03-13 A | 2009-03-06 A | 100% | 2007-03-13 | 2009-03-06 | 519d? | finish no earlier than 2009-03-06 | C6 | 4152h | 4152h | ICE | Vodafone | armin.toepfer@vodafone.com | Rel-8 | SP-38 | Xavier |  |  | 31.102 | PCG-21 |  |
| 2873 | 730 | Local Charging Zone Requirements |  | 380d? | 2006-09-28 A | 2008-03-12 A | 100% | 2006-09-28 | 2008-03-12 | 380d? | finish no earlier than 2006-12-07 | S1 | 3040h | 3040h | LCZR | China Mobile | liuhongyfw@chinamobile.com | Rel-8 |  | Alain |  | LCZR | 22.115 |  |  |
| 2874 | 731 | **Customized Alerting Tone (CAT) service** |  | 729d? | 2006-12-06 A | 2009-09-18 A | 100% | 2006-12-06 | 2009-09-18 | 729d? |  | S1; C1; C3; C4 | 39854h | 39854h | CAT | China Mobile | fenglingjuan@chinamobile.com | Rel-8 |  | Alain |  | CAT |  |  |  |
| 2875 | 731.1 | Stage 1 for CAT |  | 207d? | 2006-12-06 A | 2007-09-20 A | 100% | 2006-12-06 | 2007-09-20 | 207d? | start no earlier than 2006-12-06 | S1 | 1656h | 1656h | CAT | China Mobile | fenglingjuan@chinamobile.com | Rel-8 | SP-37 | Alain |  |  | 22.182 |  |  |
| 2876 | 731.2 | TISPAN requirements for customized multimedia information services |  | 71d? | 2007-09-03 A | 2007-12-10 A | 100% | 2007-09-03 | 2007-12-10 | 71d? | finish no earlier than 2007-12-10 | S1 | 568h | 568h | TISCMI | China Mobile | fenglingjuan@chinamobile.com | Rel-8 | SP-37 | Alain |  | TISCMI | 22.182 |  |  |
| 2877 | 731.3 | **IMS CAT Supplementary Service** |  | 399d? | 2008-03-12 A | 2009-09-18 A | 100% | 2008-03-12 | 2009-09-18 | 399d? |  | C1; C3 | 10814.4h | 10814.4h | CAT-SS | Nortel | milanpa@nortel.com | Rel-8 | CP-39 | Frederic |  | CAT-SS |  | PCG-21 |  |
| 2878 | 731.3.1 | IMS CAT SS |  | 164d? | 2008-04-21 A | 2008-12-04 A | 100% | 2008-04-21 | 2008-12-04 | 164d? | finish no earlier than 2008-12-05 | C1 | 1312h | 1312h | CAT-SS | Nortel | milanpa@nortel.com | Rel-8 | CP-39 | Frederic |  |  | 24.182 | PCG-21 |  |
| 2879 | 731.3.2 | CAT solution for voice and video call in CS domain |  | 389.8d? | 2008-03-12 A | 2009-09-18 A | 100% | 2008-03-12 | 2009-09-18 | 389.8d? | finish no earlier than 2009-09-11 | C3 | 3118.4h | 3118.4h | CAT-SS | Nortel | milanpa@nortel.com | Rel-8 | CP-39 | Adrian |  |  | 29.163 | PCG-21 |  |
| 2880 | 731.4 | **CAT Service in 3GPP CS domain** |  | 126d? | 2008-09-12 A | 2009-03-06 A | 100% | 2008-09-12 | 2009-03-06 | 126d? |  | C4; C1 | 3487.6h | 3487.6h | CAT-3G_CS | China Mobile | zhaoyuyi@chinamobile.com | Rel-8 | CP-41 | Kimmo |  | CAT-3G_CS | 23.205, 23.231, 29.002 | PCG-21 |  |
| 2881 | 731.4.1 | CT4 part of CAT Service in 3GPP CS domain |  | 126d? | 2008-09-12 A | 2009-03-06 A | 100% | 2008-09-12 | 2009-03-06 | 126d? | finish no earlier than 2009-03-06 | C4 | 1008h | 1008h | CAT-3G_CS | China Mobile | zhaoyuyi@chinamobile.com | Rel-8 | CP-41 | Kimmo |  |  | 23.205, 23.231, 29.002 | PCG-21 |  |
| 2882 | 731.4.2 | CT1 part of CAT Service in 3GPP CS domain |  | 57.95d? | 2008-09-12 A | 2008-12-05 A | 100% | 2008-09-12 | 2008-12-05 | 57.95d? | start no earlier than 2008-09-12 | C1 | 463.6h | 463.6h | CAT-3G_CS | China Mobile | zhaoyuyi@chinamobile.com | Rel-8 | CP-41 | Frederic |  |  | 24.008, 23.014 | PCG-21 |  |
| 2883 | 732 | **Service-Level Interworking for Messaging Services** |  | 509d? | 2007-03-26 A | 2009-03-06 A | 100% | 2007-03-26 | 2009-03-06 | 509d? |  | S1; S2; C3; C1 | 20800h | 20800h | MESSIW | Huawei | ling.liu@huawei.com; duanxiaoqin@huawei.com | Rel-8 |  | Alain |  | MESSIW |  |  |  |
| 2884 | 732.1 | Stage 1 for MESSIW | milestone | 0d? | 2007-03-26 A | 2007-03-26 A | 100% | 2007-03-26 | 2007-03-26 | 0d? | finish no earlier than 2007-12-01 | S1 |  |  | MESSIW | Huawei | ling.liu@huawei.com | Rel-8 |  | Alain |  |  | 22.105, 22.340 |  |  |
| 2885 | 732.2 | Stage 2 for MESSIW |  | 227d? | 2007-04-26 A | 2008-03-07 A | 100% | 2007-04-26 | 2008-03-07 | 227d? | finish no earlier than 2008-03-07 | S2 | 1816h | 1816h | MESSIW | Huawei | patrice.hede@huawei.com | Rel-8 |  | Maurice |  |  | 23.811, 23.204 |  |  |
| 2886 | 732.3 | CT3 part of Stage 3 for MESSIW |  | 201d? | 2008-05-30 A | 2009-03-06 A | 100% | 2008-05-30 | 2009-03-06 | 201d? | finish no earlier than 2008-12-05 | C3 | 1608h | 1608h | MESSIW | Huawei | xupeili@huawei.com | Rel-8 | CP-40 | Adrian |  |  | 29.311 | PCG-21 |  |
| 2887 | 732.4 | CT1 part of Stage 3 for MESSIW |  | 136d? | 2008-05-30 A | 2008-12-05 A | 100% | 2008-05-30 | 2008-12-05 | 136d? | finish no earlier than 2008-12-12 | C1 | 1088h | 1088h | MESSIW | Huawei | xupeili@huawei.com | Rel-8 | CP-40 | Frederic |  |  | 24.229 | PCG-21 |  |

Notes:
- 2863: SP#43 Larger scope Feature UID_380057 (PWS) moved to Rel-9
- 2864: SP#39 completed
- 2865: SP#41 completed
- 2866: CP#42 completed
- 2867: CP#42 completed
- 2868: SP#44 completed with CT1 help (GERAN2 LS_in SP-090154)
- 2869: RP#47 completed. Testing for Rel-8 ETWS UID_370051
- 2870: CP#43 completed (ICE Graphics not included in Rel-8)
- 2871: SP#39 Stage 1 completed
- 2872: CP#43 completed (ICE Graphics not in Rel-8 / not explicitly in SA1 WID either)
- 2873: SP#39 Stage 1 completed
- 2874: CP#45 completed
- 2875: -
- 2876: SP#38 completed
- 2877: -
- 2878: CP#42 completed
- 2879: CP#45 completed. Triggered by Study UID_360031 (TR 29.882)
- 2880: -
- 2881: CP#43 completed. Triggered by Study UID_360031 (TR 29.882)
- 2882: CP#42 completed. Triggered by Study UID_360031 (TR 29.882)
- 2883: CP#43 completed
- 2884: SP#35 completed
- 2885: SP#39 completed
- 2886: CP#43 completed
- 2887: CP#42 completed

| ID | WBS | Task | Duration | Start | Finish | Complete | Baseline start | Baseline finish | Baseline duration | Constraint | Resources | Work | Actual work | Acronym | WI rapporteur name | WI rapporteur e-mail | Release | TSG approved | MCC resp | Special Focus Doc | Acronym_3GU_Export | Impacted TSs and TRs | PCG stopped | TSG stopped | PCG approved |
| --- | --- | --- | --- | --- | --- | --- | --- | --- | --- | --- | --- | --- | --- | --- | --- | --- | --- | --- | --- | --- | --- | --- | --- | --- | --- |
| 2888 | 733 | **Multimedia Priority Service** | 858d? | 2006-06-08 A | 2009-09-18 A | 100% | 2006-06-08 | 2009-09-18 | 858d? |  | S1; C1; C3; C4 | 43016h | 43016h | PRIOR_EMR | Telcordia | jgarraha@telcordia.com | Rel-8 | SP-34 | Alain | Public Safety (I-A) | PRIOR |  |  |  |  |
| 2889 | 733.1 | Service Requirements for PRIOR | 391d? | 2006-06-08 A | 2007-12-06 A | 100% | 2006-06-08 | 2007-12-06 | 391d? | finish no earlier than 2007-11-30 | S1 | 3128h | 3128h | PRIOR_EMR | Telcordia | jgarraha@telcordia.com | Rel-8 | SP-32 | Alain | Public Safety (I-A) | PRIOR-EMR | New 22.153 |  |  |  |
| 2890 | 733.2 | CT1 part of Stage 3 for PRIOR | 732d? | 2006-12-01 A | 2009-09-18 A | 100% | 2006-12-01 | 2009-09-18 | 732d? | finish no earlier than 2009-09-18 | C1 | 5856h | 5856h | PRIOR_EMR | Alcatel-Lucent | Keith Drage (drage@alcatel-lucent.com) | Rel-8 | CP-34 | Frederic | Public Safety (I-A) |  | 24.229 |  |  |  |
| 2891 | 733.3 | CT4 part of Stage 3 for PRIOR | 381d? | 2007-09-21 A | 2009-03-06 A | 100% | 2007-09-21 | 2009-03-06 | 381d? | finish no earlier than 2009-03-06 | C4 | 3048h | 3048h | PRIOR_EMR | Alcatel-Lucent | Keith Drage (drage@alcatel-lucent.com) | Rel-8 | CP-37 | Kimmo | Public Safety (I-A) |  | 23.008, 29.228, 29.229 |  |  |  |
| 2892 | 733.4 | Deleted - Stage 3 for PRIOR | 441d? | 2007-09-21 A | 2009-05-29 A | 100% | 2007-09-21 | 2009-05-29 | 441d? | finish no earlier than 2009-05-29 | C3 | 3528h | 3528h | PRIOR-EMR | Alcatel-Lucent | Keith Drage (drage@alcatel-lucent.com) | Rel-8 | CP-37 | Adrian | Public Safety (I-A) |  | 29.212, 29.213, 29.214, 29.163 | PCG-23 | CP-44 |  |
| 2893 | 734 | **Open Service Access (OSA) Rel-8** | 202d? | 2007-08-23 A | 2008-05-30 A | 100% | 2007-08-23 | 2008-05-30 | 202d? |  | S1; C5 | 25528h | 25528h | OSA8 | Orange | Song Dong | Rel-8 |  | Alain |  | OSA8 |  |  |  |  |
| 2894 | 734.1 | OSA Stage 1 - Service Requirements | 145d? | 2007-08-23 A | 2008-03-12 A | 100% | 2007-08-23 | 2008-03-12 | 145d? | finish no earlier than 2007-12-04 | S1 | 1160h | 1160h | OSA8 | Orange, AePONA | Song Dong | Rel-8 |  | Alain |  |  | 22.127 |  |  |  |
| 2895 | 734.2 | OSA Stage 1 - NGN Service Requirement | 140d? | 2007-09-03 A | 2008-03-14 A | 100% | 2007-09-03 | 2008-03-14 | 140d? | finish no earlier than 2008-03-14 | S1 | 1120h | 1120h | OSA8-IMSReq | Orange | Song Dong | Rel-8 | SP-37 | Alain |  | OSA8-IMS | 22.127 |  |  |  |
| 2896 | 734.3 | **Rel-8 OSA Stage 2/3 enhancements** | 157d? | 2007-10-25 A | 2008-05-30 A | 100% | 2007-10-25 | 2008-05-30 | 157d? |  | C5 | 20016h | 20016h | OSA8-IMS | Alcatel-Lucent | unmehopa@alcatel-lucent.com | Rel-8 |  | Kimmo |  |  | 23.198, 29.198, 29.199 |  |  |  |
| 2897 | 734.3.1 | Deleted - Ensure Parlay-X composable with identity management frameworks, in particular Liberty Alliance | 157d? | 2007-10-25 A | 2008-05-30 A | 100% | 2007-10-25 | 2008-05-30 | 157d? | finish no earlier than 2008-12-25 | C5 | 1256h | 1256h |  | Ericsson | catherine.mulligan@ericsson.com | Rel-8 | CP-37 | Kimmo |  |  | existing 29.199-xy | PCG-21 | CP-40 | PCG-21 |
| 2898 | 734.3.2 | Parlay-X Content Management web service (store/manage meta-data) | 157d? | 2007-10-25 A | 2008-05-30 A | 100% | 2007-10-25 | 2008-05-30 | 157d? | finish no earlier than 2008-12-04 | C5 | 1256h | 1256h | OSA8-IMS | Alcatel-Lucent | unmehopa@alcatel-lucent.com | Rel-8 | CP-37 | Kimmo |  |  | 29.199-21 |  |  |  |
| 2899 | 734.3.3 | Parlay-X Policy web service | 157d? | 2007-10-25 A | 2008-05-30 A | 100% | 2007-10-25 | 2008-05-30 | 157d? | finish no earlier than 2008-12-04 | C5 | 1256h | 1256h | OSA8-IMS | Alcatel-Lucent | unmehopa@alcatel-lucent.com | Rel-8 | CP-37 | Kimmo |  |  | 29.199-22 |  |  |  |
| 2900 | 734.3.4 | Parlay-X Terminal status web service | 157d? | 2007-10-25 A | 2008-05-30 A | 100% | 2007-10-25 | 2008-05-30 | 157d? | finish no earlier than 2008-05-30 | C5 | 1256h | 1256h | OSA8-IMS | Alcatel-Lucent | unmehopa@alcatel-lucent.com | Rel-8 | CP-37 | Kimmo |  |  | 29.199-08 |  |  |  |
| 2901 | 734.3.5 | Deleted - Identify communication format used by a particular application | 157d? | 2007-10-25 A | 2008-05-30 A | 100% | 2007-10-25 | 2008-05-30 | 157d? | finish no earlier than 2008-05-30 | C5 | 1256h | 1256h |  | Ericsson | catherine.mulligan@ericsson.com | Rel-8 | CP-37 | Kimmo |  |  | existing 29.199-xy | PCG-21 | CP-40 | PCG-21 |
| 2902 | 734.3.6 | Deleted - Security on User Profile Management - reuse GUP API (22.127 CR 0084 S1-071794) | 128d? | 2007-12-05 A | 2008-05-30 A | 100% | 2007-12-05 | 2008-05-30 | 128d? | finish no earlier than 2008-12-25 | C5 | 1024h | 1024h |  | Telecom Italia | vincenzo.amorino@telecomitalia.it | Rel-8 | CP-38 | Kimmo |  |  | PXWS Framework | PCG-21 | CP-40 | PCG-21 |
| 2903 | 734.3.7 | Deleted - Privacy on Subscriber Identity (Liberty Alliance, OASIS) (22.127 CR 0085 S1-071835) | 128d? | 2007-12-05 A | 2008-05-30 A | 100% | 2007-12-05 | 2008-05-30 | 128d? | finish no earlier than 2008-12-25 | C5 | 1024h | 1024h |  | Telecom Italia | vincenzo.amorino@telecomitalia.it | Rel-8 | CP-38 | Kimmo |  |  | PXWS Framework | PCG-21 | CP-40 | PCG-21 |
| 2904 | 734.3.8 | Deleted - Topology Hiding (22.127 CR 0086 S1-071838) | 128d? | 2007-12-05 A | 2008-05-30 A | 100% | 2007-12-05 | 2008-05-30 | 128d? | finish no earlier than 2008-12-25 | C5 | 1024h | 1024h |  | Telecom Italia | vincenzo.amorino@telecomitalia.it | Rel-8 | CP-38 | Kimmo |  |  | PXWS Framework | PCG-21 | CP-40 | PCG-21 |
| 2905 | 734.3.9 | Deleted - Subscriber event notification (22.127 CR 0087 S1-071836) | 128d? | 2007-12-05 A | 2008-05-30 A | 100% | 2007-12-05 | 2008-05-30 | 128d? | finish no earlier than 2008-12-25 | C5 | 1024h | 1024h |  | Telecom Italia | vincenzo.amorino@telecomitalia.it | Rel-8 | CP-38 | Kimmo |  |  | PXWS Framework | PCG-21 | CP-40 | PCG-21 |
| 2906 | 734.3.10 | Deleted - Event notification (22.127 CR 0088 S1-071762) | 128d? | 2007-12-05 A | 2008-05-30 A | 100% | 2007-12-05 | 2008-05-30 | 128d? | finish no earlier than 2008-12-25 | C5 | 1024h | 1024h |  | Telecom Italia | vincenzo.amorino@telecomitalia.it | Rel-8 | CP-38 | Kimmo |  |  | PXWS Framework | PCG-21 | CP-40 | PCG-21 |
| 2907 | 734.3.11 | Deleted - Access policy (22.127 CR 0089 S1-071763) | 128d? | 2007-12-05 A | 2008-05-30 A | 100% | 2007-12-05 | 2008-05-30 | 128d? | finish no earlier than 2008-12-25 | C5 | 1024h | 1024h |  | Telecom Italia | vincenzo.amorino@telecomitalia.it | Rel-8 | CP-38 | Kimmo |  |  | PXWS Framework | PCG-21 | CP-40 | PCG-21 |
| 2908 | 734.3.12 | Deleted - API usage accounting (22.127 CR 0090 S1-071792) | 128d? | 2007-12-05 A | 2008-05-30 A | 100% | 2007-12-05 | 2008-05-30 | 128d? | finish no earlier than 2008-12-25 | C5 | 1024h | 1024h |  | Telecom Italia | vincenzo.amorino@telecomitalia.it | Rel-8 | CP-38 | Kimmo |  |  | PXWS Framework | PCG-21 | CP-40 | PCG-21 |
| 2909 | 734.3.13 | Presence alignment with OMA and IETF (22.127 CR 0092 S1-071764) | 128d? | 2007-12-05 A | 2008-05-30 A | 100% | 2007-12-05 | 2008-05-30 | 128d? | finish no earlier than 2008-05-30 | C5 | 1024h | 1024h | OSA8-IMS | Alcatel-Lucent | unmehopa@alcatel-lucent.com | Rel-8 | CP-38 | Kimmo |  |  | 29.199-14/13 |  |  | PCG-21 |
| 2910 | 734.3.14 | Deleted - Service identification (22.127 CR 0095 S1-071837) | 128d? | 2007-12-05 A | 2008-05-30 A | 100% | 2007-12-05 | 2008-05-30 | 128d? | finish no earlier than 2008-05-30 | C5 | 1024h | 1024h |  | Ericsson | catherine.mulligan@ericsson.com | Rel-8 | CP-38 | Kimmo |  |  | existing 29.199-xy | PCG-21 | CP-40 | PCG-21 |
| 2911 | 734.3.15 | Framework Enterprise Operator (Service Subscription function) | 102d? | 2008-01-10 A | 2008-05-30 A | 100% | 2008-01-10 | 2008-05-30 | 102d? | finish no earlier than 2008-05-30 | C5 | 816h | 816h | OSA8-IMS | Alcatel-Lucent | unmehopa@alcatel-lucent.com | Rel-8 | CP-39 | Kimmo |  |  | 29.198-03 |  |  | PCG-21 |
| 2912 | 734.3.16 | Mobility Emergency Location | 102d? | 2008-01-10 A | 2008-05-30 A | 100% | 2008-01-10 | 2008-05-30 | 102d? | finish no earlier than 2008-05-30 | C5 | 816h | 816h | OSA8-IMS | Alcatel-Lucent | unmehopa@alcatel-lucent.com | Rel-8 | CP-39 | Kimmo |  |  | 29.198-06 |  |  | PCG-21 |
| 2913 | 734.3.17 | Connectivity Manager SCF | 102d? | 2008-01-10 A | 2008-05-30 A | 100% | 2008-01-10 | 2008-05-30 | 102d? |  | C5 | 816h | 816h | OSA8-IMS | Alcatel-Lucent | unmehopa@alcatel-lucent.com | Rel-8 | CP-39 | Kimmo |  |  | 29.198-10 |  |  | PCG-21 |
| 2914 | 734.3.18 | PAM Presence Agent | 102d? | 2008-01-10 A | 2008-05-30 A | 100% | 2008-01-10 | 2008-05-30 | 102d? | finish no earlier than 2008-05-30 | C5 | 816h | 816h | OSA8-IMS | Alcatel-Lucent | unmehopa@alcatel-lucent.com | Rel-8 | CP-39 | Kimmo |  |  | 29.198-14 |  |  | PCG-21 |

Notes:
- 2888: CP#45 completed
- 2889: SP#38 completed
- 2890: CP#45 completed
- 2891: CP#43 completed
- 2892: CP#44 stopped (Reason: No Rel-8 solution expected (LS sent to SA2, but not prioritized in SA2)
- 2893: SP#40 maintenance & new OSA work moved to OMA. Rel-9 onwards 3GPP references to 22.127 changed to OMA Parlay Service Access Requirements (OMA-RD-Parlay_Service_Access-V1_0-20100427-A).
- 2894: SP#40 maintenance & new OSA work moved to OMA. Rel-9 onwards 3GPP references to 22.127 changed to OMA Parlay Service Access Requirements (OMA-RD-Parlay_Service_Access-V1_0-20100427-A).
- 2895: SP#40 maintenance & new OSA work moved to OMA
- 2896: SP#40 maintenance & new OSA work moved to OMA
- 2897: CP#40: Work moved to OMA
- 2898: CP#40 completed
- 2899: CP#40 completed
- 2900: CP#40 completed
- 2901: CP#40: Work moved to OMA
- 2902: SP#38 SP-070853 R8 CRs 22.127 OSA Stage 1. CP#40: Work moved to OMA
- 2903: SP#38 SP-070853 R8 CRs 22.127 OSA Stage 1. CP#40: Work moved to OMA
- 2904: SP#38 SP-070853 R8 CRs 22.127 OSA Stage 1. CP#40: Work moved to OMA
- 2905: SP#38 SP-070853 R8 CRs 22.127 OSA Stage 1. CP#40: Work moved to OMA
- 2906: SP#38 SP-070853 R8 CRs 22.127 OSA Stage 1. CP#40: Work moved to OMA
- 2907: SP#38 SP-070853 R8 CRs 22.127 OSA Stage 1. CP#40: Work moved to OMA
- 2908: SP#38 SP-070853 R8 CRs 22.127 OSA Stage 1. CP#40: Work moved to OMA
- 2909: CP#40 completed
- 2910: SP#38 SP-070853 R8 CRs 22.127 OSA Stage 1. CP#40: Work moved to OMA
- 2911: CP#40 completed
- 2912: CP#40 completed
- 2913: CP#40 completed
- 2914: CP#40 completed

| ID | WBS | Task | Duration | Start | Finish | Complete | Remaining | Baseline start | Baseline finish | Baseline duration | Total slack | Constraint | Resources | Work | Actual work | Acronym | WI rapporteur name | Release | MCC resp | Acronym_3GU_Export | TSG approved | PCG approved | Status Report | Special Focus Doc |
| --- | --- | --- | --- | --- | --- | --- | --- | --- | --- | --- | --- | --- | --- | --- | --- | --- | --- | --- | --- | --- | --- | --- | --- | --- |
| 2915 | 735 | **Paging Permission with Access Control (PPACR)** | 389d? | 2007-06-12 A | 2008-12-05 A | 100% |  | 2007-06-12 | 2008-12-05 | 389d? |  |  | S1; C1 | 9000h | 9000h | PPACR | NTT DoCoMo | Rel-8 | Alain | PPACR |  |  |  |  |
| 2916 | 735.1 | Stage 1 for PPACR | 69d? | 2007-06-12 A | 2007-09-14 A | 100% |  | 2007-06-12 | 2007-09-14 | 69d? |  | finish no earlier than 2007-09-14 | S1 | 552h | 552h | PPACR-S1 | NTT DoCoMo | Rel-8 | Alain | PPACR-S1 | SP-37 |  |  |  |
| 2917 | 735.2 | Stage 3 for PPACR (CT1) | 278d? | 2007-11-14 A | 2008-12-05 A | 100% |  | 2007-11-14 | 2008-12-05 | 278d? |  | finish no earlier than 2008-12-05 | C1 | 2224h | 2224h | PPACR-CT1 | NTT DoCoMo | Rel-8 | Frederic | PPACR-CT1 | CP-38 | PCG-21 |  |  |
| 2918 | 736 | Conformance Test Aspects – Paging Permission with Access Control (PPAC) | 61d? | 2010-09-17 A | 2010-12-10 A | 100% |  | 2010-09-17 | 2010-12-10 | 61d? |  | finish no earlier than 2010-12-10 | R5 | 488h | 488h | PPAC_UEConTest | NTT DoCoMo | Rel-8 | Ingbert | PPAC_UEConTest | RP-49 | PCG-25 | RP-101074 |  |
| 2919 | 737 | **Charging for multi-phases services** | 70d? | 2007-12-06 A | 2008-03-12 | 99% | 0d? | 2007-12-06 | 2008-03-12 | 70d? | 0d |  | S1 | 560h | 560h | CHRGMPH | Telecom Italia | Rel-8 | Alain | CHRGMPH | SP-38 | PCG-21 |  |  |
| 2920 | 737.1 | Stage 1 for CHRGMPH | 70d? | 2007-12-06 A | 2008-03-12 A | 100% |  | 2007-12-06 | 2008-03-12 | 70d? |  | start no earlier than 2007-12-06 | S1 | 560h | 560h | CHRGMPH-s1 | Telecom Italia | Rel-8 | Alain | CHRGMPH-s1 | SP-38 | PCG-21 |  |  |
| 2921 | 738 | **Home NodeB / eNodeB** | 327d? | 2007-12-06 A | 2009-03-06 A | 100% |  | 2007-12-06 | 2009-03-06 | 327d? |  |  | S1; C1; C4 | 10952h | 10952h | HomeNB | Vodafone | Rel-8 | Alain | HomeNB | SP-38 | PCG-21 |  | HNB |
| 2922 | 738.1 | Stage 1 for Home NodeB / eNodeB | 70d? | 2007-12-06 A | 2008-03-12 A | 100% |  | 2007-12-06 | 2008-03-12 | 70d? |  | start no earlier than 2007-12-06 | S1 | 560h | 560h | HomeNB-S1 | Vodafone | Rel-8 | Alain | HomeNB-S1 | SP-38 | PCG-21 |  | HNB |
| 2923 | 738.2 | Support of Closed Subscriber Group (CSG) | 66d? | 2008-12-05 A | 2009-03-06 A | 100% |  | 2008-12-05 | 2009-03-06 | 66d? |  | finish no earlier than 2009-03-06 | C4 | 528h | 528h |  | CT#42 | Rel-8 | Kimmo |  | CP-42 | PCG-22 |  | HNB |
| 2924 | 738.3 | CSG and Idle Mode Mobility for LTE Home eNodeB | 126d? | 2008-09-12 A | 2009-03-06 A | 100% |  | 2008-09-12 | 2009-03-06 | 126d? |  | finish no earlier than 2009-03-06 | C1 | 1008h | 1008h | HomeNB-LTE | Huawei | Rel-8 | Frederic | HomeNB-LTE | CP-41 | PCG-21 |  | HNB |
| 2925 | 738.4 | CSG and Idle Mode Mobility for 3G Home NodeB | 126d? | 2008-09-12 A | 2009-03-06 A | 100% |  | 2008-09-12 | 2009-03-06 | 126d? |  | finish no earlier than 2009-03-06 | C1 | 1008h | 1008h | HomeNB-3G | Qualcomm | Rel-8 | Frederic | HomeNB-3G | CP-41 | PCG-21 |  | HNB |
| 2926 | 739 | **UTRA HNB** | 326d? | 2008-03-07 A | 2009-06-04 A | 100% |  | 2008-03-07 | 2009-06-04 | 326d? |  |  | RP; S5 | 11008h | 11008h | HNB |  | Rel-8 | Issam | HNB | SP-39 | PCG-21 |  | HNB |
| 2927 | 739.1 | Support of UTRA HNB | 201d? | 2008-05-30 A | 2009-03-06 A | 100% |  | 2008-05-30 | 2009-03-06 | 201d? |  | finish no earlier than 2009-03-06 | R2 | 1608h | 1608h | HNB-supp | Huawei | Rel-8 | Yong-Jun | HNB-supp | SP-40 | PCG-21 | RP-090040 | HNB |
| 2928 | 739.2 | UTRAN Architecture for 3G HNB | 136d? | 2008-05-30 A | 2008-12-05 A | 100% |  | 2008-05-30 | 2008-12-05 | 136d? |  | finish no earlier than 2008-12-05 | R3 | 1088h | 1088h | HNB-arch | Alcatel-Lucent | Rel-8 | Juha | HNB-arch | SP-40 | PCG-21 | RP-090042 | HNB |
| 2929 | 739.3 | FDD Home NodeB RF requirements | 261d? | 2008-03-07 A | 2009-03-06 A | 100% |  | 2008-03-07 | 2009-03-06 | 261d? |  | finish no earlier than 2009-03-06 | R4 | 2088h | 2088h | HNB-RF | Motorola | Rel-8 | Issam | HNB-RF | SP-39 | PCG-21 | RP-090041 | HNB |
| 2930 | 739.4 | 3G Home NodeB OAM&P Type 1 Management Interface | 127d? | 2008-12-11 A | 2009-06-04 A | 100% |  | 2008-12-11 | 2009-06-04 | 127d? |  | finish no earlier than 2009-06-04 | S5 | 1008h | 1008h | HNB-3G_OAM | Huawei | Rel-8 | Mirko | HNB-3G_OAM | SP-42 | PCG-22 |  | HNB |
| 2931 | 740 | **UTRA HNB – UE Conformance Testing** | 327d? | 2009-03-06 A | 2010-06-04 A | 100% |  | 2009-03-06 | 2010-06-04 | 327d? |  |  | R5 | 5224h | 5224h | HNB-UEConTest |  | Rel-8 | Ingbert | HNB-UEConTest | RP-43 | PCG-22 |  | HNB |
| 2932 | 740.1 | Conformance Test Aspects – UTRA HNB (FDD) | 326d? | 2009-03-06 A | 2010-06-04 A | 100% |  | 2009-03-06 | 2010-06-04 | 326d? |  | finish no earlier than 2010-06-04 | R5 | 2608h | 2608h | HNB-UEConTestFDD | Huawei | Rel-8 | Ingbert | HNB-UEConTestFDD | RP-43 | PCG-22 | RP-100482 | HNB |
| 2933 | 741 | Lawful Interception in the 3GPP Rel-8 | 524d? | 2007-03-12 A | 2009-03-12 A | 100% |  | 2007-03-12 | 2009-03-12 | 524d? |  | finish no earlier than 2009-03-12 | S3 | 4192h | 4192h | LI8 | BMWI, Verizon | Rel-8 | Mirko | LI8 |  |  |  |  |
| 2934 | 742 | **Generic Bootstrapping Architecture Push Function** | 258d? | 2008-03-12 A | 2009-03-06 A | 100% |  | 2008-03-12 | 2009-03-06 | 258d? |  |  | S3; C1; C4 | 10596.8h | 10596.8h | GBAPush | Ericsson | Rel-8 | Mirko | GBAPush | SP-39 | PCG-21 |  |  |
| 2935 | 742.1 | SA3 part of GBAPush (33.223) | 193d? | 2008-03-12 A | 2008-12-05 A | 100% |  | 2008-03-12 | 2008-12-05 | 193d? |  | finish no earlier than 2008-12-05 | S3 | 1544h | 1544h | GBAPush | Ericsson | Rel-8 | Mirko |  | SP-39 | PCG-21 |  |  |
| 2936 | 742.2 | CT1 part of GBAPush | 178.8d? | 2008-03-12 A | 2009-03-06 A | 100% |  | 2008-03-12 | 2009-03-06 | 178.8d? |  | finish no earlier than 2009-03-06 | C1 | 1430.4h | 1430.4h | GBAPush | Ericsson | Rel-8 | Frederic |  | SP-39 | PCG-21 |  |  |
| 2937 | 742.3 | CT4 part of GBAPush | 178.8d? | 2008-03-12 A | 2009-03-06 A | 100% |  | 2008-03-12 | 2009-03-06 | 178.8d? |  | finish no earlier than 2009-03-06 | C4 | 1430.4h | 1430.4h | GBAPush | Ericsson | Rel-8 | Kimmo |  | SP-39 | PCG-21 |  |  |
| 2938 | 743 | Requirements and Test methods for Wideband Terminals | 197d? | 2008-03-12 A | 2008-12-11 A | 100% |  | 2008-03-12 | 2008-12-11 | 197d? |  | start no earlier than 2008-03-12 | S4 | 1576h | 1576h | RETEM_WB_T | FT, Ericsson | Rel-8 | Paolo | RETEM_WB_T |  |  |  |  |
| 2939 | 744 | Extending PSS and MBMS User Services for optimized Mobile TV | 266d? | 2007-12-06 A | 2008-12-11 A | 100% |  | 2007-12-06 | 2008-12-11 | 266d? |  | finish no earlier than 2008-12-11 | S4 | 2128h | 2128h | PSS_MBMS_OMTV | Ericsson | Rel-8 | Paolo | PSS_MBMS_OMTV |  |  |  |  |

Notes:
- 2915: CP#42 completed. Triggered by Study UID_330016 (PPAC). / WI rapporteur e-mail: Morita Takashi
- 2916: SP#37 completed / Impacted TSs and TRs: 22.011 / WI rapporteur e-mail: Morita Takashi
- 2917: CP#42 completed / Impacted TSs and TRs: 24.008, 23.122, 24.301
- 2918: RP#50 completed / Impacted TSs and TRs: UTRA 34.108, 34.123-1, 34.123-2, 34.123-3 / WI rapporteur e-mail: Takao.Shimizu.rp@nttdocomo.com
- 2919: SP#39 Stage 1 completed / Impacted TSs and TRs: 22.115 / WI rapporteur e-mail: Marco.DeLuca1@telecomitalia.it
- 2920: SP#39 completed / Impacted TSs and TRs: 22.115 / WI rapporteur e-mail: Marco.DeLuca1@telecomitalia.it
- 2921: CP#43 completed / WI rapporteur e-mail: John Watson
- 2922: SP#39 completed / Impacted TSs and TRs: 22.011, 22.115 / WI rapporteur e-mail: John Watson
- 2923: CP#43 completed. SP#42 SP-080874 22.011CR0141 confirmed Requirement to support roaming subscribers with CSG home network subscription but did NOT confirmed requirement for home network independent support of roamers in CSG / Impacted TSs and TRs: 29.002, 29.272, 23.008, 23.003 / WI rapporteur e-mail: Hannu Hietalahti
- 2924: CP#43 completed / Impacted TSs and TRs: 23.122, new (24.285, 24.301, 24.801) / WI rapporteur e-mail: zhang.peng@huawei.com
- 2925: CP#43 completed / Impacted TSs and TRs: 23.122, 24.008, new 24.285 / WI rapporteur e-mail: Osok Song
- 2926: SP#44 completed
- 2927: RP#43 completed / Impacted TSs and TRs: 25.304, 25.306, 25.331, new 25.367 / WI rapporteur e-mail: Yang Xudong (yangxudong@huawei.com)
- 2928: RP#42 completed / Impacted TSs and TRs: 25.401, 25.410, 25.412, 25.413, 25.414, 25.415, new (25.467, 25.468, 25.469) / WI rapporteur e-mail: Martin Warner (mw15@alcatel-lucent.com)
- 2929: RP#43 completed / Impacted TSs and TRs: 25.104, 25.141, new 25.967 / WI rapporteur e-mail: Ying Cai (yingcai@motorola.com)
- 2930: SP#44 completed. Complements work in BroadBand Forum / Impacted TSs and TRs: new (32.581, 32.582, 32.583, 32.584) / WI rapporteur e-mail: Zou Lan (zlan@huawei.com)
- 2931: RP#48 FDD completed. Testing for Feature UID_390033 UTRA HNB
- 2932: RP#48 completed / Impacted TSs and TRs: 34.108, 34.123-1, 34.123-2, 34.123-3 / WI rapporteur e-mail: Trica Li (trica_li@huawei.com)
- 2933: SP#43 completed / Impacted TSs and TRs: 33.106, 33.107, 33.108 / WI rapporteur e-mail: berthold.wilhelm@bnetza.de, ron_ryan@verizon.net
- 2934: CP#43 completed / WI rapporteur e-mail: Rolf Blom
- 2935: SP#42 completed 33.223 as Rel-8. TS 33.224 moved to Rel-9 under new UID_420039 / Impacted TSs and TRs: 33.223 / WI rapporteur e-mail: Rolf Blom
- 2936: CP#43 completed / Impacted TSs and TRs: 24.109 / WI rapporteur e-mail: Rolf Blom
- 2937: CP#43 completed / Impacted TSs and TRs: 29.109 / WI rapporteur e-mail: Rolf Blom
- 2938: SP#42 completed. SP#39 WID approved. / Impacted TSs and TRs: 26.131, 26.132 / WI rapporteur e-mail: stephane.ragot@orange-ftgroup.com, wanqing.shi@sonyericsson.com
- 2939: SP#42 completed. SP#38 WID approved. / Impacted TSs and TRs: 26.234, 26.346, 26.946 / WI rapporteur e-mail: thorsten.lohmar@ericsson.com

| ID | WBS | Task | Duration | Start | Finish | Complete | Baseline start | Baseline finish | Baseline duration | Constraint | Resources | Work | Actual work | Acronym | PCG approved | WI rapporteur name | Release | TSG approved | MCC resp | Acronym_3GU_Export | TSG stopped | PCG stopped |
| --- | --- | --- | --- | --- | --- | --- | --- | --- | --- | --- | --- | --- | --- | --- | --- | --- | --- | --- | --- | --- | --- | --- |
| 2940 | 745 | **Encoding formats, transport formats and media description signalling for interworking, QoE, and other enhancements to MTSI-MHI** | 331d? | 2007-12-06 A | 2009-03-12 A | 100% | 2007-12-06 | 2009-03-12 | 331d? |  | S4; C3; C4 | 14936h | 14936h | MTSI_eMHI | PCG-21 | Ericsson, Qualcomm | Rel-8 | SP-40 | Paolo | MTSI_eMHI |  |  |
| 2941 | 745.1 | MTSI Video - Dynamic Rate Adaptation/Signalling of Image Size | 331d? | 2007-12-06 A | 2009-03-12 A | 100% | 2007-12-06 | 2009-03-12 | 331d? | finish no earlier than 2009-03-12 | S4 | 2648h | 2648h | MTSI_eMHI-DRASIS |  | Qualcomm, Samsung | Rel-8 |  | Paolo | MTSI_eMHI-DRASIS |  |  |
| 2942 | 745.2 | CT3 part of Enhancement of interworking between MTSI and CS networks | 201d? | 2008-05-30 A | 2009-03-06 A | 100% | 2008-05-30 | 2009-03-06 | 201d? | finish no earlier than 2009-03-06 | C3 | 1608h | 1608h | MTSI_eMHI | PCG-21 | Huawei | Rel-8 | CP-40 | Adrian |  |  |  |
| 2943 | 745.3 | CT4 part of Enhancement of interworking between MTSI and CS networks | 201d? | 2008-05-30 A | 2009-03-06 A | 100% | 2008-05-30 | 2009-03-06 | 201d? | finish no earlier than 2009-03-06 | C4 | 1608h | 1608h | MTSI_eMHI | PCG-21 | Huawei | Rel-8 | CP-40 | Kimmo |  |  |  |
| 2944 | 745.4 | Deleted - CT1 part of Enhancement of interworking between MTSI and CS networks | 141d? | 2008-05-30 A | 2008-12-12 A | 100% | 2008-05-30 | 2008-12-12 | 141d? | start no earlier than 2008-05-30 | C1 | 1128h | 1128h | MTSI_eMHI | PCG-21 | Huawei | Rel-8 | CP-40 | Frederic |  | CP-42 |  |
| 2945 | 746 | **Rel-8 Operations, Administration, Maintenance and Provisioning (OAM&P)** | 1445d? | 2007-06-07 A | 2012-12-07 A | 100% | 2007-06-07 | 2012-12-07 | 1445d? |  | S5; C1; C4; IETF | 120270h | 120270h | OAM8 |  |  | Rel-8 |  | Mirko | OAM8 |  |  |
| 2946 | 746.1 | **Rel-8 Network Infrastructure Management** | 653d? | 2007-06-07 A | 2009-12-04 A | 100% | 2007-06-07 | 2009-12-04 | 653d? |  | S5 | 19464h | 19464h | OAM8-NIM |  |  | Rel-8 |  | Mirko | OAM8-NIM |  |  |
| 2947 | 746.1.1 | Telecom Management Methodology | 461d? | 2007-06-07 A | 2009-03-12 A | 100% | 2007-06-07 | 2009-03-12 | 461d? | finish no earlier than 2009-03-12 | S5 | 3688h | 3688h | OAM8-NIM |  | Ericsson | Rel-8 |  | Mirko |  |  |  |
| 2948 | 746.1.2 | Advanced Alarming on Itf-N | 266d? | 2007-06-07 A | 2008-06-12 A | 100% | 2007-06-07 | 2008-06-12 | 266d? | finish no earlier than 2008-12-11 | S5 | 2128h | 2128h | OAM8-NIM |  | Nokia Siemens Networks | Rel-8 |  | Mirko |  |  |  |
| 2949 | 746.1.3 | CN CS Bearer Transport Network (BTN) relative NRM | 266d? | 2007-06-07 A | 2008-06-12 A | 100% | 2007-06-07 | 2008-06-12 | 266d? | finish no earlier than 2008-12-11 | S5 | 2128h | 2128h | OAM8-NIM |  | China Mobile | Rel-8 |  | Mirko |  |  |  |
| 2950 | 746.1.4 | Alignment with eTOM and M.3060 architectural concepts | 210d? | 2008-02-22 A | 2008-12-11 A | 100% | 2008-02-22 | 2008-12-11 | 210d? | start no earlier than 2008-02-22 | S5 | 1680h | 1680h | OAM8-NIM | PCG-21 | TeliaSonera | Rel-8 | SP-39 | Mirko |  |  |  |
| 2951 | 746.1.5 | IRP SOAP Solution Sets | 201d? | 2008-06-05 A | 2009-03-12 A | 100% | 2008-06-05 | 2009-03-12 | 201d? | finish no earlier than 2009-03-12 | S5 | 1608h | 1608h | OAM8-NIM | PCG-21 | Ericsson | Rel-8 | SP-40 | Mirko |  |  |  |
| 2952 | 746.1.6 | Create missing specifications for IRP XML definitions | 52d? | 2009-09-24 A | 2009-12-04 A | 100% | 2009-09-24 | 2009-12-04 | 52d? | finish no earlier than 2010-03-12 | S5 | 416h | 416h | OAM8-NIM | PCG-23 | ZTE | Rel-8 | SP-45 | Mirko |  |  |  |
| 2953 | 746.1.7 | Deleted - End point modelling for reference point | 324d? | 2007-09-17 A | 2008-12-11 A | 100% | 2007-09-17 | 2008-12-11 | 324d? | finish no earlier than 2008-12-11 | S5 | 2592h | 2592h | OAM8-NIM |  | Motorola | Rel-8 | SP-37 | Mirko |  | SP-41 | PCG-21 |
| 2954 | 746.2 | **Rel-8 Performance Management** | 461d? | 2007-06-07 A | 2009-03-12 A | 100% | 2007-06-07 | 2009-03-12 | 461d? |  | S5 | 13712h | 13712h | OAM8-PM |  |  | Rel-8 |  | Mirko | OAM8-PM |  |  |
| 2955 | 746.2.1 | IP bearer network Performance measurement definitions | 396d? | 2007-06-07 A | 2008-12-11 A | 100% | 2007-06-07 | 2008-12-11 | 396d? | finish no earlier than 2008-12-11 | S5 | 3168h | 3168h | OAM8-PM |  | China Mobile | Rel-8 |  | Mirko |  |  |  |
| 2956 | 746.2.2 | HSUPA performance measurements | 396d? | 2007-06-07 A | 2008-12-11 A | 100% | 2007-06-07 | 2008-12-11 | 396d? | finish no earlier than 2008-12-11 | S5 | 3168h | 3168h | OAM8-PM |  | China Mobile | Rel-8 |  | Mirko |  |  |  |
| 2957 | 746.2.3 | Key Performance Indicators (KPIs) for UMTS and GSM | 461d? | 2007-06-07 A | 2009-03-12 A | 100% | 2007-06-07 | 2009-03-12 | 461d? | finish no earlier than 2009-03-12 | S5 | 3688h | 3688h | OAM8-PM |  | China Mobile | Rel-8 |  | Mirko |  |  |  |
| 2958 | 746.3 | **Rel-8 Trace Management** | 1249d? | 2008-03-07 A | 2012-12-07 A | 100% | 2008-03-07 | 2012-12-07 | 1249d? |  | C1; C4; IETF | 40854.4h | 40854.4h | OAM8-Trace |  |  | Rel-8 |  | Mirko | OAM8-Trace |  |  |
| 2959 | 746.3.1 | CT1 part of Service Level Tracing in IMS | 196d? | 2008-03-07 A | 2008-12-05 A | 100% | 2008-03-07 | 2008-12-05 | 196d? | finish no earlier than 2008-12-05 | C1 | 1568h | 1568h | OAM8-Trace |  | Vodafone | Rel-8 |  | Frederic |  |  |  |
| 2960 | 746.3.2 | (IETF) Service Level Tracing in IMS (draft-dawes-sipping-debug) | 717d? | 2008-03-07 A | 2012-12-07 A | 100% | 2008-03-07 | 2012-12-07 | 717d? | finish no earlier than 2012-12-07 | C1-IETF | 5736h | 5736h | OAM8-Trace | PCG-27 | Peter Dawes | Rel-8 | CP-52 | Frederic |  |  |  |
| 2961 | 746.3.3 | (IETF) Service Level Tracing in IMS (draft-dawes-sipping-debug-event) | 98d? | 2008-03-07 A | 2011-12-09 A | 100% | 2008-03-07 | 2011-12-09 | 98d? | finish no earlier than 2011-12-09 | C1-IETF | 768.04h | 768.04h | OAM8-Trace | PCG-27 | Peter Dawes | Rel-8 | CP-53 | Frederic |  |  |  |
| 2962 | 746.3.4 | CT4 part of Service Level Tracing in IMS | 175.4d? | 2008-03-07 A | 2008-12-05 A | 100% | 2008-03-07 | 2008-12-05 | 175.4d? | finish no earlier than 2008-12-05 | C4 | 1403.2h | 1403.2h | OAM8-Trace | PCG-21 | Vodafone | Rel-8 | CP-40 | Frederic |  |  |  |
| 2963 | 746.3.5 | Deleted - CT3 part of Service Level Tracing in IMS | 175.4d? | 2008-03-07 A | 2008-12-05 A | 100% | 2008-03-07 | 2008-12-05 | 175.4d? | finish no earlier than 2008-12-05 | C3 | 1403.2h | 1403.2h | OAM8-Trace | PCG-21 | Vodafone | Rel-8 | CP-40 | Adrian |  | CP-42 | PCG-22 |

Notes:
- 2940: TSG#43 completed / WI rapporteur e-mail: olle.franceschi@ericsson.com, nleung@qualcomm.com
- 2941: SP#43 completed / Impacted TSs and TRs: 26.114 / WI rapporteur e-mail: nleung@qualcomm.com & kyunghun.jung@samsung.com
- 2942: CP#43 completed / Impacted TSs and TRs: 29.163 / WI rapporteur e-mail: Tingfang Tang (tagna_online@huawei.com)
- 2943: CP#43 completed / Impacted TSs and TRs: 29.332 / WI rapporteur e-mail: Tingfang Tang (tagna_online@huawei.com)
- 2944: CP#42 stopped (No CT1-impact). WID updated CP-080422=>CP-080774 / WI rapporteur e-mail: Tingfang Tang (tagna_online@huawei.com)
- 2945: OAM8 is an umbrella Feature also for OAM&P related TEI8 type of changes that are not part of any other dedicated feature/WI / Impacted TSs and TRs: TR 30.818
- 2946: -
- 2947: SP#43 completed / Impacted TSs and TRs: 32.155, 32.153 / WI rapporteur e-mail: thomas.tovinger@ericsson.com
- 2948: SP#40 completed / Impacted TSs and TRs: 32.121, 32.122, 32.123 / WI rapporteur e-mail: SUERBAUM, Clemens
- 2949: SP#40 completed / Impacted TSs and TRs: 32.632, 32.633, 32.635 / WI rapporteur e-mail: Li Jian (lijian@chinamobile.com)
- 2950: SP#42 completed / Impacted TSs and TRs: 32.101/2, 32-series / WI rapporteur e-mail: tommy.berggren@teliasonera.com
- 2951: SP#43 completed / Impacted TSs and TRs: 32.111-7, 32.617, 32.417, 32.367, 32.347, 32.111-1, 32.111-2, 32.111-3, 32.111-5, 32.307, 32.317, 32.341, 32.342, 32.343, 32.345, 32.361, 32.362, 32.363, 32.365, 32.411, 32.412, 32.413, 32.415, 32.611, 32.612, 32.613, 32.615, 32.625 / WI rapporteur e-mail: edwin.tse@ericsson.com
- 2952: SP#46 completed. Create missing XML definitions specs for IRPs (Advanced Alarm Management, Communication Surveillance, Self-Configuration of Network Elements, Software Management) needed for implementation of Rel-8 Notification Log IRP (TS 32.33x) / Impacted TSs and TRs: new (32.125, 32.355, 32.505, 32.535), 32.150, 32.153, 32.335 / WI rapporteur e-mail: Shuqiang Huang (huangsq@zte.com.cn)
- 2953: SP#41 Work stopped. Contributions related to E-UTRAN/EPC to be submitted to UID_380036 E-UTRAN NRM IRP/ UID_380037 EPC NRM IRP / Impacted TSs and TRs: 32.152, 32.62/3/4x, 32.73x / WI rapporteur e-mail: Yizhi Yao (yzyao@motorola.com)
- 2954: - / WI rapporteur e-mail: Li Jian (lijian@chinamobile.com)
- 2955: SP#42 completed / Impacted TSs and TRs: 32.321, 32.322, 32.323, 32.325 / WI rapporteur e-mail: lilianyuan@chinamobile.com
- 2956: SP#42 completed / Impacted TSs and TRs: 32.405 / WI rapporteur e-mail: Li Jian (lijian@chinamobile.com)
- 2957: SP#43 completed / Impacted TSs and TRs: 32.410 / WI rapporteur e-mail: Li Jian (lijian@chinamobile.com), Liang Shuangchun (liangshuangchun@cmdi.chinamobile.com)
- 2958: -
- 2959: CP#42 completed / Impacted TSs and TRs: 24.323, 24.229 / WI rapporteur e-mail: peter.dawes@vodafone.com
- 2960: CP#58 Removed from Rel-8, Rel-9 and Rel-10 (Not completed internet-draft) / Impacted TSs and TRs: Rel-11 remains draft-dawes-dispatch-debug / WI rapporteur e-mail: peter.dawes@vodafone.com
- 2961: CP#54 Draft removed from 3GPP documentation, covered by draft-dawes-sipping-debug / Impacted TSs and TRs: draft-dawes-sipping-debug-event / WI rapporteur e-mail: peter.dawes@vodafone.com
- 2962: CP#42 completed / Impacted TSs and TRs: 29.228, 29.229 / WI rapporteur e-mail: peter.dawes@vodafone.com
- 2963: CP#42 stopped (No CT3-impact) / WI rapporteur e-mail: peter.dawes@vodafone.com

| ID | WBS | Task | Type | Duration | Start | Finish | Complete | Baseline start | Baseline finish | Baseline duration | Constraint | Resources | Work | Actual work | Acronym | Release | MCC resp | Acronym_3GU_Export | WI rapporteur name | WI rapporteur e-mail | PCG approved | TSG approved | PCG stopped | TSG stopped | Status Report |
| --- | --- | --- | --- | --- | --- | --- | --- | --- | --- | --- | --- | --- | --- | --- | --- | --- | --- | --- | --- | --- | --- | --- | --- | --- | --- |
| 2964 | 747 | **Rel-8 Charging Management small Enhancements** |  | 716d? | 2006-03-16 A | 2008-12-11 A | 100% | 2006-03-16 | 2008-12-11 | 716d? |  | S5 | 12544h | 12544h | CH8 | Rel-8 | Mirko | CH8 |  |  |  |  |  |  |  |
| 2965 | 747.1 | Online charging correlation |  | 457d? | 2006-03-16 A | 2007-12-14 A | 100% | 2006-03-16 | 2007-12-14 | 457d? | start no earlier than 2006-03-16 | S5 | 3656h | 3656h | CH8 | Rel-8 | Mirko |  | Orange | Chahine, Rony |  |  |  |  |  |
| 2966 | 747.2 | SMS online charging |  | 137d? | 2007-06-07 A | 2007-12-14 A | 100% | 2007-06-07 | 2007-12-14 | 137d? | finish no earlier than 2007-12-14 | S5 | 1096h | 1096h | CH8 | Rel-8 | Mirko |  | Vodafone | Gavin.Wong@vodafone.com |  |  |  |  |  |
| 2967 | 747.3 | Introduce Online Charging from SMS-SC into the SMS Charging Specifications |  | 61d? | 2008-09-18 A | 2008-12-11 A | 100% | 2008-09-18 | 2008-12-11 | 61d? | finish no earlier than 2008-12-11 | S5 | 488h | 488h | CH8 | Rel-8 | Mirko |  | Acision | erik.gebler@acision.com | PCG-21 | SP-41 |  |  |  |
| 2968 | 747.4 | Deleted - WLAN Offline Charging |  | 244d? | 2008-01-07 A | 2008-12-11 A | 100% | 2008-01-07 | 2008-12-11 | 244d? | finish no earlier than 2008-12-11 | S5 | 1952h | 1952h | CH8 | Rel-8 | Mirko |  | Alcatel-Lucent | maryse.gardella@alcatel-lucent.com | PCG-21 | SP-38 | PCG-22 | SP-42 |  |
| 2969 | 748 | **Conferencing enhancements for Mp interface** |  | 266d? | 2007-11-30 A | 2008-12-05 A | 100% | 2007-11-30 | 2008-12-05 | 266d? |  | C4 | 6384h | 6384h | eMp | Rel-8 | Kimmo | eMp | Huawei | Chencheng@huawei.com | PCG-21 |  |  |  |  |
| 2970 | 748.1 | Stage 2 for eMp |  | 266d? | 2007-11-30 A | 2008-12-05 A | 100% | 2007-11-30 | 2008-12-05 | 266d? | finish no earlier than 2008-12-11 | C4 | 2128h | 2128h | eMp | Rel-8 | Kimmo |  | Huawei | Chencheng@huawei.com | PCG-21 | CP-38 |  |  |  |
| 2971 | 748.2 | Stage 3 for eMp |  | 266d? | 2007-11-30 A | 2008-12-05 A | 100% | 2007-11-30 | 2008-12-05 | 266d? | finish no earlier than 2008-12-05 | C4 | 2128h | 2128h | eMp | Rel-8 | Kimmo |  | Huawei | Chencheng@huawei.com | PCG-21 | CP-38 |  |  |  |
| 2972 | 749 | **Contact Manager for 3GPP UICC applications** |  | 642d? | 2006-06-22 A | 2008-12-05 A | 100% | 2006-06-22 | 2008-12-05 | 642d? |  | C6 | 13352h | 13352h | eUPHBOOK | Rel-8 | Xavier | eUPHBOOK | Gemalto | Jacques.seif@gemalto.com |  |  |  |  |  |
| 2973 | 749.1 | Requirements for Contact Manager |  | 392d? | 2006-06-22 A | 2007-12-21 A | 100% | 2006-06-22 | 2007-12-21 | 392d? | finish no earlier than 2007-12-21 | C6 | 3136h | 3136h | eUPHBOOK-St1 | Rel-8 | Xavier | eUPHBOOK-St1 | Gemalto | Jacques.seif@gemalto.com |  |  |  |  |  |
| 2974 | 749.2 | External interface for eUPHBOOK |  | 220d? | 2007-05-07 A | 2008-03-07 A | 100% | 2007-05-07 | 2008-03-07 | 220d? | finish no earlier than 2008-03-07 | C6 | 1760h | 1760h | eUPHBOOK-Ext_Spec | Rel-8 | Xavier | eUPHBOOK-Ext_Spec | Gemalto | Jacques.seif@gemalto.com |  |  |  |  |  |
| 2975 | 749.3 | Internal interface for eUPHBOOK |  | 415d? | 2007-05-07 A | 2008-12-05 A | 100% | 2007-05-07 | 2008-12-05 | 415d? | finish no earlier than 2008-12-05 | C6 | 3320h | 3320h | eUPHBOOK-Int_Spec | Rel-8 | Xavier | eUPHBOOK-Int_Spec | Gemalto | Jacques.seif@gemalto.com |  | CP-37 |  |  |  |
| 2976 | 749.4 | Deleted - Implementation of eUPHBOOK | milestone | 0d? | 2007-06-21 A | 2007-06-21 A | 100% | 2007-06-21 | 2007-06-21 | 0d? | start no earlier than 2007-06-21 | C6 |  |  | eUPHBOOK-St23 | Rel-8 | Xavier | eUPHBOOK-St23 | Giesecke & Devrient | Claus Dietze |  |  |  | SP-33 |  |
| 2977 | 750 | **Rel-8 LTE – 3G Long Term Evolution - Evolved Packet System RAN part** |  | 644d? | 2006-09-25 A | 2009-03-12 A | 100% | 2006-09-25 | 2009-03-12 | 644d? |  | RP; S5 | 50048h | 50048h | LTE | Rel-8 |  | LTE | NTT DoCoMo | Takehiro Nakamura (nakamurata@nttdocomo.co.jp) |  |  |  |  | RP-080741 |
| 2978 | 750.1 | LTE – Physical Layer |  | 380d? | 2006-09-25 A | 2008-03-07 A | 100% | 2006-09-25 | 2008-03-07 | 380d? | finish no earlier than 2007-09-14 | R1 | 3040h | 3040h | LTE-Phys | Rel-8 | Patrick | LTE-Phys | NTT DoCoMo | Sadayuki Abeta |  |  |  |  | RP-080741 |
| 2979 | 750.2 | LTE – Radio Interface Layer 2 and 3 Protocol Aspect |  | 575d? | 2006-09-25 A | 2008-12-05 A | 100% | 2006-09-25 | 2008-12-05 | 575d? | finish no earlier than 2008-12-11 | R2 | 4600h | 4600h | LTE-L23 | Rel-8 | Yong-Jun | LTE-L23 | Nokia Siemens Networks | benoist.sebire@nokia.com |  |  |  |  | RP-080741 |
| 2980 | 750.3 | LTE – eUTRAN Interfaces |  | 575d? | 2006-09-25 A | 2008-12-05 A | 100% | 2006-09-25 | 2008-12-05 | 575d? | finish no earlier than 2008-12-11 | R3 | 4600h | 4600h | LTE-interfaces | Rel-8 | Juha | LTE-interfaces | Ericsson | Martin Israelsson |  |  |  |  | RP-080741 |
| 2981 | 750.4 | LTE – Evolved UTRA and UTRAN RF Radio Transmission/Reception, System Performance Requirements and Conformance Testing |  | 575d? | 2006-09-25 A | 2008-12-05 A | 100% | 2006-09-25 | 2008-12-05 | 575d? | finish no earlier than 2008-12-11 | R4 | 4600h | 4600h | LTE-RF | Rel-8 | Issam | LTE-RF | Nokia Siemens Networks | Tuomo Saynajakangas |  |  |  |  | RP-080741 |
| 2982 | 750.5 | LTE – FDD repeaters |  | 386d? | 2007-09-14 A | 2009-03-06 A | 100% | 2007-09-14 | 2009-03-06 | 386d? | finish no earlier than 2009-03-06 | R4 | 3088h | 3088h | LTE-Repeaters | Rel-8 | Issam | LTE-Repeaters | Powerwave Technologies, Andrew Wireless | ralf.michanikl@andrew.com, Alf.Ahlstrom@pwav.com |  | RP-37 |  |  | RP-090037 |
| 2983 | 750.6 | **E-UTRAN Data Definitions** |  | 389d? | 2007-09-17 A | 2009-03-12 A | 100% | 2007-09-17 | 2009-03-12 | 389d? |  | S5 | 13096h | 13096h | E-UTRAN-OAM | Rel-8 | Mirko | E-UTRAN-OAM |  |  | PCG-21 | SP-39 |  |  |  |
| 2984 | 750.6.1 | Subscriber and Equipment Trace for E-UTRAN and EPC |  | 389d? | 2007-09-17 A | 2009-03-12 A | 100% | 2007-09-17 | 2009-03-12 | 389d? | finish no earlier than 2009-03-12 | S5 | 3112h | 3112h | E-UTRAN-OAM | Rel-8 | Mirko |  | Ericsson | robert.petersen@ericsson.com |  | SP-37 |  |  |  |
| 2985 | 750.6.2 | E-UTRAN Network Resource Model (NRM) Integration Reference Point (IRP) |  | 309d? | 2008-01-07 A | 2009-03-12 A | 100% | 2008-01-07 | 2009-03-12 | 309d? | finish no earlier than 2009-03-12 | S5 | 2472h | 2472h | E-UTRAN-OAM | Rel-8 | Mirko |  | Ericsson | ELMDAHL, Per | PCG-21 | SP-38 |  |  |  |
| 2986 | 750.6.3 | Performance measurements for E-UTRAN |  | 275d? | 2008-02-22 A | 2009-03-12 A | 100% | 2008-02-22 | 2009-03-12 | 275d? | finish no earlier than 2009-03-12 | S5 | 2200h | 2200h | E-UTRAN-OAM | Rel-8 | Mirko |  | Motorola, Huawei | Yizhi Yao (yzyao@motorola.com) | PCG-21 | SP-39 |  |  |  |
| 2987 | 750.6.4 | Key Performance Indicators (KPIs) for E-UTRAN |  | 275d? | 2008-02-22 A | 2009-03-12 A | 100% | 2008-02-22 | 2009-03-12 | 275d? | finish no earlier than 2009-03-12 | S5 | 2200h | 2200h | E-UTRAN-OAM | Rel-8 | Mirko |  | Ericsson | ulf.hubinette@ericsson.com | PCG-21 | SP-39 |  |  |  |

Notes:
- 2964: CH8 is an umbrella Feature also for OAM&P related TEI8 type of changes that are not part of any other dedicated feature/WI / Impacted TSs and TRs: TR 30.818
- 2965: SP#38 completed / Impacted TSs and TRs: 32.296
- 2966: SP#38 completed / Impacted TSs and TRs: 32.240, 32.299, new 32.274
- 2967: SP#42 completed. Linked to SA2 UID 32081 (Support of SMS over IP networks) and CT4 UID 340016 (Routeing of MT-SMS via the HPLMN). / Impacted TSs and TRs: 32.274, 32.299
- 2968: SP#42 stopped / Impacted TSs and TRs: 32.252, 32.298, 32.299
- 2969: CP#42 completed
- 2970: CP#42 completed / Impacted TSs and TRs: 23.333
- 2971: CP#42 completed / Impacted TSs and TRs: 29.333
- 2972: CP#42 completed. CP#40: WID updated CP-070622=>CP-080382. aka Enhanced USIM phonebook
- 2973: CP#38 completed / Impacted TSs and TRs: 21.111
- 2974: CP#39 completed / Impacted TSs and TRs: new 31.220
- 2975: CP#42 completed / Impacted TSs and TRs: new 31.221
- 2976: SP#33 stopped / Impacted TSs and TRs: 31.102
- 2977: RP#43 completed. Role model for SAE/LTE system wide project management by SA2 in SP-060166 / Impacted TSs and TRs: LTE 36.300, 36.938
- 2978: RP#39 completed / Impacted TSs and TRs: 36.201, 36.211, 36.212, 36.213, 36.214, 25.215, 25.225
- 2979: RP#42 completed / Impacted TSs and TRs: 36.302, 36.304, 36.306, 36.314, 36.321, 36.322, 36.323, 36.331, 25.302, 25.304, 25.331
- 2980: RP#42 completed / Impacted TSs and TRs: 36.401, 36.410, 36.411, 36.412, 36.413, 36.414, 36.420, 36.421, 36.422, 36.423, 36.424, 25.413
- 2981: RP#42 completed. RP#47 abandoned draft 36.801, 36.803, 36.804 / Impacted TSs and TRs: 36.101, 36.104, 36.113, 36.124, 36.133, 36.141, 36.942, 25.123, 25.133
- 2982: RP#43 completed. RP#47 create Rel-9 TR 36.956 (see R4-100386, RP-100320_RAN4 Report) / Impacted TSs and TRs: 36.106, 36.143, 25.113
- 2983: SP#43 completed
- 2984: SP#43 completed / Impacted TSs and TRs: 32.421, 2.422, 32.423, 2.441, 32.442, 32.443, 32.445
- 2985: SP#43 completed / Impacted TSs and TRs: new (32.761, 32.762, 32.763, 32.765)
- 2986: SP#43 completed / Impacted TSs and TRs: new 32.425
- 2987: SP#43 completed / Impacted TSs and TRs: new (32.450, 32.451)

| ID | WBS | Task | Duration | Start | Finish | Complete | Baseline start | Baseline finish | Baseline duration | Constraint | Resources | Work | Actual work | Acronym | PCG approved | WI rapporteur name | WI rapporteur e-mail | Release | TSG approved | MCC resp | Special Focus Doc | Acronym_3GU_Export | Status Report | PCG stopped | TSG stopped |
| --- | --- | --- | --- | --- | --- | --- | --- | --- | --- | --- | --- | --- | --- | --- | --- | --- | --- | --- | --- | --- | --- | --- | --- | --- | --- |
| 2988 | 750.7 | **Self-Organizing Networks (SON)** | 210d? | 2008-02-22 A | 2008-12-11 A | 100% | 2008-02-22 | 2008-12-11 | 210d? |  | S5 | 6720h | 6720h | LTE_SON-OAM | PCG-21 | Vodafone | GOMPAKIS, Panagiotis | Rel-8 | SP-39 | Mirko | SON | LTE_SON-OAM |  |  |  |
| 2989 | 750.7.1 | SON Concepts and requirements | 210d? | 2008-02-22 A | 2008-12-11 A | 100% | 2008-02-22 | 2008-12-11 | 210d? |  | S5 | 1680h | 1680h | LTE_SON-OAM | PCG-21 | Vodafone | GOMPAKIS, Panagiotis | Rel-8 | SP-39 | Mirko |  |  |  |  |  |
| 2990 | 750.7.2 | Self-Establishment of eNBs, including automated Software Management | 210d? | 2008-02-22 A | 2008-12-11 A | 100% | 2008-02-22 | 2008-12-11 | 210d? | start no earlier than 2008-02-22 | S5 | 1680h | 1680h | LTE_SON-OAM | PCG-21 | Nokia Siemens Networks | SUERBAUM, Clemens | Rel-8 | SP-39 | Mirko |  |  |  |  |  |
| 2991 | 750.7.3 | SON Automatic Neighbour Relations (ANR) List Management | 210d? | 2008-02-22 A | 2008-12-11 A | 100% | 2008-02-22 | 2008-12-11 | 210d? | finish no earlier than 2008-12-11 | S5 | 1680h | 1680h | LTE_SON-OAM | PCG-21 | Ericsson | edwin.tse@ericsson.com | Rel-8 | SP-39 | Mirko |  |  |  |  |  |
| 2992 | 751 | **Rel-8 LTE – Terminal Conformance Test Specification** | 657d? | 2007-06-01 A | 2009-12-04 A | 100% | 2007-06-01 | 2009-12-04 | 657d? |  | R5 | 14336h | 14336h | LTE-UEConTest |  |  |  | Rel-8 |  | Ingbert |  | LTE-UEConTest |  |  |  |
| 2993 | 751.1 | 3G LTE – Terminal Protocol Conformance Test Specifications | 657d? | 2007-06-01 A | 2009-12-04 A | 100% | 2007-06-01 | 2009-12-04 | 657d? | finish no earlier than 2009-12-04 | R5 | 5256h | 5256h | LTE-UEConTest_SIG |  | NEC, Motorola | david.lecompte@nectech.fr, Jacob.John@motorola.com | Rel-8 |  | Ingbert |  | LTE-UEConTest_SIG | RP-091060 |  |  |
| 2994 | 751.2 | LTE – Terminal Radio Transmission and Reception Conformance Test Specifications | 657d? | 2007-06-01 A | 2009-12-04 A | 100% | 2007-06-01 | 2009-12-04 | 657d? |  | R5 | 5256h | 5256h | LTE-UEConTest_RF |  | Agilent | andrea_leonardi@agilent.com | Rel-8 |  | Ingbert |  | LTE-UEConTest_RF | RP-091059 |  |  |
| 2995 | 752 | **Rel-8 Improvements of the Radio Interface** | 525d? | 2007-03-05 A | 2009-03-06 A | 100% | 2007-03-05 | 2009-03-06 | 525d? |  | RP | 18152h | 18152h | RInImp8 |  |  |  | Rel-8 |  | Issam |  | RInImp8 |  |  |  |
| 2996 | 752.1 | UMTS 1500 MHz | 140d? | 2007-03-05 A | 2007-09-14 A | 100% | 2007-03-05 | 2007-09-14 | 140d? | finish no earlier than 2007-09-14 | R4 | 1120h | 1120h | RInImp8-UMTS1500 |  | NTT DoCoMo | Takehiro Nakamura (nakamurata@nttdocomo.co.jp) | Rel-8 |  | Issam |  | RInImp8-UMTS1500 | RP-070526 |  |  |
| 2997 | 752.2 | UMTS 700 MHz FDD | 325d? | 2007-03-05 A | 2008-05-30 A | 100% | 2007-03-05 | 2008-05-30 | 325d? | finish no earlier than 2008-06-12 | R4 | 2600h | 2600h | RInImp8-UMTS700 |  | Nokia | Tuomo Saynajakangas | Rel-8 |  | Issam |  | RInImp8-UMTS700 | RP-080260 |  |  |
| 2998 | 752.3 | UMTS 1880 MHz TDD | 126d? | 2008-09-12 A | 2009-03-06 A | 100% | 2008-09-12 | 2009-03-06 | 126d? | finish no earlier than 2009-03-09 | R4 | 1008h | 1008h | RInImp9-UMTS1880TDD | PCG-21 | CATT | Yuexia Song (songyuexia@catt.cn) | Rel-8 | RP-41 | Issam |  | RInImp9-UMTS1880TDD | RP-090044 |  |  |
| 2999 | 752.4 | UMTS 2300 MHz TDD LCR | 195d? | 2007-12-17 A | 2008-09-12 A | 100% | 2007-12-17 | 2008-09-12 | 195d? | finish no earlier than 2008-09-12 | R4 | 1560h | 1560h | RInImp8-UMTS2300TDD | PCG-21 | CATT | Yuexia Song (songyuexia@catt.cn) | Rel-8 | RP-38 | Issam |  | RInImp8-UMTS2300TDD | RP-080517 |  |  |
| 3000 | 752.5 | Further Improved Minimum Performance Requirements for HSDPA UE (FDD) - Two-Branch Interference Cancellation | 265d? | 2007-03-05 A | 2008-03-07 A | 100% | 2007-03-05 | 2008-03-07 | 265d? | finish no earlier than 2008-03-12 | R4 | 2120h | 2120h | RInImp8-2BIC |  | AT&T | Marc Grant | Rel-8 |  | Issam |  | RInImp8-2BIC | RP-080041 |  |  |
| 3001 | 752.6 | CS Voice Service over HSPA | 167d? | 2007-07-19 A | 2008-03-07 A | 100% | 2007-07-19 | 2008-03-07 | 167d? |  | R2 | 1336h | 1336h | RInImp8-CsHspa |  | Nokia Siemens Networks | woonhee.hwang@nsn.com | Rel-8 | RP-37 | Yong-Jun |  | RInImp8-CsHspa | RP-080042 |  |  |
| 3002 | 752.7 | Performance requirements for 15 code reception with 16QAM/QPSK (FDD) | 126d? | 2007-06-11 A | 2008-03-07 A | 100% | 2007-06-11 | 2008-03-07 | 126d? | finish no earlier than 2008-06-12 | R4 | 1008h | 1008h | RInImp8-Hsdpa15codes |  | Vodafone | tim.frost@vodafone.com | Rel-8 | RP-37 | Issam |  | RInImp8-Hsdpa15codes | RP-080043 |  |  |
| 3003 | 752.8 | Deleted - UMTS 2300 MHz FDD/TDD | 400d? | 2007-03-05 A | 2008-09-12 A | 100% | 2007-03-05 | 2008-09-12 | 400d? | finish no earlier than 2008-12-11 | R4 | 3200h | 3200h | RInImp8-UMTS2300 |  | AT&T | Marc Grant | Rel-8 |  | Issam |  | RInImp8-UMTS2300 | RP-080515 | PCG-21 | RP-41 |
| 3004 | 753 | **Rel-8 Improvements of the Radio Interface - UE Conformance Testing** | 396d? | 2007-06-01 A | 2008-12-05 A | 100% | 2007-06-01 | 2008-12-05 | 396d? |  | R5 | 6256h | 6256h |  |  |  |  | Rel-8 |  | Ingbert |  |  |  |  |  |
| 3005 | 753.1 | Conformance Test Aspects – CS Voice Service over HSPA | 336d? | 2007-06-01 A | 2008-09-12 A | 100% | 2007-06-01 | 2008-09-12 | 336d? | finish no earlier than 2008-09-12 | R5 | 2688h | 2688h | RInImp8-CsHspa_UEConTest |  | Huawei | baoyi@huawei.com | Rel-8 |  | Ingbert |  | RInImp8-CsHspa_UEConTest | RP-080542 |  |  |
| 3006 | 753.2 | Conformance Test Aspects – Performance requirements for 15 code reception with 16QAM/QPSK (FDD) | 195d? | 2008-03-07 A | 2008-12-05 A | 100% | 2008-03-07 | 2008-12-05 | 195d? | finish no earlier than 2008-12-05 | R5 | 1560h | 1560h | RInImp8-UEConTest_ Hsdpa15codes | PCG-21 | Ericsson | Mikael.Ziren@Ericsson.com | Rel-8 | RP-40 | Ingbert |  | RInImp8-UEConTest_ Hsdpa15codes | RP-080818 |  |  |
| 3007 | 754 | **Rel-8 RAN improvements** | 520d? | 2007-06-04 A | 2009-05-29 A | 100% | 2007-06-04 | 2009-05-29 | 520d? |  | RP | 37481.6h | 37481.6h |  |  |  |  | Rel-8 |  |  |  |  |  |  |  |
| 3008 | 754.1 | Combination of 64QAM and MIMO for HSDPA (FDD) | 205d? | 2007-06-04 A | 2008-09-12 A | 100% | 2007-06-04 | 2008-09-12 | 205d? | finish no earlier than 2008-09-12 | R1 | 1640h | 1640h | RANimp-64QamMimoHsdpa |  | Ericsson | Johan.Bergman@ericsson.com | Rel-8 |  | Patrick |  | RANimp-64QamMimoHsdpa | RP-080518 |  |  |
| 3009 | 754.2 | Improved L2 for uplink | 186d? | 2007-09-14 A | 2008-05-30 A | 100% | 2007-09-14 | 2008-05-30 | 186d? | finish no earlier than 2008-05-30 | R2 | 1488h | 1488h | RANimp-UplinkL2dataRates |  | Ericsson | Janne.Peisa@ericsson.com | Rel-8 | RP-37 | Yong-Jun |  | RANimp-UplinkL2dataRates | RP-080265 |  |  |
| 3010 | 754.3 | Enhanced Uplink for CELL_FACH State in FDD | 321d? | 2007-09-14 A | 2008-12-05 A | 100% | 2007-09-14 | 2008-12-05 | 321d? | finish no earlier than 2008-12-12 | R2 | 2568h | 2568h | RANimp-UplinkEnhState |  | Nokia Siemens Networks | markus.wimmer@nsn.com | Rel-8 | RP-37 | Yong-Jun |  | RANimp-UplinkEnhState | RP-080804 |  |  |
| 3011 | 754.4 | Enhanced UE Discontinuous Reception (DRX) for FDD | 261d? | 2007-09-14 A | 2008-09-12 A | 100% | 2007-09-14 | 2008-09-12 | 261d? | finish no earlier than 2008-09-12 | R2 | 2088h | 2088h | RANimp-DRX |  | Nokia | luis.barreto@nokia.com | Rel-8 | RP-37 | Yong-Jun |  | RANimp-DRX | RP-080520 |  |  |
| 3012 | 754.5 | Enhancements for Serving Radio Network Subsystem (SRNS) Relocation Procedure | 261d? | 2007-09-14 A | 2008-09-12 A | 100% | 2007-09-14 | 2008-09-12 | 261d? | finish no earlier than 2008-09-12 | R3 | 2088h | 2088h | RANimp-SrnsReloc |  | Nokia Siemens Networks | masatoshi.nakamata@nsn.com | Rel-8 | RP-37 | Juha |  | RANimp-SrnsReloc | RP-080521 |  |  |
| 3013 | 754.6 | Enhancements for FDD HSPA Evolution | 321d? | 2007-09-14 A | 2008-12-05 A | 100% | 2007-09-14 | 2008-12-05 | 321d? | finish no earlier than 2008-12-05 | R3; R2 | 5136h | 5136h | RANimp-HSPAEvo |  | Nokia Siemens Networks | masatoshi.nakamata@nsn.com | Rel-8 | RP-37 | Juha |  | RANimp-HSPAEvo | RP-080805 |  |  |
| 3014 | 754.7 | 64QAM for 1.28 Mcps TDD HSDPA | 264d? | 2007-12-04 A | 2008-12-05 A | 100% | 2007-12-04 | 2008-12-05 | 264d? | finish no earlier than 2008-12-05 | R1 | 2112h | 2112h | RANimp-64Qam1.28TDD | PCG-21 | ZTE | zfmail@zte.com.cn | Rel-8 | RP-38 | Patrick |  | RANimp-64Qam1.28TDD | RP-080806 |  |  |
| 3015 | 754.8 | Enhanced CELL_FACH state in 1.28 Mcps TDD | 264d? | 2007-12-04 A | 2008-12-05 A | 100% | 2007-12-04 | 2008-12-05 | 264d? | finish no earlier than 2008-12-12 | R2 | 2112h | 2112h | RANimp-EnhState1.28TDD | PCG-21 | ZTE | zhang.yincheng@zte.com.cn | Rel-8 | RP-38 | Yong-Jun |  | RANimp-EnhState1.28TDD | RP-080807 |  |  |
| 3016 | 754.9 | Continuous Connectivity for packet data users for 1.28 Mcps TDD | 321d? | 2008-03-07 A | 2009-05-29 A | 100% | 2008-03-07 | 2009-05-29 | 321d? | finish no earlier than 2009-05-29 | R1 | 2568h | 2568h | RANimp-LCRCPC | PCG-21 | TD Tech | chenying@td-tech.com | Rel-8 | RP-39 | Patrick |  | RANimp-LCRCPC | RP-090394 |  |  |
| 3017 | 754.10 | HSPA VoIP to WCDMA/GSM CS continuity | 261d? | 2008-03-07 A | 2009-03-06 A | 100% | 2008-03-07 | 2009-03-06 | 261d? | finish no earlier than 2009-03-06 | R2 | 2088h | 2088h | RANimp-HSPAVoIP | PCG-21 | Nokia | Simone.Provvedi@nokia.com | Rel-8 | RP-39 | Yong-Jun |  | RANimp-HSPAVoIP | RP-090050 |  |  |
| 3018 | 754.11 | HS-DSCH Serving Cell Change Enhancements | 196d? | 2008-03-07 A | 2008-12-05 A | 100% | 2008-03-07 | 2008-12-05 | 196d? | finish no earlier than 2008-12-12 | R2 | 1568h | 1568h | RANimp-HSDSCH | PCG-21 | Ericsson | henrik.enbuske@ericsson.com | Rel-8 | RP-39 | Yong-Jun |  | RANimp-HSDSCH | RP-080811 |  |  |
| 3019 | 754.12 | MIMO for 1.28 Mcps TDD. Linked to Rel-8 Study on Scope of future HSPA Evolution for 1.28 Mcps TDD (UID_370041) TR 25.824 | 351.6d? | 2008-01-24 A | 2009-05-29 A | 100% | 2008-01-24 | 2009-05-29 | 351.6d? | finish no earlier than 2009-05-29 | R1; R4 | 5625.6h | 5625.6h | RANimp-MIMOLCR | PCG-21 | CATT | wangke@datangmobile.cn | Rel-8 | RP-40 | Patrick |  | RANimp-MIMOLCR | RP-090313 |  |  |
| 3020 | 754.13 | Dual-Cell HSDPA operation on adjacent carriers | 140d? | 2008-11-17 A | 2009-05-29 A | 100% | 2008-11-17 | 2009-05-29 | 140d? | finish no earlier than 2009-05-29 | R1; R4 | 2240h | 2240h | RANimp-DCHSDPA | PCG-21 | Ericsson | johan.bergman@ericsson.com | Rel-8 | RP-40 | Patrick |  | RANimp-DCHSDPA | RP-080814 |  |  |

Notes:
- 2988: SP#42 completed (WT UID_390007 moved to Rel-9)
- 2989: SP#42 completed / Impacted TSs and TRs: new 32.500
- 2990: SP#42 completed / Impacted TSs and TRs: new (32.501, 32.502, 32.503, 32.531, 32.532, 32.533)
- 2991: SP#42 completed / Impacted TSs and TRs: 32.761, 32.762, 32.763, 32.765, new 32.511
- 2992: Testing for Feature UID_20068 (LTE)
- 2993: RP#46 completed / Impacted TSs and TRs: 36.521-1, 36.521-2, 36.508, 36.509, 36.523-1, 36.523-2, 36.523-3
- 2994: RP#46 completed. RP#50 TR 36.903 v100 for Approval / Impacted TSs and TRs: 36.521-1, 36.521-2, 36.521-3, new TR 36.903
- 2995: -
- 2996: RP#37 completed / Impacted TSs and TRs: 25.101, 25.104, 25.133, 25.141, 25.331, 25.942, 25.306, 25.307, 34.121
- 2997: RP#40 completed / Impacted TSs and TRs: 25.101, 25.104, 25.133, 25.141, 25.331, 25.942, 25.306, 25.307, 34.121
- 2998: RP#43 completed / Impacted TSs and TRs: 25.102, 25.105, 25.113, 25.123, 25.142, 34.124, 25.307
- 2999: RP#41 completed. RP#47 abandoned draft 25.828 / Impacted TSs and TRs: 25.102, 25.105, 25.113, 25.123, 25.142, 34.124, 25.306, 25.331, 34.122
- 3000: RP#39 completed / Impacted TSs and TRs: 25.101
- 3001: RP#39 completed / Impacted TSs and TRs: 25.323, 25.331, 25.322
- 3002: RP#39 completed / Impacted TSs and TRs: 25.101
- 3003: RP#41 stopped / Impacted TSs and TRs: 25.101, 25.104, 25.133, 25.141, 25.331, 25.942, 25.306, 25.307, 34.121
- 3004: 05/08: Linked to Feature UID_20028 (RInImp)
- 3005: RP#41 completed / Impacted TSs and TRs: 34.108, 34.123-1, 34.123-2, 34.123-3
- 3006: RP#42 completed / Impacted TSs and TRs: 34.121-1, 34.121-2
- 3007: -
- 3008: RP#41 completed / Impacted TSs and TRs: 25.308, 25.211, 25.212, 25.213, 25.306, 25.331, 25.433, 25.435, 25.423, 25.425, 25.101, 25.104, 25.141
- 3009: RP#40 completed. Linked to UID_370037 Enhanced Uplink for CELL_FACH State in FDD / Impacted TSs and TRs: 25.319, 25.301, 25.306, 25.321, 25.331, 25.433, 25.435, 25.423, 25.425, 25.427
- 3010: RP#42 completed. Linked to UID_370036 Improved L2 for uplink / Impacted TSs and TRs: 25.309, 25.211, 25.214, 25.321, 25.331, 25.423, 25.433
- 3011: RP#41 completed. Continuation of Rel-7 work item "Continuous connectivity for packet data users" UID_20046. / Impacted TSs and TRs: 25.306, 25.308, 25.321, 25.331, 25.423
- 3012: RP#41 completed. Linked to UID_370040 Enhancements for FDD HSPA Evolution / Impacted TSs and TRs: 25.306, 25.308, 25.321, 25.331, 25.423, 25.433, 25.214, 25.133
- 3013: RP#42 completed. Triggered by Rel-7 Study on Scope of future FDD HSPA Evolution (UID_20065) TR 25.999 / Impacted TSs and TRs: 25.401, 25.413, 25.420, 25.423, 25.427, 25.433, 25.446, 25.301, 25.346
- 3014: RP#42 completed. Linked to Rel-8 Study on Scope of future HSPA Evolution for 1.28 Mcps TDD (UID_370041) TR 25.824 / Impacted TSs and TRs: 25.102, 25.105, 25.123, 25.142, 25.201, 25.221, 25.222, 25.223, 25.224, 25.306, 25.308, 25.321, 25.331, 25.423, 25.433
- 3015: RP#42 completed. Linked to Rel-8 Study on Scope of future HSPA Evolution for 1.28 Mcps TDD (UID_370041) TR 25.824 / Impacted TSs and TRs: 25.123, 25.221, 25.222, 25.224, 25.301, 25.302, 25.304, 25.306, 25.308, 25.319, 25.321, 25.331, 25.401, 25.423, 25.425, 25.433, 25.435
- 3016: RP#44 completed. Linked to Rel-8 Study on Scope of future HSPA Evolution for 1.28 Mcps TDD (UID_370041) TR 25.824 / Impacted TSs and TRs: 25.929, 25.308, 25.319
- 3017: RP#43 completed / Impacted TSs and TRs: 25.331, 25.413
- 3018: RP#42 completed / Impacted TSs and TRs: 25.101, 25.104, 25.133, 25.212, 25.214, 25.308, 25.321, 25.331, 25.423, 25.433
- 3019: RP#43 completed / Impacted TSs and TRs: 25.201, 25.221, 25.222, 25.223, 25.224, 25.306, 25.308, 25.321, 25.331, 25.423, 25.433, 25.102, 25.105, 25.142
- 3020: RP#42 completed. Triggered by UID_390032 Study on Dual-Cell HSDPA (withdrawn TR 25.825 v100). / Impacted TSs and TRs: 25.101, 25.104, 25.133, 25.141, 25.211, 25.212, 25.213, 25.214, 25.215, 25.306, 25.308, 25.321, 25.331, 25.423, 25.433

| ID | WBS | Task | Duration | Start | Finish | Complete | Baseline start | Baseline finish | Baseline duration | Constraint | Resources | Work | Actual work | Release | MCC resp | Acronym | PCG approved | WI rapporteur name | TSG approved | Status Report | Acronym_3GU_Export |
| --- | --- | --- | --- | --- | --- | --- | --- | --- | --- | --- | --- | --- | --- | --- | --- | --- | --- | --- | --- | --- | --- |
| 3021 | 755 | **Rel-8 RAN improvements - UE Conformance Testing** | 602d? | 2008-05-30 A | 2010-09-17 A | 100% | 2008-05-30 | 2010-09-17 | 602d? |  | R5 | 29391.2h | 29391.2h | Rel-8 | Ingbert |  |  |  |  |  |  |
| 3022 | 755.1 | Conformance Test Aspects – Combination of 64QAM and MIMO for HSDPA (FDD) | 322d? | 2008-09-12 A | 2009-12-04 A | 100% | 2008-09-12 | 2009-12-04 | 322d? | finish no earlier than 2009-12-04 | R5 | 2576h | 2576h | Rel-8 | Ingbert | RANimp-UEConTest_64QamMimoHsdpa | PCG-21 | Ericsson | RP-41 | RP-091058 | RANimp-UEConTest_64QamMimoHsdpa |
| 3023 | 755.2 | Conformance Test Aspects – Improved L2 for uplink | 341d? | 2008-05-30 A | 2009-09-18 A | 100% | 2008-05-30 | 2009-09-18 | 341d? | finish no earlier than 2009-09-18 | R5 | 2728h | 2728h | Rel-8 | Ingbert | RANimp-UEConTest_UplinkL2dataRates | PCG-21 | Ericsson | RP-40 | RP-090712 | RANimp-UEConTest_UplinkL2dataRates |
| 3024 | 755.3 | Conformance Test Aspects – 1.28 Mcps TDD Improved L2 support for high data rates | 342d? | 2009-05-29 A | 2010-09-17 A | 100% | 2009-05-29 | 2010-09-17 | 342d? | finish no earlier than 2010-09-17 | R5 | 2736h | 2736h | Rel-8 | Ingbert | RANimp-UEConTest_ImprovedL2LCRTDD | PCG-23 | CATT | RP-44 | RP-100737 | RANimp-UEConTest_ImprovedL2LCRTDD |
| 3025 | 755.4 | Conformance Test Aspects – 64QAM for 1.28 Mcps TDD HSDPA | 261d? | 2008-05-30 A | 2009-05-29 A | 100% | 2008-05-30 | 2009-05-29 | 261d? | finish no earlier than 2009-05-29 | R5 | 2088h | 2088h | Rel-8 | Ingbert | RANimp-UEConTest_64Qam1.28TDD | PCG-21 | ZTE | RP-40 | RP-090415 | RANimp-UEConTest_64Qam1.28TDD |
| 3026 | 755.5 | Conformance Test Aspects – Dual-Cell HSDPA operation on adjacent carriers | 391d? | 2008-12-05 A | 2010-06-04 A | 100% | 2008-12-05 | 2010-06-04 | 391d? | finish no earlier than 2010-06-04 | R5 | 3128h | 3128h | Rel-8 | Ingbert | RANimp-UEConTest_DCHSDPA | PCG-22 | Qualcomm | RP-42 | RP-100479 | RANimp-UEConTest_DCHSDPA |
| 3027 | 755.6 | Conformance Test Aspects – Enhanced Uplink for CELL_FACH State in FDD | 326d? | 2009-03-06 A | 2010-06-04 A | 100% | 2009-03-06 | 2010-06-04 | 326d? | finish no earlier than 2010-06-04 | R5 | 2608h | 2608h | Rel-8 | Ingbert | RANimp-UEConTest_EnhancedRACHCellFACHState | PCG-22 | Nokia | RP-43 | RP-100483 | RANimp-UEConTest_EnhancedRACHCellFACHState |
| 3028 | 755.7 | Conformance Test Aspects – Receiver Type3i | 196d? | 2009-03-06 A | 2009-12-04 A | 100% | 2009-03-06 | 2009-12-04 | 196d? | finish no earlier than 2009-12-04 | R5 | 1568h | 1568h | Rel-8 | Ingbert | RANimp-UEConTest_ReceiverType3i | PCG-22 | Qualcomm | RP-43 | RP-091066 | RANimp-UEConTest_ReceiverType3i |
| 3029 | 755.8 | Conformance Test Aspects – Enhanced CELL_FACH State in LCR TDD | 341d? | 2009-05-30 A | 2010-09-17 A | 100% | 2009-05-30 | 2010-09-17 | 341d? | finish no earlier than 2010-09-17 | R5 | 2728h | 2728h | Rel-8 | Ingbert | RANimp-UEConTest_EnhancedCellFACHStateLCRTDD | PCG-23 | CATT | RP-44 | RP-100735 | RANimp-UEConTest_EnhancedCellFACHStateLCRTDD |
| 3030 | 755.9 | Conformance Test Aspects – Continuous Connectivity for packet data users for 1.28 Mcps TDD | 261d? | 2009-09-18 A | 2010-09-17 A | 100% | 2009-09-18 | 2010-09-17 | 261d? | finish no earlier than 2010-09-17 | R5 | 2088h | 2088h | Rel-8 | Ingbert | RANimp-UEConTest_CPCLCRTDD | PCG-23 | ZTE | RP-45 | RP-100739 | RANimp-UEConTest_CPCLCRTDD |
| 3031 | 755.10 | Conformance Test Aspects – MIMO for 1.28 Mcps TDD | 186d? | 2009-09-18 A | 2010-06-04 A | 100% | 2009-09-18 | 2010-06-04 | 186d? | finish no earlier than 2010-06-04 | R5 | 1488h | 1488h | Rel-8 | Ingbert | RANimp-UEConTest_MIMOLCRTDD | PCG-23 | ZTE | RP-45 | RP-100660 | RANimp-UEConTest_MIMOLCRTDD |
| 3032 | 755.11 | Conformance Test Aspects – HS-DSCH Serving Cell Change Enhancements | 131d? | 2009-09-18 A | 2010-03-19 A | 100% | 2009-09-18 | 2010-03-19 | 131d? | finish no earlier than 2010-03-12 | R5 | 1048h | 1048h | Rel-8 | Ingbert | HSDSCH_UEConTest | PCG-23 | Qualcomm | RP-45 | RP-100077 | HSDSCH_UEConTest |
| 3033 | 756 | 3.84 Mcps TDD MBMS over a Single Frequency Network (MBSFN) Integrated Mobile Broadcast | 395d? | 2007-06-04 A | 2008-12-05 A | 100% | 2007-06-04 | 2008-12-05 | 395d? |  | R1 | 3160h | 3160h | Rel-8 | Patrick | MBSFN-DOB |  | Ericsson |  | RP-080218 | MBSFN-DOB |
| 3034 | 757 | Conformance Test Aspects – 3.84 Mcps TDD MBMS over a Single Frequency Network (MBSFN) Integrated Mobile Broadcast | 211d? | 2009-05-30 A | 2010-03-19 A | 100% | 2009-05-30 | 2010-03-19 | 211d? | finish no earlier than 2010-03-19 | R5 | 1688h | 1688h | Rel-8 | Ingbert | MBSFN_IMB_UEConTest | PCG-23 | IPwireless | RP-44 | RP-100070 | MBSFN_IMB_UEConTest |
| 3035 | 758 | **GERAN support for GERAN - 3G Long Term Evolution interworking** | 1365d? | 2006-09-08 A | 2011-11-25 A | 100% | 2006-09-08 | 2011-11-25 | 1365d? |  | GP; G1; C1; G3new | 69960h | 69960h | Rel-8 | Paolo | GELTE |  | Nokia, Nokia Siemens Networks |  |  | GELTE |
| 3036 | 758.1 | G1 part of GERAN support for GERAN - 3G Long Term Evolution interworking | 641d? | 2006-09-08 A | 2009-02-20 A | 100% | 2006-09-08 | 2009-02-20 | 641d? | finish no earlier than 2009-02-20 | G1 | 5128h | 5128h | Rel-8 | Paolo | GELTE |  | Nokia, Nokia Siemens Networks |  |  |  |
| 3037 | 758.2 | G2 part of GERAN support for GERAN - 3G Long Term Evolution interworking | 641d? | 2006-09-08 A | 2009-02-20 A | 100% | 2006-09-08 | 2009-02-20 | 641d? | finish no earlier than 2009-02-20 | G2 | 5128h | 5128h | Rel-8 | Paolo | GELTE |  | Nokia, Nokia Siemens Networks |  |  |  |
| 3038 | 758.3 | CT1 part of GERAN support for GERAN - 3G Long Term Evolution interworking | 641d? | 2006-09-08 A | 2009-02-20 A | 100% | 2006-09-08 | 2009-02-20 | 641d? | finish no earlier than 2009-02-20 | C1 | 5128h | 5128h | Rel-8 | Paolo | GELTE |  | Nokia, Nokia Siemens Networks |  |  |  |
| 3039 | 758.4 | Testing for GERAN support for GERAN - 3G Long Term Evolution interworking | 1363d? | 2006-09-08 A | 2011-11-25 A | 100% | 2006-09-08 | 2011-11-25 | 1363d? | finish no earlier than 2011-11-25 | G3new | 10896h | 10896h | Rel-8 | Ingbert | GELTE |  | Renesas Mobile |  |  |  |
| 3040 | 759 | U-TDOA Enhancement | 131d? | 2007-05-18 A | 2007-11-16 A | 100% | 2007-05-18 | 2007-11-16 | 131d? | finish no earlier than 2007-05-18 | GP | 1048h | 1048h | Rel-8 | Paolo | GUTEN |  | TruePosition |  |  | GUTEN |
| 3041 | 760 | **GAN Enhancements** | 604.2d? | 2007-05-15 A | 2009-09-04 A | 100% | 2007-05-15 | 2009-09-04 | 604.2d? |  | GP | 9432h | 9432h | Rel-8 | Paolo | GANENH |  | T-Mobile |  |  | GANENH |
| 3042 | 760.1 | Update to GAN specifications | 126d? | 2007-08-31 A | 2008-02-22 A | 100% | 2007-08-31 | 2008-02-22 | 126d? | finish no earlier than 2008-02-22 | GP | 1008h | 1008h | Rel-8 | Paolo | GANENH-SPEC |  | T-Mobile |  |  | GANENH-SPEC |
| 3043 | 760.2 | Update TS 51.010 Mobile Station (MS) Conformance Specification for GAN Enhancements | 526d? | 2007-05-15 A | 2009-09-04 A | 100% | 2007-05-15 | 2009-09-04 | 526d? | finish no earlier than 2009-09-04 | G3new | 4208h | 4208h | Rel-8 | Ingbert | GANENH-MStest |  | T-Mobile |  |  | GANENH-MStest |
| 3044 | 761 | **AoIP (A-interface over IP)** | 2335d? | 2000-01-03 A | 2008-12-11 A | 100% | 2000-01-03 | 2008-12-11 | 2335d? |  | GP; S4; C4; C1; C3 | 119396h | 119396h | Rel-8 | Paolo | AoIP | PCG-21 | China Mobile, Ericsson |  |  | AoIP |
| 3045 | 761.1 | GERAN aspects of AoIP | 2321d? | 2000-01-03 A | 2008-11-21 A | 100% | 2000-01-03 | 2008-11-21 | 2321d? | finish no earlier than 2008-11-21 | GP | 18560h | 18560h | Rel-8 | Paolo | AoIP | PCG-21 | China Mobile, Ericsson | SP-40 |  |  |
| 3046 | 761.2 | Media Requirements for CS over IP based User Plane | 267d? | 2007-12-05 A | 2008-12-11 A | 100% | 2007-12-05 | 2008-12-11 | 267d? | finish no earlier than 2008-12-11 | S4 | 1996.09h | 1996.09h | Rel-8 | Paolo | AoIP-CSoIP | PCG-21 | China Mobile, Ericsson | SP-40 |  | AoIP-CSoIP |

Notes:
- 3021: Linked to Feature UID_20029 (RANimp)
- 3022: RP#46 completed. Testing for UID_360013 / Impacted TSs and TRs: 34.108, 34.121-1, 34.121-2, 34.123-1, 34.123-2 / WI rapporteur e-mail: leif.mattisson@ericsson.com
- 3023: RP#45 completed. Testing for UID_370036 / Impacted TSs and TRs: 34.108, 34.123-1, 34.123-2, 34.123-3 / WI rapporteur e-mail: leif.mattisson@ericsson.com
- 3024: RP#49 completed. Testing for Rel-7 UID_340039 Improved L2 support for high data rates and Rel-8 UID_370036 Improved L2 for uplink / Impacted TSs and TRs: 34.108, 34.123-1, 34.123-2, 34.123-3 / WI rapporteur e-mail: Xiaozhong Chen (chenxiaozhong@datangmobile.cn)
- 3025: RP#44 completed. Testing for UID_380075 / Impacted TSs and TRs: 34.108, 34.122, 34.123-1, 34.123-2, 34.123-3 / WI rapporteur e-mail: ma.zijiang@zte.com.cn
- 3026: RP#48 completed. Testing for UID_400052 / Impacted TSs and TRs: 34.108, 34.121-1, 34.121-2, 34.123-1, 34.123-2, 34.123-3 / WI rapporteur e-mail: Shubhang Vora (svora@qualcomm.com)
- 3027: RP#48 completed. Testing for UID_370037 / Impacted TSs and TRs: 34.108, 34.121-1, 34.121-2, 34.123-1, 34.123-2, 34.123-3 / WI rapporteur e-mail: jarkko.hellsten@nokia.com
- 3028: RP#46 completed. Testing for Receiver Type3i in 25.101 UE radio Tx and Rx FDD / Impacted TSs and TRs: 34.108, 34.121-1, 34.121-2 / WI rapporteur e-mail: Ashok Kumar Narayanaswamy (anarayan@qualcomm.com)
- 3029: RP#49 completed. Testing for UID_380076 / Impacted TSs and TRs: 34.108, 34.123-1, 34.123-2, 34.123-3 / WI rapporteur e-mail: Xiaozhong Chen (chenxiaozhong@datangmobile.cn)
- 3030: RP#49 completed. Testing for UID_390028 / Impacted TSs and TRs: 34.108, 34.123-1, 34.123-2, 34.123-3 / WI rapporteur e-mail: huang.he4@zte.com.cn
- 3031: PR#48 completed. Testing for UID_400050 / Impacted TSs and TRs: 34.108, 34.122, 34.123-1, 34.123-2, 34.123-3 / WI rapporteur e-mail: huang.chun2@zte.com.cn
- 3032: RP#47 completed. Testing for UID_390030 / Impacted TSs and TRs: 34.108, 34.121-1, 34.121-2, 34.123-1, 34.123-2, 34.123-3 / WI rapporteur e-mail: Shubhang Vora (svora@qualcomm.com)
- 3033: RP#42 completed. WID updated RP-070493=>RP-081124 (changed WI title "MBSFN Downlink Optimized Broadcast (DOB) 3.84 Mcps TDD" => "3.84Mcps TDD MBSFN Integrated Mobile Broadcast"). / Impacted TSs and TRs: 25.102, 25.105, 25.123, 25.201, 25.221, 25.222, 25.223, 25.224, 25.304, 25.306, 25.331, 25.346, 25.402, 25.433 / WI rapporteur e-mail: Lars.Lindbom@ericsson.com
- 3034: RP#47 completed. Testing for Rel-8 MBSFN-DOB UID_360008 / Impacted TSs and TRs: 34.108, 34.122, 34.123-1, 34.123-2, 34.123-3 / WI rapporteur e-mail: Phil Young (pyoung@ipwireless.com)
- 3035: GP#41 completed. GP#52 completed MS conformance testing / Impacted TSs and TRs: 44.018, 44.060, 45.002, 45.008, 45.010, 48.008, 48.018, 51.010 / WI rapporteur e-mail: sergio.parolari@nsn.com, vlora.rexhepi@nokia.com
- 3036: GP#41 completed / Impacted TSs and TRs: 43.055, 43.129, 43.246, 45.002, 45.008, 45.010 / WI rapporteur e-mail: sergio.parolari@nsn.com, vlora.rexhepi@nokia.com
- 3037: GP#41 completed / Impacted TSs and TRs: 44.018, 44.060, 48.008, 48.018 / WI rapporteur e-mail: sergio.parolari@nsn.com, vlora.rexhepi@nokia.com
- 3038: - / Impacted TSs and TRs: 24.008 / WI rapporteur e-mail: sergio.parolari@nsn.com, vlora.rexhepi@nokia.com
- 3039: GP#52 completed / Impacted TSs and TRs: 51.010 / WI rapporteur e-mail: deepa.kamath@renesasmobile.com
- 3040: GP#36 completed U-TDOA (Uplink Time Difference of Arrival) / Impacted TSs and TRs: 43.059, 45.008, 48.071 / WI rapporteur e-mail: Terry Brooks (terri.brooks@trueposition.com)
- 3041: GP#37 completed. GP#43 completed Testing / WI rapporteur e-mail: mohammed.versi@t-mobile.com
- 3042: GP#37 completed / Impacted TSs and TRs: 43.318, 44.318 / WI rapporteur e-mail: mohammed.versi@t-mobile.com
- 3043: GP#43 completed / Impacted TSs and TRs: 51.010 / WI rapporteur e-mail: mohammed.versi@t-mobile.com
- 3044: GP#40/TSG#42 completed . Triggered by TR 43.903 Study on A-interface over IP (AINTIP) UID_50589. / WI rapporteur e-mail: wangshuaiyu@chinamobile.com, paul.schliwa-bertling@ericsson.com
- 3045: GP#40 completed. GP#39 updated WID GP-080901=>GP-081362. / Impacted TSs and TRs: 48.001, 48.002, 48.008, 48.020, 49.008, 48.103 / WI rapporteur e-mail: wangshuaiyu@chinamobile.com, paul.schliwa-bertling@ericsson.com
- 3046: SP#42 completed / Impacted TSs and TRs: 26.102, 26.103, 26.202 / WI rapporteur e-mail: Karl.Hellwig@Ericsson.com

| ID | WBS | Task | Type | Duration | Start | Finish | Complete | Baseline start | Baseline finish | Baseline duration | Constraint | Resources | Work | Actual work | Acronym | PCG approved | WI rapporteur name | Release | TSG approved | MCC resp | Acronym_3GU_Export | Impacted TSs and TRs | Status Report | TSG stopped | Special Focus Doc | PCG stopped |
| --- | --- | --- | --- | --- | --- | --- | --- | --- | --- | --- | --- | --- | --- | --- | --- | --- | --- | --- | --- | --- | --- | --- | --- | --- | --- | --- |
| 3047 | 761.3 | **Core Network Impacts for A-Interface User Plane over IP** |  | 136d? | 2008-05-30 A | 2008-12-05 A | 100% | 2008-05-30 | 2008-12-05 | 136d? |  | C4; C1; C3 | 5440h | 5440h | AoIP-CN | PCG-21 | Ericsson | Rel-8 | CP-40 | Kimmo | AoIP-CN |  |  |  |  |  |
| 3048 | 761.3.1 | CT4 part of Core Network Impacts for A-Interface User Plane over IP |  | 136d? | 2008-05-30 A | 2008-12-05 A | 100% | 2008-05-30 | 2008-12-05 | 136d? | start no earlier than 2008-05-30 | C4 | 1088h | 1088h | AoIP-CN | PCG-21 | Ericsson | Rel-8 | CP-40 | Kimmo |  | 23.205, 23.153, 23.231, 29.232 |  |  |  |  |
| 3049 | 761.3.2 | CT1 part of Core Network Impacts for A-Interface User Plane over IP |  | 68d? | 2008-05-30 A | 2008-12-05 A | 100% | 2008-05-30 | 2008-12-05 | 68d? | finish no earlier than 2008-12-05 | C1 | 544h | 544h | AoIP-CN | PCG-21 | Ericsson | Rel-8 | CP-40 | Frederic |  | 23.009 |  |  |  |  |
| 3050 | 761.3.3 | CT3 part of Core Network Impacts for A-Interface User Plane over IP |  | 68d? | 2008-05-30 A | 2008-12-05 A | 100% | 2008-05-30 | 2008-12-05 | 68d? | finish no earlier than 2008-12-05 | C3 | 544h | 544h | AoIP-CN | PCG-21 | Ericsson | Rel-8 | CP-40 | Adrian |  | 29.007 |  |  |  |  |
| 3051 | 762 | New multicarrier BTS class |  | 261d? | 2007-08-31 A | 2008-08-29 A | 100% | 2007-08-31 | 2008-08-29 | 261d? | finish no earlier than 2008-08-29 | G1 | 2088h | 2088h | MCBTS |  | Alcatel-Lucent | Rel-8 |  | Paolo | MCBTS | 45.005, 45.050, 51.021 |  |  |  |  |
| 3052 | 763 | **Support for Additional Navigation Satellite Systems (ANSS) for LCS** |  | 150d? | 2008-05-16 A | 2008-12-11 A | 100% | 2008-05-16 | 2008-12-11 | 150d? |  | S1; G2; R2 | 5784h | 5784h | ANSS |  | Qualcomm | Rel-8 |  | Paolo | ANSS |  |  |  |  |  |
| 3053 | 763.1 | Stage 1 for ANSS for LCS |  | 1d? | 2008-12-11 A | 2008-12-11 A | 100% | 2008-12-11 | 2008-12-11 | 1d? | start no earlier than 2008-12-11 | S1 | 8h | 8h | ANSS | PCG-22 |  | Rel-8 | SP-42 | Alain |  | 22.071 |  |  |  |  |
| 3054 | 763.2 | GERAN2 part of Support for Additional Navigation Satellite Systems (ANSS) for LCS |  | 136d? | 2008-05-16 A | 2008-11-21 A | 100% | 2008-05-16 | 2008-11-21 | 136d? | start no earlier than 2008-05-16 | G2 | 1088h | 1088h | ANSS |  | Qualcomm | Rel-8 |  | Paolo |  | 43.059, 44.031, 49.031, 44.071, 48.031, 51.010 |  |  |  |  |
| 3055 | 763.3 | RAN2 part of Support for Additional Navigation Satellite Systems (ANSS) for LCS |  | 136d? | 2008-05-30 A | 2008-12-05 A | 100% | 2008-05-30 | 2008-12-05 | 136d? | finish no earlier than 2008-12-08 | R2 | 1088h | 1088h | RANimp-ANSS | PCG-21 | Qualcomm | Rel-8 | RP-40 | Yong-Jun | RANimp-ANSS | 25.305, 25.306, 25.331, 25.413, 25.423, 25.433, 25.453 | RP-080813 |  |  |  |
| 3056 | 764 | **Conformance testing for the Latency Reductions feature** |  | 532d? | 2008-02-22 A | 2010-03-05 A | 100% | 2008-02-22 | 2010-03-05 | 532d? |  | G1; G3new | 14848h | 14848h | CTLATRED | PCG-21 | Ericsson | Rel-8 |  | Paolo | CTLATRED |  |  |  |  |  |
| 3057 | 764.1 | MS conformance testing for the Latency Reductions feature |  | 532d? | 2008-02-22 A | 2010-03-05 A | 100% | 2008-02-22 | 2010-03-05 | 532d? | finish no earlier than 2010-03-05 | G3new | 4248h | 4248h | CTLATRED-MStest | PCG-21 | Ericsson | Rel-8 |  | Ingbert | CTLATRED-MStest | 51.010 |  |  |  |  |
| 3058 | 764.2 | BTS conformance testing for the Latency Reductions feature |  | 261d? | 2008-02-22 A | 2009-02-20 A | 100% | 2008-02-22 | 2009-02-20 | 261d? | finish no earlier than 2009-02-20 | G1 | 2088h | 2088h | CTLATRED-BTStest | PCG-21 | Ericsson | Rel-8 |  | Paolo | CTLATRED-BTStest | 51.021 |  |  |  |  |
| 3059 | 765 | MS conformance testing of changes introduced by WI "Support of Packet-switched Handover for GERAN A/Gb mode" |  | 196d? | 2008-02-22 A | 2008-11-21 A | 100% | 2008-02-22 | 2008-11-21 | 196d? | finish no earlier than 2008-11-21 | G3new | 1568h | 1568h | PSHCT-MStest | PCG-21 | Rohde & Schwarz | Rel-8 |  | Ingbert | PSHCT-MStest | 51.010 |  |  |  |  |
| 3060 | 766 | (Small) Technical Enhancements and Improvements for Rel-8 |  | 509d? | 2007-01-01 A | 2008-12-11 A | 100% | 2007-01-01 | 2008-12-11 | 509d? | finish no earlier than 2008-12-11 | SP; CP; RP; GP | 16288h | 16288h | TEI8 |  |  | Rel-8 |  | All | TEI8 |  |  |  |  |  |
| 3061 | 767 | (IETF) (Small) Technical Enhancements and Improvements for Rel-8 |  | 650d? | 2007-01-01 A | 2012-09-07 A | 100% | 2007-01-01 | 2012-09-07 | 650d? | finish no earlier than 2012-09-07 | C1-IETF | 5200h | 5200h | TEI8_IETF | PCG-27 | christer.holmberg@ericsson.com | Rel-8 | CP-52 | Frederic | TEI8_IETF | RFC 6714 (was draft-ietf-simple-msrp-cema) |  |  |  |  |
| 3062 | 768 | Test - (Small) Technical Enhancements and Improvements for Rel-8 |  | 993.6d? | 2007-03-07 A | 2010-12-24 A | 100% | 2007-03-07 | 2010-12-24 | 993.6d? | finish no earlier than 2010-12-24 | R5; G3new | 15897.6h | 15897.6h | TEI8_Test | PCG-21 |  | Rel-8 | RP-40 | Ingbert | TEI8_Test |  |  |  |  |  |
| 3063 | 769 | **Deleted - All-IP Network** |  | 448d? | 2004-06-28 A | 2006-03-15 A | 100% | 2004-06-28 | 2006-03-15 | 448d? |  | S1 | 7168h | 7168h | AIPN |  | NTT DoCoMo | Rel-8 |  | Alain | AIPN |  |  | SP-38 |  |  |
| 3064 | 769.1 | Deleted - Stage 1 |  | 448d? | 2004-06-28 A | 2006-03-15 A | 100% | 2004-06-28 | 2006-03-15 | 448d? | finish no earlier than 2006-03-15 | S1 | 3584h | 3584h | AIPN |  | NTT DoCoMo | Rel-8 |  | Alain |  | 22.258 |  | SP-38 |  |  |
| 3065 | 770 | Deleted - was Rel-7 - LCS for 3GPP Interworking WLAN | milestone | 0d? | 2007-09-28 A | 2007-09-28 A | 100% | 2007-09-28 | 2007-09-28 | 0d? | start no earlier than 2007-09-28 | S2 |  |  | LCS4_IWLAN |  | LG Electronics | Rel-8 |  | Maurice | LCS4_IWLAN | 23.234, 23.271, 23.167 |  | SP-35 | WLAN |  |
| 3066 | 771 | Deleted - never approved- FBI Phase 2 | milestone | 0d | 2007-09-28 A | 2007-09-28 A | 100% | 2007-09-28 | 2007-09-28 | 0d | start no earlier than 2007-09-28 | S2 |  |  | FBI2 |  | Nokia Siemens Networks | Rel-8 |  | Maurice | FBI2 |  |  | SP-38 |  |  |
| 3067 | 772 | Deleted -Enhancements to BS30 Bearer service for Videotelephony | milestone | 0d? | 2007-03-15 A | 2007-03-15 A | 100% | 2007-03-15 | 2007-03-15 | 0d? | finish no earlier than 2007-03-15 | S1 |  |  | BS30 |  |  | Rel-8 |  | Alain | BS30 | 22.002, 22.004, 22.101, 22.105, 24.008 |  | SP-38 |  |  |
| 3068 | 773 | Deleted - IMS Enhancements Rel-8 |  | 75d? | 2007-09-03 A | 2007-12-14 A | 100% | 2007-09-03 | 2007-12-14 | 75d? |  | S1 | 600h | 600h | IMS8 |  | Telecom Italia | Rel-8 | SP-37 | Alain | IMS8 |  |  | SP-38 |  |  |
| 3069 | 774 | **Deleted - Contact Manager Conformance Test specifications** |  | 471d? | 2008-06-02 A | 2010-03-19 A | 100% | 2008-06-02 | 2010-03-19 | 471d? |  | C6 | 11304h | 11304h | eUPHBOOK-Test | PCG-21 | Comprion, Gemalto | Rel-8 | CP-40 | Xavier | eUPHBOOK-Test |  |  | CP-47 |  | PCG-24 |
| 3070 | 774.1 | Deleted - Contact Manager for 3GPP UICC applications test specifications |  | 471d? | 2008-06-02 A | 2010-03-19 A | 100% | 2008-06-02 | 2010-03-19 | 471d? | finish no earlier than 2010-03-19 | C6 | 3768h | 3768h | eUPHBOOK-Test | PCG-21 | Comprion | Rel-8 | CP-40 | Xavier |  | 31.320 (external interface for communication with the ME) |  | CP-47 |  | PCG-24 |
| 3071 | 774.2 | Deleted - Contact Manager API for Java™ Card test specification |  | 471d? | 2008-06-02 A | 2010-03-19 A | 100% | 2008-06-02 | 2010-03-19 | 471d? | finish no earlier than 2010-03-19 | C6 | 3768h | 3768h | eUPHBOOK-Test | PCG-21 | Gemalto | Rel-8 | CP-40 | Xavier |  | 31.321 (internal interface (API)) |  | CP-47 |  | PCG-24 |
| 3072 | 775 | Deleted - MS conformance testing of Support of Conversational Services in A/Gb mode via the PS domain |  | 401d? | 2008-02-25 A | 2009-09-04 A | 100% | 2008-02-25 | 2009-09-04 | 401d? | finish no earlier than 2009-09-04 | G3new | 3208h | 3208h | SCSAGBCT-MStest | PCG-21 | Nokia | Rel-8 |  | Ingbert | SCSAGBCT-MStest | 51.010 |  | GP-43 |  | PCG-23 |
| 3073 | 776 | Release 8 Studies | milestone | 0d? | 2005-10-07 A | 2005-10-07 A | 100% | 2005-10-07 | 2010-11-12 | 1332d? | start no earlier than 2000-01-03 | CP; GP; RP; SP |  |  |  |  |  | Rel-8 |  | All |  |  |  |  |  |  |
| 3074 | 777 | Study on Customised Alerting Tone (CAT) Requirements |  | 245d? | 2005-10-07 A | 2006-09-14 A | 100% | 2005-10-07 | 2006-09-14 | 245d? | start no earlier than 2005-10-07 | S1 | 1960h | 1960h | FS_CAT |  | China Mobile | Rel-8 |  | Alain | FS_CAT | 22.982 |  |  |  |  |
| 3075 | 778 | Study on Facilitating Machine to Machine Communication in GSM and UMTS (M2M) |  | 350d? | 2005-11-04 A | 2007-03-08 A | 100% | 2005-11-04 | 2007-03-08 | 350d? | finish no earlier than 2006-06-16 | S1 | 2800h | 2800h | FS_M2M |  | Siemens | Rel-8 |  | Alain | FS_M2M | 22.868 |  |  | MTC, M2M |  |
| 3076 | 779 | Study on Network Composition |  | 526d? | 2005-12-07 A | 2007-12-12 A | 100% | 2005-12-07 | 2007-12-12 | 526d? | finish no earlier than 2006-09-27 | S1 | 4208h | 4208h | FS_NetComp |  | Nokia Siemens Networks | Rel-8 |  | Alain | FS_NetComp | 22.980 |  |  |  |  |
| 3077 | 780 | Study on Requirements of IMS Multimedia Conferencing |  | 330d? | 2006-06-08 A | 2007-09-12 A | 100% | 2006-06-08 | 2007-09-12 | 330d? | finish no earlier than 2007-03-21 | S1 | 2640h | 2640h | FS_IMSconf |  | China Mobile | Rel-8 |  | Alain | FS_IMSconf | 22.948 |  |  |  |  |
| 3078 | 781 | Study on support of a Public Warning System |  | 140d? | 2007-09-03 A | 2008-03-14 A | 100% | 2007-09-03 | 2008-03-14 | 140d? |  | S1 | 1120h | 1120h | FS_PWS |  | T-Mobile | Rel-8 |  | Alain | FS_PWS | 22.968 |  |  | Public Safety (I-A) |  |
| 3079 | 782 | Study on Paging Permission with Access Control |  | 256d? | 2006-09-28 A | 2007-09-20 A | 100% | 2006-09-28 | 2007-09-20 | 256d? | finish no earlier than 2007-09-20 | S1 | 2048h | 2048h | FS_PPAC |  | NTT DoCoMo | Rel-8 |  | Alain | FS_PPAC | 22.908 |  |  |  |  |
| 3080 | 783 | Study on Non-3GPP access Network Selection Principles (NSP) |  | 392d? | 2006-12-06 A | 2008-06-05 A | 100% | 2006-12-06 | 2008-06-05 | 392d? | finish no earlier than 2007-11-19 | S1 | 3136h | 3136h | FS_N3GtoNSP |  | Telefónica O2 | Rel-8 |  | Alain | FS_N3GtoNSP | 22.912 |  |  |  |  |
| 3081 | 784 | Study on Value Added Services for Short Message Service |  | 263d? | 2006-12-06 A | 2007-12-07 A | 100% | 2006-12-06 | 2007-12-07 | 263d? | finish no earlier than 2007-12-07 | S1 | 2104h | 2104h | FS_VAS4SMS |  | China Mobile | Rel-8 |  | Alain | FS_VAS4SMS | 22.942 |  |  |  |  |
| 3082 | 785 | Study on Service continuity between mobile and WLAN networks |  | 262d? | 2006-12-06 A | 2007-12-06 A | 100% | 2006-12-06 | 2007-12-06 | 262d? | finish no earlier than 2008-12-25 | S1 | 2096h | 2096h | FS_SMLSWLAN |  | NEC | Rel-8 |  | Alain | FS_SMLSWLAN | 22.937 |  |  | WLAN |  |
| 3083 | 786 | Study on Services Alignment and Migration |  | 331d? | 2006-12-06 A | 2008-03-12 A | 100% | 2006-12-06 | 2008-03-12 | 331d? | finish no earlier than 2007-09-20 | S1 | 2648h | 2648h | FS_ServAl |  | Telefónica O2 | Rel-8 | SP-37 | Alain | FS_ServAl | 22.983 |  |  |  |  |

Notes:
- 3047: CP#42 completed. Updated WID CP-080278=>CP-080722 / WI rapporteur e-mail: philip.hodges@ericsson.com
- 3048: CP#42 completed. Updated WID CP-080278=>CP-080722 / WI rapporteur e-mail: philip.hodges@ericsson.com
- 3049: CP#42 completed. Updated WID CP-080278=>CP-080722 / WI rapporteur e-mail: philip.hodges@ericsson.com
- 3050: CP#42 completed. Updated WID CP-080278=>CP-080722 / WI rapporteur e-mail: philip.hodges@ericsson.com
- 3051: GP#39 completed / WI rapporteur e-mail: thomas.bitzer@alcatel-lucent.de
- 3052: GP#40 completed / WI rapporteur e-mail: Mungal Dhanda
- 3053: SP#42 completed by 22.071 CR0077
- 3054: GP#40 completed / WI rapporteur e-mail: Mungal Dhanda
- 3055: RP#42 WI closed at 95%. Considers Rel-9 performance requirements / WI rapporteur e-mail: Etienne Chaponniere (echaponn@qualcomm.com)
- 3056: GP#45 completed / WI rapporteur e-mail: mats.y.samuelsson@ericsson.com, hakan.e.grunditz@ericsson.com
- 3057: GP#45 completed / WI rapporteur e-mail: hakan.e.grunditz@ericsson.com
- 3058: GP#41 completed / WI rapporteur e-mail: mats.y.samuelsson@ericsson.com
- 3059: GP#40 completed / WI rapporteur e-mail: Franz.Segerer@ROHDE-SCHWARZ.COM
- 3060: SP#42 completed
- 3061: CP#57 completed / WI rapporteur e-mail: christer.holmberg@ericsson.com
- 3062: -
- 3063: SP#38 stopped. 25/07/08 Moved UID_31059 Study on All-IP Network (FS_AIPN/was AIPFS) to Rel-7 out of the stopped Rel-8 Feature UID_31067 Deleted - All-IP Network (AIPN) / WI rapporteur e-mail: c.masyu@nttdocomo.co.jp
- 3064: 22.258 withdrawn, superseded by 22.278 (UID 320022). SP#38 stopped / WI rapporteur e-mail: c.masyu@nttdocomo.co.jp
- 3065: SP#35 stopped / WI rapporteur e-mail: dhshim@lge.com
- 3066: SP#38 stopped
- 3067: SP#38 stopped (no support) / WI rapporteur e-mail: andre.jarvis@three.co.uk
- 3068: SP#38 stopped
- 3069: CP#47 work stopped/abandoned / WI rapporteur e-mail: Udo Willenbrink, Jacques Seif
- 3070: CP#47 work stopped/abandoned / WI rapporteur e-mail: Udo Willenbrink (uwillenbrink@comprion.com )
- 3071: CP#47 work stopped/abandoned / WI rapporteur e-mail: jacques.seif@gemalto.com
- 3072: GP#43 work stopped/abandoned (completion 0%) / WI rapporteur e-mail: arsi.heino@nokia.com
- 3073: -
- 3074: Spin-off Rel-8 Feature Customized Alerting Tone (CAT) Service UID_340029 / WI rapporteur e-mail: Qing Huang (huangqing@chinamobile.com)
- 3075: SP#35 completed. Spin-off SA3 Study on Security Aspects of Remote Provisioning and Change of Subscription for M2M (UID_370053). SP#40 Spin-off new Feature UID_410030 (NIMTC) / WI rapporteur e-mail: Juergen Merkel
- 3076: SP#38 completed / WI rapporteur e-mail: joerg.swetina@neclab.eu
- 3077: SP#37 completed. Spin-off New Feature UID_370026 Value-Added Services for Short Message Service (VAS4SMS) / WI rapporteur e-mail: Qing Huang (huangqing@chinamobile.com)
- 3078: SP#39 completed. Spin-off Rel-9 Feature UID_380057 (PWS) / WI rapporteur e-mail: mark.younge@t-mobile.com
- 3079: SP#37 completed. Spin-off new Feature UID_370084 (PPACR) / WI rapporteur e-mail: Katsuhiro NOGUCHI (noguchi@nttdocomo.co.jp)
- 3080: SP#38 completed. Spin-off New Feature UID_380062 (N3GTONSP). SP#40 WID updated SP-060930=>SP-080318. TR re-approved with new # 22.812=>22.912 / WI rapporteur e-mail: chris.friel@O2.com
- 3081: SP#38 completed. Spin-off New Feature UID_370026 (VAS4SM) / WI rapporteur e-mail: Qing Huang (huangqing@chinamobile.com)
- 3082: SP#38 completed / WI rapporteur e-mail: joerg.swetina@neclab.eu
- 3083: SP#39 completed. Spin-off Rel-9 Feature UID_330017 Services Alignment and Migration (ServAl) / WI rapporteur e-mail: chris.friel@O2.com

| ID | WBS | Task | Duration | Start | Finish | Complete | Baseline start | Baseline finish | Baseline duration | Constraint | Resources | Work | Actual work | Acronym | WI rapporteur name | WI rapporteur e-mail | Release | MCC resp | Acronym_3GU_Export | Impacted TSs and TRs | PCG approved | TSG approved | Special Focus Doc | Status Report | PCG stopped | TSG stopped |
| --- | --- | --- | --- | --- | --- | --- | --- | --- | --- | --- | --- | --- | --- | --- | --- | --- | --- | --- | --- | --- | --- | --- | --- | --- | --- | --- |
| 3084 | 787 | **Study on 3GPP System Architecture Evolution** | 1115d? | 2004-12-03 A | 2009-03-12 A | 100% | 2004-12-03 | 2009-03-12 | 1115d? |  | S2; S3 | 34064h | 34064h | FS_SAE | Vodafone | chris.pudney@vodafone.com | Rel-8 | Maurice | FS_SAE |  |  |  |  |  |  |  |
| 3085 | 787.1 | Stage 2 Interim conclusion for RAN Work to start | 990d? | 2004-12-03 A | 2008-09-18 A | 100% | 2004-12-03 | 2008-09-18 | 990d? | finish no earlier than 2005-09-23 | S2 | 7920h | 7920h | FS_SAE | Vodafone | chris.pudney@vodafone.com | Rel-8 | Maurice |  | 23.882 |  |  |  |  |  |  |
| 3086 | 787.2 | Stage 2 study on 3GPP architectural development | 704d? | 2006-01-09 A | 2008-09-18 A | 100% | 2006-01-09 | 2008-09-18 | 704d? | finish no earlier than 2007-09-28 | S2 | 5632h | 5632h | FS_SAE | Vodafone | chris.pudney@vodafone.com | Rel-8 | Maurice |  | 23.882 |  |  |  |  |  |  |
| 3087 | 787.3 | Security study for Inter-access mobility between non-3GPP and 3GPP system | 334d? | 2007-09-03 A | 2009-03-12 A | 100% | 2007-09-03 | 2009-03-12 | 334d? | finish no earlier than 2009-03-12 | S3 | 2672h | 2672h | FS_SAE | Nokia | dajiang.zhang@nokia.com | Rel-8 | Mirko |  | 33.821, 33.822 |  |  |  |  |  |  |
| 3088 | 788 | Study on Stage 2 aspects of IMS Service Brokering | 589d? | 2006-06-19 A | 2008-09-18 A | 100% | 2006-06-19 | 2008-09-18 | 589d? | finish no earlier than 2008-09-18 | S2 | 4712h | 4712h | FS_ISB_ST2 | Telcordia | raquel@research.telcordia.com | Rel-8 | Maurice | FS_ISB_ST2 | 23.810 |  |  |  |  |  |  |
| 3089 | 789 | Study on IMS utilizing multicast bearer services | 447d? | 2006-03-22 A | 2007-12-06 A | 100% | 2006-03-22 | 2007-12-06 | 447d? | finish no earlier than 2007-12-03 | S2 | 3576h | 3576h | FS_MLTICAST-IMS | Nokia Siemens Networks |  | Rel-8 | Maurice | FS_MLTICAST-IMS | 23.847 |  |  |  |  |  |  |
| 3090 | 790 | Study on Multimedia Session Continuity | 291d? | 2007-04-26 A | 2008-06-05 A | 100% | 2007-04-26 | 2008-06-05 | 291d? | finish no earlier than 2008-06-05 | S2 | 2328h | 2328h | FS_MMSC | LG Electronics |  | Rel-8 | Maurice | FS_MMSC | 23.893 |  |  |  |  |  |  |
| 3091 | 791 | **Study on centralized IMS service control** | 363d? | 2006-10-23 A | 2008-03-12 A | 100% | 2006-10-23 | 2008-03-12 | 363d? |  | S2; S1 | 10856h | 10856h | FS_ICS | Ericsson | peter.bleckert@ericsson.com | Rel-8 | Alain | FS_ICS |  | PCG-21 | SP-38 |  |  |  |  |
| 3092 | 791.1 | Study on centralized IMS services requirements | 268d? | 2007-03-05 A | 2008-03-12 A | 100% | 2007-03-05 | 2008-03-12 | 268d? | start no earlier than 2007-03-05 | S1 | 2144h | 2144h | FS_ICS-S1 | NEC | joerg.swetina@neclab.eu | Rel-8 | Alain | FS_ICS-S1 | 22.892 |  | SP-37 |  |  |  |  |
| 3093 | 791.2 | Study on centralized IMS services control | 363d? | 2006-10-23 A | 2008-03-12 A | 100% | 2006-10-23 | 2008-03-12 | 363d? | finish no earlier than 2008-02-21 | S2 | 2904h | 2904h | FS_IMS_CSC | Alcatel-Lucent | andy.bennett@alcatel-lucent.com | Rel-8 | Maurice | FS_IMS_CSC | 23.892 |  |  |  |  |  |  |
| 3094 | 792 | Study on Architecture of IMS based Customized Alerting Tone (CAT) | 208d? | 2007-12-04 A | 2008-09-18 A | 100% | 2007-12-04 | 2008-09-18 | 208d? | finish no earlier than 2008-09-08 | S2 | 1664h | 1664h | FS_CAT-St2 | China Mobile | WANG, Jing (wangjing@chinamobilecom) | Rel-8 | Maurice | FS_CAT-St2 | 23.872 | PCG-21 | SP-38 |  |  |  |  |
| 3095 | 793 | Study on Home (e)NodeB Security | 321d? | 2007-12-20 A | 2009-03-12 A | 100% | 2007-12-20 | 2009-03-12 | 321d? | finish no earlier than 2009-03-10 | S3 | 2568h | 2568h | FS_HNB_Sec | Huawei | yangyanmei@huawei.com | Rel-8 | Mirko | FS_HNB_Sec | 33.820 | PCG-21 | SP-38 | HNB |  |  |  |
| 3096 | 794 | Study on Transferring of emergency call data – in-band modem solution | 265d? | 2006-12-07 A | 2007-12-12 A | 100% | 2006-12-07 | 2007-12-12 | 265d? | finish no earlier than 2008-09-18 | S4 | 2120h | 2120h | eCALLIBMS | Airbiquity | lhong@airbiquity.com | Rel-8 | Paolo | eCALLIBMS | 26.967 |  |  | Public Safety (I-A) |  |  |  |
| 3097 | 795 | Study on Element Operations Systems Function (EOSF) definition | 266d? | 2007-06-07 A | 2008-06-12 A | 100% | 2007-06-07 | 2008-06-12 | 266d? | finish no earlier than 2008-12-11 | S5 | 2128h | 2128h | OAM7-NIM-EOSF | China Mobile | Li Jian (lijian@chinamobile.com) | Rel-8 | Mirko | OAM7-NIM-EOSF | 32.819 |  |  |  |  |  |  |
| 3098 | 796 | Study on SA5 MTOSI XML Harmonization | 351d? | 2006-05-10 A | 2007-09-12 A | 100% | 2006-05-10 | 2007-09-12 | 351d? | finish no earlier than 2007-12-14 | S5 | 2808h | 2808h | OAM8-NIM-XML | Nortel | jduguay@nortel.com | Rel-8 | Mirko | OAM8-NIM-XML | 32.818 |  |  |  |  |  |  |
| 3099 | 797 | Study on Common Profile Storage (CPS) Framework of User Data for network services and management | 244d? | 2006-07-03 A | 2007-06-07 A | 100% | 2006-07-03 | 2007-06-07 | 244d? | finish no earlier than 2007-06-07 | S5 | 1952h | 1952h | OAM7-CPS | T-Mobile | istvan.aba@t-mobile.at | Rel-8 | Mirko | OAM7-CPS | 32.808 |  |  |  |  |  |  |
| 3100 | 798 | Study on Management for LTE and SAE | 526d? | 2006-12-07 A | 2008-12-11 A | 100% | 2006-12-07 | 2008-12-11 | 526d? | finish no earlier than 2008-12-11 | S5 | 4208h | 4208h | FS_OAM_LTE_SAE | Ericsson | robert.petersen@ericsson.com | Rel-8 | Mirko | FS_OAM_LTE_SAE | 32.816 |  |  |  |  |  |  |
| 3101 | 799 | Study on Charging Aspects of 3GPP System Evolution | 179d? | 2007-04-02 A | 2007-12-06 A | 100% | 2007-04-02 | 2007-12-06 | 179d? | finish no earlier than 2007-12-06 | S5 | 1432h | 1432h | FS_SAEcharg | Nokia Siemens Networks | Gerald.Goermer@nsn.com | Rel-8 | Mirko | FS_SAEcharg | 32.820 |  |  |  |  |  |  |
| 3102 | 800 | Study on AS-MRFC media server control protocol | 583d? | 2006-03-22 A | 2008-06-13 A | 100% | 2006-03-22 | 2008-06-13 | 583d? | finish no earlier than 2008-06-13 | C1 | 4664h | 4664h | MRFC | Hewlett-Packard | mark.syrett@hp.com | Rel-8 | Frederic | MRFC | 24.880 |  |  |  |  |  |  |
| 3103 | 801 | Study on IMS Restoration Procedures | 310d? | 2007-03-26 A | 2008-05-30 A | 100% | 2007-03-26 | 2008-05-30 | 310d? | finish no earlier than 2008-05-30 | C4 | 2480h | 2480h | FS_IMS_RP | Ericsson | german.blanco@ericsson.com | Rel-8 | Kimmo | FS_IMS_RP | 23.820 |  |  |  |  |  |  |
| 3104 | 802 | Study on IMS Application Server Service Data Descriptions for AS interoperability | 261d? | 2007-09-14 A | 2008-09-12 A | 100% | 2007-09-14 | 2008-09-12 | 261d? | finish no earlier than 2008-09-12 | C4 | 2088h | 2088h | FS_IMS_ASIO | Alcatel-Lucent | Jean-Jacques Trottin | Rel-8 | Kimmo | FS_IMS_ASIO | 29.864 |  |  |  |  |  |  |
| 3105 | 803 | Study on Customized Alerting Tone (CAT) solution for voice and video call in CS domain | 261d? | 2007-09-14 A | 2008-09-12 A | 100% | 2007-09-14 | 2008-09-12 | 261d? |  | C4 | 626.4h | 626.4h | FS_CAT_VVC_CS | China Mobile | zhanghao@chinamobile.com | Rel-8 | Kimmo | FS_CAT_VVC_CS | 29.882 |  |  |  |  |  |  |
| 3106 | 804 | Study on InterWorking Function between MAP based and Diameter based interfaces | 266d? | 2007-11-30 A | 2008-12-05 A | 100% | 2007-11-30 | 2008-12-05 | 266d? | finish no earlier than 2008-12-05 | C4 | 2128h | 2128h | FS_MAP2Diam | Huawei | liming49985@huawei.com | Rel-8 | Kimmo | FS_MAP2Diam | 29.805 | PCG-21 | CP-38 |  |  |  |  |
| 3107 | 805 | Study on Scope of future HSPA Evolution for 1.28 Mcps TDD | 186d? | 2007-09-14 A | 2008-05-30 A | 100% | 2007-09-14 | 2008-05-30 | 186d? | finish no earlier than 2008-05-30 | R1 | 1488h | 1488h | FS_RAN-LCRTDDHSPAEvo | RITT | Xu Fei | Rel-8 | Patrick | FS_RAN-LCRTDDHSPAEvo | 25.824 |  | RP-37 |  | RP-080290 |  |  |
| 3108 | 806 | Study on Synchronized E-DCH for UTRA FDD | 126d? | 2007-09-14 A | 2008-03-07 A | 100% | 2007-09-14 | 2008-03-07 | 126d? | finish no earlier than 2008-03-14 | R1 | 1008h | 1008h | FS_RAN-UplinkSync | Nokia Siemens Networks | Karri.Ranta-aho@nsn.com | Rel-8 | Patrick | FS_RAN-UplinkSync | 25.823 |  | RP-37 |  | RP-080068 |  |  |
| 3109 | 807 | Study on Improved network controlled mobility between LTE and 3GPP2/mobile WiMAX radio technologies | 131d? | 2007-06-04 A | 2007-12-03 A | 100% | 2007-06-04 | 2007-12-03 | 131d? | finish no earlier than 2007-12-03 | R4 | 1048h | 1048h | FS_RAN-LTEmob | Motorola | hao.bi@Motorola.com | Rel-8 | Issam | FS_RAN-LTEmob | 36.938 |  |  |  | RP-070827 |  |  |
| 3110 | 808 | Study on 3G Home NodeB/eNodeB | 325d? | 2007-03-05 A | 2008-05-30 A | 100% | 2007-03-05 | 2008-05-30 | 325d? | finish no earlier than 2008-05-30 | R4 | 2600h | 2600h | FS_RAN-HNBeNB | Motorola | howard.thomas@motorola.com | Rel-8 | Issam | FS_RAN-HNBeNB | 25.820 |  |  | HNB | RP-080289 |  |  |
| 3111 | 809 | Study on A-interface over IP | 126d? | 2007-08-31 A | 2008-02-22 A | 100% | 2007-08-31 | 2008-02-22 | 126d? | finish no earlier than 2008-02-22 | GP | 1008h | 1008h | AINTIP | China Mobile, Ericsson | paul.schliwa-bertling@ericsson.com | Rel-8 | Paolo | AINTIP | 43.903 |  |  |  |  |  |  |
| 3112 | 810 | Study on Multi-User Reusing-One-Slot | 782d? | 2007-11-16 A | 2010-11-12 A | 100% | 2007-11-16 | 2010-11-12 | 782d? | finish no earlier than 2010-11-12 | GP | 6248h | 6248h | MUROS | Nokia Siemens Networks | juergen.hofmann@nsn.com | Rel-8 | Paolo | MUROS | 45.914 |  |  |  |  |  |  |
| 3113 | 811 | Study on Optimized Transmit Pulse Shape for Downlink EGPRS2-B | 657d? | 2007-11-16 A | 2010-05-21 A | 100% | 2007-11-16 | 2010-05-21 | 657d? | finish no earlier than 2010-05-27 | G1 | 5248.44h | 5248.44h | WIDER | Research In Motion, Nokia Siemens Networks | jdwyer@RIM.COM and eddie.riddington@nsn.com | Rel-8 | Paolo | WIDER | 45.913 |  |  |  |  |  |  |
| 3114 | 812 | Deleted - Study on Mobility between 3GPP-WLAN Interworking and 3GPP Systems | 393d? | 2007-03-20 A | 2008-09-18 A | 100% | 2007-03-20 | 2008-09-18 | 393d? | finish no earlier than 2008-09-18 | S2 | 3144h | 3144h | FS_SM3GWLAN | Orange |  | Rel-8 | Maurice | FS_SM3GWLAN | withdrawn 23.827 |  |  | WLAN |  | PCG-21 | SP-41 |
| 3115 | 813 | Deleted - equals 340035 -FS on Service continuity between mobile and WLAN networks | 75d? | 2007-09-03 A | 2007-12-14 A | 100% | 2007-09-03 | 2007-12-14 | 75d? | finish no earlier than 2007-12-14 | S1 | 600h | 600h | FSSCMobToW | BT | mike.meyerstein@bt.com | Rel-8 | Alain | FSSCMobToW | 22.937 |  | SP-37 |  |  | PCG-21 | SP-39 |
| 3116 | 814 | Deleted - Study on Evaluation of LCS Control Plane Solution for EPS | 100d? | 2008-01-14 A | 2008-05-30 A | 100% | 2008-01-14 | 2008-05-30 | 100d? | finish no earlier than 2009-03-20 | S2 | 800h | 800h | FS_LCS_EPS | SiRF |  | Rel-8 | Maurice | FS_LCS_EPS | 23.891 |  | SP-38 |  |  | PCG-21 | SP-40 |
| 3117 | 815 | Deleted - Study on HS-PDSCH serving cell change enhancements | 60d? | 2007-12-17 A | 2008-03-07 A | 100% | 2007-12-17 | 2008-03-07 | 60d? | finish no earlier than 2008-06-12 | R4 | 480h | 480h | FS_RAN-HSPDSCH | Qualcomm |  | Rel-8 | Issam | FS_RAN-HSPDSCH | none | PCG-21 | RP-38 |  | RP-080070 | PCG-21 | RP-39 |
| 3118 | 816 | Deleted - Study on Dual-Cell HSDPA operation | 261d? | 2007-08-15 A | 2009-03-06 A | 100% | 2007-08-15 | 2009-03-06 | 261d? | finish no earlier than 2009-03-06 | R1 | 2088h | 2088h | FS_RAN-DCHS | Qualcomm | Josef Blanz | Rel-8 | Patrick | FS_RAN-DCHS | withdrawn 25.825 v100 | PCG-21 | RP-39 |  | RP-090066 | PCG-22 | RP-43 |
| 3119 | 817 | Release 7 Features | 679d? | 2005-05-02 A | 2007-12-06 A | 100% | 2005-05-02 | 2007-12-06 | 679d? | start no earlier than 2000-01-01 | CP; GP; RP; SP | 21728h | 21728h |  |  |  | Rel-7 | All |  |  |  |  |  |  |  |  |

Notes:
- 3084: SP#43 completed
- 3085: SP#41 completed
- 3086: SP#41 completed
- 3087: SP#43 completed
- 3088: SP#41 completed. No spin-off activity proposed. [Note: IMS Service Brokering enhancements UID_31088 moved back from R8 to R7 to give a home to 22228CR0036_(Rel-7)_S1-051232. Hence, Rel-7 ISB has Stage 1 only (and is misaligned with Rel-7 Stages 2/3.]
- 3089: SP#38 completed
- 3090: SP#40 completed
- 3091: SP#39 completed
- 3092: SP#39 completed
- 3093: SP#39 completed
- 3094: SP#41 completed as Rel-8
- 3095: SP#43 completed. Linked to RAN4 Study on 3G Home NodeB/eNodeB (UID_350039) and to SA5 Study on Self-Organizing Networks (SON) related OAM interfaces for Home NodeB (UID_360007)
- 3096: SP#38 completed. Spin-off WID UID_34042 (eCall_Phase2)
- 3097: SP#40 completed. WID updated SP-050608=>SP-070307
- 3098: SP#37 completed. WID updated SP-050295=>SP-070305
- 3099: SP#36 completed. Spin-off New Feature UID_400034 User Data Convergence (UDC)
- 3100: SP#42 completed
- 3101: SP#38 completed
- 3102: CP#40 completed. Spin-off New Feature UID_380035 (MRFC_TS)
- 3103: CP#40 completed. Spin-off WID UID_400012 (IMS_RP)
- 3104: CP#41 completed. Linked to SA5 Study on Common Profile Storage framework UID_320006. Spin-off WID UID_410003 (IMS_ASIO)
- 3105: CP#41 completed. Spin-off WID under Feature CAT UID_340029
- 3106: CP#42 completed. Spin-off implementation Building Block UID_410007 (MAP2Diam) under the SAES Feature UID_320005
- 3107: RP#40 completed
- 3108: RP#39 completed
- 3109: RP#38 completed
- 3110: RP#40 completed
- 3111: GP#37 completed. Spin-off implementation Feature AoIP (A-interface over IP) UID_50591
- 3112: GP#48 completed as Rel-8. Spin-off implementation WI UID_420002 VAMOS (Voice services over Adaptive Multi-user channels on One Slot)
- 3113: GP#46 completed
- 3114: SP#41 stopped. Draft TR 23.827 content implemented in TS 23.327.
- 3115: SP#39 stopped
- 3116: SP#40 spin-off Feature UID_400038 (LCS_CPS_EPS). SP#40 FS stopped
- 3117: RP#39 stopped (no TR produced). Spin-off HS-DSCH Serving Cell Change Enhancements (UID_39003)
- 3118: RP#43 stopped (draft TR 25.825 v100 withdrawn). Conclusions in RP-090318 (RAN1 findings of the UTRA Multi-Carrier Evolution study). RP#42 New WI approved on Dual-Cell HSDPA operation on adjacent carriers (UID_400052)
- 3119: -

| ID | WBS | Task | Type | Duration | Start | Finish | Complete | Baseline start | Baseline finish | Baseline duration | Constraint | Resources | Work | Actual work | Acronym | WI rapporteur name | WI rapporteur e-mail | Release | MCC resp | Acronym_3GU_Export | TSG stopped | Status Report | TSG approved | PCG approved | Special Focus Doc |
| --- | --- | --- | --- | --- | --- | --- | --- | --- | --- | --- | --- | --- | --- | --- | --- | --- | --- | --- | --- | --- | --- | --- | --- | --- | --- |
| 3120 | 818 | **Identification of Communication Services in IMS** |  | 620d? | 2005-05-02 A | 2007-09-14 A | 100% | 2005-05-02 | 2007-09-14 | 620d? |  | S2; S1; C1; S5 | 29048h | 29048h | ServID | Ericsson | stephen.terrill@ericsson.com | Rel-7 | Maurice | ServID |  |  |  |  |  |
| 3121 | 818.1 | TR on ServID |  | 232d? | 2005-05-02 A | 2006-03-21 A | 100% | 2005-05-02 | 2006-03-21 | 232d? | finish no earlier than 2006-03-20 | S2 | 1856h | 1856h | ServID | Ericsson | stephen.terrill@ericsson.com | Rel-7 | Maurice |  |  |  |  |  |  |
| 3122 | 818.2 | Stage 1,2 of ServID |  | 144d? | 2005-11-11 A | 2006-05-31 A | 100% | 2005-11-11 | 2006-05-31 | 144d? | start no earlier than 2005-11-11 | S1; S2 | 2304h | 2304h | ServID | Ericsson | stephen.terrill@ericsson.com | Rel-7 | Maurice |  |  |  |  |  |  |
| 3123 | 818.3 | Stage 3 of ServID |  | 250d? | 2006-03-31 A | 2007-03-15 A | 100% | 2006-03-31 | 2007-03-15 | 250d? | finish no earlier than 2007-03-15 | C1 | 2000h | 2000h | ServID | Ericsson | christer.holmberg@ericsson.com | Rel-7 | Frederic |  |  |  |  |  |  |
| 3124 | 818.4 | Charging of ServID |  | 381d? | 2006-03-31 A | 2007-09-14 A | 100% | 2006-03-31 | 2007-09-14 | 381d? | finish no earlier than 2007-09-14 | S5 | 3048h | 3048h | ServID | Orange | alain.bibas@orange-ft.com | Rel-7 | Mirko |  |  |  |  |  |  |
| 3125 | 819 | **Supporting Globally Routable User Agent URIs in IMS** |  | 415d? | 2005-11-14 A | 2007-06-15 A | 100% | 2005-11-14 | 2007-06-15 | 415d? |  | S2; S1; C1 | 14920h | 14920h | GRUU | Research In Motion | Adrian Buckley (abuckley@rim.com) | Rel-7 | Maurice | GRUU |  |  |  |  |  |
| 3126 | 819.1 | Deleted - TR on GRUU |  | 219d? | 2005-11-14 A | 2006-09-14 A | 100% | 2005-11-14 | 2006-09-14 | 219d? | finish no earlier than 2006-09-14 | S2 | 1752h | 1752h | GRUU | Research In Motion | Adrian Buckley (abuckley@rim.com) | Rel-7 | Maurice |  | SP-32 |  |  |  |  |
| 3127 | 819.2 | Stage 1,2 of GRUU |  | 65d? | 2006-07-03 A | 2006-09-29 A | 100% | 2006-07-03 | 2006-09-29 | 65d? | start no earlier than 2006-07-03 | S1; S2 | 1040h | 1040h | GRUU | Research In Motion | Adrian Buckley (abuckley@rim.com) | Rel-7 | Maurice |  |  |  |  |  |  |
| 3128 | 819.3 | Stage 3 of GRUU |  | 271d? | 2006-06-02 A | 2007-06-15 A | 100% | 2006-06-02 | 2007-06-15 | 271d? | finish no earlier than 2007-06-15 | C1 | 2168h | 2168h | GRUU | CableLabs | Bernie McKibben (b.mckibben@cablelabs.com) | Rel-7 | Frederic |  |  |  |  |  |  |
| 3129 | 820 | **Multimedia Telephony Service for IMS** |  | 357d? | 2006-02-01 A | 2007-06-15 A | 100% | 2006-02-01 | 2007-06-15 | 357d? |  | S1; C1; S4 | 14688h | 14688h | MTSI | Ericsson | peter.bleckert@ericsson.com | Rel-7 | Alain | MTSI |  |  |  |  |  |
| 3130 | 820.1 | Stage 1 of MTSI |  | 173d? | 2006-02-01 A | 2006-09-29 A | 100% | 2006-02-01 | 2006-09-29 | 173d? | start no earlier than 2006-02-01 | S1 | 1384h | 1384h | MTSI-REQ | Ericsson | peter.bleckert@ericsson.com | Rel-7 | Alain | MTSI-REQ |  |  |  |  |  |
| 3131 | 820.2 | Stage 3 of MTSI |  | 330d? | 2006-03-10 A | 2007-06-14 A | 100% | 2006-03-10 | 2007-06-14 | 330d? | finish no earlier than 2007-06-15 | C1 | 2640h | 2640h | MTSI | Ericsson | christer.holmberg@ericsson.com | Rel-7 | Frederic | MTSI |  |  |  |  |  |
| 3132 | 820.3 | Media handling and interaction in MTSI |  | 262d? | 2006-03-15 A | 2007-03-15 A | 100% | 2006-03-15 | 2007-03-15 | 262d? | finish no earlier than 2007-03-15 | S4 | 2096h | 2096h | MTSI-MHI | Ericsson | olle.franceschi@ericsson.com | Rel-7 | Paolo | MTSI-MHI |  |  |  |  |  |
| 3133 | 820.4 | Deleted - duplicates UID7039 - IMS Multimedia Telephony Service | milestone | 0d? | 2007-06-15 A | 2007-06-15 A | 100% | 2007-06-15 | 2007-06-15 | 0d? | start no earlier than 2007-06-15 | S1 |  |  | MMTEL | Ericsson | peter.bleckert@ericsson.com | Rel-7 | Alain | MMTEL | SP-32 |  |  |  |  |
| 3134 | 821 | Multimedia Telephony Service for IMS (MTSI) - UE Conformance Testing |  | 387d | 2007-09-19 A | 2009-03-12 A | 100% | 2007-09-19 | 2009-03-12 | 387d | finish no earlier than 2009-03-13 | R5 | 1664h | 1664h | MTSI-UEConTest | Ericsson, Motorola | Leif.Mattisson@ericsson.com, Jacob.John@motorola.com | Rel-7 | Ingbert | MTSI-UEConTest |  | RP-090056 |  |  |  |
| 3135 | 822 | TISPAN requirements for Multimedia Telephony with PSTN/ISDN simulation services |  | 58d? | 2007-09-18 A | 2007-12-06 A | 100% | 2007-09-18 | 2007-12-06 | 58d? | start no earlier than 2007-09-18 | S1 | 464h | 464h | TMMTEL7 |  |  | Rel-7 | Alain | TMMTEL7 |  |  | SP-37 |  |  |
| 3136 | 823 | **Maintenance of TISPAN release 1 common IMS** |  | 180d? | 2007-07-02 A | 2008-03-07 A | 100% | 2007-07-02 | 2008-03-07 | 180d? |  | S2 | 5808h | 5808h | MCIMSTR1 | Ericsson | Raymond Forbes | Rel-7 | Maurice | MCIMSTR1 |  |  | SP-38 | PCG-21 |  |
| 3137 | 823.1 | SA1 aspects of MCIMSTR1 |  | 58d? | 2007-09-18 A | 2007-12-06 A | 100% | 2007-09-18 | 2007-12-06 | 58d? | finish no earlier than 2007-12-06 | S1 | 464h | 464h | MCIMSTR1-S1 | Telecom Italia | Marco.DeLuca1@telecomitalia.it | Rel-7 | Alain | MCIMSTR1-S1 |  |  | SP-38 | PCG-21 |  |
| 3138 | 823.2 | SA2 aspects of MCIMSTR1 |  | 58d? | 2007-09-18 A | 2007-12-06 A | 100% | 2007-09-18 | 2007-12-06 | 58d? | finish no earlier than 2007-12-06 | S2 | 464h | 464h | MCIMSTR1-S2 | Ericsson | Raymond Forbes | Rel-7 | Maurice | MCIMSTR1-S2 |  |  | SP-38 | PCG-21 |  |
| 3139 | 823.3 | SA1,SA2 part of Maintenance of TISPAN release 1 common IMS |  | 114d? | 2007-07-02 A | 2007-12-06 A | 100% | 2007-07-02 | 2007-12-06 | 114d? | finish no earlier than 2007-12-06 | S2; S1 | 1824h | 1824h | IMS_Comm_Mtce7 | BT, Ericsson | Dick Knight, Raymond Forbes | Rel-7 | Maurice | IMS_Comm_Mtce7 |  |  | SP-38 | PCG-21 |  |
| 3140 | 823.4 | Maintenance of TISPAN R1 |  | 86d? | 2007-11-09 A | 2008-03-07 A | 100% | 2007-11-09 | 2008-03-07 | 86d? | start no earlier than 2007-11-09 | C1; C3; C4 | 2064h | 2064h | MAINT_R1 | Alcatel-Lucent | Keith Drage (drage@alcatel-lucent.com) | Rel-7 | Frederic | MAINT_R1 |  |  | CP-38 | PCG-21 |  |
| 3141 | 824 | **PS domain and IMS impacts for supporting IMS Emergency calls (EMC1)** |  | 2934d? | 2000-09-18 A | 2011-12-09 A | 100% | 2000-09-18 | 2011-12-09 | 2934d? |  | S2; S1; C1; C4; IETF | 185422h | 185422h | EMC1 | Siemens | Rainer Liebhart | Rel-7 | Maurice | EMC1 |  |  |  |  | Public Safety (I-A) |
| 3142 | 10.1.1 | Service Requirements for IP-based emergency calls |  | 985d | 2000-09-18 A | 2004-06-25 A | 100% | 2000-09-18 | 2004-06-25 | 985d | finish no earlier than 2004-06-25 | S1 | 7880h | 7880h | EMC1 | Siemens | Rainer Liebhart | Rel-7 | Alain |  |  |  |  |  | Public Safety (I-A) |
| 3143 | 824.2 | Study on Stage 2 for IMS-level solution |  | 668d? | 2003-02-26 A | 2005-09-16 A | 100% | 2003-02-26 | 2005-09-16 | 668d? | finish no earlier than 2005-09-16 | S2 | 5344h | 5344h | EMC1 | Siemens | Rainer Liebhart | Rel-7 | Maurice |  |  |  |  |  | Public Safety (I-A) |
| 3144 | 824.3 | Study on Stage 2 for GPRS-level solution |  | 301d? | 2004-10-14 A | 2005-12-08 A | 100% | 2004-10-14 | 2005-12-08 | 301d? | finish no earlier than 2005-12-08 | S2 | 2408h | 2408h | EMC1 | Siemens | Rainer Liebhart | Rel-7 | Maurice |  |  |  |  |  | Public Safety (I-A) |
| 3145 | 824.4 | Stage 2 Specification Phase - IMS-level |  | 200d? | 2005-09-05 A | 2006-06-09 A | 100% | 2005-09-05 | 2006-06-09 | 200d? | finish no earlier than 2006-06-09 | S2 | 1600h | 1600h | EMC1 | Siemens | Rainer Liebhart | Rel-7 | Maurice |  |  |  |  |  | Public Safety (I-A) |
| 3146 | 824.5 | Deleted - Stage 2 Specification Phase - GPRS-level | milestone | 0d? | 2007-03-02 A | 2007-03-02 A | 100% | 2007-03-02 | 2007-03-02 | 0d? | start no earlier than 2007-03-02 | S2 |  |  | EMC1 | Siemens | Rainer Liebhart | Rel-7 | Maurice |  | SP-32 |  |  |  | Public Safety (I-A) |

Notes:
- 3120: WID approved SP#28. WID updated SP#32
- 3121: - / Impacted TSs and TRs: 23.816
- 3122: - / Impacted TSs and TRs: 22.228, 23.228, 23.203
- 3123: CP#32 approved WID / Impacted TSs and TRs: 23.218, 24.229
- 3124: - / Impacted TSs and TRs: 32.260, 32.298, 32.299
- 3125: SP#29 approved WID
- 3126: Abandoned
- 3127: SP#29 approved WID / Impacted TSs and TRs: 22.228, 23.228, 23.218, 24.229
- 3128: CP#32 approved WID / Impacted TSs and TRs: 24.229
- 3129: -
- 3130: - / Impacted TSs and TRs: 22.173
- 3131: - / Impacted TSs and TRs: 24.173
- 3132: - / Impacted TSs and TRs: 26.114
- 3133: - / Impacted TSs and TRs: 22.173
- 3134: RP#43 completed. Linked UID_7038 (MTSI) / Impacted TSs and TRs: 34.123-1, 34.123-2, 34.123-3, 34.229-1, 34.229-2
- 3135: - / Impacted TSs and TRs: 22.273 (EI 181 002 maintenance)
- 3136: - / Impacted TSs and TRs: http://www.3gpp.org/specs/TISPAN-IMS-ansfer.htm
- 3137: - / Impacted TSs and TRs: 22.173, 22.273
- 3138: - / Impacted TSs and TRs: 23.406, 23.417, 23.508,23.509, 23.511
- 3139: SP#38 completed / Impacted TSs and TRs: 22.173, 22.273, 22.401, 23.406, 23.417, 23.508, 23.509, 23.511
- 3140: CP#39 completed / Impacted TSs and TRs: 24.404, 24.405, 24.406, 24.407, 24.408, 24.410, 24.411, 24.416, 29.421, 24.423, 24.428, 24.429, 29.433, 24.441, 24.403, 29.427, 24.430, 29.412
- 3141: - / Impacted TSs and TRs: EMC1
- 3142: - / Impacted TSs and TRs: 22.101
- 3143: - / Impacted TSs and TRs: 23.867
- 3144: - / Impacted TSs and TRs: 23.867
- 3145: - / Impacted TSs and TRs: 23.060, 23.167, 23.203, 23.221, 23.228, 23.234, 23.271, 23.406
- 3146: -

| ID | WBS | Task | Type | Duration | Start | Finish | Complete | Baseline start | Baseline finish | Baseline duration | Constraint | Resources | Work | Actual work | Acronym | WI rapporteur name | WI rapporteur e-mail | Release | MCC resp | Special Focus Doc | Impacted TSs and TRs | PCG approved | TSG approved | TSG stopped | Acronym_3GU_Export | Created at | Status Report |
| --- | --- | --- | --- | --- | --- | --- | --- | --- | --- | --- | --- | --- | --- | --- | --- | --- | --- | --- | --- | --- | --- | --- | --- | --- | --- | --- | --- |
| 3147 | 10.1 | **Emergency Call Enhancements for IP& PS Based Calls – stage 3** |  | 1549d? | 2006-01-09 A | 2011-12-09 A | 100% | 2006-01-09 | 2011-12-09 | 1549d? |  | C1; C4; IETF | 50829.8h | 50829.8h | EMC1 | Ericsson | alf.heidermark@ericsson.com | Rel-7 | Frederic | Public Safety (I-A) |  |  |  |  |  |  |  |
| 3148 | 10.1.2 | CT1 IMS aspects to support IMS Emergency sessions |  | 350.82d | 2006-01-09 A | 2007-06-15 A | 100% | 2006-01-09 | 2007-06-15 | 350.82d | finish no earlier than 2007-06-15 | C1 | 2806.57h | 2806.57h | EMC1 | Ericsson | alf.heidermark@ericsson.com | Rel-7 | Frederic | Public Safety (I-A) | 24.229 |  |  |  |  |  |  |
| 3149 | 824.6.2 | (IETF) CT1 IMS aspects to support IMS Emergency sessions |  | 452d? | 2006-01-09 A | 2011-12-09 A | 100% | 2006-01-09 | 2011-12-09 | 452d? | finish no earlier than 2011-12-09 | C1-IETF | 3608h | 3608h | EMC1 | Keith Drage |  | Rel-7 | Frederic | Public Safety (I-A) | RFC 6442 (was draft-ietf-sipcore-location-conveyance) | PCG-27 | CP-52 |  |  |  |  |
| 3150 | 10.1.2 | Deleted - CT3 IMS aspects to support IMS Emergency sessions |  | 95d | 2006-05-08 A | 2006-09-15 A | 100% | 2006-05-08 | 2006-09-15 | 95d | finish no earlier than 2006-09-15 | C3 | 760h | 760h | EMC1 | Ericsson | alf.heidermark@ericsson.com | Rel-7 | Adrian | Public Safety (I-A) | 29.163 |  |  | CP-33 |  |  |  |
| 3151 | 10.1.5 | Deleted - CT3 PS domain aspects to support IMS Emergency sessions |  | 95d | 2006-05-08 A | 2006-09-15 A | 100% | 2006-05-08 | 2006-09-15 | 95d | start no earlier than 2006-05-08 | C3 | 760h | 760h | EMC1 | Ericsson | alf.heidermark@ericsson.com | Rel-7 | Adrian | Public Safety (I-A) | 29.061 |  |  | CP-33 |  |  |  |
| 3152 | 10.1.5 | CT1 PS domain aspects to support IMS Emergency sessions |  | 349.9d | 2006-01-09 A | 2007-06-15 A | 100% | 2006-01-09 | 2007-06-15 | 349.9d | finish no earlier than 2007-06-15 | C1 | 2799.2h | 2799.2h | EMC1 | Ericsson | alf.heidermark@ericsson.com | Rel-7 | Frederic | Public Safety (I-A) | 24.008, 24.234 |  |  |  |  |  |  |
| 3153 | 10.1.5 | CT4 PS domain aspects to support IMS Emergency sessions |  | 365d | 2006-01-09 A | 2007-06-01 A | 100% | 2006-01-09 | 2007-06-01 | 365d | finish no earlier than 2007-06-01 | C4 | 2920h | 2920h | EMC1-GPRSc4 | Ericsson | alf.heidermark@ericsson.com | Rel-7 | Kimmo | Public Safety (I-A) | 29.060 |  |  |  | EMC1-GPRSc4 |  |  |
| 3154 | 825 | IMS Support of Conferencing |  | 355d? | 2005-11-04 A | 2007-03-15 A | 100% | 2005-11-04 | 2007-03-15 | 355d? | finish no earlier than 2007-03-15 | C1 | 2840h | 2840h | IMSconf | Alcatel-Lucent | Keith Drage (drage@alcatel-lucent.com) | Rel-7 | Frederic |  | 24.147, 24.229 |  |  |  | IMSconf |  |  |
| 3155 | 826 | Performance Characterization of VoIMS over HSDPA\EUL channels |  | 713d? | 2005-03-15 A | 2007-12-06 A | 100% | 2005-03-15 | 2007-12-06 | 713d? | finish no earlier than 2007-12-06 | S4 | 5704h | 5704h | VoIMS-PCVoIMS | Alcatel-Lucent | mcgowan@alcatel-lucent.com | Rel-7 | Paolo |  | 26.935 |  |  |  | VoIMS-PCVoIMS |  |  |
| 3156 | 827 | **WLAN-UMTS Interworking Phase 2** |  | 371d? | 2004-01-05 A | 2005-06-07 A | 100% | 2004-01-05 | 2005-06-07 | 371d? |  | S1; S2 | 6856h | 6856h | WLAN2 | Telenor | frederic.paint@telenor.com | Rel-7 | Alain | WLAN | 33.234 (SP-36 SA3 CRs approved) |  |  |  | WLAN2, WLAN-SC |  |  |
| 3157 | 827.1 | Stage 1 on Session Continuity |  | 115d? | 2004-01-05 A | 2004-06-11 A | 100% | 2004-01-05 | 2004-06-11 | 115d? | start no earlier than 2004-01-05 | S1 | 920h | 920h | WLAN2 |  |  | Rel-7 | Alain | WLAN | 22.234 |  |  |  |  | SP-24 |  |
| 3158 | 827.2 | Stage 2 on Session Continuity: covered by SAE | milestone | 0d? | 2005-06-07 A | 2005-06-07 A | 100% | 2005-06-07 | 2005-06-07 | 0d? | finish no earlier than 2005-06-07 | S2 |  |  | WLAN2 |  |  | Rel-7 | Maurice | WLAN |  |  |  |  |  |  |  |
| 3159 | 828 | **WLAN Interworking – Private Network access from WLAN 3GPP IP Access** |  | 252d? | 2005-10-10 A | 2006-09-26 A | 100% | 2005-10-10 | 2006-09-26 | 252d? |  | S2; C1; C3; C4 | 17704h | 17704h | WLANPNA | NEC | Toshiyuki Tamura (tamurato@aj.jp.nec.com) | Rel-7 | Maurice | WLAN |  |  |  |  | WLANPNA |  |  |
| 3160 | 828.1 | WLAN-PNA - Stage 2 |  | 185d? | 2005-10-10 A | 2006-06-23 A | 100% | 2005-10-10 | 2006-06-23 | 185d? | start no earlier than 2005-10-10 | S2 | 1480h | 1480h | WLANPNA-st2 | NEC | Toshiyuki Tamura (tamurato@aj.jp.nec.com) | Rel-7 | Maurice | WLAN | 23.234, 33.234 |  |  |  | WLANPNA-st2 |  |  |
| 3161 | 828.2 | **WLAN-PNA - Stage 3** |  | 170d? | 2006-02-01 A | 2006-09-26 A | 100% | 2006-02-01 | 2006-09-26 | 170d? |  | C1; C3; C4 | 8160h | 8160h | WLANPNA-st3 | NEC |  | Rel-7 | Frederic | WLAN |  |  |  |  | WLANPNA-st3 |  |  |
| 3162 | 828.2.1 | CT1 aspets for WLAN-PNA |  | 170d? | 2006-02-01 A | 2006-09-26 A | 100% | 2006-02-01 | 2006-09-26 | 170d? | start no earlier than 2006-02-01 | C1 | 1360h | 1360h | WLANPNA-st3 | NEC |  | Rel-7 | Frederic | WLAN | 24.234 |  |  |  |  |  |  |
| 3163 | 828.2.2 | CT3 aspets for WLAN-PNA |  | 170d? | 2006-02-01 A | 2006-09-26 A | 100% | 2006-02-01 | 2006-09-26 | 170d? | start no earlier than 2006-02-01 | C3 | 1360h | 1360h | WLANPNA-st3 | NEC |  | Rel-7 | Adrian | WLAN | 29.161 |  |  |  |  |  |  |
| 3164 | 828.2.3 | Deleted - CT4 aspets for WLAN-PNA |  | 170d? | 2006-02-01 A | 2006-09-26 A | 100% | 2006-02-01 | 2006-09-26 | 170d? | start no earlier than 2006-02-01 | C4 | 1360h | 1360h | WLANPNA-st3 | NEC |  | Rel-7 | Kimmo | WLAN | 29.234 |  |  | CP-32 |  |  |  |
| 3165 | 829 | **Enhancements to support QoS provisioning over 3GPP/WLAN Interworking** |  | 520d? | 2005-03-14 A | 2007-03-09 A | 100% | 2005-03-14 | 2007-03-09 | 520d? |  | S2; C4; C1 | 16680h | 16680h | WLANQOS | Samsung |  | Rel-7 | Maurice | WLAN |  |  |  |  | WLANQOS |  |  |
| 3166 | 829.1 | Deleted - TR on support of QoS on WLAN |  | 232d? | 2005-03-14 A | 2006-01-31 A | 100% | 2005-03-14 | 2006-01-31 | 232d? | start no earlier than 2005-03-14 | S2 | 1856h | 1856h | WLANQOS | Samsung |  | Rel-7 | Maurice | WLAN | 23.836 |  |  | SP-32 |  |  |  |
| 3167 | 829.2 | Stage 2 on support of QoS over 3GPP/WLAN interworking |  | 108d? | 2006-02-01 A | 2006-06-30 A | 100% | 2006-02-01 | 2006-06-30 | 108d? | start no earlier than 2006-02-01 | S2 | 864h | 864h | WLANQOS | Samsung |  | Rel-7 | Maurice | WLAN | 23.234 |  |  |  |  |  |  |
| 3168 | 829.3 | Stage 3 CT4 on support of QoS over 3GPP/WLAN Interworking |  | 121d? | 2006-09-22 A | 2007-03-09 A | 100% | 2006-09-22 | 2007-03-09 | 121d? | finish no earlier than 2007-03-09 | C4 | 968h | 968h | WLANQOS | Huawei | zhang.peng@huawei.com | Rel-7 | Kimmo | WLAN | 29.234, 23.008 |  |  |  |  |  |  |
| 3169 | 829.4 | Stage 3 CT1 on support of QoS over 3GPP/WLAN Interworking |  | 64d? | 2006-09-04 A | 2006-11-30 A | 100% | 2006-09-04 | 2006-11-30 | 64d? | finish no earlier than 2006-11-30 | C1 | 512h | 512h | WLANQOS | Huawei | zhang.peng@huawei.com | Rel-7 | Frederic | WLAN | 24.234 |  |  |  |  |  |  |
| 3170 | 830 | **Location Services enhancements** |  | 906d? | 2004-06-28 A | 2007-12-17 A | 100% | 2004-06-28 | 2007-12-17 | 906d? |  | S1; S2; GP; C4; R2 | 81525.6h | 81525.6h | LCS3 |  |  | Rel-7 | Alain |  |  |  |  |  | LCS3 |  |  |
| 3171 | 830.1 | Stage 2 for LCS3 (including IMS emergency location aspects) |  | 446d? | 2004-12-31 A | 2006-09-15 A | 100% | 2004-12-31 | 2006-09-15 | 446d? | finish no earlier than 2006-09-15 | S2 | 3568h | 3568h | LCS3 | SiRF | brodilitz@sirf.com | Rel-7 | Maurice |  | 23.271 |  |  |  |  |  |  |
| 3172 | 830.2 | LCS Enhancements related to Location-Based Services |  | 695d? | 2005-01-03 A | 2007-08-31 A | 100% | 2005-01-03 | 2007-08-31 | 695d? | finish no earlier than 2007-08-31 | GP | 5560h | 5560h | LCS3-LBS | SiRF | kjudge@sirf.com | Rel-7 | Paolo |  | 43.059, 44.031, 48.008, 49.031 |  |  |  | LCS3-LBS |  |  |
| 3173 | 830.3 | CT4 aspects for LCS UEPos-LBS |  | 240d? | 2006-01-02 A | 2006-12-01 A | 100% | 2006-01-02 | 2006-12-01 | 240d? | finish no earlier than 2006-12-01 | C4 | 1920h | 1920h | LCS3-UEPos-LBS | SiRF | brodilitz@sirf.com | Rel-7 | Kimmo |  | 24.030, 24.080, 29.002 |  |  |  | LCS3-UEPos-LBS |  |  |
| 3174 | 830.4 | UE positioning - Velocity |  | 394d? | 2005-03-15 A | 2006-09-15 A | 100% | 2005-03-15 | 2006-09-15 | 394d? | finish no earlier than 2006-09-15 | R2 | 3152h | 3152h | LCS3-UEPos-Velocity | SiRF | BRodilitz@SiRF.com | Rel-7 | Yong-Jun |  | 25.305, 25.331, 25.410, 25.413, 25.453 |  |  |  | LCS3-UEPos-Velocity |  | RP-060459 |
| 3175 | 830.5 | Inclusion of Uplink TDOA UE positioning method in the UTRAN specifications |  | 849d? | 2004-09-15 A | 2007-12-17 A | 100% | 2004-09-15 | 2007-12-17 | 849d? | finish no earlier than 2007-12-17 | R2 | 6792h | 6792h | LCS3-UEPos-UTDOA | TruePosition | Robert Gross (rgross@polariswireless.com) | Rel-7 | Yong-Jun |  | 25.305, 25.453, new TS 25.111 |  |  |  | LCS3-UEPos-UTDOA |  | RP-070797 |

Notes:
- 3147: -
- 3148: -
- 3149: CP#54 completed
- 3150: Cancelled for Rel-7 and there is no corresponding Rel-8 WI
- 3151: Cancelled for Rel-7 and there is no corresponding Rel-8 WI
- 3152: -
- 3153: -
- 3154: CP#35 revised WID
- 3155: -
- 3156: Created at SP#27 because of WLAN items belonging to Rel-7. Acronym changed from "WLAN2, WLAN-SC"
- 3157: Acronym changed from "WLAN2, WLAN-SC"
- 3158: Acronym changed from "WLAN2, WLAN-SC"
- 3159: -
- 3160: Approved at SP#29
- 3161: Approved at CP#29
- 3162: Approved at CP#29
- 3163: Approved at CP#29
- 3164: CT4#31; no impacts identified, therefore completed. CP-32 stopped
- 3165: Moved from FS section Feb 06. SP-30 updated WID
- 3166: SP#32 stopped
- 3167: SP#30 updated WID
- 3168: CP#33 approved WID
- 3169: CP#33 approved WID
- 3170: -
- 3171: SP#27 approved WID
- 3172: -
- 3173: -
- 3174: -
- 3175: -

| ID | WBS | Task | Duration | Start | Finish | Complete | Baseline start | Baseline finish | Baseline duration | Constraint | Resources | Work | Actual work | Acronym | WI rapporteur name | WI rapporteur e-mail | Release | MCC resp | Special Focus Doc | Acronym_3GU_Export | TSG stopped | Status Report | PCG approved | TSG approved |
| --- | --- | --- | --- | --- | --- | --- | --- | --- | --- | --- | --- | --- | --- | --- | --- | --- | --- | --- | --- | --- | --- | --- | --- | --- |
| 3176 | 830.6 | **LCS for 3GPP Interworking WLAN** | 700d? | 2004-06-28 A | 2007-03-02 A | 100% | 2004-06-28 | 2007-03-02 | 700d? |  | S1; S2 | 17501.6h | 17501.6h | LCS3-IWLAN | Telcordia | Mike Loushine | Rel-7 | Alain | WLAN | LCS3-IWLAN |  |  |  |  |
| 3177 | 830.6.1 | FS on 3GPP system to WLAN Interworking with LCS | 512.7d? | 2004-06-28 A | 2006-06-30 A | 100% | 2004-06-28 | 2006-06-30 | 512.7d? | finish no earlier than 2005-09-29 | S1 | 4101.6h | 4101.6h | LCS3-IWLAN-FSs1 | Telcordia | Mike Loushine | Rel-7 | Alain |  | LCS3-IWLAN-FSs1 |  |  |  |  |
| 3178 | 830.6.2 | Deleted - Study of work on an LCS architecture for I-WLAN. | 180d? | 2006-06-26 A | 2007-03-02 A | 100% | 2006-06-26 | 2007-03-02 | 180d? | finish no earlier than 2007-03-02 | S2 | 1440h | 1440h | LCS3-IWLAN-FSs2 | LG Electronics | dhshim@lge.com ; phede@lge.com | Rel-7 | Maurice |  | LCS3-IWLAN-FSs2 | SP-35 |  |  |  |
| 3179 | 830.6.3 | Stage 2 for LCS architecture for I-WLAN | 95d? | 2006-10-23 A | 2007-03-02 A | 100% | 2006-10-23 | 2007-03-02 | 95d? | finish no earlier than 2007-03-02 | S2 | 760h | 760h | LCS3-IWLAN | LG Electronics | dhshim@lge.com ; phede@lge.com | Rel-7 | Maurice |  | LCS3-IWLAN |  |  |  |  |
| 3180 | 830.7 | Deleted - UE positioning Rel-7 | 849d? | 2004-09-15 A | 2007-12-17 A | 100% | 2004-09-15 | 2007-12-17 | 849d? |  | RP | 6792h | 6792h | LCS3-UEpos |  |  | Rel-7 | Yong-Jun |  | LCS3-UEpos | RP-38 |  |  |  |
| 3181 | 831 | **MBMS Enhancements** | 625d? | 2005-07-11 A | 2007-11-30 A | 100% | 2005-07-11 | 2007-11-30 | 625d? |  | S1; R1; C3 | 20844.6h | 20844.6h | MBMSE | China Mobile | liuhongyfw@chinamobile.com | Rel-7 | Alain |  | MBMSE |  |  |  |  |
| 3182 | 831.1 | Stage 1 of MBMSE | 109d? | 2005-07-11 A | 2005-12-08 A | 100% | 2005-07-11 | 2005-12-08 | 109d? | finish no earlier than 2005-12-08 | S1 | 872h | 872h | MBMSE | China Mobile | liuhongyfw@chinamobile.com | Rel-7 | Alain |  |  |  |  |  |  |
| 3183 | 831.2 | MBMS FDD Physical layer Enhancements | 117.29d? | 2006-12-15 A | 2007-06-04 A | 100% | 2006-12-15 | 2007-06-04 | 117.29d? | finish no earlier than 2007-06-04 | R1 | 938.32h | 938.32h | MBMSE-RANPhysFDD | Ericsson | Lars.Lindbom@ericsson.com | Rel-7 | Patrick |  | MBMSE-RANPhysFDD |  | RP-070290 |  |  |
| 3184 | 831.3 | MBMS TDD Physical layer Enhancements | 117.29d? | 2006-12-15 A | 2007-06-04 A | 100% | 2006-12-15 | 2007-06-04 | 117.29d? | finish no earlier than 2007-06-04 | R1 | 938.32h | 938.32h | MBMSE-RANPhysTDD | IPWireless | Nicholas Anderson | Rel-7 | Patrick |  | MBMSE-RANPhysTDD |  | RP-070291 |  |  |
| 3185 | 831.4 | MBMS Low Chip Rate TDD Physical Layer Enhancement | 127d? | 2007-03-16 A | 2007-09-10 A | 100% | 2007-03-16 | 2007-09-10 | 127d? | finish no earlier than 2007-09-10 | R1 | 1016h | 1016h | MBMSE-RANPhysLCRTDD | RITT | Lin Hui | Rel-7 | Patrick |  | MBMSE-RANPhysLCRTDD |  | RP-070292 |  |  |
| 3186 | 831.5 | MBMS Mz interface | 260d? | 2006-12-04 A | 2007-11-30 A | 100% | 2006-12-04 | 2007-11-30 | 260d? | finish no earlier than 2007-05-11 | C3 | 2080h | 2080h | MBMSMz | Huawei | Deng Tingting (ttdeng@huawei.com) | Rel-7 | Adrian |  | MBMSMz |  |  |  |  |
| 3187 | 832 | **MBMS - UE Conformance Testing** | 657d? | 2007-06-01 A | 2009-12-04 A | 100% | 2007-06-01 | 2009-12-04 | 657d? |  | R5 | 13848h | 13848h | MBMSE_UEConTest |  |  | Rel-7 | Ingbert |  | MBMSE_UEConTest |  |  | PCG-21 | SP-40 |
| 3188 | 832.1 | Conformance Test Aspects – MBMS TDD Physical layer Enhancements – MBSFN for HCR and VHCR TDD | 336d? | 2007-06-01 A | 2008-09-12 A | 100% | 2007-06-01 | 2008-09-12 | 336d? | start no earlier than 2007-06-01 | R5 | 2688h | 2688h | MBMSE-RANPhysTDD_UEConTest | IPWireless | tspeight@ipwireless.com | Rel-7 | Ingbert |  | MBMSE-RANPhysTDD_UEConTest |  | RP-080541 |  |  |
| 3189 | 832.2 | Conformance Test Aspects – MBMS LCR TDD Physical Layer Enhancement | 342d? | 2008-05-30 A | 2009-09-18 A | 100% | 2008-05-30 | 2009-09-18 | 342d? | finish no earlier than 2009-09-18 | R5 | 2728h | 2728h | MBMSE-RANPhysLCRTDD_UEConTest | CATT | chenxiaozhong@datangmobile.cn | Rel-7 | Ingbert |  | MBMSE-RANPhysLCRTDD_UEConTest |  | RP-090715 | PCG-21 | RP-40 |
| 3190 | 832.3 | Conformance Test Aspects – MBSFN for FDD | 397d? | 2008-05-30 A | 2009-12-04 A | 100% | 2008-05-30 | 2009-12-04 | 397d? | finish no earlier than 2009-12-04 | R5 | 3176h | 3176h | MBMSE-UEConTest_RANPhysFDD | Huawei | Xiang Li (trica_li@huawei.com) | Rel-7 | Ingbert |  | MBMSE-UEConTest_RANPhysFDD |  | RP-091214 | PCG-21 | RP-40 |
| 3191 | 833 | MBMS User Service Extensions | 392d? | 2005-12-07 A | 2007-06-07 A | 100% | 2005-12-07 | 2007-06-07 | 392d? | finish no earlier than 2007-06-07 | S4 | 3136h | 3136h | MBMSUSE | Ericsson | Thorsten.Lohmar@ericsson.com | Rel-7 | Paolo |  | MBMSUSE |  |  |  |  |
| 3192 | 834 | **Advanced Global Navigation Satellite System (AGNSS) concept** | 830d? | 2004-06-28 A | 2007-08-31 A | 100% | 2004-06-28 | 2007-08-31 | 830d? |  | S1; S2; GP; R2 | 36129.6h | 36129.6h | LCS3-AGNSS | Alcatel | Michel.monnerat@thalesaleniaspace.com | Rel-7 | Alain |  | LCS3-AGNSS |  |  |  |  |
| 3193 | 834.1 | Stage 1/2 for Towards AGNSS Concept | 1d? | 2007-02-16 A | 2007-02-16 A | 100% | 2007-02-16 | 2007-02-16 | 1d? | start no earlier than 2007-02-16 | S1; S2 | 16h | 16h | AGNSS | Alcatel | richard.couty@space.alcatel.fr | Rel-7 | Alain |  | AGNSS |  |  |  |  |
| 3194 | 834.2 | Towards AGNSS Concept | 811.2d? | 2004-06-28 A | 2007-08-31 A | 100% | 2004-06-28 | 2007-08-31 | 811.2d? | finish no earlier than 2007-08-31 | GP | 6489.6h | 6489.6h | AGNSS-GP | Alcatel | richard.couty@space.alcatel.fr | Rel-7 | Paolo |  | AGNSS-GP |  |  |  |  |
| 3195 | 834.3 | Global Navigation Satellite System (GNSS) in UTRAN | 383d? | 2005-12-15 A | 2007-06-04 A | 100% | 2005-12-15 | 2007-06-04 | 383d? | finish no earlier than 2007-06-04 | R2 | 3064h | 3064h | LCS3-GNSS-UTRAN | France Telecom | alain.abinakhoul@francetelecom.com | Rel-7 | Yong-Jun |  | LCS3-GNSS-UTRAN |  | RP-070482 |  |  |
| 3196 | 835 | A-GPS Minimum Performance | 351d? | 2006-04-28 A | 2007-08-31 A | 100% | 2006-04-28 | 2007-08-31 | 351d? | finish no earlier than 2007-08-31 | G1; G3 | 5616h | 5616h | GAGR | Spirent | richard.catmur@spirentcom.com | Rel-7 | Paolo |  | GAGR |  |  |  |  |
| 3197 | 836 | **Unstructured Supplementary Service Data (USSD) message delivery and transfer to USIM** | 376d? | 2004-03-05 A | 2005-08-12 A | 100% | 2004-03-05 | 2005-08-12 | 376d? |  | S1; C6 | 8778.4h | 8778.4h | USSD-USIM | Axalto | Christophe Dubois (cdubois@axalto.com) | Rel-7 | Alain |  | USSD-USIM |  |  |  |  |
| 3198 | 836.1 | Stage 1 for USSD message delivery and transfer to USIM | 152d? | 2004-03-18 A | 2004-10-15 A | 100% | 2004-03-18 | 2004-10-15 | 152d? | start no earlier than 2004-03-18 | S1 | 1216h | 1216h | USSD-USIM | Axalto | Christophe Dubois (cdubois@axalto.com) | Rel-7 | Alain |  |  |  |  |  |  |
| 3199 | 836.2 | Alignment with requirements regarding USSD usage | 193.3d? | 2004-03-05 A | 2005-08-12 A | 100% | 2004-03-05 | 2005-08-12 | 193.3d? | finish no earlier than 2005-08-12 | C6 | 1546.4h | 1546.4h | USSD-USIM | Axalto | Christophe Dubois (cdubois@axalto.com) | Rel-7 | Xavier |  |  |  |  |  |  |

Notes:
- 3176: -
- 3177: - / Impacted TSs and TRs: new TR 22.935
- 3178: SP#41 TR withdrawn. All work transferred to specs / Impacted TSs and TRs: 23.837
- 3179: - / Impacted TSs and TRs: 23.234, 23.271, 23.167
- 3180: -
- 3181: -
- 3182: - / Impacted TSs and TRs: 22.146, 22.246, 22.228
- 3183: - / Impacted TSs and TRs: 25.211, 25.212, 25.213, 25.101, 25.104, 25.331, 25.433, 25.346, 25.306
- 3184: - / Impacted TSs and TRs: 25.346, 25.221, 25.222, 25.223, 25.224, 25.306, 25.331, 25.402, 25.433, 25.102, 25.105, 25.123
- 3185: - / Impacted TSs and TRs: 25.346, 25.221, 25.222, 25.223, 25.224, 25.306, 25.331, 25.402, 25.433, 25.102, 25.105, 25.123
- 3186: - / Impacted TSs and TRs: 29.061
- 3187: Linked to Rel-7 Feature UID_31084 (MBMSE)
- 3188: RP#41 completed / Impacted TSs and TRs: 34.108, 34.122, 34.123-1/2/3
- 3189: RP#45 completed / Impacted TSs and TRs: 34.108, 34.123-1
- 3190: RP#46 completed / Impacted TSs and TRs: 34.108, 34.109, 34.121-1, 34.121-2, 34.123-1, 34.123-2, 34.123-3
- 3191: - / Impacted TSs and TRs: 26.346, 26.946
- 3192: -
- 3193: - / Impacted TSs and TRs: 22.071, 23.271
- 3194: GP#36 completed / Impacted TSs and TRs: 43.030, 43.059, 44.031, 44.035, 44.071, 48.008, 48.018, 48.031, 49.031
- 3195: - / Impacted TSs and TRs: 25.305, 25.331, 25.306, 25.413, 25.423, 25.433, 25.453, 25.302, 25.215, 25.401, 25.402, 25.450, 25.452
- 3196: - / Impacted TSs and TRs: 45.005, 51.010
- 3197: -
- 3198: - / Impacted TSs and TRs: 22.090
- 3199: - / Impacted TSs and TRs: 31.111, 31.115, 31.130

| ID | WBS | Task | Type | Duration | Start | Finish | Complete | Baseline start | Baseline finish | Baseline duration | Constraint | Resources | Work | Actual work | Acronym | WI rapporteur name | WI rapporteur e-mail | Release | MCC resp | Acronym_3GU_Export | Impacted TSs and TRs | TSG stopped |
| --- | --- | --- | --- | --- | --- | --- | --- | --- | --- | --- | --- | --- | --- | --- | --- | --- | --- | --- | --- | --- | --- | --- |
| 3200 | 837 | **Combinational Services** |  | 296d? | 2005-01-17 A | 2006-03-06 A | 100% | 2005-01-17 | 2006-03-06 | 296d? |  | S1; S2; C1; S4 | 14648h | 14648h | CSICS | TeliaSonera | Robert.Frank@teliasonera.com | Rel-7 | Alain | CSICS |  |  |
| 3201 | 837.1 | Stage 1 for CSICS |  | 104d? | 2005-01-17 A | 2005-06-09 A | 100% | 2005-01-17 | 2005-06-09 | 104d? | start no earlier than 2005-01-17 | S1 | 832h | 832h | CSICS | TeliaSonera | Robert.Frank@teliasonera.com | Rel-7 | Alain |  | 22.279 |  |
| 3202 | 837.2 | Stage 2 for CSICS |  | 130d? | 2005-01-17 A | 2005-07-15 A | 100% | 2005-01-17 | 2005-07-15 | 130d? | start no earlier than 2005-01-17 | S2 | 1040h | 1040h | CSICS | TeliaSonera | Robert.Frank@teliasonera.com | Rel-7 | Maurice |  | 23.279 |  |
| 3203 | 837.3 | Stage 3 for CSICS CN aspects |  | 221d? | 2005-05-02 A | 2006-03-06 A | 100% | 2005-05-02 | 2006-03-06 | 221d? | finish no earlier than 2006-03-06 | C1 | 1768h | 1768h | CSICS | Vodafone | peter.dawes@vodafone.com | Rel-7 | Frederic |  | 24.879, 24.279, 24.229, 24.008 |  |
| 3204 | 837.4 | Stage 3 for codec aspects |  | 192d? | 2005-03-15 A | 2005-12-07 A | 100% | 2005-03-15 | 2005-12-07 | 192d? | finish no earlier than 2005-12-07 | S4 | 1536h | 1536h | CSICS-Codec | Ericsson | Per.Frojdh@ericsson.com | Rel-7 | Paolo | CSICS-Codec | 26.141, 26.235 |  |
| 3205 | 838 | **CAMEL Trunk Triggers** |  | 251d? | 2004-12-17 A | 2005-12-05 A | 100% | 2004-12-17 | 2005-12-05 | 251d? |  | S1; C4 | 8032h | 8032h | TTCAMEL | Nortel | Amar Deol (deola@nortelnetworks.com) | Rel-7 | Alain | TTCAMEL |  |  |
| 3206 | 838.1 | Stage 1 for CAMEL Trunk Triggers |  | 251d? | 2004-12-17 A | 2005-12-05 A | 100% | 2004-12-17 | 2005-12-05 | 251d? |  | S1 | 2008h | 2008h | TTCAMEL | Nortel | Amar Deol (deola@nortelnetworks.com) | Rel-7 | Alain |  | 22.078 |  |
| 3207 | 838.2 | CAMEL Trunk Originated Trigger Detection Points |  | 251d? | 2004-12-17 A | 2005-12-05 A | 100% | 2004-12-17 | 2005-12-05 | 251d? | start no earlier than 2004-12-17 | C4 | 2008h | 2008h | CamelR7 | Nortel | David Hutton (dhutton@nortel.com) | Rel-7 | Kimmo | CamelR7 |  |  |
| 3208 | 839 | **IMS Service Brokering enhancements** |  | 69d? | 2005-12-07 A | 2006-03-13 A | 100% | 2005-12-07 | 2006-03-13 | 69d? |  | S1 | 1104h | 1104h | ISB | Telcordia | jbakker@telcordia.com | Rel-7 | Alain | ISB | 22.228 |  |
| 3209 | 839.1 | Stage 1 for ISB |  | 69d? | 2005-12-07 A | 2006-03-13 A | 100% | 2005-12-07 | 2006-03-13 | 69d? | finish no earlier than 2006-03-13 | S1 | 552h | 552h | ISB-s1 | Telcordia | jbakker@telcordia.com | Rel-7 | Alain | ISB-s1 | 22.228 |  |
| 3210 | 840 | **Enhancements of VGCS for public authority officials** |  | 731d? | 2004-08-27 A | 2007-06-15 A | 100% | 2004-08-27 | 2007-06-15 | 731d? |  | S1; C1; C4; G2 | 49312h | 49312h | EVGCS |  |  | Rel-7 | Alain | EVGCS | 43.068, 44.068, 24.008, 29.002 |  |
| 3211 | 840.1 | Stage 1 for Enhancements of VGCS for public authority officials | milestone | 0d? | 2004-08-27 A | 2004-08-27 A | 100% | 2004-08-27 | 2004-08-27 | 0d? | finish no earlier than 2004-08-27 | S1 |  |  | EVGCS | Siemens | joerg.swetina@neclab.eu | Rel-7 | Alain |  | 42.068, 43.068 |  |
| 3212 | 840.2 | **Architecture and protocol aspects** |  | 731d? | 2004-08-27 A | 2007-06-15 A | 100% | 2004-08-27 | 2007-06-15 | 731d? |  | C1; C4 | 20752h | 20752h | EVGCS | Siemens | robert.zaus@nsn.com | Rel-7 | Frederic |  | 43.068, 44.068 |  |
| 3213 | 840.2.1 | CT1 aspects of EVGCS |  | 731d? | 2004-08-27 A | 2007-06-15 A | 100% | 2004-08-27 | 2007-06-15 | 731d? | finish no earlier than 2006-09-15 | C1 | 5848h | 5848h | EVGCS | Siemens | robert.zaus@nsn.com | Rel-7 | Frederic |  | 43.068, 44.068, 24.008 |  |
| 3214 | 840.2.2 | CT4 aspects of EVGCS |  | 401d? | 2004-08-27 A | 2006-03-10 A | 100% | 2004-08-27 | 2006-03-10 | 401d? | finish no earlier than 2006-03-10 | C4 | 3208h | 3208h | EVGCS | Siemens | robert.zaus@nsn.com | Rel-7 | Kimmo |  | 29.002 |  |
| 3215 | 840.3 | GERAN2 aspects of EVGCS |  | 646d? | 2004-08-27 A | 2007-02-16 A | 100% | 2004-08-27 | 2007-02-16 | 646d? | finish no earlier than 2007-02-16 | G2 | 5168h | 5168h | EVGCS | Siemens | kenneth.isaacs@roke.co.uk | Rel-7 | Gert |  |  |  |
| 3216 | 841 | **Improvements of VGCS for parallel use of services** |  | 523d? | 2005-03-15 A | 2007-03-15 A | 100% | 2005-03-15 | 2007-03-15 | 523d? |  | S1 | 12230.2h | 12230.2h | IVGCS |  |  | Rel-7 | Alain | IVGCS |  |  |
| 3217 | 841.1 | Service Requirements for VGCS improvements |  | 62d? | 2005-03-15 A | 2005-06-08 A | 100% | 2005-03-15 | 2005-06-08 | 62d? | finish no earlier than 2005-06-08 | S1 | 496h | 496h | IVGCS | T-Mobile | kurt.bischinger@t-mobile.at | Rel-7 | Alain |  | 42.068 |  |
| 3218 | 841.2 | Stage 2 modifications for VGCS improvements |  | 335d? | 2005-12-01 A | 2007-03-14 A | 100% | 2005-12-01 | 2007-03-14 | 335d? | start no earlier than 2005-12-01 | C1 | 2680h | 2680h | IVGCS | T-Mobile | kurt.bischinger@t-mobile.at | Rel-7 | Frederic |  | 43.068 |  |
| 3219 | 841.3 | **Protocol aspects** |  | 336d? | 2005-12-01 A | 2007-03-15 A | 100% | 2005-12-01 | 2007-03-15 | 336d? |  | C1 | 5376h | 5376h | IVGCS | T-Mobile | Dieter Jacobsohn | Rel-7 | Frederic |  | 44.068 |  |
| 3220 | 841.3.1 | CT1 aspects of IVGCS |  | 336d? | 2005-12-01 A | 2007-03-15 A | 100% | 2005-12-01 | 2007-03-15 | 336d? | finish no earlier than 2007-03-15 | C1 | 2688h | 2688h | IVGCS | T-Mobile |  | Rel-7 | Frederic |  | 43.068, 44.068 |  |
| 3221 | 841.3.2 | Deleted - CT4 aspects of IVGCS | milestone | 0d? | 2007-03-09 A | 2007-03-09 A | 100% | 2007-03-09 | 2007-03-09 | 0d? | finish no earlier than 2007-03-09 | C4 |  |  | IVGCS-St3-c4 | T-mobile |  | Rel-7 | Kimmo | IVGCS-St3-c4 | 29.002 | CP-35 |
| 3222 | 842 | **Open Service Access (OSA) Rel-7** |  | 584d? | 2005-03-15 A | 2007-06-08 A | 100% | 2005-03-15 | 2007-06-08 | 584d? |  | S1; C5 | 29776h | 29776h | OSA7 | AePONA | eamonn.murray@aepona.com | Rel-7 | Alain | OSA7 |  |  |
| 3223 | 842.1 | **OSA Service Broker** |  | 449d? | 2005-03-15 A | 2006-12-01 A | 100% | 2005-03-15 | 2006-12-01 | 449d? |  | S1; C5 | 10176h | 10176h | OSA7-SB | AePONA | eamonn.murray@aepona.com | Rel-7 | Alain | OSA7-SB |  |  |
| 3224 | 842.1.1 | Service Requirements for OSA Service Broker |  | 62d? | 2005-03-15 A | 2005-06-08 A | 100% | 2005-03-15 | 2005-06-08 | 62d? | finish no earlier than 2005-06-08 | S1 | 496h | 496h | OSA7 | AePONA | eamonn.murray@aepona.com | Rel-7 | Alain |  | 22.127 |  |
| 3225 | 842.1.2 | Stage 2 OSA API Service Brokering |  | 156d? | 2006-04-28 A | 2006-12-01 A | 100% | 2006-04-28 | 2006-12-01 | 156d? |  | C5 | 1248h | 1248h | OSA7 | AePONA | damian.oneill@aepona.com | Rel-7 | Kimmo |  | 23.198 |  |
| 3226 | 842.1.3 | Stage 3 OSA API Service Brokering |  | 156d? | 2006-04-28 A | 2006-12-01 A | 100% | 2006-04-28 | 2006-12-01 | 156d? | finish no earlier than 2006-12-01 | C5 | 1248h | 1248h | OSA7 | AePONA | damian.oneill@aepona.com | Rel-7 | Kimmo |  | 29.198-16 |  |

Notes:
- 3200: -
- 3201: -
- 3202: -
- 3203: -
- 3204: -
- 3205: -
- 3206: -
- 3207: -
- 3208: No CR submitted in rel-8 (according to CR database).
- 3209: No Rel-8 changes
- 3210: Moved from Rel-6 UID_50563 Enhancements of VGCS in public networks for communication of public authority officials
- 3211: Voice Group Call Service
- 3212: -
- 3213: -
- 3214: -
- 3215: -
- 3216: Voice Group Call Service
- 3217: -
- 3218: -
- 3219: Previous name (before CT32) was Architecture and protocol aspects
- 3220: -
- 3221: CT4#33 stage 2 solution is still open. ...
- 3222: -
- 3223: -
- 3224: -
- 3225: -
- 3226: -

| ID | WBS | Task | Type | Duration | Start | Finish | Complete | Baseline start | Baseline finish | Baseline duration | Constraint | Resources | Work | Actual work | Acronym | Impacted TSs and TRs | WI rapporteur name | WI rapporteur e-mail | Release | MCC resp | Acronym_3GU_Export | TSG stopped | Status Report |
| --- | --- | --- | --- | --- | --- | --- | --- | --- | --- | --- | --- | --- | --- | --- | --- | --- | --- | --- | --- | --- | --- | --- | --- |
| 3227 | 842.2 | **Rel-7 OSA Stage 2/3 enhancements** |  | 291d? | 2006-04-28 A | 2007-06-08 A | 100% | 2006-04-28 | 2007-06-08 | 291d? |  | C5 | 10256h | 10256h | OSA7 | 29.198/9, 23.198 | AePONA | damian.oneill@aepona.com | Rel-7 | Kimmo |  |  |  |
| 3228 | 842.2.1 | Parlay X Message Broadcast Web Service |  | 156d? | 2006-04-28 A | 2006-12-01 A | 100% | 2006-04-28 | 2006-12-01 | 156d? | finish no earlier than 2006-12-01 | C5 | 1248h | 1248h | OSA7 | 29.199-15, 23.198 | ETRI |  | Rel-7 | Kimmo |  |  |  |
| 3229 | 842.2.2 | Parlay X Geocoding Web Service |  | 156d? | 2006-04-28 A | 2006-12-01 A | 100% | 2006-04-28 | 2006-12-01 | 156d? | finish no earlier than 2006-12-01 | C5 | 1248h | 1248h | OSA7 | 29.199-16, 23.198 | ETRI |  | Rel-7 | Kimmo |  |  |  |
| 3230 | 842.2.3 | Parlay X Application driven QoS Web Service |  | 226d? | 2006-04-28 A | 2007-03-09 A | 100% | 2006-04-28 | 2007-03-09 | 226d? | finish no earlier than 2007-03-09 | C5 | 1808h | 1808h | OSA7 | 29.199-17, 23.198 | BT |  | Rel-7 | Kimmo |  |  |  |
| 3231 | 842.2.4 | Parlay-X Device Capabilities and Configuration |  | 162d? | 2006-10-26 A | 2007-06-08 A | 100% | 2006-10-26 | 2007-06-08 | 162d? | finish no earlier than 2007-06-09 | C5 | 1296h | 1296h | OSA7 | 29.199-18, 23.198 | Telenor |  | Rel-7 | Kimmo |  |  |  |
| 3232 | 842.2.5 | Parlay-X Multimedia Streaming Session Management Web Service |  | 97d? | 2006-10-26 A | 2007-03-09 A | 100% | 2006-10-26 | 2007-03-09 | 97d? | start no earlier than 2006-10-26 | C5 | 776h | 776h | OSA7 | 29.199-19, 23.198 | Telenor |  | Rel-7 | Kimmo |  |  |  |
| 3233 | 842.2.6 | Parlay-X Multimedia Multicast Control Web Service |  | 97d? | 2006-10-26 A | 2007-03-09 A | 100% | 2006-10-26 | 2007-03-09 | 97d? | start no earlier than 2006-10-26 | C5 | 776h | 776h | OSA7 | 29.199-20, 23.198 | ETRI |  | Rel-7 | Kimmo |  |  |  |
| 3234 | 842.2.7 | OSA API Conference Call Control SCF |  | 97d? | 2006-10-26 A | 2007-03-09 A | 100% | 2006-10-26 | 2007-03-09 | 97d? | start no earlier than 2006-10-26 | C5 | 776h | 776h | OSA7 | 29.198-04-5, 23.198 | Ericsson |  | Rel-7 | Kimmo |  |  |  |
| 3235 | 843 | **Selective Disabling of UE Capabilities** |  | 624.36d? | 2005-01-24 A | 2007-06-15 A | 100% | 2005-01-24 | 2007-06-15 | 624.36d? |  | S1; S2; C1 | 22341.5h | 22341.5h | SDoUE |  | Motorola |  | Rel-7 | Alain | SDoUE |  |  |
| 3236 | 843.1 | Stage 1 of SDoUE |  | 393.6d? | 2005-01-24 A | 2006-12-08 A | 100% | 2005-01-24 | 2006-12-08 | 393.6d? | finish no earlier than 2006-12-08 | S1 | 3148.8h | 3148.8h | SDoUE-CR | 22.011 | Motorola |  | Rel-7 | Alain | SDoUE-CR |  |  |
| 3237 | 843.2 | Deleted - TR on different possible architectures |  | 195d? | 2005-03-21 A | 2005-12-16 A | 100% | 2005-03-21 | 2005-12-16 | 195d? | finish no earlier than 2005-12-16 | S2 | 1560h | 1560h | SDoUE-FS | 23.805 abandonned at SP-30; descendant C1 24.305 | Vodafone | Gavin.Wong@vodafone.com | Rel-7 | Maurice | SDoUE-FS | SP-30 |  |
| 3238 | 843.3 | Stage 3 of SDoUE |  | 331d? | 2006-03-10 A | 2007-06-15 A | 100% | 2006-03-10 | 2007-06-15 | 331d? | finish no earlier than 2007-06-15 | C1 | 2648h | 2648h | SDoUE | 24.305 | Ericsson | christian.herrero@ericsson.com | Rel-7 | Frederic |  |  |  |
| 3239 | 844 | **Network selection enhancements (NSP)** |  | 328d? | 2006-03-15 A | 2007-06-15 A | 100% | 2006-03-15 | 2007-06-15 | 328d? |  | S1 | 6320h | 6320h | NSP |  | O2 | chris.friel@O2.com | Rel-7 | Alain | NSP |  |  |
| 3240 | 844.1 | Stage 1 of NSP |  | 191d? | 2006-03-15 A | 2006-12-06 A | 100% | 2006-03-15 | 2006-12-06 | 191d? | start no earlier than 2006-03-15 | S1 | 1528h | 1528h | NSP-TS | 22.101, 22.011, 23.122, 24.008, 25.304, 31.102, 45.008 | O2 | chris.friel@O2.com | Rel-7 | Alain | NSP-TS |  |  |
| 3241 | 844.2 | Procedural aspects of NSP |  | 271d? | 2006-06-02 A | 2007-06-15 A | 100% | 2006-06-02 | 2007-06-15 | 271d? | finish no earlier than 2007-06-15 | C1 | 2168h | 2168h | NSP-CR | 23.122, 24.008, 31.102 | Motorola | Andrew Howell | Rel-7 | Frederic | NSP-CR |  |  |
| 3242 | 845 | Network selection enhancements (NSP) - UE Conformance Testing |  | 396d? | 2007-06-01 A | 2008-12-05 A | 100% | 2007-06-01 | 2008-12-05 | 396d? | finish no earlier than 2008-12-05 | R5 | 3168h | 3168h | NSP-CR_UEConTest | 34.108, 34.123-1, 34.123-2, 34.123-3 | Nokia | jarkko.hellsten@nokia.com | Rel-7 | Ingbert | NSP-CR_UEConTest |  | RP-080819 |
| 3243 | 846 | **Access Class Barring and Overload Protection** |  | 650d? | 2004-03-15 A | 2006-09-08 A | 100% | 2004-03-15 | 2006-09-08 | 650d? |  | S2; C1 | 13968h | 13968h | ACBOP | 23.898 | Vodafone | chris.pudney@vodafone.com | Rel-7 | Maurice | ACBOP |  |  |
| 3244 | 846.1 | TR on Stage 2 |  | 274d? | 2004-03-15 A | 2005-03-31 A | 100% | 2004-03-15 | 2005-03-31 | 274d? | finish no earlier than 2005-03-31 | S2 | 2192h | 2192h | ACBOP | 23.898 | NTT DoCoMo | Jean-Jacques Davidian (davidian@docomo.fr) | Rel-7 | Maurice |  |  |  |
| 3245 | 846.2 | Stage 3 CN aspects of ACBOP |  | 172d? | 2005-06-06 A | 2006-01-31 A | 100% | 2005-06-06 | 2006-01-31 | 172d? | start no earlier than 2005-06-06 | C1 | 1376h | 1376h | ACBOP | 24.008 |  |  | Rel-7 | Frederic |  |  |  |
| 3246 | 846.3 | Deleted - Potential impact on Iu interface Overload functionality | milestone | 0d? | 2004-03-15 A | 2004-03-15 A | 100% | 2004-03-15 | 2004-03-15 | 0d? | finish no earlier than 2004-03-15 | RP |  |  | ACBOP | 25.413 |  |  | Rel-7 | Issam |  | RP-25 |  |
| 3247 | 846.4 | Deleted - Extra ACBOP information in RAN | milestone | 0d? | 2004-03-15 A | 2004-03-15 A | 100% | 2004-03-15 | 2004-03-15 | 0d? | finish no earlier than 2004-03-15 | RP |  |  | ACBOP | 25.331 |  |  | Rel-7 | Issam |  | RP-25 |  |
| 3248 | 846.5 | Deleted - Extra ACBOP information in GERAN | milestone | 0d? | 2006-09-08 A | 2006-09-08 A | 100% | 2006-09-08 | 2006-09-08 | 0d? | start no earlier than 2006-09-08 | GP |  |  | ACBOP | 44.018 |  |  | Rel-7 | Paolo |  | RP-33 |  |
| 3249 | 847 | **System enhancements for Fixed Broadband access to IMS** |  | 2117d? | 2003-11-05 A | 2011-12-09 A | 100% | 2003-11-05 | 2011-12-09 | 2117d? |  | S2; S3; S5; C1; C3; C4; IETF | 369944h | 369944h | FBI |  |  |  | Rel-7 | Maurice | FBI |  |  |
| 3250 | 847.1 | **TISPAN Rel 1 related aspects** |  | 2117d? | 2003-11-05 A | 2011-12-09 A | 100% | 2003-11-05 | 2011-12-09 | 2117d? |  | S2; S3; C1; C3; C4; IETF | 239320h | 239320h | FBI-TIS1 |  |  |  | Rel-7 | Maurice | FBI-TIS1 |  |  |
| 3251 | 847.1.1 | Stage 2 of FBI for TISPAN R1 |  | 365d? | 2004-10-14 A | 2006-03-08 A | 100% | 2004-10-14 | 2006-03-08 | 365d? | start no earlier than 2004-10-14 | S2 | 2920h | 2920h |  |  |  |  | Rel-7 | Maurice |  |  |  |

Notes:
- 3227: CP#34 updated WID CP-060607=>CP-070200
- 3228: -
- 3229: -
- 3230: -
- 3231: -
- 3232: -
- 3233: -
- 3234: -
- 3235: Moved from FS section Feb 06
- 3236: Moved from FS section Feb 06
- 3237: Moved from FS section Feb 06. Abandoned at SP-30
- 3238: -
- 3239: -
- 3240: -
- 3241: -
- 3242: RP#42 completed. Testing for Feature UID_7041 (NSP-CR)
- 3243: -
- 3244: -
- 3245: -
- 3246: -
- 3247: -
- 3248: -
- 3249: -
- 3250: -
- 3251: -

| ID | WBS | Task | Duration | Start | Finish | Complete | Baseline start | Baseline finish | Baseline duration | Constraint | Resources | Work | Actual work | WI rapporteur name | WI rapporteur e-mail | Release | MCC resp | PCG approved | TSG approved | Acronym | Acronym_3GU_Export | Special Focus Doc | TSG stopped |
| --- | --- | --- | --- | --- | --- | --- | --- | --- | --- | --- | --- | --- | --- | --- | --- | --- | --- | --- | --- | --- | --- | --- | --- |
| 3252 | 847.1.2 | **Protocol impact of FBI for TISPAN R1** | 2117d? | 2003-11-05 A | 2011-12-09 A | 100% | 2003-11-05 | 2011-12-09 | 2117d? |  | S3; C1; C3; C4; IETF | 133840h | 133840h | Siemens | peter.leis@nsn.com | Rel-7 | Frederic |  |  |  |  |  |  |
| 3253 | 847.1.2.1 | (IETF) CT aspects of FBI for TISPAN R1 | 2117d? | 2003-11-05 A | 2011-12-09 A | 100% | 2003-11-05 | 2011-12-09 | 2117d? | start no earlier than 2003-11-05 | C1-IETF; C3-IETF | 33872h | 33872h | Roland Jesske |  | Rel-7 | Frederic | PCG-27 | CP-52 |  |  |  |  |
| 3254 | 847.1.2.2 | CT1 aspects of FBI for TISPAN R1 | 802d? | 2003-11-05 A | 2006-11-30 A | 100% | 2003-11-05 | 2006-11-30 | 802d? | finish no earlier than 2006-11-30 | C1 | 6416h | 6416h | Siemens | peter.leis@nsn.com | Rel-7 | Frederic |  |  |  |  |  |  |
| 3255 | 847.1.2.3 | CT3 aspects of FBI for TISPAN R1 | 808d? | 2003-11-05 A | 2006-12-08 A | 100% | 2003-11-05 | 2006-12-08 | 808d? | finish no earlier than 2006-12-08 | C3 | 6464h | 6464h | Siemens | peter.leis@nsn.com | Rel-7 | Adrian |  |  |  |  |  |  |
| 3256 | 847.1.2.4 | CT4 aspects of FBI for TISPAN R1 | 301d? | 2006-01-13 A | 2007-03-09 A | 100% | 2006-01-13 | 2007-03-09 | 301d? | finish no earlier than 2007-03-09 | C4 | 2408h | 2408h | Siemens | peter.leis@nsn.com | Rel-7 | Kimmo |  |  | FBI-TIS1-st3-c4 | FBI-TIS1-st3-c4 |  |  |
| 3257 | 847.1.3 | Security Enhancements for FBI | 118d? | 2005-06-28 A | 2005-12-08 A | 100% | 2005-06-28 | 2005-12-08 | 118d? | start no earlier than 2005-06-28 | S3 | 944h | 944h | Ericsson | Bengt.Sahlin@ericsson.com | Rel-7 | Mirko |  |  | FBI-ISE | FBI-ISE |  |  |
| 3258 | 847.2 | **PacketCable Related aspects** | 291d? | 2006-02-01 A | 2007-03-14 A | 100% | 2006-02-01 | 2007-03-14 | 291d? |  | S2; S5; C1 | 12072h | 12072h | CableLabs | Bernie McKibben (b.mckibben@cablelabs.com) | Rel-7 | Maurice |  |  | FBI-PCBL | FBI-PCBL |  |  |
| 3259 | 847.2.1 | Stage 1,2 of FBI for PacketCable | 228d? | 2006-02-01 A | 2006-12-15 A | 100% | 2006-02-01 | 2006-12-15 | 228d? | finish no earlier than 2006-12-15 | S2 | 1824h | 1824h | CableLabs | Bernie McKibben (b.mckibben@cablelabs.com) | Rel-7 | Maurice |  |  |  |  |  |  |
| 3260 | 847.2.2 | Protocol impact of FBI for PacketCable | 228d? | 2006-05-01 A | 2007-03-14 A | 100% | 2006-05-01 | 2007-03-14 | 228d? | finish no earlier than 2007-03-15 | C1 | 1824h | 1824h |  |  | Rel-7 | Frederic |  |  |  |  |  |  |
| 3261 | 847.2.3 | SA5 Charging aspects of FBI for PacketCable | 180d? | 2006-03-31 A | 2006-12-07 A | 100% | 2006-03-31 | 2006-12-07 | 180d? | finish no earlier than 2006-12-07 | S5 | 1440h | 1440h | CableLabs | Bernie McKibben (b.mckibben@cablelabs.com) | Rel-7 | Mirko |  |  | FBI-PCBL-CH | FBI-PCBL-CH |  |  |
| 3262 | 848 | **Support of SMS over generic 3GPP IP access** | 696d? | 2004-10-14 A | 2007-06-14 A | 100% | 2004-10-14 | 2007-06-14 | 696d? |  | S2; C4; C1 | 37544h | 37544h | Huawei | zhangwenlin@huawei.com | Rel-7 | Maurice |  |  | SMSIP | SMSIP | WLAN |  |
| 3263 | 848.1 | FS on SMSIP | 173d? | 2004-10-14 A | 2005-06-13 A | 100% | 2004-10-14 | 2005-06-13 | 173d? | start no earlier than 2004-10-14 | S2 | 1384h | 1384h | Huawei | zhangwenlin@huawei.com | Rel-7 | Maurice |  |  |  |  | WLAN |  |
| 3264 | 848.2 | Stage 2 for SMSIP | 333d? | 2005-06-08 A | 2006-09-15 A | 100% | 2005-06-08 | 2006-09-15 | 333d? | finish no earlier than 2006-09-15 | S2 | 2664h | 2664h | Huawei | zhangwenlin@huawei.com | Rel-7 | Maurice |  |  |  |  | WLAN |  |
| 3265 | 848.3 | **Stage 3 for SMSIP** | 527d? | 2005-06-08 A | 2007-06-14 A | 100% | 2005-06-08 | 2007-06-14 | 527d? |  | C4; C1 | 16792h | 16792h | Nokia | jari.jansson@nokia.com | Rel-7 | Kimmo |  |  | SMSIP-St3 | SMSIP-St3 | WLAN |  |
| 3266 | 848.3.1 | CT1 aspects for SMSIP | 527d? | 2005-06-08 A | 2007-06-14 A | 100% | 2005-06-08 | 2007-06-14 | 527d? | finish no earlier than 2007-06-15 | C1 | 4216h | 4216h | Nokia | jari.jansson@nokia.com | Rel-7 | Frederic |  |  |  |  | WLAN |  |
| 3267 | 848.3.2 | CT4 aspects for SMSIP | 518d? | 2005-06-08 A | 2007-06-01 A | 100% | 2005-06-08 | 2007-06-01 | 518d? | finish no earlier than 2007-06-01 | C4 | 4144h | 4144h | Nokia | jari.jansson@nokia.com | Rel-7 | Kimmo |  |  | SMSIP-St3-c4 | SMSIP-St3-c4 | WLAN |  |
| 3268 | 849 | **Evolution of Policy Control and Charging** | 817d? | 2004-10-14 A | 2007-11-30 A | 100% | 2004-10-14 | 2007-11-30 | 817d? |  | S2; S5; C3; C1 | 54112h | 54112h | Nokia | balazs.bertenyi@nsn.com | Rel-7 | Maurice |  |  | PCC | PCC |  |  |
| 3269 | 849.1 | Deleted - TR for PCC | 315d? | 2004-10-14 A | 2005-12-29 A | 100% | 2004-10-14 | 2005-12-29 | 315d? | finish no earlier than 2005-12-28 | S2 | 2520h | 2520h | Nokia | balazs.bertenyi@nsn.com | Rel-7 | Maurice |  |  |  |  |  | SP-33 |
| 3270 | 849.2 | Stage 2 for PCC | 315d? | 2005-07-04 A | 2006-09-15 A | 100% | 2005-07-04 | 2006-09-15 | 315d? | finish no earlier than 2006-09-15 | S2 | 2520h | 2520h | Nokia | balazs.bertenyi@nsn.com | Rel-7 | Maurice |  |  |  |  |  |  |
| 3271 | 849.3 | Evolution of policy control and flow based bearer level charging | 109d? | 2006-08-01 A | 2006-12-29 A | 100% | 2006-08-01 | 2006-12-29 | 109d? | start no earlier than 2006-08-01 | S2 | 872h | 872h | Nokia | balazs.bertenyi@nsn.com | Rel-7 | Maurice |  |  |  |  |  |  |
| 3272 | 849.4 | SA5 Charging aspects of PCC | 316d? | 2006-03-31 A | 2007-06-15 A | 100% | 2006-03-31 | 2007-06-15 | 316d? | finish no earlier than 2007-06-15 | S5 | 2528h | 2528h | Orange | alain.bibas@orange-ft.com | Rel-7 | Mirko |  |  | PCC-CH | PCC-CH |  |  |
| 3273 | 849.5 | Gx reference point for Policy and Charging Control | 521d? | 2005-12-02 A | 2007-11-30 A | 100% | 2005-12-02 | 2007-11-30 | 521d? | finish no earlier than 2007-09-14 | C3 | 4168h | 4168h | Siemens | Thomas.Belling@nsn.com | Rel-7 | Adrian |  |  | PCC-Gx | PCC-Gx |  |  |
| 3274 | 849.6 | **Rx reference point for PCC CT3 aspects** | 521d? | 2005-12-02 A | 2007-11-30 A | 100% | 2005-12-02 | 2007-11-30 | 521d? |  | C3; C1 | 15360h | 15360h | Ericsson | j.javier.pastor@ericsson.com | Rel-7 | Adrian |  |  | PCC-Rx | PCC-Rx |  |  |
| 3275 | 849.6.1 | PCC-Rx CT3 aspects | 521d? | 2005-12-02 A | 2007-11-30 A | 100% | 2005-12-02 | 2007-11-30 | 521d? | finish no earlier than 2007-09-14 | C3 | 4168h | 4168h | Ericsson | j.javier.pastor@ericsson.com | Rel-7 | Adrian |  |  | PCC-Rx-c3 | PCC-Rx-c3 |  |  |
| 3276 | 849.6.2 | PCC-Rx CT1 aspects | 357d? | 2005-12-02 A | 2007-06-15 A | 100% | 2005-12-02 | 2007-06-15 | 357d? | finish no earlier than 2007-06-15 | C1 | 2856h | 2856h | Ericsson | j.javier.pastor@ericsson.com | Rel-7 | Frederic |  |  | PCC-Rx-Gx-c1 | PCC-Rx-Gx-c1 |  |  |

Notes:
- 3252: -
- 3253: CP#54 completed / Impacted TSs and TRs: RFC 6432 (was draft-jesske-dispatch-update3326-reason-responses)
- 3254: - / Impacted TSs and TRs: 24.819, 24.229
- 3255: - / Impacted TSs and TRs: 29.163, 29.209
- 3256: CT4#32: a set of CRs on FBI for cable labs / Impacted TSs and TRs: 29.229
- 3257: Duplicated entry ("ACCSEC2", "Access Security Enhancements", SP-040865) deleted by A.Sultan / Impacted TSs and TRs: 33.203
- 3258: -
- 3259: - / Impacted TSs and TRs: 22.228, 23.228
- 3260: -
- 3261: 03/2006 SP#31 WID approved / Impacted TSs and TRs: 32.240, 32.260, 32.298, 32.299
- 3262: SP#33 updated WID (removed MMS)
- 3263: SP#33 updated WID / Impacted TSs and TRs: 23.804
- 3264: SP#33 updated WID / Impacted TSs and TRs: 23.204
- 3265: CP#34 updated WID
- 3266: CP#34 updated WID / Impacted TSs and TRs: 23.040, 24.229
- 3267: CP#34 updated WID / Impacted TSs and TRs: 23.008, 29.002
- 3268: SP-29 approved WID. SP-31 updated WID adding SA5 charging. 23.125 will be discontinued from Rel-7.
- 3269: SP-30: S2 has no intention for TR completion / Impacted TSs and TRs: 23.803
- 3270: SP-29 approved WID. SP-31 updated WID. 23.125 will be discontinued from Rel-7. / Impacted TSs and TRs: 23.203
- 3271: SP-29 approved WID. SP-31 updated WID. 23.125 will be discontinued from Rel-7. / Impacted TSs and TRs: 23.207, 23.002, 23.228
- 3272: SP-31 updated WID with SA5 charging. / Impacted TSs and TRs: 32.250, 32.251, 32.298, 32.299
- 3273: - / Impacted TSs and TRs: 29.212 (not progressed to Rel-7: 29.210, 29.207, 29.208)
- 3274: WID approved at CP#30, Revised at CP#31, Revised at CP#33
- 3275: - / Impacted TSs and TRs: 29.213, 29.214 (not progressed to Rel-7: 29.209, 29.211)
- 3276: - / Impacted TSs and TRs: 24.229

| ID | WBS | Task | Type | Duration | Start | Finish | Complete | Baseline start | Baseline finish | Baseline duration | Constraint | Resources | Work | Actual work | Acronym | WI rapporteur name | WI rapporteur e-mail | Release | MCC resp | Special Focus Doc | Acronym_3GU_Export | Impacted TSs and TRs | TSG stopped |
| --- | --- | --- | --- | --- | --- | --- | --- | --- | --- | --- | --- | --- | --- | --- | --- | --- | --- | --- | --- | --- | --- | --- | --- |
| 3277 | 850 | **Voice Call Continuity between CS and IMS (incl. I-WLAN)** |  | 641d? | 2004-12-31 A | 2007-06-15 A | 100% | 2004-12-31 | 2007-06-15 | 641d? |  | S2; S1; S5; C1; C4 | 43592h | 43592h | VCC | Alcatel-Lucent | Keith Drage (drage@alcatel-lucent.com) | Rel-7 | Maurice | WLAN | VCC |  |  |
| 3278 | 850.1 | TR for Voice Call Continuity between CS and IMS (incl. I-WLAN) |  | 245d? | 2004-12-31 A | 2005-12-08 A | 100% | 2004-12-31 | 2005-12-08 | 245d? | finish no earlier than 2005-12-08 | S2 | 1960h | 1960h |  | Alcatel-Lucent | andy.bennett@alcatel-lucent.com | Rel-7 | Maurice | WLAN |  | 23.806 |  |
| 3279 | 850.2 | Stage 1 for Voice Call Continuity between CS and IMS (incl. I-WLAN) |  | 140d? | 2005-03-17 A | 2005-09-28 A | 100% | 2005-03-17 | 2005-09-28 | 140d? | finish no earlier than 2005-09-28 | S1 | 1120h | 1120h |  | Alcatel-Lucent | andy.bennett@alcatel-lucent.com | Rel-7 | Alain | WLAN |  | 22.101 |  |
| 3280 | 850.3 | Stage 2 for Voice Call Continuity between CS and IMS (incl. I-WLAN) |  | 264d? | 2005-09-06 A | 2006-09-08 A | 100% | 2005-09-06 | 2006-09-08 | 264d? | finish no earlier than 2006-09-08 | S2 | 2112h | 2112h |  | Alcatel-Lucent | andy.bennett@alcatel-lucent.com | Rel-7 | Maurice | WLAN |  | 23.206 |  |
| 3281 | 850.4 | SA5 Charging for Voice Call Continuity between CS and IMS (incl. I-WLAN) |  | 325d? | 2006-03-17 A | 2007-06-14 A | 100% | 2006-03-17 | 2007-06-14 | 325d? | finish no earlier than 2007-06-14 | S5 | 2600h | 2600h | VCC-CH | Orange | alain.bibas@orange-ft.com | Rel-7 | Mirko | WLAN | VCC-CH | 32.250, 32.260 |  |
| 3282 | 850.5 | **Stage 3 for Voice Call Continuity between CS and IMS (incl. I-WLAN)** |  | 358d? | 2006-02-01 A | 2007-06-15 A | 100% | 2006-02-01 | 2007-06-15 | 358d? |  | C1; C4 | 10160h | 10160h |  | Alcatel-Lucent | Keith Drage (drage@alcatel-lucent.com) | Rel-7 | Frederic | WLAN |  |  |  |
| 3283 | 850.5.1 | CT1 aspects of Stage 3 for Voice Call Continuity between CS and IMS (incl. I-WLAN) |  | 358d? | 2006-02-01 A | 2007-06-15 A | 100% | 2006-02-01 | 2007-06-15 | 358d? | finish no earlier than 2007-06-15 | C1 | 2864h | 2864h |  | Alcatel-Lucent | Keith Drage (drage@alcatel-lucent.com) | Rel-7 | Frederic | WLAN |  | 24.206, 24.216 |  |
| 3284 | 850.5.2 | CT4 aspects of Stage 3 for Voice Call Continuity between CS and IMS (incl. I-WLAN) |  | 196d? | 2006-06-09 A | 2007-03-09 A | 100% | 2006-06-09 | 2007-03-09 | 196d? | start no earlier than 2006-06-09 | C4 | 1568h | 1568h | VCC-St3-c4 | Alcatel-Lucent | Keith Drage (drage@alcatel-lucent.com) | Rel-7 | Kimmo | WLAN | VCC-St3-c4 | 23.003 |  |
| 3285 | 850.5.3 | Deleted - CT3 aspects of Stage 3 for Voice Call Continuity between CS and IMS (incl. I-WLAN) | milestone | 0d? | 2006-11-02 A | 2006-11-02 A | 100% | 2006-11-02 | 2006-11-02 | 0d? | finish no earlier than 2006-11-02 | C3 |  |  |  | Alcatel-Lucent | Keith Drage (drage@alcatel-lucent.com) | Rel-7 | Adrian | WLAN |  | 29.163 | CP-33 |
| 3286 | 851 | **One Tunnel solution for optimization of Packet Data Traffic** |  | 418d? | 2006-03-27 A | 2007-10-31 A | 100% | 2006-03-27 | 2007-10-31 | 418d? |  | S2 | 7048h | 7048h | OPTUNEL | Nokia | antti.j.pasanen@nokia.com | Rel-7 | Maurice |  | OPTUNEL |  |  |
| 3287 | 851.1 | Deleted - Study on Stage 2 for One Tunnel solution |  | 125d? | 2006-03-27 A | 2006-09-15 A | 100% | 2006-03-27 | 2006-09-15 | 125d? | finish no earlier than 2005-09-12 | S2 | 1000h | 1000h | OPTUNEL-Study | Nokia | antti.j.pasanen@nokia.com | Rel-7 | Maurice |  | OPTUNEL-Study | 23.809 | SP-34 |
| 3288 | 851.2 | One Tunnel Deployment Guideline |  | 268d? | 2006-10-23 A | 2007-10-31 A | 100% | 2006-10-23 | 2007-10-31 | 268d? | finish no earlier than 2007-10-31 | S2 | 2144h | 2144h | OPTUNEL-Guide | Huawei | lan.liu@huawei.com | Rel-7 | Maurice |  | OPTUNEL-Guide | 23.919 |  |
| 3289 | 851.3 | Stage 2 specification for One Tunnel solution |  | 70d? | 2006-09-11 A | 2006-12-15 A | 100% | 2006-09-11 | 2006-12-15 | 70d? | finish no earlier than 2006-12-15 | S2 | 560h | 560h | OPTUNEL-Stage2 | Nokia | antti.j.pasanen@nokia.com | Rel-7 | Maurice |  | OPTUNEL-Stage2 | 23.060 |  |
| 3290 | 852 | **CSI Terminating Session handling** |  | 267d? | 2006-06-08 A | 2007-06-15 A | 100% | 2006-06-08 | 2007-06-15 | 267d? |  | S2; C1 | 6864h | 6864h | CSItermS | Samsung | Osok Song | Rel-7 | Maurice |  | CSItermS |  |  |
| 3291 | 852.1 | Stage 2 of CStermS |  | 192d? | 2006-06-08 A | 2007-03-02 A | 100% | 2006-06-08 | 2007-03-02 | 192d? | start no earlier than 2006-06-08 | S2 | 1536h | 1536h |  | Samsung | Osok Song | Rel-7 | Maurice |  |  | 23.279 |  |
| 3292 | 852.2 | Stage 3 of CStermS |  | 132d? | 2006-12-14 A | 2007-06-15 A | 100% | 2006-12-14 | 2007-06-15 | 132d? | finish no earlier than 2007-06-15 | C1 | 1056h | 1056h |  | Samsung | chenho.chin@samsung.com | Rel-7 | Frederic |  |  | 24.229, 24.279 |  |
| 3293 | 852.3 | Deleted - duplicated with UID 340015 -Stage 3 CSI Terminating Session handling | milestone | 0d? | 2007-03-09 A | 2007-03-09 A | 100% | 2007-03-09 | 2007-03-09 | 0d? | start no earlier than 2007-03-09 | C1 |  |  |  | Samsung | chenho.chin@samsung.com | Rel-7 | Frederic |  |  | 24.229, 24.179, 24.279 | CP-34 |
| 3294 | 853 | Liberty Alliance and 3GPP Security Interworking |  | 451d? | 2005-03-10 A | 2006-11-30 A | 100% | 2005-03-10 | 2006-11-30 | 451d? | finish no earlier than 2006-11-30 | S3 | 3608h | 3608h | LibSec | Nokia | Silke.Holtmanns@nokia.com | Rel-7 | Mirko |  | LibSec | 33.980 |  |
| 3295 | 854 | Trust Requirements for Open Platforms in 3GPP |  | 499d? | 2005-01-03 A | 2006-11-30 A | 100% | 2005-01-03 | 2006-11-30 | 499d? | finish no earlier than 2006-11-30 | S3 | 3992h | 3992h | TrustOP | Nokia | Silke.Holtmanns@nokia.com | Rel-7 | Mirko |  | TrustOP | 33.905 |  |
| 3296 | 855 | Development of UEA2 and UIA2 |  | 268d? | 2004-12-01 A | 2005-12-09 A | 100% | 2004-12-01 | 2005-12-09 | 268d? | finish no earlier than 2005-12-09 | S3 | 2144h | 2144h | AlgUEA2 | TeliaSonera | per.christoffersson@teliasonera.com | Rel-7 | Mirko |  | AlgUEA2 | 35.919, 35.215, 35.216, 35.217, 35.218 |  |
| 3297 | 856 | Lawful Interception in the 3GPP Rel-7 architecture |  | 118d? | 2005-06-28 A | 2005-12-08 A | 100% | 2005-06-28 | 2005-12-08 | 118d? | start no earlier than 2005-06-28 | S3 | 944h | 944h | LI-7A | BMWI | berthold.wilhelm@regtp.de | Rel-7 | Mirko |  | LI-7A | 33.106, 33.107, 33.108 |  |
| 3298 | 857 | Key establishment between a UICC and a terminal |  | 201.45d? | 2005-12-07 A | 2006-09-28 A | 100% | 2005-12-07 | 2006-09-28 | 201.45d? | finish no earlier than 2006-09-28 | S3 | 1611.6h | 1611.6h | KeyEstUTerm | Gemalto | mireille.pauliac@gemplus.com | Rel-7 | Mirko |  | KeyEstUTerm | 33.110 |  |
| 3299 | 858 | NDS Authentication Framework Extension for Transport Layer Security |  | 50d? | 2006-09-28 A | 2006-12-06 A | 100% | 2006-09-28 | 2006-12-06 | 50d? | finish no earlier than 2006-09-28 | S3 | 400h | 400h | NDSAFTLS | Nokia | tiina.s.koskinen@nokia.com | Rel-7 | Mirko |  | NDSAFTLS | 33.310 |  |
| 3300 | 859 | **Security enhancements** |  | 319d? | 2005-09-12 A | 2006-11-30 A | 100% | 2005-09-12 | 2006-11-30 | 319d? |  | S3; C1; C4 | 16376h | 16376h | SEC7 |  |  | Rel-7 | Mirko |  | SEC7 |  |  |
| 3301 | 859.1 | HTTPS connection between a UICC and a NAF |  | 1d? | 2005-09-12 A | 2005-09-12 A | 100% | 2005-09-12 | 2005-09-12 | 1d? | start no earlier than 2005-09-12 | S3; C1 | 16h | 16h | SEC7-HSUN | Gemalto | JSeif@axalto.com, mireille.pauliac@gemplus.com | Rel-7 | Mirko |  | SEC7-HSUN | 33.918, 33.222, 24.109 |  |
| 3302 | 859.2 | 2G GBA: 2G SIM usage in 3GPP GAA framework |  | 61d? | 2005-09-12 A | 2005-12-05 A | 100% | 2005-09-12 | 2005-12-05 | 61d? | finish no earlier than 2005-12-05 | S3 | 488h | 488h | SEC7-2GGBA | Nokia | Silke.Holtmanns@nokia.com | Rel-7 | Mirko |  | SEC7-2GGBA | 33.920, 33.220 |  |
| 3303 | 859.3 | Generic Authentication Architecture usage extensions and optimizations |  | 319d? | 2005-09-12 A | 2006-11-30 A | 100% | 2005-09-12 | 2006-11-30 | 319d? | finish no earlier than 2006-11-30 | S3 | 2552h | 2552h | SEC7-GAA2 | Nokia | Silke.Holtmanns@nokia.com | Rel-7 | Mirko |  | SEC7-GAA2 | 33.220, 29.109, 24.109, (33.223 goes to R8) |  |

Notes:
- 3277: WID approved SP#27; updated SP#28; updated SP#32
- 3278: -
- 3279: -
- 3280: -
- 3281: 03/2006 SP#31 WID approved
- 3282: -
- 3283: -
- 3284: -
- 3285: -
- 3286: -
- 3287: TR for Info SP-33. SP-34: S2 Report intention to discontinue TR
- 3288: -
- 3289: -
- 3290: Triggered by the abandoned Study UID_32117
- 3291: -
- 3292: CP-34 approved WID. CP-35 updated WID
- 3293: CP-34 approved WID
- 3294: WID approved SP#27.
- 3295: WID approved SP#26.
- 3296: WID approved SP#26, Dependant on Funding Availability.
- 3297: -
- 3298: -
- 3299: TLS profile is moved to Rel-8
- 3300: -
- 3301: -
- 3302: -
- 3303: 33.223 goes to R8

| ID | WBS | Task | Duration | Start | Finish | Complete | Baseline start | Baseline finish | Baseline duration | Constraint | Resources | Work | Actual work | Acronym | WI rapporteur name | WI rapporteur e-mail | Release | MCC resp | Acronym_3GU_Export | Impacted TSs and TRs | TSG stopped | PCG approved | TSG approved |
| --- | --- | --- | --- | --- | --- | --- | --- | --- | --- | --- | --- | --- | --- | --- | --- | --- | --- | --- | --- | --- | --- | --- | --- |
| 3304 | 859.4 | **SS7 TCAP security Gateway** | 241d? | 2005-09-12 A | 2006-08-14 A | 100% | 2005-09-12 | 2006-08-14 | 241d? |  | S3; C4 | 5664h | 5664h | SEC7-NDS-TCAPsec | Siemens | marc.blommaert.ext@nsn.com | Rel-7 | Mirko | SEC7-NDS-TCAPsec |  |  |  |  |
| 3305 | 859.4.1 | SA3 aspects of SEC7-NDS-TCAPsec | 130d? | 2005-09-12 A | 2006-03-10 A | 100% | 2005-09-12 | 2006-03-10 | 130d? | finish no earlier than 2006-03-10 | S3 | 1040h | 1040h | SEC7-NDS-TCAPsec-SA3 | Siemens | marc.blommaert.ext@nsn.com | Rel-7 | Mirko | SEC7-NDS-TCAPsec-SA3 | 33.204 |  |  |  |
| 3306 | 859.4.2 | TCAPsec Gateway | 96d? | 2006-04-03 A | 2006-08-14 A | 100% | 2006-04-03 | 2006-08-14 | 96d? | start no earlier than 2006-04-01 | C4 | 768h | 768h | SEC7-TCAP | Siemens | Ulrich.wiehe@gksag.de | Rel-7 | Kimmo | SEC7-TCAP | 29.204, 29.002 |  |  |  |
| 3307 | 860 | IMS Stage 3 IETF Protocol Alignment | 589d? | 2004-12-10 A | 2007-03-14 A | 100% | 2004-12-10 | 2007-03-14 | 589d? | finish no earlier than 2007-03-15 | C1 | 4712h | 4712h | IMSProtoc |  |  | Rel-7 | Frederic | IMSProtoc | 24.930 |  |  |  |
| 3308 | 861 | **Interoperability between VGCS/VBS and A/Gb flexibility** | 253d? | 2006-03-22 A | 2007-03-09 A | 100% | 2006-03-22 | 2007-03-09 | 253d? |  | C1; C4 | 7344h | 7344h | VGCSFlex | Siemens | robert.zaus@nsn.com | Rel-7 | Frederic | VGCSFlex |  |  |  |  |
| 3309 | 861.1 | CT1 aspects of VGCSFlex | 159d? | 2006-03-22 A | 2006-10-30 A | 100% | 2006-03-22 | 2006-10-30 | 159d? | finish no earlier than 2006-10-30 | C1 | 1272h | 1272h |  | Siemens | robert.zaus@nsn.com | Rel-7 | Frederic |  | 43.068, 43.069 |  |  |  |
| 3310 | 861.2 | CT4 aspects of VGCSFlex | 253d? | 2006-03-22 A | 2007-03-09 A | 100% | 2006-03-22 | 2007-03-09 | 253d? | finish no earlier than 2007-03-09 | C4 | 2024h | 2024h | VGCSFlex-c4 | Siemens | robert.zaus@nsn.com | Rel-7 | Kimmo | VGCSFlex-c4 | 29.002 |  |  |  |
| 3311 | 862 | DIAMETER on the GGSN Gi interface | 586d? | 2004-09-10 A | 2006-12-08 A | 100% | 2004-09-10 | 2006-12-08 | 586d? | finish no earlier than 2006-12-08 | C3 | 4688h | 4688h | DIAMGi | Vodafone | Nico.Gabriele@vodafone.com | Rel-7 | Adrian | DIAMGi | 29.061 |  |  |  |
| 3312 | 863 | DIAMETER on the PDG Wi interface | 586d? | 2004-09-10 A | 2006-12-08 A | 100% | 2004-09-10 | 2006-12-08 | 586d? | finish no earlier than 2006-12-08 | C3 | 4688h | 4688h | DIAMWi | Vodafone | Nico.Gabriele@vodafone.com | Rel-7 | Adrian | DIAMWi | 29.161 |  |  |  |
| 3313 | 864 | Interworking between the 3GPP CS domain with BICC or ISUP as signalling protocol and external SIP-I networks | 478d? | 2006-09-22 A | 2008-07-22 A | 100% | 2006-09-22 | 2008-07-22 | 478d? | finish no earlier than 2007-09-14 | C3 | 3824h | 3824h | ExtSIPI | Siemens | Thomas.Belling@nsn.com | Rel-7 | Adrian | ExtSIPI | 29.164 |  |  |  |
| 3314 | 865 | PDU multiplexing at Nb Interface with IP transport | 427d? | 2006-12-04 A | 2008-07-22 A | 100% | 2006-12-04 | 2008-07-22 | 427d? | start no earlier than 2006-12-04 | C3 | 3416h | 3416h | NbIPMux | Alcatel-Lucent | Jean.Rzeznik@alcatel-lucent.fr | Rel-7 | Adrian | NbIPMux | 29.414 |  |  |  |
| 3315 | 866 | **Mp (MRFC - MRFP) interface** | 345d? | 2006-02-13 A | 2007-06-08 A | 100% | 2006-02-13 | 2007-06-08 | 345d? |  | C4; C1 | 9904h | 9904h | Mp | Ericsson | philip.hodges@ericsson.com | Rel-7 | Kimmo | Mp |  |  |  |  |
| 3316 | 866.1 | CT1 aspects of Mp | 1d | 2006-02-13 A | 2006-02-13 A | 100% | 2006-02-13 | 2006-02-13 | 1d | finish no earlier than 2006-02-13 | C1 | 8h | 8h |  | Ericsson | philip.hodges@ericsson.com | Rel-7 | Frederic |  | 24.229 |  |  |  |
| 3317 | 866.2 | Deleted - CT3 aspects of Mp | 1d | 2006-09-22 A | 2006-09-22 A | 100% | 2006-09-22 | 2006-09-22 | 1d | start no earlier than 2006-09-22 | C3 | 8h | 8h |  | Ericsson | philip.hodges@ericsson.com | Rel-7 | Adrian |  | 29.162 | CP-33 |  |  |
| 3318 | 866.3 | Procedures description | 201d? | 2006-06-02 A | 2007-03-09 A | 100% | 2006-06-02 | 2007-03-09 | 201d? | finish no earlier than 2007-03-09 | C4 | 1608h | 1608h | Mp-PROCc4 | Huawei | Chencheng@huawei.com | Rel-7 | Kimmo | Mp-PROCc4 | 23.333 |  |  |  |
| 3319 | 866.4 | Stage 3 for Mp (MRFC - MRFP) interface | 345d | 2006-02-13 A | 2007-06-08 A | 100% | 2006-02-13 | 2007-06-08 | 345d | finish no earlier than 2007-06-08 | C4 | 2760h | 2760h | Mp-St3c4 | Ericsson | philip.hodges@ericsson.com | Rel-7 | Kimmo | Mp-St3c4 | 29.333 |  |  |  |
| 3320 | 867 | Routeing of MT-SMS via the HPLMN | 71d? | 2006-12-01 A | 2007-03-09 A | 100% | 2006-12-01 | 2007-03-09 | 71d? | finish no earlier than 2007-03-09 | C4; C1 | 1136h | 1136h | SMSviaH | Vodafone | Nick.Russell@vodafone.com | Rel-7 | Kimmo | SMSviaH | 23.040, 29.002 |  |  |  |
| 3321 | 868 | Mobile Termination whilst the MS is moving to another MSC | 60d? | 2007-03-09 A | 2007-05-31 A | 100% | 2007-03-09 | 2007-05-31 | 60d? | start no earlier than 2007-03-09 | C4 | 480h | 480h | MTmovMS | Alcatel-Lucent | bruno.landais@alcatel-lucent.fr | Rel-7 | Kimmo | MTmovMS | 23.008, 23.012, 23.018, 23.078, 23.079, 29.002 |  |  |  |
| 3322 | 869 | ISIM API for Java Card | 620d? | 2005-03-14 A | 2007-07-27 A | 100% | 2005-03-14 | 2007-07-27 | 620d? | finish no earlier than 2007-07-27 | C6 | 4960h | 4960h | APIJAVA | Sun | Sebastian Hans | Rel-7 | Xavier | APIJAVA | 31.103, 102 241 |  |  |  |
| 3323 | 870 | Rel-7 (U)SIM API Testing (TS 31.213) | 211d? | 2009-05-30 A | 2010-03-19 A | 100% | 2009-05-30 | 2010-03-19 | 211d? | finish no earlier than 2010-03-12 | C6 | 1688h | 1688h | USIM_API_Test | Sagem Orga | gerrit.hartbrod@sagem-orga.com | Rel-7 | Xavier | USIM_API_Test | 31.213 |  | PCG-23 | CP-44 |
| 3324 | 871 | High speed interface between the UICC and the ME | 311d? | 2006-09-22 A | 2007-11-30 A | 100% | 2006-09-22 | 2007-11-30 | 311d? | finish no earlier than 2007-11-30 | C6 | 2488h | 2488h | HSI | Gemalto | jacques.seif@GEMALTO.COM | Rel-7 | Xavier | HSI | 31.101 |  |  |  |
| 3325 | 872 | Video Codec Performance Requirements | 634d? | 2005-01-03 A | 2007-06-07 A | 100% | 2005-01-03 | 2007-06-07 | 634d? | finish no earlier than 2007-06-07 | S4 | 5072h | 5072h | VICPer | Siemens | juergen.pandel@siemens.com | Rel-7 | Paolo | VICPer | 26.234, 26.235, 26.346, 26.140, 26.902 |  |  |  |
| 3326 | 873 | Dynamic and Interactive Multimedia Scenes | 583d? | 2005-03-15 A | 2007-06-07 A | 100% | 2005-03-15 | 2007-06-07 | 583d? | finish no earlier than 2007-06-07 | S4 | 4664h | 4664h | DIMS | Streamezzo | gaelle.martin-cocher@streamezzo.com | Rel-7 | Paolo | DIMS | 26.140, 26.142, 26.234, 26.244, 23.346 |  |  |  |
| 3327 | 874 | 3G-324M Video Telephony Call Setup Times Improvements | 341d? | 2005-06-08 A | 2006-09-27 A | 100% | 2005-06-08 | 2006-09-27 | 341d? | finish no earlier than 2006-09-27 | S4 | 2728h | 2728h | VTCSTI | Vodafone | edward.hall@vodafone.co.uk | Rel-7 | Paolo | VTCSTI | 26.911 |  |  |  |

Notes:
- 3304: -
- 3305: -
- 3306: -
- 3307: TR 24.930: Signalling flows for the session setup in the IM CN subsystem based on Session Initiation Protocol (SIP)
- 3308: Voice Group Call Service
- 3309: -
- 3310: -
- 3311: -
- 3312: -
- 3313: -
- 3314: -
- 3315: -
- 3316: -
- 3317: CP#34: CT3 not involved in Mp interface definition
- 3318: -
- 3319: -
- 3320: WID approved in CP#34
- 3321: -
- 3322: -
- 3323: CP#47 completed. Update of Rel-6 (U)SIM API for Java Card Testing UID_43007 under Rel-6 UICC/USIM enhancements and interworking UID_1800
- 3324: Following ETSI publication of TS 102 600, expected to be completed at CT6 meeting 45
- 3325: -
- 3326: -
- 3327: -

| ID | WBS | Task | Type | Duration | Start | Finish | Complete | Remaining | Baseline start | Baseline finish | Baseline duration | Total slack | Constraint | Resources | Work | Actual work | Acronym | WI rapporteur name | WI rapporteur e-mail | Release | MCC resp | Acronym_3GU_Export | TSG stopped |
| --- | --- | --- | --- | --- | --- | --- | --- | --- | --- | --- | --- | --- | --- | --- | --- | --- | --- | --- | --- | --- | --- | --- | --- |
| 3328 | 875 | **Optimizations for Multimedia Telephony over IMS** |  | 0d? | 2005-09-28 A | 2005-09-28 | 99% | 0d? | 2005-09-28 | 2005-09-28 | 0d? | 0d |  | S4 |  |  | OMTIMS | Ericsson | olle.franceschi@ericsson.com | Rel-7 | Paolo | OMTIMS |  |
| 3329 | 875.1 | Deleted - Characterisation of Adaptive Jitter Management Performance for VoIP Services | milestone | 0d? | 2005-09-28 A | 2005-09-28 A | 100% |  | 2005-09-28 | 2005-09-28 | 0d? |  | start no earlier than 2007-03-15 | S4 |  |  | OMTIMS-CAJMP | Lucent | dhuo@lucent.com | Rel-7 | Paolo | OMTIMS-CAJMP | SP-35 |
| 3330 | 876 | End-to-End Multimedia Services Performance Metrics |  | 382d? | 2005-09-28 A | 2007-03-15 A | 100% |  | 2005-09-28 | 2007-03-15 | 382d? |  | finish no earlier than 2007-03-15 | S4 | 3056h | 3056h | E2EMSPM | China Mobile | zhangyanyf@chinamobile.com | Rel-7 | Paolo | E2EMSPM |  |
| 3331 | 877 | Packet Switched Streaming Enhancements |  | 261d? | 2006-06-08 A | 2007-06-07 A | 100% |  | 2006-06-08 | 2007-06-07 | 261d? |  | finish no earlier than 2007-06-07 | S4 | 2088h | 2088h | PSSe | Ericsson | olle.franceschi@ericsson.com | Rel-7 | Paolo | PSSe |  |
| 3332 | 878 | **Rel-7 Operations, Administration, Maintenance and Provisioning (OAM&P)** |  | 472.86d? | 2005-09-02 A | 2007-06-26 A | 100% |  | 2005-09-02 | 2007-06-26 | 472.86d? |  |  | S5 | 82725.8h | 82725.8h | OAM7 | Huawei | Christian.Toche@huawei.com | Rel-7 | Mirko | OAM7 |  |
| 3333 | 878.1 | **Rel-7 Network Infrastructure Management** |  | 465d? | 2005-09-02 A | 2007-06-14 A | 100% |  | 2005-09-02 | 2007-06-14 | 465d? |  |  | S5 | 41800h | 41800h | OAM7-NIM |  |  | Rel-7 | Mirko | OAM7-NIM |  |
| 3334 | 878.1.1 | Enhance NRM to accommodate NGN (IMS as basis of the Next Generation Network) |  | 465d? | 2005-09-02 A | 2007-06-14 A | 100% |  | 2005-09-02 | 2007-06-14 | 465d? |  | finish no earlier than 2007-06-14 | S5 | 3720h | 3720h |  | Motorola |  | Rel-7 | Mirko |  |  |
| 3335 | 878.1.2 | Co-operative Element Management interface (CO-OP) (Study + Implementation) |  | 400d? | 2005-09-02 A | 2007-03-15 A | 100% |  | 2005-09-02 | 2007-03-15 | 400d? |  | finish no earlier than 2007-03-15 | S5 | 3200h | 3200h |  | Motorola |  | Rel-7 | Mirko |  |  |
| 3336 | 878.1.3 | Network Management (NM) Itf-N performance criteria |  | 465d? | 2005-09-02 A | 2007-06-14 A | 100% |  | 2005-09-02 | 2007-06-14 | 465d? |  | finish no earlier than 2007-06-14 | S5 | 3720h | 3720h |  | China Mobile |  | Rel-7 | Mirko |  |  |
| 3337 | 878.1.4 | Delta synchronization between IRP Manager and IRP Agent (Study + Implementation) |  | 465d? | 2005-09-02 A | 2007-06-14 A | 100% |  | 2005-09-02 | 2007-06-14 | 465d? |  | finish no earlier than 2007-06-14 | S5 | 3720h | 3720h |  | Siemens |  | Rel-7 | Mirko |  |  |
| 3338 | 878.1.5 | Subscription Management (SuM) IRP Solution Sets |  | 330d? | 2005-09-02 A | 2006-12-07 A | 100% |  | 2005-09-02 | 2006-12-07 | 330d? |  | finish no earlier than 2006-12-07 | S5 | 2640h | 2640h |  | Ericsson |  | Rel-7 | Mirko |  |  |
| 3339 | 878.1.6 | Integration Reference Point (IRP) Security Management |  | 400d? | 2005-09-02 A | 2007-03-15 A | 100% |  | 2005-09-02 | 2007-03-15 | 400d? |  | finish no earlier than 2007-03-15 | S5 | 3200h | 3200h |  | Huawei | Christian.Toche@huawei.com | Rel-7 | Mirko |  |  |
| 3340 | 878.1.7 | Partial suspension of Itf-N during maintenance/testing (Study + Implementation) |  | 465d? | 2005-09-02 A | 2007-06-14 A | 100% |  | 2005-09-02 | 2007-06-14 | 465d? |  | finish no earlier than 2007-06-14 | S5 | 3720h | 3720h |  | Siemens |  | Rel-7 | Mirko |  |  |
| 3341 | 878.1.8 | Deleted - Management of Legacy Equipment |  | 336d? | 2005-09-02 A | 2006-12-15 A | 100% |  | 2005-09-02 | 2006-12-15 | 336d? |  | finish no earlier than 2006-12-15 | S5 | 2688h | 2688h |  | Siemens |  | Rel-7 | Mirko |  | SP-35 |
| 3342 | 878.1.9 | Deleted - Rules for Vendor Specific Extensions |  | 400d? | 2005-09-02 A | 2007-03-15 A | 100% |  | 2005-09-02 | 2007-03-15 | 400d? |  | finish no earlier than 2007-03-15 | S5 | 3200h | 3200h |  | Siemens |  | Rel-7 | Mirko |  | SP-35 |
| 3343 | 878.1.10 | Backward and Forward Compatibility of IRP systems |  | 465d? | 2005-09-02 A | 2007-06-14 A | 100% |  | 2005-09-02 | 2007-06-14 | 465d? |  | finish no earlier than 2007-06-14 | S5 | 3720h | 3720h |  | Ericsson |  | Rel-7 | Mirko |  |  |
| 3344 | 878.1.11 | Repeater Network Resource Model (NRM) definition |  | 214d? | 2006-02-13 A | 2006-12-07 A | 100% |  | 2006-02-13 | 2006-12-07 | 214d? |  | finish no earlier than 2006-12-07 | S5 | 1712h | 1712h |  | China Mobile |  | Rel-7 | Mirko |  |  |
| 3345 | 878.1.12 | UTRAN radio channel power monitoring |  | 284d? | 2006-02-13 A | 2007-03-15 A | 100% |  | 2006-02-13 | 2007-03-15 | 284d? |  | finish no earlier than 2007-03-15 | S5 | 2272h | 2272h |  | China Mobile |  | Rel-7 | Mirko |  |  |
| 3346 | 878.1.13 | Notification XML Schema |  | 71d? | 2006-12-07 A | 2007-03-15 A | 100% |  | 2006-12-07 | 2007-03-15 | 71d? |  | finish no earlier than 2007-03-15 | S5 | 568h | 568h |  | Huawei | Christian.Toche@huawei.com | Rel-7 | Mirko |  |  |
| 3347 | 878.2 | **Rel-7 Performance Management** |  | 465d? | 2005-09-02 A | 2007-06-14 A | 100% |  | 2005-09-02 | 2007-06-14 | 465d? |  |  | S5 | 22992h | 22992h | OAM7-PM |  |  | Rel-7 | Mirko | OAM7-PM |  |
| 3348 | 878.2.1 | Performance measurements definition for CN CS |  | 400d? | 2005-09-02 A | 2007-03-15 A | 100% |  | 2005-09-02 | 2007-03-15 | 400d? |  | finish no earlier than 2007-03-15 | S5 | 3200h | 3200h |  | China Mobile |  | Rel-7 | Mirko |  |  |
| 3349 | 878.2.2 | Enhancement UTRAN performance measurements definition |  | 465d? | 2005-09-02 A | 2007-06-14 A | 100% |  | 2005-09-02 | 2007-06-14 | 465d? |  | finish no earlier than 2007-06-14 | S5 | 3720h | 3720h |  | China Mobile |  | Rel-7 | Mirko |  |  |
| 3350 | 878.2.3 | Add TDD specific counters in Performance measurement |  | 330d? | 2005-09-02 A | 2006-12-07 A | 100% |  | 2005-09-02 | 2006-12-07 | 330d? |  | finish no earlier than 2006-12-15 | S5 | 2640h | 2640h |  | CATT |  | Rel-7 | Mirko |  |  |
| 3351 | 878.2.4 | ATM bearer network Performance measurements |  | 400d? | 2005-09-02 A | 2007-03-15 A | 100% |  | 2005-09-02 | 2007-03-15 | 400d? |  | finish no earlier than 2007-03-15 | S5 | 3200h | 3200h |  | ZTE |  | Rel-7 | Mirko |  |  |
| 3352 | 878.2.5 | Performance measurements definition for IMS |  | 465d? | 2005-09-02 A | 2007-06-14 A | 100% |  | 2005-09-02 | 2007-06-14 | 465d? |  | finish no earlier than 2007-06-14 | S5 | 3720h | 3720h |  | China Mobile |  | Rel-7 | Mirko |  |  |
| 3353 | 878.2.6 | HSDPA performance measurements |  | 349d? | 2006-02-13 A | 2007-06-14 A | 100% |  | 2006-02-13 | 2007-06-14 | 349d? |  | finish no earlier than 2007-06-14 | S5 | 2792h | 2792h |  | China Mobile |  | Rel-7 | Mirko |  |  |

Notes:
- 3328: - / Impacted TSs and TRs: 26.235, 26.236
- 3329: SP-35 stopped
- 3330: - / Impacted TSs and TRs: 26.944
- 3331: - / Impacted TSs and TRs: 26.234, 26.244
- 3332: OAM7 is an umbrella Feature also for OAM&P related TEI7 type of changes that are not part of any other dedicated feature/WI / Impacted TSs and TRs: TR 30.817
- 3333: -
- 3334: - / Impacted TSs and TRs: 32.731/2/3/5, 32.631/2/3/5
- 3335: - / Impacted TSs and TRs: 32.806, 32.814, 32.101
- 3336: - / Impacted TSs and TRs: 32.811
- 3337: - / Impacted TSs and TRs: 32.391/2/3/5
- 3338: - / Impacted TSs and TRs: 32.307/317/607/667/665, 32.101, 32.175
- 3339: - / Impacted TSs and TRs: 32.372/3/5, 32.111,32.30x,32.32x,32.33x,32.34x,32.35x,32.36x,32.41x,32.60x,32.61x,32.66x
- 3340: - / Impacted TSs and TRs: 32.381/2/3/5
- 3341: Request to TSG#35 to STOP the WI / Impacted TSs and TRs: new 32.xxx
- 3342: Request to TSG#35 to STOP the WI / Impacted TSs and TRs: 32.62n; For n = 1 to 5
- 3343: - / Impacted TSs and TRs: 32.154
- 3344: - / Impacted TSs and TRs: 32.721/2/3/5
- 3345: - / Impacted TSs and TRs: 32.405, 32.64n; For n = 1 to 5
- 3346: 12/2006 SP#34 WID approved / Impacted TSs and TRs: New 32.325/345/365/415, CR to 32.335/615/665
- 3347: -
- 3348: - / Impacted TSs and TRs: 32.407, 32.408
- 3349: - / Impacted TSs and TRs: 32.405
- 3350: - / Impacted TSs and TRs: 32.405
- 3351: - / Impacted TSs and TRs: No impact on 32.404, 32.405, 32.406, 32.407
- 3352: - / Impacted TSs and TRs: 32.404,32.409,32.437, 32.632/3/4/5
- 3353: - / Impacted TSs and TRs: 32.405

| ID | WBS | Task | Type | Duration | Start | Finish | Complete | Baseline start | Baseline finish | Baseline duration | Constraint | Resources | Work | Actual work | Acronym | WI rapporteur name | Release | MCC resp | Acronym_3GU_Export | TSG stopped | WI rapporteur e-mail | Status Report |
| --- | --- | --- | --- | --- | --- | --- | --- | --- | --- | --- | --- | --- | --- | --- | --- | --- | --- | --- | --- | --- | --- | --- |
| 3354 | 44.5 | **Rel-7 Trace Management** |  | 472.86d? | 2005-09-02 A | 2007-06-26 A | 100% | 2005-09-02 | 2007-06-26 | 472.86d? |  | S5 | 14150.9h | 14150.9h | OAM7-Trace | Vodafone | Rel-7 | Mirko | OAM7-Trace |  |  |  |
| 3355 | 878.3.1 | End-to-end Service Level tracing for IMS |  | 350d? | 2005-11-11 A | 2007-03-15 A | 100% | 2005-11-11 | 2007-03-15 | 350d? | finish no earlier than 2007-03-15 | S5 | 2800h | 2800h |  | Vodafone | Rel-7 | Mirko |  | SP-31 |  |  |
| 3356 | 878.3.2 | Trace record content for UTRAN TDD |  | 330d? | 2005-09-02 A | 2006-12-07 A | 100% | 2005-09-02 | 2006-12-07 | 330d? | finish no earlier than 2006-12-07 | S5 | 2640h | 2640h |  | Nokia | Rel-7 | Mirko |  |  |  |  |
| 3357 | 878.3.3 | IRP for Subscriber and Equipment Trace Management |  | 465d? | 2005-09-02 A | 2007-06-14 A | 100% | 2005-09-02 | 2007-06-14 | 465d? | finish no earlier than 2007-06-14 | S5 | 3720h | 3720h |  | Nokia | Rel-7 | Mirko |  |  |  |  |
| 3358 | 878.3.4 | Deleted - SIP enhancements for trace | milestone | 0d? | 2007-06-15 A | 2007-06-26 A | 100% | 2007-06-15 | 2007-06-26 | 0d? | start no earlier than 2007-06-15 | C1 |  |  |  |  | Rel-7 | Frederic |  | CP-32 |  |  |
| 3359 | 878.3.5 | Deleted - duplicated with UID 35063 - IRP for Subscriber and Equipment Trace Management |  | 336d? | 2005-09-02 A | 2006-12-15 A | 100% | 2005-09-02 | 2006-12-15 | 336d? | finish no earlier than 2006-12-15 | S5 | 2688h | 2688h |  | Nokia | Rel-7 | Mirko |  | SP-33 |  |  |
| 3360 | 879 | **Rel-7 Charging Management small Enhancements** |  | 279d? | 2006-05-22 A | 2007-06-14 A | 100% | 2006-05-22 | 2007-06-14 | 279d? |  | S5 | 5952h | 5952h | CH7 | Orange | Rel-7 | Mirko | CH7 |  | alain.bibas@orange-ft.com |  |
| 3361 | 879.1 | Alternate Charged Party (ACP) for IMS |  | 279d? | 2006-05-22 A | 2007-06-14 A | 100% | 2006-05-22 | 2007-06-14 | 279d? | finish no earlier than 2007-06-14 | S5 | 2232h | 2232h | CH7-IMS-ACP | Lucent | Rel-7 | Mirko | CH7-IMS-ACP |  | njmazzarella@alcatel-lucent.com |  |
| 3362 | 879.2 | Align 3GPP Charging with OMA PoC Enabler Release 2.0 |  | 186d? | 2006-09-28 A | 2007-06-14 A | 100% | 2006-09-28 | 2007-06-14 | 186d? | finish no earlier than 2007-06-14 | S5 | 1488h | 1488h | CH7-PoC | Siemens | Rel-7 | Mirko | CH7-PoC |  | Gerald.Goermer@nsn.com |  |
| 3363 | 8.5 | **Multiple-Input Multiple-Output (MIMO) antennas** |  | 1301d? | 2003-03-14 A | 2008-03-07 A | 100% | 2003-03-14 | 2008-03-07 | 1301d? |  | R1; R5 | 55848h | 55848h | MIMO | Alcatel-Lucent | Rel-7 | Patrick | MIMO |  | hchuang@Alcatel-Lucent.com |  |
| 3364 | 880.1 | MIMO - Physical layer |  | 915d? | 2003-09-12 A | 2007-03-15 A | 100% | 2003-09-12 | 2007-03-15 | 915d? | finish no earlier than 2007-03-15 | R1 | 7320h | 7320h | MIMO-Phys | Alcatel-Lucent | Rel-7 | Patrick | MIMO-Phys |  | hchuang@Alcatel-Lucent.com | RP-070037 |
| 3365 | 880.2 | MIMO - Layer 2,3 aspects |  | 915d? | 2003-09-12 A | 2007-03-15 A | 100% | 2003-09-12 | 2007-03-15 | 915d? | finish no earlier than 2007-03-15 | R2 | 7320h | 7320h | MIMO-L23 | Alcatel-Lucent | Rel-7 | Yong-Jun | MIMO-L23 |  | hchuang@Alcatel-Lucent.com | RP-070037 |
| 3366 | 880.3 | MIMO - Iub/Iur Protocol Aspects |  | 1045d? | 2003-03-14 A | 2007-03-15 A | 100% | 2003-03-14 | 2007-03-15 | 1045d? | finish no earlier than 2007-03-15 | R3 | 8360h | 8360h | MIMO-IurIub | Alcatel-Lucent | Rel-7 | Juha | MIMO-IurIub |  | hchuang@Alcatel-Lucent.com | RP-070037 |
| 3367 | 880.4 | MIMO - RF Radio Transmission/Reception, System Performance Requirements and Conformance Testing |  | 982d? | 2003-12-12 A | 2007-09-17 A | 100% | 2003-12-12 | 2007-09-17 | 982d? | finish no earlier than 2007-09-17 | R4 | 7856h | 7856h | MIMO-RF | Alcatel-Lucent | Rel-7 | Issam | MIMO-RF |  | ngm@Alcatel-Lucent.com | RP-070531 |
| 3368 | 880.5 | **UE Conformance Testing for Multiple Input Multiple Output antennas (MIMO)** |  | 261d? | 2007-03-09 A | 2008-03-07 A | 100% | 2007-03-09 | 2008-03-07 | 261d? |  | R5 | 4176h | 4176h | MIMO-UEConTest | Qualcomm | Rel-7 | Ingbert | MIMO-UEConTest |  | svora@qualcomm.com |  |
| 3369 | 880.5.1 | Conformance Test Aspects – Multiple Input Multiple Output Antennas (MIMO) for FDD |  | 261d? | 2007-03-09 A | 2008-03-07 A | 100% | 2007-03-09 | 2008-03-07 | 261d? | finish no earlier than 2008-03-07 | R5 | 2088h | 2088h | MIMO-UEConTest_FDD | Qualcomm | Rel-7 | Ingbert | MIMO-UEConTest_FDD |  | svora@qualcomm.com |  |
| 3370 | 881 | **Rel-7 Improvements of the Radio Interface** |  | 709d? | 2004-09-15 A | 2007-06-04 A | 100% | 2004-09-15 | 2007-06-04 | 709d? |  | RP; GP | 40520h | 40520h |  |  | Rel-7 | Issam |  |  |  |  |
| 3371 | 881.1 | Extended UMTS 1.7/2.1 GHz |  | 198d? | 2006-03-15 A | 2006-12-15 A | 100% | 2006-03-15 | 2006-12-15 | 198d? | finish no earlier than 2006-12-15 | R4 | 1584h | 1584h | RInImp-UMTS1721Ext | Ericsson | Rel-7 | Issam | RInImp-UMTS1721Ext |  | johan.skold@ericsson.com | RP-060681 |
| 3372 | 881.2 | UMTS 2.6 GHz 7.68 Mcps TDD |  | 67d? | 2006-06-15 A | 2006-09-15 A | 100% | 2006-06-15 | 2006-09-15 | 67d? | finish no earlier than 2006-09-15 | R4 | 536h | 536h | RInImp-UMTS26VHCRTDD | IPWireless | Rel-7 | Issam | RInImp-UMTS26VHCRTDD |  | Shin Horng Wong (shwong@ipwireless.com) | RP-060451 |
| 3373 | 881.3 | UMTS 2.6 GHz |  | 195d? | 2004-09-15 A | 2005-06-14 A | 100% | 2004-09-15 | 2005-06-14 | 195d? | finish no earlier than 2005-06-14 | R4 | 1560h | 1560h | RInImp-UMTS2600 | Nokia | Rel-7 | Issam | RInImp-UMTS2600 |  | jussi.numminen@nokia.com | RP-050184 |
| 3374 | 881.4 | UMTS 2.6 GHz TDD |  | 261d? | 2004-12-15 A | 2005-12-14 A | 100% | 2004-12-15 | 2005-12-14 | 261d? | finish no earlier than 2005-12-15 | R4 | 2088h | 2088h | RInImp-UMTS2600TDD | IPWireless | Rel-7 | Issam | RInImp-UMTS2600TDD |  | Shin Horng Wong (shwong@ipwireless.com) | RP-050661 |
| 3375 | 881.5 | UMTS 900 MHz |  | 261d? | 2004-12-15 A | 2005-12-14 A | 100% | 2004-12-15 | 2005-12-14 | 261d? | finish no earlier than 2005-12-15 | R4 | 2088h | 2088h | RInImp-UMTS900 | Nortel | Rel-7 | Issam | RInImp-UMTS900 |  | Yannick Li (yli@nortelnetworks.com) | RP-050662 |
| 3376 | 881.6 | UMTS 1700 MHz |  | 197d? | 2005-03-15 A | 2005-12-14 A | 100% | 2005-03-15 | 2005-12-14 | 197d? | finish no earlier than 2005-12-15 | R4 | 1576h | 1576h | RInImp-UMTS1700 | NTT DoCoMo | Rel-7 | Issam | RInImp-UMTS1700 |  | Takehiro Nakamura (nakamurata@nttdocomo.co.jp) | RP-050824 |
| 3377 | 881.7 | UE Antenna Performance Evaluation Method and Requirements |  | 644d? | 2004-12-15 A | 2007-06-04 A | 100% | 2004-12-15 | 2007-06-04 | 644d? | finish no earlier than 2007-06-04 | R4; GP | 10304h | 10304h | RInImp-UEAnt | TeliaSonera | Rel-7 | Issam | RInImp-UEAnt |  | Christian.Bergljung@TeliaSonera.com | RP-070281 |
| 3378 | 881.8 | Improved Performance Requirements for HSDPA UE based on Rx Diversity (type 1) & LMMSE equalizer (type 2) | milestone | 0d? | 2005-03-15 A | 2005-03-15 A | 100% | 2005-03-15 | 2005-03-15 | 0d? | finish no earlier than 2005-03-15 | R4 |  |  | RInImp-HSPerf-Type3 | Cingular | Rel-7 | Issam | RInImp-HSPerf-Type3 |  | Marc Grant | RP-060015 |

Notes:
- 3354: -
- 3355: 07/2005: OMA (Stage 1), Stage 2/3 SA5, CT1/3/4 / Impacted TSs and TRs: 32.101, 32.421, 32.422, 32.423
- 3356: - / Impacted TSs and TRs: 32.421, 32.422, 32.423
- 3357: - / Impacted TSs and TRs: 32.441, 32.442, 32.443, 32.445, 32.632, 32.633, 32.635
- 3358: combined with UID 11067
- 3359: - / Impacted TSs and TRs: 32.421,32.422,32.423. 3 new 32.4x1,2,3
- 3360: CH7 is an umbrella Feature also for OAM&P related TEI7 type of changes that are not part of any other dedicated feature/WI / Impacted TSs and TRs: TR 30.817
- 3361: - / Impacted TSs and TRs: 32.240, 32.260, 32.298, 32.299
- 3362: 09/2006 SP#33 WID approved / Impacted TSs and TRs: 32.240, 32.272, 32.299, 32.298
- 3363: Completed Sep 2007; SR in RP-070037and RP-070531 / Impacted TSs and TRs: 25.876, 25.996
- 3364: Completed Sep 2007; SR in RP-070037 / Impacted TSs and TRs: 25.211, 25.212, 25.213, 25.214, 25.215, 25.221
- 3365: Completed Sep 2007; SR in RP-070037 / Impacted TSs and TRs: 25.876
- 3366: Completed Sep 2007; SR in RP-070037
- 3367: Completed Sep 2007; SR in RP-070531
- 3368: BB place holder for a number of RAN5 Tasks
- 3369: - / Impacted TSs and TRs: TS 34.108, TS 34.109, TS 34.121-1, TS 34.121-2, TS 34.123-1, TS 34.123-2, TS 34.123-3
- 3370: Generic feature
- 3371: RP#34 completed. Introduction of Band X (Extended UMTS 1.7/2.1 GHz) in 25.307 / Impacted TSs and TRs: 25.806, 25.101, 25.104, 25.133, 24.141, 25.331, 25.306, 25.307, 25.423, 25.461, 25.463, 34.121
- 3372: RP#33 completed / Impacted TSs and TRs: 25.102, 25.105, 25.123, 25.113, 25.142, 34.124
- 3373: RP#28 completed / Impacted TSs and TRs: 25.101, 25.104, 25.133, 25.141, 25.331, 25.942, 25.306, 25.307, 34.121
- 3374: RP#30 completed / Impacted TSs and TRs: 25.102, 25.105, 25.113, 25.123, 25.142, 25.331, 25.942, 25.306, 25.307, 34.122, 34.124
- 3375: RP#30 completed / Impacted TSs and TRs: 25.101, 25.104, 25.113, 25.133, 25.141, 25.331, 25.942, 25.306, 25.307, 34.121
- 3376: RP#30 completed / Impacted TSs and TRs: 25.101, 25.104, 25.113, 25.133, 25.141, 25.306, 25.307, 25.331, 34.121
- 3377: RP#36 completed / Impacted TSs and TRs: 25.101, new TR (25.914, 25.963)
- 3378: RP#27 completed / Impacted TSs and TRs: 25.101

| ID | WBS | Task | Type | Duration | Start | Finish | Complete | Baseline start | Baseline finish | Baseline duration | Constraint | Deadline | Resources | Work | Actual work | Acronym | WI rapporteur name | WI rapporteur e-mail | Release | MCC resp | Acronym_3GU_Export | Status Report | TSG stopped | PCG stopped | Created at |
| --- | --- | --- | --- | --- | --- | --- | --- | --- | --- | --- | --- | --- | --- | --- | --- | --- | --- | --- | --- | --- | --- | --- | --- | --- | --- |
| 3379 | 881.9 | **Additional minimum UE performance requirement for non-HSDPA channels based on type 1 enhanced receiver (Rx Diversity)** |  | 327d? | 2005-09-15 A | 2006-12-15 A | 100% | 2005-09-15 | 2006-12-15 | 327d? |  |  | R4 | 7344h | 7344h | RInImp-RxDiv | Qualcomm | Serge Willenegger (sergew@qualcomm.com) | Rel-7 | Issam | RInImp-RxDiv |  |  |  |  |
| 3380 | 881.9.1 | Additional minimum UE performance requirement for DL physical channels in support of DCH/HS-DSCH operation based on type 1 enhanced receiver (RX-Diversity) |  | 195d? | 2005-09-15 A | 2006-06-14 A | 100% | 2005-09-15 | 2006-06-14 | 195d? | finish no earlier than 2006-06-15 |  | R4 | 1560h | 1560h | RInImp-RxDiv-DCH | Cingular | Marc Grant | Rel-7 | Issam | RInImp-RxDiv-DCH | RP-060235 |  |  |  |
| 3381 | 881.9.2 | Additional minimum UE performance requirement for downlink physical channels in support of MTCH and MCCH operation based on type 1 enhanced receiver (Rx-Diversity) |  | 198d? | 2006-03-15 A | 2006-12-15 A | 100% | 2006-03-15 | 2006-12-15 | 198d? | finish no earlier than 2006-12-15 |  | R4 | 1584h | 1584h | RInImp-RxDiv-MBMS | Qualcomm | Serge Willenegger (sergew@qualcomm.com) | Rel-7 | Issam | RInImp-RxDiv-MBMS | RP-060678 |  |  |  |
| 3382 | 881.9.3 | Additional minimum UE performance requirement for downlink physical channels in support of E-DCH operation based on type 1 enhanced receiver (Rx-Diversity) |  | 198d? | 2006-03-15 A | 2006-12-15 A | 100% | 2006-03-15 | 2006-12-15 | 198d? | finish no earlier than 2006-12-15 |  | R4 | 1584h | 1584h | RInImp-RxDiv-EDCH | Qualcomm | Serge Willenegger (sergew@qualcomm.com) | Rel-7 | Issam | RInImp-RxDiv-EDCH | RP-060679 |  |  |  |
| 3383 | 881.10 | Deleted Improved support of gaming over HSDPA/EDCH |  | 262d? | 2005-12-15 A | 2006-12-15 A | 100% | 2005-12-15 | 2006-12-15 | 262d? | finish no earlier than 2006-12-15 |  | R2 | 2096h | 2096h | RInImp-Gaming | Cingular | Don Zelmer (dz1069@att.com) | Rel-7 | Yong-Jun | RInImp-Gaming | RP-060680 | RP-34 |  |  |
| 3384 | 881.11 | Deleted (not approved at PCG) - UMTS 2.6 GHz FDD DL External | milestone | 0d? | 2005-09-15 A | 2005-09-15 A | 100% | 2005-09-15 | 2005-09-15 | 0d? | finish no earlier than 2005-09-15 |  | R4 |  |  | RInImp-UMTS2600Ext | T-mobile | han.van.bussel@t-mobile.de | Rel-7 | Issam | RInImp-UMTS2600Ext |  | RP-31 | PCG-16 |  |
| 3385 | 882 | **Rel-7 Improvements of the Radio Interface - UE Conformance Testing** |  | 741d? | 2005-11-11 A | 2008-09-12 A | 100% | 2005-11-11 | 2008-09-12 | 741d? |  |  | R5 | 17568h | 17568h |  |  |  | Rel-7 | Ingbert |  |  |  |  |  |
| 3386 | 16.5.1 | UE Conformance Test for UMTS 2600 MHz |  | 146d | 2005-11-11 A | 2006-06-02 A | 100% | 2005-11-11 | 2006-06-02 | 146d | finish no earlier than 2006-06-02 | 2006-06-02 | R5 | 1168h | 1168h | RInImp-UMTS2600_Test | Nokia | Aleksi.Heino@nokia.com | Rel-7 | Ingbert | RInImp-UMTS2600_Test |  |  |  | Fri 7/11/05 |
| 3387 | 16.5.1 | UE Conformance Test for UMTS 900 MHz (band VIII) |  | 146d | 2005-11-11 A | 2006-06-02 A | 100% | 2005-11-11 | 2006-06-02 | 146d | finish no earlier than 2006-06-02 | 2006-06-02 | R5 | 1168h | 1168h | RInImp-UMTS900_Test | Qualcomm | hanye@qualcomm.com | Rel-7 | Ingbert | RInImp-UMTS900_Test |  |  |  | Fri 11/03/05 |
| 3388 | 882.3 | Conformance Test Aspects – Improved Performance of HSDPA Receiver type 3 |  | 191d? | 2006-03-10 A | 2006-12-01 A | 100% | 2006-03-10 | 2006-12-01 | 191d? | finish no earlier than 2006-12-01 |  | R5 | 1528h | 1528h | RInImp-HSPerf-Type3_Test | Motorola | carolyn.taylor@motorola.com | Rel-7 | Ingbert | RInImp-HSPerf-Type3_Test |  |  |  |  |
| 3389 | 882.4 | UE antenna Over The Air (OTA) conformance testing |  | 518d? | 2006-09-20 A | 2008-09-12 A | 100% | 2006-09-20 | 2008-09-12 | 518d? | finish no earlier than 2008-09-12 |  | R5 | 4144h | 4144h | RInImp-UEAnt_Test | Nokia | Aleksi.Heino@nokia.com | Rel-7 | Ingbert | RInImp-UEAnt_Test | RP-080535 |  |  |  |
| 3390 | 882.5 | UE conformance testing for FDD Inter-Band Operation |  | 131d? | 2006-06-02 A | 2006-12-01 A | 100% | 2006-06-02 | 2006-12-01 | 131d? | finish no earlier than 2006-12-01 |  | R5 | 1048h | 1048h | RInImp-InterBand_Test | NEC, Motorola | Jacob.John@motorola.com | Rel-7 | Ingbert | RInImp-InterBand_Test |  |  |  |  |
| 3391 | 882.6 | Conformance Test Aspects – Extended UMTS 1.7/2.1 GHz |  | 131d? | 2006-12-01 A | 2007-06-01 A | 100% | 2006-12-01 | 2007-06-01 | 131d? | finish no earlier than 2007-06-01 |  | R5 | 1048h | 1048h | RInImp-UEConTest_UMTS1721Ext | Motorola | carolyn.taylor@motorola.com | Rel-7 | Ingbert | RInImp-UEConTest_UMTS1721Ext | RP-070312 |  |  |  |
| 3392 | 882.7 | Conformance Test Aspects – Minimum UE performance requirement for downlink physical channels in support of E-DCH operation based on type 1 enhanced receiver (Rx-Diversity) |  | 136d? | 2007-06-01 A | 2007-12-07 A | 100% | 2007-06-01 | 2007-12-07 | 136d? | finish no earlier than 2007-12-07 |  | R5 | 1088h | 1088h | RInImp-UEConTest_RxDivEDCH | Motorola | carolyn.taylor@motorola.com | Rel-7 | Ingbert | RInImp-UEConTest_RxDivEDCH | RP-070810 |  |  |  |
| 3393 | 882.8 | Conformance Test Aspects – Minimum UE performance requirement for downlink physical channels in support of MTCGH and MCCH operation based on type 1 enhanced receiver (Rx-Diversity) |  | 201d? | 2007-06-01 A | 2008-03-07 A | 100% | 2007-06-01 | 2008-03-07 | 201d? | finish no earlier than 2008-03-07 |  | R5 | 1608h | 1608h | RInImp-UEConTest_RxDivMBMS | Ericsson | leif.mattisson@ericsson.com | Rel-7 | Ingbert | RInImp-UEConTest_RxDivMBMS | RP-080056 |  |  |  |
| 3394 | 883 | **Rel-7 RAN improvements** |  | 653d? | 2004-12-15 A | 2007-06-15 A | 100% | 2004-12-15 | 2007-06-15 | 653d? |  |  | RP; S5 | 39512h | 39512h |  |  |  | Rel-7 |  |  |  |  |  |  |
| 3395 | 883.1 | Optimization of channelisation code utilisation for 1.28 Mcps TDD |  | 523d? | 2004-12-15 A | 2006-12-15 A | 100% | 2004-12-15 | 2006-12-15 | 523d? | finish no earlier than 2006-12-15 |  | R1 | 4184h | 4184h | RANimp-RABSE-CodOptLCRTDD | UTStarcom | Ka Leong Lo (kaleong.lo@UTSTAR.COM) | Rel-7 | Patrick | RANimp-RABSE-CodOptLCRTDD | RP-060682 |  |  |  |
| 3396 | 883.2 | Delay optimization for procedures applicable to CS and PS Connections |  | 394d? | 2005-03-15 A | 2006-09-15 A | 100% | 2005-03-15 | 2006-09-15 | 394d? | finish no earlier than 2006-09-15 |  | R2 | 3152h | 3152h | RANimp-DelayOpt | Nokia | juho.pirskanen@nokia.com | Rel-7 | Yong-Jun | RANimp-DelayOpt | RP-060453 |  |  |  |
| 3397 | 883.3 | Improved support of IMS Realtime Services using HSDPA/HSUPA |  | 197d? | 2005-03-15 A | 2005-12-14 A | 100% | 2005-03-15 | 2005-12-14 | 197d? | start no earlier than 2005-03-15 |  | R2 | 1576h | 1576h | RANimp-IMSRealTime | Cingular | Don Zelmer (dz1069@att.com) | Rel-7 | Yong-Jun | RANimp-IMSRealTime | RP-050667 |  |  |  |
| 3398 | 883.4 | UE Performance Requirements for MBMS (TDD) |  | 328d? | 2005-03-15 A | 2006-06-15 A | 100% | 2005-03-15 | 2006-06-15 | 328d? | finish no earlier than 2006-06-15 |  | R4 | 2624h | 2624h | MBMS-RAN-RF-TDD | IPwireless | shwong@ipwireless.com | Rel-7 | Issam | MBMS-RAN-RF-TDD | RP-060477 |  |  |  |
| 3399 | 883.5 | Continuous connectivity for packet data users |  | 524d? | 2005-03-14 A | 2007-03-15 A | 100% | 2005-03-14 | 2007-03-15 | 524d? | finish no earlier than 2007-03-15 |  | R1 | 4192h | 4192h | RANimp-CPC | Siemens | Joern.Krause@siemens.com | Rel-7 | Patrick | RANimp-CPC | RP-070033 |  |  |  |
| 3400 | 883.6 | Extended WCDMA Cell Range |  | 198d? | 2006-03-15 A | 2006-12-15 A | 100% | 2006-03-15 | 2006-12-15 | 198d? | finish no earlier than 2006-12-15 |  | R3 | 1584h | 1584h | RANimp-ExtCell | Ericsson | Muhammad Kazmi | Rel-7 | Juha | RANimp-ExtCell | RP-060685 |  |  |  |
| 3401 | 883.7 | 7.68 Mcps TDD Enhanced Uplink |  | 198d? | 2006-03-15 A | 2006-12-15 A | 100% | 2006-03-15 | 2006-12-15 | 198d? | finish no earlier than 2006-12-15 |  | R1 | 1584h | 1584h | RANimp-VHCRTDD-EDCH | IPwireless | nanderson@ipwireless.com | Rel-7 | Patrick | RANimp-VHCRTDD-EDCH | RP-060684 |  |  |  |
| 3402 | 883.8 | Enhanced CELL_FACH State in FDD |  | 181d? | 2006-09-25 A | 2007-06-04 A | 100% | 2006-09-25 | 2007-06-04 | 181d? | finish no earlier than 2007-06-04 |  | R2 | 1448h | 1448h | RANimp-EnhState | Nokia | juho.pirskanen@nokia.com | Rel-7 | Yong-Jun | RANimp-EnhState | RP-070286 |  |  |  |
| 3403 | 883.9 | 64QAM for HSDPA (FDD) |  | 110d? | 2006-12-15 A | 2007-06-04 A | 100% | 2006-12-15 | 2007-06-04 | 110d? | finish no earlier than 2007-06-04 |  | R1 | 880h | 880h | RANimp-64QamDownlink | Ericsson | Johan.Bergman@ericsson.com | Rel-7 | Patrick | RANimp-64QamDownlink | RP-070287 |  |  |  |
| 3404 | 883.10 | Improved L2 support for high data rates |  | 122d? | 2006-12-15 A | 2007-06-04 A | 100% | 2006-12-15 | 2007-06-04 | 122d? | finish no earlier than 2007-06-04 |  | R2 | 976h | 976h | RANimp-L2DataRates | Ericsson | Janne.Peisa@ericsson.com | Rel-7 | Yong-Jun | RANimp-L2DataRates | RP-070289 |  |  |  |
| 3405 | 883.11 | Introduction of 16QAM in HSUPA (FDD) |  | 110d? | 2006-12-15 A | 2007-06-04 A | 100% | 2006-12-15 | 2007-06-04 | 110d? | finish no earlier than 2007-06-04 |  | R1 | 880h | 880h | RANimp-16QamUplink | Nokia | Karri.Ranta-aho@nsn.com | Rel-7 | Patrick | RANimp-16QamUplink | RP-070288 |  |  |  |

Notes:
- 3379: - / Impacted TSs and TRs: 25.101
- 3380: RP#32 completed / Impacted TSs and TRs: 25.101
- 3381: RP#34 completed / Impacted TSs and TRs: 25.101
- 3382: RP#34 completed / Impacted TSs and TRs: 25.101
- 3383: RP#34 stopped. SR in RP-060680
- 3384: This item was conditionnaly approved pending decision of PCG#16 who decided not to approve it / Impacted TSs and TRs: 25.101, 25.104, 25.133, 25.141, 25.331, 25.942, 25.306, 25.307, 34.121
- 3385: Linked to Feature UID_20028 (RInImp)
- 3386: RP#32 completed / Impacted TSs and TRs: 34.108, 34.121
- 3387: RP#32 completed / Impacted TSs and TRs: 34.108, 34.121
- 3388: RP#34 completed / Impacted TSs and TRs: 34.121, 34.108
- 3389: RP#41 completed (GERAN aspects might need to be included later) / Impacted TSs and TRs: 34.114
- 3390: RP#34 completed / Impacted TSs and TRs: 34.108, 34.123-1, 34.123-2, 34.123-3
- 3391: RP#36 completed / Impacted TSs and TRs: 34.108, 34.121-1, 34.121-2
- 3392: RP#38 completed
- 3393: RP#39 completed / Impacted TSs and TRs: 34.121-1, 34.121-2
- 3394: Generic feature
- 3395: RP#34 completed
- 3396: RP#33 completed / Impacted TSs and TRs: 25.815, 25.321, 25.322, 25.331
- 3397: RP#30 completed
- 3398: RP#32 completed / Impacted TSs and TRs: 25.102, 25.123
- 3399: RP#35 completed / Impacted TSs and TRs: 25.903, 25.201, 25.211, 25.212, 25.214, 25.308, 25.321, 25.331, 25.423, 25.433, 25.101, 25.133
- 3400: RP#34 completed / Impacted TSs and TRs: 25.133, 25.423, 25.425, 25.433, 25.435, 25.453, 25.331
- 3401: RP#34 completed / Impacted TSs and TRs: 25.201, 25.202, 25.221, 25.222, 25.223, 25.224, 25.225, 25.331, 23.321, 25.306, 25.302, 25.401, 25.420, 25.423, 25.427, 25.433, 25.102, 25.105, 25.142
- 3402: RP#36 completed / Impacted TSs and TRs: 25.308, 25.304, 25.306, 25.321, 25.331, 25.433, 25.435, 25.423, 25.425,
- 3403: RP#36 completed / Impacted TSs and TRs: 25.308, 25.211, 25.212, 25.213, 25.306, 25.331, 25.433, 25.435, 25.423, 25.425, 25.101, 25.104, 25.141
- 3404: RP#36 completed / Impacted TSs and TRs: 25.301, 25.308,25.306, 25.321, 25.322, 25.331, 25.433, 25.435, 25.423, 25.425, 25.999
- 3405: RP#36 completed / Impacted TSs and TRs: 25.319, 25.101, 25.104, 25.133, 25.141, 25.211, 25.212, 25.213, 25.214, 25.306, 25.321, 25.331, 25.423, 25.433

| ID | WBS | Task | Duration | Start | Finish | Complete | Baseline start | Baseline finish | Baseline duration | Constraint | Resources | Work | Actual work | Acronym | WI rapporteur name | WI rapporteur e-mail | Release | MCC resp | Status Report | Acronym_3GU_Export | PCG approved | TSG approved |
| --- | --- | --- | --- | --- | --- | --- | --- | --- | --- | --- | --- | --- | --- | --- | --- | --- | --- | --- | --- | --- | --- | --- |
| 3406 | 883.12 | **Interface to control Tower Mounted Amplifiers (TMAs)** | 271d? | 2006-06-02 A | 2007-06-15 A | 100% | 2006-06-02 | 2007-06-15 | 271d? |  | R3; S5 | 5984h | 5984h | RANImp-TMA | Vodafone | alexej.kulakov@vodafone.com | Rel-7 | Juha | RP-070140 | RANImp-TMA |  |  |
| 3407 | 883.12.1 | RAN3 part of Interface to control Tower Mounted Amplifiers (TMAs) | 206d? | 2006-06-02 A | 2007-03-16 A | 100% | 2006-06-02 | 2007-03-16 | 206d? |  | R3 | 840h | 840h |  | Vodafone | alexej.kulakov@vodafone.com | Rel-7 | Juha | RP-070140 |  |  |  |
| 3408 | 883.12.2 | OAM aspects to Interface to control TMAs | 101d? | 2007-01-26 A | 2007-06-15 A | 100% | 2007-01-26 | 2007-06-15 | 101d? | finish no earlier than 2007-06-15 | S5 | 808h | 808h | RANImp-TMA-OAM | Vodafone | Adrian.Neal@vodafone.com | Rel-7 | Mirko |  | RANImp-TMA-OAM |  |  |
| 3409 | 884 | **Rel-7 RAN improvements - UE Conformance Testing** | 784d? | 2006-09-20 A | 2009-09-18 A | 100% | 2006-09-20 | 2009-09-18 | 784d? |  | R5 | 25472h | 25472h |  |  |  | Rel-7 | Ingbert |  |  |  |  |
| 3410 | 884.1 | Conformance Test Aspects - 3.84 Mcps and 7.68 Mcps TDD Enhanced Uplink | 518d? | 2006-09-20 A | 2008-09-12 A | 100% | 2006-09-20 | 2008-09-12 | 518d? | finish no earlier than 2008-09-12 | R5 | 4144h | 4144h | RANimp-UEConTest_EDCHTDH | IPWireless | tspeight@ipwireless.com | Rel-7 | Ingbert | RP-080536 | RANimp-UEConTest_EDCHTDH |  |  |
| 3411 | 884.2 | Conformance Test Aspects – 64QAM for HSDPA (FDD) | 257d? | 2007-03-09 A | 2008-03-03 A | 100% | 2007-03-09 | 2008-03-03 | 257d? | finish no earlier than 2008-03-03 | R5 | 2056h | 2056h | RANimp-UEConTest_64QamDownlink | Ericsson | leif.mattisson@ericsson.com | Rel-7 | Ingbert | RP-080059 | RANimp-UEConTest_64QamDownlink |  |  |
| 3412 | 884.3 | Conformance Test Aspects – 16QAM for HSUPA (FDD) | 321d? | 2007-03-09 A | 2008-05-30 A | 100% | 2007-03-09 | 2008-05-30 | 321d? | finish no earlier than 2008-05-30 | R5 | 2568h | 2568h | RANimp-UEConTest_16QamUplink | Motorola | carolyn.taylor@motorola.com | Rel-7 | Ingbert | RP-080281 | RANimp-UEConTest_16QamUplink |  |  |
| 3413 | 884.4 | Conformance Test Aspects – Improved L2 support for high data rates | 321d? | 2007-03-09 A | 2008-05-30 A | 100% | 2007-03-09 | 2008-05-30 | 321d? | finish no earlier than 2008-05-30 | R5 | 2568h | 2568h | RANimp-UEConTest_L2DataRates | Ericsson | leif.mattisson@ericsson.com | Rel-7 | Ingbert | RP-080256 | RANimp-UEConTest_L2DataRates |  |  |
| 3414 | 884.5 | Conformance Test Aspects – Continuous connectivity for packet data users | 321d? | 2007-03-09 A | 2008-05-30 A | 100% | 2007-03-09 | 2008-05-30 | 321d? | finish no earlier than 2008-05-30 | R5 | 2568h | 2568h | RANimp-UEConTest_CPC | Nokia | jarkko.hellsten@nokia.com | Rel-7 | Ingbert | RP-080282 | RANimp-UEConTest_CPC |  |  |
| 3415 | 884.6 | Conformance Test Aspects – Enhanced CELL_FACH state in FDD | 662d? | 2007-03-09 A | 2009-09-18 A | 100% | 2007-03-09 | 2009-09-18 | 662d? | finish no earlier than 2009-09-18 | R5 | 5296h | 5296h | RANimp-UEConTest_EnhancedCellFACHState | Nokia | jarkko.hellsten@nokia.com | Rel-7 | Ingbert | RP-090711 | RANimp-UEConTest_EnhancedCellFACHState |  |  |
| 3416 | 885 | **7.68 Mcps TDD option** | 783d? | 2004-09-15 A | 2007-09-14 A | 100% | 2004-09-15 | 2007-09-14 | 783d? |  | R1; R2; R3; R4; R5 | 49552h | 49552h | VHCRTDD | IPwireless | Martin Beale (mbeale@ipwireless.com) | Rel-7 | Patrick | RP-060684 | VHCRTDD |  |  |
| 3417 | 885.1 | VHCRTDD: Stage 2 | 391d? | 2004-09-15 A | 2006-03-15 A | 100% | 2004-09-15 | 2006-03-15 | 391d? | finish no earlier than 2006-03-15 | R1 | 3128h | 3128h | VHCRTDD-Stage2 | IPwireless | Martin Beale (mbeale@ipwireless.com) | Rel-7 | Patrick | RP-060684 | VHCRTDD-Stage2 |  |  |
| 3418 | 885.2 | VHCRTDD: Physical Layer | 391d? | 2004-09-15 A | 2006-03-15 A | 100% | 2004-09-15 | 2006-03-15 | 391d? | finish no earlier than 2006-03-15 | R1 | 3128h | 3128h | VHCRTDD-Phys | IPwireless | Martin Beale (mbeale@ipwireless.com) | Rel-7 | Patrick | RP-060684 | VHCRTDD-Phys |  |  |
| 3419 | 885.3 | VHCRTDD: Layer 2 and layer 3 protocol aspects | 391d? | 2004-09-15 A | 2006-03-15 A | 100% | 2004-09-15 | 2006-03-15 | 391d? | finish no earlier than 2006-03-15 | R2 | 3128h | 3128h | VHCRTDD-L23 | IPwireless | drichards@ipwireless.com | Rel-7 | Yong-Jun | RP-060684 | VHCRTDD-L23 |  |  |
| 3420 | 885.4 | VHCRTDD: UTRAN Iub/Iur Protocol Aspects | 391d? | 2004-09-15 A | 2006-03-15 A | 100% | 2004-09-15 | 2006-03-15 | 391d? | finish no earlier than 2006-03-15 | R3 | 3128h | 3128h | VHCRTDD-IurIub | IPwireless | Peter Legg (plegg@ipwireless.com) | Rel-7 | Juha | RP-060684 | VHCRTDD-IurIub |  |  |
| 3421 | 885.5 | VHCRTDD: RF Radio Transmission/ Reception, System Performance Requirements and Conformance Testing | 457d? | 2004-09-15 A | 2006-06-15 A | 100% | 2004-09-15 | 2006-06-15 | 457d? | finish no earlier than 2006-06-15 | R4 | 3656h | 3656h | VHCRTDD-RF | IPwireless | Shin Horng Wong (shwong@ipwireless.com) | Rel-7 | Issam | RP-060684 | VHCRTDD-RF |  |  |
| 3422 | 885.6 | Conformance Test Aspects - 7.68 Mcps TDD | 258d? | 2006-09-20 A | 2007-09-14 A | 100% | 2006-09-20 | 2007-09-14 | 258d? | finish no earlier than 2007-09-10 | R5 | 2064h | 2064h | VHCRTDD-UEConTest | IPWireless | tspeight@ipwireless.com | Rel-7 | Ingbert | RP-070307 | VHCRTDD-UEConTest |  |  |
| 3423 | 886 | **3.84 Mcps TDD Enhanced Uplink** | 394d? | 2005-03-15 A | 2006-09-15 A | 100% | 2005-03-15 | 2006-09-15 | 394d? |  | RP | 18384h | 18384h | EDCHTDD | IPwireless | nanderson@ipwireless.com | Rel-7 |  | RP-060462 | EDCHTDD |  |  |
| 3424 | 886.1 | EDCHTDD: Stage 2 | 328d? | 2005-03-15 A | 2006-06-15 A | 100% | 2005-03-15 | 2006-06-15 | 328d? | finish no earlier than 2006-06-15 | R2 | 2624h | 2624h | EDCHTDD-Stage2 | IPwireless | nanderson@ipwireless.com | Rel-7 | Yong-Jun | RP-060462 | EDCHTDD-Stage2 |  |  |
| 3425 | 886.2 | EDCHTDD: Physical Layer | 394d? | 2005-03-15 A | 2006-09-15 A | 100% | 2005-03-15 | 2006-09-15 | 394d? | finish no earlier than 2006-09-15 | R1 | 3152h | 3152h | EDCHTDD-Phys | IPwireless | nanderson@ipwireless.com | Rel-7 | Patrick | RP-060462 | EDCHTDD-Phys |  |  |
| 3426 | 886.3 | EDCHTDD: Layer 2 and 3 Protocol Aspects | 394d? | 2005-03-15 A | 2006-09-15 A | 100% | 2005-03-15 | 2006-09-15 | 394d? | finish no earlier than 2006-09-15 | R2 | 3152h | 3152h | EDCHTDD-L23 | IPwireless | drichards@ipwireless.com | Rel-7 | Yong-Jun | RP-060462 | EDCHTDD-L23 |  |  |
| 3427 | 886.4 | EDCHTDD: UTRAN Iub/Iur Protocol Aspects | 394d? | 2005-03-15 A | 2006-09-15 A | 100% | 2005-03-15 | 2006-09-15 | 394d? | finish no earlier than 2006-09-15 | R3 | 3152h | 3152h | EDCHTDD-IurIub | Interdigital | jim.miller@interdigital.com | Rel-7 | Juha | RP-060462 | EDCHTDD-IurIub |  |  |
| 3428 | 886.5 | EDCHTDD: RF Radio Transmission/ Reception, System Performance Requirements and Conformance Testing | 394d? | 2005-03-15 A | 2006-09-15 A | 100% | 2005-03-15 | 2006-09-15 | 394d? | finish no earlier than 2006-09-15 | R4 | 3152h | 3152h | EDCHTDD-RF | IPwireless | Shin Horng Wong (shwong@ipwireless.com) | Rel-7 | Issam | RP-060462 | EDCHTDD-RF |  |  |
| 3429 | 887 | **1.28 Mcps TDD Enhanced Uplink** | 653d? | 2006-03-15 A | 2008-09-12 A | 100% | 2006-03-15 | 2008-09-12 | 653d? |  | R1; R2; R3; R4; R5 | 35656h | 35656h | LCRTDD-EDCH | CATT | Haijing Hu | Rel-7 | Patrick | RP-070296 | LCRTDD-EDCH |  |  |
| 3430 | 887.1 | 1.28 Mcps TDD Enhanced Uplink: Physical Layer | 262d? | 2006-03-15 A | 2007-03-15 A | 100% | 2006-03-15 | 2007-03-15 | 262d? | finish no earlier than 2007-03-15 | R1 | 2096h | 2096h | LCRTDD-EDCH-Phys | CATT | Ke Wang | Rel-7 | Patrick | RP-070038 | LCRTDD-EDCH-Phys |  |  |
| 3431 | 887.2 | 1.28 Mcps TDD Enhanced Uplink: Layer 2 and 3 Protocol Aspects | 262d? | 2006-03-15 A | 2007-03-15 A | 100% | 2006-03-15 | 2007-03-15 | 262d? | finish no earlier than 2007-03-15 | R2 | 2096h | 2096h | LCRTDD-EDCH-L23 | CATT | Haiyang Quan | Rel-7 | Yong-Jun | RP-070038 | LCRTDD-EDCH-L23 |  |  |
| 3432 | 887.3 | 1.28 Mcps TDD Enhanced Uplink: UTRAN Iub/Iur Protocol Aspects | 262d? | 2006-03-15 A | 2007-03-15 A | 100% | 2006-03-15 | 2007-03-15 | 262d? | finish no earlier than 2007-03-15 | R3 | 2096h | 2096h | LCRTDD-EDCH-IubIur | CATT | Yincheng Zhang | Rel-7 | Juha | RP-070038 | LCRTDD-EDCH-IubIur |  |  |
| 3433 | 887.4 | 1.28 Mcps TDD Enhanced Uplink: RF Radio Transmission/ Reception, System Performance Requirements and Conformance Testing | 328d? | 2006-03-15 A | 2007-06-15 A | 100% | 2006-03-15 | 2007-06-15 | 328d? | finish no earlier than 2007-06-15 | R4 | 2624h | 2624h | LCRTDD-EDCH-RF | CATT | Yuexia Song (songyuexia@catt.cn) | Rel-7 | Issam | RP-070296 | LCRTDD-EDCH-RF |  |  |
| 3434 | 887.5 | 1.28 Mcps TDD Enhanced Uplink - UE Conformance Testing | 257d? | 2007-09-20 A | 2008-09-12 A | 100% | 2007-09-20 | 2008-09-12 | 257d? | finish no earlier than 2008-09-11 | R5 | 624h | 624h | LCRTDD-EDCH-UEConTest | CATT | chenxiaozhong@datangmobile.cn | Rel-7 | Ingbert | RP-080539 | LCRTDD-EDCH-UEConTest |  |  |
| 3435 | 888 | Conformance Test Aspects – Multiple Band and Multiple Frequency operation for LCR TDD | 263d? | 2010-09-17 A | 2011-09-16 A | 100% | 2010-09-17 | 2011-09-16 | 263d? | finish no earlier than 2011-12-09 | R5 | 2091.37h | 2091.37h | LCRTDD_MB_MF_UEConTest | CATR | Ms Jun Chen (chenjun@catr.cn) | Rel-7 | Ingbert | RP-110968 | LCRTDD_MB_MF_UEConTest | PCG-25 | RP-49 |
| 3436 | 889 | MS Antenna Performance Evaluation Method and Requirements | 731d? | 2005-01-28 A | 2007-11-16 A | 100% | 2005-01-28 | 2007-11-16 | 731d? | finish no earlier than 2007-11-16 | GP | 5848h | 5848h | APEMR | TeliaSonera | Ulf.Tegth@teliasonera.com | Rel-7 | Paolo |  | APEMR |  |  |

Notes:
- 3406: RP#35 completed
- 3407: RP#35 completed
- 3408: SP#36 completed / Impacted TSs and TRs: 32.642, 32.643, 32.645 – Align with RAN 25.466
- 3409: Linked to Feature UID_20029 (RANimp)
- 3410: RP#41 completed / Impacted TSs and TRs: 34.108, 34.122, 34.123-1, 34.123-2, 34.123-3
- 3411: RP#39 completed / Impacted TSs and TRs: 34.108, 34.121-1, 34.121-2, 34.123-1, 34.123-2, 34.123-3
- 3412: RP#40 completed / Impacted TSs and TRs: 34.108, 34.121-1, 34.121-2, 34.123-1, 34.123-2, 34.123-3
- 3413: RP#40 completed / Impacted TSs and TRs: 34.108, 34.123-1, 34.123-2, 34.123-3
- 3414: RP#40 completed / Impacted TSs and TRs: 34.108, 34.121-1, 34.121-2, 34.123-1, 34.123-2, 34.123-3
- 3415: RP#45 completed / Impacted TSs and TRs: 34.108, 34.123-1, 34.123-2, 34.123-3
- 3416: RP#31 completed
- 3417: RP#31 completed / Impacted TSs and TRs: 25.202
- 3418: RP#31 completed / Impacted TSs and TRs: 25.221, 25.222, 25.223, 25.224,25.225
- 3419: RP#31 completed / Impacted TSs and TRs: 25.301, 25.302, 25.305, 25.306, 25.321, 25.331
- 3420: RP#31 completed / Impacted TSs and TRs: 25.401, 25.420, 25.423, 25.425, 25.427, 25.430, 25.433, 25.435
- 3421: RP#32 completed / Impacted TSs and TRs: 25.102, 25.105, 25.123, 25.133, 25.142
- 3422: RP#37 completed / Impacted TSs and TRs: 34.108, 34.122, 34.123-1, 34.123-2, 34.123-3
- 3423: RP#33 completed
- 3424: RP#33 completed
- 3425: RP#33 completed / Impacted TSs and TRs: 25.201, 25.221,25.222, 25.223, 25.224, 25.225
- 3426: RP#33 completed / Impacted TSs and TRs: 25.301, 25.302, 25.306, 25.321, 25.331
- 3427: RP#33 completed / Impacted TSs and TRs: 25.401, 25.420, 25.423, 25.427, 25.430, 25.433, 25.435
- 3428: RP#33 completed / Impacted TSs and TRs: 25.102, 25.105, 25.123, 25.142
- 3429: RP#35 completed
- 3430: RP#35 completed / Impacted TSs and TRs: 25.201, 25.221, 25.222, 25.223, 25.224, 25.225
- 3431: RP#35 completed / Impacted TSs and TRs: 25.301, 25.302, 25.306, 25.321, 25.331
- 3432: RP#35 completed / Impacted TSs and TRs: 25.401, 25.420, 25.423, 25.425, 25.427, 25.430, 25.433, 25.435
- 3433: RP#36 completed / Impacted TSs and TRs: 25.102, 25.105, 25.123, 25.142
- 3434: RP#41 completed / Impacted TSs and TRs: 34.108, 34.122, 34.123-1/2/3
- 3435: RP#53 completed. Core specification was introduced via Rel-7 CR under TEI7 (RP#37 RP-070650) and via 2 Rel-8 work items: RInImp9-UMTS1880TDD and RInImp8-UMTS2300TDD. / Impacted TSs and TRs: UTRA 34.108, 34.123-1, 34.123-2, 34.123-3
- 3436: GP#36 completed for R7 / Impacted TSs and TRs: 25.914, 25.144, 45.005

| ID | WBS | Task | Type | Duration | Start | Finish | Complete | Remaining | Baseline start | Baseline finish | Baseline duration | Total slack | Constraint | Resources | Work | Actual work | Acronym | WI rapporteur name | WI rapporteur e-mail | Release | MCC resp | Acronym_3GU_Export | TSG stopped |
| --- | --- | --- | --- | --- | --- | --- | --- | --- | --- | --- | --- | --- | --- | --- | --- | --- | --- | --- | --- | --- | --- | --- | --- |
| 3437 | 890 | **Lower 700 MHz Inclusion in the GERAN Specifications** |  | 390d? | 2005-01-03 A | 2006-06-30 | 99% | 0d? | 2005-01-03 | 2006-06-30 | 390d? | 0d |  | GP | 11112h | 9372h | GSM710 | UTC | dcotton@mtview.union-tel.com | Rel-7 | Paolo | GSM710 |  |
| 3438 | 890.1 | Inclusion of the 698 – 746 MHz band into GERAN core specifications |  | 129d? | 2005-01-03 A | 2005-06-30 A | 100% |  | 2005-01-03 | 2005-06-30 | 129d? |  | finish no earlier than 2005-06-30 | G1 | 1032h | 1032h | GSM710-core |  |  | Rel-7 | Paolo | GSM710-core |  |
| 3439 | 890.2 | **Aspects of GSM710** |  | 217.5d? | 2005-08-31 A | 2006-06-30 | 100% | 0d? | 2005-08-31 | 2006-06-30 | 217.5d? | 0d |  | G1; G3new | 6960h | 5220h | GSM-710-test |  |  | Rel-7 | Paolo | GSM-710-test |  |
| 3440 | 890.2.1 | G1 aspects of GSM710 |  | 217.5d? | 2005-08-31 A | 2006-06-30 A | 100% |  | 2005-08-31 | 2006-06-30 | 217.5d? |  | finish no earlier than 2006-06-30 | G1 | 1740h | 1740h |  |  |  | Rel-7 | Paolo |  |  |
| 3441 | 890.2.2 | G3 aspects of GSM710 |  | 217.5d? | 2005-08-31 A | 2006-06-30 A | 100% |  | 2005-08-31 | 2006-06-30 | 217.5d? |  | finish no earlier than 2006-06-30 | G3new | 1740h | 1740h |  |  |  | Rel-7 | Ingbert |  |  |
| 3442 | 891 | **Support of Conversational Services in A/Gb mode via the PS domain** |  | 626d? | 2005-04-08 A | 2007-08-31 A | 100% |  | 2005-04-08 | 2007-08-31 | 626d? |  |  | GP | 15442.8h | 15442.8h | SCSAGB | Ericsson | gunnar.hedby@ericsson.com | Rel-7 | Paolo | SCSAGB |  |
| 3443 | 891.1 | Minimise the transfer delay between the SGSN and the MS |  | 604.95d? | 2005-04-08 A | 2007-08-31 A | 100% |  | 2005-04-08 | 2007-08-31 | 604.95d? |  | finish no earlier than 2007-08-31 | GP | 4839.6h | 4839.6h | SCSAGB-MTD | Ericsson | gunnar.hedby@ericsson.com | Rel-7 | Paolo | SCSAGB-MTD |  |
| 3444 | 891.2 | Definition of radio resource management functionality for Support of Conversational Services in A/Gb mode via the PS domain |  | 626d? | 2005-04-08 A | 2007-08-31 A | 100% |  | 2005-04-08 | 2007-08-31 | 626d? |  | finish no earlier than 2007-08-31 | G1 | 5008h | 5008h | SCSAGB-RRM | Ericsson | gunnar.hedby@ericsson.com | Rel-7 | Paolo | SCSAGB-RRM |  |
| 3445 | 891.3 | Support of Conversational Services in A/Gb mode via the PS domain – RLC Non-Persistent mode |  | 101d? | 2006-06-30 A | 2006-11-17 A | 100% |  | 2006-06-30 | 2006-11-17 | 101d? |  | finish no earlier than 2006-11-17 | G2 | 808h | 808h | SCSAGB-RLCNP | Ericsson | gunnar.hedby@ericsson.com | Rel-7 | Gert | SCSAGB-RLCNP |  |
| 3446 | 891.4 | Deleted- Radio Channel Support | milestone | 0d? | 2006-07-17 A | 2006-07-17 A | 100% |  | 2006-07-17 | 2006-07-17 | 0d? |  | start no earlier than 2006-07-17 | G2 |  |  | SCSAGB-RCHS | Ericsson | gunnar.hedby@ericsson.com | Rel-7 | Gert | SCSAGB-RCHS | SP-32 |
| 3447 | 891.5 | Deleted- Modifications to FLO | milestone | 0d? | 2006-07-17 A | 2006-07-17 A | 100% |  | 2006-07-17 | 2006-07-17 | 0d? |  | start no earlier than 2006-07-17 | G2 |  |  | SCSAGB-FLO | Ericsson | gunnar.hedby@ericsson.com | Rel-7 | Gert | SCSAGB-FLO | SP-32 |
| 3448 | 892 | **Addition of new frequency band to GSM (T-GSM810)** |  | 626d? | 2005-04-08 A | 2007-08-31 A | 100% |  | 2005-04-08 | 2007-08-31 | 626d? |  |  | GP | 12112h | 12112h | TGSM810 | Huawei | chende@huawei.com | Rel-7 | Paolo | TGSM810 |  |
| 3449 | 892.1 | Changes to core specification |  | 106d? | 2005-04-08 A | 2005-09-02 A | 100% |  | 2005-04-08 | 2005-09-02 | 106d? |  | finish no earlier than 2005-09-02 | GP | 848h | 848h | TGSM810-Core | Huawei | chende@huawei.com | Rel-7 | Paolo | TGSM810-Core |  |
| 3450 | 892.2 | Changes to MS testing specification |  | 626d? | 2005-04-08 A | 2007-08-31 A | 100% |  | 2005-04-08 | 2007-08-31 | 626d? |  | finish no earlier than 2007-08-31 | G3new | 5008h | 5008h | TGSM810-MStest | Huawei | chende@huawei.com | Rel-7 | Ingbert | TGSM810-MStest |  |
| 3451 | 892.3 | Changes to BTS testing specification |  | 156d? | 2005-04-08 A | 2005-11-11 A | 100% |  | 2005-04-08 | 2005-11-11 | 156d? |  | finish no earlier than 2005-11-11 | G1 | 1248h | 1248h | TGSM810-BTStest | Huawei | chende@huawei.com | Rel-7 | Paolo | TGSM810-BTStest |  |
| 3452 | 893 | **Handover of dedicated and shared resources while in Dual Transfer Mode** |  | 421d? | 2005-04-08 A | 2006-11-17 A | 100% |  | 2005-04-08 | 2006-11-17 | 421d? |  |  | GP | 12672h | 12672h | HODSRDTM | Nokia | rami.vaittinen@nokia.com | Rel-7 | Paolo | HODSRDTM |  |
| 3453 | 893.1 | GERAN2 part of Handover of dedicated and shared resources while in Dual Transfer Mode |  | 321d? | 2005-04-08 A | 2006-06-30 A | 100% |  | 2005-04-08 | 2006-06-30 | 321d? |  | finish no earlier than 2006-06-30 | G2 | 2568h | 2568h | HODSRDTM-G2 | Nokia | rami.vaittinen@nokia.com | Rel-7 | Gert | HODSRDTM-G2 |  |
| 3454 | 893.2 | Deleted - MS Conformance Testing |  | 421d? | 2005-04-08 A | 2006-11-17 A | 100% |  | 2005-04-08 | 2006-11-17 | 421d? |  | finish no earlier than 2006-11-17 | G3new | 3368h | 3368h | HODSRDTM-MStest | Nokia | rami.vaittinen@nokia.com | Rel-7 | Ingbert | HODSRDTM-MStest | GP-32 |
| 3455 | 893.3 | Deleted - BTS conformance testing |  | 421d? | 2005-04-08 A | 2006-11-17 A | 100% |  | 2005-04-08 | 2006-11-17 | 421d? |  | finish no earlier than 2006-11-17 | G1 | 3368h | 3368h | HODSRDTM-BTStest | Nokia | rami.vaittinen@nokia.com | Rel-7 | Paolo | HODSRDTM-BTStest | GP-32 |
| 3456 | 894 | **Mobile Station Receive Diversity (DARP Phase II)** |  | 526d? | 2005-11-11 A | 2007-11-16 A | 100% |  | 2005-11-11 | 2007-11-16 | 526d? |  |  | GP | 16360h | 16360h | MSRD2 | Nokia | kent.pedersen@nokia.com | Rel-7 | Paolo | MSRD2 |  |
| 3457 | 894.1 | Performance Requirements for Mobile Station Receive Diversity, DARP Phase II |  | 331d? | 2005-11-11 A | 2007-02-16 A | 100% |  | 2005-11-11 | 2007-02-16 | 331d? |  | finish no earlier than 2007-02-16 | GP | 2648h | 2648h | MSRD2-PerfReq | Nokia | kent.pedersen@nokia.com | Rel-7 | Paolo | MSRD2-PerfReq |  |
| 3458 | 894.2 | Capability signalling of Mobile Station Receive Diversity, DARP Phase II |  | 331d? | 2005-11-11 A | 2007-02-16 A | 100% |  | 2005-11-11 | 2007-02-16 | 331d? |  | finish no earlier than 2007-02-16 | GP | 2648h | 2648h | MSRD2-CapSig | Nokia | kent.pedersen@nokia.com | Rel-7 | Paolo | MSRD2-CapSig |  |
| 3459 | 894.3 | Test Scenarios for Mobile Station Receive Diversity, DARP Phase II |  | 331d? | 2005-11-11 A | 2007-02-16 A | 100% |  | 2005-11-11 | 2007-02-16 | 331d? |  | finish no earlier than 2007-02-16 | GP | 2648h | 2648h | MSRD2-TestSc | Nokia | kent.pedersen@nokia.com | Rel-7 | Paolo | MSRD2-TestSc |  |
| 3460 | 894.4 | MS conformance test of DARP Phase II (MSRD) |  | 526d? | 2005-11-11 A | 2007-11-16 A | 100% |  | 2005-11-11 | 2007-11-16 | 526d? |  | finish no earlier than 2007-11-16 | GP | 4208h | 4208h | MSRD2-Msconf | Nokia | kent.pedersen@nokia.com | Rel-7 | Ingbert | MSRD2-Msconf |  |

Notes:
- 3437: -
- 3438: Completed / Impacted TSs and TRs: 24.008, 43.022, 44.018, 44.118, 45, 001, 45.005,
- 3439: -
- 3440: - / Impacted TSs and TRs: 51.021
- 3441: - / Impacted TSs and TRs: 51.010
- 3442: Originally started Nov. 2003 as GP-030443
- 3443: -
- 3444: -
- 3445: - / Impacted TSs and TRs: 43.955, 43.064, 44.060, 45.001, 45.002, 45.003, 45.005, 45.010, 51.010, 51.021
- 3446: -
- 3447: -
- 3448: - / Impacted TSs and TRs: 45.005, 45.050, 24.008, 45.008, 45.001, 43.022, 43.030, 44.018, 44.060, 51.010-1, 51.021
- 3449: - / Impacted TSs and TRs: 45.005, 45.050, 24.008, 45.008, 45.001, 43.022, 43.030, 44.018, 44.060
- 3450: - / Impacted TSs and TRs: 51010-1
- 3451: - / Impacted TSs and TRs: 51021
- 3452: GP#30 completed. Started at GP#24
- 3453: GP#30 completed / Impacted TSs and TRs: 43.055, 44.018, 44.060
- 3454: Stopped, no work done. 12/2008 Marked as stopped ("deleted") / Impacted TSs and TRs: 51-010
- 3455: Stopped, no work done. 12/2008 Marked as stopped ("deleted") / Impacted TSs and TRs: 51.026
- 3456: GP#36 completed
- 3457: GP#33 completed / Impacted TSs and TRs: 45.005
- 3458: GP#33 completed / Impacted TSs and TRs: 24.008
- 3459: GP#33 completed / Impacted TSs and TRs: 45.005
- 3460: GP#36 completed / Impacted TSs and TRs: 51.010

| ID | WBS | Task | Type | Duration | Start | Finish | Complete | Remaining | Baseline start | Baseline finish | Baseline duration | Total slack | Constraint | Resources | Work | Actual work | Acronym | WI rapporteur name | WI rapporteur e-mail | Release | MCC resp | Acronym_3GU_Export | TSG stopped |
| --- | --- | --- | --- | --- | --- | --- | --- | --- | --- | --- | --- | --- | --- | --- | --- | --- | --- | --- | --- | --- | --- | --- | --- |
| 3461 | 895 | **Downlink Dual Carrier** |  | 947d? | 2006-01-20 A | 2009-09-04 A | 100% |  | 2006-01-20 | 2009-09-04 | 947d? |  |  | GP | 15446.6h | 15446.6h | GDCDL | Nokia Siemens Networks | leonardo.provvedi@roke.co.uk | Rel-7 | Paolo | GDCDL |  |
| 3462 | 895.1 | Downlink Dual Carrier Stage 2 |  | 116d? | 2006-01-20 A | 2006-06-30 A | 100% |  | 2006-01-20 | 2006-06-30 | 116d? |  | finish no earlier than 2006-06-30 | G1 | 928h | 928h | GDCDL-Stage2 | Nokia Siemens Networks | leonardo.provvedi@roke.co.uk | Rel-7 | Paolo | GDCDL-Stage2 |  |
| 3463 | 895.2 | Downlink Dual Carrier Stage 3 |  | 421d? | 2006-01-20 A | 2007-08-31 A | 100% |  | 2006-01-20 | 2007-08-31 | 421d? |  | finish no earlier than 2007-08-31 | G1 | 3368h | 3368h | GDCDL-Stage3 | Nokia Siemens Networks | leonardo.provvedi@roke.co.uk | Rel-7 | Paolo | GDCDL-Stage3 |  |
| 3464 | 895.3 | Downlink Dual Carrier – MS Conformance Test |  | 446.82d? | 2006-01-20 A | 2009-09-04 A | 100% |  | 2006-01-20 | 2009-09-04 | 446.82d? |  | finish no earlier than 2009-09-04 | G3new | 3574.6h | 3574.6h | GDCDL-MStest | Nokia Siemens Networks | leonardo.provvedi@roke.co.uk | Rel-7 | Ingbert | GDCDL-MStest |  |
| 3465 | 896 | Support of SIGTRAN in GERAN |  | 116d? | 2006-01-20 A | 2006-06-30 A | 100% |  | 2006-01-20 | 2006-06-30 | 116d? |  | finish no earlier than 2006-06-30 | GP | 928h | 928h | GSIGT | Ericsson | peter.ostrup@ericsson.com | Rel-7 | Ingbert | GSIGT |  |
| 3466 | 897 | **Latency Reductions** |  | 306d? | 2006-06-30 A | 2007-08-31 A | 100% |  | 2006-06-30 | 2007-08-31 | 306d? |  |  | GP | 7344h | 7344h | LATRED | Ericsson | Hakan.Persson@Ericsson.com | Rel-7 | Paolo | LATRED |  |
| 3467 | 897.1 | Improved Ack/Nack reporting |  | 306d? | 2006-06-30 A | 2007-08-31 A | 100% |  | 2006-06-30 | 2007-08-31 | 306d? |  | finish no earlier than 2007-08-31 | G2 | 2448h | 2448h | LATRED-ACKNAR | Ericsson | Hakan.Persson@Ericsson.com | Rel-7 | Gert | LATRED-ACKNAR |  |
| 3468 | 897.2 | Reduced TTI |  | 306d? | 2006-06-30 A | 2007-08-31 A | 100% |  | 2006-06-30 | 2007-08-31 | 306d? |  | finish no earlier than 2007-08-31 | G2 | 2448h | 2448h | LATRED-REDTTI | Ericsson | Hakan.Persson@Ericsson.com | Rel-7 | Gert | LATRED-REDTTI |  |
| 3469 | 898 | PS Handover between GERAN/UTRAN mode and GAN Mode |  | 166d? | 2006-06-30 A | 2007-02-16 A | 100% |  | 2006-06-30 | 2007-02-16 | 166d? |  | finish no earlier than 2007-02-16 | G2 | 1328h | 1328h | GUGAN | Ericsson | John.Diachina@Ericsson.com | Rel-7 | Gert | GUGAN |  |
| 3470 | 899 | **Higher Uplink performance for GERAN Evolution** |  | 1227d? | 2006-09-08 A | 2011-05-20 A | 100% |  | 2006-09-08 | 2011-05-20 | 1227d? |  |  | GP | 37184h | 37184h | HUGE | Nokia Siemens Networks, Ericsson | eddie.riddington@nokia.com, stefan.g.eriksson@ericsson.com | Rel-7 | Paolo | HUGE |  |
| 3471 | 899.1 | Stage 2 for HUGE |  | 261d? | 2006-09-08 A | 2007-09-07 A | 100% |  | 2006-09-08 | 2007-09-07 | 261d? |  | finish no earlier than 2007-09-07 | G1 | 2088h | 2088h | HUGE-Stage2 | Nokia Siemens Networks, Ericsson | eddie.riddington@nokia.com, stefan.g.eriksson@ericsson.com | Rel-7 | Paolo | HUGE-Stage2 |  |
| 3472 | 899.2 | Layer 1 Support for HUGE |  | 381d? | 2006-09-08 A | 2008-02-22 A | 100% |  | 2006-09-08 | 2008-02-22 | 381d? |  | finish no earlier than 2008-02-22 | G1 | 3048h | 3048h | HUGE-Layer1 | Nokia Siemens Networks, Ericsson | eddie.riddington@nokia.com, stefan.g.eriksson@ericsson.com | Rel-7 | Paolo | HUGE-Layer1 |  |
| 3473 | 899.3 | Layer 2/3 Support for HUGE |  | 256d? | 2006-09-08 A | 2007-08-31 A | 100% |  | 2006-09-08 | 2007-08-31 | 256d? |  | finish no earlier than 2007-08-31 | G2 | 2048h | 2048h | HUGE-Layer23 | Nokia Siemens Networks, Ericsson | eddie.riddington@nokia.com, stefan.g.eriksson@ericsson.com | Rel-7 | Gert | HUGE-Layer23 |  |
| 3474 | 899.4 | Performance requirements for HUGE |  | 516d? | 2006-09-08 A | 2008-08-29 A | 100% |  | 2006-09-08 | 2008-08-29 | 516d? |  | finish no earlier than 2008-08-29 | G1 | 4128h | 4128h | HUGE-Perfreq | Nokia Siemens Networks, Ericsson | eddie.riddington@nokia.com, stefan.g.eriksson@ericsson.com | Rel-7 | Paolo | HUGE-Perfreq |  |
| 3475 | 899.5 | BTS Conformance Test for HUGE |  | 782d? | 2006-09-08 A | 2009-09-04 A | 100% |  | 2006-09-08 | 2009-09-04 | 782d? |  | finish no earlier than 2009-09-04 | G1 | 6248h | 6248h | HUGE-BTStest | Nokia Siemens Networks, Ericsson | eddie.riddington@nokia.com, stefan.g.eriksson@ericsson.com | Rel-7 | Paolo | HUGE-BTStest |  |
| 3476 | 899.6 | MS Conformance Test for HUGE |  | 1226d? | 2006-09-08 A | 2011-05-20 A | 100% |  | 2006-09-08 | 2011-05-20 | 1226d? |  | finish no earlier than 2011-05-20 | G3new | 9808h | 9808h | HUGE-Mstest | Nokia Siemens Networks, Ericsson | eddie.riddington@nokia.com, stefan.g.eriksson@ericsson.com | Rel-7 | Ingbert | HUGE-Mstest |  |
| 3477 | 900 | **REduced symbol Duration, Higher Order modulation and Turbo coding (RED HOT) for downlink** |  | 1177d? | 2006-11-17 A | 2011-05-20 A | 100% |  | 2006-11-17 | 2011-05-20 | 1177d? |  |  | GP | 28808h | 28808h | REDHOT | Ericsson, Nokia Siemens Networks, Marvell | stefan.g.eriksson@ericsson.com | Rel-7 | Paolo | REDHOT |  |
| 3478 | 900.1 | Stage 2 for REDHOT |  | 206d? | 2006-11-17 A | 2007-08-31 A | 100% |  | 2006-11-17 | 2007-08-31 | 206d? |  | finish no earlier than 2007-08-31 | G1 | 1648h | 1648h | REDHOT-Stage2 | Ericsson, Nokia Siemens Networks, Marvell | stefan.g.eriksson@ericsson.com | Rel-7 | Paolo | REDHOT-Stage2 |  |
| 3479 | 900.2 | Stage 3 for REDHOT |  | 391d? | 2006-11-17 A | 2008-05-16 A | 100% |  | 2006-11-17 | 2008-05-16 | 391d? |  | finish no earlier than 2008-05-16 | G1 | 3128h | 3128h | REDHOT-Stage3 | Ericsson, Nokia Siemens Networks, Marvell | stefan.g.eriksson@ericsson.com | Rel-7 | Paolo | REDHOT-Stage3 |  |
| 3480 | 900.3 | BTS Conformance Tests for REDHOT |  | 651d? | 2006-11-17 A | 2009-05-15 A | 100% |  | 2006-11-17 | 2009-05-15 | 651d? |  | finish no earlier than 2009-05-15 | G1 | 5208h | 5208h | REDHOT-BTStest | Ericsson, Nokia Siemens Networks, Marvell | stefan.g.eriksson@ericsson.com | Rel-7 | Paolo | REDHOT-BTStest |  |
| 3481 | 900.4 | MS Conformance Tests for REDHOT |  | 1176d? | 2006-11-17 A | 2011-05-20 A | 100% |  | 2006-11-17 | 2011-05-20 | 1176d? |  | finish no earlier than 2011-05-20 | G3new | 9408h | 9408h | REDHOT-Mstest | Ericsson, Nokia Siemens Networks, Marvell | stefan.g.eriksson@ericsson.com | Rel-7 | Ingbert | REDHOT-Mstest |  |
| 3482 | 901 | (Small) Technical Enhancements and Improvements for Rel-7 | milestone | 0d? | 2007-03-26 A | 2007-03-26 A | 100% |  | 2007-03-26 | 2007-03-26 | 0d? |  | start no earlier than 2007-03-26 | SP; CP; RP; GP |  |  | TEI7 |  |  | Rel-7 | All | TEI7 |  |
| 3483 | 902 | Test - (Small) Technical Enhancements and Improvements for Rel-7 |  | 389d? | 2006-06-02 A | 2007-11-28 A | 100% |  | 2006-06-02 | 2007-11-28 | 389d? |  | finish no earlier than 2010-06-04 | R5 | 3112h | 3112h | TEI7_Test |  |  | Rel-7 | Ingbert | TEI7_Test |  |
| 3484 | 903 | **Deleted - PS domain and IMS support for IMS Emergency sessions** |  | 63.69d? | 2006-06-23 A | 2006-09-21 | 99% | 0d? | 2006-06-23 | 2006-09-21 | 63.69d? | 0d |  | S2 |  |  | IMS-EMER | Nokia | curt.c.wong@nokia.com | Rel-7 | Maurice | IMS-EMER | SP-30 |
| 3485 | 903.1 | Deleted - IMS aspects to support IMS Emergency sessions | milestone | 0d? | 2006-06-23 A | 2006-09-21 A | 100% |  | 2006-06-23 | 2006-09-21 | 0d? |  | start no earlier than 2006-06-23 | S2 |  |  |  | Nokia | curt.c.wong@nokia.com | Rel-7 | Maurice |  | SP-30 |
| 3486 | 903.2 | Deleted - PS domain aspects to support IMS Emergency sessions | milestone | 0d? | 2006-06-23 A | 2006-09-21 A | 100% |  | 2006-06-23 | 2006-09-21 | 0d? |  | start no earlier than 2006-06-23 | S2 |  |  |  | Nokia | curt.c.wong@nokia.com | Rel-7 | Maurice |  | SP-30 |

Notes:
- 3461: GP#35 completed
- 3462: GP#30 completed / Impacted TSs and TRs: 43.055, 43.064
- 3463: GP#35 completed / Impacted TSs and TRs: 24.008, 44.018, 44.060, 45.001, 45.002, 45.005, 45.008
- 3464: GP#43 completed / Impacted TSs and TRs: 51.010
- 3465: GP#30 completed / Impacted TSs and TRs: 48.001, 48.006, 43.059, 49.031
- 3466: GP#35 completed / Impacted TSs and TRs: 45.001, 45.002, 45.003, 45.005, 45.010, 43.055, 43.064, 44.060, 51.010-1, 51.021
- 3467: GP#35 completed / Impacted TSs and TRs: 45.001, 45.002, 45.003, 45.005, 45.010, 43.055, 43.064, 44.060, 51.010-1, 51.021
- 3468: GP#35 completed / Impacted TSs and TRs: 45.001, 45.002, 45.003, 45.005, 45.010, 43.055, 43.064, 44.060, 51.010-1, 51.021
- 3469: GP#33 completed / Impacted TSs and TRs: 43.318, 44.318, 43.129, 25.306, 24.008, 44.060, 25.331, 51.010
- 3470: GP#39 completed
- 3471: GP#35 completed / Impacted TSs and TRs: 43.055, 43.064
- 3472: GP#37 completed / Impacted TSs and TRs: 45.001, 45.002, 45.003, 45.004, 45.008
- 3473: GP#35 completed / Impacted TSs and TRs: 24.008, 44.018, 44.060
- 3474: GP#39 completed / Impacted TSs and TRs: 45.005
- 3475: GP#43 completed / Impacted TSs and TRs: 51.021
- 3476: GP#50 completed / Impacted TSs and TRs: 51.010
- 3477: GP#38 completed
- 3478: GP#35 completed / Impacted TSs and TRs: 43.055, 43.064
- 3479: GP#38 completed / Impacted TSs and TRs: 24.008, 44.018, 44.060, 45.001, 45.002, 45.003, 45.004, 45.005, 45.008
- 3480: GP#42 completed / Impacted TSs and TRs: 51.021
- 3481: GP#50 completed / Impacted TSs and TRs: 51.010
- 3482: -
- 3483: -
- 3484: Approved at SP#29 / Impacted TSs and TRs: 23.867, 23.abc, 23.060, 23.002, 23.271
- 3485: Approved at SP#29 / Impacted TSs and TRs: 23.867, 23.abc, 23.060, 23.002, 23.271
- 3486: Approved at SP#29 / Impacted TSs and TRs: 23.867, 23.abc, 23.060, 23.002, 23.271

| ID | WBS | Task | Type | Duration | Start | Finish | Complete | Remaining | Baseline start | Baseline finish | Baseline duration | Total slack | Constraint | Resources | Work | Actual work | Acronym | Impacted TSs and TRs | Release | MCC resp | TSG stopped | Acronym_3GU_Export | WI rapporteur name | WI rapporteur e-mail | Special Focus Doc |
| --- | --- | --- | --- | --- | --- | --- | --- | --- | --- | --- | --- | --- | --- | --- | --- | --- | --- | --- | --- | --- | --- | --- | --- | --- | --- |
| 3487 | 16.7 | **Deleted - IMS Local services** |  | 0d? | 2006-01-06 A | 2006-01-06 | 99% | 0d? | 2006-01-06 | 2006-01-06 | 0d? | 0d |  | S2 |  |  | IMSLocal | 23.228 | Rel-7 | Maurice | SP-28 | IMSLocal |  |  |  |
| 3488 | 16.7.1 | Deleted - Stage 2 | milestone | 0d | 2006-01-06 A | 2006-01-06 A | 100% |  | 2006-01-06 | 2006-01-06 | 0d |  | start no earlier than 2006-01-06 | S2 |  |  |  |  | Rel-7 | Maurice | SP-26 |  |  |  |  |
| 3489 | 904.2 | Deleted - Stage 3 for IMS Local services | milestone | 0d? | 2006-01-06 A | 2006-01-06 A | 100% |  | 2006-01-06 | 2006-01-06 | 0d? |  | finish no earlier than 2006-01-06 | C1 |  |  |  |  | Rel-7 | Frederic | SP-25 |  | Lucent | Keith Drage (drage@alcatel-lucent.com) |  |
| 3490 | 905 | Deleted - IMS Phase 3 | milestone | 0d? | 2006-01-06 A | 2006-01-06 A | 100% |  | 2006-01-06 | 2006-01-06 | 0d? |  | start no earlier than 2006-01-06 | S2 |  |  |  |  | Rel-7 | Maurice | SP-25 |  |  |  |  |
| 3491 | 906 | Deleted - Improvements of Radio Interface | milestone | 0d? | 2004-09-15 A | 2004-09-15 A | 100% |  | 2004-09-15 | 2004-09-15 | 0d? |  | start no earlier than 2004-09-15 | RP |  |  |  |  | Rel-7 | Issam | SP-24 |  |  |  |  |
| 3492 | 907 | Deleted: Generic User Profile Phase 2 | milestone | 0d | 2005-08-08 A | 2006-06-30 A | 100% |  | 2005-08-08 | 2006-06-30 | 0d |  |  | C4 |  |  |  |  | Rel-7 | Kimmo | SP-27 |  |  |  |  |
| 3493 | 30.4 | Deleted - Stage 3 - Common objects | milestone | 0d | 2005-08-08 A | 2006-06-30 A | 100% |  | 2005-08-08 | 2006-06-30 | 0d |  | finish no earlier than 2006-06-30 | C4 |  |  |  | 24.241 | Rel-7 | Kimmo | SP-27 |  |  |  |  |
| 3494 | 909 | Release 7 Studies |  | 841d? | 2004-06-28 A | 2007-09-17 A | 100% |  | 2004-06-28 | 2007-09-17 | 841d? |  |  | CP; GP; RP; SP | 26912h | 26912h |  |  | Rel-7 | All |  |  |  |  |  |
| 3495 | 910 | Study on Multimedia Telephony Capabilities for IMS |  | 276d? | 2005-07-11 A | 2006-07-31 A | 100% |  | 2005-07-11 | 2006-07-31 | 276d? |  |  | S1 | 2145.6h | 2145.6h | MITE | 22.973 | Rel-7 | Alain |  | MITE | Ericsson | peter.bleckert@ericsson.com |  |
| 3496 | 911 | Study on Behaviour of Multi system UEs |  | 384d? | 2004-06-28 A | 2005-12-15 A | 100% |  | 2004-06-28 | 2005-12-15 | 384d? |  | start no earlier than 2004-06-28 | S1 | 3072h | 3072h | BMSU | 22.936 | Rel-7 | Alain |  | BMSU | Qualcomm | dwilliams@qualcomm.com |  |
| 3497 | 912 | Study on Combining CS calls and IMS sessions |  | 189d? | 2004-06-28 A | 2005-03-17 A | 100% |  | 2004-06-28 | 2005-03-17 | 189d? |  | start no earlier than 2004-06-28 | S1 | 1512h | 1512h | IRTSD-CS_IMS | 22.979 | Rel-7 | Alain |  | IRTSD-CS_IMS | TeliaSonera | robert.frank@teliasonera.com |  |
| 3498 | 913 | Study on All-IP Network |  | 188d? | 2004-06-28 A | 2005-03-16 A | 100% |  | 2004-06-28 | 2005-03-16 | 188d? |  | start no earlier than 2004-06-28 | S1 | 1504h | 1504h | FS_AIPN | 22.978 | Rel-7 | Alain |  | FS_AIPN | NTT DoCoMo | Shin-ichi Isobe (isobes@nttdocomo.co.jp) |  |
| 3499 | 914 | Study on Videotelephony teleservice |  | 231d? | 2005-03-01 A | 2006-01-17 A | 100% |  | 2005-03-01 | 2006-01-17 | 231d? |  |  | S1 | 1848h | 1848h | VidTel | 22.903 | Rel-7 | Alain |  | VidTel | T-Mobile | michael.kurz@t-mobile.at |  |
| 3500 | 915 | Study on Network Selection Principles |  | 193d? | 2005-03-15 A | 2005-12-08 A | 100% |  | 2005-03-15 | 2005-12-08 | 193d? |  |  | S1 | 1544h | 1544h | NetSel | 22.811 | Rel-7 | Alain |  | NetSel | O2 | chris.friel@O2.com |  |
| 3501 | 916 | Study on Multimedia Priority Service |  | 851d? | 2003-03-28 A | 2006-06-30 A | 100% |  | 2003-03-28 | 2006-06-30 | 851d? |  | finish no earlier than 2005-12-16 | S1 | 6808h | 6808h | PRIOR-MM | 22.953 | Rel-7 | Alain |  | PRIOR-MM | Telcordia | James Garrahan (jgarraha@telcordia.com) | Public Safety (I-A) |
| 3502 | 917 | Study on Transferring of emergency Call data |  | 190d? | 2005-07-11 A | 2006-03-31 A | 100% |  | 2005-07-11 | 2006-03-31 | 190d? |  | finish no earlier than 2005-12-08 | S1 | 1520h | 1520h | eCALL | 22.967 | Rel-7 | Alain |  | eCALL | Motorola | jian.j.wu@motorola.com | Public Safety (I-A) |
| 3503 | 918 | Study on Enhancement of E2E QoS |  | 281.4d? | 2004-06-28 A | 2005-09-15 A | 100% |  | 2004-06-28 | 2005-09-15 | 281.4d? |  | finish no earlier than 2005-12-01 | S2 | 2251.2h | 2251.2h | QoS7 | 23.802 | Rel-7 | Maurice |  | QoS7 | Huawei | Robert Jaksa |  |
| 3504 | 919 | Study on SOAP/HTTP IRP Solution Sets |  | 330d? | 2005-09-02 A | 2006-12-07 A | 100% |  | 2005-09-02 | 2006-12-07 | 330d? |  | finish no earlier than 2006-12-07 | S5 | 2640h | 2640h | OAM7-NIM-XML | 32.809 | Rel-7 | Mirko |  | OAM7-NIM-XML | Nortel | Suzèle Lariven (lariven@nortel.com) |  |
| 3505 | 920 | Study on Itf-N Implementation Conformance Statement (ICS) template |  | 400d? | 2005-09-02 A | 2007-03-15 A | 100% |  | 2005-09-02 | 2007-03-15 | 400d? |  | finish no earlier than 2007-03-15 | S5 | 3200h | 3200h | OAM7-NIM-ICS | 32.812 | Rel-7 | Mirko |  | OAM7-NIM-ICS | China Mobile | Li Yewen (liyewen@chinamobile.com) |  |
| 3506 | 921 | Study on IRP Information Model |  | 400d? | 2005-09-02 A | 2007-03-15 A | 100% |  | 2005-09-02 | 2007-03-15 | 400d? |  | finish no earlier than 2007-03-15 | S5 | 3200h | 3200h | OAM7-NIM-IM | 32.810 | Rel-7 | Mirko |  | OAM7-NIM-IM | Motorola | trevor.pirt@motorola.com |  |
| 3507 | 922 | Study on Bandwidth Saving at Nb Interface with IP transport |  | 261d? | 2006-03-10 A | 2007-03-09 A | 100% |  | 2006-03-10 | 2007-03-09 | 261d? |  | finish no earlier than 2007-03-09 | C3 | 2088h | 2088h | BSNbIP | 29.814 | Rel-7 | Adrian |  | BSNbIP | Siemens | Thomas.Belling@siemens.com |  |
| 3508 | 923 | Study on Routeing of MT-SMS via the HPLMN |  | 301d? | 2005-10-07 A | 2006-12-01 A | 100% |  | 2005-10-07 | 2006-12-01 | 301d? |  | finish no earlier than 2006-12-01 | C4 | 2408h | 2408h | SMS7 | 23.840 | Rel-7 | Kimmo |  | SMS7 | Vodafone | Nick.Russell@vodafone.com |  |
| 3509 | 924 | Feasibility Study on the TCAPsec Gateway concept |  | 96d? | 2005-10-28 A | 2006-03-10 A | 100% |  | 2005-10-28 | 2006-03-10 | 96d? |  | finish no earlier than 2006-03-10 | C4 | 768h | 768h | FS_SEC7-TCAP | 29.800 | Rel-7 | Kimmo |  | FS_SEC7-TCAP | Siemens | Ulrich.wiehe@gksag.de |  |
| 3510 | 925 | Study on using M2PA in 3GPP network |  | 318d? | 2006-03-22 A | 2007-06-08 A | 100% |  | 2006-03-22 | 2007-06-08 | 318d? |  | finish no earlier than 2007-06-08 | C4 | 2544h | 2544h | FS-M2PA | 29.801 | Rel-7 | Kimmo |  | FS-M2PA | China Mobile | zhaoyuyi@chinamobile.com |  |

Notes:
- 3487: -
- 3488: DAB - Not yet required in SA2 as it exists in previous releases
- 3489: -
- 3490: -
- 3491: Stage 2 description of Interim conclusion
- 3492: Created at TSG#27 by A. Sultan because of the move to Rel-7 of "Common Objects".
- 3493: No progress in CN4#26. This have to be moved to Rel-7. It was deleted from WID
- 3494: -
- 3495: Spin-off Feature UID_7038 (MTSI)
- 3496: -
- 3497: -
- 3498: 07/08 Moved to Rel-7 as Study out of stopped Rel-8 Feature UID_31067 All-IP Network (AIPN)
- 3499: -
- 3500: Spin-off Feature Network selection enhancements (NSP-CR) UID_7041
- 3501: Spin-off Feature PRIOR UID_340044
- 3502: -
- 3503: -
- 3504: SP#34 completed
- 3505: SP#35 completed
- 3506: SP#35 completed
- 3507: Moved to FS at CT32 (in line with slides)
- 3508: Previously known as "Study of a SMS Centre for MT SMS"
- 3509: TR 29.800 content moved to TS 29.204 under implementation WI UID_310005 TCAPsec Gateway
- 3510: -

| ID | WBS | Task | Type | Duration | Start | Finish | Complete | Remaining | Baseline start | Baseline finish | Baseline duration | Total slack | Constraint | Resources | Work | Actual work | Acronym | Impacted TSs and TRs | WI rapporteur name | WI rapporteur e-mail | Release | MCC resp | Acronym_3GU_Export | Status Report | Special Focus Doc | TSG stopped |
| --- | --- | --- | --- | --- | --- | --- | --- | --- | --- | --- | --- | --- | --- | --- | --- | --- | --- | --- | --- | --- | --- | --- | --- | --- | --- | --- |
| 3511 | 926 | **Study on Support of (G)MSC-S - (G)MSC-S Nc Interface based on the SIP-I protocol** |  | 350d? | 2006-05-15 A | 2007-09-14 A | 100% |  | 2006-05-15 | 2007-09-14 | 350d? |  |  | C4; C3 | 10600h | 10600h | NcSIP | 29.802 | Vodafone | david.hutton@vodafone.com | Rel-7 | Kimmo | NcSIP |  |  |  |
| 3512 | 926.1 | CT4 aspects of NcSIP |  | 275d? | 2006-05-15 A | 2007-06-01 A | 100% |  | 2006-05-15 | 2007-06-01 | 275d? |  | finish no earlier than 2007-06-01 | C4 | 2200h | 2200h |  | 29.802 | Vodafone | david.hutton@vodafone.com | Rel-7 | Kimmo |  |  |  |  |
| 3513 | 926.2 | CT3 aspects of NcSIP |  | 350d? | 2006-05-15 A | 2007-09-14 A | 100% |  | 2006-05-15 | 2007-09-14 | 350d? |  | finish no earlier than 2007-09-14 | C3 | 2800h | 2800h |  | 29.802 | Ericsson | ragnar.huslende@ericsson.com | Rel-7 | Adrian |  |  |  |  |
| 3514 | 927 | Study on Evolved UTRA and UTRAN |  | 458d? | 2004-12-15 A | 2006-09-15 A | 100% |  | 2004-12-15 | 2006-09-15 | 458d? |  | finish no earlier than 2006-09-15 | RP | 3664h | 3664h | RANFS-Evo | 25.912 | NTT DoCoMo | nakamurata@NTTDOCOMO.CO.JP | Rel-7 | Issam | RANFS-Evo | RP-060472 |  |  |
| 3515 | 928 | Study on Performance Evaluation of the UE behaviour in high speed trains with speeds up to 350 kmph |  | 328d? | 2005-03-15 A | 2006-06-15 A | 100% |  | 2005-03-15 | 2006-06-15 | 328d? |  | finish no earlier than 2006-06-15 | R4 | 2624h | 2624h | RANFS-HSTrains | none | Vodafone | Mike.vogel@vodafone.com,tim.frost@vodafone.com | Rel-7 | Issam | RANFS-HSTrains | RP-060412 |  |  |
| 3516 | 929 | Study on UTRA Tower Mounted Amplifier (FDD) |  | 195d? | 2005-06-15 A | 2006-03-14 A | 100% |  | 2005-06-15 | 2006-03-14 | 195d? |  | finish no earlier than 2006-03-15 | R4 | 1560h | 1560h | RANFS-TMA | 25.818 | Ericsson | Klas.Sjerling@ericsson.com | Rel-7 | Issam | RANFS-TMA | RP-060035 |  |  |
| 3517 | 930 | Study on Continuous connectivity for packet data users |  | 132d? | 2005-03-15 A | 2005-09-14 A | 100% |  | 2005-03-15 | 2005-09-14 | 132d? |  | finish no earlier than 2005-09-15 | R1 | 1056h | 1056h | RANFS-cont-packet | none | Siemens | joerg.gustrau@siemens.com | Rel-7 | Patrick | RANFS-cont-packet | RP-050427 |  |  |
| 3518 | 931 | Study on Improvement of the Multimedia Broadcast Multicast Service (MBMS) in UTRAN |  | 262d? | 2005-12-15 A | 2006-12-15 A | 100% |  | 2005-12-15 | 2006-12-15 | 262d? |  | finish no earlier than 2006-12-15 | R2 | 2096h | 2096h | RANFS-MBMSImp | 25.905 | LG Electronics | leego@lge.com | Rel-7 | Yong-Jun | RANFS-MBMSImp | RP-060692 |  |  |
| 3519 | 932 | Deleted - Study on Performance Improvements in Small Cells using HSDPA/EDCH |  | 131d? | 2005-12-15 A | 2006-06-15 A | 100% |  | 2005-12-15 | 2006-06-15 | 131d? |  | finish no earlier than 2006-06-15 | R1; R4 | 2096h | 2096h | SMALLCELLS | none | Cingular | Marc Grant | Rel-7 | Issam | SMALLCELLS | RP-060263 | Small cell |  |
| 3520 | 933 | Study on Further Improved Performance Requirements for UMTS/HSDPA UE (FDD) |  | 383d? | 2005-12-15 A | 2007-06-04 A | 100% |  | 2005-12-15 | 2007-06-04 | 383d? |  | finish no earlier than 2007-06-04 | R4 | 3064h | 3064h | RANFS-IC | 25.963 | Cingular | Marc Grant | Rel-7 | Issam | RANFS-IC | RP-070499 |  |  |
| 3521 | 934 | Study on Scope of future FDD HSPA Evolution |  | 394d? | 2006-03-15 A | 2007-09-17 A | 100% |  | 2006-03-15 | 2007-09-17 | 394d? |  | finish no earlier than 2007-09-17 | RP | 3152h | 3152h | RANFS-HSPAEvo | 25.999 | Cingular | Don Zelmer (dz1069@att.com) | Rel-7 | Issam | RANFS-HSPAEvo | RP-070533 |  |  |
| 3522 | 935 | Study on Dynamically reconfiguring a FDD UE receiver to reduce power consumption when desired Quality of Service is met | milestone | 0d? | 2007-06-22 A | 2007-06-22 A | 100% |  | 2007-06-22 | 2007-06-22 | 0d? |  |  | R4 |  |  | FSUEPow | 25.906 | Nokia | Chris.callender@nokia.com, tiina.s.koskinen@nokia.com | Rel-7 | Issam | FSUEPow | RP-070534 |  |  |
| 3523 | 936 | Study on Future GERAN Evolution |  | 486d? | 2005-04-08 A | 2007-02-16 A | 100% |  | 2005-04-08 | 2007-02-16 | 486d? |  | finish no earlier than 2007-02-16 | GP | 3888h | 3888h | FGE | 45.912 | Nokia | eddie.riddington@nokia.com | Rel-7 | Paolo | FGE |  |  |  |
| 3524 | 937 | Study on GAN Enhancements | milestone | 0d? | 2007-08-31 A | 2007-08-31 A | 100% |  | 2007-08-31 | 2007-08-31 | 0d? |  | start no earlier than 2007-08-31 | GP |  |  | EGAN | 43.902 | T-Mobile | janne.linkola@t-mobile.com | Rel-7 | Paolo | EGAN |  |  |  |
| 3525 | 938 | Deleted - Study on IMS with real time services deployment |  | 316d? | 2004-06-28 A | 2005-09-12 A | 100% |  | 2004-06-28 | 2005-09-12 | 316d? |  |  | S1 | 2528h | 2528h | IRTSD |  |  |  | Rel-7 | Alain | IRTSD |  |  | SP-30 |
| 3526 | 939 | Deleted - Covered by SI - Personal Network (PN) and Personal Area Network (PAN) | milestone | 0d? | 2005-12-08 A | 2005-12-20 A | 100% |  | 2005-12-08 | 2005-12-20 | 0d? |  | start no earlier than 2005-12-08 | S1 |  |  | PNPAN |  | Vodafone | armin.toepfer@vodafone.com | Rel-7 | Alain | PNPAN |  |  | SP-30 |
| 3527 | 940 | Deleted - Study on Customised Alerting Tone (CAT) Requirements (was duplicated) | milestone | 0d? | 2006-06-30 A | 2006-06-30 A | 100% |  | 2006-06-30 | 2006-06-30 | 0d? |  | start no earlier than 2006-06-30 | S1 |  |  |  |  |  |  | Rel-7 | Alain |  |  |  | SP-31 |
| 3528 | 941 | Deleted - IMS security extensions (covered by UID33027) | milestone | 0d? | 2005-12-08 A | 2005-12-08 A | 100% |  | 2005-12-08 | 2005-12-08 | 0d? |  | start no earlier than 2005-12-08 | S3 |  |  | IMS-SE |  | Ericsson | Bengt.Sahlin@ericsson.com | Rel-7 | Mirko | IMS-SE |  |  | SP-30 |
| 3529 | 942 | **Deleted - Study on applicability of GALILEO for LCS** |  | 0d? | 2005-06-30 A | 2005-06-30 | 99% | 0d? | 2005-06-30 | 2005-06-30 | 0d? | 0d |  | S2 |  |  | Galileo |  |  |  | Rel-7 | Maurice | Galileo |  |  | SP-25 |
| 3530 | 942.1 | Deleted - TR on Stage 2 | milestone | 0d? | 2005-06-30 A | 2005-06-30 A | 100% |  | 2005-06-30 | 2005-06-30 | 0d? |  | finish no earlier than 2005-06-30 | S2 |  |  |  |  |  |  | Rel-7 | Maurice |  |  |  | SP-25 |
| 3531 | 942.2 | Deleted - GERAN review of the TR | milestone | 0d? | 2005-06-30 A | 2005-06-30 A | 100% |  | 2005-06-30 | 2005-06-30 | 0d? |  | start no earlier than 2005-06-30 | GP |  |  |  |  |  |  | Rel-7 | Paolo |  |  |  | SP-26 |
| 3532 | 943 | Deleted - Study on Stage 2 (IMS services using CS bearers) |  | 316d? | 2004-06-28 A | 2005-09-12 A | 100% |  | 2004-06-28 | 2005-09-12 | 316d? |  | finish no earlier than 2005-09-12 | S2 | 2528h | 2528h | IRTSD-IMSCS | 23.899 | Nortel | Mark Watson | Rel-7 | Maurice | IRTSD-IMSCS |  |  | SP-30 |
| 3533 | 944 | **Deleted - VoIMS bearer related enhancements** |  | 0d? | 2006-07-21 A | 2006-07-21 | 99% | 0d? | 2006-07-21 | 2006-07-21 | 0d? | 0d |  | S2 |  |  | VoIMS |  |  |  | Rel-7 | Maurice | VoIMS |  |  | SP-32 |
| 3534 | 944.1 | Deleted - Study on enhancement of radio performance for VoIMS | milestone | 0d? | 2006-07-21 A | 2006-07-21 A | 100% |  | 2006-07-21 | 2006-07-21 | 0d? |  | start no earlier than 2006-07-21 | S2 |  |  |  | 23.807 | Nortel | Laurence Lautier (lautierl@nortel.com) | Rel-7 | Maurice |  |  |  | SP-32 |
| 3535 | 945 | Deleted - Study on IMS enhancements and optimizations for real time communication. |  | 430d? | 2005-10-10 A | 2007-06-01 A | 100% |  | 2005-10-10 | 2007-06-01 | 430d? |  | finish no earlier than 2007-06-01 | S2 | 3440h | 3440h | IMS-RT | 23.818 | Ericsson | stephen.terrill@ericsson.com | Rel-7 | Maurice | IMS-RT |  |  | SP-35 |
| 3536 | 946 | Deleted - Study on Terminating Session handling |  | 255d? | 2006-01-09 A | 2006-12-29 A | 100% |  | 2006-01-09 | 2006-12-29 | 255d? |  | finish no earlier than 2006-12-29 | S2 | 2040h | 2040h | CSIterm | 23.819 | Samsung |  | Rel-7 | Maurice | CSIterm |  |  | SP-32 |
| 3537 | 947 | Deleted eCALLIBMS - Study on Transferring of emergency call data – in-band modem solution (moved to Rel-8) | milestone | 0d? | 2007-06-22 A | 2007-06-22 A | 100% |  | 2007-06-22 | 2007-06-22 | 0d? |  | start no earlier than 2007-06-22 | S4 |  |  |  | 26.967 | Airbiquity | lhong@airbiquity.com | Rel-7 | Paolo |  |  | Public Safety (I-A) | SP-38 |
| 3538 | 948 | Deleted - Study on IRP usage scenarios |  | 330d? | 2005-09-02 A | 2006-12-07 A | 100% |  | 2005-09-02 | 2006-12-07 | 330d? |  | finish no earlier than 2006-12-07 | S5 | 2640h | 2640h | OAM-Study | 32.8xy | Lucent |  | Rel-7 | Mirko | OAM-Study |  |  | SP-32 |
| 3539 | 949 | Deleted - Study on Interference Cancellation for UTRA FDD UE (covered by UID 20053) |  | 1d? | 2007-03-28 A | 2007-03-28 A | 100% |  | 2007-03-28 | 2007-03-28 | 1d? |  | start no earlier than 2007-03-28 | R4 | 8h | 8h | RANFS-InterfCanc |  |  |  | Rel-7 | Issam | RANFS-InterfCanc |  |  | SP-38 |
| 3540 | 950 | Deleted - Study on enhanced support of Video Telephony | milestone | 0d? | 2006-06-30 A | 2006-06-30 A | 100% |  | 2006-06-30 | 2006-06-30 | 0d? |  | start no earlier than 2006-06-30 | GP |  |  | VIDGER |  | Ericsson | stefan.g.eriksson@ericsson.com | Rel-7 | Paolo | VIDGER |  |  | SP-32 |
| 3541 | 951 | Release 6 Features |  | 915d? | 2002-06-28 A | 2005-12-30 A | 100% |  | 2002-06-28 | 2005-12-30 | 915d? |  |  | NP; GP; RP; SP; TP | 36600h | 36600h |  |  |  |  | Rel-6 | All |  |  |  |  |

Notes:
- 3511: -
- 3512: -
- 3513: -
- 3514: RP#33 (Sep 2006) completed. SR in RP-060472
- 3515: RP#32 (Jun 2006) completed. SR in RP-060412
- 3516: RP#31 (Mar 2006) completed. SR in RP-060035
- 3517: RP#29 (Sep 2006) completed. SR in RP-050427
- 3518: RP#34 completed
- 3519: RP#32 (Jun 2006) stopped at 0% completion
- 3520: RP#36 (May 2007) completed. SR in RP-070499
- 3521: RP#37 (Sep 2007) completed. SR in RP-070533
- 3522: RP#37 (Sep 2007) completed. SR in RP-070534
- 3523: GP#33 completed
- 3524: GP#35 completed
- 3525: -
- 3526: -
- 3527: Awaiting MCC SA3 input
- 3528: -
- 3529: -
- 3530: -
- 3531: -
- 3532: SP-30: S2 has no intention for TR completion
- 3533: Created by MCC to group all VoIMS related items, after consultation of chairs
- 3534: WID approved SP#28. SA2#52 stopped
- 3535: abandoned at 65%
- 3536: SP#32 Jun 2006 Study abandoned => spin-off Implementation work UID_320029
- 3537: SP-38 stopped
- 3538: -
- 3539: Deleted. Same as FS on Further Improved Performance Requirements for UMTS/HSDPA UE (FDD)
- 3540: FS CLOSED at G#28 (no input)
- 3541: -

| ID | WBS | Task | Type | Duration | Start | Finish | Complete | Baseline start | Baseline finish | Baseline duration | Constraint | Resources | Work | Actual work | Release | Acronym | WI rapporteur name | WI rapporteur e-mail | MCC resp | Acronym_3GU_Export | Impacted TSs and TRs | Created at | TSG stopped |
| --- | --- | --- | --- | --- | --- | --- | --- | --- | --- | --- | --- | --- | --- | --- | --- | --- | --- | --- | --- | --- | --- | --- | --- |
| 3542 | 8 | **Rel-6 Improvements of Radio Interface** |  | 1645d? | 2000-08-14 A | 2006-12-01 A | 100% | 2000-08-14 | 2006-12-01 | 1645d? |  | R2; R4; R5 | 87632h | 87632h | Rel-6 |  |  |  |  |  |  |  |  |
| 3543 | 952.1 | Improved support of IMS Realtime Services using HSDPA/EDCH |  | 197d? | 2005-03-15 A | 2005-12-14 A | 100% | 2005-03-15 | 2005-12-14 | 197d? | finish no earlier than 2005-12-14 | R2 | 1576h | 1576h | Rel-6 | RInImp-IMSRealTime | Cingular | Don Zelmer (dz1069@att.com) | Yong-Jun | RInImp-IMSRealTime |  |  |  |
| 3544 | 952.2 | Improving Receiver Performance Requirements for the FDD UE |  | 401d | 2002-03-08 A | 2003-09-19 A | 100% | 2002-03-08 | 2003-09-19 | 401d | start no earlier than 2002-03-08 | R4 | 3208h | 3208h | Rel-6 | RInImp-UERecPerf | Intel | shimon.moshavi@INTEL.COM | Issam | RInImp-UERecPerf | 25.101 |  |  |
| 3545 | 8.2 | **Base station classification for FDD** |  | 603d | 2000-08-14 A | 2002-12-04 A | 100% | 2000-08-14 | 2002-12-04 | 603d |  | R4 | 9648h | 9648h | Rel-6 | RInImp-BSClass-FDD |  |  | Issam | RInImp-BSClass-FDD |  |  |  |
| 3546 | 8.2.1 | FDD Base station classification |  | 603d | 2000-08-14 A | 2002-12-04 A | 100% | 2000-08-14 | 2002-12-04 | 603d | finish no earlier than 2002-12-04 | R4 | 4824h | 4824h | Rel-6 |  | Nokia | antti.toskala@nokia.com | Issam |  | 25.104, 25.141 |  |  |
| 3547 | 952.4 | UMTS-850 |  | 266d | 2002-12-06 A | 2003-12-12 A | 100% | 2002-12-06 | 2003-12-12 | 266d | finish no earlier than 2003-12-15 | R4 | 2128h | 2128h | Rel-6 | RInImp-UMTS850 | Cingular | Don Zelmer (dz1069@att.com) | Issam | RInImp-UMTS850 | 25.101, 25.104, 25.133, 25.141, 25.307, 25.331, 25.942 |  |  |
| 3548 | 952.5 | DS-CDMA introduction in the 800 MHz band |  | 196d | 2003-03-14 A | 2003-12-12 A | 100% | 2003-03-14 | 2003-12-12 | 196d | finish no earlier than 2003-12-15 | R4 | 1568h | 1568h | Rel-6 | RInImp-UMTS800 | NTT DoCoMo | Takehiro Nakamura (nakamurata@nttdocomo.co.jp) | Issam | RInImp-UMTS800 | 25.101, 25.104, 25.133, 25.141, 25.307, 25.331 |  |  |
| 3549 | 952.6 | UMTS 1.7/2.1 GHz | milestone | 0d? | 2003-03-14 A | 2003-03-14 A | 100% | 2003-03-14 | 2003-03-14 | 0d? |  | R4 |  |  | Rel-6 | RInImp-UMTS1721 | Nokia | jussi.numminen@NOKIA.COM | Issam | RInImp-UMTS1721 | 25.101, 25.104, 25.133, 25.141, 25.307, 25.331 |  |  |
| 3550 | 952.7 | Conformance Test Aspects – UMTS 1.7/2.1 GHz Band |  | 191d? | 2006-03-10 A | 2006-12-01 A | 100% | 2006-03-10 | 2006-12-01 | 191d? | finish no earlier than 2006-12-01 | R5 | 1528h | 1528h | Rel-6 | RInImp-UMTS1721_Test | Motorola | carolyn.taylor@motorola.com | Ingbert | RInImp-UMTS1721_Test | TS34.121, TS34.108 |  |  |
| 3551 | 952.8 | **Improved Receiver Performance Requirements for HSDPA** |  | 711d | 2003-09-19 A | 2006-06-09 A | 100% | 2003-09-19 | 2006-06-09 | 711d |  | R4; R5 | 28496h | 28496h | Rel-6 | RInImp-HSPerf | Nokia | jussi.numminen@NOKIA.COM | Issam | RInImp-HSPerf |  |  |  |
| 3552 | 952.8.1 | Improved Minimum Performance Requirements for HSDPA UE categories 7 and 8 |  | 453d | 2004-09-15 A | 2006-06-09 A | 100% | 2004-09-15 | 2006-06-09 | 453d |  | R4 | 3624h | 3624h | Rel-6 | RInImp-HSPerf-10code | Nokia | jussi.numminen@nokia.com | Issam | RInImp-HSPerf-10code | 25.101 |  |  |
| 3553 | 952.8.2 | Testing of Improved Minimum Performance for HSDPA |  | 650d | 2003-09-19 A | 2006-03-16 A | 100% | 2003-09-19 | 2006-03-16 | 650d | finish no earlier than 2006-03-16 | R5 | 5200h | 5200h | Rel-6 | RInImp-HSPerf-10Code_Test | Motorola | carolyn.taylor@motorola.com | Ingbert | RInImp-HSPerf-10Code_Test | 34.108, 34.121, 34.122, 34.123-1, 34.123-2, 34.123-3 | 19/9/2003 |  |
| 3554 | 952.8.3 | Performance Requirements of Receive Diversity for HSDPA |  | 387d | 2003-12-15 A | 2005-06-07 A | 100% | 2003-12-15 | 2005-06-07 | 387d |  | R4 | 3096h | 3096h | Rel-6 | RInImp-HSPerf-RxDiv | NTT DoCoMo | Takehiro Nakamura (nakamurata@nttdocomo.co.jp) | Issam | RInImp-HSPerf-RxDiv | 25.101 |  |  |
| 3555 | 952.8.4 | Testing of Performance of Receiver diversity for HSDPA |  | 650d | 2003-09-19 A | 2006-03-16 A | 100% | 2003-09-19 | 2006-03-16 | 650d | finish no earlier than 2006-03-16 | R5 | 5200h | 5200h | Rel-6 | RInImp-HSPerf-RxDiv_Test | Motorola | carolyn.taylor@motorola.com | Ingbert | RInImp-HSPerf-RxDiv_Test | 34.108, 34.121, 34.122, 34.123-1, 34.123-2, 34.123-3 | 19/9/2003 |  |
| 3556 | 953 | **Rel-6 RAN Feasibility Studies** |  | 1196d? | 2000-08-14 A | 2005-03-14 A | 100% | 2000-08-14 | 2005-03-14 | 1196d? |  | RP | 43048h | 43048h | Rel-6 |  |  |  |  |  |  |  |  |
| 3557 | 953.1 | FS of the improved access to UE measurement data for CRNC to support TDD RRM |  | 270d? | 2002-12-06 A | 2003-12-18 A | 100% | 2002-12-06 | 2003-12-18 | 270d? | finish no earlier than 2003-09-19 | R3 | 2160h | 2160h | Rel-6 | RANimp-RRMopt-FSUEMsD | Interdigital | jim.miller@interdigital.com | Juha | RANimp-RRMopt-FSUEMsD | 25.801, 25.423 | SP-24 |  |
| 3558 | 953.2 | FS on Radio link performance enhancements |  | 1067d | 2000-08-14 A | 2004-09-14 A | 100% | 2000-08-14 | 2004-09-14 | 1067d | finish no earlier than 2004-09-14 | R1 | 8536h | 8536h | Rel-6 | RInImp-Rlperf | Nokia | antti.toskala@nokia.com | Patrick | RInImp-Rlperf | 25.899 |  |  |
| 3559 | 953.3 | FS on Improvement of inter-frequency and inter-system measurements for 1.28 Mcps TDD |  | 461d | 2001-12-14 A | 2003-09-19 A | 100% | 2001-12-14 | 2003-09-19 | 461d | start no earlier than 2001-12-14 | R1 | 3688h | 3688h | Rel-6 | RInImp-IfIsMLCR | Samsung | Li Xiao Qiang (xqli@samsung.co.kr) | Patrick | RInImp-IfIsMLCR | 25.888 |  |  |
| 3560 | 953.4 | FS for the analysis of OFDM for UTRAN enhancement |  | 526d | 2002-06-10 A | 2004-06-14 A | 100% | 2002-06-10 | 2004-06-14 | 526d | start no earlier than 2002-06-10 | R1 | 4208h | 4208h | Rel-6 | RInImp-FSOFDM | Nortel | Sarah Boumendil | Patrick | RInImp-FSOFDM | 25.892 |  |  |
| 3561 | 953.5 | FS on Uplink Enhancements for Dedicated Transport Channels |  | 396d | 2002-09-06 A | 2004-03-12 A | 100% | 2002-09-06 | 2004-03-12 | 396d | finish no earlier than 2004-03-12 | R1 | 3168h | 3168h | Rel-6 | RInImp-FSUpDTrCh | Nokia | Karri.Ranta-aho@nsn.com | Patrick | RInImp-FSUpDTrCh | 25.896 |  |  |
| 3562 | 953.6 | FS on Analysis on Higher Chip Rates for UTRA TDD evolutions |  | 528d | 2002-09-06 A | 2004-09-14 A | 100% | 2002-09-06 | 2004-09-14 | 528d | finish no earlier than 2004-09-14 | R1 | 4224h | 4224h | Rel-6 | RInImp-FSVHCRTDD | IPWireless | mbeale@ipwireless.com | Patrick | RInImp-FSVHCRTDD | 25.895 |  |  |
| 3563 | 953.7 | FS on Low Output Powers for general purpose FDD BSs |  | 128d | 2003-06-13 A | 2004-03-12 A | 100% | 2003-06-13 | 2004-03-12 | 128d | finish no earlier than 2004-03-12 | R3 | 1024h | 1024h | Rel-6 | RInImp-FSLoPw | Telefónica | Ana Burgos (burgos_a@tsm.es) | Juha | RInImp-FSLoPw | 25.807 |  |  |
| 3564 | 953.8 | FS on Uplink enhancements for UTRA TDD |  | 462d | 2003-06-06 A | 2005-03-14 A | 100% | 2003-06-06 | 2005-03-14 | 462d | finish no earlier than 2005-03-14 | R1 | 3696h | 3696h | Rel-6 | RInImp-FSUpEnhTDD | Interdigital | Marian.Rudolf@InterDigital.com | Patrick | RInImp-FSUpEnhTDD | 25.804 |  |  |
| 3565 | 8.8 | FS on UE antenna efficiency test methods performance requirements (2) |  | 131d | 2002-03-08 A | 2002-09-06 A | 100% | 2002-03-08 | 2002-09-06 | 131d | finish no earlier than 2002-09-06 | R4 | 1048h | 1048h | Rel-6 | RInImp-UEAnTM2 | Allgon | Alf Ahlström (alf.ahlstrom@pwav.com) | Issam | RInImp-UEAnTM2 |  |  |  |
| 3566 | 9.4 | Deleted - FS on the evolution of the UTRAN architecture |  | 592d | 2002-09-09 A | 2004-12-14 A | 100% | 2002-09-09 | 2004-12-14 | 592d | finish no earlier than 2004-12-15 | R3 | 4736h | 4736h | Rel-6 | RANimp-FSEvo | Nokia | woonhee.hwang@nsn.com, Antti.Toskala@nokia.com | Juha | RANimp-FSEvo |  |  | RP-26 |

Notes:
- 3542: -
- 3543: -
- 3544: -
- 3545: -
- 3546: -
- 3547: Introduction of UMTS850 (Band V) in 25.307
- 3548: Introduction of UMTS800 in 25.307
- 3549: Introduction of UMTS1700/2100 (Band IV)
- 3550: -
- 3551: -
- 3552: Approved at RP#25 as RP-040375
- 3553: -
- 3554: -
- 3555: -
- 3556: -
- 3557: -
- 3558: Study finished at RP#25
- 3559: -
- 3560: -
- 3561: -
- 3562: Study finished at RP#25
- 3563: -
- 3564: -
- 3565: The RInImp-UEAnTM FS was re-opened at TSG RP#15 upon request from WG4
- 3566: Study Closed, work will continue within the FS on evolved UTRA and UTRAN

| ID | WBS | Task | Type | Duration | Start | Finish | Complete | Baseline start | Baseline finish | Baseline duration | Constraint | Deadline | Resources | Work | Actual work | Acronym | WI rapporteur name | WI rapporteur e-mail | Release | MCC resp | Acronym_3GU_Export | Impacted TSs and TRs | Created at | TSG stopped |
| --- | --- | --- | --- | --- | --- | --- | --- | --- | --- | --- | --- | --- | --- | --- | --- | --- | --- | --- | --- | --- | --- | --- | --- | --- |
| 3567 | 954 | **FDD Enhanced Uplink** |  | 915d | 2004-03-15 A | 2007-09-14 A | 100% | 2004-03-15 | 2007-09-14 | 915d |  |  | R2; R1; R3; R4; R5 | 49800h | 49800h | EDCH | Ericsson | Joakim Bergström | Rel-6 | Yong-Jun | EDCH |  |  |  |
| 3568 | 954.1 | FDD Enhanced Uplink - Stage 2 |  | 197d | 2004-03-15 A | 2004-12-14 A | 100% | 2004-03-15 | 2004-12-14 | 197d | finish no earlier than 2004-12-14 |  | R2 | 1576h | 1576h | EDCH-Stage2 |  |  | Rel-6 | Yong-Jun | EDCH-Stage2 | 25.309 |  |  |
| 3569 | 954.2 | FDD Enhanced Uplink - Physical Layer |  | 261d | 2004-03-15 A | 2005-03-14 A | 100% | 2004-03-15 | 2005-03-14 | 261d | finish no earlier than 2005-03-14 |  | R1 | 2088h | 2088h | EDCH-Phys | Nokia | Karri.Ranta-aho@nsn.com | Rel-6 | Patrick | EDCH-Phys | 25.211, 25.212, 25.213, 25.214, 25.215 |  |  |
| 3570 | 954.3 | FDD Enhanced Uplink - Layer 2 and 3 Protocol Aspects |  | 261d | 2004-03-15 A | 2005-03-14 A | 100% | 2004-03-15 | 2005-03-14 | 261d | finish no earlier than 2005-03-14 |  | R2 | 2088h | 2088h | EDCH-L23 | Ericsson | Joakim Bergström | Rel-6 | Yong-Jun | EDCH-L23 | 25.301, 25.302, 25.306, 25.321, 25.331 |  |  |
| 3571 | 954.4 | FDD Enhanced Uplink - UTRAN Iub/Iur Protocol Aspects |  | 261d | 2004-03-15 A | 2005-03-14 A | 100% | 2004-03-15 | 2005-03-14 | 261d | finish no earlier than 2005-03-14 |  | R3 | 2088h | 2088h | EDCH-IurIub | Nortel | Saso Stojanovski | Rel-6 | Juha | EDCH-IurIub | 25.401, 25.420, 25.423, 25.430, 25.433 |  |  |
| 3572 | 954.5 | FDD Enhanced Uplink - RF Radio Transmission/ Reception, System Performance Requirements and Conformance Testing |  | 74d | 2004-03-15 A | 2004-06-24 A | 100% | 2004-03-15 | 2004-06-24 | 74d |  |  | R4 | 592h | 592h | EDCH-RF | Ericsson | thomas.unshelm@ericsson.com | Rel-6 | Issam | EDCH-RF | 25.101, 25.104, 25.133, 25.141 |  |  |
| 3573 | 954.6 | Conformance Test Aspects – FDD Enhanced Uplink |  | 596d | 2005-06-03 A | 2007-09-14 A | 100% | 2005-06-03 | 2007-09-14 | 596d | finish no earlier than 2007-09-14 | 2006-06-02 | R5 | 4768h | 4768h | EDCH_Test | Ericsson | Leif.Mattisson@ericsson.com | Rel-6 | Ingbert | EDCH_Test | 34.108, 34.109, 34.121, 34.123-1, 34.123-2, 34.123-3 | Fri 03/06/05 |  |
| 3574 | 955 | **Rel-6 RAN improvements** |  | 656d? | 2002-09-09 A | 2005-03-14 A | 100% | 2002-09-09 | 2005-03-14 | 656d? |  |  | RP; S5 | 36720h | 36720h |  |  |  | Rel-6 |  |  |  |  |  |
| 3575 | 9.2 | **RAB support enhancement** |  | 522d? | 2003-03-14 A | 2005-03-14 A | 100% | 2003-03-14 | 2005-03-14 | 522d? |  |  | R2 | 9360h | 9360h |  | Nokia | Jussi Kähtävä (juha.mikola@nokia.com) | Rel-6 | Yong-Jun |  | 25.862 |  |  |
| 3576 | 955.1.1 | Optimization of downlink channelisation code utilisation |  | 262d | 2004-03-12 A | 2005-03-14 A | 100% | 2004-03-12 | 2005-03-14 | 262d | finish no earlier than 2005-03-14 |  | R1 | 2096h | 2096h | RANimp-RABSE-CodeOptFDD | Nortel | Sarah Boumendil | Rel-6 | Patrick | RANimp-RABSE-CodeOptFDD |  |  |  |
| 3577 | 955.1.2 | optimization of channelisation code utilisation for 3.84 Mcps TDD |  | 261d | 2004-03-15 A | 2005-03-14 A | 100% | 2004-03-15 | 2005-03-14 | 261d | finish no earlier than 2005-03-15 |  | R1 | 2088h | 2088h | RANimp-RABSE-CodOptTDD | IPWireless | Nicholas Anderson | Rel-6 | Patrick | RANimp-RABSE-CodOptTDD |  |  |  |
| 3578 | 955.1.3 | HS-DPCCH ACK/NACK Enhancement |  | 65d? | 2004-09-15 A | 2004-12-14 A | 100% | 2004-09-15 | 2004-12-14 | 65d? | finish no earlier than 2004-12-15 |  | R1 | 520h | 520h | RANimp-RABSE-ACKNACK | Nokia | Jussi Kähtävä (juha.mikola@nokia.com) | Rel-6 | Patrick | RANimp-RABSE-ACKNACK | 25.212, 25.214, 24.331, 25.433 |  |  |
| 3579 | 955.1.4 | Deleted - Iu enhancements for IMS support in RAN |  | 320d? | 2003-03-14 A | 2004-06-03 A | 100% | 2003-03-14 | 2004-06-03 | 320d? | start no earlier than 2003-03-14 |  | R3 | 2560h | 2560h | RANimp-RABSE-IuEnhIMS | Nortel | Philippe.Godin@nortelnetworks.com | Rel-6 | Juha | RANimp-RABSE-IuEnhIMS |  |  | RP-24 |
| 3580 | 955.1.5 | Deleted - Improvement of RRM across RNS and RNS/BSS | milestone | 0d? | 2003-12-05 A | 2003-12-05 A | 100% | 2003-12-05 | 2003-12-05 | 0d? | finish no earlier than 2003-12-05 |  | R3 |  |  | RANimp-RRM1 | Nokia | antti.toskala@nokia.com | Rel-6 | Juha | RANimp-RRM1 |  |  | RP-23 |
| 3581 | 9.1 | Beamforming Enhancements |  | 66d | 2003-09-19 A | 2003-12-19 A | 100% | 2003-09-19 | 2003-12-19 | 66d | finish no earlier than 2004-03-12 |  | R1 | 528h | 528h | RANimp-BFE | Nokia | Jussi Kähtävä (juha.mikola@nokia.com) | Rel-6 | Patrick | RANimp-BFE | 24.215, 25.423, 25.425, 25.433, 25.435 |  |  |
| 3582 | 955.3 | **Rel-6 RRM optimization for Iur and Iub** |  | 126d | 2003-09-19 A | 2004-03-12 A | 100% | 2003-09-19 | 2004-03-12 | 126d |  |  | R3 | 2016h | 2016h | RANimp-RRMopt-UEMsD | Ericsson | Gert-Jan.van.Lieshout@eln.ericsson.se | Rel-6 | Juha | RANimp-RRMopt-UEMsD |  |  |  |
| 3583 | 955.3.1 | Improved access to UE measurement data for CRNC to support TDD RRM |  | 126d | 2003-09-19 A | 2004-03-12 A | 100% | 2003-09-19 | 2004-03-12 | 126d | finish no earlier than 2004-03-15 |  | R3 | 1008h | 1008h |  | Interdigital | jim.miller@interdigital.com | Rel-6 | Juha |  | 25.423 |  | RP-22 |
| 3584 | 955.4 | **Remote Control of Electrical Tilting Antennas** |  | 395d? | 2003-03-14 A | 2004-09-16 A | 100% | 2003-03-14 | 2004-09-16 | 395d? |  |  | R3; S5 | 10624h | 10624h | RANimp-TiltAnt | Vodafone | Andreas.Hauser@vodafone.com | Rel-6 | Juha | RANimp-TiltAnt |  |  |  |
| 3585 | 955.4.1 | Tilting Antenna - RAN aspects |  | 393d? | 2003-03-14 A | 2004-09-14 A | 100% | 2003-03-14 | 2004-09-14 | 393d? | finish no earlier than 2004-09-14 |  | R3 | 3144h | 3144h |  | Vodafone | Andreas.Hauser@vodafone.com | Rel-6 | Juha |  | 25.460, 25.461, 25.462, 25.463 |  |  |
| 3586 | 955.4.2 | OAM&P impacts |  | 145d | 2004-02-27 A | 2004-09-16 A | 100% | 2004-02-27 | 2004-09-16 | 145d | finish no earlier than 2004-09-16 |  | S5 | 1160h | 1160h | RANimp-TiltAnt-OAM | Vodafone | Adrian.Neal@vodafone.com | Rel-6 | Mirko | RANimp-TiltAnt-OAM | 32.804, 32.64x | SP-24 |  |
| 3587 | 955.5 | Network Assisted Cell Change (NACC) from UTRAN to GERAN - network-side aspects |  | 462d? | 2002-09-09 A | 2004-06-15 A | 100% | 2002-09-09 | 2004-06-15 | 462d? | finish no earlier than 2004-06-15 |  | R3 | 3696h | 3696h | RANimp-NACC | Vodafone | Brendan.McWilliams@gb.vodafone.co.uk | Rel-6 | Juha | RANimp-NACC |  |  |  |
| 3588 | 12 | **Location Services enhancements 2** |  | 1024d? | 2001-01-15 A | 2004-12-16 A | 100% | 2001-01-15 | 2004-12-16 | 1024d? |  |  | S2; S5; N4; R2; R4; R5; OMA | 175184h | 175184h | LCS2 | Nokia | Jan Kåll | Rel-6 | Maurice | LCS2 |  |  |  |
| 3589 | 12.1 | **Improvement on Le interface** |  | 653d? | 2002-06-17 A | 2004-12-15 A | 100% | 2002-06-17 | 2004-12-15 | 653d? |  |  | S2; OMA | 15096h | 15096h |  | Nokia | Jan Kåll | Rel-6 | Maurice |  |  |  |  |
| 3590 | 956.1.1 | Stage 2 for Improvement on Le interface |  | 331d? | 2002-06-17 A | 2003-09-22 A | 100% | 2002-06-17 | 2003-09-22 | 331d? | start no earlier than 2002-06-17 |  | S2 | 2648h | 2648h |  | Nokia | Jan Kåll | Rel-6 | Maurice |  | 23.002,23.271 |  |  |
| 3591 | 956.1.2 | Stage 3 - impacts MLP (Mobile Location Protocol) |  | 250d? | 2004-01-01 A | 2004-12-15 A | 100% | 2004-01-01 | 2004-12-15 | 250d? | finish no earlier than 2004-12-15 |  | OMA | 2000h | 2000h |  | OMA | OMA-LIAISON@mail.openmobilealliance.org | Rel-6 |  |  |  |  |  |

Notes:
- 3567: -
- 3568: -
- 3569: -
- 3570: -
- 3571: -
- 3572: -
- 3573: -
- 3574: Generic feature
- 3575: building block without particular end date
- 3576: -
- 3577: WIDS modified in RP#26, RP-040551
- 3578: Approved at RP#25 as RP-040390
- 3579: Closed RP#24 due to the lack of progress
- 3580: abandoned RP-23
- 3581: -
- 3582: -
- 3583: -
- 3584: -
- 3585: Finished at RP#25
- 3586: SP#25 09/2004 completed
- 3587: -
- 3588: -
- 3589: -
- 3590: -
- 3591: -

| ID | WBS | Task | Type | Duration | Start | Finish | Complete | Baseline start | Baseline finish | Baseline duration | Constraint | Resources | Work | Actual work | WI rapporteur name | WI rapporteur e-mail | Release | MCC resp | Acronym | Acronym_3GU_Export | TSG stopped |
| --- | --- | --- | --- | --- | --- | --- | --- | --- | --- | --- | --- | --- | --- | --- | --- | --- | --- | --- | --- | --- | --- |
| 3592 | 12.2 | **Enhanced support for anonymity and user privacy** |  | 638d? | 2002-07-08 A | 2004-12-15 A | 100% | 2002-07-08 | 2004-12-15 | 638d? |  | S2; OMA | 14248h | 14248h | Nokia | Jan Kåll | Rel-6 | Maurice |  |  |  |
| 3593 | 956.2.1 | Stage 2 for Enhanced support for anonymity and user privacy |  | 255d? | 2002-07-08 A | 2003-06-27 A | 100% | 2002-07-08 | 2003-06-27 | 255d? | finish no earlier than 2003-06-27 | S2 | 2040h | 2040h | Nokia | Jan Kåll | Rel-6 | Maurice |  |  |  |
| 3594 | 956.2.2 | Stage 3 - impacts MLP and RLP |  | 250d? | 2004-01-01 A | 2004-12-15 A | 100% | 2004-01-01 | 2004-12-15 | 250d? | finish no earlier than 2004-12-15 | OMA | 2000h | 2000h | OMA | OMA-LIAISON@mail.openmobilealliance.org | Rel-6 |  |  |  |  |
| 3595 | 12.3 | **Enhanced inter-GMLC interface** |  | 648d? | 2002-06-24 A | 2004-12-15 A | 100% | 2002-06-24 | 2004-12-15 | 648d? |  | S2; OMA | 14888h | 14888h | Nokia | Jan Kåll | Rel-6 | Maurice |  |  |  |
| 3596 | 956.3.1 | Stage 2 for Enhanced inter-GMLC interface |  | 315d? | 2002-06-24 A | 2003-09-05 A | 100% | 2002-06-24 | 2003-09-05 | 315d? | finish no earlier than 2003-09-05 | S2 | 2520h | 2520h | Nokia | Jan Kåll | Rel-6 | Maurice |  |  |  |
| 3597 | 956.3.2 | Stage 3 - definition of RLP and PCP |  | 250d? | 2004-01-01 A | 2004-12-15 A | 100% | 2004-01-01 | 2004-12-15 | 250d? | finish no earlier than 2004-12-15 | OMA | 2000h | 2000h | OMA | OMA-LIAISON@mail.openmobilealliance.org | Rel-6 |  |  |  |  |
| 3598 | 12.4 | **Location Services support for IMS public identities** |  | 473d? | 2003-02-24 A | 2004-12-15 A | 100% | 2003-02-24 | 2004-12-15 | 473d? |  | S2; OMA | 11488h | 11488h | Nokia | Jan Kåll | Rel-6 | Maurice |  |  |  |
| 3599 | 956.4.1 | Stage 2 for Location Services support for IMS public identities |  | 240d? | 2003-02-24 A | 2004-01-23 A | 100% | 2003-02-24 | 2004-01-23 | 240d? | finish no earlier than 2004-01-23 | S2 | 1920h | 1920h | Nokia | Jan Kåll | Rel-6 | Maurice |  |  |  |
| 3600 | 956.4.2 | OMA Stage 3 for Location Services support for IMS public identities - impacts MLP, RLP and PCP |  | 250d? | 2004-01-01 A | 2004-12-15 A | 100% | 2004-01-01 | 2004-12-15 | 250d? | finish no earlier than 2004-12-15 | OMA | 2000h | 2000h | OMA | OMA-LIAISON@mail.openmobilealliance.org | Rel-6 |  |  |  |  |
| 3601 | 12.5 | **New area event for location service triggering reports** |  | 663d? | 2002-06-03 A | 2004-12-15 A | 100% | 2002-06-03 | 2004-12-15 | 663d? |  | S2; N4; OMA | 22024h | 22024h | Nokia | Jan Kåll | Rel-6 | Maurice |  |  |  |
| 3602 | 956.5.1 | Stage 2 for New area event for location service triggering reports |  | 280d? | 2002-06-03 A | 2003-06-27 A | 100% | 2002-06-03 | 2003-06-27 | 280d? | finish no earlier than 2003-06-27 | S2 | 2240h | 2240h | Nokia | Jan Kåll | Rel-6 | Maurice |  |  |  |
| 3603 | 956.5.2 | Stage 3 for UE-CN signalling |  | 234d? | 2003-10-09 A | 2004-08-31 A | 100% | 2003-10-09 | 2004-08-31 | 234d? | start no earlier than 2003-10-09 | N4 | 1872h | 1872h | Nokia |  | Rel-6 | Kimmo |  |  |  |
| 3604 | 956.5.3 | Stage 3 for New area event for location service triggering reports - impacts MLP, RLP and PCP |  | 250d? | 2004-01-01 A | 2004-12-15 A | 100% | 2004-01-01 | 2004-12-15 | 250d? | finish no earlier than 2004-12-15 | OMA | 2000h | 2000h | OMA | OMA-LIAISON@mail.openmobilealliance.org | Rel-6 |  |  |  |  |
| 3605 | 12.7 | **UE positioning for Location Services enhancements 2** |  | 957d? | 2001-01-15 A | 2004-09-14 A | 100% | 2001-01-15 | 2004-09-14 | 957d? |  | R2; R4; R5 | 36456h | 36456h |  |  | Rel-6 | Issam | LCS2-UEpos | LCS2-UEpos |  |
| 3606 | 12.8 | Open SMLC-SRNC Interface within the UTRAN to support UTRAN Rel-4 positioning methods |  | 700d? | 2001-01-15 A | 2003-09-19 A | 100% | 2001-01-15 | 2003-09-19 | 700d? | finish no earlier than 2003-09-19 | R2 | 5600h | 5600h | Siemens | Meik.Kottkamp@siemens.com | Rel-6 | Yong-Jun | LCS-Rel4Pos | LCS-Rel4Pos |  |
| 3607 | 956.6.2 | A-GPS minimum performance specification |  | 333d? | 2003-06-06 A | 2004-09-14 A | 100% | 2003-06-06 | 2004-09-14 | 333d? | finish no earlier than 2004-09-14 | R4; R5 | 5328h | 5328h | AT&T Wireless | donglin.shen@attws.com | Rel-6 | Issam | LCS-UEPos-AGPSPerf | LCS-UEPos-AGPSPerf |  |
| 3608 | 12.7.2 | Deleted - FS on Enhancements to OTDOA Positioning using advanced blanking methods |  | 320d | 2002-07-01 A | 2003-09-19 A | 100% | 2002-07-01 | 2003-09-19 | 320d | finish no earlier than 2003-09-19 | R2 | 2560h | 2560h | Cambridge Positioning Systems | david.bartlett@cursor-system.com | Rel-6 | Yong-Jun | LCS2-UEpos-FSBlank | LCS2-UEpos-FSBlank | RP-38 |
| 3609 | 956.6.4 | Deleted - UE positioning enhancements - other methods | milestone | 0d? | 2003-09-26 A | 2003-09-26 A | 100% | 2003-09-26 | 2003-09-26 | 0d? | finish no earlier than 2003-09-26 | R2 |  |  | Siemens | Meik.Kottkamp@siemens.com | Rel-6 | Yong-Jun | LCS2-UEpos-enh | LCS2-UEpos-enh | RP-24 |
| 3610 | 956.7 | LCS charging |  | 455d? | 2003-03-21 A | 2004-12-16 A | 100% | 2003-03-21 | 2004-12-16 | 455d? | start no earlier than 2003-03-21 | S5 | 3640h | 3640h | France Telecom | alain.bibas@orange-ft.com | Rel-6 | Mirko | LCS2-CH | LCS2-CH |  |
| 3611 | 14 | **Rel-6 Security enhancements** |  | 1018d? | 2001-01-03 A | 2004-11-26 A | 100% | 2001-01-03 | 2004-11-26 | 1018d? |  | S3 | 28824h | 28824h | Vodafone | Peter.Howard@vodafone.com | Rel-6 | Mirko | SEC16 | SEC1, Rel-6 |  |
| 3612 | 14.1 | **Enhanced HE control of security (including positive authentication reporting)** |  | 712d | 2001-01-03 A | 2003-09-25 A | 100% | 2001-01-03 | 2003-09-25 | 712d |  | S3 | 14064h | 14064h | Vodafone | Peter.Howard@vodafone.com | Rel-6 | Mirko |  |  |  |
| 3613 | 14.1.1 | Deleted - SEC1 Stage 2 (Enhanced HE control of security) |  | 378d | 2001-01-03 A | 2002-06-14 A | 100% | 2001-01-03 | 2002-06-14 | 378d | finish no earlier than 2002-06-14 | S3 | 3024h | 3024h |  |  | Rel-6 | Mirko |  |  | SP-16 |
| 3614 | 14.1.3 | **Rel-6 Network Domain Security** |  | 334d | 2002-06-17 A | 2003-09-25 A | 100% | 2002-06-17 | 2003-09-25 | 334d |  | S3 | 5344h | 5344h | Telenor | Geir-myrdahl.koien@telenor.com | Rel-6 | Mirko | SEC1-NDS | SEC1-NDS |  |
| 3615 | 14.1.3.1 | Rel-6 IP network layer security (NDS/IP) |  | 334d | 2002-06-17 A | 2003-09-25 A | 100% | 2002-06-17 | 2003-09-25 | 334d | finish no earlier than 2003-09-25 | S3 | 2672h | 2672h |  |  | Rel-6 | Mirko | SEC1-NDS-IP | SEC1-NDS-IP |  |
| 3616 | 957.2 | Network Domain Security; Authentication Framework (NDS/AF) |  | 521d? | 2002-02-15 A | 2004-02-13 A | 100% | 2002-02-15 | 2004-02-13 | 521d? | finish no earlier than 2004-02-13 | S3 | 4168h | 4168h | Nokia | tommi.viitanen@nokia.com | Rel-6 | Mirko | SEC1-NDS-AF | SEC1-NDS-AF |  |
| 3617 | 957.3 | Key Management of group keys for Voice Group Call Services |  | 306d | 2003-09-26 A | 2004-11-26 A | 100% | 2003-09-26 | 2004-11-26 | 306d | finish no earlier than 2004-11-26 | S3 | 2448h | 2448h | Vodafone | benno.tietz@vodafone.com | Rel-6 | Mirko | SECGKYV | SECGKYV |  |
| 3618 | 958 | Network Domain Security; MAP application layer security (NDS/MAPsec) |  | 127d? | 2004-07-06 A | 2004-12-29 A | 100% | 2004-07-06 | 2004-12-29 | 127d? | finish no earlier than 2003-12-26 | S3 | 1016h | 1016h | Vodafone | Peter.Howard@vodafone.com | Rel-6 | Mirko | MAPSEC | MAPSEC |  |

Notes:
- 3592: -
- 3593: - / Impacted TSs and TRs: 23.002,23.271
- 3594: -
- 3595: -
- 3596: - / Impacted TSs and TRs: 23.002,23.271
- 3597: -
- 3598: -
- 3599: - / Impacted TSs and TRs: 23.002,23.271
- 3600: -
- 3601: -
- 3602: - / Impacted TSs and TRs: 23.002,23.271
- 3603: Current stage 3 fullfills stage 2
- 3604: -
- 3605: -
- 3606: - / Impacted TSs and TRs: 25.305, 25.401, 25.450, 25.452, 25.453
- 3607: RP#25 completed (FDD) / Impacted TSs and TRs: new 25.171, 34.171 (testing)
- 3608: RP#38 Work stopped / Impacted TSs and TRs: new TR 25.894
- 3609: RP#24 Work stopped
- 3610: SP#26 completed / Impacted TSs and TRs: new TS 32.271
- 3611: SP#9 approved WID. Acronym changed from "SEC1, Rel-6"
- 3612: SP#9 approved WID S3-000490 (Enhanced home control of security by HE) / Impacted TSs and TRs: 33.102
- 3613: Marked as stopped 12/2008
- 3614: SP#9 approved WID S3-000606 (Network Domain Security) / Impacted TSs and TRs: 33.102, 33.103, 33.105
- 3615: SP#9 approved WID S3-000626 (Access security for IP-based services) / Impacted TSs and TRs: 33.210
- 3616: SP#19 approved WID / Impacted TSs and TRs: 33.810
- 3617: - / Impacted TSs and TRs: 42.068, 43.068, 44.068, 42.069, 43.069, 44.069, 31.102, 24.008, 48.008, 42.009, 43.020, New TSs (55.236, 55.205) MILENAGE algorithms
- 3618: SP#19 approved WID. Marked as closed 12/2008 (was marked 20% complete) / Impacted TSs and TRs: 33.200

| ID | WBS | Task | Type | Duration | Start | Finish | Complete | Baseline start | Baseline finish | Baseline duration | Constraint | Resources | Work | Actual work | Acronym | Release | MCC resp | Acronym_3GU_Export | Impacted TSs and TRs | WI rapporteur name | WI rapporteur e-mail | TSG stopped |
| --- | --- | --- | --- | --- | --- | --- | --- | --- | --- | --- | --- | --- | --- | --- | --- | --- | --- | --- | --- | --- | --- | --- |
| 3619 | 16 | **IMS Phase 2** |  | 1840d? | 2000-08-28 A | 2007-09-14 A | 100% | 2000-08-28 | 2007-09-14 | 1840d? |  | S1; S2; S3; S5; NP; R5 | 210576h | 210576h | IMS2 | Rel-6 | Alain | IMS2 |  |  |  |  |
| 3620 | 959.1 | Enhancements to the Cx and Sh interfaces |  | 323d? | 2003-06-06 A | 2004-08-31 A | 100% | 2003-06-06 | 2004-08-31 | 323d? | finish no earlier than 2004-08-31 | N4 | 2584h | 2584h | IMS2-CCR | Rel-6 | Kimmo | IMS2-CCR |  |  |  |  |
| 3621 | 959.2 | Conformance Test Aspects – IMS Call Control Rel-6 enhancements |  | 396d? | 2006-03-10 A | 2007-09-14 A | 100% | 2006-03-10 | 2007-09-14 | 396d? | finish no earlier than 2007-09-14 | R5 | 3168h | 3168h | IMS2_CCR_Test | Rel-6 | Ingbert | IMS2_CCR_Test | 34.229-1, 34.229-2, 34.229-3, 34.108 | Ericsson | Jacob.John@motorola.com, Leif.Mattisson@ericsson.com |  |
| 3622 | 16.12 | **IMS Group Management** |  | 715d? | 2002-03-14 A | 2004-12-08 A | 100% | 2002-03-14 | 2004-12-08 | 715d? |  | S1 | 12680h | 12680h | IMSGM | Rel-6 | Alain | IMSGM |  | Nokia | juha.kalliokulju@nokia.com |  |
| 3623 | 16.12.1 | Stage 1 - TS on IMS group management |  | 193d | 2002-03-14 A | 2002-12-09 A | 100% | 2002-03-14 | 2002-12-09 | 193d | finish no earlier than 2002-12-09 | S1 | 1544h | 1544h |  | Rel-6 | Alain |  |  | Nokia | juha.kalliokulju@nokia.com |  |
| 3624 | 959.3.2 | Stage 2 for IMS Group Management |  | 158d? | 2003-05-26 A | 2003-12-31 A | 100% | 2003-05-26 | 2003-12-31 | 158d? | finish no earlier than 2003-12-31 | S2 | 1264h | 1264h |  | Rel-6 | Maurice |  | 23.228 |  |  |  |
| 3625 | 959.3.3 | Stage 3 for IMS Group management (e.g. chat) |  | 519d? | 2002-12-13 A | 2004-12-08 A | 100% | 2002-12-13 | 2004-12-08 | 519d? | finish no earlier than 2004-12-08 | N1 | 4152h | 4152h |  | Rel-6 | Frederic |  |  | Lucent | Keith Drage (drage@alcatel-lucent.com) |  |
| 3626 | 959.4 | **IMS Conferencing** |  | 548d? | 2002-11-04 A | 2004-12-08 A | 100% | 2002-11-04 | 2004-12-08 | 548d? |  | N1 | 10960h | 10960h |  | Rel-6 | Frederic |  |  |  |  |  |
| 3627 | 959.4.1 | Stage 2 for IMS Conferencing |  | 303d? | 2002-11-04 A | 2003-12-31 A | 100% | 2002-11-04 | 2003-12-31 | 303d? | finish no earlier than 2003-12-31 | S2 | 2424h | 2424h |  | Rel-6 | Maurice |  | 23.228 |  |  |  |
| 3628 | 959.4.2 | Stage 3 for IMS Conferencing |  | 519d? | 2002-12-13 A | 2004-12-08 A | 100% | 2002-12-13 | 2004-12-08 | 519d? | finish no earlier than 2004-12-08 | N1 | 4152h | 4152h |  | Rel-6 | Frederic |  |  | Lucent | Keith Drage (drage@alcatel-lucent.com) |  |
| 3629 | 16.11 | **IMS Messaging** |  | 992d? | 2002-03-14 A | 2005-12-30 A | 100% | 2002-03-14 | 2005-12-30 | 992d? |  | S1 | 23912h | 23912h | IMSM | Rel-6 | Alain | IMSM |  | Nokia | juha.kalliokulju@nokia.com |  |
| 3630 | 16.11.1 | TR on support of messaging in the IMS |  | 193d | 2002-03-14 A | 2002-12-09 A | 100% | 2002-03-14 | 2002-12-09 | 193d | finish no earlier than 2002-12-09 | S1 | 1544h | 1544h | IMSM-TR | Rel-6 | Alain | IMSM-TR | New 22.940 | Nokia | juha.kalliokulju@nokia.com |  |
| 3631 | 959.5.2 | Stage 1 22.340 |  | 23d? | 2002-11-11 A | 2002-12-11 A | 100% | 2002-11-11 | 2002-12-11 | 23d? | finish no earlier than 2002-12-11 | S1 | 184h | 184h | IMSM-TS | Rel-6 | Alain | IMSM-TS | 22.340 | Nokia | juha.kalliokulju@nokia.com |  |
| 3632 | 959.5.3 | CRs to 22.140 & 22.228 |  | 263d? | 2002-03-14 A | 2003-03-17 A | 100% | 2002-03-14 | 2003-03-17 | 263d? | finish no earlier than 2003-03-17 | S1 | 2104h | 2104h | IMSM-CR | Rel-6 | Alain | IMSM-CR | 22.140,22.228 | Nokia | juha.kalliokulju@nokia.com |  |
| 3633 | 16.11.3 | Stage 2 for IMS Messaging |  | 477d | 2002-11-04 A | 2004-08-31 A | 100% | 2002-11-04 | 2004-08-31 | 477d | finish no earlier than 2004-08-31 | S2 | 3816h | 3816h |  | Rel-6 | Maurice |  | 23.228 |  |  |  |
| 3634 | 959.5.5 | Stage 3 for IMS Messaging |  | 519d? | 2002-12-13 A | 2004-12-08 A | 100% | 2002-12-13 | 2004-12-08 | 519d? | finish no earlier than 2004-12-08 | N1 | 4152h | 4152h |  | Rel-6 | Frederic |  |  | Lucent | Keith Drage (drage@alcatel-lucent.com) |  |
| 3635 | 959.5.6 | SIP/SIMPLE Instant messaging |  | 522d? | 2004-01-01 A | 2005-12-30 A | 100% | 2004-01-01 | 2005-12-30 | 522d? | finish no earlier than 2005-06-30 | OMA | 4176h | 4176h |  | Rel-6 |  |  |  |  | OMA-LIAISON@mail.openmobilealliance.org |  |
| 3636 | 959.6 | **Additional SIP Capabilities support not covered by Rel-5** |  | 680d? | 2002-11-11 A | 2005-06-17 A | 100% | 2002-11-11 | 2005-06-17 | 680d? |  | N1 | 13392h | 13392h |  | Rel-6 | Frederic |  |  |  |  |  |
| 3637 | 959.6.1 | Stage 2 for add SIP cap (e.g. forking) |  | 335d? | 2002-11-11 A | 2004-02-20 A | 100% | 2002-11-11 | 2004-02-20 | 335d? | finish no earlier than 2004-02-20 | S2 | 2680h | 2680h |  | Rel-6 | Maurice |  | 23.228 |  |  |  |
| 3638 | 959.6.2 | Stage 3 for Additional SIP Capabilities |  | 454d? | 2002-12-13 A | 2004-09-08 A | 100% | 2002-12-13 | 2004-09-08 | 454d? | finish no earlier than 2004-09-08 | N1 | 3632h | 3632h |  | Rel-6 | Frederic |  |  | Lucent | Keith Drage (drage@alcatel-lucent.com) |  |
| 3639 | 959.6.3 | Procedured associated with IMS-ALG |  | 205d? | 2004-09-06 A | 2005-06-17 A | 100% | 2004-09-06 | 2005-06-17 | 205d? | start no earlier than 2004-09-06 | N1 | 1640h | 1640h |  | Rel-6 | Frederic |  |  |  |  |  |
| 3640 | 959.7 | Review additional SIP Capabilities against IMS |  | 454d? | 2002-12-13 A | 2004-09-08 A | 100% | 2002-12-13 | 2004-09-08 | 454d? | finish no earlier than 2004-09-08 | N1 | 3632h | 3632h |  | Rel-6 | Frederic |  |  | Lucent | Keith Drage (drage@alcatel-lucent.com) |  |
| 3641 | 16.5 | **Interworking between IMS and IP networks** |  | 1118d? | 2000-08-28 A | 2004-12-08 A | 100% | 2000-08-28 | 2004-12-08 | 1118d? |  | N3 | 31712h | 31712h | IMS-CCR-IWIP | Rel-6 | Gwiho | IMS-CCR-IWIP | 23.821, 29.061, 29.162 | BT | nigel.holland@bt.com |  |
| 3642 | 16.5.1 | Interworking for 3GPP_SIP and IETF_SIP |  | 730d | 2000-08-28 A | 2003-06-13 A | 100% | 2000-08-28 | 2003-06-13 | 730d | finish no earlier than 2003-06-13 | N3 | 5840h | 5840h |  | Rel-6 | Gwiho |  | New 29.962 | Siemens | Thomas.Belling@nsn.com |  |
| 3643 | 16.5.2 | Interworking for IPv6 to IPv4 |  | 1118d | 2000-08-28 A | 2004-12-08 A | 100% | 2000-08-28 | 2004-12-08 | 1118d | finish no earlier than 2004-12-08 | N3 | 8944h | 8944h |  | Rel-6 | Gwiho |  | 29.163 |  |  |  |
| 3644 | 959.8.3 | Interworking for IPv6 to IPv4 (SIP / SDP aspects) |  | 87d? | 2004-05-11 A | 2004-09-08 A | 100% | 2004-05-11 | 2004-09-08 | 87d? | finish no earlier than 2004-09-08 | N1 | 696h | 696h |  | Rel-6 | Frederic |  |  |  |  |  |
| 3645 | 16.8.1 | stage 3 of interworking with non-IMS IP networks |  | 911d | 2001-03-14 A | 2004-09-08 A | 100% | 2001-03-14 | 2004-09-08 | 911d | finish no earlier than 2004-09-08 | N1 | 7288h | 7288h |  | Rel-6 | Frederic |  |  |  |  |  |
| 3646 | 16.6.1 | Interworking between IMS and CS networks |  | 929d? | 2000-08-28 A | 2004-03-18 A | 100% | 2000-08-28 | 2004-03-18 | 929d? | finish no earlier than 2004-03-18 | N3 | 7432h | 7432h | IMS-CCR-IWCS | Rel-6 | Gwiho | IMS-CCR-IWCS | 29.163, 29.061, 24.228, and New CN4 specification | Vodafone | Brendan.McWilliams@gb.vodafone.co.uk |  |
| 3647 | 16.10 | Mn interface (IM-MGW to MGCF) enhancements (CN4 Part) |  | 418d | 2001-08-07 A | 2004-09-01 A | 100% | 2001-08-07 | 2004-09-01 | 418d | finish no earlier than 2004-09-01 | N4 | 3344h | 3344h | IMS-CCR-Mn | Rel-6 | Kimmo | IMS-CCR-Mn |  |  |  |  |
| 3648 | 959.11 | Study of subscriber and operators relationship in IMS and related ISIM requirements for Rel 6” |  | 20d? | 2002-11-15 A | 2002-12-12 A | 100% | 2002-11-15 | 2002-12-12 | 20d? | finish no earlier than 2002-12-12 | S1 | 160h | 160h |  | Rel-6 | Alain |  |  | Nokia | juha.kalliokulju@nokia.com |  |
| 3649 | 959.12 | Lawful Interception in Rel-6 architecture |  | 269d? | 2002-12-09 A | 2003-12-18 A | 100% | 2002-12-09 | 2003-12-18 | 269d? | finish no earlier than 2003-12-18 | S3 | 2152h | 2152h | SEC1-LI | Rel-6 | Mirko | SEC1-LI, Rel-6 | 33.106, 33.107, 33.108 | Reg TP, Nortel | berthold.wilhelm@regtp.de, Ron Ryan |  |
| 3650 | 959.13 | IMS Subscription and access scenarios |  | 130d? | 2002-12-16 A | 2003-06-13 A | 100% | 2002-12-16 | 2003-06-13 | 130d? | start no earlier than 2002-12-16 | S1 | 1040h | 1040h |  | Rel-6 | Alain |  | 22.800 | TeliaSonera | FRANK, Robert |  |
| 3651 | 959.14 | IMS charging |  | 455d? | 2003-03-21 A | 2004-12-16 A | 100% | 2003-03-21 | 2004-12-16 | 455d? | finish no earlier than 2004-12-16 | S5 | 3640h | 3640h | IMS2-CH | Rel-6 | Mirko | IMS2-CH | 32.260 | Ericsson | Patrik TEPPO |  |
| 3652 | 959.15 | IMS Management objects |  | 306d? | 2004-09-03 A | 2005-11-04 A | 100% | 2004-09-03 | 2005-11-04 | 306d? | finish no earlier than 2005-03-04 | N1 | 2448h | 2448h |  | Rel-6 | Frederic |  | 24.167 |  |  |  |
| 3653 | 959.16 | Deleted - Stage 2 of IMS Phase 2 | milestone | 0d? | 2003-09-19 A | 2003-09-19 A | 100% | 2003-09-19 | 2003-09-19 | 0d? | finish no earlier than 2003-09-19 | S2 |  |  |  | Rel-6 | Maurice |  |  |  |  | SP-21 |

Notes:
- 3619: -
- 3620: Shared public user identities need to be solved. If email approval CR is accepted. Work 100% done....
- 3621: -
- 3622: -
- 3623: -
- 3624: -
- 3625: Depends on CN decision on CPCP in Rel-6. Complete, if unresolved IETF dependencies are dropped (-> LS to CN plenary)
- 3626: -
- 3627: -
- 3628: Depends on CN decision on IETF dependencies in Rel-6. Higher figure if CPCP is dropped (-> LS to CN plenary)
- 3629: -
- 3630: -
- 3631: -
- 3632: -
- 3633: -
- 3634: -
- 3635: Updated according to SP-040232
- 3636: -
- 3637: -
- 3638: -
- 3639: -
- 3640: -
- 3641: [DAB 14.02.02] - end date pushed back to March 2003
- 3642: [DAB - 20.08.03] - CN Part of TR Complete @ CN#20
- 3643: -
- 3644: -
- 3645: -
- 3646: [DAB - 25.05.04] - CN3 consider this work to be complete
- 3647: TISPAN issue is open
- 3648: -
- 3649: Acronym changed from "SEC1-LI, Rel6"
- 3650: -
- 3651: SP#26 12/2004 completed
- 3652: -
- 3653: -

| ID | WBS | Task | Type | Duration | Start | Finish | Complete | Baseline start | Baseline finish | Baseline duration | Constraint | Resources | Work | Actual work | Acronym | WI rapporteur name | WI rapporteur e-mail | Release | MCC resp | Acronym_3GU_Export | Impacted TSs and TRs | Created at | TSG stopped |
| --- | --- | --- | --- | --- | --- | --- | --- | --- | --- | --- | --- | --- | --- | --- | --- | --- | --- | --- | --- | --- | --- | --- | --- |
| 3654 | 960 | **3GPP Enablers for services like Push to Talk over Cellular (PoC)** |  | 459d? | 2003-09-08 A | 2005-06-09 A | 100% | 2003-09-08 | 2005-06-09 | 459d? |  | S2; S4; S5 | 18040h | 18040h | PoC | Ericsson | Shabnam Sultana | Rel-6 | Maurice | PoC |  |  |  |
| 3655 | 960.1 | Feasibility Study on 3GPP Enablers for services like Push to Talk over Cellular (PoC) |  | 322d? | 2003-09-08 A | 2004-11-30 A | 100% | 2003-09-08 | 2004-11-30 | 322d? | finish no earlier than 2004-11-30 | S2 | 2576h | 2576h |  | Ericsson | Shabnam Sultana | Rel-6 | Maurice |  | 23.979 | SP-24 |  |
| 3656 | 960.2 | Dependencies on OMA PoC |  | 303d? | 2004-01-01 A | 2005-02-28 A | 100% | 2004-01-01 | 2005-02-28 | 303d? | finish no earlier than 2004-12-30 | OMA | 2424h | 2424h |  |  | OMA-LIAISON@mail.openmobilealliance.org | Rel-6 |  |  |  | SP-24 |  |
| 3657 | 960.3 | Selection of one or more PoC codec(s) for PoC |  | 69d? | 2004-09-13 A | 2004-12-16 A | 100% | 2004-09-13 | 2004-12-16 | 69d? | start no earlier than 2004-09-13 | S4 | 552h | 552h |  |  |  | Rel-6 | Paolo |  | 26.235, 26.236 | SP-25 |  |
| 3658 | 960.4 | PoC charging |  | 184d? | 2004-09-27 A | 2005-06-09 A | 100% | 2004-09-27 | 2005-06-09 | 184d? | finish no earlier than 2005-06-09 | S5 | 1472h | 1472h | PoC-CH | Siemens | Gerald.Goermer@nsn.com | Rel-6 | Mirko | PoC-CH | 32.272 |  |  |
| 3659 | 961 | Study on Interworking aspects and migration scenarios for IPv4 based IMS Implementations |  | 210d? | 2003-09-08 A | 2004-06-25 A | 100% | 2003-09-08 | 2004-06-25 | 210d? | finish no earlier than 2004-06-25 | S2 | 1680h | 1680h | IPv4IMS | Siemens | Alexander Milinski | Rel-6 | Maurice | IPv4IMS | 23.981 |  |  |
| 3660 | 16.3 | **Interoperability and Commonality between IMS using different IP-connectivity Networks** |  | 325d? | 2002-09-16 A | 2003-12-12 A | 100% | 2002-09-16 | 2003-12-12 | 325d? |  | S2 | 9176h | 9176h | IMSCOOP |  |  | Rel-6 | Maurice | IMSCOOP | 23.864 |  |  |
| 3661 | 16.3.1 | Stage 2 for Interoperability |  | 272d | 2002-09-16 A | 2003-09-30 A | 100% | 2002-09-16 | 2003-09-30 | 272d | finish no earlier than 2003-09-30 | S2 | 2176h | 2176h |  | Nokia | balazs.bertenyi@nsn.com | Rel-6 | Maurice |  | 23.864 |  |  |
| 3662 | 962.2 | Stage 2 for commonality |  | 265d? | 2002-09-16 A | 2003-09-19 A | 100% | 2002-09-16 | 2003-09-19 | 265d? | start no earlier than 2002-09-16 | S2 | 2120h | 2120h |  | Nokia | balazs.bertenyi@nsn.com | Rel-6 | Maurice |  | 23.864 |  |  |
| 3663 | 16.3.2 | Stage 3 for Interoperability and Commonality between IMS using different IP-connectivity Networks |  | 305d | 2002-10-14 A | 2003-12-12 A | 100% | 2002-10-14 | 2003-12-12 | 305d | finish no earlier than 2003-12-12 | N1 | 2440h | 2440h |  | Lucent | Keith Drage (drage@alcatel-lucent.com) | Rel-6 | Frederic |  |  |  |  |
| 3664 | 17 | **Support of Push Services** |  | 823d | 2001-01-03 A | 2004-02-27 A | 100% | 2001-01-03 | 2004-02-27 | 823d |  | S1 | 11390.6h | 11390.6h | PUSH | NTT Comware | Yoshinori Kitada | Rel-6 | Alain | PUSH | 23.976 |  |  |
| 3665 | 17.1 | Stage 1 for Support of Push Services |  | 378d | 2001-01-03 A | 2002-06-14 A | 100% | 2001-01-03 | 2002-06-14 | 378d | finish no earlier than 2002-06-14 | S1 | 3024h | 3024h |  |  |  | Rel-6 | Alain |  |  |  |  |
| 3666 | 17.3 | TR 23.976 on Push Architecture |  | 340d | 2002-11-11 A | 2004-02-27 A | 100% | 2002-11-11 | 2004-02-27 | 340d | finish no earlier than 2004-02-27 | S2 | 2720h | 2720h |  | Research In Motion | Nick Alfano | Rel-6 | Maurice |  | 23.976 |  |  |
| 3667 | 18 | **Rel-6 Multimedia Messaging (MMS) enhancements** |  | 865d? | 2002-08-15 A | 2005-12-07 A | 100% | 2002-08-15 | 2005-12-07 | 865d? |  | T2; S1; S4; S5; OMA | 59616h | 59616h | MMS6 | Siemens | Josef.Laumen@SAL.SIEMENS.DE | Rel-6 | Kimmo | MMS6 |  |  |  |
| 3668 | 18.1 | **Definition of service requirements for MMS6** |  | 286d? | 2002-11-15 A | 2003-12-19 A | 100% | 2002-11-15 | 2003-12-19 | 286d? |  | S1 | 4576h | 4576h | MMS6-SR |  |  | Rel-6 | Alain | MMS6-SR | 22.140 |  |  |
| 3669 | 964.1.1 | Definition of service requirements charging |  | 286d? | 2002-11-15 A | 2003-12-19 A | 100% | 2002-11-15 | 2003-12-19 | 286d? | finish no earlier than 2003-12-20 | S1 | 2288h | 2288h |  | Siemens | Josef.Laumen@SAL.SIEMENS.DE | Rel-6 | Alain |  | 22.140 |  |  |
| 3670 | 18.2 | Technical realization of MMS6 |  | 591d | 2002-09-06 A | 2004-12-10 A | 100% | 2002-09-06 | 2004-12-10 | 591d | finish no earlier than 2004-12-10 | T2 | 4728h | 4728h |  | Siemens | Josef.Laumen@SAL.SIEMENS.DE | Rel-6 | Kimmo |  | 23.140 |  |  |
| 3671 | 18.3 | OMA dependencies |  | 446d | 2003-08-15 A | 2005-04-29 A | 100% | 2003-08-15 | 2005-04-29 | 446d | finish no earlier than 2004-12-10 | OMA | 3568h | 3568h |  |  |  | Rel-6 | Kimmo |  | OMA specs |  |  |
| 3672 | 18.4 | MMS formats and codecs for MMS6 |  | 865d | 2002-08-15 A | 2005-12-07 A | 100% | 2002-08-15 | 2005-12-07 | 865d | finish no earlier than 2005-12-07 | S4 | 6920h | 6920h | MMS6-Codec | Nokia | roberto.castagno@nokia.com | Rel-6 | Paolo | MMS6-Codec | 26.140, 26.936 |  |  |
| 3673 | 964.5 | Handling of private addressing schemes in MMS |  | 263d | 2003-12-10 A | 2004-12-10 A | 100% | 2003-12-10 | 2004-12-10 | 263d | finish no earlier than 2004-12-10 | T2 | 2104h | 2104h |  | T-Mobile | Steffen.Habermann@T-MOBILE.DE | Rel-6 | Kimmo |  | 23.140 |  |  |
| 3674 | 964.6 | MMS charging |  | 390d? | 2003-03-21 A | 2004-09-16 A | 100% | 2003-03-21 | 2004-09-16 | 390d? | start no earlier than 2003-03-21 | S5 | 3120h | 3120h | MMS6-CH |  |  | Rel-6 | Mirko | MMS6-CH | 32.270 |  |  |
| 3675 | 964.7 | Deleted - FS Multiple MMS Relay/Server Architecture | milestone | 0d | 2004-12-10 A | 2004-12-10 A | 100% | 2004-12-10 | 2004-12-10 | 0d | finish no earlier than 2004-12-10 | T2 |  |  |  | Telefónica Móviles | Juan Gorospe (gorospe_j@tsm.es) | Rel-6 | Kimmo |  | probably Annex to 23.140 |  | TP-26 |
| 3676 | 19 | **Rel-6 MExE enhancements** |  | 326d | 2002-03-08 A | 2003-06-06 A | 100% | 2002-03-08 | 2003-06-06 | 326d |  | T2 | 7328h | 7328h | MEXE6 |  |  | Rel-6 | Kimmo | MEXE6 |  |  |  |
| 3677 | 19.1 | MExE Rel-6 Improvements and Investigations |  | 264d | 2002-03-08 A | 2003-03-12 A | 100% | 2002-03-08 | 2003-03-12 | 264d | finish no earlier than 2003-03-12 | T2 | 2112h | 2112h | MEXE6-ENHANC | TTPCom | Lars Brenk ( (lsb_ttpcom@HOTMAIL.COM) | Rel-6 | Kimmo | MEXE6-ENHANC |  |  |  |
| 3678 | 19.2 | MExE Run-Time Independent Framework Feasibility Study |  | 326d | 2002-03-08 A | 2003-06-06 A | 100% | 2002-03-08 | 2003-06-06 | 326d | finish no earlier than 2003-06-06 | T2 | 2608h | 2608h | MEXE6-RTIF | Nokia Siemens Networks | balazs.bertenyi@nokia.com | Rel-6 | Kimmo | MEXE6-RTIF | 22.857 |  |  |
| 3679 | 21 | Subscription Management |  | 650d | 2002-09-20 A | 2005-03-17 A | 100% | 2002-09-20 | 2005-03-17 | 650d | finish no earlier than 2005-03-17 | S5 | 5200h | 5200h | SuM | T-Mobile | istvan.aba@t-mobile.at | Rel-6 | Mirko | SuM | 32.140/1, 32.171/2/5, 32.803 |  |  |

Notes:
- 3654: -
- 3655: -
- 3656: Updated according to SP-040232
- 3657: Completed
- 3658: SP#28 06/2005 completed
- 3659: -
- 3660: -
- 3661: No contributions assumed that no more will be done in 3GPP hence work may need to be done in 3GPP2
- 3662: -
- 3663: -
- 3664: Changed from FS to actual support of Push
- 3665: -
- 3666: -
- 3667: -
- 3668: -
- 3669: -
- 3670: -
- 3671: -
- 3672: -
- 3673: -
- 3674: SP#25 09/2004 completed
- 3675: originally it was intended to create a FS TR but most likely the work will become an Annex of 23.140
- 3676: -
- 3677: -
- 3678: -
- 3679: SP#27 03/2005 completed

| ID | WBS | Task | Duration | Start | Finish | Complete | Baseline start | Baseline finish | Baseline duration | Constraint | Resources | Work | Actual work | Acronym | WI rapporteur name | WI rapporteur e-mail | Release | MCC resp | Acronym_3GU_Export |
| --- | --- | --- | --- | --- | --- | --- | --- | --- | --- | --- | --- | --- | --- | --- | --- | --- | --- | --- | --- |
| 3680 | 22 | **Presence Capability** | 1233d? | 2001-03-19 A | 2005-12-07 A | 100% | 2001-03-19 | 2005-12-07 | 1233d? |  | S1; S2; S3; S4; N1; N3; N4; OMA | 111784h | 111784h | PRESNC | Motorola | Mark Cataldo | Rel-6 | Alain | PRESNC |
| 3681 | 22.1 | Stage 1 for Presence Capability | 610d | 2001-03-19 A | 2003-07-18 A | 100% | 2001-03-19 | 2003-07-18 | 610d | finish no earlier than 2003-07-18 | S1 | 4880h | 4880h |  | Motorola | Mark Cataldo | Rel-6 | Alain |  |
| 3682 | 22.2 | Stage 2 for Presence Capability | 268d | 2001-09-12 A | 2002-09-20 A | 100% | 2001-09-12 | 2002-09-20 | 268d | finish no earlier than 2002-09-20 | S2 | 2144h | 2144h |  | Nokia | balazs.bertenyi@nsn.com | Rel-6 | Maurice |  |
| 3683 | 22.3 | Stage 3 for Presence Capability | 703d | 2002-04-01 A | 2004-12-08 A | 100% | 2002-04-01 | 2004-12-08 | 703d | finish no earlier than 2004-12-08 | N1; N4 | 11248h | 11248h |  | Lucent | Keith Drage (drage@alcatel-lucent.com) | Rel-6 | Frederic |  |
| 3684 | 967.4 | Stage 3 (CN3 Part Pk interface) | 770d? | 2002-04-01 A | 2005-03-11 A | 100% | 2002-04-01 | 2005-03-11 | 770d? | finish no earlier than 2005-03-11 | N3 | 6160h | 6160h |  | Lucent | Keith Drage (drage@alcatel-lucent.com) | Rel-6 | Gwiho |  |
| 3685 | 967.5 | Media Codecs and Formats for IMS Messaging and Presence | 650d? | 2003-06-12 A | 2005-12-07 A | 100% | 2003-06-12 | 2005-12-07 | 650d? | finish no earlier than 2005-12-07 | S4 | 5200h | 5200h | PRESNC-COFIMP | Nokia | harri.honko@nokia.com | Rel-6 | Paolo | PRESNC-COFIMP |
| 3686 | 22.4 | Security aspects of Presence Capability | 79d | 2002-08-26 A | 2002-12-12 A | 100% | 2002-08-26 | 2002-12-12 | 79d | finish no earlier than 2002-12-12 | S3 | 632h | 632h |  | Ericsson | krister.boman@erv.ericsson.se | Rel-6 | Mirko |  |
| 3687 | 967.7 | SIMPLE Presence | 326d? | 2004-01-01 A | 2005-03-31 A | 100% | 2004-01-01 | 2005-03-31 | 326d? | finish no earlier than 2004-12-30 | OMA | 2608h | 2608h |  |  | OMA-LIAISON@mail.openmobilealliance.org | Rel-6 |  |  |
| 3688 | 25 | **Enhanced A/Gb feasibility study** | 51d? | 2002-08-30 A | 2002-11-08 A | 100% | 2002-08-30 | 2002-11-08 | 51d? |  | GP | 3264h | 3264h | AGbEnFS | Vodafone | jose-luis.carrizo@vodafone.co.uk | Rel-6 | Paolo | AGbEnFS |
| 3689 | 25.1 | **Feasibility study on A/Gb enhancements** | 51d? | 2002-08-30 A | 2002-11-08 A | 100% | 2002-08-30 | 2002-11-08 | 51d? |  | G2 | 2856h | 2856h | AGbEnFS-FS | Vodafone | jose-luis.carrizo@vodafone.co.uk | Rel-6 | Gert | AGbEnFS-FS |
| 3690 | 25.1.1 | Requirements for the support of conversational services | 51d | 2002-08-30 A | 2002-11-08 A | 100% | 2002-08-30 | 2002-11-08 | 51d | finish no earlier than 2002-11-08 | GP | 408h | 408h |  |  |  | Rel-6 | Paolo |  |
| 3691 | 968.1.2 | Identification of the different building blocks for the provision of conversational services on the existing A/Gb protocol stack | 51d? | 2002-08-30 A | 2002-11-08 A | 100% | 2002-08-30 | 2002-11-08 | 51d? | finish no earlier than 2002-11-08 | GP | 408h | 408h |  |  |  | Rel-6 | Paolo |  |
| 3692 | 968.1.3 | Outline of impact and feasibility of these building blocks and their different solutions | 51d? | 2002-08-30 A | 2002-11-08 A | 100% | 2002-08-30 | 2002-11-08 | 51d? | finish no earlier than 2002-11-08 | GP | 408h | 408h |  |  |  | Rel-6 | Paolo |  |
| 3693 | 25.1.4 | Impact on 3GPP architecture and requirement to co-ordinatge with other TSGs (CN, SA) | 51d | 2002-08-30 A | 2002-11-08 A | 100% | 2002-08-30 | 2002-11-08 | 51d | finish no earlier than 2002-11-08 | GP | 408h | 408h |  |  |  | Rel-6 | Paolo |  |
| 3694 | 25.1.5 | Standardisation effort | 51d | 2002-08-30 A | 2002-11-08 A | 100% | 2002-08-30 | 2002-11-08 | 51d | finish no earlier than 2002-11-08 | GP | 408h | 408h |  |  |  | Rel-6 | Paolo |  |
| 3695 | 25.1.6 | Dependency to other features of Enhanced A/Gb feasibility study | 51d | 2002-08-30 A | 2002-11-08 A | 100% | 2002-08-30 | 2002-11-08 | 51d | finish no earlier than 2002-11-08 | GP | 408h | 408h |  |  |  | Rel-6 | Paolo |  |
| 3696 | 26 | **Flexible Layer One for GERAN** | 1171d | 2000-01-03 A | 2004-06-25 A | 100% | 2000-01-03 | 2004-06-25 | 1171d |  | GP; S3 | 86648h | 86648h | FLOGER | Nokia | benoist.sebire@nokia.com | Rel-6 | Paolo | FLOGER |
| 3697 | 26.1 | **Realisation of a Flexible Layer One** | 1126d | 2000-01-03 A | 2004-04-23 A | 100% | 2000-01-03 | 2004-04-23 | 1126d |  | GP | 42816h | 42816h | FLOGER-Real | Nokia | benoist.sebire@nokia.com | Rel-6 | Paolo | FLOGER-Real |
| 3698 | 26.1.1 | Technical Report on Realisation of a Flexible Layer One | 471d | 2002-04-19 A | 2004-02-06 A | 100% | 2002-04-19 | 2004-02-06 | 471d | finish no earlier than 2004-02-06 | GP | 3768h | 3768h |  | Nokia | benoist.sebire@nokia.com | Rel-6 | Paolo |  |
| 3699 | 26.1.2 | Architecture in 45.001 and 43.051 | 526d | 2002-04-19 A | 2004-04-23 A | 100% | 2002-04-19 | 2004-04-23 | 526d | finish no earlier than 2004-04-23 | G1 | 4208h | 4208h |  | Nokia | benoist.sebire@nokia.com | Rel-6 | Paolo |  |
| 3700 | 26.1.3 | Multiplexing in 45.002 | 526d | 2002-04-19 A | 2004-04-23 A | 100% | 2002-04-19 | 2004-04-23 | 526d | finish no earlier than 2004-04-23 | G1 | 4208h | 4208h |  | Nokia | benoist.sebire@nokia.com | Rel-6 | Paolo |  |
| 3701 | 26.1.4 | Channel Coding in 45.003 for Realisation of a Flexible Layer One | 526d | 2002-04-19 A | 2004-04-23 A | 100% | 2002-04-19 | 2004-04-23 | 526d | finish no earlier than 2004-04-23 | G1 | 4208h | 4208h |  | Nokia | benoist.sebire@nokia.com | Rel-6 | Paolo |  |
| 3702 | 26.1.5 | Performance Requirements in 45.005 for Realisation of a Flexible Layer One | 1126d | 2000-01-03 A | 2004-04-23 A | 100% | 2000-01-03 | 2004-04-23 | 1126d | finish no earlier than 2004-04-23 | G1 | 9000h | 9000h |  | Nokia | benoist.sebire@nokia.com | Rel-6 | Paolo |  |
| 3703 | 26.1.6 | Radio subsystem link control in 45.008 for Realisation of a Flexible Layer One | 526d | 2002-04-19 A | 2004-04-23 A | 100% | 2002-04-19 | 2004-04-23 | 526d | finish no earlier than 2004-04-23 | G1 | 4208h | 4208h |  | Nokia | benoist.sebire@nokia.com | Rel-6 | Paolo |  |
| 3704 | 26.1.7 | Requirements in 44.004 | 526d | 2002-04-19 A | 2004-04-23 A | 100% | 2002-04-19 | 2004-04-23 | 526d | finish no earlier than 2004-04-23 | G2 | 4208h | 4208h |  | Nokia | benoist.sebire@nokia.com | Rel-6 | Gert |  |

Notes:
- 3680: merged "Presence Service Enhancements" (UID31028, PRES1) to this feature as no answer was provided on why Presence and Presence Encmts had same target completion date
- 3681: TP#16 moved Stage 1 to Rel-6 TS 22.141 (existed already in Rel-5) / Impacted TSs and TRs: 22.141
- 3682: - / Impacted TSs and TRs: 23.002, 24.229, New 23.141
- 3683: Dependency to 2 IETF drafts, no known work at the moment / Impacted TSs and TRs: New N1 (24.141, 24.841), N4 (29.002, 29.228, 29.230, 29.328)
- 3684: - / Impacted TSs and TRs: 29.061, 29.161
- 3685: - / Impacted TSs and TRs: 26.141, 26.936
- 3686: SP#17 approved WID S3-020429
- 3687: SP#24 OMA LS_in update in SP-040232 OMA dependencies on 3GPP deliverables
- 3688: - / Impacted TSs and TRs: None
- 3689: - / Impacted TSs and TRs: None
- 3690: - / Impacted TSs and TRs: None
- 3691: - / Impacted TSs and TRs: None
- 3692: - / Impacted TSs and TRs: None
- 3693: - / Impacted TSs and TRs: None
- 3694: - / Impacted TSs and TRs: None
- 3695: - / Impacted TSs and TRs: None
- 3696: -
- 3697: -
- 3698: -
- 3699: -
- 3700: -
- 3701: -
- 3702: -
- 3703: -
- 3704: -

| ID | WBS | Task | Type | Duration | Start | Finish | Complete | Baseline start | Baseline finish | Baseline duration | Constraint | Resources | Work | Actual work | Acronym | WI rapporteur name | WI rapporteur e-mail | Release | MCC resp | Acronym_3GU_Export | Impacted TSs and TRs | TSG stopped |
| --- | --- | --- | --- | --- | --- | --- | --- | --- | --- | --- | --- | --- | --- | --- | --- | --- | --- | --- | --- | --- | --- | --- |
| 3705 | 26.2 | **Signalling and protocol support for a Flexible Layer One** |  | 571d | 2002-04-19 A | 2004-06-25 A | 100% | 2002-04-19 | 2004-06-25 | 571d |  | G2 | 13704h | 13704h | FLOGER-SigPro | Nokia | benoist.sebire@nokia.com | Rel-6 | Gert | FLOGER-SigPro |  |  |
| 3706 | 26.2.1 | Modifications to RLC/MAC in 44.060 and 44.160 |  | 571d | 2002-04-19 A | 2004-06-25 A | 100% | 2002-04-19 | 2004-06-25 | 571d | finish no earlier than 2004-06-25 | G2 | 4568h | 4568h |  | Nokia | benoist.sebire@nokia.com | Rel-6 | Gert |  |  |  |
| 3707 | 26.2.2 | Modifications to RRC in 44.118 and 44.018 |  | 571d | 2002-04-19 A | 2004-06-25 A | 100% | 2002-04-19 | 2004-06-25 | 571d | finish no earlier than 2004-06-25 | G2 | 4568h | 4568h |  | Nokia | benoist.sebire@nokia.com | Rel-6 | Gert |  |  |  |
| 3708 | 26.3 | **Security for a Flexible Layer One** |  | 356d | 2002-04-19 A | 2003-08-29 A | 100% | 2002-04-19 | 2003-08-29 | 356d |  | S3; G2 | 11392h | 11392h | FLOGER-SecFLO | Nokia | benoist.sebire@nokia.com | Rel-6 | Mirko | FLOGER-SecFLO |  |  |
| 3709 | 26.3.1 | Ciphering in 44.060, 44.160, 44.018, 44.118 |  | 356d | 2002-04-19 A | 2003-08-29 A | 100% | 2002-04-19 | 2003-08-29 | 356d | finish no earlier than 2003-08-29 | S3; G2 | 5696h | 5696h |  | Nokia | benoist.sebire@nokia.com | Rel-6 | Mirko |  | 44.060, 44.160, 44.018, 44.118 |  |
| 3710 | 26.4 | **Deleted - GERAN MS Conformance test for the Flexible Layer One - DELETE** |  | 0d | 2004-02-06 A | 2004-02-06 A | 100% | 2004-02-06 | 2004-02-06 | 0d |  | G4; G5 |  |  | FLOGER-Msconf | Nokia | benoist.sebire@nokia.com | Rel-6 | Paolo | FLOGER-Msconf |  | GP-27 |
| 3711 | 26.4.1 | Deleted at TSG #27 - MS Test in 51.010 | milestone | 0d | 2004-02-06 A | 2004-02-06 A | 100% | 2004-02-06 | 2004-02-06 | 0d | finish no earlier than 2004-02-06 | G4; G5 |  |  |  | Nokia | benoist.sebire@nokia.com | Rel-6 | Paolo |  |  | GP-22 |
| 3712 | 26.5 | **Deleted - GERAN BTS Conformance test for the Flexible Layer One - DELETE** |  | 0d | 2004-02-06 A | 2004-02-06 A | 100% | 2004-02-06 | 2004-02-06 | 0d |  | G3new |  |  | FLOGER-BTSconf | Nokia | benoist.sebire@nokia.com | Rel-6 | Ingbert | FLOGER-BTSconf |  | GP-27 |
| 3713 | 26.5.1 | Deleted at TGS #27 - BTS Test in 51.021 - DELETE | milestone | 0d | 2004-02-06 A | 2004-02-06 A | 100% | 2004-02-06 | 2004-02-06 | 0d | finish no earlier than 2004-02-06 | G3new |  |  |  | Nokia | benoist.sebire@nokia.com | Rel-6 | Ingbert |  |  | GP-22 |
| 3714 | 27 | Uplink TDOA feasibility study |  | 151d | 2001-11-30 A | 2002-06-28 A | 100% | 2001-11-30 | 2002-06-28 | 151d | finish no earlier than 2002-06-28 | GP | 1208h | 1208h | TDOAF | TruePosition | Bob Gross (rlgross@trueposition.com) | Rel-6 | Paolo | TDOAF | 45.811 |  |
| 3715 | 28 | **Multimedia Broadcast and Multicast Service** |  | 1781d? | 2001-05-11 A | 2008-03-07 A | 100% | 2001-05-11 | 2008-03-07 | 1781d? |  | S1; S2; S3; S4; S5; N1; N3; R2; R4; R5; T1; GP; G2; G3new | 391176h | 391176h | MBMS |  |  | Rel-6 | Alain | MBMS |  |  |
| 3716 | 28.1 | Stage 1 for Multimedia Broadcast and Multicast Service |  | 232d | 2001-05-11 A | 2002-04-01 A | 100% | 2001-05-11 | 2002-04-01 | 232d | finish no earlier than 2002-04-01 | S1 | 1856h | 1856h |  |  |  | Rel-6 | Alain |  | 22.146, 22.101 |  |
| 3717 | 28.2 | **Stage 2 for Multimedia Broadcast and Multicast Service** |  | 648d | 2001-09-24 A | 2004-03-17 A | 100% | 2001-09-24 | 2004-03-17 | 648d |  | S2 | 10408h | 10408h |  |  |  | Rel-6 | Maurice |  |  |  |
| 3718 | 28.2.1 | TR on MBMS Architectural Study |  | 240d | 2001-09-24 A | 2002-08-23 A | 100% | 2001-09-24 | 2002-08-23 | 240d | finish no earlier than 2002-08-23 | S2 | 1920h | 1920h |  |  |  | Rel-6 | Maurice |  | 23.846 |  |
| 3719 | 28.2.2 | Stage 2 MBMS Specification Work |  | 413d | 2002-08-19 A | 2004-03-17 A | 100% | 2002-08-19 | 2004-03-17 | 413d | finish no earlier than 2004-03-17 | S2 | 3304h | 3304h |  |  |  | Rel-6 | Maurice |  | 23.246 |  |
| 3720 | 28.4 | Support of the MBMS in CN protocols |  | 647d | 2002-06-18 A | 2004-12-08 A | 100% | 2002-06-18 | 2004-12-08 | 647d | finish no earlier than 2004-12-08 | N1 | 5176h | 5176h |  |  |  | Rel-6 | Frederic |  |  |  |
| 3721 | 971.4 | Gmb interface for MBMS (CN3 part) |  | 334d | 2003-08-29 A | 2004-12-08 A | 100% | 2003-08-29 | 2004-12-08 | 334d | finish no earlier than 2004-12-08 | N3 | 2672h | 2672h |  |  |  | Rel-6 | Gwiho |  | 29.061 |  |
| 3722 | 28.5 | Security aspects of MBMS |  | 710d | 2002-07-01 A | 2005-03-18 A | 100% | 2002-07-01 | 2005-03-18 | 710d | finish no earlier than 2005-03-18 | S3 | 5680h | 5680h |  |  | adrian.escott@three.co.uk | Rel-6 | Mirko |  | New 33.246 |  |
| 3723 | 971.6 | MBMS Charging |  | 108d? | 2005-01-11 A | 2005-06-09 A | 100% | 2005-01-11 | 2005-06-09 | 108d? | start no earlier than 2005-01-11 | S5 | 864h | 864h | MBMS-CH |  |  | Rel-6 | Mirko | MBMS-CH | 32.273 |  |
| 3724 | 28.1 | **MBMS User Services** |  | 743d? | 2003-05-13 A | 2006-03-16 A | 100% | 2003-05-13 | 2006-03-16 | 743d? |  | S1; S4 | 19520h | 19520h |  |  |  | Rel-6 | Alain |  |  |  |
| 3725 | 28.1 | Stage 1 for MBMS User Services |  | 233d | 2003-05-13 A | 2004-04-01 A | 100% | 2003-05-13 | 2004-04-01 | 233d | start no earlier than 2003-05-13 | S1 | 1864h | 1864h |  |  |  | Rel-6 | Alain |  | 22.246 |  |
| 3726 | 971.7.2 | Definition of MBMS user services, media codecs, formats and transport/application protocols using MBMS |  | 721d? | 2003-06-12 A | 2006-03-16 A | 100% | 2003-06-12 | 2006-03-16 | 721d? | finish no earlier than 2006-03-16 | S4 | 5768h | 5768h | MBMS-TSMBMS | Nokia | igor.curcio@nokia.com | Rel-6 | Paolo | MBMS-TSMBMS | 26.346, 26.936, 26.946 |  |
| 3727 | 28.3 | **Introduction of MBMS in RAN** |  | 967d? | 2002-01-01 A | 2005-09-14 A | 100% | 2002-01-01 | 2005-09-14 | 967d? |  | R2; R4 | 23728h | 23728h | MBMS-RAN | Nokia | juho.pirskanen@nokia.com | Rel-6 | Yong-Jun | MBMS-RAN |  |  |
| 3728 | 971.8.1 | Introduction of MBMS in RAN (physical & upper layers, access network interfaces) |  | 771d? | 2002-01-01 A | 2004-12-14 A | 100% | 2002-01-01 | 2004-12-14 | 771d? | finish no earlier than 2004-12-14 | R2 | 6168h | 6168h |  | Nokia | juho.pirskanen@nokia.com | Rel-6 | Yong-Jun |  | 25.346, 25.304, 25.321, 25.322, 25.323 |  |
| 3729 | 971.8.2 | UE Performance Requirements for MBMS |  | 261d? | 2004-09-15 A | 2005-09-14 A | 100% | 2004-09-15 | 2005-09-14 | 261d? | finish no earlier than 2005-09-15 | R4 | 2088h | 2088h | MBMS-RAN-RF | Ericsson | Torgny.Palenius@ericsson.com | Rel-6 | Issam | MBMS-RAN-RF | 25.101, 25.133 |  |

Notes:
- 3705: -
- 3706: -
- 3707: -
- 3708: -
- 3709: -
- 3710: -
- 3711: -
- 3712: -
- 3713: -
- 3714: -
- 3715: SP#13 Title renamed
- 3716: -
- 3717: -
- 3718: -
- 3719: -
- 3720: -
- 3721: -
- 3722: SP#17 approved WID S3-020433
- 3723: SP#28 completed
- 3724: -
- 3725: -
- 3726: -
- 3727: -
- 3728: -
- 3729: RP#25 approved WID RP-040370

| ID | WBS | Task | Type | Duration | Start | Finish | Complete | Baseline start | Baseline finish | Baseline duration | Constraint | Deadline | Resources | Work | Actual work | Acronym | Release | MCC resp | Acronym_3GU_Export | Impacted TSs and TRs | WI rapporteur name | WI rapporteur e-mail | Created at | TSG stopped |
| --- | --- | --- | --- | --- | --- | --- | --- | --- | --- | --- | --- | --- | --- | --- | --- | --- | --- | --- | --- | --- | --- | --- | --- | --- |
| 3730 | 971.9 | **MBMS UE Conformance Testing** |  | 521d? | 2006-03-10 A | 2008-03-07 A | 100% | 2006-03-10 | 2008-03-07 | 521d? |  |  | R5; T1 | 34400h | 34400h | MBMS-UEConTest | Rel-6 | Ingbert | MBMS-UEConTest |  |  |  |  |  |
| 3731 | 16.5.1 | RF/RRM Conformance Test Aspects – MBMS (FDD) |  | 461d | 2006-06-02 A | 2008-03-07 A | 100% | 2006-06-02 | 2008-03-07 | 461d | finish no earlier than 2008-03-07 | 2006-06-02 | R5; T1 | 7376h | 7376h | MBMS-RAN-RF_Test | Rel-6 | Ingbert | MBMS-RAN-RF_Test | 34.108, 34.109, 34.121-1, 34.121-2 | Ericsson | leif.mattisson@ericsson.com | Fri 11/03/05 |  |
| 3732 | 971.9.2 | Conformance Test Aspects - MBMS for 3.84 Mcps and 7.68 Mcps TDD |  | 318d? | 2006-09-20 A | 2007-12-07 A | 100% | 2006-09-20 | 2007-12-07 | 318d? | finish no earlier than 2007-12-07 |  | R5; T1 | 5088h | 5088h | MBMS-UEConTest_TDH | Rel-6 | Ingbert | MBMS-UEConTest_TDH | 34.108, 34.122, 34.123-1, 34.123-2, 34.123-3 | IPWireless | Timothy Speight (tspeight@ipwireless.com) |  |  |
| 3733 | 971.9.3 | Signalling Conformance Test Aspects – MBMS for LCR TDD |  | 318d? | 2006-09-20 A | 2007-12-07 A | 100% | 2006-09-20 | 2007-12-07 | 318d? | finish no earlier than 2007-12-07 |  | R5; T1 | 5088h | 5088h | MBMS-UEConTest_SIGTDL | Rel-6 | Ingbert | MBMS-UEConTest_SIGTDL | 34.108, 34.123-1, 34.123-2, 34.123-3 | Datang | zhaojian@datangmobile.cn |  |  |
| 3734 | 971.9.4 | Conformance Test Aspects – MBMS |  | 396d? | 2006-03-10 A | 2007-09-14 A | 100% | 2006-03-10 | 2007-09-14 | 396d? | finish no earlier than 2007-09-14 |  | R5; T1 | 6336h | 6336h | MBMS_Test | Rel-6 | Ingbert | MBMS_Test | 34.108, 34.123-1, 34.123-2, 34.123-3 | Qualcomm | Shubhang Vora (svora@qualcomm.com) |  |  |
| 3735 | 16.5.1 | Conformance Test Aspects - 1.28 Mcps TDD MBMS RF/RRM |  | 136d | 2007-06-01 A | 2007-12-07 A | 100% | 2007-06-01 | 2007-12-07 | 136d | finish no earlier than 2007-12-07 | 2006-06-02 | R5; T1 | 2176h | 2176h | MBMS-UEConTest_RFTDL | Rel-6 | Ingbert | MBMS-UEConTest_RFTDL | 34.108, 34.109, 34.122 | Datang | chenxiaozhong@datangmobile.cn | Fri 11/03/05 |  |
| 3736 | 28.6 | **Support of MBMS in GERAN** |  | 892d? | 2001-08-30 A | 2005-01-28 A | 100% | 2001-08-30 | 2005-01-28 | 892d? |  |  | GP; G2; G3new | 87400h | 87400h | MBMS-GERAN | Rel-6 | Paolo | MBMS-GERAN |  |  |  |  |  |
| 3737 | 28.6.1 | MBMS Impact on the logical and physical channels |  | 631d | 2002-08-30 A | 2005-01-28 A | 100% | 2002-08-30 | 2005-01-28 | 631d | finish no earlier than 2005-01-28 |  | GP | 5048h | 5048h |  | Rel-6 | Paolo |  |  |  |  |  |  |
| 3738 | 28.6.4 | MBMS Re-synchronisation at cell change |  | 631d | 2002-08-30 A | 2005-01-28 A | 100% | 2002-08-30 | 2005-01-28 | 631d | finish no earlier than 2005-01-28 |  | G2 | 5048h | 5048h |  | Rel-6 | Gert |  |  |  |  |  |  |
| 3739 | 971.10.3 | Simultaneous support of MBMS services |  | 631d? | 2002-08-30 A | 2005-01-28 A | 100% | 2002-08-30 | 2005-01-28 | 631d? | finish no earlier than 2005-01-28 |  | GP | 5048h | 5048h |  | Rel-6 | Paolo |  |  |  |  |  |  |
| 3740 | 971.10.4 | Simultaneous support of MBMS and non-MBMS services |  | 892d? | 2001-08-30 A | 2005-01-28 A | 100% | 2001-08-30 | 2005-01-28 | 892d? | finish no earlier than 2005-01-28 |  | GP | 7136h | 7136h |  | Rel-6 | Paolo |  |  |  |  |  |  |
| 3741 | 971.10.5 | MBMS Resynchronization at cell change |  | 892d? | 2001-08-30 A | 2005-01-28 A | 100% | 2001-08-30 | 2005-01-28 | 892d? | finish no earlier than 2005-01-28 |  | GP | 7136h | 7136h |  | Rel-6 | Paolo |  |  |  |  |  |  |
| 3742 | 28.6.5 | MBMS Decision making process between point-to-point or point-to-multipoint configurations |  | 631d | 2002-08-30 A | 2005-01-28 A | 100% | 2002-08-30 | 2005-01-28 | 631d | finish no earlier than 2005-01-28 |  | GP | 5048h | 5048h |  | Rel-6 | Paolo |  |  |  |  |  |  |
| 3743 | 28.6.6 | MBMS channel allocations procedures to multiple MSs |  | 631d | 2002-08-30 A | 2005-01-28 A | 100% | 2002-08-30 | 2005-01-28 | 631d | finish no earlier than 2005-01-28 |  | GP | 5048h | 5048h |  | Rel-6 | Paolo |  |  |  |  |  |  |
| 3744 | 28.6.7 | MBMS Changes to the Gb interface |  | 631d | 2002-08-30 A | 2005-01-28 A | 100% | 2002-08-30 | 2005-01-28 | 631d | finish no earlier than 2005-01-28 |  | GP | 5048h | 5048h |  | Rel-6 | Paolo |  |  |  |  |  |  |
| 3745 | 28.6.8 | GERAN specific changes to the Iu-ps interface for MBMS |  | 631d | 2002-08-30 A | 2005-01-28 A | 100% | 2002-08-30 | 2005-01-28 | 631d | finish no earlier than 2005-01-28 |  | GP | 5048h | 5048h |  | Rel-6 | Paolo |  |  |  |  |  |  |
| 3746 | 28.6.9 | Interaction between MBMS and Iu-flex |  | 631d | 2002-08-30 A | 2005-01-28 A | 100% | 2002-08-30 | 2005-01-28 | 631d | finish no earlier than 2005-01-28 |  | GP | 5048h | 5048h |  | Rel-6 | Paolo |  |  |  |  |  |  |
| 3747 | 28.6.10 | MBMS Security aspects |  | 631d | 2002-08-30 A | 2005-01-28 A | 100% | 2002-08-30 | 2005-01-28 | 631d | finish no earlier than 2005-01-28 |  | GP | 5048h | 5048h |  | Rel-6 | Paolo |  |  |  |  |  |  |
| 3748 | 971.10.12 | MBMS-GERAN - MS conformance tests |  | 786d? | 2002-01-25 A | 2005-01-28 A | 100% | 2002-01-25 | 2005-01-28 | 786d? | finish no earlier than 2005-01-28 |  | G3new | 6288h | 6288h |  | Rel-6 | Ingbert |  |  |  |  |  |  |
| 3749 | 971.10.13 | Deleted - MS conformance tests - G5 | milestone | 0d? | 2003-06-27 A | 2003-06-27 A | 100% | 2003-06-27 | 2003-06-27 | 0d? | start no earlier than 2003-06-27 |  | G5 |  |  |  | Rel-6 | Paolo |  |  |  |  |  | GP-19 |
| 3750 | 29 | **Speech Recognition and Speech Enabled Services** |  | 1105d? | 2001-10-08 A | 2005-12-30 A | 100% | 2001-10-08 | 2005-12-30 | 1105d? |  |  | S1; S2; S4; OMA | 46696h | 46696h | SRSES | Rel-6 | Alain | SRSES |  |  |  |  |  |
| 3751 | 29.1 | Speech Enabled Services Based on Distributed Speech Recognition (DSR) |  | 115d | 2001-10-08 A | 2002-03-15 A | 100% | 2001-10-08 | 2002-03-15 | 115d | finish no earlier than 2002-03-15 |  | S1 | 920h | 920h | DSR | Rel-6 | Alain | DSR | 22.977, 22.941, 23.207, 22.243 | Qualcomm | Dwilliams@qualcomm.com |  |  |
| 3752 | 29.2 | TR on Architectural impacts |  | 212d | 2003-05-12 A | 2004-03-02 A | 100% | 2003-05-12 | 2004-03-02 | 212d | finish no earlier than 2004-03-02 |  | S2 | 1696h | 1696h |  | Rel-6 | Maurice |  | 23.877 |  |  |  |  |
| 3753 | 972.3 | Codec Work to Support Speech Recognition Framework for Automated Voice Services |  | 568d? | 2002-10-15 A | 2004-12-16 A | 100% | 2002-10-15 | 2004-12-16 | 568d? | finish no earlier than 2004-12-16 |  | S4 | 4544h | 4544h | SRSES-Codec | Rel-6 | Paolo | SRSES-Codec | 26.235, 26.236, 26.243, 26.177, 26.943 | Motorola | David Pearce (bdp003@motorola.com) |  |  |
| 3754 | 972.4 | Multimodal support |  | 522d? | 2004-01-01 A | 2005-12-30 A | 100% | 2004-01-01 | 2005-12-30 | 522d? | finish no earlier than 2005-06-30 |  | OMA | 4176h | 4176h |  | Rel-6 | Paolo |  |  |  | OMA-LIAISON@mail.openmobilealliance.org | SP-24 |  |
| 3755 | 972.5 | Deleted - SES codec negotiation at Session Description Protocol (SDP) | milestone | 0d? | 2003-06-04 A | 2003-06-04 A | 100% | 2003-06-04 | 2003-06-04 | 0d? | start no earlier than 2003-06-04 |  | N1 |  |  |  | Rel-6 | Frederic |  |  |  |  |  | NP-23 |

Notes:
- 3730: -
- 3731: -
- 3732: -
- 3733: -
- 3734: -
- 3735: -
- 3736: -
- 3737: -
- 3738: -
- 3739: -
- 3740: -
- 3741: -
- 3742: -
- 3743: -
- 3744: -
- 3745: -
- 3746: -
- 3747: -
- 3748: -
- 3749: -
- 3750: -
- 3751: -
- 3752: -
- 3753: -
- 3754: -
- 3755: Abandoned NP-23

| ID | WBS | Task | Type | Duration | Start | Finish | Complete | Baseline start | Baseline finish | Baseline duration | Constraint | Resources | Work | Actual work | Acronym | Release | MCC resp | Acronym_3GU_Export | WI rapporteur name | WI rapporteur e-mail | Created at | TSG stopped | Special Focus Doc |
| --- | --- | --- | --- | --- | --- | --- | --- | --- | --- | --- | --- | --- | --- | --- | --- | --- | --- | --- | --- | --- | --- | --- | --- |
| 3756 | 30 | **Generic User Profile Rel-6** |  | 889d | 2001-10-08 A | 2005-03-03 A | 100% | 2001-10-08 | 2005-03-03 | 889d |  | S1; S3; N4 | 38519.8h | 38519.8h | GUP | Rel-6 | Alain | GUP |  |  |  |  |  |
| 3757 | 30.1 | Stage 1 - Requirements for Generic User Profile |  | 430d | 2001-10-08 A | 2003-05-30 A | 100% | 2001-10-08 | 2003-05-30 | 430d | finish no earlier than 2002-12-09 | S1 | 3440h | 3440h |  | Rel-6 | Alain |  | T-Mobile | kurt.bischinger@t-mobile.at |  |  |  |
| 3758 | 30.3 | Stage 2 - Architecture |  | 355d | 2002-01-28 A | 2003-06-06 A | 100% | 2002-01-28 | 2003-06-06 | 355d | finish no earlier than 2003-06-06 | S2 | 2840h | 2840h |  | Rel-6 | Maurice |  | Nokia | harri.o.koskinen@nokia.com |  |  |  |
| 3759 | 30.2 | Stage 2 - Data Description Method |  | 586d | 2002-12-05 A | 2005-03-03 A | 100% | 2002-12-05 | 2005-03-03 | 586d | finish no earlier than 2005-03-03 | N4 | 4688h | 4688h |  | Rel-6 | Kimmo |  | T-Mobile | kurt.bischinger@t-mobile.at |  |  |  |
| 3760 | 30.5 | Stage 3 - Network |  | 468.98d | 2003-05-19 A | 2005-03-03 A | 100% | 2003-05-19 | 2005-03-03 | 468.98d | finish no earlier than 2005-03-03 | N4 | 3751.83h | 3751.83h |  | Rel-6 | Kimmo |  |  |  |  |  |  |
| 3761 | 30.6 | Security aspects of GUP |  | 308d | 2002-07-16 A | 2003-09-18 A | 100% | 2002-07-16 | 2003-09-18 | 308d | finish no earlier than 2003-09-18 | S3 | 2464h | 2464h |  | Rel-6 | Mirko |  | Lucent | Bradley Owen (bvowen@lucent.com) |  |  |  |
| 3762 | 31 | **Digital Rights Management** |  | 690d? | 2001-10-08 A | 2004-05-28 A | 100% | 2001-10-08 | 2004-05-28 | 690d? |  | S1; OMA | 15672h | 15672h | DRM | Rel-6 | Alain | DRM |  |  |  |  |  |
| 3763 | 31.1 | Requirements for Digital Rights Management |  | 179d | 2001-10-08 A | 2002-06-13 A | 100% | 2001-10-08 | 2002-06-13 | 179d | finish no earlier than 2002-06-13 | S1 | 1432h | 1432h |  | Rel-6 | Alain |  | Openwave | nicholas.wood@openwave.com |  |  |  |
| 3764 | 974.2 | Stage 2 for Digital Rights Management |  | 107d? | 2004-01-01 A | 2004-05-28 A | 100% | 2004-01-01 | 2004-05-28 | 107d? | finish no earlier than 2004-05-28 | OMA | 856h | 856h |  | Rel-6 |  |  |  | OMA-LIAISON@mail.openmobilealliance.org | SP-24 |  |  |
| 3765 | 974.3 | Stage 3 for Digital Rights Management |  | 107d? | 2004-01-01 A | 2004-05-28 A | 100% | 2004-01-01 | 2004-05-28 | 107d? | finish no earlier than 2004-05-28 | OMA | 856h | 856h |  | Rel-6 |  |  |  | OMA-LIAISON@mail.openmobilealliance.org | SP-24 |  |  |
| 3766 | 31.3 | Security for Digital Rights Management |  | 186d | 2002-06-17 A | 2003-03-03 A | 100% | 2002-06-17 | 2003-03-03 | 186d | finish no earlier than 2003-03-03 | OMA | 1488h | 1488h |  | Rel-6 |  |  |  |  |  |  |  |
| 3767 | 974.5 | Deleted - Monitoring of Stages 2 and 3 progress (actual work to be done by OMA) | milestone | 0d? | 2003-03-21 A | 2003-03-21 A | 100% | 2003-03-21 | 2003-03-21 | 0d? | start no earlier than 2002-08-19 | S1 |  |  |  | Rel-6 | Alain |  |  |  |  | SP-19 |  |
| 3768 | 32 | **WLAN-UMTS Interworking Rel-6** |  | 1495d? | 2000-01-03 A | 2005-09-22 A | 100% | 2000-01-03 | 2005-09-22 | 1495d? |  | S1; S2; S3; S5; N1; N3; N4; T3 | 129192h | 129192h | WLAN | Rel-6 | Alain | WLAN | Telenor | frederic.paint@telenor.com |  |  | WLAN |
| 3769 | 32.1 | Technical Report on WLAN-UMTS Interworking |  | 901d? | 2000-01-03 A | 2003-06-13 A | 100% | 2000-01-03 | 2003-06-13 | 901d? | finish no earlier than 2003-06-13 | S1 | 7200h | 7200h | WLAN-TR | Rel-6 | Alain | WLAN-TR | T-mobile | Mark.Younge@t-mobile.com |  |  | WLAN |
| 3770 | 975.2 | Stage 1 for WLAN-UMTS Interworking Rel-6 |  | 375d? | 2003-01-06 A | 2004-06-11 A | 100% | 2003-01-06 | 2004-06-11 | 375d? |  | S1 | 920h | 920h | WLAN-TS | Rel-6 | Alain | WLAN-TS | Telenor | frederic.paint@telenor.com | SP-24 |  | WLAN |
| 3771 | 32.2 | Architecture Definition for scenarii 2 and 3 |  | 571d | 2002-03-25 A | 2004-05-31 A | 100% | 2002-03-25 | 2004-05-31 | 571d | finish no earlier than 2004-05-31 | S2 | 4568h | 4568h |  | Rel-6 | Maurice |  |  |  |  |  | WLAN |
| 3772 | 32.3 | Security aspects of WLAN-UMTS Interworking |  | 125d | 2002-09-30 A | 2003-03-21 A | 100% | 2002-09-30 | 2003-03-21 | 125d | finish no earlier than 2003-03-21 | S3 | 1000h | 1000h |  | Rel-6 | Mirko |  | Ericsson, BT | luis.lopez-soria@ece.ericsson.se, colin.blanchard@bt.com |  |  | WLAN |
| 3773 | 975.5 | Stage 3 - CN4 aspects |  | 334d? | 2003-05-23 A | 2004-09-01 A | 100% | 2003-05-23 | 2004-09-01 | 334d? | finish no earlier than 2004-09-01 | N4 | 2672h | 2672h | WLAN-IW | Rel-6 | Kimmo | WLAN-IW | Nokia | raquel.rodriguez@nokia.com |  |  | WLAN |
| 3774 | 975.6 | Stage 3 - CN3 aspects (Wi Interface for Scenario 3) |  | 355d? | 2003-05-23 A | 2004-09-30 A | 100% | 2003-05-23 | 2004-09-30 | 355d? | start no earlier than 2003-05-23 | N3 | 2840h | 2840h |  | Rel-6 | Gwiho |  |  |  | SP-24 |  | WLAN |
| 3775 | 975.7 | Stage 3 for scenario 2 |  | 339d? | 2003-05-23 A | 2004-09-08 A | 100% | 2003-05-23 | 2004-09-08 | 339d? | finish no earlier than 2004-09-08 | N1 | 2712h | 2712h |  | Rel-6 | Frederic |  |  |  |  |  | WLAN |
| 3776 | 975.8 | Stage 3 for scenario 3 |  | 404d? | 2003-05-23 A | 2004-12-08 A | 100% | 2003-05-23 | 2004-12-08 | 404d? | finish no earlier than 2004-12-08 | N1 | 3232h | 3232h |  | Rel-6 | Frederic |  |  |  | SP-24 |  | WLAN |
| 3777 | 975.9 | WLAN charging |  | 655d? | 2003-03-21 A | 2005-09-22 A | 100% | 2003-03-21 | 2005-09-22 | 655d? | finish no earlier than 2005-09-22 | S5 | 5240h | 5240h | WLAN-CH | Rel-6 | Mirko | WLAN-CH | Nokia | Benni ALEXANDER |  |  | WLAN |
| 3778 | 975.10 | USIM enhancements for WLAN Interworking |  | 391d? | 2003-09-05 A | 2005-03-04 A | 100% | 2003-09-05 | 2005-03-04 | 391d? | finish no earlier than 2005-03-04 | T3 | 3128h | 3128h |  | Rel-6 | Xavier |  | Axalto | Jabellan@axalto.com |  |  | WLAN |
| 3779 | 33 | **Priority Service** |  | 347d? | 2002-05-30 A | 2003-09-26 A | 100% | 2002-05-30 | 2003-09-26 | 347d? |  | S1 | 6464h | 6464h | PRIOR1 | Rel-6 | Alain | PRIOR1 | Telcordia | James Garrahan (jgarraha@telcordia.com) |  |  | Public Safety (I-A) |
| 3780 | 33.1 | Feasibility Study on Priority Service |  | 1d | 2002-06-14 A | 2002-06-14 A | 100% | 2002-06-14 | 2002-06-14 | 1d | finish no earlier than 2002-06-14 | S1 | 8h | 8h | PRIOR-FS | Rel-6 | Alain | PRIOR-FS | Telcordia | James Garrahan (jgarraha@telcordia.com) |  |  | Public Safety (I-A) |
| 3781 | 33.2 | Stage 1 - Requirements for Priority Service |  | 340d | 2002-05-30 A | 2003-09-17 A | 100% | 2002-05-30 | 2003-09-17 | 340d | finish no earlier than 2003-09-17 | S1 | 2720h | 2720h | PRIOR-SR | Rel-6 | Alain | PRIOR-SR | Telcordia | James Garrahan (jgarraha@telcordia.com) |  |  | Public Safety (I-A) |
| 3782 | 976.3 | Priority service implementation guide |  | 131d? | 2003-03-28 A | 2003-09-26 A | 100% | 2003-03-28 | 2003-09-26 | 131d? | finish no earlier than 2003-09-26 | S1 | 1048h | 1048h |  | Rel-6 | Alain |  | Telcordia | James Garrahan (jgarraha@telcordia.com) |  |  | Public Safety (I-A) |

Notes:
- 3756: -
- 3757: - / Impacted TSs and TRs: 22.240, 22.228
- 3758: - / Impacted TSs and TRs: 23.240
- 3759: TR approved in CN#26 / Impacted TSs and TRs: 23.241
- 3760: - / Impacted TSs and TRs: 29.240
- 3761: SP#19 approved WID / Impacted TSs and TRs: 33.102, 33.203, 33.210
- 3762: Foreseen start and completion dates introduced by MCC (no indication at all on the WID)
- 3763: -
- 3764: -
- 3765: -
- 3766: SA3 acknowledge role in WI at SA3#20. Active contribution S3#24, S3#25. S3 WID approved SP#17
- 3767: Replaced by UID 60005 and 60006
- 3768: -
- 3769: - / Impacted TSs and TRs: 22.934
- 3770: - / Impacted TSs and TRs: 22.101, 22.105
- 3771: - / Impacted TSs and TRs: 23.234
- 3772: SP#17 approved WID S3-020451 / Impacted TSs and TRs: 21.133, 33.106, 33.107, 33.108, 33.200, 33.203, 33.210, New 33.234
- 3773: WID approved at CN#19 / Impacted TSs and TRs: 29.234, 29.061
- 3774: - / Impacted TSs and TRs: 29.161
- 3775: -
- 3776: -
- 3777: - / Impacted TSs and TRs: 32.252
- 3778: - / Impacted TSs and TRs: 31.102
- 3779: -
- 3780: - / Impacted TSs and TRs: 22.950
- 3781: -
- 3782: - / Impacted TSs and TRs: 22.952

| ID | WBS | Task | Type | Duration | Start | Finish | Complete | Baseline start | Baseline finish | Baseline duration | Constraint | Deadline | Resources | Work | Actual work | Acronym | WI rapporteur name | WI rapporteur e-mail | Release | MCC resp | Acronym_3GU_Export | Created at | TSG stopped |
| --- | --- | --- | --- | --- | --- | --- | --- | --- | --- | --- | --- | --- | --- | --- | --- | --- | --- | --- | --- | --- | --- | --- | --- |
| 3783 | 34 | **Network Sharing** |  | 820d? | 2003-01-20 A | 2006-03-10 A | 100% | 2003-01-20 | 2006-03-10 | 820d? |  |  | S1; S2; N1; R2; R5 | 44936h | 44936h | NTShar | T-Mobile | michele.zarri@t-mobile.co.uk | Rel-6 | Alain | NTShar |  |  |
| 3784 | 34.1 | Technical Report on Network Sharing |  | 240d? | 2003-01-20 A | 2003-12-19 A | 100% | 2003-01-20 | 2003-12-19 | 240d? |  |  | S1 | 1920h | 1920h | NTShar-TR | T-Mobile | michele.zarri@t-mobile.co.uk | Rel-6 | Alain | NTShar-TR |  |  |
| 3785 | 977.2 | Stage 1 - CRs to implement Network Sharing |  | 240d? | 2003-01-20 A | 2003-12-19 A | 100% | 2003-01-20 | 2003-12-19 | 240d? | finish no earlier than 2003-12-19 |  | S1 | 1920h | 1920h | NTSharCR | T-Mobile | michele.zarri@t-mobile.co.uk | Rel-6 | Alain | NTSharCR |  |  |
| 3786 | 977.3 | Stage 2 for Network Sharing |  | 372d? | 2003-02-27 A | 2004-07-30 A | 100% | 2003-02-27 | 2004-07-30 | 372d? | finish no earlier than 2004-07-30 |  | S2 | 2976h | 2976h |  | T-Mobile | michele.zarri@t-mobile.co.uk | Rel-6 | Maurice |  |  |  |
| 3787 | 977.4 | Network sharing - stage 3 |  | 404d? | 2003-05-23 A | 2004-12-08 A | 100% | 2003-05-23 | 2004-12-08 | 404d? | finish no earlier than 2004-12-08 |  | N1 | 3232h | 3232h |  | T-Mobile | michele.zarri@t-mobile.co.uk | Rel-6 | Frederic |  |  |  |
| 3788 | 977.5 | Enhancement of the support of network sharing in the UTRAN | milestone | 0d | 2003-09-19 A | 2003-09-19 A | 100% | 2003-09-19 | 2003-09-19 | 0d |  |  | R2 |  |  | NTShar-UTRANEnh | TeliaSonera | Anders.Dahlen@TeliaSonera.com | Rel-6 | Yong-Jun | NTShar-UTRANEnh |  |  |
| 3789 | 16.5.1 | Conformance Test Aspects – Network Sharing |  | 261d | 2005-03-11 A | 2006-03-10 A | 100% | 2005-03-11 | 2006-03-10 | 261d | finish no earlier than 2006-03-10 | 2006-03-10 | R5 | 2088h | 2088h | NTShar-UTRANEnh_Test | TeliaSonera | Niklas.Wiren@TeliaSonera.com | Rel-6 | Ingbert | NTShar-UTRANEnh_Test | Fri 11/03/05 |  |
| 3790 | 35 | **QoS Improvements** |  | 628d? | 2002-07-15 A | 2004-12-08 A | 100% | 2002-07-15 | 2004-12-08 | 628d? |  |  | S2; N3 | 18152h | 18152h | QoS1 | Nokia |  | Rel-6 | Maurice | QoS1 |  |  |
| 3791 | 35.1 | FS on Dynamic Policy control enhancements for end-to-end QoS |  | 465d | 2002-07-15 A | 2004-04-23 A | 100% | 2002-07-15 | 2004-04-23 | 465d | finish no earlier than 2004-04-23 |  | S2 | 3720h | 3720h |  | Nortel | Claire Mousset | Rel-6 | Maurice |  |  |  |
| 3792 | 978.2 | Definition of the Gq interface |  | 214d? | 2003-07-01 A | 2004-04-23 A | 100% | 2003-07-01 | 2004-04-23 | 214d? | finish no earlier than 2004-04-23 |  | S2 | 1712h | 1712h |  |  | Janne Rinne | Rel-6 | Maurice |  |  |  |
| 3793 | 978.3 | Gq interface specification for Dynamic Policy control enhancements – Stage 3 |  | 334d | 2003-08-29 A | 2004-12-08 A | 100% | 2003-08-29 | 2004-12-08 | 334d | finish no earlier than 2004-12-08 |  | N3 | 2672h | 2672h |  | Nokia | Anna.Sillanpaai@nokia.com | Rel-6 | Gwiho |  |  |  |
| 3794 | 36 | **Subscriber certificates** |  | 728d? | 2002-02-25 A | 2004-12-08 A | 100% | 2002-02-25 | 2004-12-08 | 728d? |  |  | S3; S2; N1; N4; T3; OMA | 44512h | 44512h | SEC1-SC | Nokia | valtteri.niemi@nokia.com | Rel-6 | Mirko | SEC1-SC |  |  |
| 3795 | 36.1 | Stage 1 of Subscriber certificates |  | 144d | 2002-02-25 A | 2002-09-12 A | 100% | 2002-02-25 | 2002-09-12 | 144d | finish no earlier than 2002-09-12 |  | S3 | 1152h | 1152h |  | Nokia | valtteri.niemi@nokia.com | Rel-6 | Mirko |  |  |  |
| 3796 | 36.2 | Architecture review |  | 24d | 2002-10-14 A | 2002-11-14 A | 100% | 2002-10-14 | 2002-11-14 | 24d | finish no earlier than 2002-11-14 |  | S2 | 192h | 192h |  | Nokia |  | Rel-6 | Maurice |  |  |  |
| 3797 | 979.3 | Stage 3 for Subscriber certificates |  | 313d? | 2003-09-19 A | 2004-11-30 A | 100% | 2003-09-19 | 2004-11-30 | 313d? | finish no earlier than 2004-11-30 |  | N4; T3 | 5008h | 5008h |  | Nokia | Lauri Laitinen | Rel-6 | Kimmo |  |  |  |
| 3798 | 979.4 | Stage 3 Ua & Ub interfaces |  | 288d? | 2003-11-03 A | 2004-12-08 A | 100% | 2003-11-03 | 2004-12-08 | 288d? | finish no earlier than 2004-12-08 |  | N1 | 2304h | 2304h |  | Nokia |  | Rel-6 | Frederic |  |  |  |
| 3799 | 979.5 | OMA dependencies on Subscriber certificates |  | 114d? | 2004-01-01 A | 2004-06-08 A | 100% | 2004-01-01 | 2004-06-08 | 114d? | finish no earlier than 2004-06-08 |  | OMA | 912h | 912h |  | Nokia | OMA-LIAISON@mail.openmobilealliance.org | Rel-6 |  |  | SP-24 |  |
| 3800 | 980 | **Rel-6 Open Service Access (OSA) enhancements** |  | 616d? | 2002-10-31 A | 2005-03-10 A | 100% | 2002-10-31 | 2005-03-10 | 616d? |  |  | N5 | 22576h | 22576h | OSA3 | Alcatel | Chelo.Abarca@alcatel.fr | Rel-6 | Kimmo | OSA3 |  |  |
| 3801 | 980.1 | Scope of the Open Service Access Release 6 |  | 66d? | 2003-03-28 A | 2003-06-27 A | 100% | 2003-03-28 | 2003-06-27 | 66d? | finish no earlier than 2003-06-27 |  | S1 | 528h | 528h |  |  |  | Rel-6 | Alain |  |  |  |
| 3802 | 980.2 | OSA Stage 2 |  | 150d? | 2004-08-13 A | 2005-03-10 A | 100% | 2004-08-13 | 2005-03-10 | 150d? | finish no earlier than 2005-03-10 |  | N5 | 1200h | 1200h |  |  |  | Rel-6 | Kimmo |  |  |  |
| 3803 | 980.3 | Multi Media Messaging function |  | 487d? | 2002-10-31 A | 2004-09-10 A | 100% | 2002-10-31 | 2004-09-10 | 487d? | finish no earlier than 2004-09-10 |  | N5 | 3896h | 3896h |  |  |  | Rel-6 | Kimmo |  |  |  |
| 3804 | 980.4 | Policy management extensions |  | 292d? | 2002-10-31 A | 2003-12-12 A | 100% | 2002-10-31 | 2003-12-12 | 292d? | finish no earlier than 2003-12-12 |  | N5 | 2336h | 2336h |  |  |  | Rel-6 | Kimmo |  |  |  |
| 3805 | 980.5 | TS on Presence and Availability Management (from the PRESNC WI) |  | 367d? | 2002-10-31 A | 2004-03-26 A | 100% | 2002-10-31 | 2004-03-26 | 367d? | finish no earlier than 2004-03-26 |  | N5 | 2936h | 2936h |  |  |  | Rel-6 | Kimmo |  |  |  |
| 3806 | 980.6 | OSA interfaces at different levels of abstractions (Parlay X, Web services) |  | 305d? | 2003-07-14 A | 2004-09-10 A | 100% | 2003-07-14 | 2004-09-10 | 305d? | finish no earlier than 2004-09-10 |  | N5 | 2440h | 2440h |  |  |  | Rel-6 | Kimmo |  |  |  |
| 3807 | 980.7 | Introduction of migration support mechanism |  | 290d? | 2002-10-31 A | 2003-12-10 A | 100% | 2002-10-31 | 2003-12-10 | 290d? | finish no earlier than 2003-12-12 |  | N5 | 2320h | 2320h |  |  |  | Rel-6 | Kimmo |  |  |  |
| 3808 | 980.8 | Framework Function for Federation |  | 225d? | 2003-02-03 A | 2003-12-12 A | 100% | 2003-02-03 | 2003-12-12 | 225d? | finish no earlier than 2003-12-12 |  | N5 | 1800h | 1800h |  |  |  | Rel-6 | Kimmo |  |  |  |
| 3809 | 980.9 | OMA potential overlaps with 3GPP OSA Stage 3 (Web services) |  | 196d? | 2003-12-18 A | 2004-09-16 A | 100% | 2003-12-18 | 2004-09-16 | 196d? | start no earlier than 2003-12-18 |  | OMA | 1568h | 1568h |  |  |  | Rel-6 |  |  | SP-24 |  |
| 3810 | 980.10 | Deleted - TR on Presence and Availability Management (from the PRESNC WI) | milestone | 0d? | 2004-09-17 A | 2004-09-17 A | 100% | 2004-09-17 | 2004-09-17 | 0d? | start no earlier than 2004-09-17 |  | N5 |  |  |  |  |  | Rel-6 | Kimmo |  |  | NP-24 |

Notes:
- 3783: -
- 3784: - / Impacted TSs and TRs: 22.951
- 3785: - / Impacted TSs and TRs: 22.011, 22.101, 22.115, 22.129
- 3786: - / Impacted TSs and TRs: 23.002, 23.060, 23.221, 23.236, new TS 23.251, TR 23.851
- 3787: - / Impacted TSs and TRs: 23.008, 23.122, 24.007, 24.008, 29.018
- 3788: - / Impacted TSs and TRs: 25.401, 25.413, 25.331, 25.304
- 3789: - / Impacted TSs and TRs: 34.108, 34.123-1, 34.123-2, 34.123-3
- 3790: - / Impacted TSs and TRs: 23.107, 23.207, 23.221
- 3791: - / Impacted TSs and TRs: 23.917 withdrawn (Contents all in 23.207)
- 3792: - / Impacted TSs and TRs: 23.207
- 3793: [DAB - 25.05.04] - Delayed to Sept - possibly Dec 2004 / Impacted TSs and TRs: 29.207, 29.208, 29.209
- 3794: SP#14 approved WID
- 3795: - / Impacted TSs and TRs: New (33.220, 33.221, 33.222, 33.246, 33.919)
- 3796: -
- 3797: Finished in CN4#26 / Impacted TSs and TRs: 23.003, 23.008, 29.109, 29.230, T3 31.102, 31.103, 31.111
- 3798: - / Impacted TSs and TRs: 24.109
- 3799: Updated according to SP-040420
- 3800: CN#25: Updated WID NP-040351 replaces NP-040144. / Impacted TSs and TRs: 22.127, 23.198, 29.198, 29.199, 29.998
- 3801: -
- 3802: Inherited by CN5 from SA2 at TSG#25 Sep 2004. SA2's 23.127 (OSA/VHE Stage 2) replaced from Rel-6 onwards by a new CN5 TS 23.198 (Stage 2 OSA-only). / Impacted TSs and TRs: 23.198 OSA Stage 2-ONLY replaces 23.127 (OSA/VHE) from Rel-6 onwards
- 3803: - / Impacted TSs and TRs: 29.198-15
- 3804: - / Impacted TSs and TRs: 29.198, 29.998
- 3805: N5#26: Split WI into TS & TR. / Impacted TSs and TRs: 29.198-14
- 3806: - / Impacted TSs and TRs: 29.199
- 3807: - / Impacted TSs and TRs: 29.198, 29.998
- 3808: - / Impacted TSs and TRs: 29.198, 29.998
- 3809: TSG#25 Approved CN5 29.199 Parlay X Web services. Ongoing 3GPP/OMA co-ordination to avoid OMA producing conflicting/OVERLAPING specs (NP-040283/SP-040493).
- 3810: N5#26:TR Completion 09/04; consistent with CN1 delayed Rel-6 completion.

| ID | WBS | Task | Duration | Start | Finish | Complete | Baseline start | Baseline finish | Baseline duration | Constraint | Resources | Work | Actual work | Acronym | WI rapporteur name | WI rapporteur e-mail | Release | MCC resp | Acronym_3GU_Export | TSG stopped |
| --- | --- | --- | --- | --- | --- | --- | --- | --- | --- | --- | --- | --- | --- | --- | --- | --- | --- | --- | --- | --- |
| 3811 | 39 | **Addition of frequency bands to GSM (TAPS)** | 676d | 2002-06-28 A | 2005-01-28 A | 100% | 2002-06-28 | 2005-01-28 | 676d |  | GP | 16640h | 16640h | TAPS | Nokia | Torben Themsen | Rel-6 | Paolo | TAPS |  |
| 3812 | 39.1 | **Addition of frequency bands to GSM – Changes to core specs** | 26d | 2002-11-15 A | 2002-12-20 A | 100% | 2002-11-15 | 2002-12-20 | 26d |  | G1 | 416h | 416h | TAPS-Specs | Nokia | Torben Themsen | Rel-6 | Paolo | TAPS-Specs |  |
| 3813 | 39.1.1 | Changes to core specs | 26d | 2002-11-15 A | 2002-12-20 A | 100% | 2002-11-15 | 2002-12-20 | 26d | finish no earlier than 2002-12-20 | G1 | 208h | 208h |  | Nokia | Torben Themsen | Rel-6 | Paolo |  |  |
| 3814 | 39.2 | **Deleted - Addition of frequency bands to GSM – Changes for conformance tests** | 676d | 2002-06-28 A | 2005-01-28 A | 100% | 2002-06-28 | 2005-01-28 | 676d |  | G4 | 10816h | 10816h | TAPS-Conf | Nokia | Torben Themsen | Rel-6 | Paolo | TAPS-Conf | GP-23 |
| 3815 | 39.2.1 | Deleted - 51.010-1 Add testing | 676d | 2002-06-28 A | 2005-01-28 A | 100% | 2002-06-28 | 2005-01-28 | 676d | finish no earlier than 2005-01-28 | G4 | 5408h | 5408h |  | Nokia | Torben Themsen | Rel-6 | Paolo |  | GP-23 |
| 3816 | 40 | **Seamless support of streaming services in A/Gb mode** | 1426d? | 2000-01-03 A | 2005-06-17 A | 100% | 2000-01-03 | 2005-06-17 | 1426d? |  | GP; S3 | 70312h | 70312h | SSStrea | Vodafone | José Luis Carrizo Martínez | Rel-6 | Paolo | SSStrea |  |
| 3817 | 40.1 | **Identification of requirements for streaming** | 46d? | 2003-06-27 A | 2003-08-29 A | 100% | 2003-06-27 | 2003-08-29 | 46d? |  | G1 | 736h | 736h |  | Vodafone | José Luis Carrizo Martínez | Rel-6 | Paolo |  |  |
| 3818 | 982.1.1 | Requirements for streaming | 46d? | 2003-06-27 A | 2003-08-29 A | 100% | 2003-06-27 | 2003-08-29 | 46d? | finish no earlier than 2003-08-29 | G1 | 368h | 368h |  | Vodafone | José Luis Carrizo Martínez | Rel-6 | Paolo |  |  |
| 3819 | 40.2 | **Performance study of cell change mechanisms** | 956d? | 2000-01-03 A | 2003-08-29 A | 100% | 2000-01-03 | 2003-08-29 | 956d? |  | G1 | 30568h | 30568h |  | Vodafone | José Luis Carrizo Martínez | Rel-6 | Paolo |  |  |
| 3820 | 982.2.1 | Performance of NACC | 956d? | 2000-01-03 A | 2003-08-29 A | 100% | 2000-01-03 | 2003-08-29 | 956d? | finish no earlier than 2003-08-29 | G1 | 7640h | 7640h |  | Vodafone | José Luis Carrizo Martínez | Rel-6 | Paolo |  |  |
| 3821 | 982.2.2 | Performance of cell change in DTM for the PS domain | 956d? | 2000-01-03 A | 2003-08-29 A | 100% | 2000-01-03 | 2003-08-29 | 956d? | finish no earlier than 2003-08-29 | G1 | 7640h | 7640h |  | Vodafone | José Luis Carrizo Martínez | Rel-6 | Paolo |  |  |
| 3822 | 982.2.3 | Handover for Seamless support of streaming services in A/Gb mode | 956d? | 2000-01-03 A | 2003-08-29 A | 100% | 2000-01-03 | 2003-08-29 | 956d? | finish no earlier than 2003-08-29 | G1 | 7640h | 7640h |  | Vodafone | José Luis Carrizo Martínez | Rel-6 | Paolo |  |  |
| 3823 | 40.3 | **Reduction of service interruption times and packet loss during mobility procedures** | 516d? | 2003-06-27 A | 2005-06-17 A | 100% | 2003-06-27 | 2005-06-17 | 516d? |  | G2 | 10800h | 10800h |  | Vodafone | José Luis Carrizo Martínez | Rel-6 | Gert |  |  |
| 3824 | 982.3.1 | optimizations of existing mechanisms/procedures | 106d? | 2003-06-27 A | 2003-11-21 A | 100% | 2003-06-27 | 2003-11-21 | 106d? | finish no earlier than 2003-11-21 | G2 | 848h | 848h |  | Vodafone | José Luis Carrizo Martínez | Rel-6 | Gert |  |  |
| 3825 | 982.3.2 | Inter-system NACC | 106d? | 2003-06-27 A | 2003-11-21 A | 100% | 2003-06-27 | 2003-11-21 | 106d? | finish no earlier than 2003-11-21 | G2 | 848h | 848h |  | Vodafone | José Luis Carrizo Martínez | Rel-6 | Gert |  |  |
| 3826 | 982.3.3 | PS Handover (within GERAN and between GERAN and UTRAN) | 516d? | 2003-06-27 A | 2005-06-17 A | 100% | 2003-06-27 | 2005-06-17 | 516d? | finish no earlier than 2003-11-21 | G2 | 4128h | 4128h |  | Vodafone | José Luis Carrizo Martínez | Rel-6 | Gert |  |  |
| 3827 | 982.3.4 | Dependency to other features of Reduction of service interruption times and packet loss during mobility procedures | 106d? | 2003-06-27 A | 2003-11-21 A | 100% | 2003-06-27 | 2003-11-21 | 106d? | finish no earlier than 2003-11-21 | G2 | 848h | 848h |  | Vodafone | José Luis Carrizo Martínez | Rel-6 | Gert |  |  |
| 3828 | 40.5 | **Deleted - MS conformance testing for Seamless support of streaming services in A/Gb mode** | 31d? | 2003-12-19 A | 2004-01-30 A | 100% | 2003-12-19 | 2004-01-30 | 31d? |  | G3new | 496h | 496h |  | Vodafone | José Luis Carrizo Martínez | Rel-6 | Ingbert |  | GP-27 |
| 3829 | 982.4.1 | Deleted - MS conformance tests for Seamless support of streaming services in A/Gb mode | 31d? | 2003-12-19 A | 2004-01-30 A | 100% | 2003-12-19 | 2004-01-30 | 31d? | finish no earlier than 2004-01-30 | G4; G5 | 496h | 496h |  | Vodafone | José Luis Carrizo Martínez | Rel-6 | Ingbert |  | GP-27 |
| 3830 | 982.5 | GERAN A/Gb mode security enhancements | 612d? | 2002-09-26 A | 2005-01-28 A | 100% | 2002-09-26 | 2005-01-28 | 612d? | finish no earlier than 2005-01-28 | S3 | 4896h | 4896h |  | Vodafone | peter.howard@vodafone.com | Rel-6 | Mirko |  |  |
| 3831 | 41 | Performance characterisation of default codecs for PS conversational multimedia application | 455d | 2002-09-13 A | 2004-06-10 A | 100% | 2002-09-13 | 2004-06-10 | 455d | finish no earlier than 2004-06-10 | S4 | 3640h | 3640h | CODCAR | Nokia | pasi.s.ojala@nokia.com | Rel-6 | Paolo | CODCAR |  |
| 3832 | 43 | Study on Privacy Capability | 83d | 2003-11-10 A | 2004-03-03 A | 100% | 2003-11-10 | 2004-03-03 | 83d | start no earlier than 2003-11-10 | S1 | 664h | 664h | PrivCap | Lucent | Michael Boote (mboote@alcatel-lucent.com) | Rel-6 | Alain | PrivCap |  |
| 3833 | 44 | **Rel-6 Operations, Administration, Maintenance and Provisioning (OAM&P)** | 652d? | 2002-09-12 A | 2005-03-11 A | 100% | 2002-09-12 | 2005-03-11 | 652d? |  | S5 | 42635.5h | 42635.5h | OAM6 |  |  | Rel-6 | Mirko | OAM6 |  |
| 3834 | 44.1 | Principles, high level Requirements and Architecture | 526d | 2002-09-12 A | 2004-09-16 A | 100% | 2002-09-12 | 2004-09-16 | 526d | finish no earlier than 2004-09-16 | S5 | 4208h | 4208h |  | Motorola |  | Rel-6 | Mirko |  |  |
| 3835 | 44.2 | Performance Management | 591d | 2002-09-12 A | 2004-12-16 A | 100% | 2002-09-12 | 2004-12-16 | 591d | finish no earlier than 2004-12-16 | S5 | 4728h | 4728h |  | Nortel |  | Rel-6 | Mirko |  |  |
| 3836 | 44.4 | Network Infrastructure Management | 591d | 2002-09-12 A | 2004-12-16 A | 100% | 2002-09-12 | 2004-12-16 | 591d | finish no earlier than 2004-12-16 | S5 | 4728h | 4728h |  | Ericsson | thomas.tovinger@ericsson.com | Rel-6 | Mirko |  |  |

Notes:
- 3811: -
- 3812: -
- 3813: -
- 3814: -
- 3815: -
- 3816: -
- 3817: -
- 3818: -
- 3819: -
- 3820: -
- 3821: -
- 3822: -
- 3823: Completed at GERP#17
- 3824: -
- 3825: -
- 3826: -
- 3827: -
- 3828: Marked as stopped 10/2009
- 3829: Marked as stopped 10/2009
- 3830: SP#19 approved WID / Impacted TSs and TRs: 33.102
- 3831: - / Impacted TSs and TRs: 26.935
- 3832: - / Impacted TSs and TRs: 22.949
- 3833: SP#26: Updated WID SP-040766 was SP-020445. Completion delayed 12/04->03/05 due to OAM-Trace in CN1/4.
- 3834: SP#25 09/2004 completed / Impacted TSs and TRs: 32.101, 32.102
- 3835: SP#26 12/2004 completed / Impacted TSs and TRs: 32.401, 32.403, 52.402, 32.411, 32.412, 32.413, 32.432, 32.435, 32.436
- 3836: SP#26 12/2004 completed / Impacted TSs and TRs: 32.150/1/2, 32.805, 32.111-5, 32.313/4, 32.331/2/3/4/5, 32.341/2/3/4, 32.351/2/3/4, 32.361/2/3/4, 32.371/2/3/4, 32.804, 32.675, 32.690, 32.695, 32.71/2/3/4/5, 32.741/2/3/4/5

| ID | WBS | Task | Duration | Start | Finish | Complete | Baseline start | Baseline finish | Baseline duration | Constraint | Resources | Work | Actual work | Acronym | WI rapporteur name | WI rapporteur e-mail | Release | MCC resp | Acronym_3GU_Export | Impacted TSs and TRs | Created at | TSG stopped |
| --- | --- | --- | --- | --- | --- | --- | --- | --- | --- | --- | --- | --- | --- | --- | --- | --- | --- | --- | --- | --- | --- | --- |
| 3837 | 44.5 | **Rel-6 Trace Management** | 646d? | 2002-09-20 A | 2005-03-11 A | 100% | 2002-09-20 | 2005-03-11 | 646d? |  | S5; N4; R3 | 23877.9h | 23877.9h | OAM-Trace | Nokia | kari.t.ronka@nokia.com | Rel-6 | Mirko | OAM-Trace |  |  |  |
| 3838 | 985.4.1 | Subscriber and UE trace management | 585d | 2002-09-20 A | 2004-12-16 A | 100% | 2002-09-20 | 2004-12-16 | 585d | finish no earlier than 2004-12-16 | S5 | 4680h | 4680h |  | Nokia | kari.t.ronka@nokia.com | Rel-6 | Mirko |  | 32.421, 32.422, 32.423, 52.008 |  |  |
| 3839 | 985.4.2 | Subscriber and equipment trace in UTRAN | 268d? | 2003-06-06 A | 2004-06-15 A | 100% | 2003-06-06 | 2004-06-15 | 268d? | finish no earlier than 2004-06-15 | R3 | 2144h | 2144h | OAM-Trace-RAN | Nortel | Yann Sehedi (sehedic@nortelnetworks.com) | Rel-6 | Juha | OAM-Trace-RAN | 25.413, 25.420, 25.423 |  |  |
| 3840 | 985.4.3 | Trace Management, Stage3 | 193.74d? | 2004-06-09 A | 2005-03-11 A | 100% | 2004-06-09 | 2005-03-11 | 193.74d? | finish no earlier than 2005-03-11 | N4 | 1549.92h | 1549.92h |  | Nokia | seppo.kauntola@nokia.com | Rel-6 | Kimmo |  | 23.205, 29.232, 29.060, 29.002, 29.228 |  |  |
| 3841 | 986 | **Rel-6 Charging Management** | 666d? | 2002-11-21 A | 2005-06-09 A | 100% | 2002-11-21 | 2005-06-09 | 666d? |  | S5; S2; N3 | 67152h | 67152h | CH | T-Mobile | karl-heinz.nenner@t-mobile.de | Rel-6 | Mirko | CH |  |  |  |
| 3842 | 986.1 | Charging architecture and principles | 390d? | 2003-03-21 A | 2004-09-16 A | 100% | 2003-03-21 | 2004-09-16 | 390d? | start no earlier than 2003-03-21 | S5 | 3120h | 3120h |  |  |  | Rel-6 | Mirko |  | 32.240 |  |  |
| 3843 | 986.2 | Charging Data Record (CDR) file format and transfer | 260d? | 2003-03-21 A | 2004-03-18 A | 100% | 2003-03-21 | 2004-03-18 | 260d? | start no earlier than 2003-03-21 | S5 | 2080h | 2080h |  |  |  | Rel-6 | Mirko |  | 32.297 |  |  |
| 3844 | 986.3 | CDR parameter description | 580d? | 2003-03-21 A | 2005-06-09 A | 100% | 2003-03-21 | 2005-06-09 | 580d? | finish no earlier than 2005-06-09 | S5 | 4640h | 4640h |  |  |  | Rel-6 | Mirko |  | 32.298 |  |  |
| 3845 | 986.4 | Diameter charging applications | 390d? | 2003-03-21 A | 2004-09-16 A | 100% | 2003-03-21 | 2004-09-16 | 390d? | start no earlier than 2003-03-21 | S5 | 3120h | 3120h |  |  |  | Rel-6 | Mirko |  | 32.299 |  |  |
| 3846 | 986.5 | Online Charging System (OCS) architecture study | 130d? | 2003-03-21 A | 2003-09-18 A | 100% | 2003-03-21 | 2003-09-18 | 130d? | start no earlier than 2003-03-21 | S5 | 1040h | 1040h |  |  |  | Rel-6 | Mirko |  | 32.815 |  |  |
| 3847 | 986.6 | OCS: Applications and interfaces | 455d? | 2003-03-21 A | 2004-12-16 A | 100% | 2003-03-21 | 2004-12-16 | 455d? | start no earlier than 2003-03-21 | S5 | 3640h | 3640h |  |  |  | Rel-6 | Mirko |  | 32.296 |  |  |
| 3848 | 986.7 | **Charging Management for Bearer level** | 390d? | 2003-03-21 A | 2004-09-16 A | 100% | 2003-03-21 | 2004-09-16 | 390d? |  | S5 | 11440h | 11440h | CH-BC | Nokia | Benni ALEXANDER | Rel-6 | Mirko | CH-BC |  |  |  |
| 3849 | 986.7.1 | CS domain charging | 260d? | 2003-03-21 A | 2004-03-18 A | 100% | 2003-03-21 | 2004-03-18 | 260d? | start no earlier than 2003-03-21 | S5 | 2080h | 2080h |  |  |  | Rel-6 | Mirko |  | 32.250 |  |  |
| 3850 | 986.7.2 | PS domain charging | 390d? | 2003-03-21 A | 2004-09-16 A | 100% | 2003-03-21 | 2004-09-16 | 390d? | start no earlier than 2003-03-21 | S5 | 3120h | 3120h |  |  |  | Rel-6 | Mirko |  | 32.251 |  |  |
| 3851 | 986.7.3 | CDR transfer | 390d? | 2003-03-21 A | 2004-09-16 A | 100% | 2003-03-21 | 2004-09-16 | 390d? | start no earlier than 2003-03-21 | S5 | 3120h | 3120h |  |  |  | Rel-6 | Mirko |  | 32.295 |  |  |
| 3852 | 986.8 | Charging Management for the Service domain | 580d? | 2003-03-21 A | 2005-06-09 A | 100% | 2003-03-21 | 2005-06-09 | 580d? | finish no earlier than 2005-06-09 | S5 | 4640h | 4640h |  | Siemens | Gerald.Goermer@nsn.com | Rel-6 | Mirko |  | 32.252, 32.270, 32.271, 32.272 |  |  |
| 3853 | 986.9 | **Overall architectural aspects of IP flow based bearer level charging** | 602d? | 2002-11-21 A | 2005-03-11 A | 100% | 2002-11-21 | 2005-03-11 | 602d? |  | S2; N3 | 17448h | 17448h | CH-FBC |  |  | Rel-6 | Maurice | CH-FBC | 23.125 |  |  |
| 3854 | 986.9.1 | Overall definition of FBC architecture | 334d? | 2002-11-21 A | 2004-03-02 A | 100% | 2002-11-21 | 2004-03-02 | 334d? | start no earlier than 2002-11-21 | S2 | 2672h | 2672h |  |  |  | Rel-6 | Maurice |  |  | SP-24 |  |
| 3855 | 986.9.2 | Study on providing policy control with FBC | 130d? | 2004-02-02 A | 2004-07-30 A | 100% | 2004-02-02 | 2004-07-30 | 130d? | start no earlier than 2004-02-01 | S2 | 1040h | 1040h |  |  |  | Rel-6 | Maurice |  |  | SP-24 |  |
| 3856 | 986.9.3 | Gx interface for flow based charging | 223d? | 2004-02-02 A | 2004-12-08 A | 100% | 2004-02-02 | 2004-12-08 | 223d? | start no earlier than 2004-02-01 | N3 | 1784h | 1784h |  | Nokia | juha.a.rasanen@nokia.com | Rel-6 | Gwiho |  | 29.210 | SP-25 |  |
| 3857 | 986.9.4 | Rx interface for flow based charging | 290d? | 2004-02-02 A | 2005-03-11 A | 100% | 2004-02-02 | 2005-03-11 | 290d? | finish no earlier than 2005-03-11 | N3 | 2320h | 2320h |  | Nortel | Javier Gonzalez Gallego | Rel-6 | Gwiho |  | 29.209 | SP-25 |  |
| 3858 | 13 | **Rel-6 UICC/USIM enhancements and interworking** | 1164d? | 2000-09-25 A | 2005-03-10 A | 100% | 2000-09-25 | 2005-03-10 | 1164d? |  | T3 | 43088h | 43088h | USAT1 |  |  | Rel-6 | Xavier | USAT1 |  |  |  |
| 3859 | 13.1 | **UICC API** | 777d | 2002-03-20 A | 2005-03-10 A | 100% | 2002-03-20 | 2005-03-10 | 777d |  | T3 | 15024h | 15024h | USAT1-API |  |  | Rel-6 | Xavier | USAT1-API |  |  |  |
| 3860 | 13.1.1 | Rel-6 Java API Test specification | 59d | 2002-03-20 A | 2002-06-10 A | 100% | 2002-03-20 | 2002-06-10 | 59d | finish no earlier than 2002-09-20 | T3 | 472h | 472h |  | Microelectrónica Española | Mario Pérez | Rel-6 | Xavier |  |  |  |  |
| 3861 | 987.1.2 | 2G/3G Java Card™ API based applet interworking | 255d | 2003-03-17 A | 2004-03-05 A | 100% | 2003-03-17 | 2004-03-05 | 255d | finish no earlier than 2004-02-19 | T3 | 2040h | 2040h |  | Oberthur Card Systems | Stéphane Andrau | Rel-6 | Xavier |  |  |  |  |
| 3862 | 987.1.3 | (U)SIM API for Java Card Testing | 519d | 2003-03-17 A | 2005-03-10 A | 100% | 2003-03-17 | 2005-03-10 | 519d | finish no earlier than 2005-03-10 | T3 | 4152h | 4152h |  | Axalto | Christophe Begassat (cbegassat@axalto.com) | Rel-6 | Xavier |  | 31.213 |  |  |
| 3863 | 13.1.2 | Deleted - Java API Test specification (TS 43.019 Rel-5) | 268d | 2002-05-30 A | 2003-06-09 A | 100% | 2002-05-30 | 2003-06-09 | 268d | finish no earlier than 2003-09-17 | T3 | 2144h | 2144h |  | Microelectrónica Española | Mario Pérez | Rel-6 | Xavier |  |  |  | TP-20 |

Notes:
- 3837: SP#26 12/2004 SA5 completed 12/04. Signalling Based Trace Activation for IMS (SIP) moved to Rel-7. Reason: CN1 cannot complete 24.229 trace without IETF dependency => estimate 05/2005.
- 3838: SP#26 12/2004 completed
- 3839: -
- 3840: -
- 3841: SP#28 Target 09/2005 for WLAN Charging 32.252
- 3842: SP#25 09/2004 completed
- 3843: SP#23 03/2004 completed
- 3844: SP#28 06/2005 completed
- 3845: SP#25 09/2004 completed
- 3846: SP#21 09/2003 completed
- 3847: SP#26 12/2004 completed
- 3848: SP#28 Target 09/2005 for WLAN Charging 32.252
- 3849: SP#23 03/2004 completed
- 3850: SP#25 09/2004 completed
- 3851: SP#25 09/2004 completed
- 3852: SP#26: Updated WID SP-040778 was SP-030050. Target completion 06/2005. Consisting of MMS-CH, LCS-CH, WLAN-CH, POC-CH, MBMS-CH
- 3853: -
- 3854: -
- 3855: -
- 3856: -
- 3857: -
- 3858: -
- 3859: 8/3/2001: test spec is based on R99 core spec, so deleted from Workplan
- 3860: -
- 3861: -
- 3862: -
- 3863: MOVED to Rel-5 WP

| ID | WBS | Task | Type | Duration | Start | Finish | Complete | Remaining | Baseline start | Baseline finish | Baseline duration | Total slack | Constraint | Resources | Work | Actual work | Acronym | WI rapporteur name | WI rapporteur e-mail | Release | MCC resp | Acronym_3GU_Export | TSG stopped |
| --- | --- | --- | --- | --- | --- | --- | --- | --- | --- | --- | --- | --- | --- | --- | --- | --- | --- | --- | --- | --- | --- | --- | --- |
| 3864 | 987.2 | **Rel-6 USIM toolkit enhancements** |  | 1160d? | 2000-09-25 A | 2005-03-04 A | 100% |  | 2000-09-25 | 2005-03-04 | 1160d? |  |  | T3 | 21848h | 21848h | USAT1-API-MULTOS | Aspects Software | Neil Livingston | Rel-6 | Xavier | USAT1-API-MULTOS |  |
| 3865 | 987.2.1 | **C SIM API** |  | 525d | 2000-09-25 A | 2002-09-27 A | 100% |  | 2000-09-25 | 2002-09-27 | 525d |  |  | T3 | 9960h | 9960h |  | Aspects Software | Neil Livingston | Rel-6 | Xavier |  |  |
| 3866 | 987.2.1.1 | Specification of C SIM API |  | 525d | 2000-09-25 A | 2002-09-27 A | 100% |  | 2000-09-25 | 2002-09-27 | 525d |  | finish no earlier than 2002-09-27 | T3 | 4200h | 4200h |  | Aspects Software | Neil Livingston | Rel-6 | Xavier |  |  |
| 3867 | 987.2.1.2 | Test specification for C SIM API |  | 195d | 2001-01-01 A | 2001-09-28 A | 100% |  | 2001-01-01 | 2001-09-28 | 195d |  | finish no earlier than 2001-09-28 | T3 | 1560h | 1560h |  | Aspects Software | Neil Livingston | Rel-6 | Xavier |  |  |
| 3868 | 987.2.2 | USIM application toolkit Conformance Test Specification for Mobile Equipments |  | 326d? | 2003-12-05 A | 2005-03-04 A | 100% |  | 2003-12-05 | 2005-03-04 | 326d? |  | start no earlier than 2003-12-05 | T3 | 2608h | 2608h |  | Gemplus | Eric.laffont@gemplus.com | Rel-6 | Xavier |  |  |
| 3869 | 988 | **Packet Switched Streaming Services Rel-6** |  | 798d? | 2002-11-18 A | 2005-12-07 A | 100% |  | 2002-11-18 | 2005-12-07 | 798d? |  |  | S4; S1 | 19688h | 19688h | PSSrel6 | Ericsson | olle.franceschi@ericsson.com | Rel-6 | Paolo | PSSrel6 |  |
| 3870 | 988.1 | Stage 1 for Packet Switched Streaming Services Rel-6 |  | 86d? | 2002-11-18 A | 2003-03-17 A | 100% |  | 2002-11-18 | 2003-03-17 | 86d? |  | finish no earlier than 2003-03-17 | S1 | 688h | 688h |  | Ericsson |  | Rel-6 | Alain |  |  |
| 3871 | 988.2 | Stage 3 for Packet Switched Streaming Services Rel-6 |  | 779d? | 2002-12-13 A | 2005-12-07 A | 100% |  | 2002-12-13 | 2005-12-07 | 779d? |  | finish no earlier than 2005-12-07 | S4 | 6232h | 6232h | PSSrel6-Stage3 | Ericsson | olle.franceschi@ericsson.com | Rel-6 | Paolo | PSSrel6-Stage3 |  |
| 3872 | 989 | AMR-WB extension for high audio quality |  | 779d | 2002-12-13 A | 2005-12-07 A | 100% |  | 2002-12-13 | 2005-12-07 | 779d |  | finish no earlier than 2005-12-07 | S4 | 6232h | 6232h | AMRWB+ | Nokia | janne.m.vainio@nokia.com | Rel-6 | Paolo | AMRWB+ |  |
| 3873 | 990 | Codec Enhancements for Packet Switched Conversational Multimedia Applications |  | 198d? | 2004-03-16 A | 2004-12-16 A | 100% |  | 2004-03-16 | 2004-12-16 | 198d? |  | finish no earlier than 2004-12-16 | S4 | 1584h | 1584h | CEPSCM | Nokia | miska.hannuksela@nokia.com | Rel-6 | Paolo | CEPSCM |  |
| 3874 | 991 | 3G-324M Improvements |  | 198d? | 2004-03-16 A | 2004-12-16 A | 100% |  | 2004-03-16 | 2004-12-16 | 198d? |  | finish no earlier than 2004-12-16 | S4 | 1584h | 1584h | 3G-324MI | Ericsson | bo.burman@ericsson.com | Rel-6 | Paolo | 3G-324MI |  |
| 3875 | 992 | Single Antenna Receiver Interference Cancellation (SAIC) |  | 420.92d? | 2002-11-15 A | 2004-06-25 A | 100% |  | 2002-11-15 | 2004-06-25 | 420.92d? |  | finish no earlier than 2004-08-27 | GP; G1 | 6734.72h | 6734.72h | SAIC | Cingular | Marc Grant | Rel-6 | Paolo | SAIC |  |
| 3876 | 993 | **Enhancement of dialled service for CAMEL** |  | 199d | 2003-03-28 A | 2003-12-31 A | 100% |  | 2003-03-28 | 2003-12-31 | 199d |  |  | S1; N2; N4 | 7960h | 7960h | EDCAMEL | Samsung | craig.bishop@samsung.com | Rel-6 | Alain | EDCAMEL |  |
| 3877 | 993.1 | Stages 2 and 3 for Enhancement of dialled service for CAMEL |  | 199d | 2003-03-28 A | 2003-12-31 A | 100% |  | 2003-03-28 | 2003-12-31 | 199d |  | finish no earlier than 2003-09-19 | N2; N4 | 3184h | 3184h |  | Samsung | Richard Brook | Rel-6 | Kimmo |  |  |
| 3878 | 994 | Study on Bandwidth and resource savings in CS networks |  | 273d? | 2003-06-01 A | 2004-06-16 A | 100% |  | 2003-06-01 | 2004-06-16 | 273d? |  | finish no earlier than 2004-06-16 | S2 | 2184h | 2184h | BARS |  |  | Rel-6 | Maurice | BARS |  |
| 3879 | 995 | **Multiple TBF in A/Gb mode** |  | 736d? | 2002-04-05 A | 2005-01-28 A | 100% |  | 2002-04-05 | 2005-01-28 | 736d? |  |  | GP; G2 | 35200h | 35200h | MULTBF | Ericsson | gunnar.mildh@era.ericsson.se | Rel-6 | Paolo | MULTBF |  |
| 3880 | 995.1 | **Multiple TBF in A/Gb mode - Core** |  | 366d? | 2002-04-05 A | 2003-08-29 A | 100% |  | 2002-04-05 | 2003-08-29 | 366d? |  |  | GP; G2 | 23424h | 23424h | MULTBF-Agbmode | Ericsson | gunnar.mildh@era.ericsson.se | Rel-6 | Paolo | MULTBF-Agbmode |  |
| 3881 | 995.1.1 | Multiple TBF Concept paper |  | 366d? | 2002-04-05 A | 2003-08-29 A | 100% |  | 2002-04-05 | 2003-08-29 | 366d? |  | finish no earlier than 2003-08-29 | GP; G2 | 5856h | 5856h |  |  |  | Rel-6 | Paolo |  |  |
| 3882 | 995.1.2 | Multiple TBF Stage 2 (43.064) CRs |  | 366d? | 2002-04-05 A | 2003-08-29 A | 100% |  | 2002-04-05 | 2003-08-29 | 366d? |  | finish no earlier than 2003-08-29 | GP; G2 | 5856h | 5856h |  |  |  | Rel-6 | Paolo |  |  |
| 3883 | 995.1.3 | Multiple TBF Stage 3 (44.060) CRs |  | 366d? | 2002-04-05 A | 2003-08-29 A | 100% |  | 2002-04-05 | 2003-08-29 | 366d? |  | finish no earlier than 2003-08-29 | GP; G2 | 5856h | 5856h |  |  |  | Rel-6 | Paolo |  |  |
| 3884 | 995.2 | Deleted - Multiple TBF in A/Gb mode – MS testing | milestone | 0d? | 2005-01-28 A | 2005-01-28 A | 100% |  | 2005-01-28 | 2005-01-28 | 0d? |  | start no earlier than 2005-01-28 | G3new |  |  | MULTBF-Testing | Ericsson | gunnar.mildh@era.ericsson.se | Rel-6 | Paolo | MULTBF-Testing | GP-27 |
| 3885 | 996 | **Alignment between the test-regimes for GERAN capable MS** |  | 526d? | 2003-08-29 A | 2005-09-02 | 99% | 0d? | 2003-08-29 | 2005-09-02 | 526d? | 0d |  | G3new | 4208h | 4208h | ALTERE | Ericsson | anthony.toubassi@sonyericsson.com | Rel-6 | Ingbert | ALTERE |  |
| 3886 | 996.1 | Determine the controversial test cases in the different test regimes and align them with 3GPP GERAN test specifications. Such test cases to be added to TS 51.010. |  | 526d? | 2003-08-29 A | 2005-09-02 A | 100% |  | 2003-08-29 | 2005-09-02 | 526d? |  | finish no earlier than 2005-09-02 | G3new | 4208h | 4208h | ALTERE-TC |  |  | Rel-6 | Ingbert | ALTERE-TC |  |
| 3887 | 997 | Addition of U-TDOA in the CS domain |  | 111d? | 2003-11-21 A | 2004-04-23 A | 100% |  | 2003-11-21 | 2004-04-23 | 111d? |  | finish no earlier than 2004-04-23 | GP | 888h | 888h | UTDOACS | TruePosition | Bob Gross, Rhys Robinson (rlgross@trueposition.com) | Rel-6 | Paolo | UTDOACS |  |
| 3888 | 998 | Addition of U-TDOA in the PS domain |  | 361d? | 2003-06-27 A | 2004-11-12 A | 100% |  | 2003-06-27 | 2004-11-12 | 361d? |  | finish no earlier than 2004-11-12 | GP | 2888h | 2888h | UTDOAPS | TruePosition | Bob Gross, Rhys Robinson (rlgross@trueposition.com) | Rel-6 | Paolo | UTDOAPS |  |

Notes:
- 3864: -
- 3865: - / Impacted TSs and TRs: 31.101, 31.102, 31.103, 31.111, 31.113, new 31.115, 31.116
- 3866: -
- 3867: -
- 3868: - / Impacted TSs and TRs: 31.124
- 3869: -
- 3870: 2nd resp SA4 / Impacted TSs and TRs: 22.233
- 3871: TR tbc by Sept. 05 / Impacted TSs and TRs: 26.233, 26.234, 26.244, 26.245, 26.246, 26.401, 26.402, 26.403, 26.404, 26.405, 26.406, 26.410, 26.411, 26.412, 26.273, 26.290, 26.304, 26.412, 26.274, 26.936
- 3872: TR tbc by Sept. 05 / Impacted TSs and TRs: 26.290, 26.304, 26.273, 26.274, 26.412, 26.936
- 3873: - / Impacted TSs and TRs: 26.235, 26.236
- 3874: - / Impacted TSs and TRs: 26.111, 26.911
- 3875: - / Impacted TSs and TRs: 45.903
- 3876: - / Impacted TSs and TRs: 22.078
- 3877: - / Impacted TSs and TRs: 23.008, 23.016, 23.018, 23.078, 29.002, 29.078
- 3878: - / Impacted TSs and TRs: 23.977
- 3879: GP#17 Nov 2003 Moved from Rel-5 UID_50058 MULTBF (Only Multiple TBF Concept paper produced in Rel-5)
- 3880: -
- 3881: -
- 3882: -
- 3883: -
- 3884: -
- 3885: -
- 3886: -
- 3887: Completed, except for potential LMU performance specs
- 3888: -

| ID | WBS | Task | Type | Duration | Start | Finish | Complete | Baseline start | Baseline finish | Baseline duration | Constraint | Resources | Work | Actual work | Acronym | WI rapporteur name | WI rapporteur e-mail | Release | MCC resp | Acronym_3GU_Export | TSG stopped | Impacted TSs and TRs | Created at |
| --- | --- | --- | --- | --- | --- | --- | --- | --- | --- | --- | --- | --- | --- | --- | --- | --- | --- | --- | --- | --- | --- | --- | --- |
| 3889 | 999 | **Downlink Advanced Receiver Performance** |  | 466d? | 2003-11-21 A | 2005-09-02 A | 100% | 2003-11-21 | 2005-09-02 | 466d? |  | GP | 19160h | 19160h | DARP | Nokia | tommy.bysted@nokia.com | Rel-6 | Paolo | DARP |  |  |  |
| 3890 | 999.1 | DARP test scenarios |  | 201d? | 2003-11-21 A | 2004-08-27 A | 100% | 2003-11-21 | 2004-08-27 | 201d? | finish no earlier than 2004-08-27 | GP | 1608h | 1608h | DARP-TS | Nokia | tommy.bysted@nokia.com | Rel-6 | Paolo | DARP-TS |  |  |  |
| 3891 | 999.2 | **DARP for GMSK modulated voice services** |  | 201d? | 2004-02-06 A | 2004-11-12 A | 100% | 2004-02-06 | 2004-11-12 | 201d? |  | GP | 4824h | 4824h | DARP-GMSK | Nokia | tommy.bysted@nokia.com | Rel-6 | Paolo | DARP-GMSK |  |  |  |
| 3892 | 999.2.1 | Performance requirements in 45.005 for DARP for GMSK modulated voice services |  | 201d? | 2004-02-06 A | 2004-11-12 A | 100% | 2004-02-06 | 2004-11-12 | 201d? | finish no earlier than 2004-11-12 | GP | 1608h | 1608h | DARP-GMSK-Perf |  |  | Rel-6 | Paolo | DARP-GMSK-Perf |  |  |  |
| 3893 | 999.2.2 | Radio subsystem link control in 45.008 for DARP for GMSK modulated voice services |  | 201d? | 2004-02-06 A | 2004-11-12 A | 100% | 2004-02-06 | 2004-11-12 | 201d? | finish no earlier than 2004-11-12 | GP | 1608h | 1608h | DARP-GMSK-LC |  |  | Rel-6 | Paolo | DARP-GMSK-LC |  |  |  |
| 3894 | 999.3 | **DARP for GPRS and EGPRS MCS1-MCS4** |  | 201d? | 2004-02-06 A | 2004-11-12 A | 100% | 2004-02-06 | 2004-11-12 | 201d? |  | GP | 4824h | 4824h | DARP-GPRSE | Nokia | tommy.bysted@nokia.com | Rel-6 | Paolo | DARP-GPRSE |  |  |  |
| 3895 | 999.3.1 | Performance requirements in 45.005 for DARP for GPRS and EGPRS MCS1-MCS4 |  | 201d? | 2004-02-06 A | 2004-11-12 A | 100% | 2004-02-06 | 2004-11-12 | 201d? | finish no earlier than 2004-11-12 | GP | 1608h | 1608h | DARP-GPRSE-Perf |  |  | Rel-6 | Paolo | DARP-GPRSE-Perf |  |  |  |
| 3896 | 999.3.2 | Radio subsystem link control in 45.008 for DARP for GPRS and EGPRS MCS1-MCS4 |  | 201d? | 2004-02-06 A | 2004-11-12 A | 100% | 2004-02-06 | 2004-11-12 | 201d? | finish no earlier than 2004-11-12 | GP | 1608h | 1608h | DARP-GPRSE-LC |  |  | Rel-6 | Paolo | DARP-GPRSE-LC |  |  |  |
| 3897 | 999.4 | DARP Capability signalling |  | 256d? | 2003-11-21 A | 2004-11-12 A | 100% | 2003-11-21 | 2004-11-12 | 256d? | finish no earlier than 2004-11-12 | GP | 2048h | 2048h | DARP-CAPSIG | Nokia | tommy.bysted@nokia.com | Rel-6 | Paolo | DARP-CAPSIG |  |  |  |
| 3898 | 999.5 | GERAN MS Conformance test for DARP |  | 266d? | 2004-08-27 A | 2005-09-02 A | 100% | 2004-08-27 | 2005-09-02 | 266d? | finish no earlier than 2005-06-24 | G3new | 2128h | 2128h | ARP-ConfTest | Nokia | tommy.bysted@nokia.com | Rel-6 | Ingbert | ARP-ConfTest |  |  |  |
| 3899 | 1000 | **Reduction of PS service interruption in Dual Transfer Mode** |  | 416d? | 2003-11-21 A | 2005-06-24 A | 100% | 2003-11-21 | 2005-06-24 | 416d? |  | G2 | 8360h | 8360h | PSintDTM | Siemens | toby.proctor@roke.co.uk | Rel-6 | Gert | PSintDTM |  |  |  |
| 3900 | 1000.1 | Use case and requirement definition |  | 111d? | 2003-11-21 A | 2004-04-23 A | 100% | 2003-11-21 | 2004-04-23 | 111d? | finish no earlier than 2004-04-23 | G2 | 888h | 888h | PSintDTM-Req | Siemens | toby.proctor@roke.co.uk | Rel-6 | Gert | PSintDTM-Req |  |  |  |
| 3901 | 1000.2 | Performance Study of Current Procedures |  | 111d? | 2003-11-21 A | 2004-04-23 A | 100% | 2003-11-21 | 2004-04-23 | 111d? | start no earlier than 2003-11-21 | G2 | 888h | 888h | PSintDTM-Perf | Siemens | toby.proctor@roke.co.uk | Rel-6 | Gert | PSintDTM-Perf |  |  |  |
| 3902 | 1000.3 | Reduction of service interruption times and packet loss during Dual Transfer Mode and mobility procedures |  | 146d? | 2004-04-23 A | 2004-11-12 A | 100% | 2004-04-23 | 2004-11-12 | 146d? | finish no earlier than 2004-11-12 | G2 | 1168h | 1168h | PSintDTM-Reduct | Siemens | toby.proctor@roke.co.uk | Rel-6 | Gert | PSintDTM-Reduct |  |  |  |
| 3903 | 1000.4 | Deleted - MS Conformance testing - Reduction of PS service interruption in DTM |  | 261d? | 2004-06-25 A | 2005-06-24 A | 100% | 2004-06-25 | 2005-06-24 | 261d? | finish no earlier than 2005-06-24 | G3new | 2088h | 2088h | PSintDTM-ConfMS |  |  | Rel-6 | Ingbert | PSintDTM-ConfMS | GP-25 |  |  |
| 3904 | 1000.5 | Deleted - BTS Conformance testing - Reduction of PS service interruption in DTM | milestone | 0d? | 2005-06-24 A | 2005-06-24 A | 100% | 2005-06-24 | 2005-06-24 | 0d? | finish no earlier than 2005-06-24 | G3new |  |  | PSintDTM-ConfBTS |  |  | Rel-6 | Ingbert | PSintDTM-ConfBTS | GP-25 |  |  |
| 3905 | 1001 | CAMEL prepay interworking with SCUDIF |  | 216.3d | 2003-12-08 A | 2004-10-05 A | 100% | 2003-12-08 | 2004-10-05 | 216.3d |  | N4; N3; S1 | 5191.2h | 5191.2h | SCCAMEL | Nokia | Keijo.Palviainen@Nokia.Com | Rel-6 | Kimmo | SCCAMEL |  | 22.078, 23.078, 29.078, 29.002, 23.172 |  |
| 3906 | 1002 | **Circuit Switched Video and Voice Service Improvements** |  | 430d? | 2004-01-12 A | 2005-09-02 A | 100% | 2004-01-12 | 2005-09-02 | 430d? |  | S2; N1 | 12696h | 12696h | CS_VSS | Vodafone | John Watson | Rel-6 | Alain | CS_VSS |  |  |  |
| 3907 | 1002.1 | Deleted - Stage 1 - Requirements |  | 199d | 2004-01-12 A | 2004-10-14 A | 100% | 2004-01-12 | 2004-10-14 | 199d | finish no earlier than 2004-10-14 | S1 | 1592h | 1592h |  | Vodafone | John Watson | Rel-6 | Alain |  | SP-26 | 22.101 |  |
| 3908 | 1002.2 | Stage 2 Study on architecture alternatives |  | 244d? | 2004-01-12 A | 2004-12-16 A | 100% | 2004-01-12 | 2004-12-16 | 244d? | finish no earlier than 2004-08-13 | S2 | 1952h | 1952h |  | Vodafone | chris.pudney@vodafone.com | Rel-6 | Maurice |  |  | 23.903 | SP-24 |
| 3909 | 1002.3 | Deleted - Stage 2 description on Redial |  | 164d? | 2004-05-03 A | 2004-12-16 A | 100% | 2004-05-03 | 2004-12-16 | 164d? | finish no earlier than 2004-12-16 | S2 | 1312h | 1312h |  | Vodafone | chris.pudney@vodafone.com | Rel-6 | Maurice |  | SP-26 |  | SP-24 |
| 3910 | 1002.4 | Switching between voice and video call - Redial solution |  | 120d? | 2005-01-03 A | 2005-06-17 A | 100% | 2005-01-03 | 2005-06-17 | 120d? | start no earlier than 2005-01-03 | N1 | 960h | 960h |  | Vodafone |  | Rel-6 | Frederic |  |  | 23.009, 24.008 |  |
| 3911 | 1002.5 | Deleted - CS_VSS - GERAN2 Part | milestone | 0d | 2005-09-02 A | 2005-09-02 A | 100% | 2005-09-02 | 2005-09-02 | 0d | start no earlier than 2005-09-02 | G2 |  |  |  | Vodafone |  | Rel-6 | Gert |  | GP-26 |  |  |
| 3912 | 1002.6 | Deleted - CS_VSS - CN3 Part | milestone | 0d? | 2004-10-14 A | 2004-10-14 A | 100% | 2004-10-14 | 2004-10-14 | 0d? | start no earlier than 2004-10-14 | N3 |  |  |  | Vodafone |  | Rel-6 | Gwiho |  | TP-26 |  |  |
| 3913 | 1003 | Reorganisation of CS Data Specifications |  | 14d? | 2004-11-19 A | 2004-12-08 A | 100% | 2004-11-19 | 2004-12-08 | 14d? | finish no earlier than 2004-12-24 | N3 | 112h | 112h | CS Data | Siemens | Thomas.Belling@nsn.com | Rel-6 | Gwiho | CS Data |  | 23.910, 29.007, New 23.202 |  |

Notes:
- 3889: -
- 3890: -
- 3891: -
- 3892: -
- 3893: -
- 3894: -
- 3895: -
- 3896: -
- 3897: -
- 3898: -
- 3899: -
- 3900: -
- 3901: -
- 3902: -
- 3903: -
- 3904: -
- 3905: -
- 3906: -
- 3907: -
- 3908: -
- 3909: -
- 3910: -
- 3911: -
- 3912: -
- 3913: Created at TSG#27 as 100 % complete

| ID | WBS | Task | Type | Duration | Start | Finish | Complete | Baseline start | Baseline finish | Baseline duration | Constraint | Resources | Work | Actual work | Acronym | WI rapporteur name | Release | MCC resp | Acronym_3GU_Export | Impacted TSs and TRs | WI rapporteur e-mail | TSG stopped |
| --- | --- | --- | --- | --- | --- | --- | --- | --- | --- | --- | --- | --- | --- | --- | --- | --- | --- | --- | --- | --- | --- | --- |
| 3914 | 1004 | **Generic Access to A/Gb Interface (GAAI)** |  | 411d? | 2004-06-25 A | 2006-01-20 A | 100% | 2004-06-25 | 2006-01-20 | 411d? |  | GP | 9160h | 9160h | GAAI | Motorola | Rel-6 | Paolo | GAAI |  |  |  |
| 3915 | 1004.1 | FS on GAAI |  | 46d? | 2004-06-25 A | 2004-08-27 A | 100% | 2004-06-25 | 2004-08-27 | 46d? | finish no earlier than 2004-08-27 | GP | 368h | 368h | GAAG | Motorola | Rel-6 | Paolo | GAAG | 43.901 |  |  |
| 3916 | 1004.2 | GAAI – Stage 2 |  | 161d? | 2004-08-27 A | 2005-04-08 A | 100% | 2004-08-27 | 2005-04-08 | 161d? | finish no earlier than 2005-04-08 | GP | 1288h | 1288h | GAAI-Stage2 | Ericsson | Rel-6 | Paolo | GAAI-Stage2 | 43.318 | jari.vikberg@ericsson.com |  |
| 3917 | 1004.3 | GAAI – Stage 3 |  | 161d? | 2004-08-27 A | 2005-04-08 A | 100% | 2004-08-27 | 2005-04-08 | 161d? | finish no earlier than 2005-04-08 | GP | 1288h | 1288h | GAAI-Stage3 |  | Rel-6 | Paolo | GAAI-Stage3 | 44.318 |  |  |
| 3918 | 1004.4 | MS Conformance Test for GAAI |  | 366d? | 2004-08-27 A | 2006-01-20 A | 100% | 2004-08-27 | 2006-01-20 | 366d? | finish no earlier than 2006-01-20 | GP | 2928h | 2928h | GAAI-CT |  | Rel-6 | Ingbert | GAAI-CT |  |  |  |
| 3919 | 1005 | **Support of PS Handover for GERAN A/Gb mode** |  | 473d? | 2003-11-03 A | 2005-08-24 A | 100% | 2003-11-03 | 2005-08-24 | 473d? |  | GP; G2 | 30272h | 30272h | SPSHAGB | Ericsson | Rel-6 | Paolo | SPSHAGB |  | gunnar.hedby@ericsson.com |  |
| 3920 | 1005.1 | Stage 2 for Support of PS Handover for GERAN A/Gb mode |  | 473d? | 2003-11-03 A | 2005-08-24 A | 100% | 2003-11-03 | 2005-08-24 | 473d? | finish no earlier than 2005-09-02 | GP; G2 | 7568h | 7568h | SPSHAGB-Stage2 | Ericsson | Rel-6 | Paolo | SPSHAGB-Stage2 | 43.129 | gunnar.hedby@ericsson.com |  |
| 3921 | 1005.2 | PS handover for Support of PS Handover for GERAN A/Gb mode |  | 473d? | 2003-11-03 A | 2005-08-24 A | 100% | 2003-11-03 | 2005-08-24 | 473d? | finish no earlier than 2005-09-02 | GP; G2 | 7568h | 7568h | SPSHAGB-PSHO | Ericsson | Rel-6 | Paolo | SPSHAGB-PSHO |  | gunnar.hedby@ericsson.com |  |
| 3922 | 1005.3 | Definition of radio resource management functionality for Support of PS Handover for GERAN A/Gb mode |  | 473d? | 2003-11-03 A | 2005-08-24 A | 100% | 2003-11-03 | 2005-08-24 | 473d? | finish no earlier than 2005-09-02 | GP; G2 | 7568h | 7568h | SPSHAGB-RRM | Ericsson | Rel-6 | Paolo | SPSHAGB-RRM |  | gunnar.hedby@ericsson.com |  |
| 3923 | 1006 | Study on (U)SIM Security Reuse by Peripheral Devices on Local Interfaces |  | 127d? | 2003-07-03 A | 2003-12-26 A | 100% | 2003-07-03 | 2003-12-26 | 127d? | finish no earlier than 2003-12-26 | S3 | 1016h | 1016h |  | Toshiba | Rel-6 | Mirko |  | 33.817 | Raziq Yaqub (ryaqub@tari.toshiba.com) |  |
| 3924 | 1007 | Study on Security for early IMS |  | 127d? | 2004-10-01 A | 2005-03-28 A | 100% | 2004-10-01 | 2005-03-28 | 127d? | finish no earlier than 2003-12-26 | S3 | 1016h | 1016h | SEC-IMS | Vodafone | Rel-6 | Mirko | SEC-IMS | 33.978 | Peter.Howard@vodafone.com |  |
| 3925 | 1008 | (Small) Technical Enhancements and Improvements for Rel-6 | milestone | 0d? | 2006-06-02 A | 2006-06-02 A | 100% | 2006-06-02 | 2006-06-02 | 0d? |  | SP; CP; RP; GP |  |  | TEI6 |  | Rel-6 | all | TEI6 |  |  |  |
| 3926 | 1009 | Test - (Small) Technical Enhancements and Improvements for Rel-6 |  | 503d? | 2006-06-02 A | 2008-05-06 A | 100% | 2006-06-02 | 2008-05-06 | 503d? | start no earlier than 2006-06-02 | R5; T1 | 8048h | 8048h | TEI6_Test |  | Rel-6 | Ingbert | TEI6_Test | 34.108,34.121-1/2,34.122,34.123-1/2/3 |  |  |
| 3927 | 1010 | Deleted - Study of Feature Interactions Requirements | milestone | 0d? | 2004-09-16 A | 2004-09-16 A | 100% | 2004-09-16 | 2004-09-16 | 0d? | finish no earlier than 2004-10-01 | S1 |  |  | FINTER |  | Rel-6 | Alain | FINTER |  |  | SP-25 |
| 3928 | 1011 | Deleted EVGCS - Enhancements of VGCS in public networks for communication of public authority officials |  | 7d? | 2005-08-25 A | 2005-09-02 A | 100% | 2005-08-25 | 2005-09-02 | 7d? | start no earlier than 2005-08-24 | GP; G2 | 112h | 112h |  | Siemens | Rel-6 | Paolo |  | 44.018, 44.068, 48.008 | kenneth.isaacs@roke.co.uk | GP-26 |
| 3929 | 1012 | **Deleted SCSAGB - Support of Conversational Services in A/Gb mode via the PS domain** |  | 64d? | 2003-11-21 A | 2004-02-19 A | 100% | 2003-11-21 | 2004-02-19 | 64d? |  | GP; N1 | 2048h | 2048h |  | Ericsson | Rel-6 | Paolo |  |  | David Bladsjö (david.bladsjo@ericsson.com) | GP-18 |
| 3930 | 1012.1 | Deleted - Creation of a TR | milestone | 0d? | 2003-11-21 A | 2003-11-21 A | 100% | 2003-11-21 | 2003-11-21 | 0d? | start no earlier than 2003-11-21 | GP |  |  | SCSAGB-TR | Ericsson | Rel-6 | Paolo | SCSAGB-TR |  | David Bladsjö (david.bladsjo@ericsson.com) | GP-17 |
| 3931 | 1012.2 | Deleted - Stage 2 | milestone | 0d? | 2003-11-21 A | 2003-11-21 A | 100% | 2003-11-21 | 2003-11-21 | 0d? | finish no earlier than 2003-11-21 | GP |  |  | SCSAGB-Stage2 | Ericsson | Rel-6 | Paolo | SCSAGB-Stage2 |  | David Bladsjö (david.bladsjo@ericsson.com) | GP-17 |
| 3932 | 1012.3 | Deleted - Radio Channel Support | milestone | 0d? | 2003-11-21 A | 2003-11-21 A | 100% | 2003-11-21 | 2003-11-21 | 0d? | finish no earlier than 2003-11-21 | GP |  |  | SCSAGB-RCS | Ericsson | Rel-6 | Paolo | SCSAGB-RCS |  | David Bladsjö (david.bladsjo@ericsson.com) | GP-17 |
| 3933 | 1012.4 | Deleted SCSAGB-RRM - Definition of radio resource management functionality | milestone | 0d? | 2003-11-21 A | 2003-11-21 A | 100% | 2003-11-21 | 2003-11-21 | 0d? | finish no earlier than 2003-11-21 | GP |  |  |  | Ericsson | Rel-6 | Paolo |  |  | David Bladsjö (david.bladsjo@ericsson.com) | GP-17 |
| 3934 | 1012.5 | Deleted - replaced by 50561 - PS Handover |  | 64d | 2003-11-24 A | 2004-02-19 A | 100% | 2003-11-24 | 2004-02-19 | 64d | start no earlier than 2003-11-21 | GP; N1 | 1024h | 1024h | SCSAGB-PSH | Ericsson | Rel-6 | Paolo | SCSAGB-PSH |  | David Bladsjö (david.bladsjo@ericsson.com) | GP-18 |
| 3935 | 1012.6 | Deleted SCSAGB-FLO - Modifications to FLO | milestone | 0d? | 2003-11-21 A | 2003-11-21 A | 100% | 2003-11-21 | 2003-11-21 | 0d? | finish no earlier than 2003-11-21 | GP |  |  |  | Ericsson | Rel-6 | Paolo |  |  | David Bladsjö (david.bladsjo@ericsson.com) | RP-29 |
| 3936 | 1013 | Deleted - Rel-6 Evolutions of the transport in the UTRAN (ETRAN) | milestone | 0d | 2003-12-31 A | 2003-12-31 A | 100% | 2003-12-31 | 2003-12-31 | 0d | start no earlier than 2003-12-31 | RP |  |  |  | Alcatel | Rel-6 | Issam |  |  | Francois Courau | RP-22 |
| 3937 | 1014 | Release 5 Features |  | 325d? | 2000-01-03 A | 2001-03-29 A | 100% | 2000-01-03 | 2001-03-29 | 325d? |  | NP; GP; RP; SP; TP | 13000h | 13000h |  |  | Rel-5 | All |  |  |  |  |
| 3938 | 75 | IP transport in the UTRAN |  | 445d | 2000-07-17 A | 2002-03-29 A | 100% | 2000-07-17 | 2002-03-29 | 445d | finish no earlier than 2002-03-29 | R3 | 3560h | 3560h | ETRAN-IPtrans | Alcatel | Rel-5 | Juha | ETRAN-IPtrans |  | Nicolas Drevon |  |
| 3939 | 76 | Feasibility study on SS7 signalling transportation in the core network with SCCP-User Adaptation (SUA) |  | 205d | 2001-03-12 A | 2001-12-21 A | 100% | 2001-03-12 | 2001-12-21 | 205d | finish no earlier than 2001-12-21 | N4 | 1640h | 1640h | FS_SS7IP |  | Rel-5 | Kimmo | FS_SS7IP | 29.903 |  |  |

Notes:
- 3914: -
- 3915: Feasibility Study
- 3916: -
- 3917: -
- 3918: Marked as closed 12/2008 (was marked 90% complete)
- 3919: Replaces SCSAGB- Originally Started Nov 2003 as GP-030443
- 3920: Replaces SCSAGB-Stage2
- 3921: Replaces SCSAGB-PSH
- 3922: Replaces SCSAGB-RRM
- 3923: SP#20 approved WID
- 3924: SP#24 approved WID. SP#46 withdrawn TR 33.978 from Rel-8 onwards
- 3925: "Joker" WI, to be used for a Rel 6 CR not related to any feature and with very limited impact on the system. Moved in from Stoyan/Testing WP
- 3926: "Joker" WI, to be used for small modifications applicable to Rel 4 conformance testing
- 3927: SP#25 stopped
- 3928: GP#26 moved to Rel-7 as UID_11045 Enhancements of VGCS in public networks for communication of public authority officials
- 3929: -
- 3930: -
- 3931: Started
- 3932: Not started
- 3933: Not started
- 3934: Started
- 3935: Not started
- 3936: Generic feature ETRAN
- 3937: -
- 3938: -
- 3939: -

| ID | WBS | Task | Duration | Start | Finish | Complete | Baseline start | Baseline finish | Baseline duration | Constraint | Deadline | Resources | Work | Actual work | Acronym | WI rapporteur name | WI rapporteur e-mail | Release | MCC resp | Acronym_3GU_Export | Impacted TSs and TRs | Created at | TSG stopped |
| --- | --- | --- | --- | --- | --- | --- | --- | --- | --- | --- | --- | --- | --- | --- | --- | --- | --- | --- | --- | --- | --- | --- | --- |
| 3940 | 77 | **High Speed Downlink Packet Access** | 1550d? | 2001-04-02 A | 2007-03-09 A | 100% | 2001-04-02 | 2007-03-09 | 1550d? |  |  | R2; R5 | 43888h | 43888h | HSDPA | Motorola | Ravi Kuchibhotla | Rel-5 | Yong-Jun | HSDPA |  |  |  |
| 3941 | 77.1 | Physical Layer for High Speed Downlink Packet Access | 257d | 2001-04-05 A | 2002-03-29 A | 100% | 2001-04-05 | 2002-03-29 | 257d | finish no earlier than 2002-03-29 |  | R1 | 2056h | 2056h | HSDPA-Phys | Motorola | Amitabha Ghosh (qa0047@email.mot.com) | Rel-5 | Patrick | HSDPA-Phys |  |  |  |
| 3942 | 77.2 | Layer 2 and 3 aspects | 257d | 2001-04-05 A | 2002-03-29 A | 100% | 2001-04-05 | 2002-03-29 | 257d | finish no earlier than 2002-03-29 |  | R2 | 2056h | 2056h | HSDPA-L23 | Motorola | Ravi Kuchibhotla | Rel-5 | Yong-Jun | HSDPA-L23 |  |  |  |
| 3943 | 77.3 | Iub/Iur protocol aspects - for High Speed Downlink Packet Access | 260d | 2001-04-02 A | 2002-03-29 A | 100% | 2001-04-02 | 2002-03-29 | 260d | finish no earlier than 2002-03-29 |  | R3 | 2080h | 2080h | HSDPA-IubIur | Motorola | Mike Diesen | Rel-5 | Juha | HSDPA-IubIur |  |  |  |
| 3944 | 77.4 | RF Radio Transmission/ Reception, System Performance Requirements and Conformance Testing | 565d | 2001-04-09 A | 2003-06-06 A | 100% | 2001-04-09 | 2003-06-06 | 565d | finish no earlier than 2003-06-06 |  | R4 | 4520h | 4520h | HSDPA-RF | Motorola | Howard Benn | Rel-5 | Issam | HSDPA-RF |  |  |  |
| 3945 | 1017.5 | Conformance Testing of HSDPA | 786d | 2003-09-19 A | 2006-09-22 A | 100% | 2003-09-19 | 2006-09-22 | 786d | finish no earlier than 2006-09-22 |  | R5 | 6288h | 6288h | HSDPA_Test | Motorola | carolyn.taylor@motorola.com | Rel-5 | Ingbert | HSDPA_Test | 34.108, 34.121, 34.122, 34.123-1, 34.123-2, 34.123-3 | 19/9/2003 |  |
| 3946 | 1017.6 | Conformance Testing of HCR TDD HSDPA | 261d? | 2006-03-10 A | 2007-03-09 A | 100% | 2006-03-10 | 2007-03-09 | 261d? | finish no earlier than 2007-03-09 |  | R5 | 2088h | 2088h | HSDPA_HCRTDD_Test | IPWireless | drichards@ipwireless.com | Rel-5 | Ingbert | HSDPA_HCRTDD_Test | 34.108, 34.122, 34.123-1, 34.123-2, 34.123-3 |  |  |
| 3947 | 78 | **Rel-5 Improvements of Radio Interface** | 535d | 2000-08-14 A | 2002-08-30 A | 100% | 2000-08-14 | 2002-08-30 | 535d |  |  | RP | 30376h | 30376h |  |  |  | Rel-5 |  |  |  |  |  |
| 3948 | 78.1 | **Base station classification for TDD** | 480d | 2000-08-14 A | 2002-06-14 A | 100% | 2000-08-14 | 2002-06-14 | 480d |  |  | R4 | 9208h | 9208h | RInImp-BSClass | Nokia | antti.toskala@nokia.com | Rel-5 | Issam | RInImp-BSClass |  |  |  |
| 3949 | 78.1.1 | TDD Base station classification | 410d | 2000-08-14 A | 2002-03-08 A | 100% | 2000-08-14 | 2002-03-08 | 410d | finish no earlier than 2002-03-08 |  | R4 | 3280h | 3280h | RInImp-BSClass-TDD | Nokia | antti.toskala@nokia.com | Rel-5 | Issam | RInImp-BSClass-TDD |  |  |  |
| 3950 | 78.1.2 | Base Station Classification for 1.28 Mcps TDD option | 261d | 2001-06-15 A | 2002-06-14 A | 100% | 2001-06-15 | 2002-06-14 | 261d | finish no earlier than 2002-06-14 |  | R4 | 2088h | 2088h | RInImp-BSClass-LCRTDD | Siemens | Meik.Kottkamp@siemens.com | Rel-5 | Issam | RInImp-BSClass-LCRTDD |  |  |  |
| 3951 | 78.2 | Enhancement on the DSCH hard split mode | 271d | 2001-03-16 A | 2002-03-29 A | 100% | 2001-03-16 | 2002-03-29 | 271d | finish no earlier than 2002-03-29 |  | R1 | 2168h | 2168h | RInImp-DSCHhsp | Samsung | Jaeyoel KIM | Rel-5 | Patrick | RInImp-DSCHhsp |  |  |  |
| 3952 | 78.3 | Hybrid ARQ II/III | 355d | 2000-08-21 A | 2001-12-28 A | 100% | 2000-08-21 | 2001-12-28 | 355d | finish no earlier than 2001-12-28 |  | R2 | 2840h | 2840h | RInImp-HARQ | Siemens | armin.sitte@siemens.com | Rel-5 | Yong-Jun | RInImp-HARQ |  |  | RP-14 |
| 3953 | 78.4 | FS on USTS | 355d | 2000-08-14 A | 2001-12-21 A | 100% | 2000-08-14 | 2001-12-21 | 355d | finish no earlier than 2001-12-21 |  | R1 | 2840h | 2840h | RInImp-USTS | SK Telecom | D. Kim | Rel-5 | Patrick | RInImp-USTS |  |  |  |
| 3954 | 78.5 | FS on UE antenna efficiency test method performance requirements | 255d | 2000-09-25 A | 2001-09-14 A | 100% | 2000-09-25 | 2001-09-14 | 255d | finish no earlier than 2001-09-14 |  | R4 | 2040h | 2040h | RInImp-UEAnTM | Allgon | O. Edvardsson | Rel-5 | Issam | RInImp-UEAnTM |  |  |  |
| 3955 | 78.6 | FS on the re-introduction of the downlink SIR measurement | 200d | 2001-03-12 A | 2001-12-14 A | 100% | 2001-03-12 | 2001-12-14 | 200d | finish no earlier than 2001-12-14 |  | R4 | 1600h | 1600h | RInImp-SIR | Ericsson | Torgny.Palenius@ericsson.com | Rel-5 | Issam | RInImp-SIR |  |  |  |
| 3956 | 78.7 | FS on mitigating the effect of CPICH interference at the UE | 255d | 2001-03-19 A | 2002-03-08 A | 100% | 2001-03-19 | 2002-03-08 | 255d | finish no earlier than 2002-03-08 |  | R4 | 2040h | 2040h | RInImp-CPICH_Intf | Intel | shimon.moshavi@INTEL.COM | Rel-5 | Issam | RInImp-CPICH_Intf |  |  |  |
| 3957 | 78.8 | **Deleted - Conformance Test Spec. improvements in Radio Interface** | 140d | 2002-02-18 A | 2002-08-30 A | 100% | 2002-02-18 | 2002-08-30 | 140d |  |  | T1 | 3360h | 3360h |  |  |  | Rel-5 | Ingbert |  |  |  | TP-17 |
| 3958 | 78.8.1 | Deleted - Testing improvement of inter-frequency and inter-system measurement | 140d | 2002-02-18 A | 2002-08-30 A | 100% | 2002-02-18 | 2002-08-30 | 140d | finish no earlier than 2002-08-30 |  | T1 | 1120h | 1120h |  |  |  | Rel-5 | Ingbert |  |  |  | TP-17 |
| 3959 | 78.8.2 | Deleted - Testing Hybrid ARQ II/III | 140d | 2002-02-18 A | 2002-08-30 A | 100% | 2002-02-18 | 2002-08-30 | 140d | finish no earlier than 2002-08-30 |  | T1 | 1120h | 1120h |  |  |  | Rel-5 | Ingbert |  |  |  | TP-17 |
| 3960 | 79 | **Rel-5 RAN improvements** | 1561d? | 2001-03-16 A | 2007-03-09 A | 100% | 2001-03-16 | 2007-03-09 | 1561d? |  |  | RP | 49424h | 49424h |  |  |  | Rel-5 |  |  |  |  |  |
| 3961 | 79.1 | **RRM optimization for Iur and Iub** | 318d | 2001-03-16 A | 2002-06-04 A | 100% | 2001-03-16 | 2002-06-04 | 318d |  |  | R3 | 8904h | 8904h | RANimp-RRMopt | Ericsson | Gert-Jan.van.Lieshout@eln.ericsson.se | Rel-5 | Juha | RANimp-RRMopt |  |  |  |
| 3962 | 79.1.1 | Iur common transport channel efficiency optimization | 271d | 2001-03-16 A | 2002-03-29 A | 100% | 2001-03-16 | 2002-03-29 | 271d | finish no earlier than 2002-03-29 |  | R3 | 2168h | 2168h | RANimp-RRMopt-ctc | Ericsson | Shahrokh Amirijoo | Rel-5 | Juha | RANimp-RRMopt-ctc |  |  |  |
| 3963 | 79.1.2 | Iur neighbouring cell reporting efficiency optimization | 271d | 2001-03-16 A | 2002-03-29 A | 100% | 2001-03-16 | 2002-03-29 | 271d | finish no earlier than 2002-03-29 |  | R3 | 2168h | 2168h | RANimp-RRMopt-ncr | Ericsson | Shahrokh Amirijoo | Rel-5 | Juha | RANimp-RRMopt-ncr |  |  |  |
| 3964 | 79.1.3 | FS Introduction of direct transport bearers between SRNC and Node-B | 253d | 2001-06-15 A | 2002-06-04 A | 100% | 2001-06-15 | 2002-06-04 | 253d | finish no earlier than 2002-06-28 |  | R3 | 2024h | 2024h | RAN-imp-RRMopt-DTB | Ericsson | Risto Sepponen | Rel-5 | Juha | RAN-imp-RRMopt-DTB |  |  |  |
| 3965 | 79.2 | RL Timing Adjustment | 271d | 2001-03-16 A | 2002-03-29 A | 100% | 2001-03-16 | 2002-03-29 | 271d | finish no earlier than 2002-03-29 |  | R3 | 2168h | 2168h | RANimp-RLTA | Ericsson | Elena Voltolina | Rel-5 | Juha | RANimp-RLTA |  |  |  |
| 3966 | 79.3 | Separation of resource reservation and radio link activation | 271d | 2001-03-16 A | 2002-03-29 A | 100% | 2001-03-16 | 2002-03-29 | 271d | finish no earlier than 2002-03-29 |  | R3 | 2168h | 2168h | RANimp-SepRR | Ericsson | Gert-Jan.van.Lieshout@eln.ericsson.se | Rel-5 | Juha | RANimp-SepRR |  |  |  |
| 3967 | 79.4 | FS SRNS Relocation Procedure Enhancement | 318d | 2001-06-15 A | 2002-09-03 A | 100% | 2001-06-15 | 2002-09-03 | 318d | finish no earlier than 2002-09-06 |  | R3 | 2544h | 2544h | RANimp-SRNS | Nokia | Olivier Guyot | Rel-5 | Juha | RANimp-SRNS |  |  |  |
| 3968 | 79.5 | FS Improvement of Radio Resource Management across RNS and RNS/PSS | 201d | 2001-03-16 A | 2001-12-21 A | 100% | 2001-03-16 | 2001-12-21 | 201d | finish no earlier than 2001-12-21 |  | R3 | 1608h | 1608h | RANimp-ImpRRM | Nokia | antti.toskala@nokia.com | Rel-5 | Juha | RANimp-ImpRRM |  |  |  |
| 3969 | 79.6 | Re-arrangements of Iub transport bearers | 271d | 2001-03-16 A | 2002-03-29 A | 100% | 2001-03-16 | 2002-03-29 | 271d | finish no earlier than 2002-03-29 |  | R3 | 2168h | 2168h | RANimp-TTPS | Nokia | antti.toskala@nokia.com | Rel-5 | Juha | RANimp-TTPS |  |  |  |
| 3970 | 79.7 | RAB support enhancement for Rel-5 | 325d | 2001-04-02 A | 2002-06-28 A | 100% | 2001-04-02 | 2002-06-28 | 325d |  |  | R2 | 2600h | 2600h | RANimp-RABSE5 | Nokia | Juha Mikola | Rel-5 | Yong-Jun | RANimp-RABSE5 |  |  |  |
| 3971 | 16.5.1 | Testing of ROHC performance | 391d | 2005-09-09 A | 2007-03-09 A | 100% | 2005-09-09 | 2007-03-09 | 391d | finish no earlier than 2007-03-09 | 2006-06-02 | R5 | 3128h | 3128h | RANimp-RABSE5_Test | Nokia | jarkko.hellsten@nokia.com | Rel-5 | Ingbert | RANimp-RABSE5_Test | 34.108, 34.123-1, 34.123-2, 34.123-3 | Fri 11/03/05 |  |
| 3972 | 79.8 | Beamforming requirements for UE | 61d | 2001-09-21 A | 2001-12-14 A | 100% | 2001-09-21 | 2001-12-14 | 61d | finish no earlier than 2001-12-14 |  | R1 | 488h | 488h | RANimp-BFR-UE | Nokia | Jussi Kähtävä (juha.mikola@nokia.com) | Rel-5 | Patrick | RANimp-BFR-UE |  |  |  |
| 3973 | 79.9 | Support of Site Selection Diversity Transmission in UTRAN | 123d | 2001-12-14 A | 2002-06-04 A | 100% | 2001-12-14 | 2002-06-04 | 123d | finish no earlier than 2002-06-04 |  | R1 | 984h | 984h | RANimp-SSDT | NEC |  | Rel-5 | Patrick | RANimp-SSDT |  |  |  |
| 3974 | 79.10 | Node B Synchronisation for 1.28 Mcps TDD | 271d | 2001-03-16 A | 2002-03-29 A | 100% | 2001-03-16 | 2002-03-29 | 271d | finish no earlier than 2002-03-29 |  | R1 | 2168h | 2168h | RANimp-NBSLCR | CATT | Jinling HU | Rel-5 | Patrick | RANimp-NBSLCR |  |  |  |

Notes:
- 3940: -
- 3941: -
- 3942: -
- 3943: -
- 3944: -
- 3945: -
- 3946: -
- 3947: -
- 3948: -
- 3949: -
- 3950: -
- 3951: -
- 3952: Stopped at RP#14; work on this task was performed as part of High Speed Downlink Packet Access feature
- 3953: -
- 3954: -
- 3955: -
- 3956: -
- 3957: Marked as stopped 12/2008
- 3958: Marked as stopped 12/2008
- 3959: Marked as stopped 12/2008
- 3960: -
- 3961: -
- 3962: -
- 3963: -
- 3964: FS was closed and introduction of WI not agreed at RAN #16
- 3965: -
- 3966: -
- 3967: -
- 3968: FS was closed and WI was introduced at RAN #14
- 3969: -
- 3970: RFC 3095 context relocation
- 3971: -
- 3972: -
- 3973: RP-020356
- 3974: -

| ID | WBS | Task | Duration | Start | Finish | Complete | Baseline start | Baseline finish | Baseline duration | Constraint | Deadline | Resources | Work | Actual work | Release | MCC resp | TSG stopped | Acronym | Impacted TSs and TRs | Acronym_3GU_Export | WI rapporteur name | WI rapporteur e-mail | Created at |
| --- | --- | --- | --- | --- | --- | --- | --- | --- | --- | --- | --- | --- | --- | --- | --- | --- | --- | --- | --- | --- | --- | --- | --- |
| 3975 | 79.12 | **Deleted - Conformance Test Aspects - RAN Improvements** | 565d? | 2002-01-01 A | 2004-03-01 A | 100% | 2002-01-01 | 2004-03-01 | 565d? |  |  | T1 | 8008h | 8008h | Rel-5 | Ingbert | TP-23 |  |  |  |  |  |  |
| 3976 | 79.12.1 | Deleted - Testing Radio access bearer support enhancements | 175d | 2002-01-01 A | 2002-09-02 A | 100% | 2002-01-01 | 2002-09-02 | 175d | finish no earlier than 2002-09-02 |  | T1 | 1400h | 1400h | Rel-5 | Ingbert | TP-17 |  |  |  |  |  |  |
| 3977 | 1019.12.2 | Deleted - General changes to TS34.121 and TS34.122 corresponding to release 5 | 261d? | 2003-03-03 A | 2004-03-01 A | 100% | 2003-03-03 | 2004-03-01 | 261d? | finish no earlier than 2004-03-01 |  | T1 | 2088h | 2088h | Rel-5 | Ingbert | TP-23 | RANimp-test, TEI5 | 34.108, 34.121, 34.122 | RANimp-test, TEI5 |  |  |  |
| 3978 | 80 | UTRAN Sharing in Connected Mode | 197d | 2001-12-03 A | 2002-09-03 A | 100% | 2001-12-03 | 2002-09-03 | 197d | finish no earlier than 2002-09-06 |  | R3 | 1576h | 1576h | Rel-5 | Juha |  | NETSHARE |  | NETSHARE | Ericsson | Martin Israelsson |  |
| 3979 | 81 | **Provisioning of IP-based multimedia services** | 1806d | 2000-01-03 A | 2006-12-01 A | 100% | 2000-01-03 | 2006-12-01 | 1806d |  |  | S1; S2; S3; S5; NP; T3; T1; R5 | 325092h | 325092h | Rel-5 | Alain |  | IMS |  | IMS | Openwave | Mark Cataldo |  |
| 3980 | 81.1 | **Call control and roaming to support IMS in UMTS** | 1806d | 2000-01-03 A | 2006-12-01 A | 100% | 2000-01-03 | 2006-12-01 | 1806d |  |  | S2; R5 | 109760h | 109760h | Rel-5 | Maurice |  | IMS-CCR |  | IMS-CCR | Lucent | Liz Daniel |  |
| 3981 | 81.1.1 | Stage 1 for Call control and roaming to support IMS in UMTS | 215d | 2000-02-21 A | 2000-12-15 A | 100% | 2000-02-21 | 2000-12-15 | 215d | finish no earlier than 2000-09-21 |  | S1 | 1720h | 1720h | Rel-5 | Alain |  |  | 22.228 |  | Motorola | Mark Cataldo |  |
| 3982 | 81.1.2 | Stage 2 (Architecture and Main flows) | 246d | 2000-04-14 A | 2001-03-23 A | 100% | 2000-04-14 | 2001-03-23 | 246d | finish no earlier than 2001-03-23 |  | S2 | 1968h | 1968h | Rel-5 | Maurice |  |  | 23.228 |  | Lucent | Liz Daniel |  |
| 3983 | 81.1.3 | Impact on MM/CC/SM | 400d | 2000-08-28 A | 2002-03-08 A | 100% | 2000-08-28 | 2002-03-08 | 400d | finish no earlier than 2002-03-08 |  | N1 | 3200h | 3200h | Rel-5 | Frederic |  | IMS-CCR-IWMM |  | IMS-CCR-IWMM | Lucent | Keith Drage (drage@alcatel-lucent.com) |  |
| 3984 | 81.1.4 | **SIP Call Control protocol for the IMS** | 385d | 2000-10-02 A | 2002-03-22 A | 100% | 2000-10-02 | 2002-03-22 | 385d |  |  | N1 | 12320h | 12320h | Rel-5 | Frederic |  |  | 24.228, 24.229, 23.218 |  | Lucent | Keith Drage (drage@alcatel-lucent.com) |  |
| 3985 | 81.1.4.1 | IMS signalling flows | 385d | 2000-10-02 A | 2002-03-22 A | 100% | 2000-10-02 | 2002-03-22 | 385d | finish no earlier than 2002-03-22 |  | N1 | 3080h | 3080h | Rel-5 | Frederic |  |  | 24.228 |  |  |  |  |
| 3986 | 81.1.4.2 | IMS stage 3 | 385d | 2000-10-02 A | 2002-03-22 A | 100% | 2000-10-02 | 2002-03-22 | 385d | finish no earlier than 2002-03-22 |  | N1 | 3080h | 3080h | Rel-5 | Frederic |  |  | 24.229 |  |  |  |  |
| 3987 | 81.1.4.3 | IMS Session Handling; stage 2 | 385d | 2000-10-02 A | 2002-03-22 A | 100% | 2000-10-02 | 2002-03-22 | 385d | finish no earlier than 2002-03-22 |  | N1 | 3080h | 3080h | Rel-5 | Frederic |  |  | 23.218 |  |  |  |  |
| 3988 | 16.5.1 | Conformance Test Aspects – IMS Call Control | 451d | 2005-03-11 A | 2006-12-01 A | 100% | 2005-03-11 | 2006-12-01 | 451d |  | 2006-06-02 | R5 | 3608h | 3608h | Rel-5 | Ingbert |  | IMS-CCR_Test | 34.108, 34.229-1, 34.229-2, 34.229-3 | IMS-CCR_Test | Motorola | Jacob.John@motorola.com | Fri 11/03/05 |
| 3989 | 81.1.4.4 | **Main IETF dependencies** | 641d | 2000-01-03 A | 2002-06-14 A | 100% | 2000-01-03 | 2002-06-14 | 641d |  |  | NP | 58048h | 58048h | Rel-5 | Kimmo |  |  |  |  | Lucent |  |  |
| 3990 | 81.1.4.4.1 | IETF: RFC 3261 (Session Initiation Protocol) | 346d | 2000-11-24 A | 2002-03-22 A | 100% | 2000-11-24 | 2002-03-22 | 346d | finish no earlier than 2002-03-22 |  | N1 | 2768h | 2768h | Rel-5 | Frederic |  |  |  |  | Lucent |  |  |
| 3991 | 81.1.4.4.2 | IETF: RFC 3262 (Reliability of provisional responses) | 346d | 2000-11-24 A | 2002-03-22 A | 100% | 2000-11-24 | 2002-03-22 | 346d | finish no earlier than 2002-03-22 |  | N1 | 2768h | 2768h | Rel-5 | Frederic |  |  |  |  | Lucent |  |  |
| 3992 | 81.1.4.4.3 | IETF: RFC 3312 (Without COMET)(Integration of resource management and SIP) | 382d | 2000-11-24 A | 2002-05-13 A | 100% | 2000-11-24 | 2002-05-13 | 382d | finish no earlier than 2002-05-13 |  | N1 | 3056h | 3056h | Rel-5 | Frederic |  |  |  |  | Lucent |  |  |
| 3993 | 81.1.4.4.4 | IETF: RFC 3323 (SIP extensions for caller identity and privacy) | 382d | 2000-11-24 A | 2002-05-13 A | 100% | 2000-11-24 | 2002-05-13 | 382d | finish no earlier than 2002-05-13 |  | N1 | 3056h | 3056h | Rel-5 | Frederic |  |  |  |  | Lucent |  |  |
| 3994 | 81.1.4.4.5 | IETF: RFC 3313 (SIP extensions for media authorization) | 382d | 2000-11-24 A | 2002-05-13 A | 100% | 2000-11-24 | 2002-05-13 | 382d | finish no earlier than 2002-05-13 |  | N1 | 3056h | 3056h | Rel-5 | Frederic |  |  |  |  | Lucent |  |  |
| 3995 | 81.1.4.4.6 | IETF: RFC 3265 (specific event notification) | 346d | 2000-11-24 A | 2002-03-22 A | 100% | 2000-11-24 | 2002-03-22 | 346d | finish no earlier than 2002-03-22 |  | N1 | 2768h | 2768h | Rel-5 | Frederic |  |  |  |  | Lucent |  |  |
| 3996 | 81.1.4.4.7 | IETF: RFC editor Queue (refer method) | 401d | 2000-11-24 A | 2002-06-07 A | 100% | 2000-11-24 | 2002-06-07 | 401d | finish no earlier than 2002-06-07 |  | N1 | 3208h | 3208h | Rel-5 | Frederic |  |  |  |  | Lucent |  |  |
| 3997 | 81.1.4.4.8 | IETF: RFC editor Queue (DHCP options for SIP servers) | 382d | 2000-11-24 A | 2002-05-13 A | 100% | 2000-11-24 | 2002-05-13 | 382d | finish no earlier than 2002-05-13 |  | N1 | 3056h | 3056h | Rel-5 | Frederic |  |  |  |  | Lucent |  |  |
| 3998 | 81.1.4.4.10 | IETF: RFC 3267 (AMR and AMR WB RTP and SDP) | 346d | 2000-11-24 A | 2002-03-22 A | 100% | 2000-11-24 | 2002-03-22 | 346d | finish no earlier than 2002-03-22 |  | N1 | 2768h | 2768h | Rel-5 | Frederic |  |  |  |  | Lucent |  |  |
| 3999 | 81.1.4.4.11 | IETF: RFC 3266 (IPv6 support within SDP) | 581d | 2000-01-03 A | 2002-03-22 A | 100% | 2000-01-03 | 2002-03-22 | 581d | finish no earlier than 2002-03-22 |  | N1 | 4640h | 4640h | Rel-5 | Frederic |  |  |  |  | Lucent |  |  |
| 4000 | 81.1.4.4.12 | IETF: RFC 3311 (The Update method) | 382d | 2000-11-24 A | 2002-05-13 A | 100% | 2000-11-24 | 2002-05-13 | 382d | finish no earlier than 2002-05-13 |  | N1 | 3056h | 3056h | Rel-5 | Frederic |  |  |  |  | Lucent |  |  |
| 4001 | 81.1.4.4.13 | IETF: RFC 3324 (Network Asserted Identity) | 382d | 2000-11-24 A | 2002-05-13 A | 100% | 2000-11-24 | 2002-05-13 | 382d | finish no earlier than 2002-05-13 |  | N1 | 3056h | 3056h | Rel-5 | Frederic |  |  |  |  | Lucent |  |  |
| 4002 | 81.1.4.4.14 | IETF: RFC editor Queue (Various 3GPP Private Extensions) | 382d | 2000-11-24 A | 2002-05-13 A | 100% | 2000-11-24 | 2002-05-13 | 382d | finish no earlier than 2002-05-13 |  | N1 | 3056h | 3056h | Rel-5 | Frederic |  |  |  |  | Lucent |  |  |

Notes:
- 3975: Marked as stopped 12/2008
- 3976: Marked as stopped 12/2008
- 3977: Marked as stopped 12/2008
- 3978: Formerly 'Shared Network support in connected mode', renamed at RAN #16.
- 3979: -
- 3980: -
- 3981: Issues include e.g.: Roaming requirements, Requirements on supplementary services, Interworking requirements
- 3982: Issues include e.g.: Mobile IP, RAB selection principles, Optimized VoIP bearer mechanisms, SIP multimedia protocol
- 3983: Per 26/2-02: This is understood to be the PCO & TFT CRs which CN1 provides to TSGN #15 for approval. If this is correct understanding, then the task is 100 % complete.
- 3984: TSGN_10 approved the change:CN1 - SA2 SIP joint meeting spotted one more place for improvement: work tasks with ID 1998 and 1278 are actually subtasks under of single CN1 WT. One WI has been approved for the CN1 WT with title "SIP Call Control protocol
- 3985: 24.228
- 3986: 24.229
- 3987: 23.218
- 3988: -
- 3989: -
- 3990: -
- 3991: -
- 3992: -
- 3993: -
- 3994: -
- 3995: -
- 3996: -
- 3997: -
- 3998: -
- 3999: -
- 4000: -
- 4001: -
- 4002: -

| ID | WBS | Task | Duration | Start | Finish | Complete | Baseline start | Baseline finish | Baseline duration | Constraint | Resources | Work | Actual work | Release | MCC resp | Acronym | Impacted TSs and TRs | WI rapporteur name | WI rapporteur e-mail | Acronym_3GU_Export |
| --- | --- | --- | --- | --- | --- | --- | --- | --- | --- | --- | --- | --- | --- | --- | --- | --- | --- | --- | --- | --- |
| 4003 | 81.1.4.5 | **Addressing** | 380d | 2000-10-09 A | 2002-03-22 A | 100% | 2000-10-09 | 2002-03-22 | 380d |  | S2 | 7744h | 7744h | Rel-5 | Maurice |  |  |  |  |  |
| 4004 | 81.1.4.5.1 | Architectural issues | 235d | 2000-10-09 A | 2001-08-31 A | 100% | 2000-10-09 | 2001-08-31 | 235d | finish no earlier than 2001-03-16 | S2 | 1880h | 1880h | Rel-5 | Maurice |  |  |  |  |  |
| 4005 | 81.1.4.5.2 | Impact on HSS | 353d | 2000-11-15 A | 2002-03-22 A | 100% | 2000-11-15 | 2002-03-22 | 353d | finish no earlier than 2002-03-22 | N4 | 2824h | 2824h | Rel-5 | Kimmo |  |  |  |  |  |
| 4006 | 81.1.4.6 | **Service Examples (Work stopped)** | 304d | 2001-04-17 A | 2002-06-14 A | 100% | 2001-04-17 | 2002-06-14 | 304d |  | S1 | 4864h | 4864h | Rel-5 | Alain | IMS-Sex | 22.928 | Motorola | Mark Cataldo | IMS-Sex |
| 4007 | 81.1.4.6.1 | IMS Framework Report (work stopped) | 304d | 2001-04-17 A | 2002-06-14 A | 100% | 2001-04-17 | 2002-06-14 | 304d | finish no earlier than 2002-06-14 | S1 | 2432h | 2432h | Rel-5 | Alain | IMS-FrWk | 22.941 | SBC | Randolph Wohlert (rwohlert@tri.sbc.com) | IMS-FrWk |
| 4008 | 81.2 | **Access Security for IMS** | 190d | 2001-10-08 A | 2002-06-28 A | 100% | 2001-10-08 | 2002-06-28 | 190d |  | S3; T3 | 5640h | 5640h | Rel-5 | Mirko | IMS-ASEC |  | Ericsson | krister.boman@emw.ericsson.se | IMS-ASEC |
| 4009 | 81.2.2 | IMS impacts on UICC (ISIM application) | 185d | 2001-10-08 A | 2002-06-21 A | 100% | 2001-10-08 | 2002-06-21 | 185d | finish no earlier than 2002-06-21 | T3 | 1480h | 1480h | Rel-5 | Xavier |  | 33.102, New TS 31.103 | Vodafone | Jeremy Norris |  |
| 4010 | 81.2.3 | Deleted - SIP extensions for Integrity protection | 140d | 2001-12-17 A | 2002-06-28 A | 100% | 2001-12-17 | 2002-06-28 | 140d | finish no earlier than 2002-06-28 | N1 | 1120h | 1120h | Rel-5 | Frederic |  |  |  |  |  |
| 4011 | 81.3 | Security Aspects of Requirement for Network Configuration Independence | 130d | 2001-07-02 A | 2001-12-28 A | 100% | 2001-07-02 | 2001-12-28 | 130d | finish no earlier than 2001-12-28 | S3 | 1040h | 1040h | Rel-5 | Mirko | SEC1-NCI | 33.203 | AT&T Wireless | hugh.shieh@attws.com | SEC1-NCI |
| 4012 | 81.4 | IMS Lawful Interception | 410d | 2000-09-04 A | 2002-03-29 A | 100% | 2000-09-04 | 2002-03-29 | 410d | finish no earlier than 2002-03-29 | S3 | 3280h | 3280h | Rel-5 | Mirko | IMS-LI | 33.106, 33.107, New 33.108 | Reg TP | berthold.wilhelm@regtp.de | IMS-LI |
| 4013 | 81.5 | Charging and OAM&P for IMS | 383d | 2000-12-25 A | 2002-06-12 A | 100% | 2000-12-25 | 2002-06-12 | 383d | finish no earlier than 2002-06-12 | S5 | 3064h | 3064h | Rel-5 | Mirko | IMS-OAM | 32-series |  |  | IMS-OAM |
| 4014 | 81.6 | **Multimedia codecs and protocols for conversational PS services** | 568d | 2000-07-26 A | 2002-09-27 A | 100% | 2000-07-26 | 2002-09-27 | 568d |  | S4 | 15640h | 15640h | Rel-5 | Paolo | IMS-CODEC | 26.235, 26.236 | Toshiba, Nokia | B. Aronson (Toshiba), pasi.s.ojala@nokia.com | IMS-CODEC |
| 4015 | 81.6.1 | Codecs | 427d | 2000-07-26 A | 2002-03-14 A | 100% | 2000-07-26 | 2002-03-14 | 427d | finish no earlier than 2001-03-21 | S4 | 3416h | 3416h | Rel-5 | Paolo |  | 26.235, 26.236 |  |  |  |
| 4016 | 81.6.2 | Transport protocols | 1d | 2002-03-12 A | 2002-03-12 A | 100% | 2002-03-12 | 2002-03-12 | 1d | finish no earlier than 2002-03-12 | S4 | 8h | 8h | Rel-5 | Paolo |  | 26.236 | Nokia | P. Ojala |  |
| 4017 | 81.6.4 | recommendation for QoS parameter values for various media types | 195d | 2001-12-31 A | 2002-09-27 A | 100% | 2001-12-31 | 2002-09-27 | 195d | finish no earlier than 2002-09-27 | S4 | 1560h | 1560h | Rel-5 | Paolo |  |  |  |  |  |
| 4018 | 81.6.5 | IETF: RFC 3310 (HTTP Digest Authentication using AKA) | 382d | 2000-11-24 A | 2002-05-13 A | 100% | 2000-11-24 | 2002-05-13 | 382d | finish no earlier than 2002-05-13 | N1 | 3056h | 3056h | Rel-5 | Frederic |  |  |  |  |  |
| 4019 | 81.6.6 | IETF: RFC 3329 (Security mechanism agreement for SIP connections) | 382d | 2000-11-24 A | 2002-05-13 A | 100% | 2000-11-24 | 2002-05-13 | 382d | finish no earlier than 2002-05-13 | N1 | 3056h | 3056h | Rel-5 | Frederic |  |  |  |  |  |
| 4020 | 81.7 | **SIP message compression** | 185d | 2001-09-24 A | 2002-06-07 A | 100% | 2001-09-24 | 2002-06-07 | 185d |  | S2 | 3128h | 3128h | Rel-5 | Maurice |  |  |  |  |  |
| 4021 | 81.7.1 | Stage 2 for SIP message compression | 25d | 2001-09-24 A | 2001-10-26 A | 100% | 2001-09-24 | 2001-10-26 | 25d | finish no earlier than 2001-10-26 | S2 | 200h | 200h | Rel-5 | Maurice |  |  |  |  |  |
| 4022 | 81.7.2 | Compression signalling | 181d | 2001-09-28 A | 2002-06-07 A | 100% | 2001-09-28 | 2002-06-07 | 181d | finish no earlier than 2002-06-07 | N1 | 1448h | 1448h | Rel-5 | Frederic |  |  |  |  |  |
| 4023 | 81.8 | **Stage 3 description of IMS interfaces** | 383d | 2001-03-14 A | 2002-08-30 A | 100% | 2001-03-14 | 2002-08-30 | 383d |  | NP | 29531.6h | 29531.6h | Rel-5 | Kimmo |  |  |  |  |  |
| 4024 | 81.8.1 | Cx interface (HSS to CSCF) | 135.95d | 2001-03-14 A | 2002-06-07 A | 100% | 2001-03-14 | 2002-06-07 | 135.95d | finish no earlier than 2002-06-07 | N4 | 1087.58h | 1087.58h | Rel-5 | Kimmo |  |  |  |  |  |
| 4025 | 81.8.2 | Mp interface (MRFC - MRFP) enhancements | 258d | 2001-03-14 A | 2002-03-08 A | 100% | 2001-03-14 | 2002-03-08 | 258d | finish no earlier than 2002-06-07 | N4 | 2064h | 2064h | Rel-5 | Kimmo |  |  |  |  |  |
| 4026 | 81.8.3 | Mw interface (CSCF to P-CSCF) | 323d | 2001-03-14 A | 2002-06-07 A | 100% | 2001-03-14 | 2002-06-07 | 323d | finish no earlier than 2002-06-07 | N1 | 2584h | 2584h | Rel-5 | Frederic |  |  |  |  |  |
| 4027 | 81.8.4 | Mr interface (CSCF to MRF) | 273d | 2001-03-14 A | 2002-03-29 A | 100% | 2001-03-14 | 2002-03-29 | 273d | finish no earlier than 2002-03-29 | N1 | 2184h | 2184h | Rel-5 | Frederic |  |  |  |  |  |
| 4028 | 81.8.5 | Dx interface (I-CSCF to SLF) | 323d | 2001-03-14 A | 2002-06-07 A | 100% | 2001-03-14 | 2002-06-07 | 323d | finish no earlier than 2002-06-07 | N4 | 2584h | 2584h | Rel-5 | Kimmo |  |  |  |  |  |
| 4029 | 81.8.6 | Go interface (GGSN to PCF) | 323d | 2001-03-14 A | 2002-06-07 A | 100% | 2001-03-14 | 2002-06-07 | 323d | finish no earlier than 2002-06-07 | N3 | 2584h | 2584h | Rel-5 | Gwiho |  |  |  |  |  |
| 4030 | 81.8.7 | ISC (IMS Service Control) Interface | 323d | 2001-03-14 A | 2002-06-07 A | 100% | 2001-03-14 | 2002-06-07 | 323d | finish no earlier than 2002-06-07 | N1 | 2584h | 2584h | Rel-5 | Frederic |  |  |  |  |  |
| 4031 | 81.8.8 | Sh interface (HSS to AS) | 82d | 2002-02-14 A | 2002-06-07 A | 100% | 2002-02-14 | 2002-06-07 | 82d | finish no earlier than 2002-06-07 | N4 | 656h | 656h | Rel-5 | Kimmo |  |  |  |  |  |
| 4032 | 81.8.9 | Si interface (HSS to IM-SSF) | 162.5d | 2002-01-16 A | 2002-08-30 A | 100% | 2002-01-16 | 2002-08-30 | 162.5d | finish no earlier than 2002-06-07 | N4 | 1300h | 1300h | Rel-5 | Kimmo |  |  |  |  |  |
| 4033 | 81.8.10 | Gm interface (UE to CSCF) | 323d | 2001-03-14 A | 2002-06-07 A | 100% | 2001-03-14 | 2002-06-07 | 323d | finish no earlier than 2002-06-07 | N1 | 2584h | 2584h | Rel-5 | Frederic |  |  |  |  |  |
| 4034 | 81.8.11 | Mi interface (CSCF to BGCF) | 323d | 2001-03-14 A | 2002-06-07 A | 100% | 2001-03-14 | 2002-06-07 | 323d | finish no earlier than 2002-06-07 | N1 | 2584h | 2584h | Rel-5 | Frederic |  |  |  |  |  |
| 4035 | 81.8.12 | Mj interface (BGCF to MGCF) | 323d | 2001-03-14 A | 2002-06-07 A | 100% | 2001-03-14 | 2002-06-07 | 323d | finish no earlier than 2002-06-07 | N1 | 2584h | 2584h | Rel-5 | Frederic |  |  |  |  |  |
| 4036 | 81.8.13 | Mk interface (BGCF to BGCF) | 323d | 2001-03-14 A | 2002-06-07 A | 100% | 2001-03-14 | 2002-06-07 | 323d | finish no earlier than 2002-06-07 | N1 | 2584h | 2584h | Rel-5 | Frederic |  |  |  |  |  |
| 4037 | 81.9 | Support of VHE/OSA by entities and protocols of the IMS (e.g. CSCF) | 186d | 2001-09-21 A | 2002-06-07 A | 100% | 2001-09-21 | 2002-06-07 | 186d | finish no earlier than 2002-06-07 | N5 | 1488h | 1488h | Rel-5 | Kimmo | IMS-ONOSA | 29.198, 29.998 | Ericsson | Ard.Jan.Moerdijk@eln.ericsson.se | IMS-ONOSA |

Notes:
- 4003: -
- 4004: -
- 4005: Covered by 29.228 & 29228
- 4006: -
- 4007: -
- 4008: -
- 4009: -
- 4010: CN1 is not aware of any requirements and is not doing anything on this task
- 4011: Consider security aspects in SA2 TS 23.228 clause 4.4 & annex C
- 4012: SP#17 completed
- 4013: -
- 4014: -
- 4015: -
- 4016: -
- 4017: -
- 4018: -
- 4019: -
- 4020: -
- 4021: -
- 4022: -
- 4023: -
- 4024: -
- 4025: [DAB 08-03-02] - No work required in CN4
- 4026: -
- 4027: -
- 4028: CN4#11 30/11/01: No inputs received in CN4 / 14/02/02 Completed(introduced in 29.228)
- 4029: [DAB - 23/05/03] - 100 % complete
- 4030: -
- 4031: CN4#11 30/11/01: No inputs received in CN4 / CN4#12bis 14/02/02: WID approved / 17th May 100% complete. 3GPP TS 29.329 will be sent for approval in CN#16
- 4032: SA16: Part of Rel5 only if completed in September 02. Marked as closed 12/2008 (was marked 72% complete)
- 4033: -
- 4034: -
- 4035: -
- 4036: -
- 4037: -

| ID | WBS | Task | Duration | Start | Finish | Predecessors | Complete | Baseline start | Baseline finish | Baseline duration | Constraint | Resources | Work | Actual work | Acronym | WI rapporteur name | WI rapporteur e-mail | Release | MCC resp | Acronym_3GU_Export | TSG stopped | Impacted TSs and TRs |
| --- | --- | --- | --- | --- | --- | --- | --- | --- | --- | --- | --- | --- | --- | --- | --- | --- | --- | --- | --- | --- | --- | --- |
| 4038 | 81.10 | **CAMEL control of IMS services** | 365d | 2001-04-16 A | 2002-09-06 A |  | 100% | 2001-04-16 | 2002-09-06 | 365d |  | N2 | 9952h | 9952h | IMS-CAMEL | Lucent | Angelica Remoquillo | Rel-5 | Kimmo | IMS-CAMEL |  |  |
| 4039 | 81.10.1 | Stage2 work 'general' | 365d | 2001-04-16 A | 2002-09-06 A |  | 100% | 2001-04-16 | 2002-09-06 | 365d | finish no earlier than 2002-09-06 | N2 | 2920h | 2920h |  |  |  | Rel-5 | Kimmo |  |  |  |
| 4040 | 81.10.2 | Stage3 work 'CAP' | 175d | 2002-01-07 A | 2002-09-06 A |  | 100% | 2002-01-07 | 2002-09-06 | 175d | finish no earlier than 2002-09-06 | N2 | 1400h | 1400h |  |  |  | Rel-5 | Kimmo |  |  |  |
| 4041 | 81.10.3 | Stage2 work 'Si interface' | 175d | 2002-01-07 A | 2002-09-06 A |  | 100% | 2002-01-07 | 2002-09-06 | 175d | finish no earlier than 2002-09-06 | N2 | 1400h | 1400h |  |  |  | Rel-5 | Kimmo |  |  |  |
| 4042 | 81.10.4 | Stage3 work 'Si interface' | 82d | 2002-02-14 A | 2002-06-07 A |  | 100% | 2002-02-14 | 2002-06-07 | 82d | finish no earlier than 2002-06-07 | N4 | 656h | 656h |  |  |  | Rel-5 | Kimmo |  |  |  |
| 4043 | 81.10.5 | Deleted - SDM issues for CAMEL control of IMS | 82d | 2002-02-14 A | 2002-06-07 A |  | 100% | 2002-02-14 | 2002-06-07 | 82d | finish no earlier than 2002-06-07 | N4 | 656h | 656h |  |  |  | Rel-5 | Kimmo |  | NP-17 |  |
| 4044 | 81.11 | Pre-pay/real-time charging in IMS | 196d | 2001-06-15 A | 2002-03-15 A |  | 100% | 2001-06-15 | 2002-03-15 | 196d | finish no earlier than 2002-03-15 | S1 | 1568h | 1568h |  |  |  | Rel-5 | Alain |  |  |  |
| 4045 | 81.12 | **IMS Charging** | 289d | 2001-08-06 A | 2002-09-12 A |  | 100% | 2001-08-06 | 2002-09-12 | 289d |  | S2; S5 | 8944h | 8944h | OAM-CH | T-Mobile | karl-heinz.nenner@t-mobile.de | Rel-5 | Mirko | OAM-CH |  | 32.225 |
| 4046 | 81.12.1 | Charging Implications of IMS architecture | 75d | 2001-08-06 A | 2001-11-16 A |  | 100% | 2001-08-06 | 2001-11-16 | 75d | finish no earlier than 2001-11-16 | S2 | 600h | 600h |  |  |  | Rel-5 | Maurice |  |  |  |
| 4047 | 81.12.2 | Charging management for IMS (off-line & on-line) | 214d | 2001-11-19 A | 2002-09-12 A | 4046 | 100% | 2001-11-19 | 2002-09-12 | 214d | finish no earlier than 2002-09-12 | S5 | 1712h | 1712h |  |  |  | Rel-5 | Mirko |  |  | 32.225 |
| 4048 | 86.1.6.10 | Billing, accounting and call detail record aspects | 251d | 2001-09-27 A | 2002-09-12 A |  | 100% | 2001-09-27 | 2002-09-12 | 251d | finish no earlier than 2002-09-12 | S5 | 2008h | 2008h |  | T-Mobile | Karl-Heinz.Nenner@T-MOBILE.DE | Rel-5 | Mirko |  |  | 32.225 |
| 4049 | 81.13 | **Other IETF dependencies** | 401d | 2000-11-24 A | 2002-06-07 A |  | 100% | 2000-11-24 | 2002-06-07 | 401d |  | NP | 9624h | 9624h |  |  |  | Rel-5 |  |  |  |  |
| 4050 | 81.13.1 | IETF: draft-ietf-aaa-diameter - should be CN4 | 401d | 2000-11-24 A | 2002-06-07 A |  | 100% | 2000-11-24 | 2002-06-07 | 401d | finish no earlier than 2002-06-07 | NP | 3208h | 3208h |  |  |  | Rel-5 |  |  |  |  |
| 4051 | 81.13.2 | IETF: draft-johansson-aaa-diameter-mm-app - should be CN4 | 401d | 2000-11-24 A | 2002-06-07 A |  | 100% | 2000-11-24 | 2002-06-07 | 401d | finish no earlier than 2002-06-07 | NP | 3208h | 3208h |  |  |  | Rel-5 |  |  |  |  |
| 4052 | 81.15 | Conformance Test Aspects - Provisioning of IMS | 205d | 2002-03-18 A | 2002-12-27 A |  | 100% | 2002-03-18 | 2002-12-27 | 205d | finish no earlier than 2002-12-27 | T1 | 1640h | 1640h | IMS-TEST |  |  | Rel-5 | Ingbert | IMS-TEST |  |  |
| 4053 | 81.16 | Testing of support for IMS - prose | 270d | 2002-09-18 A | 2003-09-30 A |  | 100% | 2002-09-18 | 2003-09-30 | 270d | finish no earlier than 2003-09-30 | T1 | 2160h | 2160h |  | Anritsu | dan.fox@eu.anritsu.com | Rel-5 | Ingbert |  |  | 34.108, 34.123 |
| 4054 | 81.17 | Testing of support for IMS - TTCN | 381d | 2002-09-18 A | 2004-03-03 A |  | 100% | 2002-09-18 | 2004-03-03 | 381d | finish no earlier than 2004-03-03 | T1 | 3048h | 3048h |  | Anritsu | dan.fox@eu.anritsu.com | Rel-5 | Ingbert |  |  | 34.108, 34.123 |
| 4055 | 82 | **Extended Transparent End-to-End PS Streaming Service** | 313d? | 2002-01-03 A | 2003-03-17 A |  | 100% | 2002-01-03 | 2003-03-17 | 313d? |  | S4 | 6224h | 6224h | PSS-E | Ericsson | olle.franceschi@ericsson.com | Rel-5 | Paolo | PSS-E |  | 26.233, 26.234 |
| 4056 | 82.1 | **Stage 1 for Extended Transparent End-to-End PS Streaming Service** | 86d? | 2002-11-18 A | 2003-03-17 A |  | 100% | 2002-11-18 | 2003-03-17 | 86d? |  | S1 | 1376h | 1376h |  | Vodafone | stephen.wolak@vodafone.com | Rel-5 | Alain |  |  | 22.233 |
| 4057 | 1022.1.1 | Interaction with other services | 86d? | 2002-11-18 A | 2003-03-17 A |  | 100% | 2002-11-18 | 2003-03-17 | 86d? | finish no earlier than 2003-03-17 | S1 | 688h | 688h |  | Vodafone | stephen.wolak@vodafone.com | Rel-5 | Alain |  |  | 22.233 |
| 4058 | 82.2 | Stage 2 (version Rel-5 of TS 26.234) | 51d | 2002-01-03 A | 2002-03-14 A |  | 100% | 2002-01-03 | 2002-03-14 | 51d | finish no earlier than 2002-03-26 | S4 | 408h | 408h |  |  |  | Rel-5 | Paolo |  |  | 26.234 |
| 4059 | 82.3 | RTP usage model | 242d | 2002-01-03 A | 2002-12-06 A |  | 100% | 2002-01-03 | 2002-12-06 | 242d | finish no earlier than 2002-12-06 | S4 | 1936h | 1936h |  |  |  | Rel-5 | Paolo |  |  | 26.937 |
| 4060 | 83 | **Rel-5 Open Service Access (OSA) enhancements** | 955d | 1999-04-27 A | 2002-12-20 A |  | 100% | 1999-04-27 | 2002-12-20 | 955d |  | S1; S3 | 72648h | 72648h | OSA1 | Siemens | joerg.swetina@neclab.eu | Rel-5 | Alain | OSA1 |  | 22.127, 23.127, 29.198-x, 29.998-x |
| 4061 | 83.1 | General Stage 2 for Rel-5 | 194d | 2001-09-11 A | 2002-06-07 A |  | 100% | 2001-09-11 | 2002-06-07 | 194d |  | S2 | 1232h | 1232h |  |  |  | Rel-5 | Maurice |  |  |  |

Notes:
- 4038: -
- 4039: DAB 12.12.01 split into cn4 and cn2 parts
- 4040: DAB 12.12.01 split into cn4 and cn2 parts
- 4041: DAB 12.12.01 split into cn4 and cn2 parts
- 4042: [DAB 08-03-02] - UID 12004 is MASTER of UID 14998 / 17 May need to be recearch possible impact on 23.008 & 23.016, changes to 29.002 are done.
- 4043: Marked as stopped 12/2008
- 4044: Marked as closed 12/2008 (was marked 60% complete)
- 4045: -
- 4046: -
- 4047: -
- 4048: -
- 4049: Was introduced at SP#13 by Ileana Leuca (exact position in the WP and related WG have to be defined)
- 4050: Marked as closed 12/2008 (was marked 90% complete)
- 4051: Marked as closed 12/2008 (was marked 50% complete)
- 4052: The task is a BB, individual work items were considered but are constrained by lack of supporting companies. Marked as stopped 12/2008
- 4053: Marked as stopped 12/2008
- 4054: Marked as stopped 12/2008
- 4055: -
- 4056: 2nd resp SA4
- 4057: 2nd resp SA4. Marked as closed 12/2008 (was marked 65% complete)
- 4058: 2nd resp SA2
- 4059: Marked as closed 12/2008 (was marked 90% complete)
- 4060: -
- 4061: Marked as closed 12/2008 (was marked 47% complete)

| ID | WBS | Task | Duration | Start | Finish | Predecessors | Complete | Baseline start | Baseline finish | Baseline duration | Constraint | Resources | Work | Actual work | Acronym | Release | MCC resp | Acronym_3GU_Export | Impacted TSs and TRs | WI rapporteur name | WI rapporteur e-mail |
| --- | --- | --- | --- | --- | --- | --- | --- | --- | --- | --- | --- | --- | --- | --- | --- | --- | --- | --- | --- | --- | --- |
| 4062 | 83.2 | **OSA APIs for Multimedia Call Control** | 499d | 2000-07-11 A | 2002-06-07 A |  | 100% | 2000-07-11 | 2002-06-07 | 499d |  | S2 | 5960h | 5960h | OSA1-CSCF | Rel-5 | Maurice | OSA1-CSCF |  |  |  |
| 4063 | 83.2.1 | Stage 1 for OSA APIs for Multimedia Call Control | 438d | 2000-07-11 A | 2002-03-14 A |  | 100% | 2000-07-11 | 2002-03-14 | 438d | finish no earlier than 2002-03-14 | S1 | 3504h | 3504h |  | Rel-5 | Alain |  | 22.127 | Siemens | Manfred.leitgeb@siemens.at |
| 4064 | 83.2.2 | Stages 2 and 3 for Multimedia Call Control | 194d | 2001-09-11 A | 2002-06-07 A |  | 100% | 2001-09-11 | 2002-06-07 | 194d | finish no earlier than 2002-06-07 | N5 | 1552h | 1552h |  | Rel-5 | Kimmo |  | 29.198-04 |  |  |
| 4065 | 83.3 | Generic user interaction - Stage 3 | 194d | 2001-09-11 A | 2002-06-07 A |  | 100% | 2001-09-11 | 2002-06-07 | 194d | finish no earlier than 2002-06-07 | N5 | 1552h | 1552h |  | Rel-5 | Kimmo |  | 29.198-05 |  |  |
| 4066 | 83.4 | OSA Charging - Stage 3 | 194d | 2001-09-11 A | 2002-06-07 A |  | 100% | 2001-09-11 | 2002-06-07 | 194d | finish no earlier than 2002-06-07 | N5 | 1552h | 1552h |  | Rel-5 | Kimmo |  | 29.198-12 |  |  |
| 4067 | 83.5 | Call Control Service Mapping; Multiparty Call Control SIP - Stage 3 | 194d | 2001-09-11 A | 2002-06-07 A |  | 100% | 2001-09-11 | 2002-06-07 | 194d | finish no earlier than 2002-06-07 | N5 | 1552h | 1552h |  | Rel-5 | Kimmo |  | 29.998-04-4 |  |  |
| 4068 | 83.6 | WSDL APIs for SOAP/HTTP - Stage 3 | 455d | 2000-09-11 A | 2002-06-07 A |  | 100% | 2000-09-11 | 2002-06-07 | 455d | finish no earlier than 2002-06-07 | N5 | 3640h | 3640h |  | Rel-5 | Kimmo |  | 29.198, 29.998 |  |  |
| 4069 | 83.7 | **OSA Security** | 639d | 2000-07-11 A | 2002-12-20 A |  | 100% | 2000-07-11 | 2002-12-20 | 639d |  | S3 | 15000h | 15000h | OSA1-SEC | Rel-5 | Mirko | OSA1-SEC | 33.102 | Ericsson | colin.blanchard@bt.com |
| 4070 | 83.7.1 | Stage 1 for OSA Security | 349d | 2000-07-11 A | 2001-11-09 A |  | 100% | 2000-07-11 | 2001-11-09 | 349d | finish no earlier than 2001-11-09 | S1 | 2792h | 2792h |  | Rel-5 | Alain |  | 22.127 | Siemens | Manfred.leitgeb@siemens.at |
| 4071 | 83.7.2 | OSA Stage 3 | 430d | 2000-10-23 A | 2002-06-14 A |  | 100% | 2000-10-23 | 2002-06-14 | 430d | finish no earlier than 2002-06-14 | S3 | 3440h | 3440h |  | Rel-5 | Mirko |  | 33.102 | BT, Ericsson | colin.blanchard@bt.com |
| 4072 | 83.7.3 | security related SCF(s) definition | 186d | 2001-09-21 A | 2002-06-07 A |  | 100% | 2001-09-21 | 2002-06-07 | 186d | finish no earlier than 2002-06-07 | N5 | 1488h | 1488h |  | Rel-5 | Kimmo |  | 29.198, 29.998 | Ericsson | Ard.Jan.Moerdijk@eln.ericsson.se |
| 4073 | 83.7.4 | OSA changes required from supporting platforms, e.g. gsmSCF, HLR | 69d | 2000-09-11 A | 2000-12-14 A |  | 100% | 2000-09-11 | 2000-12-14 | 69d | finish no earlier than 2000-12-14 | S3 | 552h | 552h |  | Rel-5 | Mirko |  | 33.102 | BT, Ericsson | colin.blanchard@bt.com |
| 4074 | 1023.7.5 | OSA Security (moved from Rel-6) | 202d | 2002-03-14 A | 2002-12-20 A |  | 100% | 2002-03-14 | 2002-12-20 | 202d | finish no earlier than 2002-12-20 | S3 | 1616h | 1616h |  | Rel-5 | Mirko |  | 33.102 | BT, Ericsson | colin.blanchard@bt.com |
| 4075 | 83.8 | **Interactions OSA - e-commerce** | 815d | 1999-04-27 A | 2002-06-07 A |  | 100% | 1999-04-27 | 2002-06-07 | 815d |  | S2 | 6152h | 6152h | OSA1-ECOM | Rel-5 | Maurice | OSA1-ECOM |  |  |  |
| 4076 | 83.8.1 | Stage 1 for Interactions OSA - e-commerce | 439d | 1999-04-27 A | 2000-12-28 A |  | 100% | 1999-04-27 | 2000-12-28 | 439d | finish no earlier than 2000-12-28 | S1 | 3504h | 3504h |  | Rel-5 | Alain |  | 22.127 | Siemens | joerg.swetina@neclab.eu |
| 4077 | 83.8.2 | Stages 2 and 3 for Interactions OSA - e-commerce | 186d | 2001-09-21 A | 2002-06-07 A |  | 100% | 2001-09-21 | 2002-06-07 | 186d | finish no earlier than 2002-06-07 | N5 | 1488h | 1488h |  | Rel-5 | Kimmo |  | 29.198, 29.998 | Ericsson | Ard.Jan.Moerdijk@eln.ericsson.se |
| 4078 | 83.9 | Policy Management - Stage 3 | 194d | 2001-09-11 A | 2002-06-07 A |  | 100% | 2001-09-11 | 2002-06-07 | 194d | finish no earlier than 2002-06-07 | N5 | 1552h | 1552h |  | Rel-5 | Kimmo |  | 29.198-13 |  |  |
| 4079 | 83.10 | Presence and Availability Management (PAM) - Stage 3 | 194d | 2001-09-11 A | 2002-06-07 A |  | 100% | 2001-09-11 | 2002-06-07 | 194d | finish no earlier than 2002-06-07 | N5 | 1552h | 1552h |  | Rel-5 | Kimmo |  | 29.198-14 |  |  |
| 4080 | 83.11 | **LCS - OSA interfaces** | 455d | 2000-09-11 A | 2002-06-07 A |  | 100% | 2000-09-11 | 2002-06-07 | 455d |  | S1 | 5656h | 5656h | OSA1-LCSI | Rel-5 | Alain | OSA1-LCSI |  | Siemens | joerg.swetina@neclab.eu |
| 4081 | 83.11.1 | Stage 1 for LCS - OSA interfaces | 65d | 2000-09-11 A | 2000-12-08 A |  | 100% | 2000-09-11 | 2000-12-08 | 65d | finish no earlier than 2000-12-08 | S1 | 520h | 520h |  | Rel-5 | Alain |  | 22.127 | Siemens | joerg.swetina@neclab.eu |
| 4082 | 83.11.2 | Stage 2 for LCS - OSA interfaces | 1d | 2000-12-11 A | 2000-12-11 A | 4081 | 100% | 2000-12-11 | 2000-12-11 | 1d | finish no earlier than 2000-12-11 | S2 | 8h | 8h |  | Rel-5 | Maurice |  | 23.127 | Ericsson | Christophe GOURRAUD |
| 4083 | 83.11.3 | Stage 3 for LCS - OSA interfaces | 186d | 2001-09-21 A | 2002-06-07 A | 4082 | 100% | 2001-09-21 | 2002-06-07 | 186d | finish no earlier than 2002-06-07 | N5 | 1488h | 1488h |  | Rel-5 | Kimmo |  | 29.198, 29.998 | Ericsson | Ard.Jan.Moerdijk@eln.ericsson.se |
| 4084 | 1023.12 | Access to User Profile | 145d | 2001-06-01 A | 2001-12-20 A |  | 100% | 2001-06-01 | 2001-12-20 | 145d | finish no earlier than 2001-12-20 | S1 | 1160h | 1160h | OSA2-UP | Rel-5 | Alain | OSA2-UP |  |  |  |
| 4085 | 1023.13 | **Retrieval of Terminal capabilities** | 634d | 2000-07-11 A | 2002-12-13 A |  | 100% | 2000-07-11 | 2002-12-13 | 634d |  | S2 | 10808h | 10808h | OSA2-TC | Rel-5 | Maurice | OSA2-TC |  |  |  |
| 4086 | 1023.13.1 | Stage 1 for Retrieval of Terminal capabilities | 132d | 2000-07-11 A | 2001-01-10 A |  | 100% | 2000-07-11 | 2001-01-10 | 132d | finish no earlier than 2001-01-10 | S1 | 1056h | 1056h |  | Rel-5 | Alain |  | 22.127 | Siemens | joerg.swetina@neclab.eu |
| 4087 | 1023.13.2 | Stages 2 and 3 for Retrieval of Terminal capabilities | 321d | 2001-09-21 A | 2002-12-13 A | 4086 | 100% | 2001-09-21 | 2002-12-13 | 321d | finish no earlier than 2002-12-13 | N5 | 2568h | 2568h |  | Rel-5 | Kimmo |  | 29.198, 29.998 | Ericsson | Ard.Jan.Moerdijk@eln.ericsson.se |
| 4088 | 1023.13.3 | Provisioning of the terminal capabilities | 445d | 2001-04-02 A | 2002-12-13 A |  | 100% | 2001-04-02 | 2002-12-13 | 445d | finish no earlier than 2002-12-13 | T2 | 3560h | 3560h |  | Rel-5 |  |  | 23.057 |  |  |

Notes:
- 4062: For Rel5 even if completed by March
- 4063: -
- 4064: -
- 4065: -
- 4066: -
- 4067: -
- 4068: -
- 4069: SP#8 approved WID
- 4070: -
- 4071: SP#8 approved WID
- 4072: -
- 4073: SP#8 approved WID
- 4074: SP#8 approved WID
- 4075: -
- 4076: Marked as closed 12/2008 (was marked 95% complete)
- 4077: -
- 4078: -
- 4079: -
- 4080: az: CN#13 - changed to Rel5
- 4081: -
- 4082: az 24/05/01: Rel4 completion 90->100%.
- 4083: -
- 4084: -
- 4085: -
- 4086: -
- 4087: -
- 4088: According to T2 SWG1 M. Cataldo this is automatically supported by the MExE support of UAProf therefore 100% complete

| ID | WBS | Task | Duration | Start | Finish | Predecessors | Complete | Baseline start | Baseline finish | Baseline duration | Constraint | Resources | Work | Actual work | Acronym | WI rapporteur name | WI rapporteur e-mail | Release | MCC resp | Acronym_3GU_Export | Impacted TSs and TRs |
| --- | --- | --- | --- | --- | --- | --- | --- | --- | --- | --- | --- | --- | --- | --- | --- | --- | --- | --- | --- | --- | --- |
| 4089 | 84 | **CAMEL phase 4** | 625d | 2000-04-17 A | 2002-09-06 A |  | 100% | 2000-04-17 | 2002-09-06 | 625d |  | S1 | 41104h | 41104h | CAMEL4 | Nokia | keijo.palviainen@nokia.com | Rel-5 | Alain | CAMEL4 |  |
| 4090 | 84.1 | Service requirements | 565d | 2000-04-17 A | 2002-06-14 A |  | 100% | 2000-04-17 | 2002-06-14 | 565d | finish no earlier than 2002-06-14 | S1 | 4520h | 4520h |  |  |  | Rel-5 | Alain |  |  |
| 4091 | 84.2 | Call Party Handling | 500d | 2000-07-10 A | 2002-06-07 A |  | 100% | 2000-07-10 | 2002-06-07 | 500d | finish no earlier than 2002-06-07 | N2 | 4000h | 4000h | CAMEL4-CPH |  |  | Rel-5 | Kimmo | CAMEL4-CPH |  |
| 4092 | 84.3 | Mid call procedure for MO and MT calls | 495d | 2000-07-17 A | 2002-06-07 A |  | 100% | 2000-07-17 | 2002-06-07 | 495d | finish no earlier than 2002-06-07 | N2 | 3960h | 3960h | CAMEL4-MCP |  |  | Rel-5 | Kimmo | CAMEL4-MCP |  |
| 4093 | 84.4 | Interactions with Optimal Routing | 430d | 2000-07-17 A | 2002-03-08 A |  | 100% | 2000-07-17 | 2002-03-08 | 430d | finish no earlier than 2002-03-08 | N2 | 3440h | 3440h | CAMEL4-IOR |  |  | Rel-5 | Kimmo | CAMEL4-IOR |  |
| 4094 | 84.5 | Inclusion of flexible tone injection | 430d | 2000-07-17 A | 2002-03-08 A |  | 100% | 2000-07-17 | 2002-03-08 | 430d | finish no earlier than 2002-03-08 | N2 | 3440h | 3440h | CAMEL4-IFTI |  |  | Rel-5 | Kimmo | CAMEL4-IFTI |  |
| 4095 | 84.6 | CSE control over MT SMS | 430d | 2000-07-17 A | 2002-03-08 A |  | 100% | 2000-07-17 | 2002-03-08 | 430d | finish no earlier than 2002-03-08 | N2 | 3440h | 3440h | CAMEL4-CCSMS |  |  | Rel-5 | Kimmo | CAMEL4-CCSMS |  |
| 4096 | 84.7 | Notification of GPRS mobility management to CSE | 331d | 2001-03-02 A | 2002-06-07 A |  | 100% | 2001-03-02 | 2002-06-07 | 331d | finish no earlier than 2002-06-07 | N2 | 2648h | 2648h | CAMEL4-NMM |  |  | Rel-5 | Kimmo | CAMEL4-NMM |  |
| 4097 | 84.8 | Provision of location information of called subscriber | 266d | 2001-03-02 A | 2002-03-08 A |  | 100% | 2001-03-02 | 2002-03-08 | 266d | finish no earlier than 2002-03-08 | N2 | 2128h | 2128h | CAMEL4-LOCB |  |  | Rel-5 | Kimmo | CAMEL4-LOCB |  |
| 4098 | 84.9 | Inclusion of ODB data in the CSE_HLR interface | 175d | 2001-07-09 A | 2002-03-08 A |  | 100% | 2001-07-09 | 2002-03-08 | 175d | finish no earlier than 2002-03-08 | N2 | 1400h | 1400h | CAMEL4-ODB |  |  | Rel-5 | Kimmo | CAMEL4-ODB |  |
| 4099 | 84.10 | Location information during an ongoing call (Handover DP) | 280d | 2001-05-14 A | 2002-06-07 A |  | 100% | 2001-05-14 | 2002-06-07 | 280d | finish no earlier than 2002-06-07 | N2 | 2240h | 2240h | CAMEL4-HODP |  |  | Rel-5 | Kimmo | CAMEL4-HODP |  |
| 4100 | 84.11 | GPRS Any Time Interrogation | 240d | 2001-07-09 A | 2002-06-07 A |  | 100% | 2001-07-09 | 2002-06-07 | 240d | finish no earlier than 2002-06-07 | N2 | 1920h | 1920h | CAMEL4-ATI |  |  | Rel-5 | Kimmo | CAMEL4-ATI |  |
| 4101 | 84.12 | Transfer of IMEI (with SW version) to CSE (CAMEL4-ATI) | 240d | 2001-07-09 A | 2002-06-07 A |  | 100% | 2001-07-09 | 2002-06-07 | 240d | finish no earlier than 2002-06-07 | N2 | 1920h | 1920h |  |  |  | Rel-5 | Kimmo |  |  |
| 4102 | 84.13 | Handling of partial implementations of CAMEL4 | 131d | 2002-03-08 A | 2002-09-06 A |  | 100% | 2002-03-08 | 2002-09-06 | 131d | finish no earlier than 2002-06-07 | N2 | 1048h | 1048h | CAMEL4-SUB |  |  | Rel-5 | Kimmo | CAMEL4-SUB |  |
| 4103 | 85 | **Rel-5 MExE enhancements** | 250d | 2001-03-26 A | 2002-03-08 A |  | 100% | 2001-03-26 | 2002-03-08 | 250d |  | T2 | 2880h | 2880h | MEXE5 |  |  | Rel-5 | Kimmo | MEXE5 |  |
| 4104 | 85.1 | MExE Rel-5 Improvements and Investigations | 110d | 2001-03-26 A | 2002-03-08 A |  | 100% | 2001-03-26 | 2002-03-08 | 110d | finish no earlier than 2001-12-17 | T2 | 880h | 880h | MEXE5-ENHANC | Motorola | Mark Cataldo | Rel-5 | Kimmo | MEXE5-ENHANC | 22.057, 23.057 |
| 4105 | 86 | **Wideband Telephony Service - AMR** | 1036d | 2000-01-01 A | 2003-12-19 A |  | 100% | 2000-01-01 | 2003-12-19 | 1036d |  | S4 | 75408h | 75408h | AMRWB | Siemens | Imre.Varga@mch.siemens.de | Rel-5 | Paolo | AMRWB |  |
| 4106 | 86.1 | **Specification** | 636d | 2000-01-01 A | 2002-06-07 A |  | 100% | 2000-01-01 | 2002-06-07 | 636d |  | S4 | 19984h | 19984h |  |  |  | Rel-5 | Paolo |  |  |
| 4107 | 86.1.1 | Stage 1 for Wideband Telephony Service - AMR | 125d | 2001-10-01 A | 2002-03-22 A |  | 100% | 2001-10-01 | 2002-03-22 | 125d | finish no earlier than 2002-03-22 | S1 | 1000h | 1000h |  |  |  | Rel-5 | Alain |  |  |
| 4108 | 86.1.2 | **Stage 2 for Wideband Telephony Service - AMR** | 77d | 2000-01-03 A | 2000-04-17 A |  | 100% | 2000-01-03 | 2000-04-17 | 77d |  | S4 | 1232h | 1232h |  |  |  | Rel-5 | Paolo |  |  |
| 4109 | 86.1.2.1 | Design Constraints for Wideband Telephony Service - AMR | 27d | 2000-01-03 A | 2000-02-07 A |  | 100% | 2000-01-03 | 2000-02-07 | 27d |  | S4 | 208h | 208h |  |  |  | Rel-5 | Paolo |  |  |
| 4110 | 86.1.2.2 | General Description for Wideband Telephony Service - AMR | 51d | 2000-02-07 A | 2000-04-17 A | 4109 | 100% | 2000-02-07 | 2000-04-17 | 51d | start no earlier than 2000-09-25 | S4 | 408h | 408h |  |  |  | Rel-5 | Paolo |  |  |
| 4111 | 86.1.3 | Feasibility Study for Wideband Telephony Service - AMR | 26d | 2000-04-28 A | 2000-06-02 A | 4110 | 100% | 2000-04-28 | 2000-06-02 | 26d | finish no earlier than 2000-06-02 | S4 | 208h | 208h |  |  |  | Rel-5 | Paolo |  | 26.901 |
| 4112 | 86.1.4 | N1 Aspects for Wideband Telephony Service - AMR | 66d | 2001-09-21 A | 2001-12-21 A |  | 100% | 2001-09-21 | 2001-12-21 | 66d | finish no earlier than 2001-12-21 | N1 | 528h | 528h |  |  |  | Rel-5 | Frederic |  |  |
| 4113 | 86.1.5 | N4 work for Wideband Telephony Service - AMR | 83d | 2002-02-13 A | 2002-06-07 A |  | 100% | 2002-02-13 | 2002-06-07 | 83d | finish no earlier than 2002-06-07 | N4 | 664h | 664h |  |  |  | Rel-5 | Kimmo |  |  |

Notes:
- 4089: -
- 4090: -
- 4091: -
- 4092: -
- 4093: -
- 4094: -
- 4095: -
- 4096: -
- 4097: -
- 4098: Added on May 29, 2001
- 4099: -
- 4100: -
- 4101: -
- 4102: stage2 and stage3 CRs for approval at CN#17
- 4103: -
- 4104: -
- 4105: -
- 4106: -
- 4107: -
- 4108: -
- 4109: -
- 4110: -
- 4111: S4,TD SP-000024: TR 26.901 v.4.0.0
- 4112: Some of N1 tasks: Indication of supported codecs by the MS, Bearer cap negociation, codec indication to MS... / One common set of codec negotiation procedures will be specified as in ID1657.
- 4113: CN4#11 30/11/01: No inputs to CN4 at this meeting / 14/02/02 work started 50% reached / 17 May work is done 100%

| ID | WBS | Task | Duration | Start | Finish | Predecessors | Complete | Baseline start | Baseline finish | Baseline duration | Constraint | Resources | Work | Actual work | Release | MCC resp | Acronym | Acronym_3GU_Export | Impacted TSs and TRs | TSG stopped | WI rapporteur name | WI rapporteur e-mail |
| --- | --- | --- | --- | --- | --- | --- | --- | --- | --- | --- | --- | --- | --- | --- | --- | --- | --- | --- | --- | --- | --- | --- |
| 4114 | 86.1.6 | **Codec issues** | 636d | 2000-01-03 A | 2002-06-07 A |  | 100% | 2000-01-03 | 2002-06-07 | 636d |  | S4 | 9496h | 9496h | Rel-5 | Paolo |  |  |  |  |  |  |
| 4115 | 86.1.6.1 | Codec qualification | 86d | 2000-02-02 A | 2000-05-31 A |  | 100% | 2000-02-02 | 2000-05-31 | 86d | finish no earlier than 2000-05-31 | S4 | 688h | 688h | Rel-5 | Paolo |  |  |  |  |  |  |
| 4116 | 86.1.6.2 | Codec selection tests | 102d | 2000-06-01 A | 2000-10-20 A | 4115 | 100% | 2000-06-01 | 2000-10-20 | 102d | finish no earlier than 2000-10-20 | S4 | 816h | 816h | Rel-5 | Paolo |  |  |  |  |  |  |
| 4117 | 86.1.6.3 | Codec selection | 5d | 2000-10-23 A | 2000-10-27 A | 4116 | 100% | 2000-10-23 | 2000-10-27 | 5d | finish no earlier than 2000-10-27 | S4 | 40h | 40h | Rel-5 | Paolo |  |  |  |  |  |  |
| 4118 | 86.1.6.4 | TFO AMR-WB | 63d | 2001-12-18 A | 2002-03-14 A |  | 100% | 2001-12-18 | 2002-03-14 | 63d | finish no earlier than 2002-03-14 | S4 | 504h | 504h | Rel-5 | Paolo | AMRWB-TFO | AMRWB-TFO |  |  |  |  |
| 4119 | 86.1.6.5 | Other codec issues (verif., characterization) | 441d | 2000-09-29 A | 2002-06-07 A |  | 100% | 2000-09-29 | 2002-06-07 | 441d | finish no earlier than 2002-06-07 | S4 | 3528h | 3528h | Rel-5 | Paolo |  |  | 26.976 |  |  |  |
| 4120 | 86.1.6.6 | AMR-WB and narrrowband interworking | 121d | 2001-09-27 A | 2002-03-14 A |  | 100% | 2001-09-27 | 2002-03-14 | 121d | finish no earlier than 2002-03-14 | S4 | 968h | 968h | Rel-5 | Paolo | AMRWB-IWG | AMRWB-IWG |  |  |  |  |
| 4121 | 86.1.6.7 | Interworking with fixed broadband networks | 121d | 2001-09-27 A | 2002-03-14 A |  | 100% | 2001-09-27 | 2002-03-14 | 121d | finish no earlier than 2002-03-14 | S4 | 968h | 968h | Rel-5 | Paolo |  |  |  |  |  |  |
| 4122 | 86.1.6.8 | Tones and announcements | 121d | 2001-09-27 A | 2002-03-14 A |  | 100% | 2001-09-27 | 2002-03-14 | 121d | finish no earlier than 2002-03-14 | S4 | 968h | 968h | Rel-5 | Paolo |  |  |  |  |  |  |
| 4123 | 86.1.6.9 | Deleted - WB Conferencing and WB Voice Group calls | 1d | 2000-01-03 A | 2000-01-03 A |  | 100% | 2000-01-03 | 2000-01-03 | 1d | finish no earlier than 2000-01-03 | S1 | 8h | 8h | Rel-5 | Alain |  |  |  | SP-07 |  |  |
| 4124 | 86.1.8 | **Conformance tests (CRs to 34 series)** | 74d | 2000-01-01 A | 2000-04-12 A |  | 100% | 2000-01-01 | 2000-04-12 | 74d |  | T1 | 1768h | 1768h | Rel-5 | Ingbert |  |  |  |  |  |  |
| 4125 | 86.1.8.1 | **Terminal Acoustic Characteristics** | 74d | 2000-01-01 A | 2000-04-12 A |  | 100% | 2000-01-01 | 2000-04-12 | 74d |  | S4 | 1176h | 1176h | Rel-5 | Paolo |  |  |  |  |  |  |
| 4126 | 86.1.8.1.1 | Definition for Terminal Acoustic Characteristics | 22d | 2000-01-01 A | 2000-01-31 A |  | 100% | 2000-01-01 | 2000-01-31 | 22d | finish no earlier than 2000-01-28 | S4 | 168h | 168h | Rel-5 | Paolo |  |  | 26.131 |  |  |  |
| 4127 | 86.1.8.1.2 | Test specification for Terminal Acoustic Characteristics | 52d | 2000-02-01 A | 2000-04-12 A | 4126 | 100% | 2000-02-01 | 2000-04-12 | 52d | finish no earlier than 2000-03-13 | S4 | 416h | 416h | Rel-5 | Paolo |  |  | 26.132 |  |  |  |
| 4128 | 86.2 | Floating-point ANSI-C code for the AMR-WB speech codec | 123d | 2001-09-25 A | 2002-03-14 A |  | 100% | 2001-09-25 | 2002-03-14 | 123d | finish no earlier than 2002-03-14 | S4 | 984h | 984h | Rel-5 | Paolo | AMRWB-FP | AMRWB-FP | 26.204 |  | Nokia | janne.m.vainio@nokia.com |
| 4129 | 86.3 | **Support of AMR-WB in GERAN: GMSK and 8PSK WB FR / HR** | 651d | 2000-01-03 A | 2002-06-28 A |  | 100% | 2000-01-03 | 2002-06-28 | 651d |  | GP | 23488h | 23488h | Rel-5 | Paolo | GAMRWB | GAMRWB |  |  |  |  |
| 4130 | 86.3.1 | Channel coding in 45.003 for Support of AMR-WB in GERAN: GMSK and 8PSK WB FR / HR | 591d | 2000-01-03 A | 2002-04-05 A |  | 100% | 2000-01-03 | 2002-04-05 | 591d |  | GP | 4720h | 4720h | Rel-5 | Paolo |  |  |  |  |  |  |
| 4131 | 86.3.2 | Signalling for the A interface | 391d | 2000-01-03 A | 2001-06-29 A |  | 100% | 2000-01-03 | 2001-06-29 | 391d | finish no earlier than 2001-06-29 | GP | 3120h | 3120h | Rel-5 | Paolo |  |  |  |  |  |  |
| 4132 | 86.3.3 | Signalling for Iu | 651d | 2000-01-03 A | 2002-06-28 A |  | 100% | 2000-01-03 | 2002-06-28 | 651d | finish no earlier than 2002-06-28 | GP | 5200h | 5200h | Rel-5 | Paolo |  |  |  |  |  |  |
| 4133 | 86.3.4 | Receiver performance in TS 45.005 | 325d | 2001-04-02 A | 2002-06-28 A |  | 100% | 2001-04-02 | 2002-06-28 | 325d | finish no earlier than 2002-06-28 | GP | 2600h | 2600h | Rel-5 | Paolo |  |  |  |  |  |  |
| 4134 | 86.3.5 | Link Adaptation in 45.009 | 330d | 2001-03-26 A | 2002-06-28 A |  | 100% | 2001-03-26 | 2002-06-28 | 330d | finish no earlier than 2002-06-28 | GP | 2640h | 2640h | Rel-5 | Paolo |  |  |  |  |  |  |
| 4135 | 86.4 | **Deleted - GERAN MS conformance test for AMR-WB** | 1036d | 2000-01-03 A | 2003-12-19 A |  | 100% | 2000-01-03 | 2003-12-19 | 1036d |  | GP | 16568h | 16568h | Rel-5 | Paolo |  |  |  |  |  |  |
| 4136 | 86.4.1 | Deleted - MS test for AMR-WB | 1036d | 2000-01-03 A | 2003-12-19 A |  | 100% | 2000-01-03 | 2003-12-19 | 1036d | finish no earlier than 2003-12-19 | GP | 8280h | 8280h | Rel-5 | Paolo |  |  |  | GP-17 |  |  |
| 4137 | 86.5 | GERAN BTS conformance test for AMR-WB | 762d | 2000-01-03 A | 2002-12-02 A |  | 100% | 2000-01-03 | 2002-12-02 | 762d |  | GP | 6096h | 6096h | Rel-5 | Paolo |  |  |  |  |  |  |

Notes:
- 4114: -
- 4115: -
- 4116: -
- 4117: -
- 4118: -
- 4119: ANSI C-Code , Test Sequences, Speech Transcoding Functions, Error Concealment of lost frames, Source Controlled Bit-Rate Operation, Voice Activity Detector, Frame Structure
- 4120: -
- 4121: -
- 4122: -
- 4123: -
- 4124: -
- 4125: -
- 4126: -
- 4127: -
- 4128: -
- 4129: -
- 4130: 50098 -> 50298
- 4131: -
- 4132: -
- 4133: -
- 4134: -
- 4135: Not started 02/2003. Marked as stopped 12/2008
- 4136: Marked as stopped 12/2008
- 4137: -

| ID | WBS | Task | Duration | Start | Finish | Complete | Baseline start | Baseline finish | Baseline duration | Constraint | Resources | Work | Actual work | Acronym | Release | MCC resp | Acronym_3GU_Export | WI rapporteur name | WI rapporteur e-mail |
| --- | --- | --- | --- | --- | --- | --- | --- | --- | --- | --- | --- | --- | --- | --- | --- | --- | --- | --- | --- |
| 4138 | 11 | **Rel-5 Terminal interfaces** | 223d | 2001-05-14 A | 2002-03-20 A | 100% | 2001-05-14 | 2002-03-20 | 223d |  | T2 | 3568h | 3568h | TLM5 | Rel-5 | Kimmo | TI, TLM5 |  |  |
| 4139 | 87 | Terminal local model enhancements | 223d | 2001-05-14 A | 2002-03-20 A | 100% | 2001-05-14 | 2002-03-20 | 223d | finish no earlier than 2002-03-20 | T2 | 1784h | 1784h | TLM5 | Rel-5 |  | TLM5 |  |  |
| 4140 | 88 | **Rel-5 Location Services enhancements** | 845d | 2000-04-03 A | 2003-06-27 A | 100% | 2000-04-03 | 2003-06-27 | 845d |  | S2; S1; S3; S5; N4; R2; R3; GP | 237560h | 237560h | LCS1 | Rel-5 | Maurice | LCS1, Rel-5 | Nokia | Jan Kall |
| 4141 | 88.1 | **UE positioning for Rel-5 Location Services enhancements** | 315d | 2001-01-15 A | 2002-03-29 A | 100% | 2001-01-15 | 2002-03-29 | 315d |  | R2 | 6120h | 6120h | LCS1-Uepos | Rel-5 | Issam | LCS1-Uepos, Rel-5 |  |  |
| 4142 | 88.1.1 | UE positioning enhancements for 1.28 Mcps TDD | 255d | 2001-04-09 A | 2002-03-29 A | 100% | 2001-04-09 | 2002-03-29 | 255d | finish no earlier than 2002-03-29 | R2 | 2040h | 2040h | LCS-128Pos | Rel-5 | Yong-Jun | LCS-128Pos | CATT | Xiaohua Mei |
| 4143 | 88.1.2 | Open SMLC-SRNC Interface within the UTRAN to support A-GPS Positioning | 195d | 2001-01-15 A | 2001-10-12 A | 100% | 2001-01-15 | 2001-10-12 | 195d |  | R2 | 1560h | 1560h | LCS-INTF | Rel-5 | Yong-Jun | LCS-INTF | Qualcomm | Kirk Burroughs |
| 4144 | 88.2 | **Event Based and Periodic LCS** | 535d | 2000-05-22 A | 2002-06-07 A | 100% | 2000-05-22 | 2002-06-07 | 535d |  | S1; S2; N4 | 14848h | 14848h | LCS1-EBP | Rel-5 | Alain | LCS1-EBP | Pacific Bell Wireless | Randolph Wohlert (rwohlert@tri.sbc.com) |
| 4145 | 88.2.1 | Stage 1 for Event based and Periodic LCS | 130d | 2000-05-22 A | 2000-11-17 A | 100% | 2000-05-22 | 2000-11-17 | 130d | finish no earlier than 2000-07-21 | S1 | 1040h | 1040h |  | Rel-5 | Alain |  | Pacific Bell Wireless | Randolph Wohlert (rwohlert@tri.sbc.com) |
| 4146 | 88.2.2 | Stage 2 for Event based and Periodic LCS | 60d | 2000-11-06 A | 2001-01-26 A | 100% | 2000-11-06 | 2001-01-26 | 60d | finish no earlier than 2001-01-26 | S2 | 480h | 480h |  | Rel-5 | Maurice |  |  |  |
| 4147 | 88.2.3 | Impact on MAP | 61d | 2002-03-15 A | 2002-06-07 A | 100% | 2002-03-15 | 2002-06-07 | 61d | finish no earlier than 2002-06-07 | N4 | 488h | 488h |  | Rel-5 | Kimmo |  |  |  |
| 4148 | 88.3 | **Location Services for GERAN in A/Gb Mode** | 485d | 2000-04-03 A | 2002-02-08 A | 100% | 2000-04-03 | 2002-02-08 | 485d |  | GP | 26400h | 26400h | LCS-GERAN | Rel-5 | Paolo | LCS-GERAN | Nokia | Margaret Livingston |
| 4149 | 88.3.1 | GERAN LCS Stage 2 (first release) | 485d | 2000-04-03 A | 2002-02-08 A | 100% | 2000-04-03 | 2002-02-08 | 485d | finish no earlier than 2002-02-08 | GP; S2; G1; G2 | 15520h | 15520h |  | Rel-5 | Paolo |  | Nokia | Margaret Livingston |
| 4150 | 88.3.2 | Gb interface support for LCS | 370d | 2000-04-03 A | 2001-08-31 A | 100% | 2000-04-03 | 2001-08-31 | 370d | finish no earlier than 2001-08-31 | GP | 2960h | 2960h |  | Rel-5 | Paolo |  | Nokia | Margaret Livingston |
| 4151 | 88.3.3 | L3 protocol support for LCS | 305d | 2000-04-03 A | 2001-06-01 A | 100% | 2000-04-03 | 2001-06-01 | 305d | finish no earlier than 2001-06-01 | GP | 2440h | 2440h |  | Rel-5 | Paolo |  | Nokia | Margaret Livingston |
| 4152 | 88.3.4 | Stage 3 for Location Services for GERAN in A/Gb Mode | 305d | 2000-04-03 A | 2001-06-01 A | 100% | 2000-04-03 | 2001-06-01 | 305d | finish no earlier than 2001-06-01 | GP | 2440h | 2440h |  | Rel-5 | Paolo |  | Nokia | Margaret Livingston |
| 4153 | 88.4 | **Location Services for GERAN in Iu Mode** | 585d | 2000-04-03 A | 2002-06-28 A | 100% | 2000-04-03 | 2002-06-28 | 585d |  | S2; G1; G2; R2; R3 | 64264h | 64264h |  | Rel-5 | Paolo |  | Nokia | Margaret Livingston |
| 4154 | 88.4.1 | GERAN LCS Stage 2 | 585d | 2000-04-03 A | 2002-06-28 A | 100% | 2000-04-03 | 2002-06-28 | 585d | finish no earlier than 2002-06-28 | S2; G1; G2 | 14040h | 14040h |  | Rel-5 | Paolo |  | Nokia | Margaret Livingston |
| 4155 | 88.4.2 | Iu-ps interface support for LCS | 585d | 2000-04-03 A | 2002-06-28 A | 100% | 2000-04-03 | 2002-06-28 | 585d | finish no earlier than 2002-06-28 | R2; R3 | 9360h | 9360h |  | Rel-5 | Paolo |  | Nokia | Margaret Livingston |
| 4156 | 88.4.3 | Iu-cs interface support for LCS | 585d | 2000-04-03 A | 2002-06-28 A | 100% | 2000-04-03 | 2002-06-28 | 585d | finish no earlier than 2002-06-28 | R2; R3 | 9360h | 9360h |  | Rel-5 | Paolo |  | Nokia | Margaret Livingston |
| 4157 | 88.4.4 | Iur-g interface support for LCS | 62.5d | 2002-01-23 A | 2002-04-19 A | 100% | 2002-01-23 | 2002-04-19 | 62.5d | finish no earlier than 2002-04-19 | G1; G2 | 1000h | 1000h |  | Rel-5 | Paolo |  | Nokia | Margaret Livingston |
| 4158 | 88.4.5 | RRC protocol support for LCS | 75d | 2001-08-20 A | 2001-11-30 A | 100% | 2001-08-20 | 2001-11-30 | 75d | finish no earlier than 2001-11-30 | G1; G2; R2; R3 | 2400h | 2400h |  | Rel-5 | Paolo |  | Nokia | Margaret Livingston |
| 4159 | 88.4.6 | Additional impacts on Broadcast of LCS data on packet channels | 77.5d | 2001-08-20 A | 2001-12-05 A | 100% | 2001-08-20 | 2001-12-05 | 77.5d | finish no earlier than 2001-12-05 | G1; G2; R2; R3 | 2480h | 2480h |  | Rel-5 | Paolo |  | Nokia | Margaret Livingston |
| 4160 | 88.4.7 | Stage 3 for Location Services for GERAN in Iu Mode | 69.5d | 2002-03-25 A | 2002-06-28 A | 100% | 2002-03-25 | 2002-06-28 | 69.5d | finish no earlier than 2002-06-28 | G1; G2; R2; R3 | 2224h | 2224h |  | Rel-5 | Paolo |  | Nokia | Margaret Livingston |
| 4161 | 88.5 | **GERAN MS Conformance test for LCS** | 280d | 2002-06-03 A | 2003-06-27 A | 100% | 2002-06-03 | 2003-06-27 | 280d |  | GP | 11200h | 11200h | LCS-GERAN-MSconf | Rel-5 | Paolo | LCS-GERAN-MSconf |  |  |
| 4162 | 88.5.1 | LCS MS test case work plan (Release 98/99/4) | 280d | 2002-06-03 A | 2003-06-27 A | 100% | 2002-06-03 | 2003-06-27 | 280d | finish no earlier than 2003-06-27 | G4; G5 | 4480h | 4480h |  | Rel-5 | Paolo |  |  |  |
| 4163 | 88.5.2 | LCS MS test cases | 280d | 2002-06-03 A | 2003-06-27 A | 100% | 2002-06-03 | 2003-06-27 | 280d | finish no earlier than 2003-06-27 | G4; G5 | 4480h | 4480h |  | Rel-5 | Paolo |  |  |  |

Notes:
- 4138: Acronym changed from "TI, TLMN5"
- 4139: - / Impacted TSs and TRs: 23.227
- 4140: . Acronym changed from "LCS1, Rel-5"
- 4141: Acronym changed from "LCS1-Uepos, Rel-5"
- 4142: - / Impacted TSs and TRs: 25.123, 25.224, 25.225, 25.302, 25.303, 25.304, 25.305, 25.331, 25.420, 25.423, 25.430, 25.433, New TR 25.859
- 4143: RP#13 completed
- 4144: -
- 4145: Evaluate Event based and Periodic LCS to be included in R00, corresponding Stage 1 description / Impacted TSs and TRs: 22.071
- 4146: Marked as closed 12/2008 (was marked 51% complete)
- 4147: Possible impact on UTRAN of LCS quality level request / 17 May No stage 2 for event-based & periodic LCS. Work 100% completefor current stage 2
- 4148: -
- 4149: -
- 4150: -
- 4151: -
- 4152: -
- 4153: -
- 4154: -
- 4155: -
- 4156: -
- 4157: FFS
- 4158: -
- 4159: -
- 4160: -
- 4161: -
- 4162: Marked as closed 12/2008 (was marked 60% complete)
- 4163: Marked as closed 12/2008 (was marked 60% complete)

| ID | WBS | Task | Duration | Start | Finish | Predecessors | Complete | Baseline start | Baseline finish | Baseline duration | Constraint | Resources | Work | Actual work | Acronym | Release | MCC resp | TSG stopped | Acronym_3GU_Export | Impacted TSs and TRs | WI rapporteur name | WI rapporteur e-mail |
| --- | --- | --- | --- | --- | --- | --- | --- | --- | --- | --- | --- | --- | --- | --- | --- | --- | --- | --- | --- | --- | --- | --- |
| 4164 | 88.6 | **Deleted - GERAN BTS Conformance test for LCS** | 280d | 2002-06-03 A | 2003-06-27 A |  | 100% | 2002-06-03 | 2003-06-27 | 280d |  | GP | 11200h | 11200h | LCS-GERAN-BTSconf | Rel-5 | Paolo | GP-15 | LCS-GERAN-BTSconf |  |  |  |
| 4165 | 88.6.1 | Deleted - LCS BTS test case work plan (Release 98/99/4) | 280d | 2002-06-03 A | 2003-06-27 A |  | 100% | 2002-06-03 | 2003-06-27 | 280d | finish no earlier than 2003-06-27 | G4; G5 | 4480h | 4480h |  | Rel-5 | Paolo | GP-15 |  |  |  |  |
| 4166 | 88.6.2 | Deleted - LCS BTS test cases | 280d | 2002-06-03 A | 2003-06-27 A |  | 100% | 2002-06-03 | 2003-06-27 | 280d | finish no earlier than 2003-06-27 | G4; G5 | 4480h | 4480h |  | Rel-5 | Paolo | GP-15 |  |  |  |  |
| 4167 | 88.7 | LCS interoperation stage 2 aspects | 480d | 2000-08-28 A | 2002-06-28 A |  | 100% | 2000-08-28 | 2002-06-28 | 480d |  | S2 | 3840h | 3840h |  | Rel-5 | Maurice |  |  |  |  |  |
| 4168 | 88.8 | **LCS interoperability aspects to GERAN (LCS-GERAN)** | 480d | 2000-08-28 A | 2002-06-28 A |  | 100% | 2000-08-28 | 2002-06-28 | 480d |  | GP; S5 | 34560h | 34560h |  | Rel-5 | Paolo |  |  |  |  |  |
| 4169 | 88.8.1 | Co-ordinated development of GSM LCS Phase 2 and UMTS LCS, S2 and GERAN | 480d | 2000-08-28 A | 2002-06-28 A |  | 100% | 2000-08-28 | 2002-06-28 | 480d | finish no earlier than 2002-06-28 | GP; S2; S5; R2; R3; G2; G1 | 26880h | 26880h |  | Rel-5 | Paolo |  |  |  |  |  |
| 4170 | 88.9 | FS on LCS support in the IMS | 90d | 2001-02-12 A | 2002-01-18 A |  | 100% | 2001-02-12 | 2002-01-18 | 90d | start no earlier than 2001-02-12 | S1 | 720h | 720h |  | Rel-5 | Alain |  |  |  |  |  |
| 4171 | 88.10 | Charging and OAM&P for LCS enhancements | 201d | 2001-09-21 A | 2002-06-28 A |  | 100% | 2001-09-21 | 2002-06-28 | 201d | finish no earlier than 2002-06-28 | S5 | 1608h | 1608h | LCS1-OAM | Rel-5 | Mirko |  | LCS1-OAM | 32.200-series |  |  |
| 4172 | 88.11 | New security aspects of LCS | 446d | 2000-04-14 A | 2001-12-28 A |  | 100% | 2000-04-14 | 2001-12-28 | 446d | finish no earlier than 2001-12-28 | S3; S2 | 7136h | 7136h | LCS1-SEC | Rel-5 | Mirko |  | LCS1-SEC | 23.271, 43.059 | Nokia | valtteri.niemi@nokia.com |
| 4173 | 88.12 | Specification for the Le interface | 45d | 2002-01-14 A | 2002-03-15 A |  | 100% | 2002-01-14 | 2002-03-15 | 45d | start no earlier than 2002-01-14 | S2 | 360h | 360h | LCS1-Le | Rel-5 | Maurice |  | LCS1-Le |  |  |  |
| 4174 | 88.13 | Deleted - CHECK STATUS - Inter-GMLC interface | 153d | 2002-05-30 A | 2002-12-30 A |  | 100% | 2002-05-30 | 2002-12-30 | 153d | finish no earlier than 2002-12-30 | S2 | 1224h | 1224h |  | Rel-5 | Maurice | SP-10 |  |  |  |  |
| 4175 | 89 | **Rel-5 Security enhancements (SEC1)** | 615d | 2000-02-21 A | 2002-06-28 A |  | 100% | 2000-02-21 | 2002-06-28 | 615d |  | S3 | 29974.9h | 29974.9h |  | Rel-5 | Mirko |  |  |  | Vodafone | Peter.Howard@vodafone.com |
| 4176 | 89.1 | **Rel-5 Network Domain Security (SEC1-NDS)** | 615d | 2000-02-21 A | 2002-06-28 A |  | 100% | 2000-02-21 | 2002-06-28 | 615d |  | S3 | 25054.9h | 25054.9h |  | Rel-5 | Mirko |  |  | New 33.200 (exists also for Rel-4) | Telenor | Geir-myrdahl.koien@telenor.com |
| 4177 | 89.1.3 | Rel-5 IP network layer security (NDS/IP) (SEC1-NDS-IP) | 457d | 2000-06-15 A | 2002-03-15 A |  | 100% | 2000-06-15 | 2002-03-15 | 457d | finish no earlier than 2002-03-15 | S3 | 3656h | 3656h |  | Rel-5 | Mirko |  |  | New 33.210 | Telenor | Geir-myrdahl.koien@telenor.com |
| 4178 | 89.1.1 | **Deleted - Control plane protection in core network (e.g., GTP, CAP, MAP/IP, provided by IPsec)** | 541d | 2000-05-12 A | 2002-06-07 A |  | 100% | 2000-05-12 | 2002-06-07 | 541d |  | S3 | 7118.9h | 7118.9h |  | Rel-5 | Mirko | SP-16 |  |  |  |  |
| 4179 | 89.1.1.1 | Deleted - Main aspects of User plane protection in core network (e.g., provided by IPsec) | 290d | 2000-05-12 A | 2001-06-21 A |  | 100% | 2000-05-12 | 2001-06-21 | 290d | finish no earlier than 2001-06-21 | S3 | 2320h | 2320h |  | Rel-5 | Mirko | SP-12 |  |  |  |  |
| 4180 | 89.1.1.2 | Deleted - Integration of GTP signalling security architecture - for User plane protection in core network (e.g., provided by IPsec) | 191d | 2001-09-14 A | 2002-06-07 A |  | 100% | 2001-09-14 | 2002-06-07 | 191d | finish no earlier than 2002-06-07 | N4 | 1528h | 1528h |  | Rel-5 | Kimmo | NP-16 |  |  |  |  |
| 4181 | 89.1.2 | **Deleted - User plane protection in core network (e.g., provided by IPsec)** | 615d | 2000-02-21 A | 2002-06-28 A |  | 100% | 2000-02-21 | 2002-06-28 | 615d |  | S3 | 9360h | 9360h |  | Rel-5 | Mirko | SP-16 |  |  |  |  |
| 4182 | 89.1.2.1 | Deleted -Main aspects of User plane protection in core network (e.g., provided by IPsec) | 349d | 2000-02-21 A | 2001-06-21 A |  | 100% | 2000-02-21 | 2001-06-21 | 349d | finish no earlier than 2001-06-21 | S3 | 2792h | 2792h |  | Rel-5 | Mirko | SP-12 |  |  |  |  |
| 4183 | 89.1.2.2 | Deleted - Integration of GTP signalling security architecture - for User plane protection in core network (e.g., provided by IPsec) | 206d | 2001-09-14 A | 2002-06-28 A |  | 100% | 2001-09-14 | 2002-06-28 | 206d | finish no earlier than 2002-06-28 | N4 | 1648h | 1648h |  | Rel-5 | Kimmo | NP-16 |  |  |  |  |
| 4184 | 90 | **Intra Domain Connection of RAN Nodes to Multiple CN Nodes** | 455d | 2000-10-02 A | 2002-06-28 A |  | 100% | 2000-10-02 | 2002-06-28 | 455d |  | S2; N1; N4; R3; GP | 30232h | 30232h | IUFLEX | Rel-5 | Alain |  | IUFLEX | 23.236 | Ericsson | stephen.terrill@ericsson.com |
| 4185 | 90.1 | Overall System Architecture for Intra Domain Connection of RAN Nodes to Multiple CN Nodes | 188d | 2001-01-03 A | 2001-09-21 A |  | 100% | 2001-01-03 | 2001-09-21 | 188d | finish no earlier than 2001-06-01 | S2 | 1504h | 1504h |  | Rel-5 | Maurice |  |  |  |  |  |
| 4186 | 90.2 | Stage 3: RAN node selecting CN node | 130d | 2001-09-24 A | 2002-03-22 A | 4185 | 100% | 2001-09-24 | 2002-03-22 | 130d | finish no earlier than 2002-03-22 | R3 | 1040h | 1040h |  | Rel-5 | Juha |  |  |  | Vodafone | Brendan.McWilliams@gb.vodafone.co.uk |
| 4187 | 90.3 | N1 work for Intra Domain Connection of RAN Nodes to Multiple CN Nodes | 205d | 2001-09-17 A | 2002-06-28 A |  | 100% | 2001-09-17 | 2002-06-28 | 205d | start no earlier than 2001-09-17 | N1 | 1640h | 1640h |  | Rel-5 | Frederic |  |  | 24.008 and check 29.018 |  |  |
| 4188 | 90.4 | N4 work for Intra Domain Connection of RAN Nodes to Multiple CN Nodes | 375d | 2000-10-02 A | 2002-03-08 A |  | 100% | 2000-10-02 | 2002-03-08 | 375d | finish no earlier than 2002-03-15 | N4 | 3000h | 3000h |  | Rel-5 | Kimmo |  |  |  |  |  |

Notes:
- 4164: Not started 02/3003. Marked as stopped 12/2008
- 4165: Marked as stopped 12/2008
- 4166: Marked as stopped 12/2008
- 4167: Marked as closed 12/2008 (was marked 17% complete)
- 4168: -
- 4169: -
- 4170: Marked as closed 12/2008 (was marked 75% complete)
- 4171: -
- 4172: SP#9 updated WID S3-000609 (Location services security)
- 4173: -
- 4174: Marked as stopped 12/2008
- 4175: Added BB UE authentication and rapporteur added. TO BE DELETED
- 4176: SP#9 approved WID SP-000420 (S3-000606 Network domain security). S3#17: All due in Rel5. (WI Update at S3#18). Replaced by NDS-IP and NDS-MAP. TO BE DELETED OR MOVED TO HISTORY FILE
- 4177: SP#12 WID updated SP-000420 (S3-000606) =>SP-010326 (S3-010286)
- 4178: Marked as stopped 12/2008
- 4179: TO BE DELETED. Marked as stopped 12/2008
- 4180: Waiting for input from SA3!.... Marked as stopped 12/2008
- 4181: TO BE DELETED. Marked as stopped 12/2008
- 4182: -
- 4183: 14/02/2002 requirements are not clear/not received...Marked as closed 12/2008 (was marked 95 complete)
- 4184: No clear indication on the end date. Put to Rel5 by AS.
- 4185: -
- 4186: Not identified
- 4187: -
- 4188: DAB 12.12.01 - % complete to 66% / 14/02/02 Work completed

| ID | WBS | Task | Duration | Start | Finish | Complete | Baseline start | Baseline finish | Baseline duration | Constraint | Resources | Work | Actual work | Acronym | WI rapporteur name | WI rapporteur e-mail | Release | MCC resp | Acronym_3GU_Export | TSG stopped | Impacted TSs and TRs |
| --- | --- | --- | --- | --- | --- | --- | --- | --- | --- | --- | --- | --- | --- | --- | --- | --- | --- | --- | --- | --- | --- |
| 4189 | 90.5 | **GERAN work for Intra Domain Connection of RAN Nodes to Multiple CN Nodes** | 101d | 2002-02-08 A | 2002-06-28 A | 100% | 2002-02-08 | 2002-06-28 | 101d |  | GP | 4848h | 4848h | IDCRAN-GERAN | Ericsson | ingemar.backlund@era.ericsson.se | Rel-5 | Paolo | IDCRAN-GERAN |  |  |
| 4190 | 90.5.1 | Stage 2 (changes to ) | 101d | 2002-02-08 A | 2002-06-28 A | 100% | 2002-02-08 | 2002-06-28 | 101d | finish no earlier than 2002-06-28 | G1 | 808h | 808h |  |  |  | Rel-5 | Paolo |  |  |  |
| 4191 | 90.5.2 | 43.051 Introduction of support for IDNNS in GERAN Iu mode | 101d | 2002-02-08 A | 2002-06-28 A | 100% | 2002-02-08 | 2002-06-28 | 101d | finish no earlier than 2002-06-28 | G1 | 808h | 808h |  |  |  | Rel-5 | Paolo |  |  |  |
| 4192 | 90.5.3 | Stage 3 (changes to ) | 101d | 2002-02-08 A | 2002-06-28 A | 100% | 2002-02-08 | 2002-06-28 | 101d | finish no earlier than 2002-06-28 | G2 | 808h | 808h |  |  |  | Rel-5 | Gert |  |  |  |
| 4193 | 90.5.4 | 48.016 Use of Gb interface concepts when a network applies IDNNS | 101d | 2002-02-08 A | 2002-06-28 A | 100% | 2002-02-08 | 2002-06-28 | 101d | finish no earlier than 2002-06-28 | G2 | 808h | 808h |  |  |  | Rel-5 | Gert |  |  |  |
| 4194 | 90.5.5 | 48.018 Include MSC/VLR identity in CS IMSI paging | 101d | 2002-02-08 A | 2002-06-28 A | 100% | 2002-02-08 | 2002-06-28 | 101d | finish no earlier than 2002-06-28 | G2 | 808h | 808h |  |  |  | Rel-5 | Gert |  |  |  |
| 4195 | 91 | **Deleted - GERAN improvements 3 (new transport layer on interface A)** | 446d | 2001-04-06 A | 2002-12-20 A | 100% | 2001-04-06 | 2002-12-20 | 446d |  | GP | 14272h | 14272h | GEIMP3 |  |  | Rel-5 | Paolo | GEIMP3 |  |  |
| 4196 | 91.1 | **Deleted - Evolution of the transport for A** | 446d | 2001-04-06 A | 2002-12-20 A | 100% | 2001-04-06 | 2002-12-20 | 446d |  | GP | 10704h | 10704h | GEIMP3-EtA |  |  | Rel-5 | Paolo | GEIMP3-EtA | GP-12 |  |
| 4197 | 91.1.1 | Deleted - Definition of a new A/Ater interface Transport Layer option based on the Iu Interface Transport Layer | 446d | 2001-04-06 A | 2002-12-20 A | 100% | 2001-04-06 | 2002-12-20 | 446d | finish no earlier than 2002-12-20 | GP | 3568h | 3568h |  |  |  | Rel-5 | Paolo |  | GP-12 |  |
| 4198 | 91.1.2 | Deleted - Adaptation of the Layer 3 BSSMAP procedures as required | 446d | 2001-04-06 A | 2002-12-20 A | 100% | 2001-04-06 | 2002-12-20 | 446d | finish no earlier than 2002-12-20 | GP | 3568h | 3568h |  |  |  | Rel-5 | Paolo |  | GP-12 |  |
| 4199 | 92 | **Rel-5 Charging Management & Operations, Administration, Maintenance and Provisioning (OAM&P)** | 264d | 2001-09-10 A | 2002-09-12 A | 100% | 2001-09-10 | 2002-09-12 | 264d |  | S5 | 9976h | 9976h | OAM5 |  |  | Rel-5 | Mirko | OAM5 |  |  |
| 4200 | 92.1 | Rel-5 Principles, high level Requirements and Architecture | 205d | 2001-09-17 A | 2002-06-28 A | 100% | 2001-09-17 | 2002-06-28 | 205d | finish no earlier than 2002-06-28 | S5 | 1640h | 1640h |  | Motorola |  | Rel-5 | Mirko |  |  | 32.101, 32.102 |
| 4201 | 92.2 | Rel-5 Performance Management | 259d | 2001-09-17 A | 2002-09-12 A | 100% | 2001-09-17 | 2002-09-12 | 259d | finish no earlier than 2002-09-12 | S5 | 2072h | 2072h |  | Nortel |  | Rel-5 | Mirko |  |  | 32.4xy, 52.402 |
| 4202 | 92.3 | Rel-5 Charging Management | 264d | 2001-09-10 A | 2002-09-12 A | 100% | 2001-09-10 | 2002-09-12 | 264d | finish no earlier than 2002-09-12 | S5 | 2112h | 2112h |  | T-Mobile | Karl-Heinz.Nenner@T-MOBILE.DE | Rel-5 | Mirko |  |  | 32.200, 32.205, 32.215, 32.225, 32.235 |
| 4203 | 92.4 | Rel-5 Network Infrastructure Management | 255d | 2001-09-21 A | 2002-09-12 A | 100% | 2001-09-21 | 2002-09-12 | 255d | finish no earlier than 2002-09-12 | S5 | 2040h | 2040h |  | Ericsson | thomas.tovinger@ericsson.com | Rel-5 | Mirko |  |  | 32.6xy, 32.3xy |
| 4204 | 93 | **GERAN enhancements for streaming services 1 (RLC enhancements)** | 430d | 2000-11-06 A | 2002-06-28 A | 100% | 2000-11-06 | 2002-06-28 | 430d |  | GP | 8944h | 8944h |  |  |  | Rel-5 | Paolo |  |  |  |
| 4205 | 93.1 | Concept for GERAN enhancements for streaming services 1 (RLC enhancements) | 258d | 2000-11-06 A | 2001-10-31 A | 100% | 2000-11-06 | 2001-10-31 | 258d | finish no earlier than 2001-10-31 | GP | 2064h | 2064h |  |  |  | Rel-5 | Paolo |  |  |  |
| 4206 | 93.2 | RLC protocol enhancement (SDU Discard) | 430d | 2000-11-06 A | 2002-06-28 A | 100% | 2000-11-06 | 2002-06-28 | 430d | finish no earlier than 2002-06-28 | GP | 3440h | 3440h |  |  |  | Rel-5 | Paolo |  |  |  |
| 4207 | 94 | **GERAN enhancements for streaming services 2 (usage of ECSD)** | 430d | 2000-11-06 A | 2002-06-28 A | 100% | 2000-11-06 | 2002-06-28 | 430d |  | GP | 19840h | 19840h |  | Ericsson | Frank Muller | Rel-5 | Paolo |  |  |  |
| 4208 | 94.1 | Usage of ECSD Concept | 380d | 2000-11-06 A | 2002-04-19 A | 100% | 2000-11-06 | 2002-04-19 | 380d | finish no earlier than 2002-04-19 | GP | 3040h | 3040h |  |  |  | Rel-5 | Paolo |  |  |  |
| 4209 | 94.2 | Stage 2 for GERAN enhancements for streaming services 2 (usage of ECSD) | 380d | 2000-11-06 A | 2002-04-19 A | 100% | 2000-11-06 | 2002-04-19 | 380d | finish no earlier than 2002-04-19 | GP | 3040h | 3040h |  |  |  | Rel-5 | Paolo |  |  |  |
| 4210 | 94.3 | Stage 3 for GERAN enhancements for streaming services 2 (usage of ECSD) | 430d | 2000-11-06 A | 2002-06-28 A | 100% | 2000-11-06 | 2002-06-28 | 430d | finish no earlier than 2002-06-28 | GP | 3440h | 3440h |  |  |  | Rel-5 | Paolo |  |  |  |
| 4211 | 94.4 | RLC PDU formats | 430d | 2000-11-06 A | 2002-06-28 A | 100% | 2000-11-06 | 2002-06-28 | 430d | finish no earlier than 2002-06-28 | GP | 3440h | 3440h |  |  |  | Rel-5 | Paolo |  |  |  |
| 4212 | 94.5 | MAC header | 430d | 2000-11-06 A | 2002-06-28 A | 100% | 2000-11-06 | 2002-06-28 | 430d | finish no earlier than 2002-06-28 | GP | 3440h | 3440h |  |  |  | Rel-5 | Paolo |  |  |  |

Notes:
- 4189: Accept changes Gb over IP
- 4190: -
- 4191: -
- 4192: -
- 4193: Closed, accept changes for Gb over IP
- 4194: -
- 4195: Terminated - not standardized. Marked as stopped 12/2008
- 4196: TERMINATED - NOT STANDARDIZED. Marked as stopped 12/2008
- 4197: TERMINATED - NOT STANDARDIZED. Marked as stopped 12/2008
- 4198: TERMINATED - NOT STANDARDIZED. Marked as stopped 12/2008
- 4199: -
- 4200: -
- 4201: -
- 4202: -
- 4203: -
- 4204: -
- 4205: -
- 4206: -
- 4207: AWS, Nokia, Ericsson, Nortel, Siemens, Motorola, Vodafone
- 4208: -
- 4209: -
- 4210: -
- 4211: -
- 4212: -

| ID | WBS | Task | Duration | Start | Finish | Predecessors | Complete | Baseline start | Baseline finish | Baseline duration | Constraint | Resources | Work | Actual work | Acronym | WI rapporteur name | WI rapporteur e-mail | Release | MCC resp | Acronym_3GU_Export |
| --- | --- | --- | --- | --- | --- | --- | --- | --- | --- | --- | --- | --- | --- | --- | --- | --- | --- | --- | --- | --- |
| 4213 | 95 | **GERAN/UTRAN interface evolution 1 (evolution of Iu PS)** | 476d | 2000-09-01 A | 2002-06-28 A |  | 100% | 2000-09-01 | 2002-06-28 | 476d |  | GP; R3 | 22848h | 22848h | GERUEV1 | SBC | Marc Grant | Rel-5 | Paolo | GERUEV1 |
| 4214 | 95.1 | **Evolution of Iu ps** | 476d | 2000-09-01 A | 2002-06-28 A |  | 100% | 2000-09-01 | 2002-06-28 | 476d |  | GP; R3 | 15232h | 15232h | GERUEV1-IuPS |  |  | Rel-5 | Paolo | GERUEV1-IuPS |
| 4215 | 95.1.1 | Identification of GERAN requirements on Iu ps | 326d | 2000-09-01 A | 2001-11-30 A |  | 100% | 2000-09-01 | 2001-11-30 | 326d | finish no earlier than 2001-11-30 | GP; R3 | 5216h | 5216h |  |  |  | Rel-5 | Paolo |  |
| 4216 | 95.1.2 | Update of Evolution of Iu ps specifications | 150d | 2001-12-03 A | 2002-06-28 A | 4215 | 100% | 2001-12-03 | 2002-06-28 | 150d | finish no earlier than 2002-06-28 | GP; R3 | 2400h | 2400h |  |  |  | Rel-5 | Paolo |  |
| 4217 | 96 | **GERAN/UTRAN interface evolution 2 (evolution of Iu CS)** | 522d | 2000-06-29 A | 2002-06-28 A |  | 100% | 2000-06-29 | 2002-06-28 | 522d |  | GP; R3 | 31872h | 31872h | GERUEV2 |  |  | Rel-5 | Paolo | GERUEV2 |
| 4218 | 96.1 | **Evolution of Iu cs** | 522d | 2000-06-29 A | 2002-06-28 A |  | 100% | 2000-06-29 | 2002-06-28 | 522d |  | GP; R3 | 23520h | 23520h | GERUEV2-IuCS | Lucent | Krishna Balachandran | Rel-5 | Paolo | GERUEV2-IuCS |
| 4219 | 96.1.1 | Identification of GERAN requirements on Iu cs | 472d | 2000-06-29 A | 2002-04-19 A |  | 100% | 2000-06-29 | 2002-04-19 | 472d | finish no earlier than 2002-04-19 | GP; R3 | 7552h | 7552h |  |  |  | Rel-5 | Paolo |  |
| 4220 | 96.1.2 | Update of Evolution of Iu cs specifications | 476d | 2000-09-01 A | 2002-06-28 A |  | 100% | 2000-09-01 | 2002-06-28 | 476d | finish no earlier than 2002-06-28 | GP; R3 | 7616h | 7616h |  |  |  | Rel-5 | Paolo |  |
| 4221 | 97 | **End to End QoS for PS Domain including IMS** | 480d | 2000-08-28 A | 2002-06-28 A |  | 100% | 2000-08-28 | 2002-06-28 | 480d |  | S2; S5; N3 | 18272h | 18272h | E2EQoS | Ericsson | Johnson.oyama@era.ericcson.se | Rel-5 | Maurice | E2EQoS, Rel-5 |
| 4222 | 97.1 | E2E QoSConcept and Architecture | 178d | 2001-01-03 A | 2001-09-07 A |  | 100% | 2001-01-03 | 2001-09-07 | 178d | finish no earlier than 2001-09-07 | S2 | 1424h | 1424h |  |  |  | Rel-5 | Maurice |  |
| 4223 | 97.2 | E2E QoS interworking | 465d | 2000-08-28 A | 2002-06-07 A |  | 100% | 2000-08-28 | 2002-06-07 | 465d | finish no earlier than 2002-06-07 | N3 | 3720h | 3720h | E2EQoS-IW | Lucent | Daisuke Yokota (yokota@lucent.com) | Rel-5 | Gwiho | E2EQoS-IW |
| 4224 | 97.3 | QoS Management (Provisioning and Monitoring) | 201d | 2001-09-21 A | 2002-06-28 A |  | 100% | 2001-09-21 | 2002-06-28 | 201d | finish no earlier than 2002-06-28 | S5 | 1608h | 1608h | E2EQoS-OAM |  |  | Rel-5 | Mirko | E2EQoS-OAM |
| 4225 | 98 | **Rel-5 Messaging enhancements** | 467d | 2001-06-15 A | 2003-03-31 A |  | 100% | 2001-06-15 | 2003-03-31 | 467d |  | T2 | 19000h | 19000h | MESS5 |  |  | Rel-5 | Kimmo | MESS5 |
| 4226 | 98.1 | **Rel-5 Multimedia Messaging (MMS) enhancements** | 467d | 2001-06-15 A | 2003-03-31 A |  | 100% | 2001-06-15 | 2003-03-31 | 467d |  | T2 | 11688h | 11688h | MESS5-MMS | Siemens | Josef.Laumen@SAL.SIEMENS.DE | Rel-5 | Alain | MESS5-MMS |
| 4227 | 98.1.1 | Definition of service requirements for MESS5-MMS | 196d | 2001-06-15 A | 2002-03-15 A |  | 100% | 2001-06-15 | 2002-03-15 | 196d | finish no earlier than 2002-03-15 | S1 | 1568h | 1568h | MESS5-SR | Siemens | Josef.Laumen@SAL.SIEMENS.DE | Rel-5 | Alain | MESS5-SR |
| 4228 | 98.1.2 | Technical realization of MESS5-MMS | 256d | 2001-06-15 A | 2002-06-07 A |  | 100% | 2001-06-15 | 2002-06-07 | 256d | finish no earlier than 2002-06-07 | T2 | 2048h | 2048h |  | Siemens | Josef.Laumen@SAL.SIEMENS.DE | Rel-5 |  |  |
| 4229 | 98.1.3 | WAP Forum dependency: MM1 stage 3 | 467d | 2001-06-15 A | 2003-03-31 A |  | 100% | 2001-06-15 | 2003-03-31 | 467d | finish no earlier than 2003-03-31 | T2 | 3736h | 3736h |  |  |  | Rel-5 |  |  |
| 4230 | 98.1.4 | MMS formats and codecs for MESS5-MMS | 75d | 2001-12-03 A | 2002-03-15 A |  | 100% | 2001-12-03 | 2002-03-15 | 75d | finish no earlier than 2002-03-15 | S4 | 600h | 600h |  |  |  | Rel-5 | Paolo |  |
| 4231 | 98.2 | **Enhanced Messaging Service (EMS) enhancements** | 191d | 2001-06-15 A | 2002-03-08 A |  | 100% | 2001-06-15 | 2002-03-08 | 191d |  | T2 | 3584h | 3584h | MESS5-EMS | Ericsson | Alan.Baldwin@EML.ERICSSON.SE | Rel-5 | Kimmo | MESS5-EMS |
| 4232 | 98.2.1 | Definition of service requirements for Enhanced Messaging Service (EMS) enhancements | 66d | 2001-06-15 A | 2001-09-14 A |  | 100% | 2001-06-15 | 2001-09-14 | 66d | finish no earlier than 2001-09-14 | S1 | 528h | 528h |  | Ericsson | Alan.Baldwin@EML.ERICSSON.SE | Rel-5 | Alain |  |
| 4233 | 98.2.2 | Technical realization of Enhanced Messaging Service (EMS) enhancements | 191d | 2001-06-15 A | 2002-03-08 A |  | 100% | 2001-06-15 | 2002-03-08 | 191d | finish no earlier than 2002-03-08 | T2 | 1528h | 1528h |  | Ericsson | Alan.Baldwin@EML.ERICSSON.SE | Rel-5 | Kimmo |  |
| 4234 | 99 | **GERAN Inter BSC NACC improvements over the Gb Interface** | 215d | 2001-09-03 A | 2002-06-28 A |  | 100% | 2001-09-03 | 2002-06-28 | 215d |  | GP | 11184h | 11184h | GERNACC |  |  | Rel-5 | Paolo | GERNACC |
| 4235 | 99.1 | **Modification of core network protocols for GERAN Inter BSC NACC over Gb Interface** | 165d | 2001-09-03 A | 2002-04-19 A |  | 100% | 2001-09-03 | 2002-04-19 | 165d |  | N4; S2 | 7048h | 7048h | GERNACC-Cnmod |  |  | Rel-5 | Kimmo | GERNACC-Cnmod |
| 4236 | 99.1.1 | Stage 2 - Concept | 43d | 2001-09-03 A | 2001-10-31 A |  | 100% | 2001-09-03 | 2001-10-31 | 43d | finish no earlier than 2001-10-31 | N4; S2 | 688h | 688h |  |  |  | Rel-5 | Kimmo |  |
| 4237 | 99.1.2 | Stage 2 - 23.060 change - Definition of Inter BSC NACC | 165d | 2001-09-03 A | 2002-04-19 A |  | 100% | 2001-09-03 | 2002-04-19 | 165d | finish no earlier than 2002-04-19 | N4; S2 | 2640h | 2640h |  |  |  | Rel-5 | Kimmo |  |
| 4238 | 99.1.3 | Stage 3 (changes to TS 29.060) | 135d | 2001-09-03 A | 2002-03-08 A |  | 100% | 2001-09-03 | 2002-03-08 | 135d | finish no earlier than 2002-03-08 | N4 | 1080h | 1080h |  |  |  | Rel-5 | Kimmo |  |

Notes:
- 4213: SBC, Motorola, Nokia, Ericsson, Nortel
- 4214: -
- 4215: -
- 4216: -
- 4217: -
- 4218: Lucent, Ericsson, AWS, Nortel
- 4219: -
- 4220: -
- 4221: Acronym changed from "E2EQoS, Rel-5"
- 4222: - / Impacted TSs and TRs: 23.207
- 4223: [DAB - 30/07/02] - % complete to 95% (if we exclude Diffserv). Marked as closed 12/2008 (was marked 95% complete) / Impacted TSs and TRs: 29.208, 29.207, 27.060, 29.061, 24.008, 24.228, , 24.229, 29.060, 29.163
- 4224: - / Impacted TSs and TRs: 32-series
- 4225: support of UAProf, so this in my opinion is 100% complete
- 4226: -
- 4227: - / Impacted TSs and TRs: 22.140
- 4228: stage 3 MM7 is missing / Impacted TSs and TRs: 23.140
- 4229: Marked as closed 12/2008 (was marked 80% complete)
- 4230: - / Impacted TSs and TRs: 26.140
- 4231: - / Impacted TSs and TRs: 23.040
- 4232: -
- 4233: - / Impacted TSs and TRs: 23.040
- 4234: -
- 4235: -
- 4236: -
- 4237: -
- 4238: IP 30/11/01: Input awaited from GERAN2 to CN4 / 17 May Work complete 100%

| ID | WBS | Task | Duration | Start | Finish | Complete | Baseline start | Baseline finish | Baseline duration | Constraint | Resources | Work | Actual work | Acronym | Release | MCC resp | Acronym_3GU_Export | TSG stopped | WI rapporteur name | WI rapporteur e-mail |
| --- | --- | --- | --- | --- | --- | --- | --- | --- | --- | --- | --- | --- | --- | --- | --- | --- | --- | --- | --- | --- |
| 4239 | 99.2 | **Modification of Gb protocols for GERAN Inter BSC NACC over Gb Interface** | 151d | 2001-11-30 A | 2002-06-28 A | 100% | 2001-11-30 | 2002-06-28 | 151d |  | GP | 2416h | 2416h | GERNACC-Gbmod | Rel-5 | Paolo | GERNACC-Gbmod |  |  |  |
| 4240 | 99.2.1 | Stage 3 (changes to TS 48.018) | 151d | 2001-11-30 A | 2002-06-28 A | 100% | 2001-11-30 | 2002-06-28 | 151d | finish no earlier than 2002-06-28 | GP | 1208h | 1208h |  | Rel-5 | Paolo |  |  |  |  |
| 4241 | 100 | **Enhanced Power Control** | 540d | 2001-11-26 A | 2003-12-19 A | 100% | 2001-11-26 | 2003-12-19 | 540d |  | GP | 12840h | 12840h | EPC | Rel-5 | Paolo | EPC |  |  |  |
| 4242 | 100.1 | Realization of Enhanced power control and signalling support | 5d | 2001-11-26 A | 2001-11-30 A | 100% | 2001-11-26 | 2001-11-30 | 5d | finish no earlier than 2001-11-30 | GP | 40h | 40h |  | Rel-5 | Paolo |  |  |  |  |
| 4243 | 100.2 | Deleted - GERAN MS Conformance test for Enhanced Power Control | 530d | 2001-12-10 A | 2003-12-19 A | 100% | 2001-12-10 | 2003-12-19 | 530d | finish no earlier than 2003-12-19 | GP | 4240h | 4240h |  | Rel-5 | Paolo |  | GP-17 |  |  |
| 4244 | 100.3 | Deleted - GERAN BTS Conformance test for Enhanced Power Control | 530d | 2001-12-10 A | 2003-12-19 A | 100% | 2001-12-10 | 2003-12-19 | 530d | finish no earlier than 2003-12-19 | GP | 4240h | 4240h |  | Rel-5 | Paolo |  | GP-17 |  |  |
| 4245 | 101 | **8PSK AMR HR** | 530d | 2001-12-10 A | 2003-12-19 A | 100% | 2001-12-10 | 2003-12-19 | 530d |  | GP | 21080h | 21080h | 8PSK-AH | Rel-5 | Paolo | 8PSK-AH |  |  |  |
| 4246 | 101.1 | **Definition of channel coding, performance requirements and signalling support** | 145d | 2001-12-10 A | 2002-06-28 A | 100% | 2001-12-10 | 2002-06-28 | 145d |  | GP | 10440h | 10440h |  | Rel-5 | Paolo |  |  |  |  |
| 4247 | 101.1.1 | Concept | 145d | 2001-12-10 A | 2002-06-28 A | 100% | 2001-12-10 | 2002-06-28 | 145d | finish no earlier than 2002-06-28 | GP | 1160h | 1160h |  | Rel-5 | Paolo |  |  |  |  |
| 4248 | 101.1.2 | Changes to 44.018 | 145d | 2001-12-10 A | 2002-06-28 A | 100% | 2001-12-10 | 2002-06-28 | 145d | finish no earlier than 2002-06-28 | G2 | 1160h | 1160h |  | Rel-5 | Gert |  |  |  |  |
| 4249 | 101.1.3 | Changes to 45.001 | 145d | 2001-12-10 A | 2002-06-28 A | 100% | 2001-12-10 | 2002-06-28 | 145d | finish no earlier than 2002-06-28 | G1 | 1160h | 1160h |  | Rel-5 | Paolo |  |  |  |  |
| 4250 | 101.1.4 | Changes to 45.002 | 145d | 2001-12-10 A | 2002-06-28 A | 100% | 2001-12-10 | 2002-06-28 | 145d | finish no earlier than 2002-06-28 | G1 | 1160h | 1160h |  | Rel-5 | Paolo |  |  |  |  |
| 4251 | 101.1.5 | Changes to 45.003 | 145d | 2001-12-10 A | 2002-06-28 A | 100% | 2001-12-10 | 2002-06-28 | 145d | finish no earlier than 2002-06-28 | G1 | 1160h | 1160h |  | Rel-5 | Paolo |  |  |  |  |
| 4252 | 101.1.6 | Changes to 45.005 | 145d | 2001-12-10 A | 2002-06-28 A | 100% | 2001-12-10 | 2002-06-28 | 145d | finish no earlier than 2002-06-28 | G1 | 1160h | 1160h |  | Rel-5 | Paolo |  |  |  |  |
| 4253 | 101.1.7 | Changes to 24.008 | 145d | 2001-12-10 A | 2002-06-28 A | 100% | 2001-12-10 | 2002-06-28 | 145d | finish no earlier than 2002-06-28 | G2 | 1160h | 1160h |  | Rel-5 | Gert |  |  |  |  |
| 4254 | 101.1.8 | Changes to 48.058 | 145d | 2001-12-10 A | 2002-06-28 A | 100% | 2001-12-10 | 2002-06-28 | 145d | finish no earlier than 2002-06-28 | G2 | 1160h | 1160h |  | Rel-5 | Gert |  |  |  |  |
| 4255 | 101.2 | Deleted - GERAN MS Conformance test for 8PSK HR | 530d | 2001-12-10 A | 2003-12-19 A | 100% | 2001-12-10 | 2003-12-19 | 530d | finish no earlier than 2003-12-19 | GP | 4240h | 4240h |  | Rel-5 | Paolo |  | GP-17 |  |  |
| 4256 | 101.3 | GERAN BTS Conformance test for 8PSK HR | 270d | 2001-12-10 A | 2002-12-20 A | 100% | 2001-12-10 | 2002-12-20 | 270d | finish no earlier than 2002-12-20 | GP | 2160h | 2160h |  | Rel-5 | Paolo |  |  |  |  |
| 4257 | 102 | Service Change and UDI Fallback | 175d | 2001-10-08 A | 2002-06-07 A | 100% | 2001-10-08 | 2002-06-07 | 175d | finish no earlier than 2002-06-07 | N3 | 1400h | 1400h | SCUDIF | Rel-5 | Gwiho | SCUDIF |  | Ericsson | Rune.Werner.Wiik@ericsson.no |
| 4258 | 103 | **Rel-5 USIM toolkit enhancements** | 865d | 2000-06-05 A | 2003-09-26 A | 100% | 2000-06-05 | 2003-09-26 | 865d |  | T3; S1 | 36776h | 36776h | USAT5 | Rel-5 | Xavier | USAT1, USAT1-Interpr, USAT1LocLnk |  | G & D | Michael Meyer |
| 4259 | 103.1 | Deleted - Test specification for USIM toolkit security mechanisms | 349d | 2002-05-28 A | 2003-09-26 A | 100% | 2002-05-28 | 2003-09-26 | 349d | finish no earlier than 2003-09-26 | T3 | 2792h | 2792h |  | Rel-5 | Xavier |  | TP-21 | Gemplus | Sophie Viallet |
| 4260 | 103.2 | **Protocol Standardisation of a SIM Toolkit Interpreter** | 688d | 2000-06-05 A | 2003-01-22 A | 100% | 2000-06-05 | 2003-01-22 | 688d |  | T3; T2 | 18016h | 18016h |  | Rel-5 | Xavier |  |  | G & D | Michael Meyer |
| 4261 | 103.2.1 | Stage 1 for Protocol Standardisation of a SIM Toolkit Interpreter | 205d | 2000-06-05 A | 2001-03-16 A | 100% | 2000-06-05 | 2001-03-16 | 205d | finish no earlier than 2001-03-16 | T3 | 1640h | 1640h |  | Rel-5 | Xavier |  |  |  |  |
| 4262 | 103.2.2 | Stage 2 and 3 | 308d | 2001-01-03 A | 2002-03-08 A | 100% | 2001-01-03 | 2002-03-08 | 308d | finish no earlier than 2002-03-08 | T3 | 2464h | 2464h |  | Rel-5 | Xavier |  |  |  |  |
| 4263 | 103.2.3 | Test specification for Protocol Standardisation of a SIM Toolkit Interpreter | 363d | 2001-09-03 A | 2003-01-22 A | 100% | 2001-09-03 | 2003-01-22 | 363d | finish no earlier than 2003-01-22 | T3 | 2904h | 2904h |  | Rel-5 | Xavier |  |  | Gemplus | Gérald MAUNIER |

Notes:
- 4239: -
- 4240: -
- 4241: -
- 4242: Completed 11/2001
- 4243: Not started. Marked as stopped 12/2008
- 4244: Not started. Marked as stopped 12/2008
- 4245: Completed for Rel-5
- 4246: -
- 4247: -
- 4248: -
- 4249: -
- 4250: -
- 4251: -
- 4252: -
- 4253: -
- 4254: -
- 4255: Marked as stopped 12/2008
- 4256: -
- 4257: - / Impacted TSs and TRs: 29.007, 27.001, 24.008
- 4258: Acronym changed from USAT1, USAT1-Interpr, USAT1LocLnk / Impacted TSs and TRs: 22.038, 31.111 (USAT1), 22.038, 03.19, 03.48 (USAT1LocLnk), 23.048 (USAT1SM), 43.019 (USAT1APIJAVA)
- 4259: Marked as stopped 12/2008
- 4260: 28/5/2001: T3-19 proposed that since the stage 2 and 3 will not be presented to TP-12 for approval as expected, the WI will be moved to rel-5, with completion expected at TP-13. / Impacted TSs and TRs: T2 27.103
- 4261: 5/10/2001: Stage one comepeted at TP-12. / Impacted TSs and TRs: 31.112, 31.113, 31.114
- 4262: 5/10/2001: TS 31.112 and 31.113 approved at TP-13. TS 31.114 to be presented to TP-14. / Impacted TSs and TRs: 31.112, 31.113, 31.114
- 4263: 5/10/2001: Work started on test specification. Marked as closed 12/2008 (was marked 12% complete)

| ID | WBS | Task | Type | Duration | Start | Finish | Complete | Baseline start | Baseline finish | Baseline duration | Constraint | Resources | Work | Actual work | Acronym | WI rapporteur name | WI rapporteur e-mail | Release | MCC resp | Acronym_3GU_Export | TSG stopped |
| --- | --- | --- | --- | --- | --- | --- | --- | --- | --- | --- | --- | --- | --- | --- | --- | --- | --- | --- | --- | --- | --- |
| 4264 | 103.4 | **(U)SIM API** |  | 133d | 2002-03-20 A | 2002-09-20 A | 100% | 2002-03-20 | 2002-09-20 | 133d |  | T3 | 2128h | 2128h | USAT5-API | Microelectrónica Española | Mario Pérez | Rel-5 | Xavier | USAT1-API, TEI4 |  |
| 4265 | 103.4.1 | Rel-5 Java API Test specification |  | 133d | 2002-03-20 A | 2002-09-20 A | 100% | 2002-03-20 | 2002-09-20 | 133d | finish no earlier than 2002-09-20 | T3 | 1064h | 1064h |  | Microelectrónica Española | Mario Pérez | Rel-5 | Xavier |  |  |
| 4266 | 104 | (Small) Technical Enhancements and Improvements for Rel-5 | milestone | 0d? | 2000-01-03 A | 2000-01-03 A | 100% | 2000-01-03 | 2000-01-03 | 0d? |  | SP; CP; RP; GP |  |  | TEI5 |  |  | Rel-5 | all | TEI5 |  |
| 4267 | 1045 | Test - (Small) Technical Enhancements and Improvements for Rel-5 |  | 2349d? | 2000-01-03 A | 2008-12-31 A | 100% | 2000-01-03 | 2008-12-31 | 2349d? | finish no earlier than 2008-12-31 | R5; T1 | 37584h | 37584h | TEI5_Test |  |  | Rel-5 | Ingbert | TEI5_Test |  |
| 4268 | 105 | Technical Report on UE Functionality Split |  | 87d | 2000-01-03 A | 2000-05-01 A | 100% | 2000-01-03 | 2000-05-01 | 87d |  | S1 | 688h | 688h | UESPLIT | Motorola | jian.j.wu@motorola.com | Rel-5 | Alain | UESPLIT |  |
| 4269 | 106 | **User Equipment Management** |  | 267d | 2001-06-21 A | 2002-06-28 A | 100% | 2001-06-21 | 2002-06-28 | 267d |  | S5 | 3752h | 3752h | UEM | Vodafone | john.mudge@vf.vodafone.co.uk | Rel-5 | Mirko | UEM |  |
| 4270 | 106.1 | FS on User Equipment (UE) Management |  | 267d | 2001-06-21 A | 2002-06-28 A | 100% | 2001-06-21 | 2002-06-28 | 267d | finish no earlier than 2002-06-28 | S5 | 2136h | 2136h | OAM-UEM | Vodafone | john.mudge@vf.vodafone.co.uk | Rel-5 | Mirko | OAM-UEM |  |
| 4271 | 107 | **Flow control supporting an MS with multiple data flows with different QoS over the Gb interface** |  | 50d | 2002-06-24 A | 2002-08-30 A | 100% | 2002-06-24 | 2002-08-30 | 50d |  | GP | 1288h | 1288h | FlowCon | Ericsson | ingemar.backlund@era.ericsson.se | Rel-5 | Paolo | FlowCon |  |
| 4272 | 107.1 | **Update of stage 2 specifications** |  | 50d | 2002-06-24 A | 2002-08-30 A | 100% | 2002-06-24 | 2002-08-30 | 50d |  | GP | 808h | 808h |  |  |  | Rel-5 | Paolo |  |  |
| 4273 | 107.1.1 | Concept document 23.060 (changes to) |  | 46d | 2002-06-28 A | 2002-08-30 A | 100% | 2002-06-28 | 2002-08-30 | 46d | finish no earlier than 2002-08-30 | S2 | 368h | 368h |  |  |  | Rel-5 | Maurice |  |  |
| 4274 | 107.1.2 | Flow Control |  | 5d | 2002-06-24 A | 2002-06-28 A | 100% | 2002-06-24 | 2002-06-28 | 5d | finish no earlier than 2002-06-28 | GP | 40h | 40h |  |  |  | Rel-5 | Paolo |  |  |
| 4275 | 107.2 | **Modification of BSSGP protocol** |  | 5d | 2002-06-24 A | 2002-06-28 A | 100% | 2002-06-24 | 2002-06-28 | 5d |  | GP | 80h | 80h |  | Ericsson | ingemar.backlund@era.ericsson.se | Rel-5 | Paolo |  |  |
| 4276 | 107.2.1 | Stage 3 (changes to 48.018) |  | 5d | 2002-06-24 A | 2002-06-28 A | 100% | 2002-06-24 | 2002-06-28 | 5d | finish no earlier than 2002-06-28 | G2 | 40h | 40h |  |  |  | Rel-5 | Gert |  |  |
| 4277 | 108 | **Deleted - Multiple TBF in A/Gb mode - Phase 1 (MULTBF)** |  | 421d | 2002-04-19 A | 2003-11-28 A | 100% | 2002-04-19 | 2003-11-28 | 421d |  | GP | 17480h | 17480h |  | Ericsson | gunnar.mildh@era.ericsson.se | Rel-5 | Paolo |  | GP-17 |
| 4278 | 108.1 | **Deleted - Multiple TBF in A/Gb mode - Core (MULTBF-Agbmode)** |  | 351d | 2002-04-19 A | 2003-08-22 A | 100% | 2002-04-19 | 2003-08-22 | 351d |  | GP | 8112h | 8112h |  |  |  | Rel-5 | Paolo |  | GP-17 |
| 4279 | 108.1.1 | Deleted - Multiple TBF Concept paper |  | 351d | 2002-04-19 A | 2003-08-22 A | 100% | 2002-04-19 | 2003-08-22 | 351d | finish no earlier than 2003-08-22 | GP | 2808h | 2808h |  |  |  | Rel-5 | Paolo |  | GP-17 |
| 4280 | 108.1.2 | Deleted - Multiple TBF Stage 2 (43.064) CRs |  | 156d | 2002-04-19 A | 2002-11-22 A | 100% | 2002-04-19 | 2002-11-22 | 156d | finish no earlier than 2002-11-22 | G1 | 1248h | 1248h |  |  |  | Rel-5 | Paolo |  | GP-12 |
| 4281 | 108.1.3 | Deleted - Multiple TBF Stage 3 (44.060) CRs |  | 156d | 2002-04-19 A | 2002-11-22 A | 100% | 2002-04-19 | 2002-11-22 | 156d | finish no earlier than 2002-11-22 | G2 | 1248h | 1248h |  |  |  | Rel-5 | Gert |  | GP-12 |
| 4282 | 108.2 | **Deleted - Multiple TBF in A/Gb mode - Phase 1 – MS testing** |  | 375d | 2002-06-24 A | 2003-11-28 A | 100% | 2002-06-24 | 2003-11-28 | 375d |  | GP | 6000h | 6000h |  | Ericsson | ingemar.backlund@era.ericsson.se | Rel-5 | Paolo |  | GP-17 |
| 4283 | 108.2.1 | Deleted - MS conformance tests for Multiple TBF in A/Gb mode |  | 375d | 2002-06-24 A | 2003-11-28 A | 100% | 2002-06-24 | 2003-11-28 | 375d | finish no earlier than 2003-11-28 | G4 | 3000h | 3000h |  |  |  | Rel-5 | Paolo |  | GP-17 |
| 4284 | 109 | **Alignment of 3G functional split and Iu** |  | 922d | 2000-06-08 A | 2003-12-19 A | 100% | 2000-06-08 | 2003-12-19 | 922d |  | GP | 165704h | 165704h | GER3GAL | Ericsson | Frank Muller | Rel-5 | Paolo | GER3GAL |  |
| 4285 | 109.1 | **GERAN user / control plane** |  | 540d | 2000-08-07 A | 2002-08-30 A | 100% | 2000-08-07 | 2002-08-30 | 540d |  | GP | 36232h | 36232h | GER3GAL-GUCOPL | Ericsson | Frank Muller | Rel-5 | Paolo | GER3GAL-GUCOPL |  |
| 4286 | 109.1.1 | **Alignment with UMTS bearer concept** |  | 540d | 2000-08-07 A | 2002-08-30 A | 100% | 2000-08-07 | 2002-08-30 | 540d |  | GP | 24952h | 24952h |  |  |  | Rel-5 | Paolo |  |  |
| 4287 | 109.1.1.1 | Enhanced power control - for Alignment with UMTS bearer concept |  | 1d | 2001-08-31 A | 2001-08-31 A | 100% | 2001-08-31 | 2001-08-31 | 1d | finish no earlier than 2001-08-31 | GP | 8h | 8h |  |  |  | Rel-5 | Paolo |  |  |
| 4288 | 109.1.1.2 | Stage 2 - for Alignment with UMTS bearer concept |  | 235d | 2000-08-07 A | 2001-06-29 A | 100% | 2000-08-07 | 2001-06-29 | 235d | finish no earlier than 2001-06-29 | GP | 1880h | 1880h |  |  |  | Rel-5 | Paolo |  |  |
| 4289 | 109.1.1.3 | Adoption of the UTRAN PDCP |  | 295d | 2000-11-06 A | 2001-12-21 A | 100% | 2000-11-06 | 2001-12-21 | 295d | finish no earlier than 2001-12-21 | GP | 2360h | 2360h |  |  |  | Rel-5 | Paolo |  |  |
| 4290 | 109.1.1.4 | Development of RLC / MAC |  | 261d | 2001-08-31 A | 2002-08-30 A | 100% | 2001-08-31 | 2002-08-30 | 261d | finish no earlier than 2002-08-30 | GP | 2088h | 2088h |  |  |  | Rel-5 | Paolo |  |  |
| 4291 | 109.1.1.5 | Development of GERAN RRC |  | 266d | 2001-06-22 A | 2002-06-28 A | 100% | 2001-06-22 | 2002-06-28 | 266d | finish no earlier than 2002-06-28 | GP | 2128h | 2128h |  |  |  | Rel-5 | Paolo |  |  |
| 4292 | 109.1.1.6 | Ciphering and integrity protection concept paper |  | 166d | 2001-08-31 A | 2002-04-19 A | 100% | 2001-08-31 | 2002-04-19 | 166d | finish no earlier than 2002-04-19 | GP | 1328h | 1328h |  |  |  | Rel-5 | Paolo |  |  |
| 4293 | 109.1.1.7 | Multiple TBF or equivalent Concept paper |  | 116d | 2001-08-31 A | 2002-02-08 A | 100% | 2001-08-31 | 2002-02-08 | 116d | finish no earlier than 2002-02-08 | GP | 928h | 928h |  |  |  | Rel-5 | Paolo |  |  |
| 4294 | 109.1.1.8 | Paging concept |  | 166d | 2001-08-31 A | 2002-04-19 A | 100% | 2001-08-31 | 2002-04-19 | 166d | finish no earlier than 2002-04-19 | GP | 1328h | 1328h |  |  |  | Rel-5 | Paolo |  |  |
| 4295 | 109.1.1.9 | Dedicated Physical subchannels, includes traffic and control channels |  | 66d | 2001-08-31 A | 2001-11-30 A | 100% | 2001-08-31 | 2001-11-30 | 66d | finish no earlier than 2001-11-30 | GP | 528h | 528h |  |  |  | Rel-5 | Paolo |  |  |
| 4296 | 109.1.1.10 | Iu support and broadcast concept |  | 166d | 2001-08-31 A | 2002-04-19 A | 100% | 2001-08-31 | 2002-04-19 | 166d | finish no earlier than 2002-04-19 | GP | 1328h | 1328h |  |  |  | Rel-5 | Paolo |  |  |
| 4297 | 109.1.1.11 | Impact of using RLC instead of LAPDm concept |  | 116d | 2001-08-31 A | 2002-02-08 A | 100% | 2001-08-31 | 2002-02-08 | 116d | finish no earlier than 2002-02-08 | GP | 928h | 928h |  |  |  | Rel-5 | Paolo |  |  |
| 4298 | 109.1.1.12 | Contention resolution, mobile station identity, and access concept |  | 66d | 2001-08-31 A | 2001-11-30 A | 100% | 2001-08-31 | 2001-11-30 | 66d | finish no earlier than 2001-11-30 | GP | 528h | 528h |  |  |  | Rel-5 | Paolo |  |  |
| 4299 | 109.1.1.13 | PDCP concept |  | 166d | 2001-08-31 A | 2002-04-19 A | 100% | 2001-08-31 | 2002-04-19 | 166d | finish no earlier than 2002-04-19 | GP | 1328h | 1328h |  |  |  | Rel-5 | Paolo |  |  |
| 4300 | 109.1.1.14 | Downlink delayed TBF release |  | 261d | 2001-08-31 A | 2002-08-30 A | 100% | 2001-08-31 | 2002-08-30 | 261d | finish no earlier than 2002-08-30 | GP | 2088h | 2088h |  |  |  | Rel-5 | Paolo |  |  |
| 4301 | 109.1.1.15 | Add transparent RLC Concept |  | 116d | 2001-08-31 A | 2002-02-08 A | 100% | 2001-08-31 | 2002-02-08 | 116d | finish no earlier than 2002-02-08 | GP | 928h | 928h |  |  |  | Rel-5 | Paolo |  |  |
| 4302 | 109.1.1.16 | Handover concept |  | 116d | 2001-08-31 A | 2002-02-08 A | 100% | 2001-08-31 | 2002-02-08 | 116d | finish no earlier than 2002-02-08 | GP | 928h | 928h |  |  |  | Rel-5 | Paolo |  |  |

Notes:
- 4264: 8/3/2001: test spec is based on R99 core spec, so deleted from Workplan. Acronym changed from USAT1-API, TEI4
- 4265: - / Impacted TSs and TRs: 51.013
- 4266: "Joker" WI, to be used for a Rel 5 CR not related to any feature and with very limited impact on the system
- 4267: "Joker" WI, to be used for small modifications applicable to Rel 5 conformance testing. Moved in from Stoyan/testing WP. / Impacted TSs and TRs: 34.108, 34.109, 34.121-1, 34.121-2, 34.122, 34.123-1, 34.123-2, 34.123-3, 34.171, 34.229-1, 34.229-2, 34.229-3
- 4268: - / Impacted TSs and TRs: New TR 22.944
- 4269: - / Impacted TSs and TRs: 32.802
- 4270: - / Impacted TSs and TRs: 32.802
- 4271: 50101 -> 50201
- 4272: 50102 -> 50202
- 4273: -
- 4274: 50103 -> 50203
- 4275: 50104 -> 50204
- 4276: -
- 4277: GP#17 Nov 2003 Moved to Rel-6 as UID_50600 MULTBF (Only Multiple TBF Concept paper produced in Rel-5)
- 4278: Marked as closed 12/2008 (was marked 26% complete)
- 4279: Marked as closed 12/2008 (was marked 50% complete)
- 4280: Marked as stopped 12/2008
- 4281: Marked as stopped 12/2008
- 4282: 08/08: duplicate UID_50106=-> 50206. Marked as stopped 12/2008
- 4283: Not started. Marked as stopped 12/2008
- 4284: AWS, Nokia, Ericsson, Nortel, Siemens, Vodafone
- 4285: AWS, Nokia, Ericsson, Nortel, Siemens, Vodafone
- 4286: -
- 4287: -
- 4288: -
- 4289: Responsible is GERAN; RAN WG2 help may be needed.
- 4290: -
- 4291: -
- 4292: -
- 4293: -
- 4294: -
- 4295: -
- 4296: -
- 4297: -
- 4298: -
- 4299: -
- 4300: -
- 4301: -
- 4302: -

| ID | WBS | Task | Duration | Start | Finish | Complete | Baseline start | Baseline finish | Baseline duration | Constraint | Resources | Work | Actual work | Release | MCC resp | Acronym | WI rapporteur name | WI rapporteur e-mail | Acronym_3GU_Export |
| --- | --- | --- | --- | --- | --- | --- | --- | --- | --- | --- | --- | --- | --- | --- | --- | --- | --- | --- | --- |
| 4303 | 109.1.2 | **Physical layer alignment with UMTS bearer concept** | 280d | 2000-11-06 A | 2001-11-30 A | 100% | 2000-11-06 | 2001-11-30 | 280d |  | GP | 6960h | 6960h | Rel-5 | Paolo |  |  |  |  |
| 4304 | 109.1.2.1 | PDTCH/TCH in 45.003 | 155d | 2000-11-06 A | 2001-06-08 A | 100% | 2000-11-06 | 2001-06-08 | 155d | finish no earlier than 2001-06-08 | GP | 1240h | 1240h | Rel-5 | Paolo |  |  |  |  |
| 4305 | 109.1.2.2 | Control channels in 45.003 | 155d | 2000-11-06 A | 2001-06-08 A | 100% | 2000-11-06 | 2001-06-08 | 155d | finish no earlier than 2001-06-08 | GP | 1240h | 1240h | Rel-5 | Paolo |  |  |  |  |
| 4306 | 109.1.2.3 | Receiver performance in 45.005 for PDTCH/TCH and control channels | 280d | 2000-11-06 A | 2001-11-30 A | 100% | 2000-11-06 | 2001-11-30 | 280d | finish no earlier than 2001-11-30 | GP | 2240h | 2240h | Rel-5 | Paolo |  |  |  |  |
| 4307 | 109.2 | **Iu rg interface** | 430d | 2000-11-06 A | 2002-06-28 A | 100% | 2000-11-06 | 2002-06-28 | 430d |  | GP; RP | 61920h | 61920h | Rel-5 | Paolo | GER3GAL-Iurg | Ericsson | Frank Muller | GER3GAL-Iurg |
| 4308 | 109.2.1 | **Inter BSS interface** | 430d | 2000-11-06 A | 2002-06-28 A | 100% | 2000-11-06 | 2002-06-28 | 430d |  | GP; RP | 24080h | 24080h | Rel-5 | Paolo |  |  |  |  |
| 4309 | 109.2.1.1 | Identification of requirements for Inter BSS interface | 430d | 2000-11-06 A | 2002-06-28 A | 100% | 2000-11-06 | 2002-06-28 | 430d | finish no earlier than 2002-06-28 | GP | 3440h | 3440h | Rel-5 | Paolo |  |  |  |  |
| 4310 | 109.2.1.2 | Stage 2 for Inter BSS interface | 430d | 2000-11-06 A | 2002-06-28 A | 100% | 2000-11-06 | 2002-06-28 | 430d | finish no earlier than 2002-06-28 | GP | 3440h | 3440h | Rel-5 | Paolo |  |  |  |  |
| 4311 | 109.2.1.3 | Adoption of relevant parts from Iur - for Inter BSS interface | 430d | 2000-11-06 A | 2002-06-28 A | 100% | 2000-11-06 | 2002-06-28 | 430d | finish no earlier than 2002-06-28 | GP | 3440h | 3440h | Rel-5 | Paolo |  |  |  |  |
| 4312 | 109.2.1.4 | Complementation with GERAN specifics - for Inter BSS interface | 430d | 2000-11-06 A | 2002-06-28 A | 100% | 2000-11-06 | 2002-06-28 | 430d | finish no earlier than 2002-06-28 | GP | 3440h | 3440h | Rel-5 | Paolo |  |  |  |  |
| 4313 | 109.2.1.5 | Stage 3 for Inter BSS interface | 430d | 2000-11-06 A | 2002-06-28 A | 100% | 2000-11-06 | 2002-06-28 | 430d | finish no earlier than 2002-06-28 | GP | 3440h | 3440h | Rel-5 | Paolo |  |  |  |  |
| 4314 | 109.2.2 | **Inter BSS-RNS interface** | 430d | 2000-11-06 A | 2002-06-28 A | 100% | 2000-11-06 | 2002-06-28 | 430d |  | GP; RP | 30960h | 30960h | Rel-5 | Paolo |  |  |  |  |
| 4315 | 109.2.2.1 | Identification of requirements for Inter BSS-RNS interface | 430d | 2000-11-06 A | 2002-06-28 A | 100% | 2000-11-06 | 2002-06-28 | 430d | start no earlier than 2000-11-06 | GP; R3 | 6880h | 6880h | Rel-5 | Paolo |  |  |  |  |
| 4316 | 109.2.2.2 | Stage 2 for Inter BSS-RNS interface | 430d | 2000-11-06 A | 2002-06-28 A | 100% | 2000-11-06 | 2002-06-28 | 430d | finish no earlier than 2002-06-28 | GP; R3 | 6880h | 6880h | Rel-5 | Paolo |  |  |  |  |
| 4317 | 109.2.2.3 | Adoption of relevant parts from Iur - for Inter BSS-RNS interface | 430d | 2000-11-06 A | 2002-06-28 A | 100% | 2000-11-06 | 2002-06-28 | 430d | finish no earlier than 2002-06-28 | GP; R3 | 6880h | 6880h | Rel-5 | Paolo |  |  |  |  |
| 4318 | 109.2.2.4 | Complementation with GERAN specifics - for Inter BSS-RNS interface | 107.5d | 2002-01-30 A | 2002-06-28 A | 100% | 2002-01-30 | 2002-06-28 | 107.5d | finish no earlier than 2002-06-28 | GP; R3 | 1720h | 1720h | Rel-5 | Paolo |  |  |  |  |
| 4319 | 109.2.2.5 | Stage 3 for Inter BSS-RNS interface | 107.5d | 2002-01-30 A | 2002-06-28 A | 100% | 2002-01-30 | 2002-06-28 | 107.5d | finish no earlier than 2002-06-28 | GP; R3 | 1720h | 1720h | Rel-5 | Paolo |  |  |  |  |
| 4320 | 109.3 | **Voice over GERAN PS and CS concept** | 430d | 2000-11-06 A | 2002-06-28 A | 100% | 2000-11-06 | 2002-06-28 | 430d |  | GP; R3 | 35200h | 35200h | Rel-5 | Paolo |  |  |  |  |
| 4321 | 109.3.1 | Architecture for A, Iu cs and Iu ps | 430d | 2000-11-06 A | 2002-06-28 A | 100% | 2000-11-06 | 2002-06-28 | 430d | finish no earlier than 2002-06-28 | GP; R3 | 6880h | 6880h | Rel-5 | Paolo |  |  |  |  |
| 4322 | 109.3.2 | Transcoder position/operation | 115d | 2000-11-06 A | 2001-04-13 A | 100% | 2000-11-06 | 2001-04-13 | 115d | finish no earlier than 2001-04-13 | GP | 920h | 920h | Rel-5 | Paolo |  |  |  |  |
| 4323 | 109.3.3 | Handover for Voice over GERAN PS and CS | 430d | 2000-11-06 A | 2002-06-28 A | 100% | 2000-11-06 | 2002-06-28 | 430d | finish no earlier than 2002-06-28 | GP; R3 | 6880h | 6880h | Rel-5 | Paolo |  |  |  |  |
| 4324 | 109.3.4 | RTP payload | 430d | 2000-11-06 A | 2002-06-28 A | 100% | 2000-11-06 | 2002-06-28 | 430d | finish no earlier than 2002-06-28 | GP; R3 | 6880h | 6880h | Rel-5 | Paolo |  |  |  |  |
| 4325 | 109.3.5 | Codec renegotiation concept | 365d | 2000-11-06 A | 2002-03-29 A | 100% | 2000-11-06 | 2002-03-29 | 365d | finish no earlier than 2002-03-29 | GP; R3 | 5840h | 5840h | Rel-5 | Paolo |  |  |  |  |
| 4326 | 109.3.6 | LA | 115d | 2000-11-06 A | 2001-04-13 A | 100% | 2000-11-06 | 2001-04-13 | 115d | finish no earlier than 2001-04-13 | GP | 920h | 920h | Rel-5 | Paolo |  |  |  |  |

Notes:
- 4303: -
- 4304: -
- 4305: -
- 4306: -
- 4307: AWS, Nokia, Ericsson, Nortel, Siemens, Vodafone
- 4308: -
- 4309: -
- 4310: -
- 4311: -
- 4312: -
- 4313: -
- 4314: -
- 4315: -
- 4316: -
- 4317: -
- 4318: -
- 4319: -
- 4320: -
- 4321: -
- 4322: -
- 4323: -
- 4324: -
- 4325: -
- 4326: -

| ID | WBS | Task | Duration | Start | Finish | Complete | Baseline start | Baseline finish | Baseline duration | Constraint | Resources | Work | Actual work | Release | MCC resp | TSG stopped | Acronym | WI rapporteur name | WI rapporteur e-mail | Acronym_3GU_Export | Impacted TSs and TRs |
| --- | --- | --- | --- | --- | --- | --- | --- | --- | --- | --- | --- | --- | --- | --- | --- | --- | --- | --- | --- | --- | --- |
| 4327 | 109.4 | **Deleted - GERAN MS Conformance test for GERAN interface evolution** | 660d | 2001-06-11 A | 2003-12-19 A | 100% | 2001-06-11 | 2003-12-19 | 660d |  | GP | 10560h | 10560h | Rel-5 | Paolo | GP-17 |  |  |  |  |  |
| 4328 | 109.4.1 | Deleted - MS test for GERAN interface evolution | 660d | 2001-06-11 A | 2003-12-19 A | 100% | 2001-06-11 | 2003-12-19 | 660d | finish no earlier than 2003-12-19 | GP | 5280h | 5280h | Rel-5 | Paolo | GP-17 |  |  |  |  |  |
| 4329 | 109.5 | **GERAN BSS Conformance test for GERAN interface evolution** | 922d | 2000-06-08 A | 2003-12-19 A | 100% | 2000-06-08 | 2003-12-19 | 922d |  | GP | 14752h | 14752h | Rel-5 | Paolo |  |  |  |  |  |  |
| 4330 | 109.5.1 | Deleted - BSS test | 922d | 2000-06-08 A | 2003-12-19 A | 100% | 2000-06-08 | 2003-12-19 | 922d | finish no earlier than 2003-12-19 | GP | 7376h | 7376h | Rel-5 | Paolo | GP-17 |  |  |  |  |  |
| 4331 | 110 | **GERAN support for IMS** | 690d | 2000-05-01 A | 2002-12-20 A | 100% | 2000-05-01 | 2002-12-20 | 690d |  | GP | 83939.6h | 83939.6h | Rel-5 | Paolo |  | GERIMS | Nokia | Shkumbin Hamiti | GERIMS |  |
| 4332 | 110.1 | **GERAN Header adaptation** | 690d | 2000-05-01 A | 2002-12-20 A | 100% | 2000-05-01 | 2002-12-20 | 690d |  | GP; S2; RP | 40011.6h | 40011.6h | Rel-5 | Paolo |  | GERIMS-HEADAPT | Nokia | Shkumbin Hamiti | GERIMS-HEADAPT |  |
| 4333 | 110.1.1 | Definition of compression and removal modes for PDCP protocol | 29.15d | 2000-07-24 A | 2000-09-01 A | 100% | 2000-07-24 | 2000-09-01 | 29.15d | finish no earlier than 2000-09-01 | GP; S2; RP | 699.6h | 699.6h | Rel-5 | Paolo |  |  |  |  |  |  |
| 4334 | 110.1.2 | Conceptual description in stage 2 | 393d | 2000-05-01 A | 2001-10-31 A | 100% | 2000-05-01 | 2001-10-31 | 393d | finish no earlier than 2001-10-31 | GP; S2; RP | 9432h | 9432h | Rel-5 | Paolo |  |  |  |  |  |  |
| 4335 | 110.1.3 | Necessary changes on stage 3 regarding header removal | 555d | 2000-11-06 A | 2002-12-20 A | 100% | 2000-11-06 | 2002-12-20 | 555d | finish no earlier than 2002-12-20 | GP; S2; RP | 13320h | 13320h | Rel-5 | Paolo |  |  |  |  |  |  |
| 4336 | 110.2 | **Deleted - GERAN Radio access bearer design for IMS** | 430d | 2000-11-06 A | 2002-06-28 A | 100% | 2000-11-06 | 2002-06-28 | 430d |  | GP; S2; RP | 29520h | 29520h | Rel-5 | Paolo | GP-10 | GERIMS-RABDES | Nokia | Shkumbin Hamiti | GERIMS-RABDES |  |
| 4337 | 110.2.1 | **Deleted - MuM control signalling for conversational multimedia services** | 430d | 2000-11-06 A | 2002-06-28 A | 100% | 2000-11-06 | 2002-06-28 | 430d |  | GP; S2; RP | 19200h | 19200h | Rel-5 | Paolo | GP-10 |  |  |  |  |  |
| 4338 | 110.2.1.1 | Deleted - Identification of requirements for MuM control signalling for conversational multimedia services | 330d | 2000-11-06 A | 2002-02-08 A | 100% | 2000-11-06 | 2002-02-08 | 330d | finish no earlier than 2002-02-08 | GP; S2; RP | 7920h | 7920h | Rel-5 | Paolo | GP-08 |  |  |  |  |  |
| 4339 | 110.2.1.2 | Deleted - Necessary modifications due to SIP | 40d | 2002-05-06 A | 2002-06-28 A | 100% | 2002-05-06 | 2002-06-28 | 40d | finish no earlier than 2002-06-28 | GP; S2; RP | 960h | 960h | Rel-5 | Paolo | GP-10 |  |  |  |  |  |
| 4340 | 110.3 | **Deleted - GERAN MS Conformance test for support of IMS** | 400d | 2001-06-11 A | 2002-12-20 A | 100% | 2001-06-11 | 2002-12-20 | 400d |  | GP | 6400h | 6400h | Rel-5 | Paolo | GP-12 | GERIMS-MSconf | Nokia | Shkumbin Hamiti | GERIMS-MSconf |  |
| 4341 | 110.3.1 | Deleted - MS test for support of IMS | 400d | 2001-06-11 A | 2002-12-20 A | 100% | 2001-06-11 | 2002-12-20 | 400d | finish no earlier than 2002-12-20 | G4 | 3200h | 3200h | Rel-5 | Paolo | GP-12 |  |  |  |  |  |
| 4342 | 110.4 | Deleted - GERAN BTS Conformance test for support of IMS | 400d | 2001-06-11 A | 2002-12-20 A | 100% | 2001-06-11 | 2002-12-20 | 400d |  | GP | 3200h | 3200h | Rel-5 | Paolo | GP-12 | GERIMS-BTSconf | Nokia | Shkumbin Hamiti | GERIMS-BTSconf |  |
| 4343 | 1052 | MS Conformance Testing of Dual Transfer Mode | 65d? | 2002-11-11 A | 2003-02-07 A | 100% | 2002-11-11 | 2003-02-07 | 65d? | finish no earlier than 2003-02-07 | G4; G5 | 1040h | 1040h | Rel-5 | Paolo |  | MSCTDTM | Vodafone | Dave Fox | MSCTDTM |  |
| 4344 | 1053 | **Handling of early Ues** | 911d? | 2000-01-03 A | 2003-06-27 A | 100% | 2000-01-03 | 2003-06-27 | 911d? |  | S2 | 4488h | 4488h | Rel-5 | Maurice |  | LATE_UE |  |  | LATE_UE |  |
| 4345 | 1053.1 | Feasibility Study on Handling of early Ues | 50d? | 2002-10-07 A | 2002-12-13 A | 100% | 2002-10-07 | 2002-12-13 | 50d? | finish no earlier than 2002-12-13 | S2 | 400h | 400h | Rel-5 | Maurice |  |  |  |  |  |  |
| 4346 | 1053.2 | Stage 2 for Handling of early Ues | 125d? | 2003-01-06 A | 2003-06-27 A | 100% | 2003-01-06 | 2003-06-27 | 125d? | start no earlier than 2003-01-06 | S2 | 1000h | 1000h | Rel-5 | Maurice |  |  |  |  |  |  |
| 4347 | 1053.3 | FS for the Early Mobile Handling in UTRAN | 195d | 2002-09-09 A | 2003-06-06 A | 100% | 2002-09-09 | 2003-06-06 | 195d | finish no earlier than 2003-06-06 | R2 | 1560h | 1560h | Rel-5 | Yong-Jun |  | FSEarlyUE | Vodafone | alan.law@vodafone.com | FSEarlyUE |  |
| 4348 | 1053.4 | Note: Stage 3 RAN part not shown | 1d | 2000-01-03 A | 2000-01-03 A | 100% | 2000-01-03 | 2000-01-03 | 1d |  | RP | 8h | 8h | Rel-5 |  |  |  |  |  |  |  |
| 4349 | 1054 | Release 4 Features | 326d? | 2000-01-03 A | 2001-03-30 A | 100% | 2000-01-03 | 2001-03-30 | 326d? |  | NP; GP; RP; SP; TP | 13040h | 13040h | Rel-4 | All |  |  |  |  |  |  |
| 4350 | 15 | **Miscellaneous UE Conformance Testing Activities** | 958d | 2001-04-02 A | 2004-12-01 A | 100% | 2001-04-02 | 2004-12-01 | 958d |  | T1 | 36360h | 36360h | Rel-4 | Ingbert |  | MISTST1 |  |  | MISTST1 |  |
| 4351 | 15.1 | Optimization of Test Time, RF Aspects (FDD) | 508d | 2001-09-24 A | 2003-09-03 A | 100% | 2001-09-24 | 2003-09-03 | 508d | finish no earlier than 2003-09-03 | T1 | 4064h | 4064h | Rel-4 | Ingbert |  | MISTST1-OpFDD |  |  | MISTST1-OpFDD | 34.121 |
| 4352 | 15.2 | Optimization of Test Time, RF Aspects (TDD) | 508d | 2001-09-24 A | 2003-09-03 A | 100% | 2001-09-24 | 2003-09-03 | 508d | finish no earlier than 2003-09-03 | T1 | 4064h | 4064h | Rel-4 | Ingbert |  | MISTST1-OpTDD |  |  | MISTST1-OpTDD | 34.122 |
| 4353 | 15.3 | Extensions to R99 Test cases | 139.4w | 2001-04-02 A | 2003-12-02 A | 100% | 2001-04-02 | 2003-12-02 | 139.4w | finish no earlier than 2003-12-02 | T1 | 5576h | 5576h | Rel-4 | Ingbert |  | MISTST1-Ext |  |  | MISTST1-Ext | 34.123 p 1,2 |
| 4354 | 15.4 | Extension to R99 Test cases - TTCN | 439d | 2002-06-28 A | 2004-03-03 A | 100% | 2002-06-28 | 2004-03-03 | 439d | finish no earlier than 2004-03-03 | T1 | 3512h | 3512h | Rel-4 | Ingbert |  |  |  |  |  |  |
| 4355 | 15.5 | Creation of R99 TCs for TDD - prose | 719d | 2001-10-01 A | 2004-07-01 A | 100% | 2001-10-01 | 2004-07-01 | 719d | finish no earlier than 2004-07-01 | T1 | 5752h | 5752h | Rel-4 | Ingbert |  | MISTST1-TDD |  |  | MISTST1-TDD | 34.123-1 |
| 4356 | 15.6 | Deleted - Creation of R99 TCs for TDD - TTCN | 587d | 2002-09-03 A | 2004-12-01 A | 100% | 2002-09-03 | 2004-12-01 | 587d | finish no earlier than 2004-12-01 | T1 | 4696h | 4696h | Rel-4 | Ingbert | TP-26 |  |  |  |  |  |
| 4357 | 15.7 | Deleted - Review all other work items for impact on new or exiting 34 series specs. | 25.8w | 2002-07-02 A | 2002-12-27 A | 100% | 2002-07-02 | 2002-12-27 | 25.8w | finish no earlier than 2002-12-27 | T1 | 1032h | 1032h | Rel-4 | Ingbert | TP-18 |  |  |  |  | 34.121,122,123,125 |

Notes:
- 4327: Not started. Marked as stopped 12/2008
- 4328: Not started. Marked as stopped 12/2008
- 4329: Not started. Marked as stopped 12/2008
- 4330: Not started. Marked as stopped 12/2008
- 4331: AWS, Nokia, Ericsson, Nortel, Siemens, Motorola
- 4332: AWS, Nokia, Ericsson, Nortel, Siemens, Motorola
- 4333: -
- 4334: -
- 4335: -
- 4336: TERMINATED - NOT STANDARDIZED. Marked as stopped 12/2008
- 4337: TERMINATED - NOT STANDARDIZED. Marked as stopped 12/2008
- 4338: TERMINATED - NOT STANDARDIZED
- 4339: TERMINATED - NOT STANDARDIZED
- 4340: TERMINATED - NOT STANDARDIZED. Marked as stopped 12/2008
- 4341: TERMINATED - NOT STANDARDIZED. Marked as stopped 12/2008
- 4342: TERMINATED - NOT STANDARDIZED. Marked as stopped 12/2008
- 4343: Needed to complete DTM (R99)
- 4344: -
- 4345: -
- 4346: -
- 4347: -
- 4348: -
- 4349: -
- 4350: -
- 4351: It is believed that the current R99 test spec. can be optimised for faster overall test times. Marked as stopped 12/2008 (was 70% complete)
- 4352: It is believed that the current R99 test spec. can be optimised for faster overall test times
- 4353: Further test coverage of the R99 specification to cover supplementry services. Marked as stopped 12/2008 (was 70% complete)
- 4354: Marked as closed 12/2008 (was marked 50% complete)
- 4355: Marked as closed 12/2008 (was marked 50% complete)
- 4356: Marked as stopped 12/2008
- 4357: Marked as stopped 12/2008

| ID | WBS | Task | Duration | Start | Finish | Predecessors | Complete | Baseline start | Baseline finish | Baseline duration | Constraint | Resources | Work | Actual work | Acronym | Release | MCC resp | Acronym_3GU_Export | Impacted TSs and TRs | WI rapporteur name | WI rapporteur e-mail |
| --- | --- | --- | --- | --- | --- | --- | --- | --- | --- | --- | --- | --- | --- | --- | --- | --- | --- | --- | --- | --- | --- |
| 4358 | 46 | **Real Time Facsimile** | 89d | 2000-02-22 A | 2000-06-23 A |  | 100% | 2000-02-22 | 2000-06-23 | 89d |  | S1 | 4376h | 4376h | FAX-RT | Rel-4 | Alain | FAX-RT |  |  |  |
| 4359 | 46.1 | **Real Time Fax** | 89d | 2000-02-22 A | 2000-06-23 A |  | 100% | 2000-02-22 | 2000-06-23 | 89d |  | S2 | 3664h | 3664h |  | Rel-4 | Maurice |  |  |  |  |
| 4360 | 46.1.1 | Terminal capabilities, AT commands | 89d | 2000-02-22 A | 2000-06-23 A |  | 100% | 2000-02-22 | 2000-06-23 | 89d | finish no earlier than 2000-06-23 | T2 | 712h | 712h |  | Rel-4 |  |  | 21.904, 27.007 |  |  |
| 4361 | 46.1.2 | Signalling aspects (e.g. ICM) | 89d | 2000-02-22 A | 2000-06-23 A |  | 100% | 2000-02-22 | 2000-06-23 | 89d | start no earlier than 2000-02-22 | N1 | 712h | 712h |  | Rel-4 | Frederic |  |  |  |  |
| 4362 | 46.1.3 | Service provision | 89d | 2000-02-22 A | 2000-06-23 A |  | 100% | 2000-02-22 | 2000-06-23 | 89d | finish no earlier than 2000-06-23 | N3 | 712h | 712h |  | Rel-4 | Gwiho |  | 23.146 |  |  |
| 4363 | 46.1.4 | Review whether service/stage 1 aspects need to be aligned | 51d | 2000-04-14 A | 2000-06-23 A |  | 100% | 2000-04-14 | 2000-06-23 | 51d | finish no earlier than 2000-12-14 | S1 | 408h | 408h |  | Rel-4 | Alain |  |  |  |  |
| 4364 | 46.1.5 | Review whether architecture/stage 2 aspects need to be aligned | 51d | 2000-04-14 A | 2000-06-23 A |  | 100% | 2000-04-14 | 2000-06-23 | 51d | finish no earlier than 2000-12-14 | S2 | 408h | 408h |  | Rel-4 | Maurice |  |  |  |  |
| 4365 | 47 | Transparent End-to-End PS mobile streaming application | 253d | 2000-04-03 A | 2001-03-21 A |  | 100% | 2000-04-03 | 2001-03-21 | 253d | finish no earlier than 2000-12-29 | S4 | 2024h | 2024h | PSTREAM | Rel-4 | Paolo | PSTREAM | 26.233, 26.234 |  |  |
| 4366 | 48 | **Multimedia Messaging** | 277d | 2000-02-22 A | 2001-03-14 A |  | 100% | 2000-02-22 | 2001-03-14 | 277d |  | T2; S1 | 14424h | 14424h | MMS4 | Rel-4 | Kimmo | MMS, Rel-4 | 22.140, 23.140 | Siemens | Josef.Laumen@SAL.SIEMENS.DE |
| 4367 | 48.1 | Definition of service requirements for Multimedia Messaging | 72d | 2000-02-22 A | 2000-05-31 A |  | 100% | 2000-02-22 | 2000-05-31 | 72d | start no earlier than 2000-02-22 | S1 | 576h | 576h |  | Rel-4 | Alain |  |  |  |  |
| 4368 | 48.2 | Review of definition of service requirements | 205d | 2000-06-01 A | 2001-03-14 A | 4367 | 100% | 2000-06-01 | 2001-03-14 | 205d | finish no earlier than 2000-09-08 | T2 | 1640h | 1640h |  | Rel-4 | Kimmo |  | 22.140, 23.140 | Siemens |  |
| 4369 | 48.3 | **Technical Realisation** | 243d | 2000-04-10 A | 2001-03-14 A |  | 100% | 2000-04-10 | 2001-03-14 | 243d |  | T2 | 7776h | 7776h |  | Rel-4 | Kimmo |  | 22.140, 23.140 | Siemens | Josef.Laumen@SAL.SIEMENS.DE |
| 4370 | 48.3.1 | Review of definition of reference Achitecture model | 243d | 2000-04-10 A | 2001-03-14 A |  | 100% | 2000-04-10 | 2001-03-14 | 243d | finish no earlier than 2001-03-14 | T2 | 1944h | 1944h |  | Rel-4 | Kimmo |  | 22.140, 23.140 | Siemens | Josef.Laumen@SAL.SIEMENS.DE |
| 4371 | 48.3.2 | Fulfill Requirements of Stage 1 | 243d | 2000-04-10 A | 2001-03-14 A |  | 100% | 2000-04-10 | 2001-03-14 | 243d | finish no earlier than 2001-03-14 | T2 | 1944h | 1944h |  | Rel-4 | Kimmo |  | 22.140, 23.140 | Siemens | Josef.Laumen@SAL.SIEMENS.DE |
| 4372 | 48.3.3 | Definition of MMS primitives in Stage 2 | 243d | 2000-04-10 A | 2001-03-14 A |  | 100% | 2000-04-10 | 2001-03-14 | 243d | finish no earlier than 2001-03-14 | T2 | 1944h | 1944h |  | Rel-4 | Kimmo |  | 22.140, 23.140 | Siemens | Josef.Laumen@SAL.SIEMENS.DE |
| 4373 | 49 | **Transcoder-Free Operation** | 326d | 2000-01-03 A | 2001-03-30 A |  | 100% | 2000-01-03 | 2001-03-30 | 326d |  | N4; S2; N1 | 18272h | 18272h | TrFO | Rel-4 | Kimmo | TrFO |  |  |  |
| 4374 | 49.1 | **Out-of-Band Transcoder Control solution** | 326d | 2000-01-03 A | 2001-03-30 A |  | 100% | 2000-01-03 | 2001-03-30 | 326d |  | N4 | 8448h | 8448h | TrFO-OoBTC | Rel-4 | Kimmo | TrFO-OoBTC |  | NEC | Toshiyuki Tamura (tamurato@aj.jp.nec.com) |
| 4375 | 49.1.1 | implementation in UTRAN | 145d | 2000-09-11 A | 2001-03-30 A |  | 100% | 2000-09-11 | 2001-03-30 | 145d | finish no earlier than 2001-03-30 | R3 | 1160h | 1160h | TrFO-OoBTC-UTRAN | Rel-4 | Juha | TrFO-OoBTC-UTRAN | 25.401, 25.410, 25.413, 25.415, 23.153 | Siemens | Alexander Vesely |
| 4376 | 49.1.2 | Impact on architecture, Principles and Terminology | 211d | 2000-01-03 A | 2000-10-20 A |  | 100% | 2000-01-03 | 2000-10-20 | 211d | finish no earlier than 2000-10-20 | S2 | 1680h | 1680h |  | Rel-4 | Maurice |  |  |  |  |
| 4377 | 49.1.3 | Codec Negotiation between UE and MSC | 125d | 2000-08-14 A | 2001-02-02 A |  | 100% | 2000-08-14 | 2001-02-02 | 125d | finish no earlier than 2001-02-02 | N1 | 1000h | 1000h |  | Rel-4 | Frederic |  | 24.008, 23.009, 23.108, (29.002) | Motorola | Andrew Howell |
| 4378 | 49.1.4 | Codec Negotiation inter MSC | 125d | 2000-07-03 A | 2000-12-22 A |  | 100% | 2000-07-03 | 2000-12-22 | 125d | finish no earlier than 2000-12-22 | N4 | 1000h | 1000h |  | Rel-4 | Kimmo |  |  |  |  |
| 4379 | 49.1.5 | Bearer establishment inter MSC | 125d | 2000-07-03 A | 2000-12-22 A |  | 100% | 2000-07-03 | 2000-12-22 | 125d | finish no earlier than 2000-12-22 | N4 | 1000h | 1000h |  | Rel-4 | Kimmo |  | 23.153 |  |  |
| 4380 | 49.2 | **Speech Transcoder: Location and Control at the UMTS Core Network Border** | 125d | 2000-04-10 A | 2000-09-29 A |  | 100% | 2000-04-10 | 2000-09-29 | 125d |  | S2 | 2000h | 2000h | TrFO-STLC | Rel-4 | Maurice | TrFO-STLC |  |  |  |
| 4381 | 49.2.1 | Transcoder at Edge | 125d | 2000-04-10 A | 2000-09-29 A |  | 100% | 2000-04-10 | 2000-09-29 | 125d | finish no earlier than 2000-09-29 | NP | 1000h | 1000h |  | Rel-4 | Kimmo |  |  |  |  |

Notes:
- 4358: -
- 4359: postponed from R99 to R00, SP-000169
- 4360: -
- 4361: -
- 4362: -
- 4363: -
- 4364: -
- 4365: -
- 4366: Acronym changed from "MMS, Rel-4"
- 4367: -
- 4368: -
- 4369: -
- 4370: -
- 4371: e.g. minimum set of media formats, media format conversion, personalization of MMS.
- 4372: -
- 4373: Lead given to CN4 from CN / [DAB 28/11/00]
- 4374: -
- 4375: moved according to NP-000575
- 4376: e.g. study cascading TrFO/TFO/TrFO
- 4377: the link to NP-000085has been deleted because refering to a R99 status sheet / One common set of codec negotiation procedures will be specified as in ID1656.
- 4378: Bearer establishment inter MSC. TS 23.153 R99 part complete. capabilities moved to annex + list of open issues
- 4379: Bearer establishment inter MSC. TS 23.153 R99 part complete. capabilities moved to annex. / See NP-000127 / Open issues: / Handling of Conference Calls; / Handling of Multi Party Supplementary Services; / Handling of Handover UMTS to GSM; / Handling of Sending a ...
- 4380: WI description and Tdoc S2-99352 / Speech Transcoder: Location and Control at the UMTS Core Network Border
- 4381: WI description and Tdoc S2-99352...

| ID | WBS | Task | Duration | Start | Finish | Complete | Baseline start | Baseline finish | Baseline duration | Constraint | Resources | Work | Actual work | Acronym | Release | MCC resp | Acronym_3GU_Export | WI rapporteur name | WI rapporteur e-mail |
| --- | --- | --- | --- | --- | --- | --- | --- | --- | --- | --- | --- | --- | --- | --- | --- | --- | --- | --- | --- |
| 4382 | 50 | **GERAN improvements 1 (Gb over IP)** | 225d | 2000-05-09 A | 2001-03-19 A | 100% | 2000-05-09 | 2001-03-19 | 225d |  | GP | 6472h | 6472h | GEIMP1 | Rel-4 | Paolo | GEIMP1 |  |  |
| 4383 | 50.1 | **Gb over IP (Ip-fication of Gb)** | 225d | 2000-05-09 A | 2001-03-19 A | 100% | 2000-05-09 | 2001-03-19 | 225d |  | GP | 4672h | 4672h | GbIP | Rel-4 | Paolo | GbIP |  |  |
| 4384 | 50.1.1 | Concept of Gb over IP (Ip-fication of Gb) | 134d | 2000-05-09 A | 2000-11-10 A | 100% | 2000-05-09 | 2000-11-10 | 134d |  | GP | 1072h | 1072h |  | Rel-4 | Paolo |  |  |  |
| 4385 | 50.1.2 | Changes to 08.16, 08.18 | 225d | 2000-05-09 A | 2001-03-19 A | 100% | 2000-05-09 | 2001-03-19 | 225d |  | GP | 1800h | 1800h |  | Rel-4 | Paolo |  |  |  |
| 4386 | 51 | **GERAN improvements 2 (NACC)** | 677d | 2000-11-06 A | 2003-06-10 A | 100% | 2000-11-06 | 2003-06-10 | 677d |  | GP | 22408h | 22408h | GEIMP2 | Rel-4 | Paolo | GEIMP2 |  |  |
| 4387 | 51.1 | **Gb enhancements** | 155d | 2000-11-06 A | 2001-06-08 A | 100% | 2000-11-06 | 2001-06-08 | 155d |  | GP | 7440h | 7440h | Gben | Rel-4 | Paolo | Gben |  |  |
| 4388 | 51.1.1 | **Intra BSC NACC (Network Assisted Cell Change)** | 155d | 2000-11-06 A | 2001-06-08 A | 100% | 2000-11-06 | 2001-06-08 | 155d |  | GP | 6200h | 6200h |  | Rel-4 | Paolo |  |  |  |
| 4389 | 51.1.1.1 | Concept | 155d | 2000-11-06 A | 2001-06-08 A | 100% | 2000-11-06 | 2001-06-08 | 155d | finish no earlier than 2001-06-08 | GP | 1240h | 1240h |  | Rel-4 | Paolo |  |  |  |
| 4390 | 51.1.1.2 | Changes in 03.64 | 155d | 2000-11-06 A | 2001-06-08 A | 100% | 2000-11-06 | 2001-06-08 | 155d | finish no earlier than 2001-06-08 | GP | 1240h | 1240h |  | Rel-4 | Paolo |  |  |  |
| 4391 | 51.1.1.3 | Changes in 04.60 | 155d | 2000-11-06 A | 2001-06-08 A | 100% | 2000-11-06 | 2001-06-08 | 155d | finish no earlier than 2001-06-08 | GP | 1240h | 1240h |  | Rel-4 | Paolo |  |  |  |
| 4392 | 51.1.1.4 | Changes in 44.008 | 155d | 2000-11-06 A | 2001-06-08 A | 100% | 2000-11-06 | 2001-06-08 | 155d | finish no earlier than 2001-06-08 | GP | 1240h | 1240h |  | Rel-4 | Paolo |  |  |  |
| 4393 | 51.3 | **MS conformance test for Intra BSC NACC** | 398d | 2001-11-30 A | 2003-06-10 A | 100% | 2001-11-30 | 2003-06-10 | 398d |  | GP | 9552h | 9552h | GEIMP2-Msconf | Rel-4 | Paolo | GEIMP2-Msconf |  |  |
| 4394 | 51.3.1 | Changes in 51.010 | 398d | 2001-11-30 A | 2003-06-10 A | 100% | 2001-11-30 | 2003-06-10 | 398d | finish no earlier than 2003-12-19 | G5; G4 | 6368h | 6368h |  | Rel-4 | Paolo |  |  |  |
| 4395 | 52 | **GERAN improvements 4 (Delayed TBF)** | 105d | 2001-01-15 A | 2001-06-08 A | 100% | 2001-01-15 | 2001-06-08 | 105d |  | GP | 3960h | 3960h | GEIMP4 | Rel-4 | Paolo | GEIMP4 |  |  |
| 4396 | 52.1 | **Gb enhancements 2** | 105d | 2001-01-15 A | 2001-06-08 A | 100% | 2001-01-15 | 2001-06-08 | 105d |  | GP | 3120h | 3120h | GEIMP4-Gben2 | Rel-4 | Paolo | GEIMP4-Gben2 |  |  |
| 4397 | 52.1.1 | Stage 2 for Gb enhancements 2 | 105d | 2001-01-15 A | 2001-06-08 A | 100% | 2001-01-15 | 2001-06-08 | 105d | finish no earlier than 2001-06-08 | GP | 840h | 840h |  | Rel-4 | Paolo |  |  |  |
| 4398 | 52.1.2 | **Stage 3 (changes in 44.060)** | 60d | 2001-01-15 A | 2001-04-06 A | 100% | 2001-01-15 | 2001-04-06 | 60d |  | G2 | 1440h | 1440h |  | Rel-4 | Gert |  |  |  |
| 4399 | 52.1.2.1 | Definition of enhanced countdown procedure | 60d | 2001-01-15 A | 2001-04-06 A | 100% | 2001-01-15 | 2001-04-06 | 60d | finish no earlier than 2001-04-06 | G2 | 480h | 480h |  | Rel-4 | Gert |  |  |  |
| 4400 | 52.1.2.2 | Definition of enhanced TBF release procedure | 60d | 2001-01-15 A | 2001-04-06 A | 100% | 2001-01-15 | 2001-04-06 | 60d | finish no earlier than 2001-04-06 | G2 | 480h | 480h |  | Rel-4 | Gert |  |  |  |
| 4401 | 52.1.2.3 | Definition of USF=FREE type polling mechanism on PDCH | 60d | 2001-01-15 A | 2001-04-06 A | 100% | 2001-01-15 | 2001-04-06 | 60d | finish no earlier than 2001-04-06 | G2 | 480h | 480h |  | Rel-4 | Gert |  |  |  |
| 4402 | 53 | **Low Chip Rate TDD option** | 880d | 2000-07-19 A | 2003-12-02 A | 100% | 2000-07-19 | 2003-12-02 | 880d |  | R1 | 27488h | 27488h | LCRTDD | Rel-4 | Patrick | LCRTDD | CWTS | G. Yang |
| 4403 | 53.1 | Physical layer for Low Chip Rate TDD option | 183d | 2000-07-19 A | 2001-03-30 A | 100% | 2000-07-19 | 2001-03-30 | 183d | finish no earlier than 2001-03-30 | R1 | 1464h | 1464h | LCRTDD-Phys | Rel-4 | Patrick | LCRTDD-Phys | CWTS | G. Yang |
| 4404 | 53.2 | Layer 2 and layer 3 protocol aspects | 183d | 2000-07-19 A | 2001-03-30 A | 100% | 2000-07-19 | 2001-03-30 | 183d | finish no earlier than 2001-03-30 | R2 | 1464h | 1464h | LCRTDD-L23 | Rel-4 | Yong-Jun | LCRTDD-L23 | CWTS | Y. Liu |
| 4405 | 53.3 | RF radio transmission/reception, system performance requirements and conformance testing | 165d | 2000-08-14 A | 2001-03-30 A | 100% | 2000-08-14 | 2001-03-30 | 165d | finish no earlier than 2001-03-30 | R4 | 1320h | 1320h | LCRTDD-RF | Rel-4 | Issam | LCRTDD-RF | CWTS | D. Zhang |
| 4406 | 53.4 | UE radio access capability | 165d | 2000-08-14 A | 2001-03-30 A | 100% | 2000-08-14 | 2001-03-30 | 165d | finish no earlier than 2001-03-30 | R2 | 1320h | 1320h | LCRTDD-UErac | Rel-4 | Yong-Jun | LCRTDD-UErac | CWTS | Y. Liu |
| 4407 | 53.5 | Iub/Iur protocol aspects - for Low Chip Rate TDD option | 165d | 2000-08-14 A | 2001-03-30 A | 100% | 2000-08-14 | 2001-03-30 | 165d | finish no earlier than 2001-03-30 | R3 | 1320h | 1320h | LCRTDD-IubIur | Rel-4 | Juha | LCRTDD-IubIur | CWTS | Y. Liu |

Notes:
- 4382: -
- 4383: -
- 4384: -
- 4385: -
- 4386: -
- 4387: -
- 4388: -
- 4389: -
- 4390: -
- 4391: -
- 4392: -
- 4393: -
- 4394: az 05/08: duplicated UID_50099 => 50299. Marked as closed 12/2008 (was marked 50% complete)
- 4395: -
- 4396: -
- 4397: -
- 4398: -
- 4399: -
- 4400: -
- 4401: -
- 4402: -
- 4403: -
- 4404: -
- 4405: -
- 4406: -
- 4407: -

| ID | WBS | Task | Duration | Start | Finish | Predecessors | Complete | Baseline start | Baseline finish | Baseline duration | Constraint | Resources | Work | Actual work | Release | MCC resp | Impacted TSs and TRs | TSG stopped | Acronym | WI rapporteur name | WI rapporteur e-mail | Acronym_3GU_Export |
| --- | --- | --- | --- | --- | --- | --- | --- | --- | --- | --- | --- | --- | --- | --- | --- | --- | --- | --- | --- | --- | --- | --- |
| 4408 | 53.6 | **Low chiprate TDD interworking with GERAN** | 101d | 2000-09-01 A | 2001-01-19 A | 4407 | 100% | 2000-09-01 | 2001-01-19 | 101d |  | GP | 1616h | 1616h | Rel-4 | Paolo |  |  |  |  |  |  |
| 4409 | 53.6.1 | Handover and Cell Selection / Reselection to UTRA 1.28 Mcps TDD | 101d | 2000-09-01 A | 2001-01-19 A |  | 100% | 2000-09-01 | 2001-01-19 | 101d | finish no earlier than 2001-01-19 | GP | 808h | 808h | Rel-4 | Paolo |  |  |  |  |  |  |
| 4410 | 53.8 | **Conformance Test Aspects - Low Chip Rate TDD** | 577d | 2001-09-17 A | 2003-12-02 A | 4408 | 100% | 2001-09-17 | 2003-12-02 | 577d |  | T1 | 12088h | 12088h | Rel-4 | Ingbert |  |  |  |  |  |  |
| 4411 | 53.8.1 | Testing Layer 2 and layer 3 protocol aspects | 468d | 2001-09-17 A | 2003-07-02 A |  | 100% | 2001-09-17 | 2003-07-02 | 468d | finish no earlier than 2003-07-02 | T1 | 3744h | 3744h | Rel-4 | Ingbert | 34.123-1, 34.123-2 |  |  |  |  |  |
| 4412 | 53.8.2 | Deleted - Testing Layer 2 and layer 3 protocol aspects - TTCN | 261d | 2002-12-03 A | 2003-12-02 A |  | 100% | 2002-12-03 | 2003-12-02 | 261d | finish no earlier than 2003-12-02 | T1 | 2088h | 2088h | Rel-4 | Ingbert | 34.123-3 | TP-22 |  |  |  |  |
| 4413 | 53.8.3 | Testing RF Radio Transmission and Reception | 205d | 2001-09-17 A | 2002-06-28 A |  | 100% | 2001-09-17 | 2002-06-28 | 205d | finish no earlier than 2002-06-28 | T1 | 1640h | 1640h | Rel-4 | Ingbert |  |  |  |  |  |  |
| 4414 | 54 | **Enable bearer independent CS architecture** | 566d | 2000-01-03 A | 2002-03-01 A |  | 100% | 2000-01-03 | 2002-03-01 | 566d |  | S2; N3; N4 | 28008h | 28008h | Rel-4 | Maurice |  |  | CSSPLIT | Siemens | Alexander Milinski | CSSPLIT |
| 4415 | 54.1 | **Enable bearer-independent call control** | 425d | 2000-01-03 A | 2001-08-16 A |  | 100% | 2000-01-03 | 2001-08-16 | 425d |  | N4 | 12344h | 12344h | Rel-4 | Kimmo |  |  |  | Ericsson | Heinz-Peter.Keutmann@eed.ericsson.se |  |
| 4416 | 54.1.1 | Architecture and Stage 2 description | 181d | 2000-01-03 A | 2000-09-08 A |  | 100% | 2000-01-03 | 2000-09-08 | 181d | finish no earlier than 2000-09-08 | S2 | 1440h | 1440h | Rel-4 | Maurice | 23.002 |  |  |  |  |  |
| 4417 | 54.1.2 | Standardisation of protocols (control & user planes) over Nb interface | 64d | 2001-01-02 A | 2001-03-30 A |  | 100% | 2001-01-02 | 2001-03-30 | 64d | finish no earlier than 2001-03-30 | N3 | 512h | 512h | Rel-4 | Gwiho |  |  |  |  |  |  |
| 4418 | 54.1.3 | Standardisation of protocols over reference points between MSC server and Gateway MSC server | 130d | 2000-09-25 A | 2001-03-23 A |  | 100% | 2000-09-25 | 2001-03-23 | 130d | finish no earlier than 2001-03-23 | N4 | 1040h | 1040h | Rel-4 | Kimmo |  |  |  |  |  |  |
| 4419 | 54.1.4 | Standardisation of detailed stage 2 description | 180d | 2000-07-17 A | 2001-03-23 A |  | 100% | 2000-07-17 | 2001-03-23 | 180d | finish no earlier than 2001-03-23 | N4 | 1440h | 1440h | Rel-4 | Kimmo |  |  |  |  |  |  |
| 4420 | 54.1.5 | **Bearer control between MSC server and MGW** | 250d | 2000-09-01 A | 2001-08-16 A |  | 100% | 2000-09-01 | 2001-08-16 | 250d |  | N4 | 4512h | 4512h | Rel-4 | Kimmo |  |  |  |  |  |  |
| 4421 | 54.1.5.1 | stage 3 - protocol issues | 250d | 2000-09-01 A | 2001-08-16 A |  | 100% | 2000-09-01 | 2001-08-16 | 250d | finish no earlier than 2001-08-16 | N4 | 2000h | 2000h | Rel-4 | Kimmo |  |  |  |  |  |  |
| 4422 | 54.1.5.2 | stage 3 - parameter value issues | 64d | 2001-01-02 A | 2001-03-30 A |  | 100% | 2001-01-02 | 2001-03-30 | 64d | finish no earlier than 2001-03-30 | N3 | 512h | 512h | Rel-4 | Gwiho |  |  |  |  |  |  |
| 4423 | 54.4 | Deleted - Conformance Test Aspects - Enable bearer independent CS architecture | 260d | 2001-03-05 A | 2002-03-01 A |  | 100% | 2001-03-05 | 2002-03-01 | 260d |  | T1 | 2080h | 2080h | Rel-4 | Ingbert |  | TP-15 | CSSPLIT-TEST |  |  | CSSPLIT-TEST |
| 4424 | 55 | **MExE enhancements Rel-4** | 511d | 2000-01-03 A | 2001-12-14 A |  | 100% | 2000-01-03 | 2001-12-14 | 511d |  | T2; S3 | 26912h | 26912h | Rel-4 | Kimmo |  |  | MEXE |  |  | MEXE |
| 4425 | 55.1 | **MExE Security Analysis Activity** | 474d | 2000-02-22 A | 2001-12-14 A |  | 100% | 2000-02-22 | 2001-12-14 | 474d |  | S3; T2 | 12256h | 12256h | Rel-4 | Mirko |  |  | MEXE-SEC | BT | Andrew.Myers@bt.com | MEXE-SEC |
| 4426 | 55.1.1 | Stage 3 for MExE Security | 370d | 2000-07-17 A | 2001-12-14 A |  | 100% | 2000-07-17 | 2001-12-14 | 370d | finish no earlier than 2001-12-14 | S3 | 2960h | 2960h | Rel-4 | Mirko | 21.133, 33.102 |  |  | BT | Andrew.Myers@bt.com |  |
| 4427 | 55.1.2 | Terminal aspects for MExE Security | 214d | 2000-02-22 A | 2000-12-15 A |  | 100% | 2000-02-22 | 2000-12-15 | 214d | finish no earlier than 2000-12-15 | T2 | 1712h | 1712h | Rel-4 |  | 23.057 |  |  | BT | Andrew.Myers@bt.com |  |
| 4428 | 55.2 | **MExE Rel-4 Improvements and Investigations** | 251d | 2000-01-03 A | 2000-12-15 A |  | 100% | 2000-01-03 | 2000-12-15 | 251d |  | T2 | 6480h | 6480h | Rel-4 | Kimmo | 22.057, 23.057 |  | MEXE-ENHANC | Motorola | Mark Cataldo | MEXE-ENHANC |
| 4429 | 55.2.1 | 3rd MExE classmark | 251d | 2000-01-03 A | 2000-12-15 A |  | 100% | 2000-01-03 | 2000-12-15 | 251d | finish no earlier than 2000-12-15 | T2 | 2000h | 2000h | Rel-4 | Kimmo | 22.057, 23.057 |  |  | Motorola | Mark Cataldo |  |
| 4430 | 55.2.2 | FS on Secure download mechanism and capabilities to support SDR concepts | 225d | 2000-02-07 A | 2000-12-15 A |  | 100% | 2000-02-07 | 2000-12-15 | 225d | finish no earlier than 2000-12-15 | T2 | 1800h | 1800h | Rel-4 | Kimmo | 22.057, 23.057 |  |  | Motorola | Mark Cataldo |  |
| 4431 | 55.2.3 | FS on Support of MP3/MPEG4 content | 225d | 2000-02-07 A | 2000-12-15 A |  | 100% | 2000-02-07 | 2000-12-15 | 225d | finish no earlier than 2000-12-15 | T2 | 1800h | 1800h | Rel-4 | Kimmo | 22.057, 23.057 |  |  | Motorola | Mark Cataldo |  |

Notes:
- 4408: -
- 4409: -
- 4410: -
- 4411: Marked as closed 12/2008 (was marked 60% complete)
- 4412: Marked as stopped 12/2008
- 4413: duration set to 6 months (was 0), finish date set
- 4414: -
- 4415: DAB 12.12.01 should be 100% hence closed
- 4416: R00 stage 2 at least 80 % complete in TSGS #8 21.-23.6.2000
- 4417: -
- 4418: -
- 4419: -
- 4420: -
- 4421: -
- 4422: -
- 4423: Marked as stopped 12/2008
- 4424: -
- 4425: SP#12 updated WID
- 4426: -
- 4427: -
- 4428: -
- 4429: Additional features for MExE R2000
- 4430: -
- 4431: -

| ID | WBS | Task | Duration | Start | Finish | Complete | Baseline start | Baseline finish | Baseline duration | Constraint | Resources | Work | Actual work | Acronym | Release | MCC resp | Acronym_3GU_Export | Impacted TSs and TRs | WI rapporteur name | WI rapporteur e-mail |
| --- | --- | --- | --- | --- | --- | --- | --- | --- | --- | --- | --- | --- | --- | --- | --- | --- | --- | --- | --- | --- |
| 4432 | 56 | **Tandem Free aspects for 3G and between 2G and 3G systems** | 344d | 2000-02-22 A | 2001-06-15 A | 100% | 2000-02-22 | 2001-06-15 | 344d |  | S4 | 9696h | 9696h | TFO | Rel-4 | Paolo | TFO |  |  |  |
| 4433 | 56.1 | **Tandem Free AMR** | 344d | 2000-02-22 A | 2001-06-15 A | 100% | 2000-02-22 | 2001-06-15 | 344d |  | S4 | 6944h | 6944h | TFO-AMR | Rel-4 | Paolo | TFO-AMR |  |  |  |
| 4434 | 56.1.1 | Specification of Tandem Free AMR | 284d | 2000-02-22 A | 2001-03-23 A | 100% | 2000-02-22 | 2001-03-23 | 284d | start no earlier than 2000-02-22 | S4 | 2272h | 2272h |  | Rel-4 | Paolo |  | 28.062 |  |  |
| 4435 | 56.1.2 | **Impact of Tandem Free AMR on:** | 115d | 2001-01-08 A | 2001-06-15 A | 100% | 2001-01-08 | 2001-06-15 | 115d |  | NP | 1920h | 1920h |  | Rel-4 | Kimmo |  |  |  |  |
| 4436 | 56.1.2.1 | CN | 60d | 2001-03-26 A | 2001-06-15 A | 100% | 2001-03-26 | 2001-06-15 | 60d | finish no earlier than 2001-06-15 | NP | 480h | 480h |  | Rel-4 | Kimmo |  |  |  |  |
| 4437 | 56.1.2.2 | GERAN | 65d | 2001-01-08 A | 2001-04-06 A | 100% | 2001-01-08 | 2001-04-06 | 65d | finish no earlier than 2001-04-06 | GP | 520h | 520h |  | Rel-4 | Paolo |  |  |  |  |
| 4438 | 57 | **Advanced Speech Call Items enhancements_Rel-4** | 334d | 2000-12-03 A | 2002-03-14 A | 100% | 2000-12-03 | 2002-03-14 | 334d |  | N1 | 5925.6h | 5925.6h | ASCI4 | Rel-4 | Frederic | ASCI, Rel-4 |  | Nortel | sonia.garapaty@nortelnetworks.com |
| 4439 | 57.1 | Stage 2 for Advanced Speech Call Items enhancements_Rel-4 (ASCI) | 326.7d | 2000-12-03 A | 2002-03-14 A | 100% | 2000-12-03 | 2002-03-14 | 326.7d | finish no earlier than 2002-03-14 | N4 | 2613.6h | 2613.6h |  | Rel-4 | Kimmo |  | 23.067, 24.067 | Sagem | Vivien Perlic |
| 4440 | 57.2 | Stages 2 and 3 on A interface | 80d | 2000-12-03 A | 2001-03-23 A | 100% | 2000-12-03 | 2001-03-23 | 80d | finish no earlier than 2001-03-23 | N1 | 640h | 640h |  | Rel-4 | Frederic |  | 44.068, 44.069, 24.008 | Nortel | sonia.garapaty@nortelnetworks.com |
| 4441 | 58 | **700 MHz spectrum support** | 776d | 2000-01-03 A | 2002-12-20 A | 100% | 2000-01-03 | 2002-12-20 | 776d |  | GP | 20016h | 20016h | 700SS | Rel-4 | Paolo | 700SS |  |  |  |
| 4442 | 58.1 | **GERAN support for the 700 MHz band** | 276d | 2000-01-03 A | 2001-01-19 A | 100% | 2000-01-03 | 2001-01-19 | 276d |  | GP | 8808h | 8808h |  | Rel-4 | Paolo |  |  |  |  |
| 4443 | 58.1.1 | Signalling support | 276d | 2000-01-03 A | 2001-01-19 A | 100% | 2000-01-03 | 2001-01-19 | 276d | finish no earlier than 2001-01-19 | GP | 2200h | 2200h |  | Rel-4 | Paolo |  |  |  |  |
| 4444 | 58.1.2 | Physical layer definitions - for GERAN support for the 700 MHz band | 276d | 2000-01-03 A | 2001-01-19 A | 100% | 2000-01-03 | 2001-01-19 | 276d | finish no earlier than 2001-01-19 | GP | 2200h | 2200h |  | Rel-4 | Paolo |  |  |  |  |
| 4445 | 58.1.3 | Receiver performance and RF budget | 276d | 2000-01-03 A | 2001-01-19 A | 100% | 2000-01-03 | 2001-01-19 | 276d | finish no earlier than 2001-01-19 | GP | 2200h | 2200h |  | Rel-4 | Paolo |  |  |  |  |
| 4446 | 58.2 | GERAN MS Conformance test for 700 MHz band | 175d | 2001-04-02 A | 2001-11-30 A | 100% | 2001-04-02 | 2001-11-30 | 175d |  | GP | 1400h | 1400h |  | Rel-4 | Paolo |  |  |  |  |
| 4447 | 58.3 | GERAN BTS Conformance test for 700 MHz band | 450d | 2001-04-02 A | 2002-12-20 A | 100% | 2001-04-02 | 2002-12-20 | 450d |  | GP | 3600h | 3600h |  | Rel-4 | Paolo |  |  |  |  |
| 4448 | 59 | Operator Determined Barring for Packet Oriented Services | 208d | 2000-06-01 A | 2001-03-19 A | 100% | 2000-06-01 | 2001-03-19 | 208d | finish no earlier than 2001-03-19 | NP | 1664h | 1664h | ODB | Rel-4 | Kimmo | ODB |  | NEC | Toshiyuki Tamura (tamurato@aj.jp.nec.com) |
| 4449 | 60 | **UMTS QoS Architecture for PS Domain** | 759d | 2000-01-03 A | 2002-11-27 A | 100% | 2000-01-03 | 2002-11-27 | 759d |  | S2; S5; R3; GP | 72848h | 72848h | QoSPS | Rel-4 | Maurice | QoSPS |  | Ericsson | Ina.widegren@era.ericsson.se |
| 4450 | 60.1 | Architecture | 153d | 2000-06-05 A | 2001-01-03 A | 100% | 2000-06-05 | 2001-01-03 | 153d | finish no earlier than 2001-01-03 | S2 | 1224h | 1224h |  | Rel-4 | Maurice |  | 23.107 |  |  |
| 4451 | 60.2 | Charging and OAM&P for QoS Management | 201d | 2001-09-21 A | 2002-06-28 A | 100% | 2001-09-21 | 2002-06-28 | 201d | finish no earlier than 2002-06-28 | S5 | 1608h | 1608h | QoSPS-OAM | Rel-4 | Mirko | QoSPS-OAM | 32-series |  |  |
| 4452 | 60.3 | **RAB Quality of Service (re)Negotiation over Iu** | 155d | 2000-08-21 A | 2001-03-23 A | 100% | 2000-08-21 | 2001-03-23 | 155d |  | R3 | 3648h | 3648h | QoSPS-MAPEND-RABQoS | Rel-4 | Juha | QoSPS-MAPEND-RABQoS | 25.413 | Ericsson | anders.molander@ericsson.com |
| 4453 | 60.3.1 | RAB Quality of Service Negotiation over Iu | 155d | 2000-08-21 A | 2001-03-23 A | 100% | 2000-08-21 | 2001-03-23 | 155d | finish no earlier than 2001-03-23 | R3 | 1240h | 1240h | QoSPS-MAPEND-RABQoS-Negot | Rel-4 | Juha | QoSPS-MAPEND-RABQoS-Negot |  | Ericsson | anders.molander@ericsson.com |
| 4454 | 60.3.2 | RAB Quality of Service Negotiation over Iu during relocation | 16d | 2001-03-02 A | 2001-03-23 A | 100% | 2001-03-02 | 2001-03-23 | 16d | start no earlier than 2001-03-02 | R3 | 128h | 128h | QoSPS-MAPEND-RABQoS-NegotReloc | Rel-4 | Juha | QoSPS-MAPEND-RABQoS-NegotReloc |  |  |  |
| 4455 | 60.3.3 | RAB Quality of Service Re-Negotiation over Iu | 130d | 2000-09-25 A | 2001-03-23 A | 100% | 2000-09-25 | 2001-03-23 | 130d | finish no earlier than 2001-03-23 | R3 | 1040h | 1040h | QoSPS-MAPEND-RABQoS-ReNegot | Rel-4 | Juha | QoSPS-MAPEND-RABQoS-ReNegot |  | Motorola | S. Irwin |

Notes:
- 4432: RAN and CN to verify no problems for GSM terminals roaming in 3G R99
- 4433: RAN and CN to verify UMTS_AMR_2 support
- 4434: -
- 4435: "Implementation" changed to "Impact on:" by A. Sultan (for better wording)
- 4436: RAN and CN to verify UMTS_AMR_2 support
- 4437: End date Modified from June to March to have it in Rel4
- 4438: Approved at CN#10. Acronym changed from ASCI, Rel-4
- 4439: CN4#11 30/11/02: no inputs received in CN4
- 4440: -
- 4441: -
- 4442: -
- 4443: -
- 4444: -
- 4445: -
- 4446: -
- 4447: -
- 4448: Completed WI missing from the P-plan Added for tracking
- 4449: -
- 4450: -
- 4451: -
- 4452: -
- 4453: -
- 4454: -
- 4455: -

| ID | WBS | Task | Type | Duration | Start | Finish | Complete | Baseline start | Baseline finish | Baseline duration | Constraint | Resources | Work | Actual work | Acronym | Release | MCC resp | Acronym_3GU_Export | TSG stopped | WI rapporteur name | WI rapporteur e-mail | Impacted TSs and TRs |
| --- | --- | --- | --- | --- | --- | --- | --- | --- | --- | --- | --- | --- | --- | --- | --- | --- | --- | --- | --- | --- | --- | --- |
| 4456 | 60.4 | **GERAN QoS Aspects - Handovers: maintenance of real-time QoS while moving between cells in the PLMN including inter-SGSN and SRNS relocation or possibly other mechanisms** |  | 501d | 2000-01-03 A | 2001-11-30 A | 100% | 2000-01-03 | 2001-11-30 | 501d |  | GP | 14456h | 14456h | GERQoS | Rel-4 | Paolo | GERQoS |  |  |  |  |
| 4457 | 60.4.1 | **Handover Concept for the PS domain** |  | 501d | 2000-01-03 A | 2001-11-30 A | 100% | 2000-01-03 | 2001-11-30 | 501d |  | GP | 10448h | 10448h |  | Rel-4 | Paolo |  |  |  |  |  |
| 4458 | 60.4.1.1 | Stable RT handover report 25.936 including header removal |  | 14d | 2000-01-03 A | 2000-01-19 A | 100% | 2000-01-03 | 2000-01-19 | 14d | start no earlier than 2000-01-03 | GP | 104h | 104h |  | Rel-4 | Paolo |  |  |  |  |  |
| 4459 | 60.4.1.2 | Update of stage 2 |  | 293d | 2000-01-03 A | 2001-02-13 A | 100% | 2000-01-03 | 2001-02-13 | 293d | finish no earlier than 2001-02-13 | GP | 2336h | 2336h |  | Rel-4 | Paolo |  |  |  |  |  |
| 4460 | 60.4.1.3 | Update of relevant stage 3 specs -> RRC |  | 501d | 2000-01-03 A | 2001-11-30 A | 100% | 2000-01-03 | 2001-11-30 | 501d | finish no earlier than 2001-11-30 | G2 | 4000h | 4000h |  | Rel-4 | Gert |  |  |  |  |  |
| 4461 | 60.5 | **Deleted - GERAN MS Conformance test for inter-system and intra-system Packet data real-time Handover** |  | 324d | 2001-08-31 A | 2002-11-27 A | 100% | 2001-08-31 | 2002-11-27 | 324d |  | G4; R3 | 25920h | 25920h | GERQoS-Mstest | Rel-4 | Paolo | GERQoS-Mstest | GP-12 |  |  |  |
| 4462 | 60.5.1 | **Deleted - Handover for the PS domain** |  | 324d | 2001-08-31 A | 2002-11-27 A | 100% | 2001-08-31 | 2002-11-27 | 324d |  | G4; R3 | 20736h | 20736h |  | Rel-4 | Paolo |  | GP-12 |  |  |  |
| 4463 | 60.5.1.1 | Deleted - Stable RT handover report 25.936 including header removal |  | 324d | 2001-08-31 A | 2002-11-27 A | 100% | 2001-08-31 | 2002-11-27 | 324d | finish no earlier than 2002-11-27 | G4; R3 | 5184h | 5184h |  | Rel-4 | Paolo |  | GP-12 |  |  |  |
| 4464 | 60.5.1.2 | Deleted - Update of stage 2 |  | 324d | 2001-08-31 A | 2002-11-27 A | 100% | 2001-08-31 | 2002-11-27 | 324d | finish no earlier than 2002-11-27 | G4; R3 | 5184h | 5184h |  | Rel-4 | Paolo |  | GP-12 |  |  |  |
| 4465 | 60.5.1.3 | Deleted - Update of relevant stage 3 specs |  | 324d | 2001-08-31 A | 2002-11-27 A | 100% | 2001-08-31 | 2002-11-27 | 324d | finish no earlier than 2002-11-27 | G4; R3 | 5184h | 5184h |  | Rel-4 | Paolo |  | GP-12 |  |  |  |
| 4466 | 60.6 | PS-domain handover for real-time services |  | 155d | 2000-08-28 A | 2001-03-30 A | 100% | 2000-08-28 | 2001-03-30 | 155d | finish no earlier than 2001-03-30 | R3 | 1240h | 1240h | QoSPS-PSdoRTS | Rel-4 | Juha | QoSPS-PSdoRTS |  | Nokia | atte.lansisalmi@nokia.com |  |
| 4467 | 60.7 | Deleted - RAB QoS Renegotiation at Relocation |  | 58d | 2001-01-03 A | 2001-03-23 A | 100% | 2001-01-03 | 2001-03-23 | 58d | finish no earlier than 2001-03-23 | R3 | 464h | 464h |  | Rel-4 | Juha |  | RP-11 |  |  | 25.851, 25.946 |
| 4468 | 61 | (Small) Technical Enhancements and Improvements for Rel-4 | milestone | 0d? | 2000-01-03 A | 2000-01-03 A | 100% | 2000-01-03 | 2001-03-30 | 326d? |  | SP; CP; RP; GP |  |  | TEI4 | Rel-4 | all | TEI4 |  |  |  |  |
| 4469 | 1072 | Test - (Small) Technical Enhancements and Improvements for Rel-4 |  | 326d? | 2000-01-03 A | 2001-03-30 A | 100% | 2000-01-03 | 2001-03-30 | 326d? | finish no earlier than 2008-12-31 | R5; T1 | 5216h | 5216h | TEI4_Test | Rel-4 | Ingbert | TEI4_Test |  |  |  |  |
| 4470 | 62 | **Rel-4 Evolutions of the transport in the UTRAN** |  | 525d | 2000-08-21 A | 2002-08-23 A | 100% | 2000-08-21 | 2002-08-23 | 525d |  | RP | 8600h | 8600h | ETRAN | Rel-4 | Issam | ETRAN |  | Alcatel | Francois Courau |  |
| 4471 | 62.1 | QoS optimization for AAL2 connections over Iub and Iur interfaces |  | 160d | 2000-08-21 A | 2001-03-30 A | 100% | 2000-08-21 | 2001-03-30 | 160d | finish no earlier than 2001-03-30 | R3 | 1280h | 1280h | ETRAN-QoSAAL2 | Rel-4 | Juha | ETRAN-QoSAAL2 |  | Japan Telecom | T. Yoshimura |  |
| 4472 | 62.2 | Transport bearer modification procedure on Iub, Iur, and Iu |  | 130d | 2000-10-02 A | 2001-03-30 A | 100% | 2000-10-02 | 2001-03-30 | 130d | finish no earlier than 2001-03-30 | R3 | 1040h | 1040h | ETRAN-MigrMod | Rel-4 | Juha | ETRAN-MigrMod |  | Japan Telecom | T. Yoshimura |  |
| 4473 | 62.3 | **Deleted - Conformance Test Aspects of Rel-4 evolutions of the transport in UTRAN** |  | 130d | 2002-02-25 A | 2002-08-23 A | 100% | 2002-02-25 | 2002-08-23 | 130d |  | T1 | 2080h | 2080h |  | Rel-4 | Ingbert |  | TP-17 |  |  |  |
| 4474 | 62.3.1 | Deleted - Testing RAB support enhancements |  | 130d | 2002-02-25 A | 2002-08-23 A | 100% | 2002-02-25 | 2002-08-23 | 130d | finish no earlier than 2002-08-23 | T1 | 1040h | 1040h | CT-RABS? | Rel-4 | Ingbert | CT-RABS? | TP-17 |  |  | 34.108, 34. 121, 34.122, 34.123 p 1,2, 34.123 pt 3 |
| 4475 | 63 | **Rel-4 Evolutions of the transport in the CN** |  | 215d | 2000-05-29 A | 2001-03-23 A | 100% | 2000-05-29 | 2001-03-23 | 215d |  | N4; N1; N2; S2 | 13128h | 13128h | CNTRSP | Rel-4 | Kimmo | CNTRSP |  |  |  |  |
| 4476 | 63.1 | **IP Transport of CN protocols (e.g. CAP, MAP)** |  | 77d | 2000-12-07 A | 2001-03-23 A | 100% | 2000-12-07 | 2001-03-23 | 77d |  | N4 | 2808h | 2808h | SS7IP | Rel-4 | Kimmo | SS7IP |  |  |  |  |
| 4477 | 63.1.1 | **Stage 3 for IP Transport of CN protocols (e.g. CAP, MAP)** |  | 77d | 2000-12-07 A | 2001-03-23 A | 100% | 2000-12-07 | 2001-03-23 | 77d |  | N4 | 2192h | 2192h |  | Rel-4 | Kimmo |  |  |  |  |  |
| 4478 | 63.1.1.1 | CAP |  | 77d | 2000-12-07 A | 2001-03-23 A | 100% | 2000-12-07 | 2001-03-23 | 77d | finish no earlier than 2001-03-23 | N2 | 616h | 616h |  | Rel-4 | Kimmo |  |  |  |  |  |
| 4479 | 63.1.1.2 | MAP |  | 77d | 2000-12-07 A | 2001-03-23 A | 100% | 2000-12-07 | 2001-03-23 | 77d | finish no earlier than 2001-03-23 | N4 | 616h | 616h |  | Rel-4 | Kimmo |  |  |  |  | 29.202 |
| 4480 | 63.1.1.3 | BSSAP+ |  | 43d | 2001-01-15 A | 2001-03-14 A | 100% | 2001-01-15 | 2001-03-14 | 43d | finish no earlier than 2001-03-14 | N1 | 344h | 344h | SS7IP-BSSAP+ | Rel-4 | Frederic | SS7IP-BSSAP+ |  |  |  |  |

Notes:
- 4456: -
- 4457: -
- 4458: -
- 4459: -
- 4460: -
- 4461: Still exist? To be clarified by GERAN4/5. Marked as stopped 12/2008
- 4462: Marked as stopped 12/2008
- 4463: Marked as stopped 12/2008
- 4464: Marked as stopped 12/2008
- 4465: Marked as stopped 12/2008
- 4466: -
- 4467: Marked as stopped 12/2008
- 4468: "Joker" WI, to be used for a Rel 4 CR not related to any feature and with very limited impact on the system
- 4469: "Joker" WI, to be used for small modifications applicable to Rel 4 conformance testing. Moved in from the Stoyan/Testing WP
- 4470: -
- 4471: -
- 4472: -
- 4473: Marked as stopped 12/2008
- 4474: Marked as stopped 12/2008
- 4475: -
- 4476: -
- 4477: -
- 4478: -
- 4479: -
- 4480: -

| ID | WBS | Task | Duration | Start | Finish | Complete | Baseline start | Baseline finish | Baseline duration | Constraint | Resources | Work | Actual work | WI rapporteur name | WI rapporteur e-mail | Release | MCC resp | Acronym | Acronym_3GU_Export | Impacted TSs and TRs | TSG stopped |
| --- | --- | --- | --- | --- | --- | --- | --- | --- | --- | --- | --- | --- | --- | --- | --- | --- | --- | --- | --- | --- | --- |
| 4481 | 63.2 | **FS on Transport and control separation in the PS CN domain** | 215d | 2000-05-29 A | 2001-03-23 A | 100% | 2000-05-29 | 2001-03-23 | 215d |  | S2 | 3440h | 3440h | Ericsson | Juan-Antonio.Ibanez@eed.ericsson.se | Rel-4 | Maurice |  |  |  |  |
| 4482 | 63.2.1 | Architectural impacts | 215d | 2000-05-29 A | 2001-03-23 A | 100% | 2000-05-29 | 2001-03-23 | 215d | finish no earlier than 2001-03-23 | S2 | 1720h | 1720h |  |  | Rel-4 | Maurice |  |  |  |  |
| 4483 | 64 | **Rel-4 Improvements of Radio Interface** | 700d | 2000-07-10 A | 2003-03-14 A | 100% | 2000-07-10 | 2003-03-14 | 700d |  | RP | 28624h | 28624h |  |  | Rel-4 |  |  |  |  |  |
| 4484 | 64.1 | UTRA repeater specification (master) | 183d | 2000-07-10 A | 2001-03-21 A | 100% | 2000-07-10 | 2001-03-21 | 183d | finish no earlier than 2001-03-21 | R4 | 1464h | 1464h | Mikom, Allgon | T. Kummetz, Mikom; Alf Ahlström, Allgon | Rel-4 | Issam | RInImp-REP | RInImp-REP |  |  |
| 4485 | 64.2 | DSCH power control improvement in soft handover | 140d | 2000-09-11 A | 2001-03-23 A | 100% | 2000-09-11 | 2001-03-23 | 140d | finish no earlier than 2001-03-23 | R1 | 1120h | 1120h | Nokia | antti.toskala@nokia.com | Rel-4 | Patrick | RInImp-DSCHsho | RInImp-DSCHsho |  |  |
| 4486 | 64.3 | UMTS 1800 | 320d | 2000-09-25 A | 2001-12-14 A | 100% | 2000-09-25 | 2001-12-14 | 320d | finish no earlier than 2001-12-14 | R4 | 2560h | 2560h | Motorola | Howard Benn | Rel-4 | Issam | RInImp-UMTS18 | RInImp-UMTS18 |  |  |
| 4487 | 64.4 | UMTS 1900 | 195d | 2001-03-19 A | 2001-12-14 A | 100% | 2001-03-19 | 2001-12-14 | 195d | finish no earlier than 2001-12-14 | R4 | 1560h | 1560h | Motorola | Howard Benn | Rel-4 | Issam | RInImp-UMTS19 | RInImp-UMTS19 | 25.101 |  |
| 4488 | 64.5 | FS on High Speed downlink packet access | 155d | 2000-08-21 A | 2001-03-23 A | 100% | 2000-08-21 | 2001-03-23 | 155d | finish no earlier than 2001-03-23 | R2 | 1240h | 1240h | Motorola | Amitabha Ghosh (qa0047@email.mot.com) | Rel-4 | Yong-Jun | RInImp-HSDPA | RInImp-HSDPA |  |  |
| 4489 | 64.6 | Deleted - FS on improved common DL channel for Cell-FACH state | 340d | 2000-09-11 A | 2001-12-28 A | 100% | 2000-09-11 | 2001-12-28 | 340d | finish no earlier than 2001-12-28 | R2 | 2720h | 2720h | GBT | J. Kwak | Rel-4 | Yong-Jun | RInImp-DLCFACH | RInImp-DLCFACH |  | RP-14 |
| 4490 | 64.7 | **Conformance Test Spec. Rel-4 improvements in Radio Interface** | 375d | 2001-10-08 A | 2003-03-14 A | 100% | 2001-10-08 | 2003-03-14 | 375d |  | T1 | 12360h | 12360h |  |  | Rel-4 | Ingbert |  |  |  |  |
| 4491 | 64.7.1 | Deleted - Testing Improved usage of downlink resource in FDD for CCTrCHs of dedicated type | 140d | 2002-02-18 A | 2002-08-30 A | 100% | 2002-02-18 | 2002-08-30 | 140d | finish no earlier than 2002-08-30 | T1 | 1120h | 1120h |  |  | Rel-4 | Ingbert |  |  |  | TP-17 |
| 4492 | 64.7.2 | Deleted - Testing Terminal Power saving features | 140d | 2002-02-18 A | 2002-08-30 A | 100% | 2002-02-18 | 2002-08-30 | 140d | finish no earlier than 2002-08-30 | T1 | 1120h | 1120h |  |  | Rel-4 | Ingbert |  |  |  | TP-17 |
| 4493 | 64.7.3 | Deleted - Testing DSCH power control improvement in soft handover | 140d | 2002-02-18 A | 2002-08-30 A | 100% | 2002-02-18 | 2002-08-30 | 140d | finish no earlier than 2002-08-30 | T1 | 1120h | 1120h |  |  | Rel-4 | Ingbert |  |  |  | TP-17 |
| 4494 | 64.7.4 | Testing UMTS 1800 | 180d | 2001-10-08 A | 2002-06-14 A | 100% | 2001-10-08 | 2002-06-14 | 180d | finish no earlier than 2002-06-14 | T1 | 1440h | 1440h |  |  | Rel-4 | Ingbert |  |  | 34.108, 34,121, 34.122, 34.123-1 |  |
| 4495 | 64.7.5 | Testing UMTS 1900 | 180d | 2001-10-08 A | 2002-06-14 A | 100% | 2001-10-08 | 2002-06-14 | 180d | finish no earlier than 2002-06-14 | T1 | 1440h | 1440h |  |  | Rel-4 | Ingbert |  |  | 34.108, 34,121, 34.122, 34.123-1 |  |
| 4496 | 64.7.6 | Testing UMTS 1800 - TTCN | 195d | 2002-06-17 A | 2003-03-14 A | 100% | 2002-06-17 | 2003-03-14 | 195d | finish no earlier than 2003-03-14 | T1 | 1560h | 1560h |  |  | Rel-4 | Ingbert |  |  | 34.123-3 |  |
| 4497 | 64.7.7 | Testing UMTS 1900 - TTCN | 195d | 2002-06-17 A | 2003-03-14 A | 100% | 2002-06-17 | 2003-03-14 | 195d | finish no earlier than 2003-03-14 | T1 | 1560h | 1560h |  |  | Rel-4 | Ingbert |  |  | 34.123-3 |  |
| 4498 | 65 | **Rel-4 RAN improvements** | 938d? | 2000-08-14 A | 2004-03-17 A | 100% | 2000-08-14 | 2004-03-17 | 938d? |  | RP | 29336h | 29336h |  |  | Rel-4 |  |  |  |  |  |
| 4499 | 65.1 | Node B synchronization for TDD | 160d | 2000-08-14 A | 2001-03-23 A | 100% | 2000-08-14 | 2001-03-23 | 160d | finish no earlier than 2001-03-23 | R1 | 1280h | 1280h | Siemens | S. Oestreich | Rel-4 | Patrick | RANimp-NBsync | RANimp-NBsync |  |  |
| 4500 | 65.2 | RAB support enhancement for Rel-4 | 155d | 2000-08-21 A | 2001-03-23 A | 100% | 2000-08-21 | 2001-03-23 | 155d | finish no earlier than 2001-03-23 | R2 | 1240h | 1240h | Ericsson | M. Israelsson, A. Krishnarajah | Rel-4 | Yong-Jun | RANimp-RABSE | RANimp-RABSE |  |  |
| 4501 | 65.4 | **Deleted - Conformance Test Aspects - Rel-4 RAN Improvements** | 577d? | 2002-01-01 A | 2004-03-17 A | 100% | 2002-01-01 | 2004-03-17 | 577d? |  | T1 | 19312h | 19312h |  |  | Rel-4 | Ingbert |  |  |  | TP-23 |
| 4502 | 65.4.1 | Deleted - Testing Radio access bearer support enhancments | 175d | 2002-01-01 A | 2002-09-02 A | 100% | 2002-01-01 | 2002-09-02 | 175d | finish no earlier than 2002-09-02 | T1 | 1400h | 1400h |  |  | Rel-4 | Ingbert |  |  |  | TP-17 |
| 4503 | 65.4.2 | Deleted - Testing RAB support enhancements-Robust Header Compression | 332d | 2002-05-28 A | 2003-09-03 A | 100% | 2002-05-28 | 2003-09-03 | 332d | finish no earlier than 2003-09-03 | T1 | 2656h | 2656h |  |  | Rel-4 | Ingbert | RABimp-RoCH | RABimp-RoCH | 34.123-1, -2 | TP-21 |
| 4504 | 65.4.3 | Deleted - Testing RAB support enhancements-Robust Header Compression - TTCN | 472d | 2002-05-28 A | 2004-03-17 A | 100% | 2002-05-28 | 2004-03-17 | 472d | finish no earlier than 2004-03-17 | T1 | 3776h | 3776h |  |  | Rel-4 | Ingbert |  |  | 34.123-3 | TP-23 |
| 4505 | 65.4.4 | Testing of Extended Robut Header Compression | 270d | 2002-09-18 A | 2003-09-30 A | 100% | 2002-09-18 | 2003-09-30 | 270d | finish no earlier than 2003-09-30 | T1 | 2160h | 2160h |  |  | Rel-4 | Ingbert | Ext-RoHC | Ext-RoHC | 34.123-1, -2 |  |
| 4506 | 65.4.5 | Deleted - Testing of Extended Robut Header Compression - TTCN | 325d | 2002-09-18 A | 2003-12-16 A | 100% | 2002-09-18 | 2003-12-16 | 325d | finish no earlier than 2003-12-16 | T1 | 2600h | 2600h |  |  | Rel-4 | Ingbert |  |  | 34.123-3 | TP-22 |
| 4507 | 1076.3.6 | Deleted - General changes to TS34.121 corresponding to release 4 | 263d? | 2003-03-03 A | 2004-03-03 A | 100% | 2003-03-03 | 2004-03-03 | 263d? | finish no earlier than 2004-03-03 | T1 | 2104h | 2104h |  |  | Rel-4 | Ingbert | RANimp-test, TEI4 | RANimp-test, TEI4 | 34.108, 34.121 | TP-23 |

Notes:
- 4481: -
- 4482: -
- 4483: -
- 4484: -
- 4485: -
- 4486: -
- 4487: -
- 4488: -
- 4489: Stopped at RP#14
- 4490: -
- 4491: Marked as stopped 12/2008
- 4492: Marked as stopped 12/2008
- 4493: Marked as stopped 12/2008
- 4494: -
- 4495: -
- 4496: -
- 4497: -
- 4498: -
- 4499: -
- 4500: 29 Nov 2000: split into ROHC and non-ROHC part; 5 Mar 2001: splitting off of ROHC for Rel-4 agreed by R2
- 4501: Marked as stopped 12/2008
- 4502: Marked as stopped 12/2008
- 4503: UID changed. Marked as stopped 12/2008
- 4504: UID changed. Marked as stopped 12/2008
- 4505: Marked as closed 12/2008 (was marked 15% complete)
- 4506: Marked as stopped 12/2008
- 4507: Marked as stopped 12/2008

| ID | WBS | Task | Duration | Start | Finish | Complete | Baseline start | Baseline finish | Baseline duration | Constraint | Resources | Work | Actual work | Acronym | WI rapporteur name | Release | MCC resp | Special Focus Doc | Acronym_3GU_Export | TSG stopped | WI rapporteur e-mail | Status Report |
| --- | --- | --- | --- | --- | --- | --- | --- | --- | --- | --- | --- | --- | --- | --- | --- | --- | --- | --- | --- | --- | --- | --- |
| 4508 | 66 | **Rel-4 Emergency call enhancements** | 628d | 2000-01-03 A | 2002-05-28 A | 100% | 2000-01-03 | 2002-05-28 | 628d |  | N1; S1; T1 | 18672h | 18672h | EMC1-CS | Ericsson | Rel-4 | Frederic | Public Safety (I-A) | EMC1, EMC1-CS |  |  |  |
| 4509 | 66.1 | **For CS based calls** | 628d | 2000-01-03 A | 2002-05-28 A | 100% | 2000-01-03 | 2002-05-28 | 628d |  | N1 | 3600h | 3600h | EMC1-CS | Ericsson | Rel-4 | Frederic | Public Safety (I-A) | EMC1-CS |  |  |  |
| 4510 | 66.1.1 | Distinction in CS domain of emergency call types to different emergency services | 40d | 2000-05-01 A | 2000-06-23 A | 100% | 2000-05-01 | 2000-06-23 | 40d | finish no earlier than 2000-06-23 | S1 | 320h | 320h |  |  | Rel-4 | Alain | Public Safety (I-A) |  |  |  |  |
| 4511 | 66.1.2 | Distinction in CS domain of emergency calls to different emergency types | 22d | 2000-08-24 A | 2000-09-22 A | 100% | 2000-08-24 | 2000-09-22 | 22d | finish no earlier than 2000-09-22 | N1 | 176h | 176h |  |  | Rel-4 | Frederic | Public Safety (I-A) |  |  |  |  |
| 4512 | 66.1.3 | Deleted - Conformance Test Aspects - Emergency call enhancements | 151d | 2000-01-03 A | 2000-07-28 A | 100% | 2000-01-03 | 2000-07-28 | 151d |  | T1 | 1200h | 1200h |  |  | Rel-4 | Ingbert | Public Safety (I-A) |  | TP-08 |  |  |
| 4513 | 66.1.4 | Testing CS based emergency calls | 67d | 2002-02-25 A | 2002-05-28 A | 100% | 2002-02-25 | 2002-05-28 | 67d | finish no earlier than 2002-05-28 | T1 | 536h | 536h |  |  | Rel-4 | Ingbert | Public Safety (I-A) |  |  |  |  |
| 4514 | 66.1.5 | Testing CS based emergency calls - TTCN | 134d | 2001-11-22 A | 2002-05-28 A | 100% | 2001-11-22 | 2002-05-28 | 134d | finish no earlier than 2002-05-28 | T1 | 1072h | 1072h |  |  | Rel-4 | Ingbert | Public Safety (I-A) |  |  |  |  |
| 4515 | 67 | **Rel-4 Terminal interfaces** | 315d | 2000-01-03 A | 2001-03-15 A | 100% | 2000-01-03 | 2001-03-15 | 315d |  | T2 | 14296h | 14296h | TI |  | Rel-4 | Kimmo |  | TI |  |  |  |
| 4516 | 67.1 | **AT commands enhancements** | 314d | 2000-01-03 A | 2001-03-14 A | 100% | 2000-01-03 | 2001-03-14 | 314d |  | T2 | 5016h | 5016h | TI-ATC |  | Rel-4 | Kimmo |  | TI-ATC |  |  |  |
| 4517 | 67.1.1 | Specification of AT commands for new services | 314d | 2000-01-03 A | 2001-03-14 A | 100% | 2000-01-03 | 2001-03-14 | 314d | finish no earlier than 2001-03-14 | T2 | 2504h | 2504h |  |  | Rel-4 | Kimmo |  |  |  |  |  |
| 4518 | 67.2 | **Wide Area Data Synchronization** | 314d | 2000-01-03 A | 2001-03-14 A | 100% | 2000-01-03 | 2001-03-14 | 314d |  | T2 | 5016h | 5016h | TI-WADS |  | Rel-4 | Kimmo |  | TI-WADS |  |  |  |
| 4519 | 67.2.1 | Continues evolution of Synchronization protocol | 314d | 2000-01-03 A | 2001-03-14 A | 100% | 2000-01-03 | 2001-03-14 | 314d | finish no earlier than 2001-03-14 | T2 | 2504h | 2504h | TI-SYNC-EVOL |  | Rel-4 | Kimmo |  | TI-SYNC-EVOL |  |  |  |
| 4520 | 67.3 | Terminal local model | 218d | 2000-05-16 A | 2001-03-15 A | 100% | 2000-05-16 | 2001-03-15 | 218d | finish no earlier than 2001-03-15 | T2 | 1744h | 1744h | TLM | Ericsson | Rel-4 | Kimmo |  | TLM |  | Olga.Tome@ECS.ERICSSON.SE |  |
| 4521 | 68 | **Rel-4 Location Services enhancements** | 455d | 2000-04-03 A | 2001-12-28 A | 100% | 2000-04-03 | 2001-12-28 | 455d |  | S2; S1; T2; N1; N4; R3; R2 | 67671.2h | 67671.2h | LCS4 | Nokia | Rel-4 | Maurice |  | LCS1 |  | Jan Kall |  |
| 4522 | 68.1 | CBS interactions | 455d | 2000-04-03 A | 2001-12-28 A | 100% | 2000-04-03 | 2001-12-28 | 455d | finish no earlier than 2001-12-28 | T2 | 3640h | 3640h | LCS4-CBS |  | Rel-4 |  |  | LCS1-CBS |  |  |  |
| 4523 | 68.2 | LCS support in the CS domain | 180d | 2000-05-15 A | 2001-01-19 A | 100% | 2000-05-15 | 2001-01-19 | 180d | finish no earlier than 2001-01-19 | S2 | 1440h | 1440h | LCS4-CS |  | Rel-4 | Maurice |  | LCS1-CS |  |  |  |
| 4524 | 68.3 | **LCS support in the PS domain** | 435d | 2000-05-01 A | 2001-12-28 A | 100% | 2000-05-01 | 2001-12-28 | 435d |  | S2; S1; N1; N4 | 29880h | 29880h | LCS4-PS |  | Rel-4 | Maurice |  | LCS1-PS |  |  |  |
| 4525 | 68.3.1 | Stage 1 for LCS support in the PS domain | 40d | 2000-07-03 A | 2000-08-25 A | 100% | 2000-07-03 | 2000-08-25 | 40d | start no earlier than 2000-07-03 | S1 | 320h | 320h |  | Pacific Bell Wireless | Rel-4 | Alain |  |  |  | Randolph Wohlert (rwohlert@tri.sbc.com) |  |
| 4526 | 68.3.2 | Stage 2 for LCS support in the PS domain | 190d | 2000-05-01 A | 2001-01-19 A | 100% | 2000-05-01 | 2001-01-19 | 190d | finish no earlier than 2001-01-19 | S2; R2; G1 | 4560h | 4560h |  |  | Rel-4 | Maurice |  |  |  |  |  |
| 4527 | 68.3.3 | **Stage 3 for LCS support in the PS domain** | 355d | 2000-08-21 A | 2001-12-28 A | 100% | 2000-08-21 | 2001-12-28 | 355d |  | N1; N4 | 11080h | 11080h |  |  | Rel-4 | Frederic |  |  |  |  |  |
| 4528 | 68.3.3.1 | Layer 3 LCS signalling UE (MS) -SGSN (UMTS PS and and GSM-GPRS) | 355d | 2000-08-21 A | 2001-12-28 A | 100% | 2000-08-21 | 2001-12-28 | 355d | finish no earlier than 2001-12-28 | N1 | 2840h | 2840h |  | Nokia | Rel-4 | Frederic |  |  |  | Janne Muhonen |  |
| 4529 | 68.3.3.2 | MAP impacts of LCS | 160d | 2000-08-21 A | 2001-03-30 A | 100% | 2000-08-21 | 2001-03-30 | 160d | finish no earlier than 2001-03-30 | N4 | 1280h | 1280h |  |  | Rel-4 | Kimmo |  |  |  |  |  |
| 4530 | 68.3.3.3 | GTP signalling for LCS | 160d | 2000-08-21 A | 2001-03-30 A | 100% | 2000-08-21 | 2001-03-30 | 160d | finish no earlier than 2001-03-30 | N4 | 1280h | 1280h |  |  | Rel-4 | Kimmo |  |  |  |  |  |
| 4531 | 68.4 | **UE positioning Rel-4** | 260d | 2000-04-03 A | 2001-03-30 A | 100% | 2000-04-03 | 2001-03-30 | 260d |  | R3; R2 | 7231.2h | 7231.2h | LCS1-UEpos |  | Rel-4 | Issam |  | LCS1-UEpos |  |  | RP-010045 |
| 4532 | 68.4.1 | Iub/Iur interfaces for methods Rel 99 | 233.9d | 2000-04-03 A | 2001-03-30 A | 100% | 2000-04-03 | 2001-03-30 | 233.9d | finish no earlier than 2001-03-30 | R3 | 1871.2h | 1871.2h | LCS1-UEpos-IubIur | Ericsson | Rel-4 | Juha |  | LCS1-UEpos-IubIur |  | Yun-Chao Hu | RP-010045 |
| 4533 | 68.4.2 | UE positioning enhancements - IPDL for TDD | 150d | 2000-08-28 A | 2001-03-23 A | 100% | 2000-08-28 | 2001-03-23 | 150d | finish no earlier than 2001-03-23 | R2 | 1200h | 1200h | LCS1-UEpos-enh | Siemens | Rel-4 | Yong-Jun |  | LCS1-UEpos-enh |  | Armin Sitte | RP-010045 |

Notes:
- 4508: Acronym changed from EMC1, EMC1-CS
- 4509: WI approved in TSG_10
- 4510: -
- 4511: Calls to different emergency services such as ambulance, fire brigade, police, etc. can be routed to respective different emergency centres. / NP-000447 is the stage 3 changes for CS call control protocol. / Impacted TSs and TRs: 24.008
- 4512: UID changed. Marked as stopped 12/2008
- 4513: - / Impacted TSs and TRs: 34.123-1
- 4514: - / Impacted TSs and TRs: 34.123-3
- 4515: -
- 4516: - / Impacted TSs and TRs: 27.007
- 4517: goal not completely achieved because of missing input / Impacted TSs and TRs: 27.007
- 4518: AS: Rel5 changed to Rel4 according to SP#10 decision, milestone on testing added
- 4519: - / Impacted TSs and TRs: 27.903, 27.103
- 4520: - / Impacted TSs and TRs: 23.227
- 4521: Acronym changed form LCS1
- 4522: - / Impacted TSs and TRs: 23.041
- 4523: Only MAP impact foreseen so far. To be further split if needed.
- 4524: -
- 4525: To be also considered: External LCS client identity, and Privacy options when PDP-context and when no PDP-context is established / Impacted TSs and TRs: 22.071
- 4526: SP#10 completed / Impacted TSs and TRs: 25.305 (UTRAN part), new 23.271 (CN part by S2, 43.059 (GERAN part)
- 4527: -
- 4528: -
- 4529: -
- 4530: -
- 4531: -
- 4532: - / Impacted TSs and TRs: 25.401, 25.420, 25.423, 25.430, 25.433, new TR 25.850
- 4533: 5 Mar 2001: split of IPDL for TDD agreed by R2 / Impacted TSs and TRs: new TR 25.847

| ID | WBS | Task | Duration | Start | Finish | Complete | Remaining | Baseline start | Baseline finish | Baseline duration | Total slack | Constraint | Resources | Work | Actual work | Acronym | Release | MCC resp | Acronym_3GU_Export | Impacted TSs and TRs | WI rapporteur name | WI rapporteur e-mail | TSG stopped |
| --- | --- | --- | --- | --- | --- | --- | --- | --- | --- | --- | --- | --- | --- | --- | --- | --- | --- | --- | --- | --- | --- | --- | --- |
| 4534 | 69 | **Rel-4 UICC/(U)SIM enhancements and interworking** | 175d | 2000-07-24 A | 2001-03-23 A | 100% |  | 2000-07-24 | 2001-03-23 | 175d |  |  | T3 | 2800h | 2800h | UICC1 | Rel-4 | Xavier | UICC1, Rel-4 |  |  |  |  |
| 4535 | 69.1 | Common PCN Handset Specification (CPHS) | 175d | 2000-07-24 A | 2001-03-23 A | 100% |  | 2000-07-24 | 2001-03-23 | 175d |  | finish no earlier than 2001-03-23 | T3 | 1400h | 1400h | UICC1-CPHS | Rel-4 | Xavier | UICC1-CPHS | 27.103 | One2One |  |  |
| 4536 | 70 | **Rel-4 (U)SIM toolkit enhancements** | 210d | 2000-06-05 A | 2001-03-23 | 99% | 0d | 2000-06-05 | 2001-03-23 | 210d | 0d |  | T3; S1 | 6720h | 5040h | USAT4 | Rel-4 | Xavier | USAT1, USAT1-LocLnk, USAT1APIJAVA, USAT1SM | 23.048 (USAT1SM), 43.019 (USAT1APIJAVA) | Gemplus | Jean-Francois Rubon |  |
| 4537 | 70.1 | USAT local link | 210d | 2000-06-05 A | 2001-03-23 A | 100% |  | 2000-06-05 | 2001-03-23 | 210d |  | finish no earlier than 2001-03-23 | T3; S1 | 3360h | 3360h | USAT1-LocLnk | Rel-4 | Xavier | USAT1-LocLnk | 22.038, 31.111 | Gemplus | Jean-Francois Rubon |  |
| 4538 | 71 | **Rel-4 Security enhancements** | 576d | 2000-01-03 A | 2002-03-15 A | 100% |  | 2000-01-03 | 2002-03-15 | 576d |  |  | S3; N4; N1 | 38112h | 38112h | SEC4 | Rel-4 | Mirko | SEC1 |  | Vodafone | Peter.Howard@vodafone.com |  |
| 4539 | 54.2 | Rel-4 Lawful Interception | 155d | 2000-08-21 A | 2001-03-23 A | 100% |  | 2000-08-21 | 2001-03-23 | 155d |  | finish no earlier than 2001-03-23 | S3 | 1240h | 1240h | SEC4-LI | Rel-4 | Mirko | SEC1-LI | 33.107 |  |  |  |
| 4540 | 71.1 | Evolution of GSM CS algorithms (e.g. A5/3 development and deployment) | 272d | 2000-01-03 A | 2001-01-15 A | 100% |  | 2000-01-03 | 2001-01-15 | 272d |  | finish no earlier than 2001-01-15 | S3 | 2168h | 2168h | SEC1-CSALGO1 | Rel-4 | Mirko | SEC1-CSALGO1 | 33.102, 33.103, 33.105 | DTI, BIS | cbrookson@iee.org |  |
| 4541 | 71.2 | **Evolution of GSM PS algorithms (e.g. GEA 2 deployment)** | 219d | 2000-02-22 A | 2000-12-22 A | 100% |  | 2000-02-22 | 2000-12-22 | 219d |  |  | S3; N4; N1 | 9528h | 9528h | SEC1-PSALGO1 | Rel-4 | Mirko | SEC1-PSALGO1 | 33.102, 33.103, 33.105 | DTI, BIS | cbrookson@iee.org |  |
| 4542 | 71.2.1 | Deleted - Main aspects of Evolution of GSM PS algorithms (e.g. GEA 2 deployment) | 199d | 2000-02-22 A | 2000-11-24 A | 100% |  | 2000-02-22 | 2000-11-24 | 199d |  | finish no earlier than 2000-11-24 | S3 | 1592h | 1592h |  | Rel-4 | Mirko |  |  | DTI, BIS | cbrookson@iee.org |  |
| 4543 | 71.2.2 | Impact on GTP | 200d | 2000-03-20 A | 2000-12-22 A | 100% |  | 2000-03-20 | 2000-12-22 | 200d |  | finish no earlier than 2000-12-22 | N4 | 1600h | 1600h |  | Rel-4 | Kimmo |  |  | DTI, BIS | cbrookson@iee.org |  |
| 4544 | 71.2.3 | GEA capability indication in MS CM | 135d | 2000-06-19 A | 2000-12-22 A | 100% |  | 2000-06-19 | 2000-12-22 | 135d |  | finish no earlier than 2000-12-22 | N1 | 1080h | 1080h | SEC1-PSALGO1-GEACAP | Rel-4 | Frederic | SEC1-PSALGO1-GEACAP |  | Vodafone Airtouch | Duncan Mills |  |
| 4545 | 71.3 | **Deleted - MAP application layer security** | 576d | 2000-01-03 A | 2002-03-15 A | 100% |  | 2000-01-03 | 2002-03-15 | 576d |  |  | S3 | 11352h | 11352h | SEC1-MAPAL | Rel-4 | Mirko | SEC1-MAPAL |  |  |  | SP-15 |
| 4546 | 71.3.1 | Deleted - Main aspects of MAP application layer security | 199d | 2000-02-21 A | 2001-03-29 A | 100% |  | 2000-02-21 | 2001-03-29 | 199d |  | start no earlier than 2000-02-21 | S3 | 1592h | 1592h |  | Rel-4 | Mirko |  |  |  |  | SP-11 |
| 4547 | 71.3.2 | Deleted - Other stage 3 aspects | 199d | 2000-02-22 A | 2000-11-24 A | 100% |  | 2000-02-22 | 2000-11-24 | 199d |  | finish no earlier than 2000-11-24 | N4 | 1592h | 1592h |  | Rel-4 | Kimmo |  |  |  |  | CP-10 |
| 4548 | 71.3.3 | Deleted - Visibility and Configurability of security | 576d | 2000-01-03 A | 2002-03-15 A | 100% |  | 2000-01-03 | 2002-03-15 | 576d |  | finish no earlier than 2002-03-15 | S3 | 4600h | 4600h | SEC1-VCS | Rel-4 | Mirko | SEC1-VCS |  | France Telecom | Sebastien.nguyenngoc@rd.francetelecom.com | SP-15 |
| 4549 | 72 | **Rel-4 Charging and OAM&P** | 221d | 2000-12-01 A | 2001-10-05 A | 100% |  | 2000-12-01 | 2001-10-05 | 221d |  |  | S5 | 10472h | 10472h | OAM4 | Rel-4 | Mirko | OAM4 |  |  |  |  |
| 4550 | 72.1 | Rel-4 Principles, high level Requirements and Architecture | 145d | 2000-12-01 A | 2001-06-21 A | 100% |  | 2000-12-01 | 2001-06-21 | 145d |  | finish no earlier than 2001-06-21 | S5 | 1160h | 1160h |  | Rel-4 | Mirko |  | 32.101, 32.102 | Motorola, Telia | Michael.Truss@motorola.com, Tommy.R.Berggren@TELIA.SE |  |
| 4551 | 72.2 | Rel-4 Performance Management | 216d | 2000-12-01 A | 2001-09-28 A | 100% |  | 2000-12-01 | 2001-09-28 | 216d |  | finish no earlier than 2001-06-21 | S5 | 1728h | 1728h |  | Rel-4 | Mirko |  | 32.4xy, 52.402 | T-Mobile | karl-heinz.nenner@t-mobile.de |  |
| 4552 | 72.3 | Fault Management | 221d | 2000-12-01 A | 2001-10-05 A | 100% |  | 2000-12-01 | 2001-10-05 | 221d |  | finish no earlier than 2001-06-21 | S5 | 1768h | 1768h |  | Rel-4 | Mirko |  | 32.111-1/4 | Lucent |  |  |
| 4553 | 72.4 | Configuration Management | 145d | 2000-12-01 A | 2001-06-21 A | 100% |  | 2000-12-01 | 2001-06-21 | 145d |  | finish no earlier than 2001-06-21 | S5 | 1160h | 1160h |  | Rel-4 | Mirko |  | 32.106-1/8 | Ericsson | thomas.tovinger@ericsson.com |  |
| 4554 | 72.5 | Rel-4 Charging Management | 216d | 2000-12-01 A | 2001-09-28 A | 100% |  | 2000-12-01 | 2001-09-28 | 216d |  | finish no earlier than 2001-06-21 | S5 | 1728h | 1728h |  | Rel-4 | Mirko |  | 32.200, 32.205, 32.215, 32.235 | T-Mobile | karl-heinz.nenner@t-mobile.de |  |
| 4555 | 72.6 | UTRAN Operations and Maintenance procedures | 145d | 2000-12-01 A | 2001-06-21 A | 100% |  | 2000-12-01 | 2001-06-21 | 145d |  | finish no earlier than 2001-06-21 | S5 | 1160h | 1160h | UOAM | Rel-4 | Mirko | UOAM | 32.800 | Mannesmann Mobilfunk | bert.boden@d2mannesmann.de |  |
| 4556 | 73 | **Global Text Telephony** | 317d? | 2000-01-03 A | 2001-03-19 A | 100% |  | 2000-01-03 | 2009-09-18 | 2537d? |  |  | S1; S2; S4; T1; R5 | 18528h | 18528h | GTT | Rel-4 | Maurice | GTT |  | Ericsson | gunnar.hellstrom@omnitor.se |  |
| 4557 | 73.1 | Stage 1 for Global Text Telephony | 188d | 2000-04-05 A | 2000-12-22 A | 100% |  | 2000-04-05 | 2000-12-22 | 188d |  | finish no earlier than 2000-12-22 | S1 | 1504h | 1504h |  | Rel-4 | Alain |  | 22.226 |  |  |  |
| 4558 | 73.2 | Stage 2 for Global Text Telephony | 206d | 2000-01-03 A | 2000-10-13 A | 100% |  | 2000-01-03 | 2000-10-13 | 206d |  |  | S2 | 1640h | 1640h |  | Rel-4 | Maurice |  | 23.226 |  |  |  |

Notes:
- 4534: Acronym changed from UICC1, Rel-4
- 4535: 28/5/2001: CRs approved at TP-11. WI complete.
- 4536: Acronym changed from USAT1, USAT1-LocLnk, USAT1APIJAVA, USAT1SM
- 4537: 25/5/2001:CR was approved at TP-11. WI is complete
- 4538: acronym changed from SEC1
- 4539: Requirements capture: S3#14 (Aug 00), Feature specification: S3#15 (Sep 00), Definition of architecture. Should be included in general LI work mentioned above.. Acronym changed from SEC1-LI
- 4540: SP#8 approved WID
- 4541: SP#8 approved WID
- 4542: Complete TSG#09 (09/2000). S3#17: Proposed for deletion. TO BE DELETED
- 4543: -
- 4544: -
- 4545: REPLACED BY NDS-MAP and NDS-IP. Completed Auto Key Management -> Rel-6. Marked as stopped 12/2008
- 4546: UID changed. Marked as stopped 12/2008
- 4547: UID changed. Marked as stopped 12/2008
- 4548: CR approved at SA3#21 awaiting comments from CN1. Marked as stopped 12/2008
- 4549: SP#13 approved WID
- 4550: -
- 4551: -
- 4552: -
- 4553: -
- 4554: -
- 4555: -
- 4556: SP#12 updated WID SP-000162=>SP-010340
- 4557: -
- 4558: -

| ID | WBS | Task | Type | Duration | Start | Finish | Complete | Baseline start | Baseline finish | Baseline duration | Constraint | Resources | Work | Actual work | Acronym | Release | MCC resp | Acronym_3GU_Export | PCG stopped | TSG stopped |
| --- | --- | --- | --- | --- | --- | --- | --- | --- | --- | --- | --- | --- | --- | --- | --- | --- | --- | --- | --- | --- |
| 4559 | 73.3 | **Specification of Cellular Text telephone Modem** |  | 136d | 2000-09-11 A | 2001-03-19 A | 100% | 2000-09-11 | 2001-03-19 | 136d |  | S4 | 2704h | 2704h | GTT-CTM | Rel-4 | Paolo | GTT-CTM |  |  |
| 4560 | 73.3.1 | General description and C-code |  | 66d | 2000-09-11 A | 2000-12-11 A | 100% | 2000-09-11 | 2000-12-11 | 66d | finish no earlier than 2000-12-11 | S4 | 528h | 528h |  | Rel-4 | Paolo |  |  |  |
| 4561 | 73.3.2 | Minimum Performance requirements |  | 136d | 2000-09-11 A | 2001-03-19 A | 100% | 2000-09-11 | 2001-03-19 | 136d | finish no earlier than 2001-03-19 | S4 | 1088h | 1088h |  | Rel-4 | Paolo |  |  |  |
| 4562 | 73.5 | Deleted - Conformance Test Aspects - Global Text Telephony | milestone | 0d? | 2000-09-21 A | 2000-09-21 A | 100% | 2000-09-21 | 2009-09-18 | 2348d? | finish no earlier than 2009-09-18 | R5; T1 |  |  | GTT_Test | Rel-4 | Ingbert | GTT_Test | PCG-23 | RP-45 |
| 4563 | 1085 | Release 1999 Features |  | 261d? | 2000-01-03 A | 2000-12-29 A | 100% | 2000-01-03 | 2000-12-29 | 261d? |  | NP; SP; TP; SMG | 8352h | 8352h |  | R99 | All |  |  |  |
| 4564 | 1086 | **UMTS Features** |  | 261d? | 1999-01-01 A | 1999-12-31 A | 100% | 1999-01-01 | 1999-12-31 | 261d? |  | S1; S2; S4; SMG; N3; N4; RP | 39672h | 39672h |  | R99 | Alain |  |  |  |
| 4565 | 1086.1 | UMTS_SERVICES |  | 261d? | 1999-01-01 A | 1999-12-31 A | 100% | 1999-01-01 | 1999-12-31 | 261d? | start no earlier than 1999-01-01 | S1 | 2088h | 2088h | UMTS_SERVICES | R99 | Alain | UMTS_SERVICES |  |  |
| 4566 | 1086.2 | UMTS phase 1 |  | 261d? | 1999-01-01 A | 1999-12-31 A | 100% | 1999-01-01 | 1999-12-31 | 261d? | start no earlier than 1999-01-01 | S1 | 2088h | 2088h | UMTS1 | R99 | Alain | UMTS1 |  |  |
| 4567 | 1086.3 | UMTS Capabilities |  | 261d? | 1999-01-01 A | 1999-12-31 A | 100% | 1999-01-01 | 1999-12-31 | 261d? | start no earlier than 1999-01-01 | S1 | 2088h | 2088h | UMTS_Capabil | R99 | Alain | UMTS_Capabil |  |  |
| 4568 | 1086.4 | Architecture of the GSM-UMTS platform |  | 261d? | 1999-01-01 A | 1999-12-31 A | 100% | 1999-01-01 | 1999-12-31 | 261d? | start no earlier than 1999-01-01 | S2; N4 | 4176h | 4176h |  | R99 | Maurice |  |  |  |
| 4569 | 1086.5 | UMTS Terrestrial Radio Access Network |  | 261d? | 1999-01-01 A | 1999-12-31 A | 100% | 1999-01-01 | 1999-12-31 | 261d? | start no earlier than 1999-01-01 | RP | 2088h | 2088h | UTRAN | R99 | Yong-Jun | UTRAN |  |  |
| 4570 | 1086.6 | UMTS 1800, UMTS 1900 |  | 261d? | 1999-01-01 A | 1999-12-31 A | 100% | 1999-01-01 | 1999-12-31 | 261d? | start no earlier than 1999-01-01 | R2 | 2088h | 2088h | Rlnlmp19, Rlnlmp18 | R99 | Yong-Jun | Rlnlmp19, Rlnlmp18 |  |  |
| 4571 | 1086.7 | Mandatory speech codec for narrowband telephony service |  | 261d? | 1999-01-01 A | 1999-12-31 A | 100% | 1999-01-01 | 1999-12-31 | 261d? | start no earlier than 1999-01-01 | S4 | 2088h | 2088h | Mandatory_Speech_Codec, AMR-NB, AMR | R99 | Paolo | Mandatory_Speech_Codec, AMR-NB, AMR |  |  |
| 4572 | 1086.8 | Codec for low bitrate multimedia telephony service |  | 261d? | 1999-01-01 A | 1999-12-31 A | 100% | 1999-01-01 | 1999-12-31 | 261d? | start no earlier than 1999-01-01 | S4 | 2088h | 2088h | Low_bit_rate_codec_for_MM_Tel., H.324M | R99 | Paolo | Low_bit_rate_codec_for_MM_Tel., H.324M |  |  |
| 4573 | 1086.9 | 3G Audio-Visual Terminal characteristics |  | 261d? | 1999-01-01 A | 1999-12-31 A | 100% | 1999-01-01 | 1999-12-31 | 261d? | start no earlier than 1999-01-01 | S4 | 2088h | 2088h | WI5TAC, 3G-AVT, Terminal_Acoustic_Characteristics | R99 | Paolo | WI5TAC, 3G-AVT, Terminal_Acoustic_Characteristics |  |  |
| 4574 | 1086.10 | Updates_for_UMTS |  | 261d? | 1999-01-01 A | 1999-12-31 A | 100% | 1999-01-01 | 1999-12-31 | 261d? | start no earlier than 1999-01-01 | N3 | 2088h | 2088h | Updates_for_UMTS | R99 | Gwiho | Updates_for_UMTS |  |  |
| 4575 | 1086.11 | UMTS |  | 261d? | 1999-01-01 A | 1999-12-31 A | 100% | 1999-01-01 | 1999-12-31 | 261d? | start no earlier than 1999-01-01 | N3 | 2088h | 2088h | UMTS | R99 | Gwiho | UMTS |  |  |
| 4576 | 1087 | **UMTS and GSM Features** |  | 261d? | 1999-01-01 A | 1999-12-31 A | 100% | 1999-01-01 | 1999-12-31 | 261d? |  | S1; S2; SMG; T2; N1; N2; N3; N4; R2; R3 | 219240h | 219240h |  | R99 | Alain |  |  |  |
| 4577 | 1087.1 | Multimedia Messaging Service |  | 261d? | 1999-01-01 A | 1999-12-31 A | 100% | 1999-01-01 | 1999-12-31 | 261d? | start no earlier than 1999-01-01 | T2 | 2088h | 2088h | MMS | R99 |  | MMS |  |  |
| 4578 | 1087.2 | Location Services |  | 261d? | 1999-01-01 A | 1999-12-31 A | 100% | 1999-01-01 | 1999-12-31 | 261d? | start no earlier than 1999-01-01 | S1; S2; S3; SMG1; SMG2; SMG12; N1; N2; N4; R2; R3 | 22968h | 22968h | LCS | R99 | Alain | LCS |  |  |
| 4579 | 1087.3 | **Customised Application for Mobile network Enhanced Logic Phase 3** |  | 261d? | 1999-01-01 A | 1999-12-31 A | 100% | 1999-01-01 | 1999-12-31 | 261d? |  | S1; S2; N2; N4 | 18792h | 18792h | CAMEL3 | R99 | Alain | CAMEL3 |  |  |
| 4580 | 1087.3.1 | Global view |  | 261d? | 1999-01-01 A | 1999-12-31 A | 100% | 1999-01-01 | 1999-12-31 | 261d? | start no earlier than 1999-01-01 | S1; S2; N2; N4 | 8352h | 8352h |  | R99 | Alain |  |  |  |
| 4581 | 1087.3.2 | Multiple Subscriber Profile (MSP) based on CAMEL phase 3 |  | 261d? | 1999-01-01 A | 1999-12-31 A | 100% | 1999-01-01 | 1999-12-31 | 261d? | start no earlier than 1999-01-01 | S1 | 2088h | 2088h |  | R99 | Alain |  |  |  |
| 4582 | 1087.4 | Short Message Service enhancements / Enhanced Messaging Service (EMS) |  | 261d? | 1999-01-01 A | 1999-12-31 A | 100% | 1999-01-01 | 1999-12-31 | 261d? | start no earlier than 1999-01-01 | T2 | 2088h | 2088h | EMS | R99 |  | EMS |  |  |
| 4583 | 1087.5 | Mobile Station Execution Environment |  | 261d? | 1999-01-01 A | 1999-12-31 A | 100% | 1999-01-01 | 1999-12-31 | 261d? | start no earlier than 1999-01-01 | S1; SMG1; T2 | 6264h | 6264h | MExE | R99 | Alain | MExE |  |  |
| 4584 | 1087.6 | MS_Classmark |  | 261d? | 1999-01-01 A | 1999-12-31 A | 100% | 1999-01-01 | 1999-12-31 | 261d? | start no earlier than 1999-01-01 | N1 | 2088h | 2088h | MS_Classmark | R99 | Frederic | MS_Classmark |  |  |

Notes:
- 4559: -
- 4560: - / Impacted TSs and TRs: 26.226, 26.230
- 4561: - / Impacted TSs and TRs: 26.231
- 4562: RP#45 work item abandoned/closed (it was never really started)
- 4563: -
- 4564: -
- 4565: - / Impacted TSs and TRs: 22.101
- 4566: - / Impacted TSs and TRs: 22.100
- 4567: Requirement for high quality speech in UMTS Phase 1 but not in R99 / Impacted TSs and TRs: 22.105
- 4568: wid Architecture overview of the GSM-UMTS System, Architecture the GSM-UMTS Platform and New Access Network to Core Network (BSS-NSS) interface / Impacted TSs and TRs: 23.002, 23.008, 23.060, 23.101, 23.110
- 4569: - / Impacted TSs and TRs: 22.011, 22.038, 22.060, 22.078, 22.100, 22.101, 22.105, 22.115, 22.129, 23.002, 23.060, 24.007, 24.008, 25.101, 25.102, 25.104, 25.105, 25.113, 25.123, 25.133, 25.141, 25.142, 25.201, 25.211, 25.212, 25.213, 25.214, 25.215, 25.221, 25.222, 25.223, 25.224,
- 4570: - / Impacted TSs and TRs: 25.307 CR#0002, 0003 Inclusion of release independent RF related information
- 4571: Define the default speech codec for UMTS (both for FDD and TDD). Definition limited to selection of one codec among several existing ones/proposed codecs: GSM AMR, IS127 EVRC, ITU G.729 and MPEG-4 speech codec. / Impacted TSs and TRs: 04.08, 05.01, 05.02, 05.03, 05.05, 05.08, 05.09, 05.09, 05.50, 08.60, 08.61, 11.21, 26.071, 26.073, 26.074, 26.090, 26.091, 26.092, 26.093, 26.094, 26.101, 26.102, 26.103, 26.104, 26.975
- 4572: - / Impacted TSs and TRs: 26.104, 26.110, 26.111, 26.911, 26.912, 26.915
- 4573: - / Impacted TSs and TRs: 26.131, 26.132
- 4574: - / Impacted TSs and TRs: 24.022, 27.001, 29.007
- 4575: - / Impacted TSs and TRs: 27.060, 29.061
- 4576: -
- 4577: MMS allows users to send/receive messages e.g. almost unlimited text length, images, audio and video clips and new content types. R99 only includes the concept. MMS stage 3 is not included in 23.140. Rel-4 adds detailed architecture and protocols. / Impacted TSs and TRs: 22.140, 23.040, 23.140
- 4578: LCS provide ability to localize a terminal / Impacted TSs and TRs: 02.07, 03.71, 04.31, 04.35, 04.71, 05.05, 08.08, 08.31, 08.71, 09.31, 22.071, 23.002, 23.003, 23.007, 23.008, 23.016, 23.018, 23.032, 23.171, 24.007, 24.008, 24.030, 24.080, 25.305, 25.306, 25.331, 25.413, 25.423, 29.002, 29.010
- 4579: CAMEL is a network feature providing mechanisms to support services of operators which are not covered by standardised services, even when roaming outside the HPLMN. / Impacted TSs and TRs: 22.101, 23.008, 23.012, 23.016, 23.018, 23.060, 23.072, 23.078, 23.079, 23.082, 23.093, 29.002, 29.078
- 4580: - / Impacted TSs and TRs: 22.078, 23.078, 29.078
- 4581: MSP is an optional service enabling mobile subscribers to have several profiles associated with a single IMSI, with each profile being a subscription option. Each profile may be used for mobile originated and mobile terminated calls. / Impacted TSs and TRs: 22.097 (Advanced Addressing)
- 4582: SMS for 3G terminals compatible with GSM SMS. Added Enhanced Messaging Service (EMS) allowing small pictures, sounds, animations to be transferred via SMS. / Impacted TSs and TRs: 23.038, 23.039, 23.040, 23.042
- 4583: MExE provides a standardized MS execution environment and ability to negotiate its supported capabilities with a MExE SP. R99 enhances SIM MExE certificate management, security clarifications, QoS and defines two MExE classmarks WAP/Personal-Java based. / Impacted TSs and TRs: 02.57, 22.057, 22.101, 23.057
- 4584: MExE classmark identifies a category of MExE UE supporting MExE functionality with a minimum level of processing, memory, display, and interactive capabilities. Several MExE classmarks may be defined. / Impacted TSs and TRs: 24.008

| ID | WBS | Task | Duration | Start | Finish | Complete | Baseline start | Baseline finish | Baseline duration | Constraint | Resources | Work | Actual work | Acronym | Release | MCC resp | Acronym_3GU_Export | TSG stopped |
| --- | --- | --- | --- | --- | --- | --- | --- | --- | --- | --- | --- | --- | --- | --- | --- | --- | --- | --- |
| 4585 | 1087.7 | **MultiCall** | 261d? | 1999-01-01 A | 1999-12-31 A | 100% | 1999-01-01 | 1999-12-31 | 261d? |  | S1; N1; N2; N4 | 10440h | 10440h | Multicall | R99 | Alain | Multicall |  |
| 4586 | 1087.7.1 | Stage 1 for Multicall | 261d? | 1999-01-01 A | 1999-12-31 A | 100% | 1999-01-01 | 1999-12-31 | 261d? | start no earlier than 1999-01-01 | S1 | 2088h | 2088h |  | R99 | Alain |  |  |
| 4587 | 1087.8 | Virtual Home Environment | 261d? | 1999-01-01 A | 1999-12-31 A | 100% | 1999-01-01 | 1999-12-31 | 261d? | start no earlier than 1999-01-01 | S1; SMG1; S2 | 6264h | 6264h | VHE | R99 | Alain | VHE |  |
| 4588 | 1087.9 | Open Service Access | 261d? | 1999-01-01 A | 1999-12-31 A | 100% | 1999-01-01 | 1999-12-31 | 261d? | start no earlier than 1999-01-01 | S1; S2; N5 | 6264h | 6264h | OSA | R99 | Alain | OSA |  |
| 4589 | 1087.10 | Super Charger mechanism for signalling traffic associated with mobility | 261d? | 1999-01-01 A | 1999-12-31 A | 100% | 1999-01-01 | 1999-12-31 | 261d? | start no earlier than 1999-01-01 | N2; N4 | 4176h | 4176h | Super_Charger | R99 | Kimmo | Super_Charger |  |
| 4590 | 1087.11 | Follow_Me service | 261d? | 1999-01-01 A | 1999-12-31 A | 100% | 1999-01-01 | 1999-12-31 | 261d? | start no earlier than 1999-01-01 | S1; N2; N4 | 6264h | 6264h | Follow_Me | R99 | Alain | Follow_Me |  |
| 4591 | 1087.12 | Wide area network Synchronization and object exchange | 261d? | 1999-01-01 A | 1999-12-31 A | 100% | 1999-01-01 | 1999-12-31 | 261d? | start no earlier than 1999-01-01 | T2 | 2088h | 2088h | SYNC | R99 |  | SYNC |  |
| 4592 | 1087.13 | **R99 Terminal Interfaces** | 261d? | 1999-01-01 A | 1999-12-31 A | 100% | 1999-01-01 | 1999-12-31 | 261d? |  | T2 | 8352h | 8352h |  | R99 |  |  |  |
| 4593 | 1087.13.1 | AT commands for 3GPP | 261d? | 1999-01-01 A | 1999-12-31 A | 100% | 1999-01-01 | 1999-12-31 | 261d? | start no earlier than 1999-01-01 | T2 | 2088h | 2088h |  | R99 |  |  |  |
| 4594 | 1087.13.2 | Physical interfaces | 261d? | 1999-01-01 A | 1999-12-31 A | 100% | 1999-01-01 | 1999-12-31 | 261d? | start no earlier than 1999-01-01 | T2 | 2088h | 2088h |  | R99 |  |  |  |
| 4595 | 1087.13.3 | Multiplexer | 261d? | 1999-01-01 A | 1999-12-31 A | 100% | 1999-01-01 | 1999-12-31 | 261d? | start no earlier than 1999-01-01 | T2 | 2088h | 2088h | MUX MS-TE | R99 |  | MUX MS-TE |  |
| 4596 | 1087.14 | **Bearer Services** | 261d? | 1999-01-01 A | 1999-12-31 A | 100% | 1999-01-01 | 1999-12-31 | 261d? |  | S1; T2; N1; N3 | 41760h | 41760h |  | R99 | Alain |  |  |
| 4597 | 1087.14.1 | **Circuit Switched Bearer Services** | 261d? | 1999-01-01 A | 1999-12-31 A | 100% | 1999-01-01 | 1999-12-31 | 261d? |  | S1; N3 | 16704h | 16704h | Circuit_switched_Bearer_Services | R99 | Alain | Circuit_switched_Bearer_Services |  |
| 4598 | 1087.14.1.1 | Stage 1 for Circuit Switched Bearer Services | 261d? | 1999-01-01 A | 1999-12-31 A | 100% | 1999-01-01 | 1999-12-31 | 261d? | start no earlier than 1999-01-01 | S1 | 2088h | 2088h | CS_Bearerss_in_UMTS | R99 | Alain | CS_Bearerss_in_UMTS |  |
| 4599 | 1087.14.1.2 | CS_Bearers | 261d? | 1999-01-01 A | 1999-12-31 A | 100% | 1999-01-01 | 1999-12-31 | 261d? | start no earlier than 1999-01-01 | N3 | 2088h | 2088h | CS_Bearers | R99 | Gwiho | CS_Bearers |  |
| 4600 | 1087.14.1.3 | CS_Bearerss | 261d? | 1999-01-01 A | 1999-12-31 A | 100% | 1999-01-01 | 1999-12-31 | 261d? | start no earlier than 1999-01-01 | N3 | 2088h | 2088h | CS_Bearerss | R99 | Gwiho | CS_Bearerss |  |
| 4601 | 1087.14.1.4 | CS_Data | 261d? | 1999-01-01 A | 1999-12-31 A | 100% | 1999-01-01 | 1999-12-31 | 261d? | start no earlier than 1999-01-01 | N3 | 2088h | 2088h | CS_Data | R99 | Gwiho | CS_Data |  |
| 4602 | 1087.14.1.5 | CS_Data_Bearers | 261d? | 1999-01-01 A | 1999-12-31 A | 100% | 1999-01-01 | 1999-12-31 | 261d? | start no earlier than 1999-01-01 | N3 | 2088h | 2088h | CS_Data_Bearers | R99 | Gwiho | CS_Data_Bearers |  |
| 4603 | 1087.14.1.6 | Deleted - CN3 poart of Circuit Switched Bearer Services | 261d? | 1999-01-01 A | 1999-12-31 A | 100% | 1999-01-01 | 1999-12-31 | 261d? | start no earlier than 1999-01-01 | N3 | 2088h | 2088h | CSBS | R99 | Gwiho | CSBS | NP-06 |
| 4604 | 1087.14.2 | Frame Tunnelling Mode | 261d? | 1999-01-01 A | 1999-12-31 A | 100% | 1999-01-01 | 1999-12-31 | 261d? | start no earlier than 1999-01-01 | T2; N1; N3 | 6264h | 6264h | FTM | R99 | Gwiho | FTM |  |
| 4605 | 1087.14.3 | Access to ISPs and Intranets – Wireless/Remote access to LANs | 261d? | 1999-01-01 A | 1999-12-31 A | 100% | 1999-01-01 | 1999-12-31 | 261d? | start no earlier than 1999-01-01 | N3 | 2088h | 2088h | Interworking with PDN (DHCP) | R99 | Gwiho | Interworking with PDN (DHCP) |  |
| 4606 | 1087.14.4 | **PHS Internet Access Forum Specification** | 261d? | 1999-01-01 A | 1999-12-31 A | 100% | 1999-01-01 | 1999-12-31 | 261d? |  | S1; N3 | 8352h | 8352h | PIAFS | R99 | Alain | PIAFS |  |
| 4607 | 1087.14.4.1 | Personal Handyphone System Internet Access Forum Standard (PIAFS) | 261d? | 1999-01-01 A | 1999-12-31 A | 100% | 1999-01-01 | 1999-12-31 | 261d? | start no earlier than 1999-01-01 | S1 | 2088h | 2088h |  | R99 | Alain |  |  |
| 4608 | 1087.14.4.2 | Support_of_PIAFS_in_UMTS | 261d? | 1999-01-01 A | 1999-12-31 A | 100% | 1999-01-01 | 1999-12-31 | 261d? | start no earlier than 1999-01-01 | N3 | 2088h | 2088h | Support_of_PIAFS_in_UMTS | R99 | Gwiho | Support_of_PIAFS_in_UMTS |  |

Notes:
- 4585: Multicall allows several simultaneous CS calls with dedicated bearers of independent traffic and performance characteristics. R99 Multicall was defined as a supplementary service limited to one CS bearer to be used for speech at any time. / Impacted TSs and TRs: 22.030, 22.083, 22.087, 23.008, 23.009, 23.016, 23.018, 23.108, 23.135, 24.008, 24.080, 24.135, 29.002, 29.010
- 4586: - / Impacted TSs and TRs: 22.030, 22.083, 22.087
- 4587: Information exists in SP#5-8 reports & in SP-99416,SP-000095,SP 000155. OSA allows service development by operators and 3rd parties by making use of network functionality through open, standardised, secure, extensible and scalable interfaces. / Impacted TSs and TRs: 02.01, 22.105, 22.121,23.127
- 4588: Open Service Architecture became in later Releases Open Service Access. Produced by Parlay, ETSI SPAN (TISPAN), 3GPP SA1 (Stage 1), SA2 (Stage 2) and CN5 (Stage 3), resulting in a single set of standard OSA APIs for the whole development community. / Impacted TSs and TRs: 22.121, 23.127, 29.198, 29.998
- 4589: Super Charger reduces mobility management cost by reducing the volume of location update signalling. It changes subscriber data management associated with inter-VLR and SGSN location updates. It also applies to packet services (SGSN replaces VLR and … / Impacted TSs and TRs: 21.905, 23.007, 23.008, 23.012, 23.016, 23.018, 23.040, 23.060, 23.116, 23.912, 29.002
- 4590: Follow Me enables a mobile subscriber A to manipulate the Follow Me data of a party B in such a way that - under certain conditions - subsequent calls directed to party B will be forwarded to subscriber A. It is PLMN-specific and control based on USSD / Impacted TSs and TRs: 21.905, 22.004, 22.030, 22.082, 22.090, 22.094, 23.090, 24.090, 22.094, 23.011, 23.015, 23.082, 29.002
- 4591: Allows data stored in ME/USIM to be synchronized with the outside world. TS 27.103 defines protocols based upon IrMC level 4 and will evaluate new technologies (XML) for inclusion. From Rel-4 IrMC was replaced by SyncML in 27.103. / Impacted TSs and TRs: 27.103, 27.903
- 4592: -
- 4593: AT commands to control a 3G ME via an external Terminal Equipment (TE), fully compatible with GSM AT commands. R99 adds new AT commands e.g. to control Advanced Speech Call Items (ASCI) services. / Impacted TSs and TRs: 27.005, 27.007
- 4594: Conclusion: 3GPP should not produce any technical specification for terminal interfaces other than radio interface and USIM interface. SDOs could develop own optional physical connector specification based on market requirements / Impacted TSs and TRs: 27.901
- 4595: Multiplexing protocol allowing a number of simultaneous sessions between a MS and a terminal; used to send any data (voice, SMS, USSD, fax etc.). 27.010 describes the protocol, but not the commands or data transported with it. / Impacted TSs and TRs: 27.010
- 4596: -
- 4597: CS and real-time data services provided for interworking with PSTN/ISDN so that user is unaware of access network used (UMTS, GSM or handover between ANs). Transparent(constant delay) & non-transparent(zero error with flow control) services are supported / Impacted TSs and TRs: 22.002, 23.910, 27.001, 29.007
- 4598: CS and real-time data services provided for interworking with PSTN/ISDN so that user is unaware of access network used (UMTS, GSM or handover between ANs). Transparent(constant delay) & non-transparent(zero error with flow control) services are supported / Impacted TSs and TRs: 22.002
- 4599: - / Impacted TSs and TRs: 29.007
- 4600: - / Impacted TSs and TRs: 04.21, 23.910, 27.001, 29.007
- 4601: - / Impacted TSs and TRs: 27.001, 27.002, 27.003, 29.007
- 4602: - / Impacted TSs and TRs: 23.910, 27.001, 29.007
- 4603: No CR or new TS/TR approved under this WI / Impacted TSs and TRs: 23.910, 27.001, 29.007
- 4604: FTM is a type of async non-transparent CS bearer service (22.002). Generic term for HDLC and HDLC-related transmission protocols. Converts async non-transp data stream towards mobile side & sync data stream using X.31 flag stuffing on fixed network side. / Impacted TSs and TRs: 22.002, 27.001, 27.007, 29.007
- 4605: Access to an Intranet or ISP by running DHCP between the TE and a server in the Intranet/ISP domain. / Impacted TSs and TRs: 29.061
- 4606: PIAFS is one type of CS bearer data service (22.002). It refers to async CS tx protocol over ISDN 64 kbit/s unrestricted digital line. Facilitates interworking between PHS-MS and UMTS-UE & UMTS-UE and existing PIAFS TA (Terminal Adapter). / Impacted TSs and TRs: 22.002, 27.001, 27.007, 29.007
- 4607: PIAFS was originally standardised by the PHS Internet Access Forum in Japan. More information can be found at: http://www.infopro.or.jp/piaf / Impacted TSs and TRs: 22.002
- 4608: - / Impacted TSs and TRs: 27.001, 27.007, 29.007

| ID | WBS | Task | Duration | Start | Finish | Complete | Baseline start | Baseline finish | Baseline duration | Constraint | Resources | Work | Actual work | Acronym | Release | MCC resp | Acronym_3GU_Export | TSG stopped |
| --- | --- | --- | --- | --- | --- | --- | --- | --- | --- | --- | --- | --- | --- | --- | --- | --- | --- | --- |
| 4609 | 1087.15 | **Universal Integrated Circuit Card (UICC) and Universal Subscriber Identity Module (USIM)** | 261d? | 1999-01-01 A | 1999-12-31 A | 100% | 1999-01-01 | 1999-12-31 | 261d? |  | T3 | 31320h | 31320h | UICC, USIM | R99 | Xavier | UICC, USIM |  |
| 4610 | 1087.15.1 | UICC / Terminal interface; Physical and logical characteristics | 261d? | 1999-01-01 A | 1999-12-31 A | 100% | 1999-01-01 | 1999-12-31 | 261d? | start no earlier than 1999-01-01 | T3 | 2088h | 2088h | UICC | R99 | Xavier | UICC |  |
| 4611 | 1087.15.2 | UICC/(U)SIM enhancements and interworking | 261d? | 1999-01-01 A | 1999-12-31 A | 100% | 1999-01-01 | 1999-12-31 | 261d? | start no earlier than 1999-01-01 | T3 | 2088h | 2088h | UICC99 | R99 | Xavier | UICC1 |  |
| 4612 | 1087.15.3 | Characteristics of the USIM application | 261d? | 1999-01-01 A | 1999-12-31 A | 100% | 1999-01-01 | 1999-12-31 | 261d? | start no earlier than 1999-01-01 | T3 | 2088h | 2088h | USIM | R99 | Xavier | USIM |  |
| 4613 | 1087.15.4 | UICC Application Identifiers | 261d? | 1999-01-01 A | 1999-12-31 A | 100% | 1999-01-01 | 1999-12-31 | 261d? | start no earlier than 1999-01-01 | T3 | 2088h | 2088h | AID, Application_Identifiers | R99 | Xavier | AID, Application_Identifiers |  |
| 4614 | 1087.15.5 | SIM Application Toolkit | 261d? | 1999-01-01 A | 1999-12-31 A | 100% | 1999-01-01 | 1999-12-31 | 261d? | start no earlier than 1999-01-01 | S1; T3 | 4176h | 4176h | SAT | R99 | Alain | SAT |  |
| 4615 | 1087.15.6 | USIM Application Toolkit | 261d? | 1999-01-01 A | 1999-12-31 A | 100% | 1999-01-01 | 1999-12-31 | 261d? | start no earlier than 1999-01-01 | T3 | 2088h | 2088h | USAT | R99 | Xavier | USAT |  |
| 4616 | 1087.15.7 | Bearer Independent Protocol for SAT applications to exchange data over the GSM network | 261d? | 1999-01-01 A | 1999-12-31 A | 100% | 1999-01-01 | 1999-12-31 | 261d? | start no earlier than 1999-01-01 | T3 | 2088h | 2088h | BIP | R99 | Xavier | BIP |  |
| 4617 | 1087.15.8 | Administrative commands and functions for IC cards | 261d? | 1999-01-01 A | 1999-12-31 A | 100% | 1999-01-01 | 1999-12-31 | 261d? | start no earlier than 1999-01-01 | T3 | 2088h | 2088h |  | R99 | Xavier |  |  |
| 4618 | 1087.15.9 | USIM and UICC requirements | 261d? | 1999-01-01 A | 1999-12-31 A | 100% | 1999-01-01 | 1999-12-31 | 261d? | start no earlier than 1999-01-01 | T3 | 2088h | 2088h |  | R99 | Xavier |  |  |
| 4619 | 1087.15.10 | SIM_API | 261d? | 1999-01-01 A | 1999-12-31 A | 100% | 1999-01-01 | 1999-12-31 | 261d? | start no earlier than 1999-01-01 | T3 | 2088h | 2088h | SIM_API | R99 | Xavier | SIM_API |  |
| 4620 | 1087.15.11 | SIM_toolkit_API | 261d? | 1999-01-01 A | 1999-12-31 A | 100% | 1999-01-01 | 1999-12-31 | 261d? | start no earlier than 1999-01-01 | SMG9; T3 | 4176h | 4176h | SIM_toolkit | R99 | Xavier | SIM_toolkit |  |
| 4621 | 1087.15.12 | Deleted - 1.8 Volt SIM ME interface | 261d? | 1999-01-01 A | 1999-12-31 A | 100% | 1999-01-01 | 1999-12-31 | 261d? | start no earlier than 1999-01-01 | SMG9 | 2088h | 2088h | SMIME_1.8V | R99 | Xavier | SMIME_1.8V | TP-06 |
| 4622 | 1087.16 | **USIM/UICC Testing** | 261d? | 1999-01-01 A | 1999-12-31 A | 100% | 1999-01-01 | 1999-12-31 | 261d? |  | T3 | 10440h | 10440h |  | R99 | Xavier |  |  |
| 4623 | 1087.16.1 | Terminal tests for the UICC Interface | 261d? | 1999-01-01 A | 1999-12-31 A | 100% | 1999-01-01 | 1999-12-31 | 261d? | start no earlier than 1999-01-01 | T3 | 2088h | 2088h |  | R99 | Xavier |  |  |
| 4624 | 1087.16.2 | USIM application test specification | 261d? | 1999-01-01 A | 1999-12-31 A | 100% | 1999-01-01 | 1999-12-31 | 261d? | start no earlier than 1999-01-01 | T3 | 2088h | 2088h |  | R99 | Xavier |  |  |
| 4625 | 1087.16.3 | USIM conformance test specification | 261d? | 1999-01-01 A | 1999-12-31 A | 100% | 1999-01-01 | 1999-12-31 | 261d? | start no earlier than 1999-01-01 | T3 | 2088h | 2088h |  | R99 | Xavier |  |  |
| 4626 | 1087.16.4 | SIM toolkit test specification | 261d? | 1999-01-01 A | 1999-12-31 A | 100% | 1999-01-01 | 1999-12-31 | 261d? | start no earlier than 1999-01-01 | T3 | 2088h | 2088h |  | R99 | Xavier |  |  |
| 4627 | 1087.17 | **Security for UMTS and GSM Features** | 261d? | 1999-01-01 A | 1999-12-31 A | 100% | 1999-01-01 | 1999-12-31 | 261d? |  | S3; N2; N4 | 16704h | 16704h | Security | R99 | Mirko | Security |  |
| 4628 | 1087.17.1 | Fraud Information Gathering Service (for connection-orientated services) | 261d? | 1999-01-01 A | 1999-12-31 A | 100% | 1999-01-01 | 1999-12-31 | 261d? | start no earlier than 1999-01-01 | S3 | 2088h | 2088h | FIGS | R99 | Mirko | FIGS |  |
| 4629 | 1087.17.2 | Immediate Service Termination / SECurity Immediate Service Termination | 261d? | 1999-01-01 A | 1999-12-31 A | 100% | 1999-01-01 | 1999-12-31 | 261d? | start no earlier than 1999-01-01 | S3; N2; N4 | 6264h | 6264h | IST, SECIST | R99 | Mirko | IST, SECIST |  |
| 4630 | 1087.17.3 | Core_Network_Security | 261d? | 1999-01-01 A | 1999-12-31 A | 100% | 1999-01-01 | 1999-12-31 | 261d? | start no earlier than 1999-01-01 | N4 | 2088h | 2088h | Core_Network_Security | R99 | Kimmo | Core_Network_Security |  |
| 4631 | 1088 | **GSM Features** | 261d? | 1999-01-01 A | 1999-12-31 A | 100% | 1999-01-01 | 1999-12-31 | 261d? |  | S1; S2; SMG; T2; N1; N2; N3; N4 | 164952h | 164952h |  | R99 | Alain |  |  |
| 4632 | 1088.1 | **Dual Transfer Mode within GSM and GPRS** | 261d? | 1999-01-01 A | 1999-12-31 A | 100% | 1999-01-01 | 1999-12-31 | 261d? |  | SMG; N1 | 10440h | 10440h | DTM | R99 | Frederic | DTM |  |
| 4633 | 1088.1.1 | Class A Dual Transfer Mode | 261d? | 1999-01-01 A | 1999-12-31 A | 100% | 1999-01-01 | 1999-12-31 | 261d? | start no earlier than 1999-01-01 | SMG | 2088h | 2088h | Class_A_Dual_Transfer_Mode_(DTM) | R99 | Frederic | Class_A_Dual_Transfer_Mode_(DTM) |  |
| 4634 | 1088.1.2 | Dual Transfer Mode | 261d? | 1999-01-01 A | 1999-12-31 A | 100% | 1999-01-01 | 1999-12-31 | 261d? | start no earlier than 1999-01-01 | SMG; N1 | 4176h | 4176h |  | R99 | Frederic |  |  |

Notes:
- 4609: For 3G, GSM 11.11 was divided into two parts: a platform comprised of basic physical, electrical and logical specification (31.101) and an application specification (31.102)
- 4610: Defines a generic Terminal/Integrated Circuit Card (ICC) interface. Is independent of 3G USIM application => platform for any IC card application. Ensures interoperability between ICC and terminal independently of manufacturer, card issuer or operator. / Impacted TSs and TRs: 31.101 (Since 10/2000, ETSI EP SCP is responsible for the generic Terminal/Integrated Circuit Card (ICC) interface TS 102 221)
- 4611: Acronym changed from UICC1 / Impacted TSs and TRs: 31.102, 31.900
- 4612: Defines Universal Subscriber Identity Module (USIM) application for 3G telecom network operation & resides on UICC, an IC card specified in 31.101. UICC can be used as a multi-application card: several USIMs and/or other applications can co-exist / Impacted TSs and TRs: 31.102
- 4613: Defines and administers Application IDentifiers (AID) for UICC. AID is used to address an application in the card. Consists of Registered application provider ID (RID) & Proprietary application ID exception (PIX - according to ISO/IEC 7816-5). / Impacted TSs and TRs: 21.111, 31.110
- 4614: - / Impacted TSs and TRs: 11.14, 22.030, 22.100, 22.101
- 4615: Defines UICC - ME interface, and mandatory ME procedures for USAT. Based on GSM 11.14 (SIM Application Toolkit). Commands and procedures defined in USIM and 3G Terminal for using USAT. Service and security requirements defined in 22.100 and 22.101. / Impacted TSs and TRs: 31.111
- 4616: Defines at SIM-ME interface a basic protocol allowing SIM Toolkit applications to determine available bearers and to exchange data by selecting using the most appropriate bearer available (CS data, GPRS, SMS, Unstructured Supplementary Service Data (USSD) / Impacted TSs and TRs: 03.48, 11.10, 11.14
- 4617: Defines function and syntax of administrative commands for telecommunication IC Card used during installation, activation and de-activation of applications. Compliant to ISO/IEC 7816 series. Handed over to ETSI Project Smart Card Platform (SCP) in 2000. / Impacted TSs and TRs: ETSI TS 102 222
- 4618: High level requirements for 3GPP IC card and its interface to 3GPP terminal (USIM&UICC reqs). Service&security reqs in 322.01,22.00. USIM is a 3GPP application on an IC card. Inter-operates with 3GPP terminals and provides access to 3GPP services / Impacted TSs and TRs: 21.111
- 4619: - / Impacted TSs and TRs: 03.19
- 4620: - / Impacted TSs and TRs: 03.48, 11.11, 11.14
- 4621: No CR or new TS/TR approved under this WI / Impacted TSs and TRs: 11.18
- 4622: -
- 4623: Test spec for the interface between UICC and terminal (originally based GSM 11.10-1 clause 27). Ensures UICC - terminal interoperability independently of manufacturer, card issuer or operator. Tests for applications residing on UICC are in 31.121 / Impacted TSs and TRs: 31.120
- 4624: Application test spec originally based on GSM 11.17. Aspects related to UICC administrative management phase are not defined. Any internal technical realisation of either UICC or terminal is only specified where these are reflected over the interface. / Impacted TSs and TRs: 31.121
- 4625: Conformance Test specification for UICC defined in 31.101 with USIM defined in 31.102. / Impacted TSs and TRs: 31.122
- 4626: SIM Application Toolkit (SAT) has major impact on ME design and enhances SIM/ME interface. Contains tests for SIM/ME interface optional features (no network related signalling issues involved). Doesn't form basis for any type approval or regulatory tests. / Impacted TSs and TRs: 11.10-4
- 4627: - / Impacted TSs and TRs: 02.09, 03.20, 21.133, 22.022, 23.003, 23.007, 23.008, 23.012, 23.018, 24.007, 24.008, 24.010, 24.011, 29.002, 29.060, New (33.102, 33.103, 33.105, 33.107, 35.201)
- 4628: HPLMN can monitor its subscribers in VPLMN, which collects info on a defined set of monitored subscribers activities & sends it to HPLMN, which can perform service limitation control eg Operator Determined Barring (ODB) and IST to limit financial exposure / Impacted TSs and TRs: New 22.031, 23.031
- 4629: HPLMN can terminate all activities of its subscriber in VPLMN, if decides (based on info via eg FIGS) that a roaming subscriber is behaving in fraudulent/suspicious way. HPLMN can terminate all subscriber activities including calls in progress. / Impacted TSs and TRs: 03.35, 22.032, 23.008, 23.016, 23.035, 29.002
- 4630: - / Impacted TSs and TRs: 29.002
- 4631: -
- 4632: 2-99-1780 (2-99-H80 from SMG2#32) WID on BSS co-ordination of Radio Resource allocation for class A GPRS services - GSM Radio Access (R99) / Impacted TSs and TRs: 03.55, 03.64, 04.18, 04.60, 05.01, 05.02, 05.08, 08.08, 23.060, 24.007, 24.008
- 4633: - / Impacted TSs and TRs: 05.10
- 4634: - / Impacted TSs and TRs: 03.55, 03.64, 04.18, 05.01, 05.02, 05.08, 24.008

| ID | WBS | Task | Duration | Start | Finish | Complete | Baseline start | Baseline finish | Baseline duration | Constraint | Resources | Work | Actual work | Acronym | Release | MCC resp | Acronym_3GU_Export | TSG stopped | WI rapporteur name | WI rapporteur e-mail |
| --- | --- | --- | --- | --- | --- | --- | --- | --- | --- | --- | --- | --- | --- | --- | --- | --- | --- | --- | --- | --- |
| 4635 | 1088.2 | **General Packet Radio Service enahancements** | 261d? | 1999-01-01 A | 1999-12-31 A | 100% | 1999-01-01 | 1999-12-31 | 261d? |  | S1; S2; SMG1; SMG2; SMG7; N1; N2; N3; N4; T2 | 50112h | 50112h | GPRS enhancements | R99 | Alain | GPRS enhancements |  |  |  |
| 4636 | 1088.2.1 | General Packet Radio Service | 261d? | 1999-01-01 A | 1999-12-31 A | 100% | 1999-01-01 | 1999-12-31 | 261d? | start no earlier than 1999-01-01 | S1; S2; SMG1; SMG2; SMG7; N1; N2; N3; N4; T2 | 20880h | 20880h | GPRS | R99 | Alain | GPRS |  |  |  |
| 4637 | 1088.2.2 | GPRS2 | 261d? | 1999-01-01 A | 1999-12-31 A | 100% | 1999-01-01 | 1999-12-31 | 261d? | start no earlier than 1999-01-01 | SMG1; N2 | 4176h | 4176h | GPRS2 | R99 |  | GPRS2 |  |  |  |
| 4638 | 1088.2.3 | GPRS Tunnelling Protocol enhancement | 261d? | 1999-01-01 A | 1999-12-31 A | 100% | 1999-01-01 | 1999-12-31 | 261d? | start no earlier than 1999-01-01 | N4; N2 | 4176h | 4176h | GTP_enhancement | R99 | Kimmo | GTP_enhancement |  |  |  |
| 4639 | 1088.3 | **Enhanced Data rates for GSM Evolution - Phase 1** | 261d? | 1999-01-01 A | 1999-12-31 A | 100% | 1999-01-01 | 1999-12-31 | 261d? |  | SMG2; SMG1; SMG3; SMG4; SMG7; SMG9; SMG10; N1; N3; T2 | 73080h | 73080h | EDGE - Phase 1 | R99 | Maurice | EDGE - Phase 1 |  |  |  |
| 4640 | 1088.3.1 | Enhanced Data rates for GSM Evolution | 261d? | 1999-01-01 A | 1999-12-31 A | 100% | 1999-01-01 | 1999-12-31 | 261d? | start no earlier than 1999-01-01 | SMG2; SMG1; SMG3; SMG4; SMG7; SMG9; SMG10; N1; N3; T2 | 20880h | 20880h | EDGE | R99 | Maurice | EDGE |  |  |  |
| 4641 | 1088.3.2 | EDGE-Layer1 | 261d? | 1999-01-01 A | 1999-12-31 A | 100% | 1999-01-01 | 1999-12-31 | 261d? | start no earlier than 1999-01-01 | SMG2 | 2088h | 2088h | EDGE-Layer1 | R99 |  | EDGE-Layer1 |  |  |  |
| 4642 | 1088.3.3 | High Speed Circuit Switched Data | 261d? | 1999-01-01 A | 1999-12-31 A | 100% | 1999-01-01 | 1999-12-31 | 261d? | start no earlier than 1999-01-01 | SMG1; SMG2; SMG7 | 6264h | 6264h | HSCSD | R99 |  | HSCSD |  |  |  |
| 4643 | 1088.3.4 | Enhanced Circuit Switched Data - Phase 1 | 261d? | 1999-01-01 A | 1999-12-31 A | 100% | 1999-01-01 | 1999-12-31 | 261d? | start no earlier than 1999-01-01 | S1; SMG | 4176h | 4176h | ECSD | R99 | Alain | ECSD |  |  |  |
| 4644 | 1088.3.5 | EDGE-Enhanced Circuit Switched Data | 261d? | 1999-01-01 A | 1999-12-31 A | 100% | 1999-01-01 | 1999-12-31 | 261d? | start no earlier than 1999-01-01 | SMG2 | 2088h | 2088h | EDGE-ECSD | R99 |  | EDGE-ECSD |  |  |  |
| 4645 | 1088.3.6 | Enhanced GPRS - Phase 1 | 261d? | 1999-01-01 A | 1999-12-31 A | 100% | 1999-01-01 | 1999-12-31 | 261d? | start no earlier than 1999-01-01 | SMG; N1 | 4176h | 4176h | EGPRS | R99 |  | EGPRS |  |  |  |
| 4646 | 1088.3.7 | EDGE-EGPRS | 261d? | 1999-01-01 A | 1999-12-31 A | 100% | 1999-01-01 | 1999-12-31 | 261d? | start no earlier than 1999-01-01 | SMG2 | 2088h | 2088h | EDGE-EGPRS | R99 |  | EDGE-EGPRS |  |  |  |
| 4647 | 1088.3.8 | Packet Flow Context (PFC) | 261d? | 1999-01-01 A | 1999-12-31 A | 100% | 1999-01-01 | 1999-12-31 | 261d? | start no earlier than 1999-01-01 | SMG2 | 2088h | 2088h | PFC | R99 |  | PFC |  |  |  |
| 4648 | 1088.3.9 | Support for EGPRS in ANSI-136 networks and EDGE COMPACT | 261d? | 1999-01-01 A | 1999-12-31 A | 100% | 1999-01-01 | 1999-12-31 | 261d? | start no earlier than 1999-01-01 | SMG | 2088h | 2088h | EDGE-Compact | R99 |  | EDGE-Compact |  |  |  |
| 4649 | 1088.3.10 | EGPRS COMPACT | 261d? | 1999-01-01 A | 1999-12-31 A | 100% | 1999-01-01 | 1999-12-31 | 261d? | start no earlier than 1999-01-01 | SMG | 2088h | 2088h | EGPRS-Compact | R99 |  | EGPRS-Compact |  |  |  |
| 4650 | 1088.3.11 | COMPACT | 261d? | 1999-01-01 A | 1999-12-31 A | 100% | 1999-01-01 | 1999-12-31 | 261d? | start no earlier than 1999-01-01 | SMG; N1 | 4176h | 4176h | COMPACT | R99 |  | COMPACT |  |  |  |
| 4651 | 1088.4 | GSM_400 | 261d? | 1999-01-01 A | 1999-12-31 A | 100% | 1999-01-01 | 1999-12-31 | 261d? | start no earlier than 1999-01-01 | SMG2; SMG7; T2 | 6264h | 6264h | GSM_400 | R99 | Paolo | GSM_400 |  |  |  |
| 4652 | 1088.5 | GSM_450 | 261d? | 1999-01-01 A | 1999-12-31 A | 100% | 1999-01-01 | 1999-12-31 | 261d? | start no earlier than 1999-01-01 | SMG2 | 2088h | 2088h | GSM_450 | R99 |  | GSM_450 |  |  |  |
| 4653 | 1088.6 | GSM_700 | 261d? | 1999-01-01 A | 1999-12-31 A | 100% | 1999-01-01 | 1999-12-31 | 261d? | start no earlier than 1999-01-01 | SMG2 | 2088h | 2088h | GSM_700 | R99 |  | GSM_700 |  |  |  |
| 4654 | 1088.7 | Deleted - GERAN | 261d? | 1999-01-01 A | 1999-12-31 A | 100% | 1999-01-01 | 1999-12-31 | 261d? | start no earlier than 1999-01-01 | SMG2; S2 | 4176h | 4176h | GERAN | R99 | Maurice | GERAN | SP-06 |  |  |
| 4655 | 1089 | **GSM Features transposed to UMTS** | 261d? | 1999-01-01 A | 1999-12-31 A | 100% | 1999-01-01 | 1999-12-31 | 261d? |  | S1; S3; T2; N2; N4 | 31320h | 31320h |  | R99 | Alain |  |  |  |  |
| 4656 | 1089.1 | Cell Broadcast Service | 261d? | 1999-01-01 A | 1999-12-31 A | 100% | 1999-01-01 | 1999-12-31 | 261d? | start no earlier than 1999-01-01 | T2 | 2088h | 2088h | CBS | R99 |  | CBS |  |  |  |
| 4657 | 1089.2 | **GSM mobile number portability euro MNP / North American MNP** | 261d? | 1999-01-01 A | 1999-12-31 A | 100% | 1999-01-01 | 1999-12-31 | 261d? |  | S1; N2; N4 | 10440h | 10440h | MNP | R99 | Alain | MNP |  |  |  |
| 4658 | 1089.2.1 | Mobile Number Portability | 261d? | 1999-01-01 A | 1999-12-31 A | 100% | 1999-01-01 | 1999-12-31 | 261d? | start no earlier than 1999-01-01 | N2; N4 | 4176h | 4176h |  | R99 | Kimmo |  |  |  |  |
| 4659 | 1089.3 | Automatic establishment of roaming relations | 261d? | 1999-01-01 A | 1999-12-31 A | 100% | 1999-01-01 | 1999-12-31 | 261d? | start no earlier than 1999-01-01 | S1 | 2088h | 2088h |  | R99 | Alain |  |  | Telecom Italia | enrico.scarrone@telecomitalia.it |
| 4660 | 1089.4 | Advanced addressing | 261d? | 1999-01-01 A | 1999-12-31 A | 100% | 1999-01-01 | 1999-12-31 | 261d? | start no earlier than 1999-01-01 | S1 | 2088h | 2088h |  | R99 | Alain |  |  |  |  |
| 4661 | 1089.5 | UMTS numbering, addressing and identities | 261d? | 1999-01-01 A | 1999-12-31 A | 100% | 1999-01-01 | 1999-12-31 | 261d? | start no earlier than 1999-01-01 | S1 | 2088h | 2088h |  | R99 | Alain |  |  |  |  |
| 4662 | 1089.6 | Lawful Interception for GSM Features transposed to UMTS | 261d? | 1999-01-01 A | 1999-12-31 A | 100% | 1999-01-01 | 1999-12-31 | 261d? | start no earlier than 1999-01-01 | S3 | 2088h | 2088h | LI | R99 | Mirko | LI |  |  |  |

Notes:
- 4635: GPRS was introduced in Release 97. Release 99 brings a number of essential corrections e.g. on Downlink Power Control, Timing Advance procedure, Cell reselection delay time, PBCCH scheduling, PTCCH mapping, etc. / Impacted TSs and TRs: 05.02, 05.05, 05.08, 05.10, 05.50, 11.21, 23.064, 24.008, 24.060
- 4636: - / Impacted TSs and TRs: 02.60, 03.22, 03.64, 04.18, 04.60, 04.64, 04.65, 05.01, 05.02, 05.05, 05.08, 05.10, 08.08, 08.18, 11.10-1, 11.21, 22.041, 22.060, 23.003, 23.007, 23.060, 23.107, 23.122, 24.007, 24.008, 27.007, 27.060, 29.002, 29.016, 29.018, 29.060, 29.061
- 4637: Introduction of EGPRS (S1) + Introduction of Reserved Service Labels in the APN (N2) / Impacted TSs and TRs: 02.60, 23.003
- 4638: - / Impacted TSs and TRs: 23.003, 23.008, 29.060
- 4639: EDGE is independent of the frequency bands, so it can be deployed e.g. in 900 and 1900 MHz bands. The new physical layer based on 8-PSK modulation is introduced and EGPRS and ECSD facilitate the new modulation in single and multi slot constellation. / Impacted TSs and TRs: 10.59, 02.34, 02.60, 03.30, 05.10, 05.50, 11.26
- 4640: WID in SMG2 331/97, SMG 1147/97, SMG 1148/97 / Impacted TSs and TRs: 02.34, 03.10, 03.20, 03.64, 04.03, 04.04, 04.06, 04.08, 04.18, 04.21, 04.22, 04.60, 04.64, 05.01, 05.02, 05.03, 05.04, 05.05, 05.08, 05.10, 05.50, 07.01, 07.02, 07.03, 08.08, 08.20, 08.58, 08.60, 09.07, 09.18, 11.10-1, 11.11, 11.21, 11.26, 23.034, 24.008,
- 4641: WID in SMG2 331/97, SMG 1147/97, SMG 1148/97 / Impacted TSs and TRs: 05.05, 05.10, 05.50
- 4642: No additional features for R99. / Impacted TSs and TRs: 02.34, 04.18, 11.10-1
- 4643: ECSD supports both transparent and non-transparent services, up to 64 kbit/s and 57.6 kbit/s respectively. See Tdoc SMG2 670/99 ECSD Concept Evaluation for more info / Impacted TSs and TRs: 05.02, 08.58, 22.034
- 4644: - / Impacted TSs and TRs: 05.03
- 4645: - / Impacted TSs and TRs: 02.07, 03.64, 04.14, 04.18, 04.60, 05.05, 05.08, 24.008
- 4646: - / Impacted TSs and TRs: 05.03, 05.05, 05.08
- 4647: - / Impacted TSs and TRs: 04.18
- 4648: Support for EGPRS in ANSI-136 networks and EDGE Compact (for ANSI-136 networks only). COMPACT = Deployment of services in spectrum below 1 MHz / Impacted TSs and TRs: 03.22, 03.30, 03.64, 05.01, 05.02, 05.03, 05.05, 05.08, 05.10
- 4649: COMPACT = Deployment of services in spectrum below 1 MHz / Impacted TSs and TRs: 04.18, 05.02
- 4650: COMPACT = Deployment of services in spectrum below 1 MHz / Impacted TSs and TRs: 03.22, 04.18, 04.60, 05.08, 23.122, 24.008
- 4651: GSM in the 400 MHz bands allows to deploy GSM within frequency bands in the range 450 to 500 MHz, previously used for analogue cellular systems. See Tdoc SMG2 190/99 and 595/99 for further info. / Impacted TSs and TRs: 02.17, 03.22, 03.30, 04.04, 04.18, 04.60, 05.01, 05.02, 05.05, 05.08, 05.10, 05.50, 08.18, 08.58, 11.21, 24.008, 27.007
- 4652: - / Impacted TSs and TRs: 03.22, 03.30, 05.01, 05.05, 05.08
- 4653: - / Impacted TSs and TRs: 05.05
- 4654: No CR or new TS/TR approved under this WI / Impacted TSs and TRs: G2: 04.18 CR#A248 , 04.60 CR#B090
- 4655: -
- 4656: Moved to CT1 at TSG-T closure. Applicability of the Cell Broadcast Service (as defined for GSM network) to 3G networks / Impacted TSs and TRs: 23.041
- 4657: R98 MNP: mobile subscriber ability to change PLMN operator within the same country whilst retaining its original MS ISDN number (MSISDN). IMSI is changed, only MSISDN is kept. R99 adds requirements for North American Service Provider Number Portability. / Impacted TSs and TRs: 22.066
- 4658: - / Impacted TSs and TRs: 23.018, 23.066, 29.002
- 4659: framework for commercial and technical interworking between UMTS Home Environments and Serving Networks who have no direct prior commercial agreements with each other. / Impacted TSs and TRs: 22.101, 22.971
- 4660: - / Impacted TSs and TRs: 22.101, 22.75U, 22.975
- 4661: Also new requirements for Single and Multiple Numbering scheme was added (CR#20 and 21). Deleted the term International Mobile User Identifier (IMUI) and changed IMSI (International Mobile Station Identifier=>International Mobile Subscriber Identity. / Impacted TSs and TRs: 22.101
- 4662: Defines an interception system in UMTS that supports a number of regional interception regulations. Regional interception requirements shall be met in using specific (regional) mediation functions allowing only required information to be transported. / Impacted TSs and TRs: New 33.106, 33.107

| ID | WBS | Task | Duration | Start | Finish | Complete | Baseline start | Baseline finish | Baseline duration | Constraint | Resources | Work | Actual work | Release | MCC resp | Acronym | Acronym_3GU_Export |
| --- | --- | --- | --- | --- | --- | --- | --- | --- | --- | --- | --- | --- | --- | --- | --- | --- | --- |
| 4663 | 1090 | **Charging** | 261d? | 1999-01-01 A | 1999-12-31 A | 100% | 1999-01-01 | 1999-12-31 | 261d? |  | S1; S5 | 8352h | 8352h | R99 | Alain |  |  |
| 4664 | 1090.1 | R99 Charging | 261d? | 1999-01-01 A | 1999-12-31 A | 100% | 1999-01-01 | 1999-12-31 | 261d? | start no earlier than 1999-01-01 | S1 | 2088h | 2088h | R99 | Alain | Charging | Charging |
| 4665 | 1090.2 | R99 OAM Charging Management | 261d? | 1999-01-01 A | 1999-12-31 A | 100% | 1999-01-01 | 1999-12-31 | 261d? | start no earlier than 1999-01-01 | S5 | 2088h | 2088h | R99 | Mirko | OAMCH, CH | OAMCH, CH |
| 4666 | 1091 | **Operations, Administration, Maintenance and Provisioning (OAM&P)** | 261d? | 1999-01-01 A | 1999-12-31 A | 100% | 1999-01-01 | 1999-12-31 | 261d? |  | S5 | 12528h | 12528h | R99 | Mirko | OAM1999 | OAM1999 |
| 4667 | 1091.1 | OAM Principles and High-level Requirements | 261d? | 1999-01-01 A | 1999-12-31 A | 100% | 1999-01-01 | 1999-12-31 | 261d? | start no earlier than 1999-01-01 | S5 | 2088h | 2088h | R99 | Mirko | PR, Princs_&_Reqs_(PR) | PR, Princs_&_Reqs_(PR) |
| 4668 | 1091.2 | OAM Architecture | 261d? | 1999-01-01 A | 1999-12-31 A | 100% | 1999-01-01 | 1999-12-31 | 261d? | start no earlier than 1999-01-01 | S5 | 2088h | 2088h | R99 | Mirko | OAMAR, AR, Telecom_Management_Arch_(AR) | OAMAR, AR, Telecom_Management_Arch_(AR) |
| 4669 | 1091.3 | OAM Configuration Management | 261d? | 1999-01-01 A | 1999-12-31 A | 100% | 1999-01-01 | 1999-12-31 | 261d? | start no earlier than 1999-01-01 | S5 | 2088h | 2088h | R99 | Mirko | OAMCM, CM | OAMCM, CM |
| 4670 | 1091.4 | OAM Fault Management | 261d? | 1999-01-01 A | 1999-12-31 A | 100% | 1999-01-01 | 1999-12-31 | 261d? | start no earlier than 1999-01-01 | S5 | 2088h | 2088h | R99 | Mirko | OAMFM | OAMFM |
| 4671 | 1091.5 | OAM Performance Management | 261d? | 1999-01-01 A | 1999-12-31 A | 100% | 1999-01-01 | 1999-12-31 | 261d? | start no earlier than 1999-01-01 | S5 | 2088h | 2088h | R99 | Mirko | OAMPM, PM | OAMPM, PM |
| 4672 | 1092 | Vocabulary | 261d? | 1999-01-01 A | 1999-12-31 A | 100% | 1999-01-01 | 1999-12-31 | 261d? | start no earlier than 1999-01-01 | S1 | 2088h | 2088h | R99 | Alain | Vocabulary | Vocabulary |
| 4673 | 1093 | Emergency | 261d? | 1999-01-01 A | 1999-12-31 A | 100% | 1999-01-01 | 1999-12-31 | 261d? | start no earlier than 1999-01-01 | S1 | 2088h | 2088h | R99 | Alain | Emergency | Emergency |
| 4674 | 1094 | GSM General Bearer Services (GBS) and interworking scenarios support in UMTS | 261d? | 1999-01-01 A | 1999-12-31 A | 100% | 1999-01-01 | 1999-12-31 | 261d? | start no earlier than 1999-01-01 | S1 | 2088h | 2088h | R99 | Alain | GSM_to_UMTS_Evol | GSM_to_UMTS_Evol |
| 4675 | 1095 | GPRS_Mobile_IP_interworking | 261d? | 1999-01-01 A | 1999-12-31 A | 100% | 1999-01-01 | 1999-12-31 | 261d? | start no earlier than 1999-01-01 | N3 | 2088h | 2088h | R99 |  | GPRS_Mobile_IP_interworking | GPRS_Mobile_IP_interworking |
| 4676 | 1096 | GSM/UMTS interworking | 261d? | 1999-01-01 A | 1999-12-31 A | 100% | 1999-01-01 | 1999-12-31 | 261d? | start no earlier than 1999-01-01 | N1; N2; N4; R3; S1; SMG | 12528h | 12528h | R99 | Frederic | 2G3Ginterworking | 2G3Ginterworking |
| 4677 | 1097 | Handover | 261d? | 1999-01-01 A | 1999-12-31 A | 100% | 1999-01-01 | 1999-12-31 | 261d? | start no earlier than 1999-01-01 | S1; SMG2; N1; N2; N4 | 10440h | 10440h | R99 | Alain | Handover | Handover |
| 4678 | 1098 | 2G3Ghandover | 261d? | 1999-01-01 A | 1999-12-31 A | 100% | 1999-01-01 | 1999-12-31 | 261d? | start no earlier than 1999-01-01 | SMG2 | 2088h | 2088h | R99 |  | 2G3Ghandover | 2G3Ghandover |
| 4679 | 1099 | Service Provider Name Indication | 261d? | 1999-01-01 A | 1999-12-31 A | 100% | 1999-01-01 | 1999-12-31 | 261d? | start no earlier than 1999-01-01 | S1 | 2088h | 2088h | R99 | Alain | SPANME | SPANME |
| 4680 | 1100 | Data & Data_CleanUp | 261d? | 1999-01-01 A | 1999-12-31 A | 100% | 1999-01-01 | 1999-12-31 | 261d? | start no earlier than 1999-01-01 | SMG1 | 2088h | 2088h | R99 |  | Data, Data_CleanUp | Data, Data_CleanUp |
| 4681 | 1101 | Unstructured Supplementary Service Data (USSD) | 261d? | 1999-01-01 A | 1999-12-31 A | 100% | 1999-01-01 | 1999-12-31 | 261d? | start no earlier than 1999-01-01 | SMG1; N4 | 4176h | 4176h | R99 | Kimmo | USSD | USSD |
| 4682 | 1102 | Man-Machine Interface (MMI) of the User Equipment (UE) | 261d? | 1999-01-01 A | 1999-12-31 A | 100% | 1999-01-01 | 1999-12-31 | 261d? | start no earlier than 1999-01-01 | S1 | 2088h | 2088h | R99 | Alain | MMI | MMI |
| 4683 | 1103 | Network Identity and Timezone (NITZ) | 261d? | 1999-01-01 A | 1999-12-31 A | 100% | 1999-01-01 | 1999-12-31 | 261d? | start no earlier than 1999-01-01 | SMG1; SMG3 | 4176h | 4176h | R99 | Alain | NITZ | NITZ |
| 4684 | 1104 | Deleted - Operator Determined Barring for Packet Oriented Services | 261d? | 1999-01-01 A | 1999-12-31 A | 100% | 1999-01-01 | 1999-12-31 | 261d? | start no earlier than 1999-01-01 | S1 | 2088h | 2088h | R99 | Alain | ODB_Enh. | ODB_Enh. |
| 4685 | 1105 | Packet Flow Management | 261d? | 1999-01-01 A | 1999-12-31 A | 100% | 1999-01-01 | 1999-12-31 | 261d? | start no earlier than 1999-01-01 | SMG2 | 2088h | 2088h | R99 |  | Packet_Flow_Management | Packet_Flow_Management |
| 4686 | 1106 | GPRS_Point-To-Multipoint Group call | 261d? | 1999-01-01 A | 1999-12-31 A | 100% | 1999-01-01 | 1999-12-31 | 261d? | start no earlier than 1999-01-01 | SMG1 | 2088h | 2088h | R99 |  | GPRS_PTMG | GPRS_PTMG |

Notes:
- 4663: -
- 4664: - / Impacted TSs and TRs: 22.115, 23.121
- 4665: - / Impacted TSs and TRs: 32.005, 32.015
- 4666: -
- 4667: - / Impacted TSs and TRs: 32.101
- 4668: - / Impacted TSs and TRs: 32.101, 32.102
- 4669: - / Impacted TSs and TRs: 32.106, 32.106-1, 32.106-2, 32.106-3, 32.106-4, 32.106-5, 32.106-6, 32.106-7, 32.106-8
- 4670: - / Impacted TSs and TRs: 32.111, 32.111-1, 32.111-2, 32.111-3, 32.111-4
- 4671: - / Impacted TSs and TRs: 12.04, 32.104
- 4672: - / Impacted TSs and TRs: 21.905
- 4673: - / Impacted TSs and TRs: 22.101
- 4674: UMTS shall support GSM General Bearer Services (GBS) and interworking scenarios as specified in 02.02 / Impacted TSs and TRs: 22.105
- 4675: - / Impacted TSs and TRs: 29.061
- 4676: - / Impacted TSs and TRs: 03.22, 04.18, 04.60, 05.02, 05.08, 05.10, 08.08, 08.18, 08.58, 09.08, 22.011, 23.003, 23.009, 23.014, 23.034, 23.122, 24.007, 24.008, 24.011, 24.080, 29.108
- 4677: - / Impacted TSs and TRs: 04.18, 08.08, 08.58, 22.129, 23.009, 29.002, 29.010
- 4678: - / Impacted TSs and TRs: 04.18, 04.60, 05.02, 05.08, 05.10, 08.08, 29.010
- 4679: Service Provider Name Indication included in R98 (02.07) was not carried into R99 (22.101), but is in the SIM/USIM specification for R99 / Impacted TSs and TRs: 22.101
- 4680: - / Impacted TSs and TRs: 02.01, 02.02, 02.04, 02.34
- 4681: No additional features for R99. / Impacted TSs and TRs: 02.04, 02.90, 23.090, 29.002
- 4682: Data services streamlining + Support for Anonymous Call Rejection / Impacted TSs and TRs: 22.030
- 4683: - / Impacted TSs and TRs: 02.42, 04.08
- 4684: Remove ODB for Packet Oriented Services from R99 / Impacted TSs and TRs: 22.041
- 4685: - / Impacted TSs and TRs: 08.18
- 4686: - / Impacted TSs and TRs: 02.60

| ID | WBS | Task | Duration | Start | Finish | Complete | Baseline start | Baseline finish | Baseline duration | Constraint | Resources | Work | Actual work | Release | MCC resp | Acronym | Acronym_3GU_Export |
| --- | --- | --- | --- | --- | --- | --- | --- | --- | --- | --- | --- | --- | --- | --- | --- | --- | --- |
| 4687 | 1107 | **Call Forwarding** | 261d? | 1999-01-01 A | 1999-12-31 A | 100% | 1999-01-01 | 1999-12-31 | 261d? |  | SMG1; N2; N4 | 16704h | 16704h | R99 | Kimmo |  |  |
| 4688 | 1107.1 | Call Forwarding enhancements | 261d? | 1999-01-01 A | 1999-12-31 A | 100% | 1999-01-01 | 1999-12-31 | 261d? | start no earlier than 1999-01-01 | N4; N2 | 4176h | 4176h | R99 | Kimmo | CF_enhancements | CF_enhancements |
| 4689 | 1107.2 | Call_Forwarding | 261d? | 1999-01-01 A | 1999-12-31 A | 100% | 1999-01-01 | 1999-12-31 | 261d? | start no earlier than 1999-01-01 | SMG1; N2 | 4176h | 4176h | R99 | Kimmo | Call_Forwarding | Call_Forwarding |
| 4690 | 1107.3 | Call_Forwarding_Enhancements | 261d? | 1999-01-01 A | 1999-12-31 A | 100% | 1999-01-01 | 1999-12-31 | 261d? | start no earlier than 1999-01-01 | N4 | 2088h | 2088h | R99 | Kimmo | Call_Forwarding_Enhancements | Call_Forwarding_Enhancements |
| 4691 | 1108 | **Quality of Service** | 261d? | 1999-01-01 A | 1999-12-31 A | 100% | 1999-01-01 | 1999-12-31 | 261d? |  | S2; T2; N1; N2; N4 | 31320h | 31320h | R99 | Maurice |  |  |
| 4692 | 1108.1 | End-to-end UMTS Quality of Service management | 261d? | 1999-01-01 A | 1999-12-31 A | 100% | 1999-01-01 | 1999-12-31 | 261d? | start no earlier than 1999-01-01 | S2; T2; N1; N2; N4 | 10440h | 10440h | R99 | Maurice | QoS | QoS |
| 4693 | 1108.2 | End-to-end QoS for PS Domain including IMS | 261d? | 1999-01-01 A | 1999-12-31 A | 100% | 1999-01-01 | 1999-12-31 | 261d? | start no earlier than 1999-01-01 | S2 | 2088h | 2088h | R99 | Maurice | E2EQoS99 | E2EQoS |
| 4694 | 1108.3 | GPRS-enhanced_QoS | 261d? | 1999-01-01 A | 1999-12-31 A | 100% | 1999-01-01 | 1999-12-31 | 261d? | start no earlier than 1999-01-01 | T2 | 2088h | 2088h | R99 |  | GPRS-enhanced_QoS | GPRS-enhanced_QoS |
| 4695 | 1108.4 | QoS_enhancements | 261d? | 1999-01-01 A | 1999-12-31 A | 100% | 1999-01-01 | 1999-12-31 | 261d? | start no earlier than 1999-01-01 | N2; N1; N4 | 6264h | 6264h | R99 | Kimmo | QoS_enhancements | QoS_enhancements |
| 4696 | 1109 | Support of Localised Service Area | 261d? | 1999-01-01 A | 1999-12-31 A | 100% | 1999-01-01 | 1999-12-31 | 261d? | start no earlier than 1999-01-01 | SMG2; SMG3; SMG7; N2 | 8352h | 8352h | R99 | Maurice | SoLSA | SoLSA |
| 4697 | 1110 | Transcoder_location | 261d? | 1999-01-01 A | 1999-12-31 A | 100% | 1999-01-01 | 1999-12-31 | 261d? | start no earlier than 1999-01-01 | S2 | 2088h | 2088h | R99 | Maurice | Transcoder_location | Transcoder_location |
| 4698 | 1111 | Antenna_test_methods | 261d? | 1999-01-01 A | 1999-12-31 A | 100% | 1999-01-01 | 1999-12-31 | 261d? | start no earlier than 1999-01-01 | SMG2 | 2088h | 2088h | R99 |  | Antenna_test_methods | Antenna_test_methods |
| 4699 | 1112 | WBAMR / high quality speech in UMTS Phase 1 but not in R99 | 261d? | 1999-01-01 A | 1999-12-31 A | 100% | 1999-01-01 | 1999-12-31 | 261d? | start no earlier than 1999-01-01 | S1 | 2088h | 2088h | R99 | Alain | WBAMR | WBAMR |
| 4700 | 1113 | **Codec** | 261d? | 1999-01-01 A | 1999-12-31 A | 100% | 1999-01-01 | 1999-12-31 | 261d? |  | S4 | 27144h | 27144h | R99 | Paolo |  |  |
| 4701 | 1113.1 | **Codecs for Multimedia Telephony Service** | 261d? | 1999-01-01 A | 1999-12-31 A | 100% | 1999-01-01 | 1999-12-31 | 261d? |  | S4 | 14616h | 14616h | R99 | Paolo | Codec_for_Multimedia_Telephony | Codec_for_Multimedia_Telephony |
| 4702 | 1113.1.1 | Codecs for Multimedia Telephony Service | 261d? | 1999-01-01 A | 1999-12-31 A | 100% | 1999-01-01 | 1999-12-31 | 261d? | start no earlier than 1999-01-01 | S4 | 2088h | 2088h | R99 | Paolo | Multimedia_Codec | Multimedia_Codec |
| 4703 | 1113.1.2 | Codecs for Multimedia Telephony Service | 261d? | 1999-01-01 A | 1999-12-31 A | 100% | 1999-01-01 | 1999-12-31 | 261d? | start no earlier than 1999-01-01 | S4 | 2088h | 2088h | R99 | Paolo | CSM | CSM |
| 4704 | 1113.1.3 | Codecs for Multimedia Telephony Service | 261d? | 1999-01-01 A | 1999-12-31 A | 100% | 1999-01-01 | 1999-12-31 | 261d? | start no earlier than 1999-01-01 | S4 | 2088h | 2088h | R99 | Paolo | WI2MMC | WI2MMC |
| 4705 | 1113.1.4 | Codecs for Multimedia Telephony Service | 261d? | 1999-01-01 A | 1999-12-31 A | 100% | 1999-01-01 | 1999-12-31 | 261d? | start no earlier than 1999-01-01 | S4 | 2088h | 2088h | R99 | Paolo | Codec(s)_for_CS_MM_Tel._Serv | Codec(s)_for_CS_MM_Tel._Serv |
| 4706 | 1113.1.5 | Codecs for Multimedia Telephony Service | 261d? | 1999-01-01 A | 1999-12-31 A | 100% | 1999-01-01 | 1999-12-31 | 261d? | start no earlier than 1999-01-01 | S4 | 2088h | 2088h | R99 | Paolo | Codec(s)_for_MM_Tel_Service | Codec(s)_for_MM_Tel_Service |
| 4707 | 1113.1.6 | Codecs for Multimedia Telephony Service | 261d? | 1999-01-01 A | 1999-12-31 A | 100% | 1999-01-01 | 1999-12-31 | 261d? | start no earlier than 1999-01-01 | S4 | 2088h | 2088h | R99 | Paolo |  |  |
| 4708 | 1113.2 | QoS for Speech and Multimedia Codec | 261d? | 1999-01-01 A | 1999-12-31 A | 100% | 1999-01-01 | 1999-12-31 | 261d? | start no earlier than 1999-01-01 | S4 | 2088h | 2088h | R99 | Paolo | QoS_for_Speech_&_MM_Codecs_/_AMR | QoS_for_Speech_&_MM_Codecs_/_AMR |
| 4709 | 1113.3 | Tandem Free Operation - Adaptive Multi-Rate codec types | 261d? | 1999-01-01 A | 1999-12-31 A | 100% | 1999-01-01 | 1999-12-31 | 261d? | start no earlier than 1999-01-01 | S4 | 2088h | 2088h | R99 | Paolo | TFOAMR | TFOAMR |
| 4710 | 1113.4 | Noise Suppression for AMR | 261d? | 1999-01-01 A | 1999-12-31 A | 100% | 1999-01-01 | 1999-12-31 | 261d? | start no earlier than 1999-01-01 | S4 | 2088h | 2088h | R99 | Paolo | AMRNS | AMRNS |
| 4711 | 1113.5 | Out-of-Band Transcoder | 261d? | 1999-01-01 A | 1999-12-31 A | 100% | 1999-01-01 | 1999-12-31 | 261d? | start no earlier than 1999-01-01 | N1 | 2088h | 2088h | R99 | Frederic | OoBT | OoBT |
| 4712 | 1113.6 | Out-of-Band Transcoder Control | 261d? | 1999-01-01 A | 1999-12-31 A | 100% | 1999-01-01 | 1999-12-31 | 261d? | start no earlier than 1999-01-01 | N1 | 2088h | 2088h | R99 | Frederic | OoBTC | OoBTC |
| 4713 | 1114 | Advanced Speech Call Items enhancements | 261d? | 1999-01-01 A | 1999-12-31 A | 100% | 1999-01-01 | 1999-12-31 | 261d? | start no earlier than 1999-01-01 | SMG1; SMG2; SMG3; SMG7; SMG9; N1; N4; S1; T2 | 18792h | 18792h | R99 | Alain | ASCI | ASCI |
| 4714 | 1115 | Call Control improvements | 261d? | 1999-01-01 A | 1999-12-31 A | 100% | 1999-01-01 | 1999-12-31 | 261d? | start no earlier than 1999-01-01 | N1 | 2088h | 2088h | R99 | Frederic | CC_Related_items | CC_Related_items |
| 4715 | 1116 | Multimedia | 261d? | 1999-01-01 A | 1999-12-31 A | 100% | 1999-01-01 | 1999-12-31 | 261d? | start no earlier than 1999-01-01 | N1; N3 | 4176h | 4176h | R99 | Frederic | Multimedia | Multimedia |
| 4716 | 1117 | Sub-System Number allocation for RANAP, RNSAP | 261d? | 1999-01-01 A | 1999-12-31 A | 100% | 1999-01-01 | 1999-12-31 | 261d? | start no earlier than 1999-01-01 | N2 | 2088h | 2088h | R99 | Frederic | SSN_allocation | SSN_allocation |
| 4717 | 1118 | Intranet / ISP access with DHCP end-to-end | 261d? | 1999-01-01 A | 1999-12-31 A | 100% | 1999-01-01 | 1999-12-31 | 261d? | start no earlier than 1999-01-01 | N3 | 2088h | 2088h | R99 | Gwiho | ISPaccess | ISPaccess |
| 4718 | 1119 | Point_to_Multipoint_Services | 261d? | 1999-01-01 A | 1999-12-31 A | 100% | 1999-01-01 | 1999-12-31 | 261d? | start no earlier than 1999-01-01 | N3 | 2088h | 2088h | R99 | Gwiho | Point_to_Multipoint_Services | Point_to_Multipoint_Services |
| 4719 | 1120 | Facsimile | 261d? | 1999-01-01 A | 1999-12-31 A | 100% | 1999-01-01 | 1999-12-31 | 261d? | start no earlier than 1999-01-01 | S1 | 2088h | 2088h | R99 | Alain | FAX | FAX |
| 4720 | 1121 | Realtime_NT_FAX_in_UMTS | 261d? | 1999-01-01 A | 1999-12-31 A | 100% | 1999-01-01 | 1999-12-31 | 261d? | start no earlier than 1999-01-01 | N3 | 2088h | 2088h | R99 | Gwiho | Realtime_NT_FAX_in_UMTS | Realtime_NT_FAX_in_UMTS |
| 4721 | 1122 | Gateway Location Register (GLR) - Mobile Application Part (MAP) specification | 261d? | 1999-01-01 A | 1999-12-31 A | 100% | 1999-01-01 | 1999-12-31 | 261d? | start no earlier than 1999-01-01 | N4 | 2088h | 2088h | R99 | Kimmo | GLR | GLR |
| 4722 | 1123 | Multiple Subscriber Profile phase 2 | 261d? | 1999-01-01 A | 1999-12-31 A | 100% | 1999-01-01 | 1999-12-31 | 261d? | start no earlier than 1999-01-01 | S1; N4 | 4176h | 4176h | R99 | Alain | MSP2 | MSP2 |
| 4723 | 1124 | Prepaging | 261d? | 1999-01-01 A | 1999-12-31 A | 100% | 1999-01-01 | 1999-12-31 | 261d? | start no earlier than 1999-01-01 | N2; N4 | 4176h | 4176h | R99 | Kimmo | Prepaging | Prepaging |
| 4724 | 1125 | Re-definition of channel quality measure used for AMR link adaptation for Downlink Advanced Receiver Performance (DARP) MS | 261d? | 1999-01-01 A | 1999-12-31 A | 100% | 1999-01-01 | 1999-12-31 | 261d? | start no earlier than 1999-01-01 | SMG | 2088h | 2088h | R99 |  |  |  |
| 4725 | 1126 | Harmonized Standard | 261d? | 1999-01-01 A | 1999-12-31 A | 100% | 1999-01-01 | 1999-12-31 | 261d? | start no earlier than 1999-01-01 | SMG2 | 2088h | 2088h | R99 |  | HS | HS |
| 4726 | 1127 | Streamlining of specifications | 261d? | 1999-01-01 A | 1999-12-31 A | 100% | 1999-01-01 | 1999-12-31 | 261d? | start no earlier than 1999-01-01 | N3 | 2088h | 2088h | R99 | Gwiho | Streamlining | Streamlining |
| 4727 | 1128 | R99_Service_Clean_up | 261d? | 1999-01-01 A | 1999-12-31 A | 100% | 1999-01-01 | 1999-12-31 | 261d? | start no earlier than 1999-01-01 | N3 | 2088h | 2088h | R99 | Gwiho | R99_Service_Clean_up | R99_Service_Clean_up |

Notes:
- 4687: -
- 4688: No additional features for R99. / Impacted TSs and TRs: 23.078, 23.079, 23.082, 29.002, 29.078
- 4689: - / Impacted TSs and TRs: 02.82, 29.002
- 4690: - / Impacted TSs and TRs: 23.082
- 4691: WID SMG 98-0781 End To End UMTS QoS Management
- 4692: WID SMG 98-0781 End To End UMTS QoS Management / Impacted TSs and TRs: 23.107, 23.907, 24.008
- 4693: Acronym changed from E2EQos / Impacted TSs and TRs: 23.060, 23.170
- 4694: AT-commands for Enhanced QoS Support management / Impacted TSs and TRs: 27.007
- 4695: - / Impacted TSs and TRs: 23.008, 23.016, 24.008, 29.002, 29.060
- 4696: Mechanism which can be used as a platform for providing special tariffs and/or special set of service features for certain subscribers within a regionally restricted area or areas. No additional features for R99. / Impacted TSs and TRs: 04.08, 04.18, 08.08, 11.10-1, 29.002
- 4697: UE location identification: background information and associated primitives 2. Transcoder location at the core network and source depending coding belonging to the non-access stratum. / Impacted TSs and TRs: 23.110
- 4698: - / Impacted TSs and TRs: 03.30
- 4699: Add requirement for high quality speech in UMTS Phase 1 but not in R99 / Impacted TSs and TRs: 22.105
- 4700: -
- 4701: -
- 4702: - / Impacted TSs and TRs: 26.911, 26.104, 26.111
- 4703: - / Impacted TSs and TRs: 26.911, 26.104, 26.111
- 4704: - / Impacted TSs and TRs: 26.911, 26.104, 26.111
- 4705: - / Impacted TSs and TRs: 26.911, 26.104, 26.111
- 4706: - / Impacted TSs and TRs: 26.911, 26.104, 26.111
- 4707: - / Impacted TSs and TRs: 26.911, 26.104, 26.111
- 4708: - / Impacted TSs and TRs: 26.102, 26.912
- 4709: UMTS_AMR2 is default Codec Type in R99 dual_mode terminals / Impacted TSs and TRs: 26.103
- 4710: Combination of the AMR speech codec and the Noise Suppression function. TS 06.77 and TR 06.78 only apply to GSM. They apply to UMTS from Rel-4 onwards, when they were converted to TS 26.077 and TR 26.078. / Impacted TSs and TRs: 06.77, 06.78
- 4711: Transcoder handling in the CN at inter-system handover and relocation + Introduction of UMTS AMR / Impacted TSs and TRs: 23.009, 24.008
- 4712: 24.008 CR#0572 in NP-020220 was approved under this WI / Impacted TSs and TRs: 24.008 CR#0572 in NP-020220
- 4713: - / Impacted TSs and TRs: 02.30, 02.68, 03.68, 03.69, 04.18, 08.08, 11.10-1, 11.11, 23.067, 23.094, 24.008, 24.067, 27.007, 29.002
- 4714: Minor improvements to 24.007 and 24.008 to increase the number of simultaneous calls/sessions from the present 7: the TI value is increased (NP-99441). / Impacted TSs and TRs: 24.007, 24.008
- 4715: - / Impacted TSs and TRs: 24.008, 27.001, 29.007
- 4716: Sub-System Number allocation for Radio Access Network Application Part, Radio Network Subsystem Application Part / Impacted TSs and TRs: 23.003
- 4717: Access to an Intranet/ISP with DHCP end to end / Impacted TSs and TRs: 29.061
- 4718: Support for the IP-Multicast protocol / Impacted TSs and TRs: 29.061
- 4719: - / Impacted TSs and TRs: 22.003, 22.100
- 4720: Asynchronous Interface for real-time NT Fax + Introduction of Asynchronous interface for Real-time non-transparent FAX / Impacted TSs and TRs: 27.001, 27.003
- 4721: - / Impacted TSs and TRs: 29.120
- 4722: - / Impacted TSs and TRs: 22.097, 23.072, 23.083, 23.084, 23.091, 23.093, 23.097
- 4723: - / Impacted TSs and TRs: 23.018, 23.082, 29.002
- 4724: Re-definition of channel quality measure used for AMR link adaptation for DARP MS / Impacted TSs and TRs: 05.09
- 4725: - / Impacted TSs and TRs: 13.21
- 4726: - / Impacted TSs and TRs: 27.060, 29.061
- 4727: - / Impacted TSs and TRs: 03.10, 27.001, 27.002, 27.003, 27.060, 29.007, 29.061

| ID | WBS | Task | Type | Duration | Start | Finish | Complete | Baseline start | Baseline finish | Baseline duration | Constraint | Resources | Work | Actual work | Acronym | Release | MCC resp | Acronym_3GU_Export | Impacted TSs and TRs | TSG stopped | WI rapporteur name | WI rapporteur e-mail |
| --- | --- | --- | --- | --- | --- | --- | --- | --- | --- | --- | --- | --- | --- | --- | --- | --- | --- | --- | --- | --- | --- | --- |
| 4728 | 1129 | **(Small) Technical Enhancements and Improvements for R99** |  | 261d? | 1999-01-01 A | 1999-12-31 A | 100% | 1999-01-01 | 1999-12-31 | 261d? |  | N3 | 6264h | 6264h | TEI | R99 | Gwiho | TEI |  |  |  |  |
| 4729 | 1129.1 | TEI_[CS_Data] |  | 261d? | 1999-01-01 A | 1999-12-31 A | 100% | 1999-01-01 | 1999-12-31 | 261d? | start no earlier than 1999-01-01 | N3 | 2088h | 2088h | TEI_[CS_Data] | R99 | Gwiho | TEI_[CS_Data] |  |  |  |  |
| 4730 | 1129.2 | TEI_[GPRS] |  | 261d? | 1999-01-01 A | 1999-12-31 A | 100% | 1999-01-01 | 1999-12-31 | 261d? | start no earlier than 1999-01-01 | N3 | 2088h | 2088h | TEI_[GPRS] | R99 | Gwiho | TEI_[GPRS] |  |  |  |  |
| 4731 | 1130 | **R99 UE Conformance Testing** |  | 261d? | 1999-01-01 A | 1999-12-31 A | 100% | 1999-01-01 | 1999-12-31 | 261d? |  | R5; T1 | 6264h | 6264h | TEI_Test | R99 | Ingbert | TEI_Test | 34.108, 34.121, 34.122, 34.123-1, 34.123-2, 34.123-3 |  |  |  |
| 4732 | 1130.1 | Deleted - RTEI |  | 261d? | 1999-01-01 A | 1999-12-31 A | 100% | 1999-01-01 | 1999-12-31 | 261d? | start no earlier than 1999-01-01 | T1 | 2088h | 2088h | RTEI | R99 | Ingbert | RTEI | 34.123-1 CR#0650, 0651, 34.123-3 CR#0148, 0149, 0150 | TP-06 |  |  |
| 4733 | 1130.2 | Common test environments for User Equipment (UE); Conformance testing | milestone | 0d? | 1999-01-01 A | 1999-01-01 A | 100% | 1999-01-01 | 1999-01-01 | 0d? | start no earlier than 1999-01-01 | R5; T1 |  |  |  | R99 | Ingbert |  | 34.108 |  |  |  |
| 4734 | 1130.3 | Terminal conformance specification, Radio transmission and reception (FDD) | milestone | 0d? | 1999-01-01 A | 1999-01-01 A | 100% | 1999-01-01 | 1999-01-01 | 0d? | start no earlier than 1999-01-01 | R5; T1 |  |  |  | R99 | Ingbert |  | 34.121 |  |  |  |
| 4735 | 1130.4 | Terminal conformance specification, Radio transmission and reception (TDD) | milestone | 0d? | 1999-01-01 A | 1999-01-01 A | 100% | 1999-01-01 | 1999-01-01 | 0d? | start no earlier than 1999-01-01 | R5; T1 |  |  |  | R99 | Ingbert |  | 34.122 |  |  |  |
| 4736 | 1130.5 | UE conformance specification; Part 1: Protocol conformance specification | milestone | 0d? | 1999-01-01 A | 1999-01-01 A | 100% | 1999-01-01 | 1999-01-01 | 0d? | start no earlier than 1999-01-01 | R5; T1 |  |  |  | R99 | Ingbert |  | 34.123-1 |  |  |  |
| 4737 | 1130.6 | UE conformance specification; Part 2: Implementation Conformance Statement (ICS) specification | milestone | 0d? | 1999-01-01 A | 1999-01-01 A | 100% | 1999-01-01 | 1999-01-01 | 0d? | start no earlier than 1999-01-01 | R5; T1 |  |  |  | R99 | Ingbert |  | 34.123-2 |  |  |  |
| 4738 | 1130.7 | UE conformance specification; Part 3: Abstract test suites (ATSs) | milestone | 0d? | 1999-01-01 A | 1999-01-01 A | 100% | 1999-01-01 | 1999-01-01 | 0d? | start no earlier than 1999-01-01 | R5; T1 |  |  |  | R99 | Ingbert |  | 34.123-3 |  |  |  |
| 4739 | 1131 | Deleted - Dual Tone Multi-Frequency signalling : Support in the whole 3GPP system |  | 261d? | 1999-01-01 A | 1999-12-31 A | 100% | 1999-01-01 | 1999-12-31 | 261d? | start no earlier than 1999-01-01 | N1 | 2088h | 2088h | DTMF | R99 | Frederic | DTMF | 23.014 CR#0004 | NP-06 |  |  |
| 4740 | 1132 | Deleted - Intersystem_Change |  | 261d? | 1999-01-01 A | 1999-12-31 A | 100% | 1999-01-01 | 1999-12-31 | 261d? | start no earlier than 1999-01-01 | SMG | 2088h | 2088h | Intersystem_Change | R99 |  | Intersystem_Change | 04.18 CR#A243 | SMG |  |  |
| 4741 | 1133 | Deleted - Long_Forwardedto_Numbers |  | 261d? | 1999-01-01 A | 1999-12-31 A | 100% | 1999-01-01 | 1999-12-31 | 261d? | start no earlier than 1999-01-01 | N2 | 2088h | 2088h | Long_Forwardedto_Numbers | R99 | Kimmo | Long_Forwardedto_Numbers | 29.002 | NP-06 |  |  |
| 4742 | 1134 | Deleted - RANimp-FSEarlyUE |  | 261d? | 1999-01-01 A | 1999-12-31 A | 100% | 1999-01-01 | 1999-12-31 | 261d? | start no earlier than 1999-01-01 | R3 | 2088h | 2088h | RANimp-FSEarlyUE | R99 | Juha | RANimp-FSEarlyUE | 25.413 CR#0520, 0538, 0565, 0563, 0541, 0540, 0539, 0547 | RP-06 |  |  |
| 4743 | 1135 | Release 1999 Studies |  | 261d? | 1999-01-01 A | 1999-12-31 A | 100% | 1999-01-01 | 1999-12-31 | 261d? |  | S1; T2 | 4176h | 4176h |  | R99 | Alain |  |  |  |  |  |
| 4744 | 1136 | Advanced Addressing/Numbering |  | 261d? | 1999-01-01 A | 1999-12-31 A | 100% | 1999-01-01 | 1999-12-31 | 261d? | start no earlier than 1999-01-01 | S1 | 2088h | 2088h | Numbering | R99 | Alain | Numbering | 22.975 |  | Vodafone | mona.mustapha@vodafone.com |
| 4745 | 1137 | Combined GSM and Mobile IP mobility handling in UMTS IP CN |  | 261d? | 1999-01-01 A | 1999-12-31 A | 100% | 1999-01-01 | 1999-12-31 | 261d? | start no earlier than 1999-01-01 | S2 | 2088h | 2088h |  | R99 | Maurice |  | 23.923 |  |  |  |
| 4746 | 1138 | UE Capabilities Requirements |  | 261d? | 1999-01-01 A | 1999-12-31 A | 100% | 1999-01-01 | 1999-12-31 | 261d? | start no earlier than 1999-01-01 | T2 | 2088h | 2088h | UCR | R99 |  | UCR | 21.904 |  |  |  |
| 4747 | 1139 | Electrical safety requirements and regulations |  | 261d? | 1999-01-01 A | 1999-12-31 A | 100% | 1999-01-01 | 1999-12-31 | 261d? | start no earlier than 1999-01-01 | T2 | 2088h | 2088h |  | R99 |  |  | 34.907 |  |  |  |
| 4748 | 1140 | Specific Absorbtion Rate (SAR) requirements and regulations in different regions |  | 261d? | 1999-01-01 A | 1999-12-31 A | 100% | 1999-01-01 | 1999-12-31 | 261d? | start no earlier than 1999-01-01 | T2 | 2088h | 2088h |  | R99 |  |  | 34.925 |  |  |  |
| 4749 | 1141 | Multi-mode UE issues |  | 261d? | 1999-01-01 A | 1999-12-31 A | 100% | 1999-01-01 | 1999-12-31 | 261d? | start no earlier than 1999-01-01 | T2 | 2088h | 2088h |  | R99 |  |  | 21.810, 21.910 |  |  |  |
| 4750 | 1142 | Provision of fax service in GSM and UMTS |  | 261d? | 1999-01-01 A | 1999-12-31 A | 100% | 1999-01-01 | 1999-12-31 | 261d? | start no earlier than 1999-01-01 | T2 | 2088h | 2088h |  | R99 |  |  | 22.945 |  | Ericsson | peter.bleckert@ericsson.com |
| 4751 | 1143 | Separating Radio Resources and Mobility Management specific parts of the MS Classmark |  | 261d | 1999-01-01 A | 1999-12-31 A | 100% | 1999-01-01 | 1999-12-31 | 261d |  | T2 | 2088h | 2088h |  | R99 |  |  | 23.814 |  |  |  |

Notes:
- 4728: -
- 4729: -
- 4730: -
- 4731: Specifies Conformance Tests for a 3G UE to be recognised as 3GPP-standard compliant. A 3GPP-external body, GCF (Global Certification Forum), delivers certificates to prove that a UE has correctly passed tests and is then conform to the 3GPP standard.
- 4732: No CR or new TS/TR approved under this WI
- 4733: -
- 4734: measurement procedures for the conformance test of the UE that contain transmitting characteristics, receiving characteristics and performance requirements in addition to requirements for support of RRM (Radio Resource Management) in FDD mode.
- 4735: measurement procedures for the conformance test of the UE that contain transmitting characteristics, receiving characteristics and performance requirements in addition to requirements for support of RRM (Radio Resource Management) in TDD mode.
- 4736: TS 34.123, composed of three parts, actually specifies the protocol conformance testing for the 3G UE. Part 1 describes the overall test structure.
- 4737: Part 2 contains the applicability of each test case defined as the Implementation Conformance Statement (ICS) proforma, in compliance with the relevant requirements, and in accordance with the relevant guidance given in ISO/IEC 9646-7 and ETS 300 406.
- 4738: Part 3 specifies the protocol conformance testing in TTCN for the 3G UE at the Uu interface. It defines the TTCN test specification and design considerations in Abstract Test Suites based on the test cases specified in prose in part 1.
- 4739: No CR or new TS/TR approved under this WI
- 4740: No CR or new TS/TR approved under this WI
- 4741: -
- 4742: No CR or new TS/TR approved under this WI
- 4743: -
- 4744: Study on requirements for numbering and addressing for UMTS
- 4745: -
- 4746: Moved to CT1 at TSG-T closure
- 4747: Moved to RAN4 at TSG-T closure. TR summarizes differences between international and national standards relevant to IEC60950 and refers to regulations for conformity assessment due to different regulatory environments in different countries / regions.
- 4748: Moved to RAN4 at TSG-T closure.
- 4749: Moved to CT1 at TSG-T closure. Consequences on roaming capabilities and service availability (e.g. handover) of multi-mode UEs while roaming in various regions with various network configurations. Case studies for each of the possible scenarios in specs
- 4750: CP#27: Moved to C1 on closure of T2; see TP-050062. CP#28: C1->C3
- 4751: CP#27: change of WG as a result of closure of CN and T.
